# Work_plan_3gpp_190315_Rel15_onwrds

Schedule from MS Project, 1999-01-01 to 2125-12-12, A marks actual dates.

## Calendars

- Standard: Mon-Fri 08:00-12:00, 13:00-17:00; Sat-Sun 08:00-17:00. Exceptions (off unless hours are given): 2000-01-15 08:00-12:00, 13:00-17:00, 2009-05-30 08:00-12:00, 13:00-17:00, 2011-08-27 to 2011-08-28 08:00-12:00, 13:00-17:00, 2011-09-24 08:00-12:00, 13:00-17:00, 2012-06-02 08:00-12:00, 13:00-17:00, 2012-09-01 08:00-12:00, 13:00-17:00, 2012-11-18 08:00-12:00, 13:00-17:00, 2012-11-24 08:00-12:00, 13:00-17:00, 2013-02-16 08:00-12:00, 13:00-17:00, 2013-06-02 08:00-12:00, 13:00-17:00, 2013-08-10 to 2013-08-11 08:00-12:00, 13:00-17:00, 2013-09-14 08:00-12:00, 13:00-17:00, 2014-03-01 08:00-12:00, 13:00-17:00, 2014-08-24 08:00-12:00, 13:00-17:00, 2014-09-21 08:00-12:00, 13:00-17:00, 2014-10-05 08:00-12:00, 13:00-17:00, 2016-06-18 08:00-12:00, 13:00-17:00, 2021-12-12 08:00-12:00, 13:00-17:00, 2023-09-09 08:00-12:00, 13:00-17:00, 2024-03-03 08:00-12:00, 13:00-17:00, 2024-03-10 08:00-12:00, 13:00-17:00, 2025-02-02 08:00-12:00, 13:00-17:00, 2026-06-06 08:00-12:00, 13:00-17:00, 2027-06-06 08:00-12:00, 13:00-17:00.

## Resources

| Resource |
| --- |
| NP |
| N1 |
| N2 |
| N3 |
| N4 |
| N5 |
| TP |
| T1 |
| T2 |
| T3 |
| RP |
| R1 |
| R2 |
| R3 |
| R4 |
| SP |
| S1 |
| S2 |
| S3 |
| S4 |
| S5 |
| PCG |
| GP |
| No |
| CN4 |
| ? |
| WG G2 |
| G2 |
| G1 |
| G4 |
| G3 |
| All |
| Generic |
| MLST |
| G5 |
| S3, G2 |
| WG T2 |
| GP,G1 |
| G4,G5 |
| OMA |
| GP-G2 |
| Yes |
| GP, |
| N4, |
| GP, N1 |
| CT5 |
| C5 |
| C1 |
| C4 |
| C3 |
| C6 |
| G1, |
| 4 |
| ct |
| c,s,r |
| CT,RAN,SA |
| G2, |
| G1, G3 |
| CT6 |
| CT1 |
| CT1, CT3, CT4 |
| C1, C3, C4 |
| CP |
| R5 |
| C |
| Rel-8 |
| GP, G2 |
| R1,R4 |
| S5,C1 |
| CT,RAN,SA,GERAN |
| S3,C1,C4 |
| 5 |
| S1,C1,C3,C4,S5 |
| S1,C1,C3,C5 |
| S1,C1,C3,C4 |
| S1,S5 |
| S2,S3 |
| RAN,SA |
| RP,S5 |
| S2,CT |
| S1,CT |
| S1,CT,GERAN |
| S1,C5 |
| S3,CT |
| S4,CT |
| C1,SA |
| S1,S2 |
| S1,S4 |
| S2,S2,S3,CT |
| S2,S3,CT |
| S1,CT,GX |
| S1,S4,CT |
| S2,S2,S3,S5,CT |
| S1,S2,CT |
| S1,S2,S3,CT |
| S1,S2,S3,S5CT |
| S1,S2,S3,S5,CT |
| S2,S5,CT |
| S4,S3 |
| S1,C1 |
| CP,C1 |
| C1,C3 |
| C1,C3,C4 |
| S1,S5,CT |
| C4,C3 |
| CP,RAN,SA,GERAN |
| S1,S2,S3,S5,CP |
| S2,S3,CP |
| S2,CP |
| S1,CP,GX |
| S1,CP |
| S1,S4,CP |
| S1,S2,CP |
| S1,S2,S3,CP |
| S2,S5,CP |
| S3,CP |
| S1,S5,CP |
| RAN,SA,GERAN |
| S1,S2,S3,S5,C1,C3,C4,C6 |
| S2,S3,C1,C3,C4 |
| S2,C4 |
| S2,C1,C3,C4 |
| S2,C1,C4 |
| S2,S3,C1,C4 |
| S1,C1,C4,G2 |
| C1,C4 |
| S1,C1,C3 |
| S1,S4,C1,C3,C4 |
| S1,S2,S3,C1,C3,C4 |
| S2,S5,C3 |
| S1,S2,C1,C4 |
| S2,C1 |
| S2,C1,C3 |
| S3,C1,C3,C4 |
| S1,S5,C1,C3,C4 |
| S2,C3,C4 |
| C3,C1 |
| R2,R4 |
| R2,R5 |
| RP,R5 |
| RP,S5,R5 |
| R1,R5 |
| S1,C1,R5 |
| S1,C1,S4,R5 |
| GERAN |
| G3new |
| G1, G3new |
| C4,C1,C3 |
| R1.R4 |
| R1, R4 |
| R2,R3 |
| C3,C4 |
| S4,C3 |
| S4,C3,C1,C4 |
| S1,S2,C1 |
| S1,S2<C1,C3,C4 |
| S1,S2,C1,C3,C4 |
| S5,C1,C3,C4 |
| GP,C4 |
| C4,C1 |
| S2,S1 |
| RP,SP,GP |
| RP,SP,CP,GP |
| CP,GP,RP,SP |
| GP,C4,S4 |
| S1,C1,C4 |
| S1,S2,C3,C1 |
| R2,R4,R3 |
| CP,GP, RP,SP |
| S2,S1,C1,S5 |
| S2,S1,C1 |
| S1,C1,S4 |
| S1,S2,GP,C4,R2 |
| S1,GP,R2 |
| S1,C6 |
| S1,S2,C1,S4 |
| S2,S3,S5,C1,C3,C4 |
| S2,S5,C1 |
| S2,S3,S5 |
| CP,GP, RP,SP,TP |
| S2,C4,C1 |
| S1,C1,C4,S3 |
| S2,S5 |
| S3,C1 |
| S3,C4 |
| S1,C4 |
| S2,S5,C3,C1 |
| S2,S1,S5,C1,C4 |
| S1,R1,C3 |
| S1,C1,R2 |
| S2,S1,C1,C4 |
| S1,C1,C6 |
| GP,S4,C4,C1,C3 |
| C3,C1,C4 |
| S1,C4,C1 |
| S1,S3 |
| S1,S2,S5,C3,C4 |
| R4,G1 |
| G1,R4 |
| RP,GP |
| R4,GP |
| R3,R2 |
| C6,RP,SP |
| R5,C6 |
| CP,RP,SP |
| RP,SP,CP |
| R3,S5 |
| S1,S2,RP |
| S1,S2,S5,RP |
| S2,S1,RP |
| Rel-9 |
| S3,C6 |
| S1,S2,S3,S5,RP |
| S2,S1,S3 |
| S1,S2,S3 |
| S1,S2,S3,S5 |
| C6,R5 |
| S1,S2,RP,GP |
| S1,S2,S4,S5,RP,GP |
| GP,G2 |
| GP,GP, N1 |
| GP,S2,G1,G2 |
| GP,R2,R3,S2,G1,G2 |
| GP,S2,S5,R2,R3,G2,G1 |
| GP,R3 |
| N4,S2 |
| GP,RP |
| GP,S2,RP |
| G5,G4 |
| G4,R3 |
| S2,R2,R4 |
| S1,S2,R2,R4 |
| GP,S5 |
| S1,S2,S5 |
| R4,R5 |
| R4,R2,R3,R5 |
| S2,S5,N4,RP |
| S1,S2,S3,S5,NP |
| S2,S4,S5 |
| T2,S1,S4,S5 |
| SP,RP |
| S2,RP |
| S1,S2,CP,G2 |
| CP,SP |
| S1,G2 |
| SP,CP |
| S1,S2,S5,C3 |
| S1,C1,S3 |
| G1,G3new |
| C4, C3, C1C4 |
| C4,C3,C1 |
| S1,S2,S3,S5,R2,R3,R4 |
| S1,S2,S3,R2 |
| S2,S3,S5,C4,R2 |
| S1,S5,C1 |
| S1,S2,S3,C1,C3,C4,R2 |
| Ggp |
| S3,S2,C1,C4,G2 G3new |
| R1,R2,R3,R4 |
| R4,R1,R2,R3 |
| R4,R2,R3 |
| S1,C1,C4,R2 |
| R4,R2 |
| S2,C4,R2,R4 |
| S2,C4,R2 |
| S2,S3,S5,C3,C4,R2 |
| S1,S2,S4,T2 |
| S1,S2,S4 |
| S1,S2,S4,R5 |
| S3,S2,C1,C4,G2,G3new |
| GP,C1 |
| S1,S5,C4 |
| S1,S2,S3,S5,R2,R3,R4,GP |
| GP,C4,C3,C1 |
| SMG9 |
| SMG1 |
| SMG2 |
| N3,R5 |
| N1, N2, N4, G1, G2, R3, S1, SMG2 |
| S1,SMG1 |
| SMG1,N4 |
| N1,C1,N4,S1,T2,G2,SMG1,SMG2,SMG3,SMG7,SMG9 |
| SMG1,N2 |
| S1,S2,N2,N4 |
| N4,N2 |
| G1,G2 |
| G1,G2,C1 |
| G1,G2,N1 |
| SMG2, SMG1, SMG3, SMG4, SMG7, SMG9, SMG10, G1, G2, G3, N1, N3, T2 |
| SMG2,G1 |
| S1,G1,G2 |
| SMG1,N1,G1,G2 |
| G2,G1 |
| G1,G2,G3,S1,S2,SMG1,SMG2,SMG7,N1,N2,N3,N4,T2 |
| 23.003, 23.008, 29.060 |
| S1, S2, SMG1, SMG2, SMG12, G2, N1, N2, N4 |
| S1,S2,SMG1,SMG2,SMG12,G2,N1,N2,N4 |
| S1,SMG2,N1,N2,N4 |
| SMG1,T2 |
| S1,N1,N2,N4 |
| S1,S2,N5 |
| SMG2,SMG7,G2,T2 |
| S3,N1,N2,N3 |
| S3,N1,N2,N4 |
| SMG9,T3 |
| SMG2,SMG3,SMG7,G2,N2 |
| SMG2,N1,G1,G2 |
| S1,N2 |
| N1,N3 |
| S2,N1 |
| N1,N2,N4 |
| N2,N1,N4 |
| N2,N4 |
| S1,T3 |
| T2,N3 |
| S3,N2 |
| T2,S1 |
| S1,N4 |
| SMG1,SMG2,SMG7 |
| N1,S1,T1 |
| SMG1,SMG3 |
| N4,S2,N1 |
| S1,S2,SMG1,SMG2,SMG7,G1,G2,G3,N1,N2,N3,N4,T2 |
| SMG1,N3 |
| S1,N3 |
| CP,SP,SMG |
| CP,SP,TP,GP,SMG |
| NP,SP,TP,GP,SMG |
| NP,GP, RP,SP,TP |
| SMG2,SMG1,SMG3,SMG4,SMG7,SMG9,SMG10,G1,G2,G3,N1,N3,T2 |
| S1,N2,N4 |
| S1,S2,S3,C1,C3,C4,R2,R3 |
| R2,R3,R1,R4 |
| R2,R3,R4 |
| R2,R1,R3,R4 |
| S2,C4,R2,R3,R4 |
| S2,C4,R2,R1,R3,R4 |
| S2,S3,S5,C3,C4,R2,R3,R4 |
| R1,R2,R4 |
| R3,R1,R4 |
| S2, |
| S2,G2, |
| S1,S2,G2, |
| S1,S2,G2,R2,R3, |
| S1,S2,C4,G2,R2,R3 |
| S1,S2,N4,G2,R2,R3 |
| S1,S2,SMG1,SMG2,SMG12,G2,N1,N2,N4,R2,R3 |
| S1,SMG1,T2 |
| S1,SMG1,S2 |
| S1,N4,N2 |
| T2,N1,N3 |
| S3,N2,N4 |
| SMG1,SMG2,SMG3,SMG7,SMG9,N1,C1,N4,S1,T2,G2 |
| SMG1,N2,N4 |
| S2,T2,N1,N2,N4 |
| S1,T2 |
| S1,S2,C4 |
| S1,S2,N4,RP |
| S2,N4 |
| S1,S2,N3,N4,RP |
| S1,S2,SMG1,SMG2,SMG12,T2,G2,N1,N2,N4,R2,R3 |
| S1,T2,N1,N3 |
| S1,S2,SMG1,SMG2,SMG12,T2,G2,N1,N2,N3,N4,R2,R3 |
| S1,S2,S3,SMG1,SMG2,SMG12,G2,N1,N2,N4,R2,R3 |
| S1,S2,SMG,G1,G2,G3,N1,N2,N3,N4,T2 |
| S1,S2,SMG,T2,G2,N1,N2,N3,N4,R2,R3 |
| S1,S3,SMG,G1,G2,G3,N1,N2,N3,N4,T2 |
| S1,S3,T2,N2,N4 |
| S1,S2,SMG,T2,G1,G2,G3,N1,N2,N3,N4 |
| G2,S2 |
| T1,R5 |
| R5,T1 |
| S1,S2,S4,T1,R5 |
| S1,S2,S4,S5,T1,RP,GP |
| S1,S2,S3,S5,R2,R3,R4,GP,C1 |
| S1,S2,S3,SMG1,SMG2,SMG12,N1,N2,N4,R2,R3 |
| S1,S2,SMG,T2,N1,N2,N3,N4,R2,R3 |
| NP,SP,TP,SMG |
| S1,S2,SMG,T2,N1,N2,N3,N4 |
| SMG,N1 |
| SMG |
| S1,S2,SMG1,SMG2,SMG7,N1,N2,N3,N4,T2 |
| SMG2,SMG1,SMG3,SMG4,SMG7,SMG9,SMG10,N1,N3,T2 |
| S1,SMG |
| SMG2,SMG7,T2 |
| SMG2,S2 |
| N1,N2,N4,R3,S1,SMG |
| SMG2,SMG3,SMG7,N2 |
| SMG1,SMG2,SMG3,SMG7,SMG9,N1,C1,N4,S1,T2 |
| S1,S2,SMG,N3,N4,RP |
| S1,S2,S4,SMG,N3,N4,RP |
| S2,C1,C4,R2,R1,R3,R4 |
| R2,S2,S4 |
| G3new,R5 |
| GP,R4 |
| S2,S4,R2 |
| SP,GP |
| RP,SP |
| S2,S1,S3,S5 |
| S3,S1 |
| N4,N1,N2,S2 |
| S2,G1,G2,R2,R3 |
| S2,G1,G2 |
| G1,G2,R2,R3 |
| N4,T3 |
| S3,S2,N1,N4,T3,OMA |
| T2,S1,S4,S5,OMA |
| S2,N3 |
| S4,S1 |
| N4,N3,S1 |
| R5,G3new |
| R4,R2,R1 |
| S2,R2 |
| C3, C4,C1 |
| S3,C1,C4,C3 |
| C1,C4,C3 |
| S2,C1,C4,C3 |
| R3,R5 |
| S1,S2,C3 |
| R1,R2 |
| S3,C1,C4,G2,G3new |
| R1,R3 |
| GP,N1 |
| R1,R2,R3 |
| R3,R2,R4 |
| R4,R3 |
| S1,S2,R2,R3 |
| S1,S2,S3,C1,C3,C4,R2,R3,R5 |
| S2,S1,S5 |
| C4, C1 |
| C3, C1, C4 |
| S2,S1,S3,S5,C4,C1 |
| S2,C3,C1,C4 |
| S2,S1,S5,C3 |
| GP,S2,C1 |
| GP,S2,C1,G2 |
| G2,S2,C1 |
| v |
| G3new,G1,G2 |
| G1,G2,C1,G3new |
| S2,S1,S5,C1,C3 |
| C1,C3,C4,R5 |
| R2,R1 |
| S1<S2,N1,R2,R5 |
| S1,S2,N1,R2,R5 |
| S2,R5 |
| S1,S2,S5,R5 |
| S2,C1,C4,R2,R1,R3,R4,R5 |
| S1,S2,S3,S5,NP,R5 |
| S1,S2,S4,S5,RP,R5,GP |
| S1,S2,S3,S5,C1,C6,R2,R3,R4 |
| S1,S2,S3,S5,C1,C6,R2,R3,R4,GP |
| S4,R2 |
| S1,S2,C1,C4,G2 |
| S4,C3,C4 |
| S5,C1,C4 |
| S2,C4,C3,C1 |
| C4, C3, C1 |
| S2,S4,R2,C4,C3,C1 |
| GP1,GP2 |
| GP,GP1,GP2 |
| GP,G1,G2 |
| G2,R3 |
| S1,S2,S3,C1,C3,C4,G2 |
| GP,G1,C1 |
| S1,S2,C4,C3,C1 |
| - |
| GP,G1,G2,G3new |
| S1,S2,S3,C1,C3,C4,G2,R2,R3 |
| S1,S2,C1,C3,C4,G2,R2,R3 |
| C1,C6 |
| GP,G2,C4 |
| S2,C3 |
| R5,R4 |
| C4,GP,G2 |
| S1,S2,C1,C4,G2,R2,R3 |
| R1,R2,R4,S3 |
| S2,S5,C3,C1,C4 |
| S2,S4,C4,C3,C1 |
| S2,S4 |
| S3,S1,S2 |
| S1,S2,S3,C1,R2 |
| S3,S1,S2,C1,R2 |
| S2,C3,S5 |
| S1,S2,C1,C4,C3,G2,R2,R3 |
| S5,C4 |
| S2,S1,C3 |
| C1,C4,C3,C6 |
| S1,S2,C1,C4,C3,C6,G2,R2,R3 |
| R1,R2,R4,S3,C4,C6 |
| R4,R1,R4,R1,R2,R3,R3 |
| S2,R3,R2 |
| S1,S2,S5,CP |
| S1,S3,CP |
| C6,C1 |
| R4,R2,R1,R3 |
| R3,R1,R2 |
| R1,R4,R2,R3 |
| S2,C4,C1,C3 |
| R3,R1,R2,R4 |
| C4,S1 |
| S2,S5,R3,GP, |
| S2,S5,R3,GP |
| S1,S2,S3,S5,C1,C3,C4 |
| S2,S3,S5,C1,C3,C4,C6 |
| S5,S1 |
| 03.06.2011 |
| CT1 CT3, CT4 |
| CT3, |
| CT4 |
| CT3 |
| GP,G2,G1 |
| S5,S1,C1 |
| SP,RP,CP |
| SP,CP,GP,RP |
| R1,R2,R4,R3 |
| R4,R2,R5 |
| R2,R4,R5 |
| R1,R2,R4,S2,S3,C4,C6 |
| C1-IETF |
| S4-IETF |
| C1-IETF, C3-IETF, C4-IETF |
| S3-IETF |
| C4-IETF |
| C1-IETF, C3-IETF |
| S2,S4,C1,R2 |
| S2,S4,C3,C4 |
| S2,S4,C1,C3,R2 |
| S1,S2,C1,IETF |
| S4,IETF |
| C1,C4,IETF |
| S2,S4,C1,C3,R2,IETF |
| S3,C1,C4,C3,IETF |
| S3,C4,IETF |
| C1,IETF |
| S1,S2,S3,S5,C1,C3,C4,C6,IETF |
| S2,S3,C1,C4,IETF |
| S1,S2,C1,C3,C4,IETF |
| C1,C3,C4,IETF |
| S1,S5,C1,C3,C4,IETF |
| C1,C3,IETF |
| S2,C1,C3,C4,IETF |
| S2,S4,C3,C4,IETF |
| S5,C1,C4,IETF |
| S5,C1,C3,C4,IETF |
| S2,S3,S5,C1,C3,C4,IETF |
| S2,IETF |
| S3,C1,C3,C4,IETF |
| S2,S3,C1,C3,C4,IETF |
| S3,S2 |
| S3,S2,C1 |
| S3,S1,S2,C1 |
| S2,S5,N3 |
| S1,S2,S3,S5,N1,N3,N4,T3 |
| S5,N4,R3 |
| S1,S2,S5,C1,C4,C3,C6,G2,R2,R3 |
| S2,N1,N4,R3,GP |
| T2,S3 |
| S3,N4,N1 |
| S2,N3,N4 |
| S3,T2 |
| S2,S1,S3,S5,RP,GP |
| S1,S2,S3,S5,R5 |
| S1,S2,S3,S5,NP,T3,T1,R5 |
| S3,T3 |
| GP,S3 |
| S1,S2,S3,S4,S5,RP,R5,GP |
| N1,N4 |
| S1,S2,S3,S4,N1,N3,N4,OMA |
| S2,C1,C3,C4,G2,R2,R3 |
| S1,C4,C3 |
| S2,S1,C1,C4,IETF |
| C1,C3,C4,C6 |
| C4,C1,C6 |
| S1,S2,S3,C1,C3,C4,C6 |
| S2,S1,C1,C3,C4 |
| S1,S2,C1,C3 |
| C1.IETF |
| C1-IETF,C4-IETF |
| G1,C1 |
| G1,S2,C4 |
| G2,S2,C4 |
| R1,R2,R3,R4,R5 |
| R2,R4,R3,R5 |
| R3,R2,R5 |
| R2,R3,C1,C6 |
| S1,S2,S3,C1,C3,C4,C6,R2,R3 |
| R4,R1 |
| S2,S4,C4,C3,C1,IETF |
| S2,C4,C3 |
| S3.C4,C1 |
| G2,C4 |
| R4,G1,G3new |
| C4,G2 |
| S3,C4,C1 |
| R2,R3,R5 |
| R1,R2,R4,R5 |
| S1,S2,S3,S5,C1,C6,R2,R3,R4,R5,GP |
| S1,C1,C4,R2,R5 |
| S2,S3,S5,C3,C4,R2,R3,R4,R5 |
| R2,R1,R3,R4,R5 |
| S3-IETF, C1-IETF |
| S3-IETF,C1-IETF |
| C1-IETF,C3-IETF |
| S2-IETF |
| S2,S1,C1,C3,C4,IETF |
| 25.101, 25.104, 25.141, 25.317 |
| S1,G2,S2,C1 |
| S1,C1,C4,R2,R3,R5 |
| S5,S2 |
| S4,C3,C4,IETF |
| S4,S3,C3,C4,IETF |
| S4,S3,C3,C4 |
| S4,S3,IETF |
| S1,S2,S3,S5,C1,C3,C4,C6,R2,R3 |
| C1,C4,C6 |
| S1,S2,S5,C1,C4,C6,G2,R2,R3 |
| GP,G1,C1,G3new |
| S2,S5,C1,C3 |
| C4,C3,G2 |
| S2,S1,S5,C3,C1,C4 |
| C3,C4,C1 |
| S2,S1,S5,C3,C4,C1 |
| RAN1 |
| RAN2 |
| RAN3 |
| RAN4 |
| R4,R2,R3, |
| Feasibility Study on LTE Device to Device Communications – Radio Aspects |
| SMG1,SMG2,SMG3,SMG7,SMG9,N1,N4,S1,T2 |
| C3-IETF, C4-IETF |
| S3-IETF,C1-IETF,C3-IETF |
| C3-IETF |
| C3,IETF |
| S2,C1,C4,C3,IETF |
| S1,S2,S3,C1,C3,C4,R2,R3,R5,IETF |
| C1-IETF,C3-IETF,C4-IETF |
| C4,C1,C3,IETF |
| S2,C4,C1,C3,IETF |
| C1,C4,C3,IETF |
| S2,S1,T2,N1,N4,R3,R2 |
| S2,S1,S2,S1,N1,N4 |
| S2,S1,N1,N4 |
| S2,R2,G1 |
| S2,S1,S3,S5,N4,R2,R3,GP |
| S1,S2,N4 |
| S2,OMA |
| S2,N4,OMA |
| S2,S5,N4,R2,R4 |
| S2,S5,N4,R2,R4,OMA |
| GP,R2 |
| S1,S2,GP,R2 |
| G1,G3 |
| S1,G2,R2 |
| S2,S5,N4,R2,R4,R5,OMA |
| SR5 |
| S3,C4,C1,R5 |
| S3,S1,C1 |
| S2,C4,C3,G2 |
| SP,CP,RP |
| S3,R5 |
| GP,G2,G3new |
| S1,S2,S3,S4,S5,N1,N3,RP,R5,GP |
| S1,S2,S3,S4,S5,N1,N3,RP,R5,T1,GP |
| S1,S2,S3,S4,S5,N1,N3,RP,R5,T1,GP,G2,G3new |
| S1,S2,S3,S4,S5,N1,N3,R2,R4,R5,T1,GP,G2,G3new |
| S1,S2,S5,C1,C4,C6,G2,R2,R3,G3new |
| SP,CP,RP,GP |
| G2,G1,G3new |
| G2,G1,C1,G3new |
| RAN |
| R |
| S2,S1,S3,S5,R2 |
| S2,S1,S3,S5,R2,R3 |
| S1,S2,S5,C1,C4,C6,G2,R2,R3,R5,G3new |
| C1,C4,R5,IETF |
| C1,R5 |
| R3,R1 |
| R3,GP |
| S3,IETF |
| S1,S2,S5,C1,C3,C4,C6,R2,R3 |
| S3,C4,C1,C3 |
| C1,C4,S1 |
| C1,C4,R3 |
| R2,R1,R3 |
| R1,R4,R2,R3,R5 |
| RAN5 |
| S2,C4,C1,R3 |
| G1,G2,G3new |
| S4,C1 |
| S4,C4,C1,C3 |
| 14/06/2013 08:00 |
| S2,C1,C3,IETF |
| C3, C1 |
| R3,C4 |
| S2,S1,C1,C3 |
| R3,S2,C4 |
| R% |
| G1,C1,G3new |
| R3,S2,C4,G2 |
| S1,S3,N4 |
| S1,OMA |
| S1,S2,S4,OMA |
| S5,S2,N3 |
| S3,C4,C1,C3,IETF |
| S1,S2,S5,C1,C3,C4,C6,R2,R3,R5 |
| S2,S1,S5<c3 |
| S2,C1,C4,C6 |
| S2,S1,S3,C1,C4,C6 |
| S2,S1,S3,C1 |
| R2,R3,R4,G2,G1,G3new |
| C1,C3,R5 |
| ,C4,C6 |
| S2,S1,S3,C1,C4,C6,R2 |
| S2,S1,S3,C1,C4,C6,R2,R3 |
| S2,S1,S3,C1,C3,C4,C6,R2,R3 |
| S1,S2,S3,IETF |
| S1,S2,S3,C1,C3 |
| S1,S2,S3,C4,C1,C3 |
| C1,S1 |
| C34 |
| S1,S2,S3,C1,C4,IETF |
| IETF |
| SMG12 |
| SMG7 |
| SMG3 |
| SMG4 |
| SMG10 |
| C3-IETF,C4-IETF |
| NP,GP,RP,SP,TP |
| S3,G2 |
| R2,S2 |
| R2,S2,C1 |
| R2,C1 |
| S1` |
| R2,S1,C1 |
| C1-IET |
| 18/06/2014 08:00 |
| C4-IET |
| RAN1 (primary) |
| C3.S2 |
| C3-IET |
| S6 |
| ` |
| SA5 |
| Rel-13 |
| Rel-14 |
| 18/06/2015 |
| SA2 |
| S3-IET |
| SA1 |
| SA4-IETF |
| R6 |
| S3LI |
| ITU-R AH |
| Rel-15 |
| CT1-IETF |
| FRASE |
| SP-180438 |
| SP-180439 |
| SP-180440 |
| SP-180441 |
| SP-180442 |
| SP-180443 |
| SP-180387 |
| SP-180388 |
| SP-180390 |
| SP-180391 |
| S5-IETF |
| ITU-RAH |
| 0% |
| S4_ |

## Schedule

| ID | WBS | Task | Type | Duration | Start | Finish | Complete | Remaining | Total slack | Constraint | Resources | Work | Actual work | Release | Acronym | WI rapporteur name | WI rapporteur e-mail | PCG approved | TSG approved | Impacted TSs and TRs | Status Report |
| --- | --- | --- | --- | --- | --- | --- | --- | --- | --- | --- | --- | --- | --- | --- | --- | --- | --- | --- | --- | --- | --- |
| 1 | 1 | Work Plan 3GPP version January 23rd 2026 |  | 1d? | 2019-03-07 | 2019-03-07 |  |  | 40387.9d |  |  |  |  | Rel-20 |  |  |  |  |  |  |  |
| 2 | 2 | Post TSG#110 version |  | 1d? | 2019-03-07 | 2019-03-07 |  |  | 40387.9d |  |  |  |  | Rel-20 |  |  |  |  |  |  |  |
| 3 | 3 | Next main milestones: Rel-20 5GA St.2: Sept.26 |  | 1d? | 2019-03-07 | 2019-03-07 |  |  | 40387.9d |  |  |  |  | Rel-20 |  |  |  |  |  |  |  |
| 5 | 4 | --- RELEASE 21 --- |  | 1d | 2019-03-07 | 2019-03-07 |  |  | 40387.9d |  |  |  |  | Rel-21 |  |  |  |  |  |  |  |
| 6 | 5 | Study on Requirements Simplification |  | 192.5d | 2025-12-03 | 2026-06-06 |  |  | 37646d | finish no earlier than 2026-06-06 | S1 | 1540h |  | Rel-21 | FS_SIMP | Guttman, Erik, Samsung | erik.guttman@samsung.com. |  |  |  |  |
| 7 | 6 | --- RELEASE 20 --- | milestone | 0d? | 2019-03-07 | 2019-03-07 |  |  | 40388.9d |  |  |  |  | Rel-20 |  |  |  |  |  |  |  |
| 8 | 7 | Study on Modernization of Specification Format and Procedures for 6G |  | 259d | 2025-06-27 | 2026-03-03 |  |  | 37744.2d | finish no earlier than 2026-03-03 | SP | 2072h |  | Rel-20 | FS_6GSpecs | Baker, Matthew, Nokia | matthew.baker@nokia.com | 55 | 108 |  |  |
| 9 | 8 | Rel-20 6G Studies |  | 829d? | 2024-09-04 A | 2026-11-13 | 15% | 704.65d? | 37480.6d |  |  |  |  | Rel-20 |  |  |  |  |  |  |  |
| 10 | 9 | Study on 6G Use Cases and Service Requirements |  | 565.38d | 2024-09-04 A | 2026-03-03 | 80% | 113.08d | 37744.2d | finish no earlier than 2026-03-03 | S1 | 4523h |  | Rel-20 | FS_6G_REQ | Xiaonan Shi, China Mobile | shixiaonan@chinamobile.com | 53 | 105 |  |  |
| 11 | 10 | Study on 6G Scenarios and Requirements |  | 564.25d | 2024-12-08 A | 2026-06-05 | 40% | 338.55d | 37647d | finish no earlier than 2026-06-05 | RP | 4514h |  | Rel-20 | FS_6G_RAN_Scen_Req | CMCC |  | 54 | 106 | 38.914 | RP‑252082 |
| 12 | 11 | Study on Architecture for 6G System |  | 659.62d | 2025-06-05 A | 2027-03-03 | 20% | 583.62d | 37366.4d | finish no earlier than 2027-03-03 | S2 | 5277h |  | Rel-20 | FS_6G_ARC | Malla Reddy Sama, NTT DOCOMO | sama@docomolab-euro.com | 55 | 108 |  |  |
| 13 | 12 | Study on 6G Radio |  | 658.62d | 2025-06-06 A | 2027-03-03 | 12% | 579.59d | 37366.4d | finish no earlier than 2027-03-03 | R1 | 5269h |  | Rel-20 | FS_6G_Radio | NTT DOCOMO |  | 55 | 108 | 38.760-4; 38.760-3; 38.760-2; 38.960; 38.760-1 | RP-253483 |
| 14 | 13 | Study on 6G Application Enablement |  | 570.5d | 2025-12-03 | 2027-06-06 |  |  | 37268d | finish no earlier than 2027-06-06 | S6 | 4564h |  | Rel-20 | FS_6G_APP | Yonatan Shiferaw, KPN | yonatan.shiferaw(@tno.nl |  |  |  |  |
| 15 | 14 | Study on Security for the 6G System |  | 637.75d | 2025-09-29 A | 2027-06-06 | 4% | 612.24d | 37268d | start no earlier than 2025-09-29 | S3 | 5102h |  | Rel-20 | FS_6G_SEC | Todor Gamishev, Orange | todor.gamishev@orange.com |  |  | 33.801-01 |  |
| 16 | 15 | Study on Media Aspects for 6G System |  | 472.12d | 2025-12-03 | 2027-03-03 |  |  | 37366.4d | start no earlier than 2025-12-03 | S4 | 3777h |  | Rel-20 | FS_6G_MED | Thomas Stockhammer, Qualcomm | tsto@qti.qualcomm.com |  |  | 26.870 |  |
| 17 | 16 | Study on Charging Aspects of 6G System |  | 637.75d | 2025-09-29 A | 2027-06-06 | 15% | 553.73d | 37268d | finish no earlier than 2027-06-06 | S5 | 5102h |  | Rel-20 | FS_6G_CH | Zhiwei Mo (China Telecom) | mozw@chinatelecom.cn |  |  |  |  |
| 18 | 17 | Study on 6G Management and Orchestration |  | 570.5d | 2025-12-03 | 2027-06-06 |  |  | 37268d | finish no earlier than 2027-06-06 | S5 | 4564h |  | Rel-20 | FS_6G_OAM | SADEGHI, BAHAR (AT&T) | bs8014@att.com |  |  |  |  |
| 19 | 18 | Study on Lawful Interception for 6G |  | 766.25d | 2025-12-03 | 2027-12-12 |  |  | 37072.2d | finish no earlier than 2027-12-12 | S3LI | 6130h |  | Rel-20 | FS_6G_LI | Tyler Hawbaker, , OTD_US | thawbaker@fbi.gov |  |  |  |  |
| 20 | 19 | Rel-20 Satellite, Non-Terrestrial Networks (NTN) |  | 855.25d | 2019-03-07 | 2021-06-09 |  |  | 39533.6d |  |  |  |  | Rel-20 |  |  |  |  |  |  |  |
| 21 | 20 | **Satellite access - Phase 4** |  | 446.12d | 2024-04-02 A | 2025-06-06 A | 100% |  |  |  |  | 3635h | 3635h | Rel-20 | 5GSAT_Ph4 |  |  | 55 | 108 |  |  |
| 22 | 20.1 | Study on satellite access - Phase 4 |  | 264d | 2024-04-02 A | 2024-12-12 A | 100% |  |  | finish no earlier than 2024-12-12 | S1 | 2112h | 2112h | Rel-20 | FS_5GSAT_Ph4 | Thierry Bérisot, Novamint | tberisot@novamint.com | 52 | 103 | 22.887 |  |
| 23 | 20.2 | Stage 1 for Satellite access - Phase 4 |  | 190.38d | 2024-12-05 A | 2025-06-06 A | 100% |  |  | finish no earlier than 2025-06-06 | S1 | 1523h | 1523h | Rel-20 | 5GSAT_Ph4-REQ | Thierry Bérisot, Novamint, | tberisot@novamint.com | 54 | 106 | 22.261 |  |
| 24 | 21 | Study on Integration of satellite components in the 5G architecture Phase 4 |  | 355.25d | 2025-03-26 A | 2026-03-03 | 85% | 53.29d | 37744.2d | finish no earlier than 2026-03-03 | S2 | 2842h |  | Rel-20 | FS_5GSAT_Ph4_ARC | Hucheng Wang (CATT) | wanghucheng@catt.cn | 54 | 107 |  |  |
| 25 | 22 | Study on application enablement for satellite access enabled 5G services Phase 4 |  | 281.75d | 2025-06-05 A | 2026-03-03 | 50% | 140.88d | 37744.2d | finish no earlier than 2026-03-03 | S6 | 2254h |  | Rel-20 | FS_5GSAT_Ph4_APP | Zhou Zhe, China Telecom, | zhouz11@chinatelecom.cn | 55 | 108 | 23.700-02 |  |
| 26 | 23 | Study on Charging Aspects of satellite access phase 4 |  | 290.88d | 2025-12-03 | 2026-09-09 |  |  | 37547.6d | finish no earlier than 2026-09-09 | S5 | 2327h |  | Rel-20 | FS_5GSAT_Ph4_CH | Yingying Liu (CATT) | liuyingying@cictmobile.com |  |  |  |  |
| 27 | 24 | Study on Security Aspects of Satellite Access in 5G Phase 4 |  | 279.5d | 2025-09-10 A | 2026-06-06 | 50% | 139.75d | 37646d | finish no earlier than 2026-06-06 | S3 | 2236h |  | Rel-20 | FS_5GSAT_Ph4_SEC | Hongil Kim (Qualcomm | hongilk@qti.qualcomm.com | 55 | 109 | 33.700-30 |  |
| 28 | 25 | Indirect Network Sharing on Satellite Access Network |  | 4d | 2024-09-04 A | 2024-09-09 A | 100% |  |  | finish no earlier than 2024-09-09 | S1 | 32h | 32h | Rel-20 | INS_SAT | Qun Wei, China Unicom | weiqun5@chinaunicom.cn | 53 | 105 | 22.261 |  |
| 29 | 26 | MPS support in 3GPP system with satellite |  | 6d | 2024-12-05 A | 2024-12-12 A | 100% |  |  | finish no earlier than 2024-12-12 | S1 | 48h | 48h | Rel-20 | MPS_Sat | Singh, Ray, Peraton Labs, | rsingh@peratonlabs.com | 54 | 106 | 22.153 |  |
| 30 | 27 | Study on GNSS resilient NR-NTN operation |  | 378d | 2025-06-06 A | 2026-06-05 | 50% | 189d | 37647d | finish no earlier than 2026-06-05 | R1 | 3024h |  | Rel-20 | FS_NR_NTN_GNSS_resilient | Thales |  | 55 | 108 | 38.742 | RP-253138 |
| 31 | 28 | Study on Ultra Low Bitrate Speech Codec |  | 453.5d | 2025-03-26 A | 2026-06-06 | 27% | 331.06d | 37646d | start no earlier than 2025-03-26 | S4 | 3628h |  | Rel-20 | FS_ULBC | Xu Jiayi, China Mobile | xujiayi@chinamobile.com | 54 | 107 | 26.940 |  |
| 32 | 29 | Stage 2 of Integration of satellite components in the 5G architecture Phase 4 |  | 290.88d | 2025-12-03 | 2026-09-09 |  |  | 37547.6d | finish no earlier than 2026-09-09 | S2 | 2327h |  | Rel-20 | 5GSAT_Ph4-ARC | Hucheng Wang, CATT | wanghucheng@catt.cn |  |  | 23.401; 23.228; 23.167; 23.203; 23.501; 23.502; 23.503 |  |

Notes:
- 7: -
- 9: -
- 10: 6/3/25: 0%->25; 5/6/25: 25%->66; 12/9/25: 66%->77; 12/12/25: 77%->80
- 11: 6/3/25: FCD:01/03/2026->05/06/2026; Compl:0%->5%; Stat Rep: ->RP-250266; ; 26/3/25: 38.914 added;; 3/4/25: WID:RP-243327->RP-250810; 6/6/25: Compl:5%->10%; Stat Rep: RP-250266->RP-251396; List of Impacted TS & TR updated; ; 18/7/25: WID:RP-250810->RP-2513; 3/12/25: FCD:Sat 06/06/26->Fri 05/06/26; Stat Rep: RP-251396->RP_252082; List of Impacted TS & TR updated;
- 12: 12/9/25: 0%->5; 4/12/25: 5%->20; 11/12/25: WID:SP-250806->SP-251633
- 13: TR 38.9xx (RAN; work done in WGs!), TR 38.8xx (RAN1), TR 38.8xx (RAN2), TR 38.8xx (RAN3), TR 38.8xx (RAN4) ; note: SID shows June 27 as target which would be REL-21 so corrected to March 27 ; 11/9/25: FCD:Wed 03/03/27->Fri 04/06/27; Compl:0%->2%; Stat Re; 7/1/26: 38.760-1 added;
- 14: 12/12/25: FCD:Wed 03/03/->/27; 12/12/25: WID:SP-251688->SP-251705; 6/1/26: WID:SP-251705->SP-251688
- 15: 4/12/25: 0%->4
- 16: 7/1/26: 26.870 added;
- 17: 4/12/25: 0%->15; 12/12/25: WID:SP-251218->SP-251705
- 20: -
- 22: 13/6/24: 0%->30; 4/9/24: 30%->60; 8/1/25: WID:SP-240495->SP-241824; 6/3/25: 60%->85; 5/6/25: 85%->100
- 23: ; 6/3/25: 0%->60; 26/3/25: WID:SP-241822->SP-250386; 26/3/25: FCD:03/02/2025->/25; 5/6/25: 60%->100
- 24: 27/6/25: WID:SP-250400->SP-250787; 12/9/25: 0%->60; 4/12/25: 60%->85; 4/12/25: FCD:Fri 12/12/->/26
- 25: 18/7/25: 23.700-02 added;; 12/9/25: 0%->10; 4/12/25: 10%->50
- 27: 4/12/25: 0%->50
- 29: ; 5/12/24: 0%->100
- 30: compare REL-16 SI FS_NR_NTN_solutions, REL-17 WI NR_NTN_solutions, REL-18 WI NR_NTN_enh, REL-19 WI NR_NTN_Ph3 ; 11/9/25: FCD:Sat 06/06/26->Fri 05/06/26; Compl:0%->10%; Stat Rep: ->RP-251934; ; 29/9/25: WID:RP-251863->RP-251933; 30/9/25: 38.742 added;; 3/; 7/1/26: WID:RP-251933->RP-253137
- 31: 3/4/25: 26.940 added;; 5/6/25: 0%->10; 27/6/25: WID:SP-250378->SP-250635; 12/9/25: 10%->15; 4/12/25: 15%->27

| ID | WBS | Task | Duration | Start | Finish | Complete | Remaining | Total slack | Constraint | Resources | Work | Actual work | Acronym | PCG approved | WI rapporteur name | Release | TSG approved | Status Report | Impacted TSs and TRs | WI rapporteur e-mail |
| --- | --- | --- | --- | --- | --- | --- | --- | --- | --- | --- | --- | --- | --- | --- | --- | --- | --- | --- | --- | --- |
| 33 | 30 | **E-UTRA TN (Terrestrial Network) to NR NTN handover enhancements** | 855.25d | 2025-06-06 | 2027-09-09 |  |  | 37169.8d |  |  | 12111h |  | LTE_TN_NR_NTN_HO | 55 | CATT | Rel-20 | 108 |  |  |  |
| 34 | 30.1 | Core part: E-UTRA TN to NR NTN handover enhancements | 658.62d | 2025-06-06 | 2027-03-03 |  |  | 37366.4d | finish no earlier than 2027-03-03 | R2 | 5269h |  | LTE_TN_NR_NTN_HO-Core | 55 | CATT | Rel-20 | 108 | RP-253454 |  |  |
| 35 | 30.2 | Perf. Part: E-UTRA TN to NR NTN handover enhancements | 855.25d | 2025-06-06 | 2027-09-09 |  |  | 37169.8d | finish no earlier than 2027-09-09 | R4 | 6842h |  | LTE_TN_NR_NTN_HO-Perf | 55 | CATT | Rel-20 | 108 | RP-253454 |  |  |
| 36 | 31 | **NTN for IoT Phase 4** | 3022.5d | 2019-03-07 A | 2027-03-03 | 8% | 2780.71d | 37366.4d |  |  | 24180h |  | IoT_NTN_Ph4 | 55 | vivo | Rel-20 | 108 |  |  |  |
| 37 | 31.1 | Core part: NTN for IoT Phase 4 | 3022.5d | 2019-03-07 A | 2027-03-03 | 8% | 2780.7d | 37366.4d | finish no earlier than 2027-03-03 | R2 | 24180h |  | IoT_NTN_Ph4-Core | 55 | vivo | Rel-20 | 108 | RP-253260 |  |  |
| 38 | 32 | **Enhanced requirements for NR NTN and IoT NTN Phase 2** | 756.75d | 2025-09-09 A | 2027-09-09 | 6% | 708.48d | 37169.8d |  | R4 | 16589h | 386.18h | NR_IoT_NTN_req_Ph2 | 55 | Mediatek | Rel-20 | 109 |  |  |  |
| 39 | 32.1 | Core part: Enhanced requirements for NR NTN and IoT NTN Phase 2 | 560.12d | 2025-09-09 A | 2027-03-03 | 15% | 476.11d | 37366.4d | finish no earlier than 2027-03-03 | R4 | 4481h |  | NR_IoT_NTN_req_Ph2-Core | 55 | Mediatek | Rel-20 | 109 | RP-253694 |  |  |
| 40 | 32.2 | Perf. part: Enhanced requirements for NR NTN and IoT NTN Phase 2 | 756.75d | 2025-09-09 | 2027-09-09 |  |  | 37169.8d | finish no earlier than 2027-09-09 | R4 | 6054h |  | NR_IoT_NTN_req_Ph2-Perf | 55 | Mediatek | Rel-20 | 109 | RP-253694 |  |  |
| 41 | 33 | Rel-20 Internet of Things (IoT), Ambient power-enabled IoT (AmbientIoT), RedCap, MTC | 38436d? | 2024-05-05 | 2125-12-12 |  |  | 0d | start no earlier than 2024-05-05 |  |  |  |  |  |  | Rel-20 |  |  |  |  |
| 42 | 34 | MPS Enhancements for IoT | 175d | 2025-06-27 | 2025-12-12 |  |  | 37828.2d | start no earlier than 2025-06-27 | S2 | 1400h |  | MPS_IOT-ARC | 55 | Hala Mowafy, (Peraton Labs) | Rel-20 | 108 |  | 23.401; 23.682 | hala.mowafy@peratonlabs.com |
| 43 | 35 | Study on Architecture support of AmbientIoT - Phase 2 | 281.75d | 2025-06-05 A | 2026-03-03 | 75% | 70.44d | 37744.2d | finish no earlier than 2026-03-03 | S2 | 2254h |  | FS_AmbientIoT_Ph2_ARC | 55 | Runze ZHOU, huawei | Rel-20 | 108 |  |  | zhourunze@huawei.com |
| 44 | 36 | Study on application enablement for Ambient IoT services Phase 2 | 281.75d | 2025-06-05 A | 2026-03-03 | 70% | 84.53d | 37744.2d | finish no earlier than 2026-03-03 | S6 | 2254h |  | FS_AmbientIoT_Ph2_APP | 55 | Liping Wu, CATT | Rel-20 | 108 |  | 23.700-26 | wuliping@cictmobile.com |
| 45 | 37 | Study on enhancements for solutions for Ambient IoT in NR outdoor for active devices | 2644.62d | 2019-03-07 A | 2026-03-03 | 75% | 661.16d | 37744.2d | finish no earlier than 2026-03-03 | R1 | 21157h |  | FS_Ambient_IoT_Outdoor_Active | 55 | LG Electronics | Rel-20 | 108 | RP-253393 |  |  |
| 46 | 38 | **Solutions for Ambient IoT in NR Phase 2** | 855.25d | 2025-06-06 A | 2027-09-09 | 2% | 836.65d | 37169.8d |  |  | 12111h |  | Ambient_IoT_Solutions_Ph2 | 55 | Huawei | Rel-20 | 108 |  |  |  |
| 47 | 38.1 | Core part: Solutions for Ambient IoT in NR Phase 2 | 658.62d | 2025-06-06 A | 2027-03-03 | 5% | 625.69d | 37366.4d | finish no earlier than 2027-03-03 | R1 | 5269h |  | Ambient_IoT_Solutions_Ph2-Core | 55 | Huawei | Rel-20 | 108 | RP-253109 |  |  |
| 48 | 38.2 | Perf. Part: Solutions for Ambient IoT in NR Phase 2 | 855.25d | 2025-06-06 | 2027-09-09 |  |  | 37169.8d | finish no earlier than 2027-09-09 | R4 | 6842h |  | Ambient_IoT_Solutions_Ph2-Perf | 55 | Huawei | Rel-20 | 108 | RP-253109 |  |  |
| 49 | 39 | See also "NTN for IoT Phase 4" (UID 1080090) | 1d | 2019-03-07 | 2019-03-07 |  |  | 40387.9d |  |  |  |  |  |  |  | Rel-20 |  |  |  |  |
| 50 | 40 | Rel-20 AIML (Artificial Intelligence/Machine Learning) | 829d? | 2024-04-02 A | 2026-06-11 |  | 829d? | 37641.1d | finish no earlier than 2027-06-06 |  |  |  |  |  |  | Rel-20 |  |  |  |  |
| 51 | 41 | Study on AIMLE Service Security | 181.25d | 2025-09-10 A | 2026-03-03 | 60% | 72.5d | 37744.2d | finish no earlier than 2026-03-03 | S3 | 1450h |  | FS_AIMLE_SEC | 55 | Sheeba Backia Mary Baskaran, Lenovo | Rel-20 | 109 |  | 33.786 | smary@lenovo.com |
| 52 | 42 | Study on Security for Core Network Enhanced Support for Artificial Intelligence (AI) / Machine Learning (ML) Phase 2 | 181.25d | 2025-09-10 A | 2026-03-03 | 40% | 108.75d | 37744.2d | finish no earlier than 2026-03-03 | S3 | 1450h |  | FS_AIML_CN_Ph2_SEC | 55 | samir.ferdi(InterDigital, | Rel-20 | 109 |  | 33.785 | samir.ferdi@interdigital.com) |
| 53 | 43 | Study on Core Network Enhanced Support for AIML Phase 2 | 271.25d | 2025-03-26 A | 2025-12-12 | 89% | 29.84d | 37828.2d | finish no earlier than 2025-12-12 | S2 | 2170h |  | FS_AIML_CN_Ph2 | 54 | Xiaobo Wu, vivo | Rel-20 | 107 |  |  | xiaobo.wu@vivo.com |
| 54 | 44 | Study on AIML for NG-RAN Phase 3 | 280.75d | 2025-06-06 A | 2026-03-03 | 70% | 84.22d | 37744.2d | finish no earlier than 2026-03-03 | R3 | 2246h |  | FS_NR_AIML_NGRAN_Ph3 | 55 | ZTE | Rel-20 | 108 | RP-253244 | 38.745 |  |
| 55 | 45 | Study on Stage 2 for AI/ML service Phase 2 | 271.25d | 2025-03-26 A | 2025-12-12 | 85% | 40.69d | 37828.2d | start no earlier than 2025-03-26 | S6 | 2170h |  | FS_AIML_App_Ph2 | 54 | Pateromichelakis, Emmanouil (Manos), Lenovo | Rel-20 | 107 |  | 23.700-83 | epateromiche@lenovo.com |
| 56 | 46 | Stage 2 for AI/ML service Phase 2 | 290.88d | 2025-12-03 | 2026-09-09 |  |  | 37547.6d | finish no earlier than 2026-09-09 | S6 | 2327h |  | AIML_Ph2-APP |  | Pateromichelakis, Emmanouil (Manos), Lenovo, | Rel-20 |  |  | 23.482; 23.436; 23.434 | epateromiche@lenovo.com |
| 57 | 47 | Study on AIML management phase 3 | 281.75d | 2025-06-05 A | 2026-03-03 | 23% | 216.95d | 37744.2d | finish no earlier than 2026-03-03 | S5 | 2254h |  | FS_AIML_MGT_Ph3 | 55 | Hassan Al-Kanani (NEC), | Rel-20 | 108 |  | 28.882 | Hassan.Alkanani@EMEA.NEC.COM |
| 58 | 48 | Media aspects for AI/ML in IMS services | 248.5d | 2025-07-07 A | 2026-03-03 | 20% | 198.8d | 37744.2d | finish no earlier than 2026-03-03 | S4 | 1988h |  | AIML_IMS-MED | 55 | Yip, Eric, Samsung Electronics Co., Ltd, | Rel-20 | 108 |  | 26.114; 26.264 | eric dot yip AT samsung dot com |
| 59 | 49 | Core Network Enhanced Support for Artificial Intelligence (AI) / Machine Learning (ML) Phase 2; Stage 2 | 192.5d | 2025-12-03 | 2026-06-06 |  |  | 37646d | finish no earlier than 2026-06-06 | S2 | 1540h |  | AIML_CN_Ph2-ARC |  | Hyesung Kim, Samsung | Rel-20 |  |  | 23.288; 23.502; 23.503 | hs1207.kim@SAMSUNG.COM |

Notes:
- 33: to support RRC connected mode mobility; compare: REL-19 WI LTE_TN_NR_NTN_mob-Core which introduced idle mode mobility ; 29/9/25: WID:RP-251878->RP-252890
- 34: to support RRC connected mode mobility; compare: REL-19 WI LTE_TN_NR_NTN_mob-Core which introduced idle mode mobility ; 3/12/25: Stat Rep: ->RP-253454;
- 35: ; 3/12/25: Stat Rep: ->RP-253454;
- 36: no Perf. part; compare: REL-19 WI IoT_NTN_Ph3, REL-18 WI IoT_NTN_enh, REL-17 WI LTE_NBIOT_eMTC_NTN; enhancement of NB-IoT-NTN to support IMS voice call over GSO ; 29/9/25: WID:RP-251867->RP-252473; 7/1/26: WID:RP-252473->RP-253813
- 37: no Perf. part; compare: REL-19 WI IoT_NTN_Ph3, REL-18 WI IoT_NTN_enh, REL-17 WI LTE_NBIOT_eMTC_NTN; enhancement of NB-IoT-NTN to support IMS voice call over GSO ; 11/9/25: FCD:Wed 09/06/21->Wed 03/03/27; Stat Rep: ->RP-252012; ; 3/12/25: Compl:0%->8%; Stat Rep: RP-252012->RP-253260;
- 38: compare REL-19 WI NR_IoT_NTN_req_test_enh ; 7/1/26: WID:RP-252962->RP-253834
- 39: compare REL-19 WI NR_IoT_NTN_req_test_enh ; 3/12/25: Compl:0%->15%; Stat Rep: ->RP-253694;
- 40: ; 3/12/25: Stat Rep: ->RP-253694;
- 41: -
- 43: 12/9/25: 0%->15; 4/12/25: 15%->75
- 44: 18/7/25: 23.700-26 added;; 12/9/25: 0%->10; 12/9/25: 10%->20; 4/12/25: 20%->60; 4/12/25: 60%->70
- 45: affecting TR 38.769 of REL-19 SI FS_Ambient_IoT_solutions ; 11/9/25: FCD:Wed 09/06/21->Tue 03/03/26; Compl:0%->25%; Stat Rep: ->RP-252344; ; 29/9/25: WID:RP-251884->RP-252964; 3/12/25: Compl:25%->75%; Stat Rep: RP-252344->RP-253393; ; 7/1/26: WID:RP-252964->RP-253394
- 46: compare REL-19 WI Ambient_IoT_Solutions; note: There is a parallel REL-20 SI FS_Ambient_IoT_Outdoor_Active (no overlap allowed); SI TR 38.769 must be removed from this WID ; 29/9/25: WID:RP-251885->RP-252894
- 47: compare REL-19 WI Ambient_IoT_Solutions; note: There is a parallel REL-20 SI FS_Ambient_IoT_Outdoor_Active (no overlap allowed); SI TR 38.769 must be removed from this WID ; 11/9/25: Stat Rep: ->RP-252361; ; 3/12/25: FCD:Tue 03/03/26->Wed 03/03/27; Compl:0%->5%; Stat Rep: RP-252361->RP-253109;
- 48: ; 11/9/25: Stat Rep: ->RP-252361; ; 3/12/25: FCD:Tue 03/03/26->Thu 09/09/27; Stat Rep: RP-252361->RP-253109;
- 50: -
- 51: 4/12/25: 0%->60
- 52: 4/12/25: 0%->40
- 53: 27/6/25: WID:SP-250413->SP-250810; 12/9/25: 0%->70; 4/12/25: 70%->89
- 54: compare REL-17 SI FS_NR_ENDC_data_collect and REL-19 SI FS_NR_AIML_NGRAN_enh; TR 38.7XX ; 11/9/25: Stat Rep: ->RP-252455; ; 29/9/25: WID:RP-251868->RP-252867; 30/9/25: 38.745 added;; 3/12/25: Compl:0%->70%; Stat Rep: RP-252455->RP-253244;
- 55: 3/4/25: 23.700-83 added;; 6/6/25: 0%->40; 12/9/25: 40%->60; 4/12/25: 60%->85
- 57: 18/7/25: 28.882 added;; 4/12/25: 0%->23; 6/1/26: WID:SP-250867->SP-251650
- 58: ; 4/12/25: 0%->20
- 59: ; 6/1/26: WID:SP-251342->SP-251669

| ID | WBS | Task | Duration | Start | Finish | Complete | Remaining | Total slack | Constraint | Resources | Work | Actual work | Acronym | PCG approved | WI rapporteur name | Release | TSG approved | Status Report | Impacted TSs and TRs | WI rapporteur e-mail |
| --- | --- | --- | --- | --- | --- | --- | --- | --- | --- | --- | --- | --- | --- | --- | --- | --- | --- | --- | --- | --- |
| 60 | 50 | **AIML for NR air interface Phase 2** | 855.25d | 2025-06-06 A | 2027-09-09 | 9% | 780.84d | 37169.8d |  |  | 12111h |  | NR_AIML_air_Ph2 | 55 | Qualcomm | Rel-20 | 108 |  |  |  |
| 61 | 50.1 | Core part: AIML or NR air interface Phase 2 | 658.62d | 2025-06-06 A | 2027-03-03 | 20% | 526.9d | 37366.4d | finish no earlier than 2027-03-03 | R1 | 5269h |  | NR_AIML_air_Ph2-Core | 55 | Qualcomm | Rel-20 | 108 | RP-253339 |  |  |
| 62 | 50.2 | Perf. Part: AIML for NR air interface Phase 2 | 855.25d | 2025-06-06 | 2027-09-09 |  |  | 37169.8d | finish no earlier than 2027-09-09 | R4 | 6842h |  | NR_AIML_air_Ph2-Perf | 55 | Qualcomm | Rel-20 | 108 | RP-253339 |  |  |
| 63 | 51 | **AIML for mobility in NR** | 855.25d | 2025-06-06 A | 2027-09-09 | 3% | 829.22d | 37169.8d |  |  | 12111h |  | NR_AIML_Mob | 55 | OPPO | Rel-20 | 108 |  |  |  |
| 64 | 51.1 | Core part: AIML for mobility in NR | 658.62d | 2025-06-06 A | 2027-03-03 | 7% | 612.52d | 37366.4d | finish no earlier than 2027-03-03 | R2 | 5269h |  | NR_AIML_Mob-Core | 55 | OPPO | Rel-20 | 108 | RP-253076 |  |  |
| 65 | 51.2 | Perf. Part: AIML for mobility in NR | 855.25d | 2025-06-06 | 2027-09-09 |  |  | 37169.8d | finish no earlier than 2027-09-09 | R4 | 6842h |  | NR_AIML_Mob-Perf | 55 | OPPO | Rel-20 | 108 | RP-253076 |  |  |
| 66 | 52 | Rel-20 Energy Efficiency, Energy Saving | 38436d? | 2024-05-05 | 2125-12-12 |  |  | 0d | start no earlier than 2024-05-05 |  |  |  |  |  |  | Rel-20 |  |  |  |  |
| 67 | 53 | **Energy Efficiency as Service Criteria Phase 2** | 446.12d | 2024-04-02 A | 2025-06-06 A | 100% |  |  |  |  | 2690h | 2690h |  | 55 |  | Rel-20 | 108 |  |  |  |
| 68 | 53.1 | Study on Energy Efficiency as Service Criteria Phase 2 | 240d | 2024-04-02 A | 2025-03-03 A | 100% |  |  | start no earlier than 2024-04-02 | S1 | 1920h | 1920h | FS_EnergyServ_Ph2 | 52 | Laurent-WalterGoix, Nokia | Rel-20 | 103 |  | 22.883 | laurent-walter.goix@NOKIA.COM |
| 69 | 53.2 | Stage 1 for Energy Efficiency as Service Criteria Phase 2 | 96.25d | 2025-03-06 A | 2025-06-06 A | 100% |  |  | start no earlier than 2025-03-06 | S1 | 770h | 770h | EnergyServ_Ph2-REQ | 54 | Laurent-Walter Goix, Nokia | Rel-20 | 107 |  | 22.261 | laurent-walter.goix@nokia.com |
| 70 | 54 | Study on Energy Efficiency and Energy Saving Phase2 | 174d | 2025-03-26 A | 2025-09-09 A | 100% |  |  | finish no earlier than 2025-12-12 | S2 | 1392h | 1392h | FS_EnergySys_Ph2 | 54 | Konstantinos Samdanis (Lenovo) | Rel-20 | 107 |  |  | ksamdanis@lenovo.com |
| 71 | 55 | Study on Application Enablement to support Energy Saving Phase 2 | 281.75d | 2025-06-05 A | 2026-03-03 | 60% | 112.7d | 37744.2d | finish no earlier than 2026-03-03 | S6 | 2254h |  | FS_EnergySys_Ph2_APP | 55 | Yue, Jing, Ericsson | Rel-20 | 108 |  | 23.700-44 | jing.yue@ericsson.com |
| 72 | 56 | Study on energy efficiency and energy saving aspects of 5G Advanced | 281.75d | 2025-06-05 A | 2026-03-03 | 15% | 239.49d | 37744.2d | finish no earlier than 2026-03-03 | S5 | 2254h |  | FS_Energy_Ph4_OAM | 55 | Srilakshmi S (Nokia), | Rel-20 | 108 |  | 28.885 | srilakshmi.s@nokia.com |
| 73 | 57 | Study on Media energy consumption exposure and evaluation framework Phase 2 | 248.5d | 2025-07-07 A | 2026-03-03 | 30% | 173.95d | 37744.2d | finish no earlier than 2026-03-03 | S4 | 1988h |  | FS_Energy_Ph2_MED | 55 | Julien Lemotheux, Orange | Rel-20 | 108 |  | 26.942 | <julien.lemotheux@orange.com> |
| 74 | 58 | Stage 2 of Energy Efficiency and Energy Saving Phase 2 | 290.88d | 2025-12-03 | 2026-09-09 |  |  | 37547.6d | finish no earlier than 2026-09-09 | S2 | 2327h |  | EnergySys_Ph2-ARC |  | Konstantinos Samdanis (Lenovo), | Rel-20 |  |  | 23.501; 23.502; 23.503 | ksamdanis@lenovo.com |
| 75 | 59 | Rel-20 Radio-centric: NR-only | 855.25d | 2019-03-07 | 2021-06-09 |  |  | 39533.6d |  |  |  |  |  |  |  | Rel-20 |  |  |  |  |
| 76 | 60 | **Additional NR bands for NR features in Rel-20** | 462.88d | 2025-12-12 | 2027-03-03 |  |  | 37366.4d |  |  | 3703h |  | NR_bands_xFeature_R20 |  | ZTE | Rel-20 |  |  |  |  |
| 77 | 60.1 | Core part: Additional NR bands for NR features in Rel-20 | 462.88d | 2025-12-12 | 2027-03-03 |  |  | 37366.4d | finish no earlier than 2027-03-03 | R4 | 3703h |  | NR_bands_xFeature_R20-Core |  | ZTE | Rel-20 |  |  |  |  |
| 78 | 61 | **Introduction of EESS protection and PC1 for NR band(s) at 40GHz** | 281.62d | 2025-12-12 | 2026-09-09 |  |  | 37547.6d |  |  | 4506h |  | NR_40GHz_EESSprot_PC1 |  | NTT DOCOMO | Rel-20 |  |  |  |  |
| 79 | 61.1 | Core part: Introduction of EESS protection and PC1 for NR band(s) at 40GHz | 281.62d | 2025-12-12 | 2026-09-09 |  |  | 37547.6d | finish no earlier than 2026-09-09 | R4 | 2253h |  | NR_40GHz_EESSprot_PC1-Core |  | NTT DOCOMO | Rel-20 |  |  |  |  |
| 80 | 61.2 | Perf. part: Introduction of EESS protection and PC1 for NR band(s) at 40GHz | 281.62d | 2025-12-12 | 2026-09-09 |  |  | 37547.6d | finish no earlier than 2026-09-09 | R4 | 2253h |  | NR_40GHz_EESSprot_PC1-Perf |  | NTT DOCOMO | Rel-20 |  |  |  |  |
| 81 | 62 | **Introduction of a new NR FDD band for 1.5GHz Japanese allocation** | 379d | 2025-12-12 | 2026-12-12 |  |  | 37450.2d |  |  | 4498h |  | NR_1500MHz_JP |  | KDDI | Rel-20 |  |  |  |  |
| 82 | 62.1 | Core part: Introduction of a new NR FDD band for 1.5GHz Japanese allocation | 183.25d | 2025-12-12 | 2026-06-06 |  |  | 37646d | finish no earlier than 2026-06-06 | R4 | 1466h |  | NR_1500MHz_JP-Core |  | KDDI | Rel-20 |  |  |  |  |
| 83 | 62.2 | Perf. part: Introduction of a new NR FDD band for 1.5GHz Japanese allocation | 379d | 2025-12-12 | 2026-12-12 |  |  | 37450.2d | finish no earlier than 2026-12-12 | R4 | 3032h |  | NR_1500MHz_JP-Perf |  | KDDI | Rel-20 |  |  |  |  |

Notes:
- 60: follow-up WI of REL-19 SI FS_NR_AIML_air_Ph2; compare REL-19 WI NR_AIML_air ; 29/9/25: WID:RP-251870->RP-252445; 7/1/26: WID:RP-252445->RP-253340
- 61: follow-up WI of REL-19 SI FS_NR_AIML_air_Ph2; compare REL-19 WI NR_AIML_air ; 11/9/25: Compl:0%->4%; Stat Rep: ->RP-252444; ; 3/12/25: Compl:4%->20%; Stat Rep: RP-252444->RP-253339;
- 62: ; 11/9/25: Stat Rep: ->RP-252444; ; 3/12/25: Stat Rep: RP-252444->RP-253339;
- 63: follow-up WI of REL-19 SI FS_NR_AIML_Mob ; 29/9/25: WID:RP-251864->RP-252899
- 64: follow-up WI of REL-19 SI FS_NR_AIML_Mob ; 11/9/25: Stat Rep: ->RP-251967; ; 3/12/25: Compl:0%->7%; Stat Rep: RP-251967->RP-253076;
- 65: ; 11/9/25: FCD:Sun 06/06/27->Thu 09/09/27; Stat Rep: ->RP-251967; ; 3/12/25: Stat Rep: RP-251967->RP-253076;
- 66: -
- 68: 13/6/24: 0%->25; 4/9/24: 25%->55; 6/3/25: 55%->100
- 69: ; 26/3/25: WID:SP-250271->SP-250385
- 70: 27/6/25: WID:SP-250417->SP-250791; 12/9/25: 0%->85; 4/12/25: 85%->100
- 71: 18/7/25: 23.700-44 added;; 12/9/25: 0%->15; 4/12/25: 15%->60
- 72: 18/7/25: 28.885 added;; 29/9/25: WID:SP-250860->SP- 251025; 4/12/25: 0%->15
- 73: ; 4/12/25: 0%->30; 4/12/25: 0%->30; 4/12/25: 20%->30
- 75: -

| ID | WBS | Task | Duration | Start | Finish | Complete | Remaining | Total slack | Constraint | Resources | Work | Actual work | Acronym | PCG approved | WI rapporteur name | Release | TSG approved | Status Report | Impacted TSs and TRs |
| --- | --- | --- | --- | --- | --- | --- | --- | --- | --- | --- | --- | --- | --- | --- | --- | --- | --- | --- | --- |
| 84 | 63 | **Data Collection for SON (Self-Organising Networks)/MDT (Minimization of Drive Tests) in NR Phase 5** | 658.62d | 2025-06-06 A | 2027-03-03 | 20% | 526.91d | 37366.4d |  |  | 5269h |  | NR_SON_MDT_Ph5 | 55 | China Unicom | Rel-20 | 108 |  |  |
| 85 | 63.1 | Core part: Data collection for SON/MDT in NR Phase 5 | 658.62d | 2025-06-06 A | 2027-03-03 | 20% | 526.9d | 37366.4d | finish no earlier than 2027-03-03 | R3 | 5269h |  | NR_SON_MDT_Ph5-Core | 55 | China Unicom | Rel-20 | 108 | RP-253367 |  |
| 86 | 64 | **NR mobility enhancements Phase 5** | 757d | 2025-06-06 | 2027-06-06 |  |  | 37268d |  |  | 11325h |  | NR_Mob_Ph5 | 55 | Apple | Rel-20 | 108 |  |  |
| 87 | 64.1 | Core part: NR mobility enhancements Phase 5 | 658.62d | 2025-06-06 | 2027-03-03 |  |  | 37366.4d | finish no earlier than 2027-03-03 | R2 | 5269h |  | NR_Mob_Ph5-Core | 55 | Apple | Rel-20 | 108 | RP-253623 |  |
| 88 | 64.2 | Perf. part: NR mobility enhancements Phase 5 | 757d | 2025-06-06 | 2027-06-06 |  |  | 37268d | finish no earlier than 2027-06-06 | R4 | 6056h |  | NR_Mob_Ph5-Perf | 55 | Apple | Rel-20 | 108 | RP-253623 |  |
| 89 | 65 | **NR MIMO Phase 6** | 855.25d | 2025-06-06 A | 2027-09-09 | 17% | 706.42d | 37169.8d |  |  | 12111h |  | NR_MIMO_Ph6 | 55 | MediaTek | Rel-20 | 108 |  |  |
| 90 | 65.1 | Core part: NR MIMO Phase 6 | 658.62d | 2025-06-06 A | 2027-03-03 | 40% | 395.18d | 37366.4d | finish no earlier than 2027-03-03 | R1 | 5269h |  | NR_MIMO_Ph6-Core | 55 | MediaTek | Rel-20 | 108 | RP-253693 |  |
| 91 | 65.2 | Perf. part: NR MIMO Phase 6 | 855.25d | 2025-06-06 | 2027-09-09 |  |  | 37169.8d | finish no earlier than 2027-09-09 | R4 | 6842h |  | NR_MIMO_Ph6-Perf | 55 | MediaTek | Rel-20 | 108 | RP-253693 |  |
| 92 | 66 | **NR coverage enhancements Phase 3** | 658.62d | 2025-06-06 A | 2027-03-03 | 13% | 572.78d | 37366.4d |  |  | 9858h |  | NR_cov_Ph3 | 55 | China Telecom | Rel-20 | 108 |  |  |
| 93 | 66.1 | Core part: NR coverage enhancements Phase 3 | 573.62d | 2025-06-06 A | 2026-12-11 | 28% | 413.01d | 37451.4d | finish no earlier than 2026-12-11 | R1 | 4589h |  | NR_cov_Ph3-Core | 55 | China Telecom | Rel-20 | 108 | RP-253456 |  |
| 94 | 66.2 | Perf. part: Coverage enhancements for NR Phase 3 | 658.62d | 2025-06-06 | 2027-03-03 |  |  | 37366.4d | finish no earlier than 2027-03-03 | R4 | 5269h |  | NR_cov_Ph3-Perf | 55 | China Telecom | Rel-20 | 108 | RP-253456 |  |
| 95 | 67 | Study on spatial channel model for demodulation performance requirements for NR: MultiUser-MIMO | 3022.5d | 2019-03-07 | 2027-03-03 |  |  | 37366.4d | finish no earlier than 2027-03-03 | R4 | 24180h |  | FS_NR_demod_SCM_MUMIMO |  | Nokia | Rel-20 |  |  |  |
| 96 | 68 | **UE RF enhancements for NR FR1, Phase 5** | 756.75d | 2025-09-09 A | 2027-09-09 | 9% | 692.38d | 37169.8d |  | R4 | 16589h | 515h | NR_UE_RF_Ph5 |  | Huawei | Rel-20 |  |  |  |
| 97 | 68.1 | Core part: UE RF enhancements for NR FR1, Phase 5 | 560.12d | 2025-09-09 A | 2027-03-03 | 20% | 448.1d | 37366.4d | finish no earlier than 2027-03-03 | R4 | 4481h |  | NR_UE_RF_Ph5-Core |  | Huawei | Rel-20 |  | RP-253509 |  |
| 98 | 68.2 | Perf. part: UE RF enhancements for NR FR1, Phase 5 | 756.75d | 2025-09-09 | 2027-09-09 |  |  | 37169.8d | finish no earlier than 2027-09-09 | R4 | 6054h |  | NR_UE_RF_Ph5-Perf |  | Huawei | Rel-20 |  | RP-253509 |  |
| 99 | 69 | **NR base station (BS) RF requirement evolution for FR1/FR2 and testing, Phase 2** | 756.75d | 2025-09-09 A | 2027-09-09 | 2% | 740.66d | 37169.8d |  | R4 | 16589h | 128.72h | NR_BS_RF_req_evo_Ph2 |  | ZTE | Rel-20 |  |  |  |
| 100 | 69.1 | Core part: NR base station (BS) RF requirement evolution for FR1/FR2 and testing, Phase 2 | 560.12d | 2025-09-09 A | 2027-03-03 | 5% | 532.12d | 37366.4d | finish no earlier than 2027-03-03 | R4 | 4481h |  | NR_BS_RF_req_evo_Ph2-Core |  | ZTE | Rel-20 |  | RP-253211 | 38.748 |
| 101 | 69.2 | Perf. part: NR base station (BS) RF requirement evolution for FR1/FR2 and testing, Phase 2 | 756.75d | 2025-09-09 | 2027-09-09 |  |  | 37169.8d | finish no earlier than 2027-09-09 | R4 | 6054h |  | NR_BS_RF_req_evo_Ph2-Perf |  | ZTE | Rel-20 |  | RP-253211 |  |
| 102 | 70 | **Enhancement of UE OTA test method and requirements for NR** | 756.75d | 2025-09-09 A | 2027-09-09 | 6% | 708.48d | 37169.8d |  | R4 | 16589h | 386.18h | NR_UE_OTA_enh |  | vivo | Rel-20 |  |  |  |
| 103 | 70.1 | Core part: Enhancement of UE OTA test method and requirements for NR | 560.12d | 2025-09-09 A | 2027-03-03 | 15% | 476.11d | 37366.4d | finish no earlier than 2027-03-03 | R4 | 4481h |  | NR_UE_OTA_enh-Core |  | vivo | Rel-20 |  | RP-253264 | 38.763 |
| 104 | 70.2 | Perf. part: Enhancement of UE OTA test method and requirements for NR | 756.75d | 2025-09-09 | 2027-09-09 |  |  | 37169.8d | finish no earlier than 2027-09-09 | R4 | 6054h |  | NR_UE_OTA_enh-Perf |  | vivo | Rel-20 |  | RP-253264 |  |
| 105 | 71 | **NR Radio Resource Management (RRM), Phase 6** | 560.12d | 2025-09-09 A | 2027-03-03 | 12% | 490.11d | 37366.4d |  | R4 | 13443h | 643.72h | NR_RRM_Ph6 |  | Ericsson | Rel-20 |  |  |  |
| 106 | 71.1 | Core part: NR Radio Resource Management (RRM), Phase 6 | 560.12d | 2025-09-09 A | 2027-03-03 | 25% | 420.09d | 37366.4d | finish no earlier than 2027-03-03 | R4 | 4481h |  | NR_RRM_Ph6-Core |  | Ericsson | Rel-20 |  | RP-253478 |  |
| 107 | 71.2 | Perf. part: NR Radio Resource Management (RRM), Phase 6 | 560.12d | 2025-09-09 | 2027-03-03 |  |  | 37366.4d | finish no earlier than 2027-03-03 | R4 | 4481h |  | NR_RRM_Ph6-Perf |  | Ericsson | Rel-20 |  | RP-253278 |  |

Notes:
- 84: no Perf. part; compare: REL-19 WI NR_ENDC_SON_MDT_Ph4, REL-18 WI NR_ENDC_SON_MDT_enh2, REL-17 WI NR_ENDC_SON_MDT_enh, REL-16 WI NR_SON_MDT ; 29/9/25: WID:RP-251869->RP-252560
- 85: no Perf. part; compare: REL-19 WI NR_ENDC_SON_MDT_Ph4, REL-18 WI NR_ENDC_SON_MDT_enh2, REL-17 WI NR_ENDC_SON_MDT_enh, REL-16 WI NR_SON_MDT ; 11/9/25: Stat Rep: ->RP-252561; ; 3/12/25: Compl:0%->20%; WID: RP-252560->RP-234038; Stat Rep: RP-252561->RP-253367;
- 86: compare: REL-16 WI NR_Mob_enh, REL-18 WI NR_Mob_enh2, REL-19 WI NR_Mob_Ph4 ; 29/9/25: WID:RP-251865->RP-252113
- 87: compare: REL-16 WI NR_Mob_enh, REL-18 WI NR_Mob_enh2, REL-19 WI NR_Mob_Ph4 ; 11/9/25: Stat Rep: ->RP-252112; ; 3/12/25: Stat Rep: RP-252112->RP-253623;
- 88: ; 11/9/25: Stat Rep: ->RP-252112; ; 3/12/25: Stat Rep: RP-252112->RP-253623;
- 89: compare REL-19 WI NR_MIMO_Ph5, REL-18 WIs NR_MIMO_evo_DL_UL, NR_MIMO_OTA_enh, REL-17 WIs NR_feMIMO, NR_MIMO_OTA, REL-16 WI NR_eMIMO ; 29/9/25: WID:RP-251856->RP-252936
- 90: compare REL-19 WI NR_MIMO_Ph5, REL-18 WIs NR_MIMO_evo_DL_UL, NR_MIMO_OTA_enh, REL-17 WIs NR_feMIMO, NR_MIMO_OTA, REL-16 WI NR_eMIMO ; 11/9/25: FCD:Wed 03/03/27->Fri 04/06/27; Compl:0%->10%; Stat Rep: ->RP-252509; ; 30/9/25: FCD:Sun 06/06/->/27; 3/12/25: Compl:10%->40%; Stat Rep: RP-252509->RP-253693;
- 91: ; 11/9/25: Stat Rep: ->RP-252509; ; 3/12/25: Stat Rep: RP-252509->RP-253693;
- 92: compare REL-18 WI NR_cov_enh2, REL-17 WI NR_cov_enh ; 29/9/25: WID:RP-251862->RP-252824
- 93: compare REL-18 WI NR_cov_enh2, REL-17 WI NR_cov_enh ; 11/9/25: Stat Rep: ->RP-252571; ; 3/12/25: FCD:Sat 12/12/26->Fri 11/12/26; Compl:0%->28%; Stat Rep: RP-252571->RP-253456;
- 94: ; 11/9/25: Stat Rep: ->RP-252571; ; 3/12/25: Stat Rep: RP-252571->RP-253456;
- 95: compare REL-19 SI FS_NR_demod_SCM ; 3/12/25: FCD:Sat 06/03/21->Wed 03/03/27; ; 7/1/26: WID:RP-252956->RP-253766
- 96: compare REL-19 WI NR_ENDC_RF_Ph4, REL-18 WI NR_RF_FR2_req_Ph3, REL-17 WI NR_RF_FR1_enh, REL-16 WI NR_RF_FR1 ; 7/1/26: WID:RP-252952->RP-253510
- 97: compare REL-19 WI NR_ENDC_RF_Ph4, REL-18 WI NR_RF_FR2_req_Ph3, REL-17 WI NR_RF_FR1_enh, REL-16 WI NR_RF_FR1 ; 3/12/25: Compl:0%->20%; Stat Rep: ->RP-253509;
- 98: ; 3/12/25: Stat Rep: ->RP-253509;
- 99: compare REL-19 WI NR_BS_RF_req_evo; TR 38.8xx ; 7/1/26: WID:RP-252905->RP-253210
- 100: compare REL-19 WI NR_BS_RF_req_evo; TR 38.8xx ; 3/12/25: Compl:0%->5%; Stat Rep: ->RP-253211; ; 7/1/26: 38.748 added;
- 101: ; 3/12/25: Stat Rep: ->RP-253211;
- 102: compare REL-19 WI TRP_TRS_MIMO_OTA_Ph3; introduces test method enhancements for NTN VSAT; new TR or TS? ; 7/1/26: WID:RP-252903->RP-253851
- 103: compare REL-19 WI TRP_TRS_MIMO_OTA_Ph3; introduces test method enhancements for NTN VSAT; new TR or TS? ; 3/12/25: Compl:0%->15%; Stat Rep: ->RP-253264; ; 7/1/26: 38.763 added;
- 104: ; 3/12/25: Stat Rep: ->RP-253264;
- 105: compare: REL-19 WI NR_RRM_Ph5, REL-18 WI NR_RRM_enh3, REL-17 WI NR_RRM_enh2, REL-16 WI NR_RRM_enh ; 7/1/26: WID:RP-252955->RP-253279
- 106: compare: REL-19 WI NR_RRM_Ph5, REL-18 WI NR_RRM_enh3, REL-17 WI NR_RRM_enh2, REL-16 WI NR_RRM_enh ; 3/12/25: Compl:0%->25%; Stat Rep: ->RP-253478;
- 107: ; 3/12/25: FCD:Thu 09/09/27->Wed 03/03/27; Stat Rep: ->RP-253278;

| ID | WBS | Task | Duration | Start | Finish | Complete | Remaining | Total slack | Constraint | Resources | Work | Actual work | Acronym | WI rapporteur name | Release | Status Report | PCG approved | TSG approved | Impacted TSs and TRs | WI rapporteur e-mail |
| --- | --- | --- | --- | --- | --- | --- | --- | --- | --- | --- | --- | --- | --- | --- | --- | --- | --- | --- | --- | --- |
| 108 | 72 | **NR demodulation performance Phase 6** | 560.12d | 2025-09-09 A | 2027-03-03 | 22% | 436.91d | 37366.4d |  | R4 | 8962h | 985.7h | NR_demod_Ph6 | China Telecom | Rel-20 |  |  |  |  |  |
| 109 | 72.1 | Perf. part: NR demodulation performance Phase 6 | 560.12d | 2025-09-09 A | 2027-03-03 | 22% | 436.9d | 37366.4d | finish no earlier than 2027-03-03 | R4 | 4481h |  | NR_demod_Ph6-Perf | China Telecom | Rel-20 | RP-253457 |  |  |  |  |
| 110 | 73 | **Enhancement of low NR band carrier aggregation via switching** | 560.12d | 2025-09-09 A | 2027-03-03 | 8% | 517.87d | 37366.4d |  | R4 | 10420h | 257.45h | NR_LBCA_Sw_enh | Telus | Rel-20 |  |  |  |  |  |
| 111 | 73.1 | Core part: Enhancement of low NR band carrier aggregation via switching | 560.12d | 2025-09-09 A | 2027-03-03 | 10% | 504.11d | 37366.4d | finish no earlier than 2027-03-03 | R4 | 4481h |  | NR_LBCA_Sw_enh-Core | Telus | Rel-20 | RP-253306 |  |  |  |  |
| 112 | 73.2 | Perf. part: Enhancement of low NR band carrier aggregation via switching | 182.25d | 2025-09-09 | 2026-03-03 |  |  | 37744.2d | finish no earlier than 2026-03-03 | R4 | 1458h |  | NR_LBCA_Sw_enh-Perf | Telus | Rel-20 | RP-253306 |  |  |  |  |
| 113 | 74 | **Enhancement of NR RF and RRM requirements for uncrewed aerial vehicle (UAV)** | 756.75d | 2025-09-09 A | 2027-09-09 | 5% | 718.13d | 37169.8d |  | R4 | 16589h | 308.98h | NR_UAV_req | CMCC | Rel-20 |  |  |  |  |  |
| 114 | 74.1 | Core part: Enhancement of NR RF and RRM requirements for uncrewed aerial vehicle (UAV) | 560.12d | 2025-09-09 A | 2027-03-03 | 12% | 492.91d | 37366.4d | finish no earlier than 2027-03-03 | R4 | 4481h |  | NR_UAV_req-Core | CMCC | Rel-20 | RP-253478 |  |  |  |  |
| 115 | 74.2 | Perf. part: Enhancement of NR RF and RRM requirements for uncrewed aerial vehicle (UAV) | 756.75d | 2025-09-09 | 2027-09-09 |  |  | 37169.8d | finish no earlier than 2027-09-09 | R4 | 6054h |  | NR_UAV_req-Perf | CMCC | Rel-20 | RP-253478 |  |  |  |  |
| 116 | 75 | **Introduction of NR TDD 4.9GHz band for US operation** | 379d | 2025-06-06 A | 2026-06-06 | 30% | 265.45d | 37646d |  | R4 | 9088h | 908.39h | NR_TDD_band_4900MHz_US | Fujitsu | Rel-20 |  | 55 | 108 |  |  |
| 117 | 75.1 | Core part: Introduction of NR TDD 4.9GHz band for US operation | 378d | 2025-06-06 A | 2026-06-05 | 60% | 151.2d | 37647d | finish no earlier than 2026-06-05 | R4 | 3024h |  | NR_TDD_band_4900MHz_US-Core | Fujitsu | Rel-20 | RP-253441 | 55 | 108 |  |  |
| 118 | 75.2 | Perf. part: Introduction of NR TDD 4.9GHz band for US operation | 379d | 2025-06-06 | 2026-06-06 |  |  | 37646d | finish no earlier than 2026-06-06 | R4 | 3032h |  | NR_TDD_band_4900MHz_US-Perf | Fujitsu | Rel-20 | RP-253441 | 55 | 108 |  |  |
| 119 | 76 | Rel-20 Radio-centric: LTE-only | 855.25d | 2019-03-07 | 2021-06-09 |  |  | 39533.6d |  |  |  |  |  |  | Rel-20 |  |  |  |  |  |
| 120 | 77 | **Rel-20 LTE-Advanced Carrier Aggregation for x bands (1<=x<= 6) DL with y bands (y=1, 2) UL** | 462.88d | 2025-12-12 | 2027-03-03 |  |  | 37366.4d |  |  | 3703h |  | LTE_CA_R20_xBDL_yBUL | Huawei | Rel-20 |  |  |  |  |  |
| 121 | 77.1 | Core part: Rel-20 LTE-Advanced Carrier Aggregation for x bands (1<=x<= 6) DL with y bands (y=1, 2) UL | 462.88d | 2025-12-12 | 2027-03-03 |  |  | 37366.4d | finish no earlier than 2027-03-03 | R4 | 3703h |  | LTE_CA_R20_xBDL_yBUL-Core | Huawei | Rel-20 |  |  |  |  |  |
| 122 | 78 | Rel-20 Radio-centric: LTE and NR | 855.25d | 2019-03-07 | 2021-06-09 |  |  | 39533.6d |  |  |  |  |  |  | Rel-20 |  |  |  |  |  |
| 123 | 79 | **Introduction of the higher power classes, 3MHz channel bandwidth and eRedCap for the existing NR/IoT NTN bands** | 462.88d | 2025-12-12 | 2027-03-03 |  |  | 37366.4d |  |  | 3703h |  | NTN_bands_Features_R20 | Apple | Rel-20 |  |  |  |  |  |
| 124 | 79.1 | Core part: Introduction of the higher power classes, 3MHz channel bandwidth and eRedCap for the existing NR/IoT NTN bands | 462.88d | 2025-12-12 | 2027-03-03 |  |  | 37366.4d | finish no earlier than 2027-03-03 | R4 | 3703h |  | NTN_bands_Features_R20-Core | Apple | Rel-20 |  |  |  |  |  |
| 125 | 80 | **Additional NR and LTE band combinations for features in Rel-20** | 462.88d | 2025-12-12 | 2027-03-03 |  |  | 37366.4d |  |  | 3703h |  | NR_LTE_combos_Features_R2 | China Telecom | Rel-20 |  |  |  |  |  |
| 126 | 80.1 | Core part: Additional NR and LTE band combinations for features in Rel-20 | 462.88d | 2025-12-12 | 2027-03-03 |  |  | 37366.4d | finish no earlier than 2027-03-03 | R4 | 3703h |  | NR_LTE_combos_Features_R20-Core | China Telecom | Rel-20 |  |  |  |  |  |
| 127 | 81 | **Rel-20 Dual connectivity (DC) of x LTE band(s), y NR band(s) (1<=x<6, 1<=y<6, x+y<=6) and single or two NR Supplementary Uplink (SUL) bands plus high power UE** | 462.88d | 2025-12-12 | 2027-03-03 |  |  | 37366.4d |  | R4 | 7406h |  | DC_xBLTE_yBNR_R20_HPUE | China Unicom | Rel-20 |  |  |  |  |  |
| 128 | 81.1 | Core part: Rel-20 Dual connectivity (DC) of x LTE band(s), y NR band(s) (1<=x<6, 1<=y<6, x+y<=6) and single or two NR Supplementary Uplink (SUL) bands plus high power UE | 462.88d | 2025-12-12 | 2027-03-03 |  |  | 37366.4d | finish no earlier than 2027-03-03 | R4 | 3703h |  | DC_xBLTE_yBNR_R20_HPUE-Core | China Unicom | Rel-20 |  |  |  |  |  |
| 129 | 82 | **Rel-20 NR Carrier Aggregation (CA)/Dual Connectivity (DC) for x bands DL with y bands UL (x<7, y<3) and Supplementary Uplink (SUL) band combinations/CA band combinations with a single SUL or two SUL cells plus high power UE** | 462.88d | 2025-12-12 | 2027-03-03 |  |  | 37366.4d |  | R4 | 7406h |  | NR_CADC_SUL_R20_HPUE | Ericsson | Rel-20 |  |  |  |  |  |
| 130 | 82.1 | Core part: Rel-20 NR Carrier Aggregation (CA)/Dual Connectivity (DC) for x bands DL with y bands UL (x<7, y<3) and Supplementary Uplink (SUL) band combinations/CA band combinations with a single SUL or two SUL cells plus high power UE | 462.88d | 2025-12-12 | 2027-03-03 |  |  | 37366.4d | finish no earlier than 2027-03-03 | R4 | 3703h |  | NR_CADC_SUL_R20_HPUE-Core | Ericsson | Rel-20 |  |  |  |  |  |
| 131 | 83 | Rel-20 Extended reality, Metaverse, Media | 824.12d? | 2024-04-02 A | 2026-06-06 |  | 824.12d? | 37646d | finish no earlier than 2026-06-06 |  |  |  |  |  | Rel-20 |  |  |  |  |  |
| 132 | 84 | Stage 2 for mobile metaverse services Phase 2 | 271.25d | 2025-03-26 A | 2025-12-12 A | 100% |  |  | finish no earlier than 2025-12-12 | S6 | 2170h | 2170h | Metaverse_Ph2-APP | Ramamoorthy, Arunprasath (Arun), Samsung, | Rel-20 |  | 54 | 107 | 23.437; 23.438 | arun.prasath@samsung.com |

Notes:
- 108: compare: REL-19 WI NR_demod_Ph5, REL-18 WI NR_demod_enh3, REL-17 WI NR_demod_enh2, REL-16 WI NR_perf_enh
- 109: compare: REL-19 WI NR_demod_Ph5, REL-18 WI NR_demod_enh3, REL-17 WI NR_demod_enh2, REL-16 WI NR_perf_enh ; 3/12/25: Compl:0%->22%; Stat Rep: ->RP-253457; ; 7/1/26: WID:RP-252957->RP-253458
- 110: compare: REL-19 WI NR_LBCA_Sw
- 111: compare: REL-19 WI NR_LBCA_Sw ; 3/12/25: Compl:0%->10%; Stat Rep: ->RP-253306;
- 112: ; 3/12/25: FCD:Thu 09/09/27->Tue 03/03/26; Stat Rep: ->RP-253306;
- 113: compare: REL-18 WI NR_UAV
- 114: compare: REL-18 WI NR_UAV ; 3/12/25: Compl:0%->12%; Stat Rep: ->RP-253478;
- 115: ; 3/12/25: Stat Rep: ->RP-253478;
- 116: 4940-4990 MHz NR TDD band for public safety in US, REL-independent from REL-15; Core part target colliding with REL-19 ASN.1 freeze ; 29/9/25: WID:RP-251887->RP-252929; 7/1/26: WID:RP-252929->RP-253836
- 117: 4940-4990 MHz NR TDD band for public safety in US, REL-independent from REL-15; Core part target colliding with REL-19 ASN.1 freeze ; 11/9/25: Compl:0%->15%; Stat Rep: ->RP-252349; ; 3/12/25: FCD:Fri 12/12/25->Fri 05/06/26; Compl:15%->60%; Stat Rep: RP-252349->RP-253441;
- 118: ; 11/9/25: Stat Rep: ->RP-252349; ; 3/12/25: Stat Rep: RP-252349->RP-253441;
- 119: -
- 122: -
- 131: -
- 132: ; 6/6/25: 0%->45; 12/9/25: 45%->65; 4/12/25: 65%->100

| ID | WBS | Task | Duration | Start | Finish | Complete | Remaining | Total slack | Constraint | Resources | Work | Actual work | Acronym | PCG approved | WI rapporteur name | Release | TSG approved | Status Report | Impacted TSs and TRs | WI rapporteur e-mail |
| --- | --- | --- | --- | --- | --- | --- | --- | --- | --- | --- | --- | --- | --- | --- | --- | --- | --- | --- | --- | --- |
| 133 | 85 | **XR (eXtended Reality) for NR Phase 4** | 658.62d | 2025-06-06 | 2027-03-03 |  |  | 37366.4d |  | R2 | 10538h |  | NR_XR_Ph | 55 | Meta | Rel-20 | 108 |  |  |  |
| 134 | 85.1 | Core part: XR (eXtended Reality) for NR Phase 4 | 658.62d | 2025-06-06 | 2027-03-03 |  |  | 37366.4d | finish no earlier than 2027-03-03 | R2 | 5269h |  | NR_XR_Ph4-Core | 55 | Meta | Rel-20 | 108 | RP-253364 |  |  |
| 135 | 86 | Study on Usage of Dynamically Changing Traffic Characteristics and Enhanced QoS support in Media Applications and Services | 377.88d | 2025-09-10 A | 2026-09-09 | 10% | 340.09d | 37547.6d | finish no earlier than 2026-09-09 | S4 | 3023h |  | FS_DCTC_eQOS_MED | 55 | Rufael Mekuria, Huawei | Rel-20 | 109 |  | 26.926; 26.925; 26.822; 26.812 ; 26.823 | Rufael.mekuria@huawei.com |
| 136 | 87 | Study of Advanced Video Formats and Operation Points | 377.88d | 2025-09-10 A | 2026-09-09 | 10% | 340.09d | 37547.6d | finish no earlier than 2026-09-09 | S4 | 3023h |  | FS_AVFOPS_MED | 55 | Emmanuel Thomas, Xiaomi | Rel-20 | 109 |  | 26.966 | thomase@xiaomi.com |
| 137 | 88 | Study on 3D Gaussian splats | 559.12d | 2025-09-10 A | 2027-03-03 | 10% | 503.21d | 37366.4d | finish no earlier than 2027-03-03 | S4 | 4473h |  | FS_3DGS_MED | 55 | Ricard Julien, Tencent | Rel-20 | 109 |  | 26.958 | jricard@global.tencent.com |
| 138 | 89 | Study on Advanced Media Delivery Phase 2 | 279.5d | 2025-09-10 A | 2026-06-06 | 10% | 251.55d | 37646d | finish no earlier than 2026-06-06 | S4 | 2236h |  | FS_AMD_Ph2 | 55 | Thomas Stockhammer, Qualcomm Incorporated, | Rel-20 | 109 |  | 26.802; 26.804; 26.941; 26.802; 26.804; 26.941 | tsto@qti.qualcomm.com. |
| 139 | 90 | Diverse audio Capturing System for UEs | 568.38d | 2024-12-05 A | 2026-06-06 | 60% | 227.35d | 37646d | finish no earlier than 2026-06-06 | S4 | 4547h |  | DaCAS | 54 | Wang Bin, Xiaomi Technology | Rel-20 | 106 |  | 26.533 | wangbin23@xiaomi.com |
| 140 | 91 | Study on Audio Codec APIs | 446.12d | 2024-04-02 A | 2025-06-06 | 60% | 178.45d | 38024d | finish no earlier than 2025-06-06 | S4 | 3569h |  | FS_ACAPI | 52 | Stefan Döhla | Rel-20 | 103 |  | 26.858 | (stefan DOT doehla AT iis DOT fraunhofer DOT de) |
| 141 | 92 | Terminal Audio quality performance and Test methods for Immersive Audio Services, Phase 3 | 472.12d | 2025-12-03 | 2027-03-03 |  |  | 37366.4d | finish no earlier than 2027-03-03 | S4 | 3777h |  | ATIAS_Ph3-MED |  | Jan Reimes, HEAD acoustics GmbH, | Rel-20 |  |  | 26.260; 26.261 | jan.reimes@head-acoustics.com |
| 142 | 93 | Study on evaluation of QUIC-based protocols for on-demand and live video services | 472.12d | 2025-12-03 | 2027-03-03 |  |  | 37366.4d | start no earlier than 2025-12-03 | S4 | 3777h |  | FS_QStream_MED |  | Emmanouil Potetsianakis, Xiaomi, | Rel-20 |  |  | 26.944 | emmanouil@xiaomi.com |
| 143 | 94 | Study on QUIC-based Media Delivery for Real-time Communication | 472.12d | 2025-12-03 | 2027-03-03 |  |  | 37366.4d | finish no earlier than 2027-03-03 | S4 | 3777h |  | FS_Q4RTC_MED |  | Serhan Gül, Nokia, | Rel-20 |  |  |  | serhan.guel@nokia.com |
| 144 | 95 | Study on advanced image formats | 290.88d | 2025-12-03 | 2026-09-09 |  |  | 37547.6d | finish no earlier than 2026-09-09 | S4 | 2327h |  | FS_AIF_MED |  | Waqar Zia, waqar_zia, Apple | Rel-20 |  |  |  | Waqar Zia, waqar_zia (at) apple.com |
| 145 | 96 | Study on Avatar communication Phase 2 | 290.88d | 2025-12-03 | 2026-09-09 |  |  | 37547.6d | start no earlier than 2025-12-03 | S4 | 2327h |  | FS_Avatar_Ph2_MED |  | Martin-Cocher, Gaëlle, | Rel-20 |  |  | 26.813 | gaelle.martin-cocher@interdigital.com |
| 146 | 97 | Study on Application enabler for XR Services Phase 3 | 271.25d | 2025-03-26 A | 2025-12-12 A | 100% |  |  | start no earlier than 2025-03-26 | S6 | 2170h | 2170h | FS_XRM_Ph3_APP | 54 | Liu, Tangqing, China Mobile | Rel-20 | 107 |  | 23.700-51 | liutangqing@chinamobile.com |
| 147 | 98 | Application enabler for XR Services Phase 3 | 290.88d | 2025-12-03 | 2026-09-09 |  |  | 37547.6d | finish no earlier than 2026-09-09 | S6 | 2327h |  | XRM_Ph3-APP |  | Tanqing, Liu, CMCC, | Rel-20 |  |  | 23.433; 23.542 | liutangqing@chinamobile.com |
| 148 | 99 | Rel-20 Integrated Sensing and Communication (Sensing, ISAC) | 824.12d? | 2024-04-02 A | 2026-06-06 |  | 824.12d? | 37646d | finish no earlier than 2026-06-06 |  |  |  |  |  |  | Rel-20 |  |  |  |  |
| 149 | 100 | Study on Stage 2 for Integrated Sensing and Communication | 271.25d | 2025-03-26 A | 2025-12-12 | 93% | 18.99d | 37828.2d | finish no earlier than 2025-12-12 | S2 | 2170h |  | FS_Sensing_ARC | 54 | Jianning LIU, Xiaomi | Rel-20 | 107 |  |  | liujianning@xiaomi.com |
| 150 | 101 | Study on Security and Privacy Aspects of Integrated Sensing and Communication | 279.5d | 2025-09-10 A | 2026-06-06 | 50% | 139.75d | 37646d | finish no earlier than 2026-06-06 | S3 | 2236h |  | FS_Sensing_SEC | 55 | Henry Leung (Xiaomi | Rel-20 | 109 |  | 33.777 | lianghaoran@xiaomi.com |
| 151 | 102 | Study on use of Sensing results for Vertical Applications | 281.75d | 2025-06-05 A | 2026-03-03 | 60% | 112.7d | 37744.2d | finish no earlier than 2026-03-03 | S6 | 2254h |  | FS_Sensing_APP | 55 | Liu, Yue, China Mobile | Rel-20 | 108 |  | 23.700-15 | liuyueyjy@chinamobile.com |
| 152 | 103 | Study on Integrated Sensing And Communication (ISAC) for NR | 378d | 2025-06-06 A | 2026-06-05 | 58% | 158.76d | 37647d | finish no earlier than 2026-06-05 | R1 | 3024h |  | FS_Sensing_NR_bis | 55 | Xiaomi | Rel-20 | 108 | RP-253245 | 38.765 |  |
| 153 | 104 | Study on 5GA Charging aspects of integrated sensing and communications | 290.88d | 2025-12-03 | 2026-09-09 |  |  | 37547.6d | finish no earlier than 2026-09-09 | S5 | 2327h |  | FS_Sensing_CH |  | Mingrui Sun (China Unicom) | Rel-20 |  |  |  | sunmr19@chinaunicom.cn |
| 154 | 105 | Study on Management aspects of Integrated Sensing and Communication | 388.25d | 2025-12-03 | 2026-12-12 |  |  | 37450.2d | finish no earlier than 2026-12-12 | S5 | 3106h |  | FS_Sensing_OAM |  | Ruan bangqiu (ZTE) | Rel-20 |  |  |  | ruan.bangqiu@zte.com.cn |
| 155 | 106 | **Indirect Network Sharing Phase 2** | 978.25d | 2024-02-08 A | 2026-09-09 A | 100% |  |  |  |  | 5607h | 5607h | NetShare_Ph2 | 53 | Qun Wei, China Unicom | Rel-20 | 105 |  | 22.261 | weiqun5@chinaunicom.cn |
| 156 | 106.1 | Stage 1 for Indirect Network Sharing Phase 2 | 222.5d | 2024-02-08 A | 2024-09-09 A | 100% |  |  | finish no earlier than 2124-09-09 | S1 | 1780h | 1780h | NetShare_Ph2-REQ | 53 | Qun Wei, China Unicom | Rel-20 | 105 |  |  | weiqun5@chinaunicom.cn |
| 157 | 106.2 | Stage 2 for Indirect Network Sharing Phase2 | 478.38d | 2025-06-05 A | 2026-09-09 A | 100% |  |  | finish no earlier than 2026-09-09 | S2 | 3827h | 3827h | TEI20_NetShare_Ph2-ARC | 55 | Tianqi Xing, China Unicom | Rel-20 | 108 |  | 23.501; 23.502; 23.503 | xingtq@chinaunicom.cn |

Notes:
- 133: no Perf. part; no affected RAN2 spec??? ; 29/9/25: WID:RP-251866->RP-252755
- 134: no Perf. part; no affected RAN2 spec??? ; 11/9/25: Stat Rep: ->RP-252754; ; 3/12/25: Stat Rep: RP-252754->RP-253364;
- 135: ; 4/12/25: 0%->10; 7/1/26: 26.823 added;
- 136: ; 29/9/25: WID:SP-250938->SP-251202; 4/12/25: 0%->10
- 137: 4/12/25: 0%->10; 4/12/25: FCD:Tue 03/03/->/27; 7/1/26: 26.958 added;
- 138: ; 4/12/25: 0%->10
- 139: 6/3/25: 0%->5; 5/6/25: 5%->50; 5/6/25: FCD:Fri 06/06/->/25; 12/9/25: 50%->55; 12/9/25: FCD:Tue 09/09/->/2026; Rel-19->Rel-20; 4/12/25: 55%->60
- 140: 14/5/24: 26.858 added;; 13/6/24: 0%->10; 5/12/24: 10%->20; 5/12/24: FCD:03/03/2025->/25; 6/3/25: 20%->40; 5/6/25: 40%->47; 5/6/25: FCD:Sat 25/01/->12/25; 12/9/25: 47%->49; Rel-19->Rel-20; 4/12/25: 49%->60; 4/12/25: FCD:Fri 12/12/->/25
- 146: 3/4/25: 23.700-51 added;; 6/6/25: 0%->35; 12/9/25: 35%->70; 29/9/25: WID:SP-250381->SP-251042; 4/12/25: 70%->100
- 148: -
- 149: ; 27/6/25: WID:SP-250401->SP-250809; 12/9/25: 0%->65; 4/12/25: 65%->93
- 150: 4/12/25: 0%->50
- 151: 18/7/25: 23.700-15 added;; 12/9/25: 0%->15; 29/9/25: WID:SP-250875->SP-251044; 4/12/25: 15%->60
- 152: compare REL-19 RAN1 SI FS_Sensing_NR and REL-20 SA2 SI FS_Sensing_ARC; 38.xxx ? ; 11/9/25: FCD:Sat 06/06/26->Fri 05/06/26; Compl:0%->15%; Stat Rep: ->RP-252200; ; 29/9/25: WID:RP-251861->RP-252819; 30/9/25: 38.765 added;; 3/12/25: FCD:Sat 06/06/26->Fri 0; 7/1/26: WID:RP-252819->RP-253246
- 157: ; 4/12/25: 0%->100

| ID | WBS | Task | Type | Duration | Start | Finish | Complete | Remaining | Total slack | Constraint | Resources | Work | Actual work | Acronym | PCG approved | Release | TSG approved | WI rapporteur name | WI rapporteur e-mail |
| --- | --- | --- | --- | --- | --- | --- | --- | --- | --- | --- | --- | --- | --- | --- | --- | --- | --- | --- | --- |
| 158 | 107 | **FRMCS Phase 6** |  | 844.88d | 2024-03-13 A | 2026-06-06 | 82% | 148.62d | 37646d |  |  | 7218h | 3590h | FRMCS_Ph6 | 55 | Rel-20 | 108 |  |  |
| 159 | 107.1 | Study on FRMCS Phase 6 |  | 254d | 2024-03-13 A | 2025-03-03 A | 100% |  |  | finish no earlier than 2025-03-03 | S1 | 2032h | 2032h | FS_FRMCS_Ph6 | 52 | Rel-20 | 103 | Nikolopoulou, Vassiliki, UIC, | nikolopoulou@uic.org |
| 160 | 107.2 | Stage 1 for FRMCS Phase 6 |  | 194.75d | 2025-03-06 A | 2025-09-09 A | 100% |  |  | finish no earlier than 2025-09-09 | S1 | 1558h | 1558h | FRMCS_Ph6-REQ | 54 | Rel-20 | 107 | Nikolopoulou, Vassiliki, UIC | nikolopoulou@uic.org |
| 161 | 107.3 | Stage 2 for FRMCS Phase 6 |  | 453.5d | 2025-03-26 A | 2026-06-06 | 65% | 158.72d | 37646d | start no earlier than 2025-03-26 | S6 | 3628h |  | FRMCS_Ph6-MC | 54 | Rel-20 | 107 | Oettl, Martin, Nokia | martin.oettl@nokia.com |
| 162 | 108 | **Short Message Service to Emergency Response Centre** |  | 325d | 2025-02-02 A | 2025-12-12 | 78% | 70.24d | 37828.2d |  |  | 1830h | 248h | SMS2EC | 55 | Rel-20 | 108 |  |  |
| 163 | 108.1 | Stage 1 of SMS to Emergency Centre |  | 31d | 2025-02-02 A | 2025-03-03 A | 100% |  |  | start no earlier than 2025-02-02 | S1 | 248h | 248h | SMS2EC-REQ | 54 | Rel-20 | 107 | Francesco Pica, Qualcomm | fpica@qti.qualcomm.com |
| 164 | 108.2 | Study on Short Message Service to Emergency Response Centre |  | 197.75d | 2025-06-05 A | 2025-12-12 | 75% | 49.44d | 37828.2d | finish no earlier than 2025-12-12 | S2 | 1582h |  | FS_SMS2EC_ARC | 55 | Rel-20 | 108 | Krisztian Kiss, Apple | krisztian@apple.com |
| 165 | 109 | Rel-20 IMS related aspects |  | 1d | 2019-03-07 | 2019-03-07 |  |  | 40387.9d |  |  |  |  |  |  | Rel-20 |  |  |  |
| 166 | 110 | Study on IMS Architecture Enhancement |  | 535.25d | 2026-01-06 | 2027-06-06 |  |  | 37268d | finish no earlier than 2027-06-06 | S2 | 4282h |  | FS_enIMS_ARC |  | Rel-20 |  | Dieter Gludovacz (Deutsche Telekom), | dieter.gludovacz@magenta.at |
| 167 | 111 | Study on IMS DC Enhancements |  | 192.5d | 2025-12-03 | 2026-06-06 |  |  | 37646d | finish no earlier than 2026-06-06 | S4 | 1540h |  | FS_DCE_MED |  | Rel-20 |  | Bouazizi, Imed, Qualcomm Inc., | bouazizi@qti.qualcomm.com |
| 168 | 112 | Study on Security Aspects for IMS resiliency |  | 181.25d | 2025-09-10 A | 2026-03-03 | 5% | 172.19d | 37744.2d | finish no earlier than 2026-03-03 | S3 | 1450h |  | FS_IMSRE_SEC | 55 | Rel-20 | 109 | Rohini Rajendran (Samsung | r.rohini@samsung.com |
| 169 | 113 | Study on IMS resiliency |  | 99.5d | 2025-06-06 A | 2025-09-09 | 58% | 41.79d | 37925.5d | finish no earlier than 2025-09-09 | C4 | 796h |  | FS_IMSResil | 51 | Rel-20 | 101 | Kenichi Yamamoto, KDDI | kc-yamamoto@kddi.com |
| 170 | 114 | see also UID 1080049 Media aspects for AI/ML in IMS services |  | 1d | 2019-03-07 | 2019-03-07 |  |  | 40387.9d |  |  |  |  |  |  | Rel-20 |  |  |  |
| 171 | 115 | Rel-20 Other topics |  | 824.12d? | 2024-04-02 A | 2026-06-06 |  | 824.12d? | 37646d | finish no earlier than 2026-06-06 |  |  |  |  |  | Rel-20 |  |  |  |
| 172 | 116 | Service Enabler Architecture Layer (SEAL) Phase 4 |  | 181.25d | 2025-09-10 A | 2026-03-03 | 45% | 99.69d | 37744.2d | finish no earlier than 2026-03-03 | S6 | 1450h |  | SEAL_Ph4-APP | 55 | Rel-20 | 109 | Yang, Yanmei, Huawei Technologies Co. Ltd. | <yangyanmei@huawei.com> |
| 173 | 117 | Study on SEAL data delivery Phase 3 |  | 355.25d | 2025-03-26 A | 2026-03-03 | 95% | 17.76d | 37744.2d | finish no earlier than 2026-03-03 | S6 | 2842h |  | FS_SEALDD_Ph3 | 54 | Rel-20 | 107 | Ge, Cuili, Huawei | gecuili@huawei.com |
| 174 | 118 | SEAL data delivery Phase 3 |  | 290.88d | 2025-12-03 | 2026-09-09 |  |  | 37547.6d | finish no earlier than 2026-09-09 | S6 | 2327h |  | SEALDD_Ph3-APP |  | Rel-20 |  | Cuili Ge, Huawei | gecuili@huawei.com |
| 175 | 119 | Study on Logging and recording of mission critical services, Phase 2 |  | 355.25d | 2025-03-26 A | 2026-03-03 | 40% | 213.15d | 37744.2d | start no earlier than 2025-03-26 | S6 | 2842h |  | FS_MCLOG_Ph2 | 54 | Rel-20 | 107 | Vialen, Jukka, Airbus | jukka.vialen@airbus.com |
| 176 | 120 | Study on Discreet listening and monitoring of mission critical services, Phase 2 |  | 355.25d | 2025-03-26 A | 2026-03-03 | 40% | 213.15d | 37744.2d | start no earlier than 2025-03-26 | S6 | 2842h |  | FS_MCDISC_Ph2 | 54 | Rel-20 | 107 | Verweij, Kees, Netherlands Police, | kees.verweij@politie.nl |
| 177 | 121 | Study on security aspect of support of Ambient power-enabled Internet of Things-Phase 2 |  | 279.5d | 2025-09-10 A | 2026-06-06 | 30% | 195.65d | 37646d | finish no earlier than 2026-06-06 | S3 | 2236h |  | FS_AIoT_SEC_Ph2 | 55 | Rel-20 | 109 | Lihui Xiong (OPPO | xionglihui@oppo.com |
| 178 | 122 | Study on security for PLMN hosting a NPN phase 2 |  | 279.5d | 2025-09-10 A | 2026-06-06 | 35% | 181.68d | 37646d | finish no earlier than 2026-06-06 | S3 | 2236h |  | FS_PLMNNPN_Ph2 | 55 | Rel-20 | 109 | Jun Shen (China Telecom | shenjun6@chinatelecom.cn |
| 179 | 123 | Study on providing PSK for MPQUIC/TLS |  | 181.25d | 2025-09-10 A | 2026-03-03 | 79% | 38.06d | 37744.2d | finish no earlier than 2026-03-03 | S3 | 1450h |  | FS_PSK_MQC_TLS | 55 | Rel-20 | 109 | Li He, (Huawei | lihe2@huawei.com |
| 180 | 124 | Study of CAPIF Phase 4 |  | 281.75d | 2025-06-05 | 2026-03-03 |  |  | 37744.2d | finish no earlier than 2026-03-03 | S6 | 2254h |  | FS_CAPIF_Ph4 | 55 | Rel-20 | 108 | Sapan Shah, Nokia | sapan.shah@nokia.com |
| 181 | 125 | Study on Security aspects of CAPIF Phase 4 |  | 475.25d | 2025-09-10 A | 2026-12-12 | 50% | 237.62d | 37450.2d | finish no earlier than 2026-12-12 | S3 | 3802h |  | FS_CAPIF_Ph4_SEC | 55 | Rel-20 | 109 | Weiyin Zhang(China Telecom, | zhangwy12@chinatelecom.cn |
| 182 | 126 | Security Assurance Specification (SCAS) for the CAPIF Core Function |  | 192.5d | 2025-12-03 | 2026-06-06 |  |  | 37646d | finish no earlier than 2026-06-06 | S3 | 1540h |  | SCAS_5GA_CAPIF |  | Rel-20 |  | Lisanne Gebhardt, BSI | lisanne.gebhardt@bsi.bund.de |
| 183 | 127 | Study on Security Assurance Specification (SCAS) for Container-based Product |  | 377.88d | 2025-09-10 A | 2026-09-09 | 79% | 79.35d | 37547.6d | finish no earlier than 2026-09-09 | S3 | 3023h |  | FS_SCAS_CP | 55 | Rel-20 | 109 | Markus Hanhisalo (Ericsson | markus.hanhisalo@ericsson.com |
| 184 | 128 | PRINS Refinement |  | 181.25d | 2025-09-10 A | 2026-03-03 | 60% | 72.5d | 37744.2d | finish no earlier than 2026-03-03 | S3 | 1450h |  | RefinePRINS | 55 | Rel-20 | 109 | Tao Wan (CableLabs | t.wan@cablelabs.com |
| 185 | 129 | Security Assurance Specification (SCAS) for NR Femto |  | 279.5d | 2025-09-10 A | 2026-06-06 | 30% | 195.65d | 37646d | finish no earlier than 2026-06-06 | S3 | 2236h |  | SCAS_NR_Femto | 55 | Rel-20 | 109 | Zhonghuai Xie (China Unicom | xiezh55@chinaunicom.cn |
| 186 | 130 | 5G Security Assurance Specification (SCAS) for NR Femto Security Gateway (SeGW) |  | 279.5d | 2025-09-10 A | 2026-06-06 | 50% | 139.75d | 37646d | finish no earlier than 2026-06-06 | S3 | 2236h |  | SCAS_Femto_SeGW | 55 | Rel-20 | 109 | Shihan Bao (CATT | baoshihan@cictmobile.com |
| 187 | 131 | Study on security aspects of WAB nodes for NR |  | 259.75d | 2025-09-29 A | 2026-06-06 | 25% | 194.81d | 37646d | finish no earlier than 2026-06-06 | S3 | 2078h |  | FS_5G_WAB_SEC | 55 | Rel-20 | 109 | Weihan Gao (China Telecom) | gaowh@chinatelecom..cn |
| 188 | 132 | Study on Security Aspect for NR Femto Phase 2 |  | 279.5d | 2025-09-10 A | 2026-06-06 | 40% | 167.7d | 37646d | finish no earlier than 2026-06-06 | S3 | 2236h |  | FS_NR_Femto_SEC_Ph2 | 55 | Rel-20 | 109 | Peilin Liu (ZTE | liu.peilin@zte.com.cn |
| 189 | 133 | Study on best security practices for SBA |  | 181.25d | 2025-09-10 A | 2026-03-03 | 75% | 45.31d | 37744.2d | finish no earlier than 2026-03-03 | S3 | 1450h |  | FS_BSP4SBA | 55 | Rel-20 | 109 | Imran Saleem (Huawei | imran.saleem1@huawei.com |
| 190 | 134 | Study on supporting AEAD algorithms |  | 377.88d | 2025-09-10 A | 2026-09-09 | 20% | 302.3d | 37547.6d | finish no earlier than 2026-09-09 | S3 | 3023h |  | FS_AEAD | 55 | Rel-20 | 109 | Yuto Nakano (KDDI, | yt-nakano@kddi.com |
| 191 | 135 | Stage 1 for Phase 2 of Mission Critical Discreet listening |  | 34.25d | 2025-08-08 A | 2025-09-09 A | 100% |  |  | finish no earlier than 2025-09-09 | S1 | 274h | 274h | MCDISC_Ph2-REQ | 55 | Rel-20 | 109 | Kees Verweij, Netherlands Police: | keesdotverweijatpolitiedotnl |
| 192 | 136 | Model Evaluation Metrics Enhancement |  | 181.25d | 2025-09-10 | 2026-03-03 |  |  | 37744.2d | finish no earlier than 2026-03-03 | S2 | 1450h |  | TEI20_Metrics | 55 | Rel-20 | 109 | Yuang Feng(ZTE) | feng.yuang@zte.com.cn |
| 193 | 137 | NR to LTE mobility restriction |  | 161.5d | 2025-09-29 A | 2026-03-03 A | 100% |  |  | finish no earlier than 2026-03-03 | S2 | 1292h | 1292h | TEI20_NRLTEREST | 55 | Rel-20 | 109 | Sushmit Bhattacharjee (NTT DOCOMO) | bhattacharjee@docomolab-euro.com |
| 194 | 138 | Support for Ethernet PDU session for backhauling of MWAB |  | 181.25d | 2025-09-10 A | 2026-03-03 A | 100% |  |  | finish no earlier than 2026-03-03 | S2 | 1450h | 1450h | TEI20_Eth4MWAB | 55 | Rel-20 | 109 | Cheng, Hong, Qualcomm Incorporated | hongc@qti.qualcomm.com |
| 195 | 139 | Support of NSSAA in EPS |  | 161.5d | 2025-09-29 A | 2026-03-03 A | 100% |  |  | finish no earlier than 2026-03-03 | S2 | 1292h | 1292h | TEI20_NEPS | 55 | Rel-20 | 109 | Alessio Casati, Nokia | alessio.casati@nokia.com |
| 196 | 140 | Deferred AM Policies in the 5GC |  | 181.25d | 2025-09-10 | 2026-03-03 |  |  | 37744.2d | finish no earlier than 2026-03-03 | S2 | 1450h |  | TEI20_DAMP | 55 | Rel-20 | 109 | Baniel, Uri, Oracleuri dot baniel at oracle dot com, O | uri dot baniel at oracle dot com |
| 197 | 141 | Dynamic NITZ Update |  | 215.5d | 2025-08-08 | 2026-03-03 |  |  | 37744.2d | finish no earlier than 2026-03-03 | S2 | 1724h |  | TEI20_DNU | 55 | Rel-20 | 109 | Aihua Li, China Mobile | <liaihua@chinamobile.com> |
| 198 | 142 | Providing per-subscriber Allowed MAC addresses from UDM |  | 181.25d | 2025-09-10 A | 2026-03-03 A | 100% |  |  | finish no earlier than 2026-03-03 | S2 | 1450h | 1450h | TEI20_MACSUB | 55 | Rel-20 | 109 | Ashok Kumar Nayak, Samsung | ashok.nayak @ samsung.com |
| 199 | 143 | Mission critical security for Rel-20 |  | 658.62d | 2019-03-07 A | 2020-12-01 | 30% | 461.04d | 39730.2d |  | S3 | 5269h |  | MCX20-SEC | 55 | Rel-20 | 108 | Woodward, Tim, Motorola Solutions, Inc., | tim.woodward@motorolasolutions.com |
| 200 | 144 | Vehicle-Mounted Relays Phase3 |  | 6d | 2024-12-05 A | 2024-12-12 A | 100% |  |  | finish no earlier than 2024-12-12 | S1 | 48h | 48h | VMR_Ph3 | 54 | Rel-20 | 106 | Qing Wan, CATT, | wanqing1@cictmobile.com |
| 201 | 145 | Resident Phase 2 |  | 4d | 2024-09-04 A | 2024-09-09 A | 100% |  |  | finish no earlier than 2024-09-09 | S1 | 32h | 32h | Resident_Ph2 | 53 | Rel-20 | 105 | Qun Wei, China Unicom | weiqun5@chinaunicom.cn |
| 202 | 146 | 5G ProSe Phase 4 |  | 478.38d | 2025-06-05 A | 2026-09-09 A | 100% |  |  | finish no earlier than 2026-09-09 | S2 | 3827h | 3827h | ProSe_Ph4-ARC | 55 | Rel-20 | 108 | Toumi, Nassima, KPN N.V. | nassima (dot) toumi (dot) tno (dot) nl |
| 203 | 147 | Study on Transitioning to Post Quantum Cryptography in 3GPP |  | 380d | 2025-06-05 A | 2026-06-06 | 50% | 190d | 37646d | finish no earlier than 2026-06-06 | S3 | 3040h |  | FS_CryptoPQC | 55 | Rel-20 | 108 | Zander, Huawei | lei.zhongding@huawei.com |
| 204 | 148 | CPAS specific requirement |  | 2d | 2025-06-05 A | 2025-06-06 A | 100% |  |  | finish no earlier than 2025-06-06 | S1 | 16h | 16h | CPAS-REQ | 55 | Rel-20 | 108 | Pengtai Qin | qinpengtai@chinamobile.com |
| 205 | 149 | Security Assurance Specification for 5G-Advanced |  | 478.38d | 2025-06-05 A | 2026-09-09 | 50% | 239.19d | 37547.6d | finish no earlier than 2026-09-09 | S3 | 3827h |  | SCAS_5GA | 55 | Rel-20 | 108 | Wurong (raina), Huawei | raina.wu@huawei.com |
| 206 | 150 | Security related Events Handling |  | 197.75d | 2025-06-05 A | 2025-12-12 | 70% | 59.33d | 37828.2d | finish no earlier than 2025-12-12 | S3 | 1582h |  | SECHAND | 55 | Rel-20 | 108 | Susana Sabater, Vodafone | susana.sabater@vodafone.com |
| 207 | 151 | Management for Security-related events handling (SECHAND) |  | 388.25d | 2025-12-03 | 2026-12-12 |  |  | 37450.2d | finish no earlier than 2026-12-12 | S5 | 3106h |  | SECHAND-OAM |  | Rel-20 |  | Veronica Gonzalez (VDF) | veronica.gonzalez2@vodafone.com |
| 208 | 152 | Guidelines for 3GPP Application Enablement usage |  | 281.75d | 2025-06-05 A | 2026-03-03 | 60% | 112.7d | 37744.2d | finish no earlier than 2026-03-03 | S6 | 2254h |  | AppEnable_EXT | 55 | Rel-20 | 108 | David Artuñedo, Telefónica | david.artunedoguillen@telefonica.com |
| 209 | 153 | Study on Application user consent |  | 281.75d | 2025-06-05 A | 2026-03-03 | 60% | 112.7d | 37744.2d | finish no earlier than 2026-03-03 | S6 | 2254h |  | FS_APCOT | 55 | Rel-20 | 108 | Cristina Badulescu | cristina.badulescu@ericsson.com |
| 210 | 154 | Study on system architecture for Phase 3 of NG RTC |  | 281.75d | 2025-06-05 A | 2026-03-03 | 80% | 56.35d | 37744.2d | finish no earlier than 2026-03-03 | S2 | 2254h |  | FS_NG_RTC_Ph3_ARC | 55 | Rel-20 | 108 | Christopher Joul, T-Mobile USA, | chris.joul@t-mobile.com |
| 211 | 155 | Study on Service Enabler Architecture Layer (SEAL) Phase 4 |  | 481.38d | 2024-09-04 A | 2025-12-12 A | 100% |  |  | finish no earlier than 2025-12-12 | S6 | 3851h | 3851h | FS_SEAL_Ph4 | 53 | Rel-20 | 105 | Yang, Yanmei, Huawei Technologies Co.,Ltd. | yangyanmei@huawei.com |
| 212 | 156 | Stage 1 for Ambient listening enhancements including pause and resume in MCS |  | 21d | 2025-02-11 A | 2025-03-03 A | 100% |  |  | finish no earlier than 2025-03-03 | S1 | 168h | 168h | ALPR-REQ | 54 | Rel-20 | 107 | S. (Ram) Ramanan | Sivasubramaniam.ramanan@homeoffice.gov.uk |
| 213 | 157 | Study on Stage 2 for MMTel Phase 2 |  | 355.25d | 2025-03-26 A | 2026-03-03 | 75% | 88.81d | 37744.2d | start no earlier than 2025-03-26 | S6 | 2842h |  | FS_MMTel_Ph2_APP | 54 | Rel-20 | 107 | Liu, Yue, China Mobile | liuyueyjy@chinamobile.com |
| 214 | 158 | Stage 2 for Mission Critical Services for UE-to-UE and UE-to-Network over multi-hop relay | manual | 355.25d | 2025-03-26 A | 2026-03-03 A | 100% |  |  | start no earlier than 2025-03-26 | S6 | 2842h | 2842h | MultiHop-MC | 54 | Rel-20 | 107 | Lipford, Mark, FirstNet Authority | mark.lipford@firstnet.gov |
| 215 | 159 | Stage 2 for Enhanced Mission Critical Services Architecture Phase 2 |  | 453.5d | 2025-03-26 A | 2026-06-06 | 45% | 249.43d | 37646d | start no earlier than 2025-03-26 | S6 | 3628h |  | enhMC_Ph2-MC | 54 | Rel-20 | 107 | Negalaguli, Harish, Motorola Solutions | harish.negalaguli@motorolasolutions.com |
| 216 | 160 | Combined QoS configuration and monitoring |  | 4d | 2024-09-04 A | 2024-09-09 A | 100% |  |  | finish no earlier than 2024-09-09 | S1 | 32h | 32h | CombQoS | 53 | Rel-20 | 105 | Yansheng Liu, ZTE | liu.yansheng@zte.com.cn |
| 217 | 161 | Legacy Residential Gateway Supporting 5G LAN-type Service |  | 4d | 2024-09-04 A | 2024-09-09 A | 100% |  |  | finish no earlier than 2024-09-09 | S1 | 32h | 32h | LegacyRG_5GLAN | 53 | Rel-20 | 105 | Yuying Zhang, China Telecom | zhangyy45@chinatelecom.cn |
| 218 | 162 | Exposure for Virtual Network information and capability |  | 4d | 2024-09-04 A | 2024-09-09 A | 100% |  |  | finish no earlier than 2024-09-09 | S1 | 32h | 32h | VNExposure | 53 | Rel-20 | 105 | Pengtai Qin, China Mobile | qinpengtai@chinamobile.com |
| 219 | 163 | Study on enhanced security management service for security configuration provisioning |  | 388.25d | 2025-12-03 | 2026-12-12 |  |  | 37450.2d | finish no earlier than 2026-12-12 | S3 | 3106h |  | FS_SCP |  | Rel-20 |  | Minpeng Qi, CMCC | qiminpeng@chinamobile.com |
| 220 | 164 | Rel-20 Miscellaneous OAM&Charging |  | 824.12d? | 2024-04-02 A | 2026-06-06 |  | 824.12d? | 37646d | finish no earlier than 2026-06-06 |  |  |  |  |  | Rel-20 |  |  |  |
| 221 | 165 | Study on intent driven management services for mobile network phase 4 |  | 281.75d | 2025-06-05 A | 2026-03-03 | 85% | 42.26d | 37744.2d | finish no earlier than 2026-03-03 | S5 | 2254h |  | FS_IDMS_MN_Ph4 | 55 | Rel-20 | 108 | Ruiyue Xu (Huawei), | xuruiyue@huawei.com |
| 222 | 166 | Study on Management Data Analytics (MDA) phase 4 |  | 281.75d | 2025-06-05 A | 2026-03-03 | 60% | 112.7d | 37744.2d | finish no earlier than 2026-03-03 | S5 | 2254h |  | FS_eMDAS_Ph4 | 55 | Rel-20 | 108 | Brendan T Hassett (Huawei), | brendan.t.hassett@huawei.com |
| 223 | 167 | Study on Service Based Management Architecture enhancement phase 4 |  | 281.75d | 2025-06-05 A | 2026-03-03 | 50% | 140.88d | 37744.2d | finish no earlier than 2026-03-03 | S5 | 2254h |  | FS_SBMA_Ph4 | 55 | Rel-20 | 108 | Kai Zhang (Huawei), | kai.zhangkai@huawei.com |
| 224 | 168 | Study on Enhanced exposure of management services |  | 281.75d | 2025-06-05 A | 2026-03-03 | 20% | 225.4d | 37744.2d | finish no earlier than 2026-03-03 | S5 | 2254h |  | FS_EnExpo | 55 | Rel-20 | 108 | Winnie Nakimuli (Nokia) | winnie.nakimuli@nokia.com |
| 225 | 169 | Study for Data management phase 3 |  | 281.75d | 2025-06-05 A | 2026-03-03 | 25% | 211.31d | 37744.2d | finish no earlier than 2026-03-03 | S5 | 2254h |  | FS_MADCOL_Ph3 | 55 | Rel-20 | 108 | Sreekumar PK (Nokia), | sreekumar.pk@nokia.com |
| 226 | 170 | Study on management aspects of Network Digital Twins phase 2 |  | 281.75d | 2025-06-05 A | 2026-03-03 | 50% | 140.88d | 37744.2d | finish no earlier than 2026-03-03 | S5 | 2254h |  | FS_NDT_Ph2 | 55 | Rel-20 | 108 | Xian Zhao (Huawei), | zhaoxian7@huawei.com |
| 227 | 171 | Study on Closed Control Loop Management phase 2 |  | 281.75d | 2025-06-05 A | 2026-03-03 | 70% | 84.53d | 37744.2d | finish no earlier than 2026-03-03 | S5 | 2254h |  | FS_CCLM_Ph2 | 55 | Rel-20 | 108 | Deepanshu Gautam (Samsung), | deepanshu.g@samsung.com |

Notes:
- 159: ; 13/6/24: 0%->20; 4/9/24: 20%->40; 26/9/24: WID:SP-240199->SP-241392; 26/9/24: FCD:09/09/2024->/25; 6/3/25: 40%->100 / Impacted TSs and TRs: 22.989
- 160: ; 6/6/25: 0%->10; 6/6/25: FCD:Fri 06/06/->/25; 12/9/25: 10%->100 / Impacted TSs and TRs: 22.280; 22.179; 22.281
- 161: ; 6/6/25: 0%->35; 12/9/25: 35%->45; 4/12/25: 45%->65 / Impacted TSs and TRs: 23.280; 23.281; 23.282; 23.379; 23.283; 23.289
- 163: Impacted TSs and TRs: 22.201
- 164: 12/9/25: 0%->25; 29/9/25: WID:SP-250837->SP-251216; 4/12/25: 25%->75; 4/12/25: FCD:Tue 03/03/->12/25 / Impacted TSs and TRs: 23.700-65
- 168: 4/12/25: 0%->5 / Impacted TSs and TRs: 33.768
- 169: Move to Rel-20 as it was not completed in Rel-19 / Impacted TSs and TRs: 29.867
- 171: -
- 172: ; 4/12/25: 0%->45; 7/1/26: 23.949 added; / Impacted TSs and TRs: 23.433; 23.434; 23.435; 23.436; 23.437; 23.438; 23.222 ; 23.949
- 173: 3/4/25: 23.700-52 added;; 6/6/25: 0%->30; 12/9/25: 30%->40; 29/9/25: FCD:Fri 12/12/->/26; 29/9/25: WID:SP-250382->SP-251217; 4/12/25: 40%->95; 6/1/26: WID:SP-251217->SP-251681 / Impacted TSs and TRs: 23.700-52
- 174: Impacted TSs and TRs: 23.433
- 175: 3/4/25: 23.700-39 added;; 6/6/25: 0%->10; 27/6/25: WID:SP-250380->SP-250581; 12/9/25: 10%->20; 4/12/25: 20%->40 / Impacted TSs and TRs: 23.700-39
- 176: 3/4/25: 23.700-37 added;; 6/6/25: 0%->10; 12/9/25: 10%->20. Rapporteur corrected to Kees (was Juha); 4/12/25: 20%->40 / Impacted TSs and TRs: 23.700-37
- 177: 4/12/25: 0%->30 / Impacted TSs and TRs: 33.714
- 178: 4/12/25: 0%->35 / Impacted TSs and TRs: 33.758
- 179: 4/12/25: 0%->79; 4/12/25: 79%-> / Impacted TSs and TRs: 33.778
- 180: 18/7/25: 23.700-43 added;; 29/9/25: WID:SP-250873->SP-251043 / Impacted TSs and TRs: 23.700-43
- 181: 4/12/25: 0%->50; 6/1/26: WID:SP-251245->SP-251677 / Impacted TSs and TRs: 33.700-23
- 182: Impacted TSs and TRs: 33.926
- 183: 4/12/25: 0%->79 / Impacted TSs and TRs: 33.730
- 184: ; 4/12/25: 0%->60 / Impacted TSs and TRs: 33.501
- 185: ; 4/12/25: 0%->30 / Impacted TSs and TRs: 33.546, 33.926
- 186: ; 4/12/25: 0%->50 / Impacted TSs and TRs: 33.547, 33.926
- 187: 4/12/25: 0%->25 / Impacted TSs and TRs: 33.724
- 188: 4/12/25: 0%->40; 6/1/26: WID:SP-251249->SP-251518 / Impacted TSs and TRs: 33.746
- 189: 4/12/25: 0%->75 / Impacted TSs and TRs: 33.755
- 190: 4/12/25: 0%->20 / Impacted TSs and TRs: 33.771
- 191: ; 12/9/25: 0%->100 / Impacted TSs and TRs: 22.280
- 192: Impacted TSs and TRs: 23.288
- 193: ; 4/12/25: 0%->100 / Impacted TSs and TRs: 23.501
- 194: ; 4/12/25: 0%->100 / Impacted TSs and TRs: 23.501
- 195: ; 4/12/25: 0%->100 / Impacted TSs and TRs: 23.501; 23.502
- 196: Impacted TSs and TRs: 23.503; 23.502
- 197: Impacted TSs and TRs: 23.501; 23.502; 23.503
- 198: ; 4/12/25: 0%->100 / Impacted TSs and TRs: 23.501; 23.502
- 199: ; 12/9/25: 0%->10; 4/12/25: 10%->30 / Impacted TSs and TRs: 33.180
- 200: ; 5/12/24: 0%->100 / Impacted TSs and TRs: 22.261
- 201: Impacted TSs and TRs: 22.261
- 202: ; 4/12/25: 0%->100 / Impacted TSs and TRs: 23.304
- 203: 12/9/25: 0%->15; 12/9/25: 33.703 added;; 4/12/25: 15%->50 / Impacted TSs and TRs: 33.703
- 204: ; 5/6/25: 0%->100 / Impacted TSs and TRs: 23.304
- 205: 12/9/25: 0%->15; 4/12/25: 15%->50
- 206: 18/7/25: 33.502 added;; 12/9/25: 0%->20; 4/12/25: 20%->70; 6/1/26: WID:SP-250876->SP-251689 / Impacted TSs and TRs: 33.502
- 208: 12/9/25: 0%->5; 4/12/25: 5%->60
- 209: 18/7/25: 23.700-42 added;; 12/9/25: 0%->5; 4/12/25: 5%->60 / Impacted TSs and TRs: 23.700-42
- 210: 12/9/25: 0%->20; 4/12/25: 20%->80
- 211: 5/12/24: 0%->20; 6/3/25: 20%->40. Moved from Rel-19; 26/3/25: WID:SP-241375->SP-250374; 26/3/25: FCD:12/12/2024->12/25; 6/6/25: 40%->75; 12/9/25: 75%->95; 4/12/25: 95%->100
- 212: ; 26/3/25: 0%->100 / Impacted TSs and TRs: 22.179; 22.280
- 213: 3/4/25: 23.700-57 added;; 6/6/25: 0%->30; 12/9/25: 30%->40; 4/12/25: 40%->75 / Impacted TSs and TRs: 23.700-57
- 214: ; 6/6/25: 0%->75; 12/9/25: 0%->75; 4/12/25: 0%->100 / Impacted TSs and TRs: 23.289
- 215: ; 6/6/25: 0%->15; 12/9/25: 15%->30; 4/12/25: 30%->45 / Impacted TSs and TRs: 23.280; 23.379; 23.281; 23.282; 23.283; 23.289
- 216: Impacted TSs and TRs: 22.261
- 217: Impacted TSs and TRs: 22.261
- 218: Impacted TSs and TRs: 22.261
- 220: -
- 221: 18/7/25: 28.881 added;; 12/9/25: 0%->15; 4/12/25: 15%->85 / Impacted TSs and TRs: 28.881
- 222: 18/7/25: 28.886 added;; 12/9/25: 0%->15; 4/12/25: 15%->60 / Impacted TSs and TRs: 28.886
- 223: 18/7/25: 28.884 added;; 4/12/25: 0%->50 / Impacted TSs and TRs: 28.884
- 224: 18/7/25: 28.888 added;; 4/12/25: 0%->20; 6/1/26: WID:SP-250864->SP-251679 / Impacted TSs and TRs: 28.888
- 225: 18/7/25: 28.887 added;; 12/9/25: 0%->2; 4/12/25: 2%->25; 6/1/26: WID:SP-250865->SP-251680 / Impacted TSs and TRs: 28.887
- 226: 18/7/25: 28.883 added;; 4/12/25: 0%->50 / Impacted TSs and TRs: 28.883
- 227: 18/7/25: 28.889 added;; 4/12/25: 0%->70 / Impacted TSs and TRs: 28.889

| ID | WBS | Task | Type | Duration | Start | Finish | Complete | Remaining | Total slack | Constraint | Resources | Work | Actual work | Acronym | PCG approved | WI rapporteur name | WI rapporteur e-mail | Release | TSG approved |
| --- | --- | --- | --- | --- | --- | --- | --- | --- | --- | --- | --- | --- | --- | --- | --- | --- | --- | --- | --- |
| 228 | 172 | 5G performance measurements/KPIs and Trace/MDT/QoE |  | 478.38d | 2025-06-05 A | 2026-09-09 | 30% | 334.86d | 37547.6d | finish no earlier than 2026-09-09 | S5 | 3827h |  | PM_KPI_Trace_MDT_QoE-OAM | 55 | XiuMin Chen (China Telecom), | chenxiumin@chinatelecom.cn | Rel-20 | 108 |
| 229 | 173 | Management Aspects related to NWDAF phase 3 |  | 380d | 2025-06-05 A | 2026-06-06 | 58% | 159.6d | 37646d | finish no earlier than 2026-06-06 | S5 | 3040h |  | NWDAF_Ph3-OAM | 55 | Song Zhao (China Telecom), | zhaosong1@chinatelecom.cn | Rel-20 | 108 |
| 230 | 174 | 5G Advanced NRM features phase 4 |  | 575.75d | 2025-06-05 A | 2026-12-12 | 30% | 403.02d | 37450.2d | finish no earlier than 2026-12-12 | S5 | 4606h |  | AdNRM_Ph4-OAM | 55 | Sean Sun (Nokia) | sean.sun@nokia-sbell.com | Rel-20 | 108 |
| 231 | 175 | Study on 5GA roaming charging reliability enhancement |  | 181.25d | 2025-09-10 A | 2026-03-03 | 45% | 99.69d | 37744.2d | finish no earlier than 2026-03-03 | S5 | 1450h |  | FS_RoamRE_CH | 55 | Wang Han (Huawei) | wanghan28@huawei.com | Rel-20 | 109 |
| 232 | 176 | Study on Unified Management interface for Multi-RAT support |  | 377.88d | 2025-09-10 A | 2026-09-09 | 30% | 264.51d | 37547.6d | finish no earlier than 2026-09-09 | S5 | 3023h |  | FS_UMMR_OAM | 55 | Veronica Gonzalez, Vodafone | veronica.gonzalez2@vodafone.com | Rel-20 | 109 |
| 233 | 177 | Study on Cloud Aspects of Management and Orchestration |  | 637.62d | 2024-01-03 A | 2025-09-09 A | 100% |  |  | finish no earlier than 2025-09-09 | S5 | 5101h | 5101h | FS_Cloud_OAM | 52 | Guangjing Cao (CMCC) | caoguangjing@chinamobile.com | Rel-20 | 102 |
| 234 | 178 | Life Cycle Management (LCM) of NF Deployment |  | 388.25d | 2025-12-03 | 2026-12-12 |  |  | 37450.2d | finish no earlier than 2026-12-12 | S5 | 3106h |  | NF_Deployment_LCM-OAM |  | Guangjing Cao (CMCC) | caoguangjing@chinamobile.com | Rel-20 |  |
| 235 | 179 | Charging enhancements of next generation real time communication services phase 2 |  | 388.25d | 2025-12-03 | 2026-12-12 |  |  | 37450.2d | finish no earlier than 2026-12-12 | S5 | 3106h |  | Ph2_NG_RTC_Ph2-CH |  | Ai Chen (CMCC) | chenai@chinamobile.com | Rel-20 |  |
| 236 | 180 | (Small) Technical Enhancements and Improvements for Rel-20 |  | 575.75d | 2025-06-05 A | 2026-12-12 |  | 575.75d | 37450.2d | finish no earlier than 2026-12-12 |  |  |  | TEI20 | 47 |  |  | Rel-20 | 92 |
| 237 | 181 | Lawful Interception Rel-20 |  | 753.88d | 2025-03-06 | 2027-03-03 |  |  | 37366.4d | start no earlier than 2025-03-06 | S3LI | 6031h |  | LI20 | 53 | Koen Jaspers, PIDS, | k.b.jaspers@minjenv.nl | Rel-20 | 104 |
| 238 | 182 | --- RELEASE 19 --- | milestone | 0d? | 2019-03-07 | 2019-03-07 |  |  | 40388.9d |  |  |  |  |  |  |  |  | Rel-19 |  |
| 239 | 183 | Rel-19 Energy Efficiency, Energy Saving | milestone | 0d? | 2016-03-15 A | 2016-03-15 A | 100% |  |  | start no earlier than 2016-03-15 |  |  |  |  |  |  |  | Rel-19 |  |
| 240 | 184 | **Energy Efficiency as Service Criteria** |  | 1238.25d | 2022-06-02 A | 2025-09-09 A | 100% |  |  |  |  | 17233h | 17233h | EnergyServ | 51 | Xiaonan Shi, CMCC | shixiaonan@chinamobile.com | Rel-19 | 100 |
| 241 | 184.1 | Study on Energy Efficiency as service criteria |  | 333d | 2022-06-02 A | 2023-09-09 A | 100% |  |  | finish no earlier than 2023-09-09 | S1 | 2664h | 2664h | FS_EnergyServ | 49 | Xiaonan Shi, CMCC | shixiaonan@chinamobile.com | Rel-19 | 96 |
| 242 | 184.2 | Stage 1 of Energy Efficiency as Service Criteria |  | 135d | 2023-06-08 A | 2023-12-12 A | 100% |  |  | finish no earlier than 2023-12-12 | S1 | 1080h | 1080h | EnergyServ | 51 | Xiaonan Shi, CMCC | shixiaonan@chinamobile.com | Rel-19 | 100 |
| 243 | 184.3 | Charging Aspects for Energy Efficiency of Network Slice |  | 372.62d | 2024-06-12 A | 2025-06-06 A | 100% |  |  | finish no earlier than 2025-06-06 | S5 | 2981h | 2981h | EnergySys_CH | 53 | YiMeng, DENG, Huawei, | dengyimeng@huawei.com | Rel-19 | 104 |
| 244 | 184.4 | Study on Energy Efficiency and Energy Saving |  | 197d | 2023-09-09 A | 2024-06-06 A | 100% |  |  | finish no earlier than 2024-06-06 | S2 | 1576h | 1576h | FS_EnergySys | 51 | Jungshin Park (Samsung) | shin02.park@samsung.com | Rel-19 | 101 |
| 245 | 184.5 | Energy Efficiency and Energy Saving |  | 72d | 2024-09-04 A | 2024-12-12 A | 100% |  |  | finish no earlier than 2024-12-12 | S2 | 576h | 576h | EnergySys | 53 | Jungshin Park (Samsung) | shin02.park@samsung.com | Rel-19 | 105 |
| 246 | 184.6 | **CT aspects of energy efficiency and energy saving** |  | 197.75d | 2025-03-03 A | 2025-09-09 A | 100% |  |  |  |  | 3164h | 3164h | EnergySys | 53 | Suh, Kyungjoo(Grace), Samsung | joo.suh@samsung.com | Rel-19 | 105 |
| 247 | 184.6.1 | CT3 aspects of energy efficiency and energy saving |  | 197.75d | 2025-03-03 A | 2025-09-09 A | 100% |  |  | finish no earlier than 2025-09-09 | C3 | 1582h | 1582h | EnergySys | 53 | Suh, Kyungjoo(Grace), Samsung | joo.suh@samsung.com | Rel-19 | 105 |
| 248 | 184.6.2 | CT4 aspects of energy efficiency and energy saving |  | 197.75d | 2025-03-03 A | 2025-09-09 A | 100% |  |  | finish no earlier than 2025-09-09 | C4 | 1582h | 1582h | EnergySys | 53 | Suh, Kyungjoo(Grace), Samsung | joo.suh@samsung.com | Rel-19 | 105 |
| 249 | 184.7 | Study on energy efficiency and energy saving aspects of 5G networks and services |  | 267d | 2023-12-08 A | 2024-12-12 A | 100% |  |  | finish no earlier than 2024-12-12 | S5 | 2136h | 2136h | FS_Energy_OAM_Ph3 | 52 | Jean-Michel Cornily (Huawei) | jean.michel.cornily@huawei.com | Rel-19 | 102 |
| 250 | 184.8 | Study on security aspects of energy saving in 5G |  | 183d | 2024-04-02 A | 2024-12-12 A | 100% |  |  | start no earlier than 2024-04-02 | S3 | 1464h | 1464h | FS_Energy_Sec | 52 | Bo Bjerrum | bo.bjerrum@nokia.com | Rel-19 | 103 |
| 251 | 184.9 | Energy efficiency and energy saving aspects of 5G networks and services |  | 199d | 2025-03-01 A | 2025-09-09 A | 100% |  |  | finish no earlier than 2025-09-09 | S5 | 1592h | 1592h | Energy_OAM_Ph3 | 54 | Jean-Michel Cornily (Huawei) | jean.michel.cornily@huawei.com | Rel-19 | 106 |

Notes:
- 228: ; 12/9/25: 0%->5; 4/12/25: 5%->30 / Impacted TSs and TRs: 28.552; 28.554; 28.532; 28.558; 32.404; 32.421; 32.422; 32.423; 28.404; 28.405; 28.406; 28.622; 28.623; 28.541
- 229: ; 12/9/25: 0%->30; 29/9/25: WID:SP-250881->SP- 251026; 4/12/25: 30%->58 / Impacted TSs and TRs: 28.541; 28.552; 28.554
- 230: ; 12/9/25: 0%->10; 29/9/25: WID:SP-250882->SP- 251024; 4/12/25: 10%->30; 6/1/26: WID:SP-251024->SP-251683 / Impacted TSs and TRs: 28.540; 28.541; 28.622; 28.623; 32.160
- 231: 4/12/25: 0%->45
- 232: 4/12/25: 0%->30
- 233: 14/3/24: 0%->2; 13/6/24: 2%->40; 4/9/24: 40%->80; 4/9/24: FCD:09/09/2024->12/24; 5/12/24: 80%->90; 8/1/25: WID:SP-231781->SP-241566 (rapp changed); 6/3/25: 90%->85; 6/3/25: FCD:30/08/2024->/25; 6/6/25: 85%->90; 12/9/25: 90%->95. Rel-19->Rel-20; 4/12/25: 9; 6/1/26: WID:SP-241566->SP-251678
- 234: Impacted TSs and TRs: 28.531; 28.533
- 235: Impacted TSs and TRs: 32.240; 32.260; 32.291; 32.298
- 237: ; 26/3/25: WID:SP-241012->SP-250388; 27/6/25: WID:SP-250388->SP-250447; 7/1/26: 33.801-06 added; / Impacted TSs and TRs: 33.107; 33.108; 33.126; 33.127; 33.128; 33.928 ; 33.129; 33.801-06
- 238: -
- 239: -
- 240: ; 6/9/23: 0%->75; 8/12/23: 75%->100 / Impacted TSs and TRs: 22.261
- 241: 13/7/22: 22.882 added;; 9/9/22: 0%->10; 10/12/22: FCD:10/03/2023->06/23; 10/12/22: 10%->40; 16/3/23: WID:SP-220446->SP-230235; 17/3/23: 40%->70; 8/6/23: 70%->90; 8/6/23: FCD:06/06/2023->09/20; 6/9/23: 90%->95; 8/12/23: 95%->100 / Impacted TSs and TRs: 22.882
- 242: ; 6/9/23: 0%->75; 8/12/23: 75%->100 / Impacted TSs and TRs: 22.261
- 243: ; 4/9/24: 0%->45; 6/3/25: 45%->100; 26/3/25: WID:SP-241003->SP-250124; 26/3/25: FCD:12/12/2024->6/6/25. Name changed from "Charging Aspects for Energy Efficiency of 5G" / Impacted TSs and TRs: 32.240; 28.201; 28.202; 32.291; 32.298
- 244: 9/23: company-submitted WID, to be corrected; 6/10/23: 23.700-66 added;; 8/12/23: 0%->15; 4/1/24: 28.880 added;; 14/3/24: 15%->55; 13/6/24: 55%->100; 4/9/24: 99%->100 / Impacted TSs and TRs: SP-231192; 23.700-66; 28.880
- 245: ; 5/12/24: 0%->70; 6/3/25: 70%->100; 26/3/25: WID:SP-241388->SP-250069 / Impacted TSs and TRs: 23.501; 23.502; 23.503
- 246: Impacted TSs and TRs: 29.508,29.513,29.522,29.122,29.519,29.510,29.503,29.504,29.518
- 247: Impacted TSs and TRs: 29.508,29.513,29.522,29.122,29.519,29.510,29.503,29.504,29.518
- 248: Impacted TSs and TRs: 29.508,29.513,29.522,29.122,29.519,29.510,29.503,29.504,29.518
- 249: 4/1/24: 28.866 added;; 14/3/24: 0%->10; 13/6/24: 10%->25; 4/9/24: 25%->60; 4/9/24: FCD:09/09/2024->12/24; 5/12/24: 60%->100; 8/1/25: WID:SP-231723->SP-241568 / Impacted TSs and TRs: 28.866
- 250: 3/4/24: 33.766 added;; 13/6/24: 0%->30; 5/9/24: 30%->70; 5/12/24: 70%->90; 6/3/25: 90%->100; 5/6/25: 100%->100 / Impacted TSs and TRs: 33.766
- 251: ; 6/3/25: 0%->20; 6/6/25: 20%->70; 12/9/25: 70%->100; 29/9/25: WID:SP-241940->SP- 251274 / Impacted TSs and TRs: 28.310; 28.622; 28.623; 28.541; 28.554; 28.104

| ID | WBS | Task | Type | Duration | Start | Finish | Complete | Remaining | Total slack | Constraint | Resources | Work | Actual work | Acronym | PCG approved | WI rapporteur name | Release | TSG approved | WI rapporteur e-mail | Status Report |
| --- | --- | --- | --- | --- | --- | --- | --- | --- | --- | --- | --- | --- | --- | --- | --- | --- | --- | --- | --- | --- |
| 252 | 185 | **Enhancements of Network energy savings for NR** |  | 462.62d | 2023-12-13 A | 2025-03-03 | 91% | 43.38d |  |  |  | 9931h | 5275h | Netw_Energy_NR_enh | 52 | Ericsson | Rel-19 | 102 |  |  |
| 253 | 185.1 | Core part: Enhancements of Network energy savings for NR |  | 659.38d | 2023-12-13 A | 2025-09-09 A | 100% |  |  | finish no earlier than 2025-09-09 | R1 | 5275h | 5275h | Netw_Energy_NR_enh-Core | 52 | Ajit Nimbalker, Ericsson | Rel-19 | 102 | Ajit.Nimbalker@ericsson.com | RP-252331 |
| 254 | 185.2 | Perf. part: Enhancements of Network energy savings for NR |  | 582d | 2024-08-18 A | 2026-03-03 | 80% | 116.4d | 37744.2d | finish no earlier than 2026-03-03 | R4 | 4656h |  | Netw_Energy_NR_enh-Perf | 52 | Ajit Nimbalker, Ericsson | Rel-19 | 102 | Ajit.Nimbalker@ericsson.com | RP-253335 |
| 255 | 186 | Study on Media enerGy consumption exposuRE and EvaluatioN framework |  | 240d | 2024-04-02 A | 2025-03-03 A | 100% |  |  | start no earlier than 2024-04-02 | S4 | 1920h | 1920h | FS_MediaEnergyGREEN | 52 | Julien Lemotheux, Orange, | Rel-19 | 103 | julien.lemotheux@orange.com |  |
| 256 | 187 | **Low-power wake-up signal and receiver for NR (LP-WUS/WUR)** |  | 462.62d | 2023-12-13 A | 2025-03-03 | 73% | 124.82d |  |  |  | 12963h | 5275h | NR_LPWUS | 52 | vivo | Rel-19 | 102 |  |  |
| 257 | 187.1 | Core part: Low-power wake-up signal and receiver for NR (LP-WUS/WUR) |  | 659.38d | 2023-12-13 A | 2025-09-09 A | 100% |  |  | finish no earlier than 2025-09-09 | R1 | 5275h | 5275h | NR_LPWUS-Core | 52 | Xueming Pan, vivo | Rel-19 | 102 | panxueming@vivo.com | RP-252008 |
| 258 | 187.2 | Perf. part: Low-power wake-up signal and receiver for NR (LP-WUS/WUR) |  | 582d | 2024-08-18 A | 2026-03-03 | 90% | 58.2d | 37744.2d | finish no earlier than 2026-03-03 | R4 | 4656h |  | NR_LPWUS-Perf | 52 | Xueming Pan, vivo | Rel-19 | 102 | panxueming@vivo.com | RP-253258 |
| 259 | 187.3 | UE Conformance - Low-power wake-up signal and receiver for NR |  | 379d | 2025-12-12 | 2026-12-12 |  |  | 37450.2d | finish no earlier than 2026-12-12 | R5 | 3032h |  | NR_LPWUS-UEConTest |  | vivo | Rel-20 |  |  |  |
| 260 | 188 | Rel-19 Artificial Intelligence (AI)/Machine Learning (ML) | milestone | 0d? | 2016-03-15 A | 2016-03-15 A | 100% |  |  | start no earlier than 2016-03-15 |  |  |  |  |  |  | Rel-19 |  |  |  |
| 261 | 189 | Study on Artificial Intelligence (AI)/Machine Learning (ML) for NR air interface Phase 2 |  | 342d | 2024-10-14 A | 2025-09-09 A | 100% |  |  | finish no earlier than 2025-09-09 | R1 | 2736h | 2736h | FS_NR_AIML_air_Ph2 | 54 | Qualcomm | Rel-19 | 106 |  | RP-252444 |
| 262 | 190 | Study on 3GPP AI/ML Consistency Alignment |  | 447.75d | 2024-10-06 | 2025-12-12 |  |  | 37828.2d | finish no earlier than 2025-12-12 | SP | 3582h |  | FS_AIML_CAL | 53 | Johannes Achter, Magenta | Rel-19 | 104 |  |  |
| 263 | 191 | Study on AI/ML Model Transfer Phase2 |  | 393d | 2022-03-10 A | 2023-09-09 A | 100% |  |  | finish no earlier than 2023-09-09 | S1 | 3144h | 3144h | FS_AIML_MT_Ph2 | 48 | Yang Xu, OPPO | Rel-19 | 95 | xuyang@oppo.com |  |
| 264 | 192 | Study on Artificial Intelligence (AI) and Machine Learning (ML) for Media |  | 1224.75d | 2022-03-12 A | 2025-06-06 A | 100% |  |  | finish no earlier than 2025-06-06 | S4 | 9798h | 9798h | FS_AI4Media | 48 | Eric Yip, Samsung | Rel-19 | 95 | eric.yip@samsung.com |  |
| 265 | 193 | AI/ML Model Transfer Phase 2 |  | 135d | 2023-06-08 A | 2023-12-12 A | 100% |  |  | finish no earlier than 2023-12-12 | S1 | 1080h | 1080h | AIML_MT_Ph2 | 51 | Yang Xu, OPPO | Rel-19 | 100 | xuyang<at>oppo.com |  |
| 266 | 194 | **Core Network Enhanced Support for Artificial Intelligence (AI)/Machine Learning (ML)** |  | 471.12d | 2024-06-12 A | 2025-09-09 A | 100% |  |  |  |  | 11354h | 11354h | AIML_CN | 53 | Xiaobo Wu, vivo | Rel-19 | 105 | (xiaobo.wu@vivo.com) |  |
| 267 | 194.1 | Stage 2 of Core Network Enhanced Support for Artificial Intelligence (AI)/Machine Learning (ML) |  | 471.12d | 2024-06-12 A | 2025-09-09 A | 100% |  |  | finish no earlier than 2025-09-09 | S2 | 3769h | 3769h | AIML_CN | 53 | Xiaobo Wu, vivo | Rel-19 | 104 | (xiaobo.wu@vivo.com) |  |
| 268 | 194.2 | **CT aspects of Core Network Enhanced Support for Artificial Intelligence (AI)/Machine Learning (ML)** |  | 378.88d | 2024-09-09 A | 2025-09-09 A | 100% |  |  |  |  | 6062h | 6062h | AIML_CN | 53 | Yizhong ZHANG, vivo | Rel-19 | 105 | yizhong.zhang@vivo.com |  |
| 269 | 194.2.1 | CT3 aspects of Core Network Enhanced Support for Artificial Intelligence (AI)/Machine Learning (ML) |  | 378.88d | 2024-09-09 A | 2025-09-09 A | 100% |  |  | finish no earlier than 2025-09-09 | C3 | 3031h | 3031h | AIML_CN | 53 | Yizhong ZHANG, vivo | Rel-19 | 105 | yizhong.zhang@vivo.com |  |
| 270 | 194.2.2 | CT4 aspects of Core Network Enhanced Support for Artificial Intelligence (AI)/Machine Learning (ML) |  | 378.88d | 2024-09-09 A | 2025-09-09 A | 100% |  |  | finish no earlier than 2025-09-09 | C4 | 3031h | 3031h | AIML_CN | 53 | Yizhong ZHANG, vivo | Rel-19 | 105 | yizhong.zhang@vivo.com |  |
| 271 | 194.3 | Security aspects of Core Network Enhanced Support for AIML |  | 190.38d | 2024-12-05 A | 2025-06-06 A | 100% |  |  | finish no earlier than 2025-06-06 | S3 | 1523h | 1523h | AIML_CN_SEC | 54 | Chang Liu, China Mobile | Rel-19 | 106 | liuchangyjy@chinamobile.com |  |
| 272 | 195 | **Application enablement for AI/ML services** |  | 435.88d | 2024-07-16 A | 2025-09-09 A | 100% |  |  |  |  | 6926h | 6926h | AIML_App | 53 | Pateromichelakis, Emmanouil (Manos), | Rel-19 | 105 | epateromiche@lenovo.com |  |
| 273 | 195.1 | Stage 2 of Application enablement for AI/ML services |  | 108d | 2024-07-16 A | 2024-12-12 A | 100% |  |  | start no earlier than 2024-07-16 | S6 | 864h | 864h | AIML_App | 53 | Pateromichelakis, Emmanouil (Manos), | Rel-19 | 104 | epateromiche@lenovo.com |  |
| 274 | 195.2 | **CT aspects of Application enablement for AI/ML services** |  | 378.88d | 2024-09-09 A | 2025-09-09 A | 100% |  |  |  |  | 6062h | 6062h | AIML_App | 53 | Atarius, Roozbeh (Lenovo) | Rel-19 | 105 | ratarius@motorola.com |  |
| 275 | 195.2.1 | CT1 aspects of Application enablement for AI/ML services |  | 378.88d | 2024-09-09 A | 2025-09-09 A | 100% |  |  | finish no earlier than 2025-09-09 | C1 | 3031h | 3031h | AIML_App | 53 | Atarius, Roozbeh (Lenovo) | Rel-19 | 105 | ratarius@motorola.com |  |
| 276 | 195.2.2 | CT3 aspects of Application enablement for AI/ML services |  | 378.88d | 2024-09-09 A | 2025-09-09 A | 100% |  |  | finish no earlier than 2025-09-09 | C3 | 3031h | 3031h | AIML_App | 53 | Atarius, Roozbeh (Lenovo) | Rel-19 | 105 | ratarius@motorola.com |  |
| 277 | 196 | AI/ML Management Phase 2 |  | 199d | 2025-03-01 A | 2025-09-09 A | 100% |  |  | finish no earlier than 2025-09-09 | S5 | 1592h | 1592h | AIML_MGT_Ph2 | 54 | Hassan Al-Kanani (NEC) | Rel-19 | 106 | Hassan.Alkanani@EMEA.NEC.COM |  |
| 278 | 197 | Study on Core Network Enhanced Support for Artificial Intelligence (AI)/Machine Learning (ML) |  | 113d | 2024-01-04 A | 2024-06-06 A | 100% |  |  | finish no earlier than 2024-06-06 | S2 | 904h | 904h | FS_AIML_CN | 52 | Xiaobo Wu, vivo | Rel-19 | 102 | xiaobo.wu@vivo.com) |  |
| 279 | 198 | Study on security aspects of Core Network Enhanced Support for AIML |  | 183d | 2024-04-02 A | 2024-12-12 A | 100% |  |  | start no earlier than 2024-04-02 | S3 | 1464h | 1464h | FS_AIML_CN_SEC | 52 | Chang Liu, | Rel-19 | 103 | liuchangyjy@chinamobile.com |  |
| 280 | 199 | Study on AI/ML management - phase 2 |  | 249d | 2024-01-03 A | 2024-12-12 A | 100% |  |  | finish no earlier than 2024-12-12 | S5 | 1992h | 1992h | FS_AIML_MGT_Ph2 | 52 | Yizhi Yao (Intel) | Rel-19 | 102 | yizhi.yao@intel.com |  |
| 281 | 200 | Study on application layer support for AI/ML services |  | 266d | 2023-09-07 A | 2024-09-09 A | 100% |  |  | finish no earlier than 2024-09-09 | S6 | 2128h | 2128h | FS_AIMLAPP | 51 | Pateromichelakis, Emmanouil (Manos) | Rel-19 | 101 | epateromiche@lenovo.com |  |
| 282 | 201 | Study on enhancements for Artificial Intelligence (AI)/Machine Learning (ML) for NG-RAN |  | 196d | 2023-12-13 A | 2024-09-09 A | 100% |  |  | finish no earlier than 2024-09-24 | R3 | 1568h | 1568h | FS_NR_AIML_NGRAN_enh | 52 | ZTE | Rel-19 | 102 |  | RP-241791 |
| 283 | 202 | Study on Artificial Intelligence (AI)/Machine Learning (ML) for mobility in NR |  | 2463.38d | 2019-03-07 A | 2025-09-09 A | 100% |  |  | finish no earlier than 2025-09-09 | R2 | 19707h | 19707h | FS_NR_AIML_Mob | 52 | Zhongda Du, OPPO | Rel-19 | 102 | duzhongda@oppo.com | RP-251965 |

Notes:
- 252: 2/4/24: WID:RP-234065->RP-240170; 23/7/24: WID:RP-240170->RP-241650; 26/9/24: WID:RP-241650->RP-242354; 3/4/25: WID:RP-242354->RP-250343; 18/7/25: WID:RP-250343->RP-251678; 29/9/25: WID:RP-251678->RP-252332
- 253: 14/3/24: Compl:0%->5%; Stat Rep: ->RP-240169; Rapporteur: Ericsson->Ajit Nimbalker, Ericsson; Rap eMail: ->Ajit.Nimbalker@ericsson.com; ; 13/6/24: Compl:5%->25%; Stat Rep: RP-240169->RP-241182; ; 4/9/24: FCD:09/09/2025->25/09/2024; Compl:25%->35%; Stat Re; 11/9/25: Compl:90%->100%; Stat Rep: RP-251677->RP-252331;
- 254: 14/3/24: Stat Rep: ->RP-240169; Rapporteur: Ericsson->Ajit Nimbalker, Ericsson; Rap eMail: ->Ajit.Nimbalker@ericsson.com; ; 13/6/24: Stat Rep: RP-240169->RP-241182; ; 4/9/24: FCD:03/03/2026->26/03/2025; Stat Rep: RP-241182->RP-241866; ; 6/12/24: FCD:03/03; 3/12/25: Compl:15%->80%; Stat Rep: RP-252331->RP-253335;
- 255: 14/5/24: 26.942 added;; 13/6/24: 0%->15; 4/9/24: 15%->30; 5/12/24: 30%->60; 6/3/25: 60%->100 / Impacted TSs and TRs: 26.942
- 256: 2/4/24: WID:RP-234056->RP-240801; 26/9/24: WID:RP-240801->RP-241824; 26/9/24: 38.774 added;; 18/7/25: WID:RP-241824->RP-251200 / Impacted TSs and TRs: 38.774
- 257: 14/3/24: Compl:0%->8%; Stat Rep: ->RP-240134; Rapporteur: vivo->Xueming Pan, vivo; Rap eMail: ->panxueming@vivo.com; ; 13/6/24: Compl:8%->20%; Stat Rep: RP-240134->RP-241039; ; 4/9/24: FCD:09/09/2025->25/09/2024; Compl:20%->30%; Stat Rep: RP-241039->RP-24; 11/9/25: Compl:90%->100%; Stat Rep: RP-251199->RP-252008;
- 258: 14/3/24: Stat Rep: ->RP-240134; Rapporteur: vivo->Xueming Pan, vivo; Rap eMail: ->panxueming@vivo.com; ; 13/6/24: Stat Rep: RP-240134->RP-241039; ; 4/9/24: FCD:03/03/2026->26/03/2025; Stat Rep: RP-241039->RP-241822; ; 6/12/24: FCD:03/03/2025->03/03/2026; ; 3/12/25: Compl:25%->90%; Stat Rep: RP-252008->RP-253258;
- 260: -
- 261: 6/3/25: FCD:07/09/2025->09/09/2025; Compl:0%->50%; Stat Rep: ->RP-250307; ; 3/4/25: WID:RP-243245->RP-250308; 6/6/25: Compl:50%->90%; Stat Rep: RP-250307->RP-251184; ; 11/9/25: Compl:90%->100%; Stat Rep: RP-251184->RP-252444;
- 262: 26/9/24: WID:SP-240970->SP-241368; 27/6/25: WID:SP-241368->SP-250745; 27/6/25: FCD:Fri 06/06/->12/25
- 263: 5/4/22: 22.875 added;; 4/6/22: 0%->15; 21/6/22: WID:SP-220083->SP-220439. FS_AIML_Ph2->FS_AIML_MT_Ph2; 13/7/22: 22.876 added;; 10/12/22: 15%->50; 10/12/22: FCD:12/12/2022->06/23; 17/3/23: 50%->75; 8/6/23: 75%->95; 8/6/23: FCD:06/06/2023->09/20; 6/9/23: 95%->100 / Impacted TSs and TRs: 22.875; 22.876
- 264: 5/4/22: 26.927 added;; 4/6/22: 0%->10; 12/9/22: 10%->15; 12/9/22: FCD:12/03/2022->12/23; 11/12/22: 15%->20; 17/3/23: 20%->25; 8/6/23: 25%->35; 8/6/23: FCD:12/12/2023->/24; 7/9/23: 35%->40; 21/9/23: 26.847 added;; 8/12/23: 40%->50; 14/3/24: 50%->60; 14/...; 5/6/25: FCD:Sat 08/06/->/25 / Impacted TSs and TRs: 26.927; 26.847
- 265: ; 6/9/23: 0%->80; 8/12/23: 80%->100 / Impacted TSs and TRs: 22.261
- 266: Impacted TSs and TRs: 23.288; 23.501; 23.502; 23.503; 23.273
- 267: ; 4/9/24: 0%->15; 5/12/24: 15%->85; 6/3/25: 85%->98; 5/6/25: 98%->99; 12/9/25: 99%->99; 4/12/25: 99%->100 / Impacted TSs and TRs: 23.288; 23.501; 23.502; 23.503; 23.273
- 268: Impacted TSs and TRs: 29.508,29.513,29.520,29.522,29.552,29.574,29.575,29.576,29.591,24.080,29.503,29.510,29.518,29.572
- 270: ; 26/3/25: 29.570 added; / Impacted TSs and TRs: 29.570
- 271: ; 6/3/25: 0%->80; 5/6/25: 80%->100 / Impacted TSs and TRs: 33.501
- 272: Impacted TSs and TRs: 23.436; 23.434; 23.558
- 273: ; 4/9/24: 0%->40; 26/9/24: 23.482 added;; 5/12/24: 40%->100 / Impacted TSs and TRs: 23.436; 23.434; 23.558 ; 23.482
- 274: Impacted TSs and TRs: 24.559, 29.549, 29.558, 24.559, 29.549, 29.558
- 275: ; 26/9/24: 24.560 added;
- 277: ; 6/3/25: 0%->15; 6/6/25: 15%->52; 12/9/25: 52%->100; 12/9/25: 100%->; 29/9/25: WID:SP-241944->SP- 251197 / Impacted TSs and TRs: 28.105; 28.552; 28.554; 28.541
- 278: 14/3/24: 0%->25; 13/6/24: 25%->100; 26/9/24: WID:SP-231800->SP-241383; 8/1/25: WID:SP-241383->SP-241936; 6/3/25: 100%->100
- 279: 3/4/24: 33.784 added;; 13/6/24: 0%->35; 5/9/24: 35%->60; 5/12/24: 60%->100; 6/3/25: 100%->100; 5/6/25: 100%->100 / Impacted TSs and TRs: 33.784
- 280: 13/6/24: 0%->19; 16/7/24: WID:SP-231780->SP-240965; 4/9/24: 19%->55; 4/9/24: FCD:09/09/2024->12/24; 26/9/24: 28.858 added;; 5/12/24: 55%->100; 8/1/25: WID:SP-240965->SP-241567; 6/6/25: 100%->100 / Impacted TSs and TRs: 28.858
- 281: 8/12/23: 0%->35; 4/1/24: 23.700-82 added;; 14/3/24: 35%->55; 13/6/24: 55%->95; 4/9/24: 95%->100 / Impacted TSs and TRs: 23.700-82
- 282: 14/3/24: FCD:06/06/2024->/24; 2/4/24: WID:RP-234054->RP-240323; 3/4/24: 38.743 added;; 13/6/24: Compl:0%->80%; Stat Rep: ->RP-241097; ; 4/9/24: FCD:09/09/2024->24/09/2024; Compl:80%->100%; Stat Rep: RP-241097->RP-241791; / Impacted TSs and TRs: 38.743
- 283: 14/3/24: FCD:28/05/2021->12/12/2024; Stat Rep: ->RP-240083; Rapporteur: Oppo->Zhongda Du, OPPO; Rap eMail: ->duzhongda@oppo.com; ; 2/4/24: WID:RP-234055->RP-240082; 3/4/24: 38.744 added;; 4/9/24: FCD:12/12/2024->25/09/2024; Compl:0%->38%; Stat Rep: RP-...; 11/9/25: Compl:90%->100%; Stat Rep: RP-250970->RP-251965; List of Impacted TS & TR updated; / Impacted TSs and TRs: 38.744

| ID | WBS | Task | Type | Duration | Start | Finish | Complete | Remaining | Actual start | Actual finish | Total slack | Constraint | Resources | Work | Actual work | Acronym | PCG approved | Release | TSG approved | Status Report |
| --- | --- | --- | --- | --- | --- | --- | --- | --- | --- | --- | --- | --- | --- | --- | --- | --- | --- | --- | --- | --- |
| 284 | 203 | **Artificial Intelligence (AI)/Machine Learning (ML) for NR air interface** |  | 462.62d | 2023-12-13 A | 2025-03-03 | 64% | 164.78d |  |  |  |  |  | 13741h | 6053h | NR_AIML_air | 52 | Rel-19 | 102 |  |
| 285 | 203.1 | Core part: Artificial Intelligence (AI)/Machine Learning (ML) for NR air interface |  | 756.62d | 2023-12-13 A | 2025-12-12 A | 100% |  |  |  |  | finish no earlier than 2025-12-12 | R1 | 6053h | 6053h | NR_AIML_air-Core | 52 | Rel-19 | 102 | RP-253361 |
| 286 | 203.2 | Perf. part: Artificial Intelligence (AI)/Machine Learning (ML) for NR air interface |  | 582d | 2024-08-18 A | 2026-03-03 | 60% | 232.8d |  |  | 37744.2d | finish no earlier than 2026-03-03 | R4 | 4656h |  | NR_AIML_air-Perf | 52 | Rel-19 | 102 | RP-253361 |
| 287 | 203.3 | UE Conformance - Artificial Intelligence (AI)/Machine Learning (ML) for NR Air Interface |  | 379d | 2025-12-12 | 2026-12-12 |  |  |  |  | 37450.2d | finish no earlier than 2026-12-12 | R5 | 3032h |  | NR_AIML_air-UEConTest |  | Rel-19 |  |  |
| 288 | 204 | **Enhancements for Artificial Intelligence (AI)/Machine Learning (ML) for NG-RAN** |  | 378.88d | 2024-09-09 A | 2025-09-09 A | 100% |  |  |  |  |  |  | 3031h | 3031h | NR_AIML_NGRAN_enh | 53 | Rel-19 | 105 |  |
| 289 | 204.1 | Core part: Enhancements for Artificial Intelligence (AI)/Machine Learning (ML) for NG-RAN |  | 378.88d | 2024-09-09 A | 2025-09-09 A | 100% |  |  |  |  | finish no earlier than 2025-09-09 | R3 | 3031h | 3031h | NR_AIML_NGRAN_enh-Core | 53 | Rel-19 | 105 | RP-252150 |
| 290 | 205 | Rel-19 Ambient power-enabled Internet of Things | milestone | 0d? | 2016-03-15 A | 2016-03-15 A | 100% |  |  |  |  | start no earlier than 2016-03-15 |  |  |  |  |  | Rel-19 |  |  |
| 291 | 206 | **Ambient power-enabled Internet of Things** |  | 1370.75d | 2022-03-10 A | 2025-10-23 | 100% |  |  | 2025-09-09 |  |  |  | 9494h | 9494h | AmbientIoT | 52 | Rel-19 | 102 |  |
| 292 | 206.1 | Study on Ambient power-enabled Internet of Things |  | 460d | 2022-03-10 A | 2023-05-28 A | 100% |  |  |  |  | finish no earlier than 2023-12-12 | S1 | 3680h | 3680h | FS_AmbientIoT | 48 | Rel-19 | 95 |  |
| 293 | 206.2 | Study on Architecture support of Ambient power-enabled Internet of Things |  | 248d | 2024-01-04 A | 2024-08-30 A | 100% |  |  |  |  | finish no earlier than 2024-12-12 | S2 | 1984h | 1984h | FS_AmbientIoT | 52 | Rel-19 | 102 |  |
| 294 | 206.3 | Stage 1 of Ambient power-enabled Internet of Things |  | 6.25d | 2023-12-07 A | 2023-12-12 A | 100% |  |  |  |  | finish no earlier than 2023-12-12 | S1 | 50h | 50h | AmbientIoT | 52 | Rel-19 | 102 |  |
| 295 | 206.4 | Architecture support of Ambient power-enabled Internet of Things |  | 174d | 2025-03-26 A | 2025-09-09 A | 100% |  |  |  |  | finish no earlier than 2025-09-09 | S2 | 1392h | 1392h | AmbientIoT-ARC | 54 | Rel-19 | 107 |  |
| 296 | 206.5 | **CT aspects of Ambient power-enabled Internet of Things** |  | 99.5d | 2025-06-06 A | 2025-09-09 A | 100% |  |  |  |  |  |  | 2388h | 2388h | AmbientIoT-CT | 54 | Rel-19 | 107 |  |
| 297 | 206.5.1 | CT1 aspects of Ambient power-enabled Internet of Things |  | 99.5d | 2025-06-06 A | 2025-09-09 A | 100% |  |  |  |  | finish no earlier than 2025-10-23 | C1 | 796h | 796h | AmbientIoT-CT | 54 | Rel-19 | 107 |  |
| 298 | 206.5.2 | CT3 aspects of Ambient power-enabled Internet of Things |  | 99.5d | 2025-06-06 A | 2025-09-09 A | 100% |  |  |  |  | finish no earlier than 2025-10-23 | C3 | 796h | 796h | AmbientIoT-CT | 54 | Rel-19 | 107 |  |
| 299 | 206.5.3 | CT4 aspects of Ambient power-enabled Internet of Things |  | 99.5d | 2025-06-06 A | 2025-09-09 A | 100% |  |  |  |  | finish no earlier than 2025-10-23 | C4 | 796h | 796h | AmbientIoT-CT | 54 | Rel-19 | 107 |  |
| 300 | 207 | Study on solutions for Ambient IoT (Internet of Things) in NR |  | 264d | 2023-12-13 A | 2024-12-12 A | 100% |  |  |  |  | finish no earlier than 2024-12-12 | R1 | 2112h | 2112h | FS_Ambient_IoT_solutions | 52 | Rel-19 | 102 | RP-242965 |
| 301 | 208 | Study on Security Aspect of Ambient IoT Services in 5G |  | 264d | 2024-04-02 A | 2024-12-12 A | 100% |  |  |  |  | finish no earlier than 2024-12-12 | S3 | 2112h | 2112h | FS_Ambient_IoT_Sec | 52 | Rel-19 | 103 |  |
| 302 | 209 | Charging for Ambient power-enabled Internet of Things |  | 75.5d | 2025-03-26 A | 2025-06-06 A | 100% |  |  |  |  | start no earlier than 2025-03-26 | S5 | 604h | 604h | AmbientIoT-CH | 54 | Rel-19 | 107 |  |
| 303 | 210 | Security Aspects of Ambient IoT Services in 5G for Isolated Private Networks |  | 174d | 2025-03-26 A | 2025-09-09 | 95% | 8.7d |  |  | 37925.5d | finish no earlier than 2025-09-09 | S3 | 1392h |  | AmbientIoT-SEC | 54 | Rel-19 | 107 |  |
| 304 | 211 | **Solutions for Ambient IoT (Internet of Things) in NR** |  | 676.25d | 2024-05-19 | 2026-03-02 | 56% | 295.49d | 2024-10-14 |  |  |  |  | 9504h | 2736h | Ambient_IoT_Solutions | 54 | Rel-19 | 106 |  |
| 305 | 211.1 | Core part: Solutions for Ambient IoT (Internet of Things) in NR |  | 342d | 2024-10-14 A | 2025-09-09 A | 100% |  |  |  |  | finish no earlier than 2025-09-09 | R1 | 2736h | 2736h | Ambient_IoT_Solutions-Core | 54 | Rel-19 | 106 | RP-252104 |
| 306 | 211.2 | Perf. part: Solutions for Ambient IoT (Internet of Things) in NR |  | 467d | 2024-12-08 A | 2026-03-03 | 70% | 140.1d |  |  | 37744.2d | finish no earlier than 2026-03-03 | R4 | 3736h |  | Ambient_IoT_Solutions-Perf | 54 | Rel-19 | 106 | RP-253475 |
| 307 | 211.3 | UE Conformance - Solutions for Ambient IoT (Internet of Things) in NR plus CT1 and SA3 aspects |  | 379d | 2025-12-12 | 2026-12-12 |  |  |  |  | 37450.2d | finish no earlier than 2026-12-12 | R5 | 3032h |  | Ambient_IoT_Solutions_plus_CT1_SA3-ConTest |  | Rel-19 |  |  |
| 308 | 212 | See also IoT_NTN_Ph3 under Satellite/NTN | milestone | 0d? | 2016-03-15 A | 2016-03-15 A | 100% |  |  |  |  | start no earlier than 2016-03-15 |  |  |  |  |  | Rel-19 |  |  |
| 309 | 213 | Rel-19 Internet of Things, RedCap, MTC | milestone | 0d? | 2019-03-07 | 2019-03-07 |  |  |  |  | 40388.9d |  |  |  |  |  |  | Rel-19 |  |  |

Notes:
- 284: 2/4/24: WID:RP-234039->RP-240774; 26/9/24: WID:RP-240774->RP-242399; 24/1/25: WID:RP-242399->RP-243244; 12/9/25: WID:RP-243244->RP-251186; 29/9/25: WID:RP-251186->RP-252930 / WI rapporteur name: Qualcomm
- 285: 14/3/24: Compl:0%->5%; Stat Rep: ->RP-240499; Rapporteur: Qualcomm->Juan Montojo (RAN1); Xiaofeng Liu (RAN4); Marco Belleschi (RAN2/RAN3), Qualcomm; CAICT; Ericsson; Rap eMail: ->juanm@qti.qualcomm.com; liuxiaofeng1@caict.ac.cn; marco.belleschi@ericsso...; 3/12/25: Compl:90%->100%; Stat Rep: RP-252447->RP-253361; / WI rapporteur name: Juan Montojo (RAN1); Xiaofeng Liu (RAN4); Marco Belleschi (RAN2/RAN3), Qualcomm; CAICT; Ericsson / WI rapporteur e-mail: juanm@qti.qualcomm.com; liuxiaofeng1@caict.ac.cn; marco.belleschi@ericsson.com
- 286: 14/3/24: Stat Rep: ->RP-240499; Rapporteur: Qualcomm->Juan Montojo (RAN1); Xiaofeng Liu (RAN4); Marco Belleschi (RAN2/RAN3), Qualcomm; CAICT; Ericsson; Rap eMail: ->juanm@qti.qualcomm.com; liuxiaofeng1@caict.ac.cn; marco.belleschi@ericsson.com; ; 13/6/...; 3/12/25: Compl:25%->60%; Stat Rep: RP-252447->RP-253361; / WI rapporteur name: Juan Montojo (RAN1); Xiaofeng Liu (RAN4); Marco Belleschi (RAN2/RAN3), Qualcomm; CAICT; Ericsson / WI rapporteur e-mail: juanm@qti.qualcomm.com; liuxiaofeng1@caict.ac.cn; marco.belleschi@ericsson.com
- 287: WI rapporteur name: Qualcomm
- 288: 3/4/25: WID:RP-242385->RP-250326; 18/7/25: WID:RP-250326->RP-251245 / WI rapporteur name: ZTE
- 289: 6/12/24: Compl:0%->30%; Stat Rep: ->RP-242503; ; 6/3/25: FCD:20/05/2025->09/09/2025; Compl:30%->50%; Stat Rep: RP-242503->RP-250327; ; 6/6/25: Compl:50%->80%; Stat Rep: RP-250327->RP-251246; ; 11/9/25: Compl:80%->100%; Stat Rep: RP-251246->RP-252150; / WI rapporteur name: ZTE
- 290: -
- 291: ; 8/12/23: 0%->95; 29/9/25: FCD:Tue 09/09/25->Thu 23/10/25; Compl:97%->89%; / Impacted TSs and TRs: 22.261 / WI rapporteur name: Xu, Weijie, OPPO / WI rapporteur e-mail: xuweijie@oppo.com
- 292: 5/4/22: 22.840 added;; 4/6/22: 0%->25; 9/9/22: 25%->50; 10/12/22: 50%->65; 17/3/23: 65%->80; 17/3/23: FCD:12/12/2022->/23; 8/6/23: 80%->90; 8/6/23: FCD:03/03/2023->12/20; 6/9/23: 90%->95; 8/12/23: 95%->100; 3/12/25: 89%->100 / Impacted TSs and TRs: 22.840 / WI rapporteur name: Rapporteur:Xu, weijie, OPPO / WI rapporteur e-mail: xuweijie@oppo.com
- 293: 14/3/24: 0%->25; 13/6/24: 25%->65; 16/7/24: WID:SP-231803->SP-240969; 4/9/24: 65%->80; 5/12/24: 80%->90; 6/3/25: 90%->100 / WI rapporteur name: Runze Zhou (Huawei) / WI rapporteur e-mail: zhourunze@huawei.com
- 294: ; 8/12/23: 0%->95; 6/3/25: 95%->100; 3/12/25: 89%->100 / Impacted TSs and TRs: 22.261 / WI rapporteur name: Xu, Weijie, OPPO / WI rapporteur e-mail: xuweijie@oppo.com
- 295: ; 5/6/25: 0%->90; 12/9/25: 90%->95; 4/12/25: 89%->100 / Impacted TSs and TRs: 23.501; 23.502 / WI rapporteur name: Runze Zhou (Huawei) / WI rapporteur e-mail: zhourunze@huawei.com
- 296: ; 18/7/25: 24.369 added;; 29/9/25: FCD:Tue 09/09/25->Thu 23/10/25; WID: CP-251281->CP-252196; List of Impacted TS & TR updated; / Impacted TSs and TRs: 24.007, 29.522, 23.003, 29.518, 29.504, 29.510, 29.571 / WI rapporteur name: Wass, Mikael, Huawei / WI rapporteur e-mail: mikael.wass@huawei.com
- 297: ; 29/9/25: FCD:Tue 09/09/25->Thu 23/10/25; WID: CP-251281->CP-252196; / Impacted TSs and TRs: 29.522, 23.003, 29.518, 29.504, 29.505, 29.510, 29.571 / WI rapporteur name: Wass, Mikael, Huawei / WI rapporteur e-mail: mikael.wass@huawei.com
- 298: ; 29/9/25: FCD:Tue 09/09/25->Thu 23/10/25; WID: CP-251281->CP-252196; / Impacted TSs and TRs: 29.522, 23.003, 29.518, 29.504, 29.505, 29.510, 29.571 / WI rapporteur name: Wass, Mikael, Huawei / WI rapporteur e-mail: mikael.wass@huawei.com
- 299: ; 18/7/25: 29.506, 29.369added;; 29/9/25: FCD:Tue 09/09/25->Thu 23/10/25; WID: CP-251281->CP-252196; / Impacted TSs and TRs: 29.522, 23.003, 29.518, 29.504, 29.505, 29.510, 29.571; 29.506; 29.369 / WI rapporteur name: Wass, Mikael, Huawei / WI rapporteur e-mail: mikael.wass@huawei.com
- 300: 14/3/24: Compl:0%->8%; Stat Rep: ->RP-240155; Rapporteur: CMCC->Xiaodong Shen, CMCC; Rap eMail: ->shenxiaodong@chinamobile.com; ; 2/4/24: WID:RP-234058->RP-240826; 3/4/24: 38.769 added;; 13/6/24: Compl:8%->40%; Stat Rep: RP-240155->RP-241206; ; 4/9/24: FC; 24/1/25: 99%->100 / Impacted TSs and TRs: 38.769 / WI rapporteur name: Xiaodong Shen, CMCC / WI rapporteur e-mail: shenxiaodong@chinamobile.com
- 301: 3/4/24: 33.713 added;; 13/6/24: 0%->30; 5/9/24: 30%->35; 5/12/24: 35%->55; 6/3/25: 55%->75; 6/3/25: FCD:12/12/2024->/25; 5/6/25: 75%->90; 12/9/25: 90%->100 / Impacted TSs and TRs: 33.713 / WI rapporteur name: Marcus Wong, / WI rapporteur e-mail: marcus.wong@oppo.com
- 302: ; 6/6/25: 0%->100; 12/9/25: FCD:Tue 09/09/->/25 / Impacted TSs and TRs: 32.240; 32.254; 32.291; 32.298 / WI rapporteur name: YiMeng, DENG, Huawei / WI rapporteur e-mail: dengyimeng@huawei.com
- 303: 3/4/25: 33.369 added;; 5/6/25: 0%->45; 12/9/25: 45%->95; 29/9/25: WID:SP-250359->SP- 251196 / Impacted TSs and TRs: 33.369 / WI rapporteur name: Marcus Wong / WI rapporteur e-mail: marcus.wong@oppo.co
- 304: 26/3/25: 38.391 added;; 26/3/25: 38.191 added;; 26/3/25: 38.194 added;; 26/3/25: 38.195 added;; 3/4/25: WID:RP-243326->RP-250796; 29/9/25: WID:RP-250796->RP-252105 / Impacted TSs and TRs: 38.391; 38.191; 38.194; 38.195 / WI rapporteur name: CMCC
- 305: 6/3/25: FCD:07/09/2025->09/09/2025; Compl:0%->27%; Stat Rep: ->RP-250267; ; 6/6/25: Compl:27%->84%; WID: RP-250796->RP-240796; Stat Rep: RP-250267->RP-251399; ; 11/9/25: Compl:84%->100%; WID: RP-240796->RP-250796; Stat Rep: RP-251399->RP-252104; / WI rapporteur name: CMCC
- 306: 6/3/25: FCD:01/03/2026->03/03/2026; Stat Rep: ->RP-250267; ; 6/6/25: WID: RP-250796->RP-240796; Stat Rep: RP-250267->RP-251399; ; 11/9/25: Compl:0%->11%; WID: RP-240796->RP-250796; Stat Rep: RP-251399->RP-252104; ; 3/12/25: Compl:11%->70%; Stat Rep: RP-252104->RP-253475; / WI rapporteur name: CMCC
- 307: WI rapporteur name: CMCC
- 308: -
- 309: -

| ID | WBS | Task | Type | Duration | Start | Finish | Complete | Remaining | Total slack | Constraint | Resources | Work | Actual work | Acronym | PCG approved | WI rapporteur name | Release | TSG approved | Status Report | WI rapporteur e-mail |
| --- | --- | --- | --- | --- | --- | --- | --- | --- | --- | --- | --- | --- | --- | --- | --- | --- | --- | --- | --- | --- |
| 310 | 214 | **NR power class 2 RedCap (Reduced Capability) UE in FR1** |  | 378.88d | 2024-06-06 A | 2025-06-06 | 62% | 143.75d |  |  |  | 7620h | 3031h | NR_PC2_RedCap_UE | 53 | China Telecom | Rel-19 | 104 |  |  |
| 311 | 214.1 | Core part: NR power class 2 RedCap (Reduced Capability) UE in FR1 |  | 378.88d | 2024-06-06 A | 2025-06-06 A | 100% |  |  | finish no earlier than 2025-06-06 | R4 | 3031h | 3031h | NR_PC2_RedCap_UE-Core | 53 | China Telecom | Rel-19 | 104 | RP-251452 |  |
| 312 | 214.2 | UE Conformance - NR power class 2 RedCap (Reduced Capability) UE in FR1 |  | 573.62d | 2025-06-06 A | 2026-12-11 | 37% | 361.38d | 37451.4d | finish no earlier than 2026-12-11 | R5 | 4589h |  | NR_PC2_RedCap_UE-UEConTest | 55 | China Telecom | Rel-19 | 108 | RP-253473 |  |
| 313 | 215 | **Introduction of IoT-NTN TDD mode** |  | 854.12d | 2024-09-09 A | 2026-12-12 | 56% | 378.03d | 37450.2d |  |  | 9159h | 3031h | IoT_NTN_TDD | 53 | Iridium | Rel-19 | 105 |  |  |
| 314 | 215.1 | Core part: Introduction of IoT-NTN TDD mode |  | 378.88d | 2024-09-09 A | 2025-09-09 A | 100% |  |  | finish no earlier than 2025-09-09 | R1 | 3031h | 3031h | IoT_NTN_TDD-Core | 53 | Iridium | Rel-19 | 105 | RP-252329 |  |
| 315 | 215.2 | Perf. part: Introduction of IoT-NTN TDD mode |  | 387d | 2025-02-23 A | 2026-03-03 | 67% | 127.71d | 37744.2d | finish no earlier than 2026-03-03 | R4 | 3096h |  | IoT_NTN_TDD-Perf | 53 | Iridium | Rel-19 | 105 | RP-253685 |  |
| 316 | 215.3 | UE Conformance - Introduction of IoT-NTN TDD mode |  | 379d | 2025-12-12 | 2026-12-12 |  |  | 37450.2d | finish no earlier than 2026-12-12 | R5 | 3032h |  | IoT_NTN_TDD-UEConTest |  | CMCC | Rel-19 |  |  |  |
| 317 | 216 | Management Aspects of RedCap features |  | 199d | 2025-03-01 A | 2025-09-09 A | 100% |  |  | finish no earlier than 2025-09-09 | S5 | 1592h | 1592h | NR_RedCap_OAM | 54 | Zhen Xing (China Unicom) | Rel-19 | 106 |  | xingz12@chinaunicom.cn |
| 318 | 217 | Rel-19 Satellite (5GSAT), NTN | milestone | 0d? | 2016-03-15 A | 2016-03-15 A | 100% |  |  | start no earlier than 2016-03-15 |  |  |  |  |  |  | Rel-19 |  |  |  |
| 319 | 218 | **Satellite access Phase 3** |  | 1238.25d | 2022-06-02 A | 2025-09-09 A | 100% |  |  |  |  | 22369h | 22369h | 5GSAT_Ph3 | 51 | Rapporteur: Thierry Bérisot, Novamint | Rel-19 | 100 |  | tberisot@novamint.com |
| 320 | 218.1 | Study on satellite access - Phase 3 |  | 333d | 2022-06-02 A | 2023-09-09 A | 100% |  |  | finish no earlier than 2023-09-09 | S1 | 2664h | 2664h | FS_5GSAT_Ph3 | 49 | Rapporteur: Thierry Bérisot, Novamint | Rel-19 | 96 |  | tberisot@novamint.com |
| 321 | 218.2 | Stage 1 of Satellite access Phase 3 |  | 135d | 2023-06-08 A | 2023-12-12 A | 100% |  |  | finish no earlier than 2023-12-12 | S1 | 1080h | 1080h | 5GSAT_Ph3 | 51 | Rapporteur: Thierry Bérisot, Novamint | Rel-19 | 100 |  | tberisot@novamint.com |
| 322 | 218.3 | Study on Integration of satellite components in the 5G architecture Phase 3 |  | 189d | 2023-09-20 A | 2024-06-06 A | 100% |  |  | finish no earlier than 2024-06-06 | S2 | 1512h | 1512h | FS_5GSAT_Ph3_ARCH | 51 | Jean-Yves Fine (Thales) | Rel-19 | 101 |  | jean-yves.fine@thalesgroup.com |
| 323 | 218.4 | Study on application enablement for Satellite access enabled 5G Services |  | 181d | 2024-01-03 A | 2024-09-09 A | 100% |  |  | finish no earlier than 2024-09-09 | S6 | 1448h | 1448h | FS_5GSAT_Ph3_App | 52 | Basavaraj (Basu) Pattan, Samsung | Rel-19 | 102 |  | basavarajjp@samsung.com |
| 324 | 218.5 | Integration of satellite components in the 5G architecture Phase 3 |  | 132d | 2024-06-12 A | 2024-12-12 A | 100% |  |  | finish no earlier than 2024-12-12 | S2 | 1056h | 1056h | 5GSAT_Ph3-ARC | 53 | Hucheng Wang (CATT) | Rel-19 | 104 |  | wanghucheng@catt.cn |
| 325 | 218.6 | Application enablement for satellite access Phase 3 |  | 108d | 2024-07-16 A | 2024-10-28 A | 100% |  |  | start no earlier than 2024-07-16 | S6 | 864h | 864h | 5GSAT_Ph3_App | 53 | Basavaraj (Basu) Pattan, Samsung | Rel-19 | 104 |  | basavarajjp@samsung.com |
| 326 | 218.7 | **CT aspects for application enablement for satellite access Phase 3** |  | 291.88d | 2024-12-02 A | 2025-09-09 A | 100% |  |  |  |  | 4652h | 4652h | 5GSAT_Ph3_App | 53 | Narendranath Durga Tangudu, Samsung | Rel-19 | 104 |  | n.tangudu@samsung.com |
| 327 | 218.7.1 | CT1 aspects for application enablement for satellite access Phase 3 |  | 291.88d | 2024-12-02 A | 2025-09-09 A | 100% |  |  | finish no earlier than 2025-09-09 | C1 | 2335h | 2335h | 5GSAT_Ph3_App | 53 | Narendranath Durga Tangudu, Samsung | Rel-19 | 104 |  | n.tangudu@samsung.com |
| 328 | 218.7.2 | CT3 aspects for application enablement for satellite access Phase 3 |  | 289.62d | 2024-12-02 A | 2025-09-09 A | 100% |  |  | finish no earlier than 2025-09-09 | C3 | 2317h | 2317h | 5GSAT_Ph3_App | 53 | Narendranath Durga Tangudu, Samsung | Rel-19 | 104 |  | n.tangudu@samsung.com |
| 329 | 218.8 | **CT aspects of integration of satellite components in the 5G architecture Phase 3** |  | 378.88d | 2024-09-09 A | 2025-09-09 A | 100% |  |  |  |  | 9093h | 9093h | 5GSAT_Ph3_ARCH | 53 | Zhao, Xiaoxue (CATT) | Rel-19 | 105 |  | zhaoxiaoxue@cictmobile.com |
| 330 | 218.8.1 | CT1 aspects of integration of satellite components in the 5G architecture Phase 3 |  | 378.88d | 2024-09-09 A | 2025-09-09 A | 100% |  |  | finish no earlier than 2025-09-09 | C1 | 3031h | 3031h | 5GSAT_Ph3_ARCH | 53 | Zhao, Xiaoxue (CATT) | Rel-19 | 105 |  | zhaoxiaoxue@cictmobile.com |
| 331 | 218.8.2 | CT3 aspects of integration of satellite components in the 5G architecture Phase 3 |  | 378.88d | 2024-09-09 A | 2025-09-09 A | 100% |  |  | finish no earlier than 2025-09-09 | C3 | 3031h | 3031h | 5GSAT_Ph3_ARCH | 53 | Zhao, Xiaoxue (CATT) | Rel-19 | 105 |  | zhaoxiaoxue@cictmobile.com |
| 332 | 218.8.3 | CT4 aspects of integration of satellite components in the 5G architecture Phase 3 |  | 378.88d | 2024-09-09 A | 2025-09-09 A | 100% |  |  | finish no earlier than 2025-09-09 | C4 | 3031h | 3031h | 5GSAT_Ph3_ARCH | 53 | Zhao, Xiaoxue (CATT) | Rel-19 | 105 |  | zhaoxiaoxue@cictmobile.com |
| 333 | 219 | Management Aspects of NTN Phase 2 |  | 132d | 2025-01-30 A | 2025-06-06 A | 100% |  |  | finish no earlier than 2025-06-06 | S5 | 1056h | 1056h | NTN_OAM_Ph2 | 54 | MingRui Sun (China Unicom) | Rel-19 | 106 |  | sunmr19@chinaunicom.cn |
| 334 | 220 | Study on Security Aspects of 5G Satellite Access Phase 3 |  | 248d | 2024-01-04 A | 2024-12-12 A | 100% |  |  | finish no earlier than 2024-12-12 | S3 | 1984h | 1984h | FS_5GSAT_Ph3_SEC | 52 | Zhou Wei | Rel-19 | 102 |  | zhouwei@catt.cn |
| 335 | 221 | Security Aspects of 5G Satellite Access Phase 3 |  | 190.38d | 2024-12-05 A | 2025-06-06 A | 100% |  |  | finish no earlier than 2025-06-06 | S3 | 1523h | 1523h | 5GSAT_Ph3_SEC | 54 | Wei Zhou, CATT | Rel-19 | 106 |  | zhouwei@catt.cn |
| 336 | 222 | Study on charging aspects of satellite access Phase 3 |  | 189d | 2024-06-12 A | 2024-12-11 A | 100% |  |  | finish no earlier than 2025-03-03 | S5 | 1512h | 1512h | FS_5GSAT_Ph3_CH | 53 | Yingying Liu, CATT, | Rel-19 | 104 |  | liuyingying@cictmobile.com |
| 337 | 223 | Charging aspects of satellite access Phase 3 |  | 174d | 2025-03-26 A | 2025-09-09 A | 100% |  |  | finish no earlier than 2025-09-09 | S5 | 1392h | 1392h | 5GSAT_Ph3-CH | 54 | Yingying Liu, CATT | Rel-19 | 107 |  | liuyingying@cictmobile.com |

Notes:
- 310: 26/9/24: WID:RP-241665->RP-241997; 24/1/25: WID:RP-241997->RP-243267
- 311: 4/9/24: FCD:06/06/2025->25/06/2025; Compl:0%->20%; Stat Rep: ->RP-241998; ; 6/12/24: Compl:20%->50%; Stat Rep: RP-241998->RP-242859; ; 6/3/25: FCD:14/02/2025->06/06/2025; Compl:50%->70%; Stat Rep: RP-242859->RP-250372; ; 6/6/25: Compl:70%->100%; Stat Rep: RP-250372->RP-251452;
- 312: tested: REL-19 WI NR_PC2_RedCap_UE-Core ; 11/9/25: FCD:Sat 12/12/26->Thu 10/12/26; Compl:0%->5%; Stat Rep: ->RP-252553; ; 3/12/25: FCD:Sat 12/12/26->Fri 11/12/26; Compl:5%->37%; Stat Rep: RP-252553->RP-253473;
- 313: 24/1/25: WID:RP-242415->RP-243293; 29/9/25: WID:RP-243293->RP-252935
- 314: 6/12/24: Compl:0%->20%; Stat Rep: ->RP-242652; ; 6/3/25: FCD:20/05/2025->09/09/2025; Compl:20%->30%; Stat Rep: RP-242652->RP-250045; ; 6/6/25: Compl:30%->76%; Stat Rep: RP-250045->RP-251175; ; 11/9/25: Compl:76%->100%; Stat Rep: RP-251175->RP-252329;
- 315: 6/12/24: Stat Rep: ->RP-242652; ; 6/3/25: Stat Rep: RP-242652->RP-250045; ; 6/6/25: Stat Rep: RP-250045->RP-251175; ; 11/9/25: Stat Rep: RP-251175->RP-252329; ; 3/12/25: Compl:0%->67%; Stat Rep: RP-252329->RP-253685;
- 317: ; 6/3/25: 0%->50; 6/6/25: 50%->90; 12/9/25: 90%->100 / Impacted TSs and TRs: 28.540; 28.541; 28.552; 28.554
- 318: -
- 319: ; 6/9/23: 0%->95; 8/12/23: 95%->100 / Impacted TSs and TRs: 22.261
- 320: 17/8/22: WID:SP-220443->SP-220679; 9/9/22: 0%->35; 10/12/22: 35%->55; 10/12/22: FCD:10/03/2023->06/23; 17/3/23: 55%->80; 8/6/23: 80%->90; 8/6/23: FCD:06/06/2023->09/20; 6/9/23: 90%->100
- 321: ; 6/9/23: 0%->95; 8/12/23: 95%->100 / Impacted TSs and TRs: 22.261
- 322: 9/23: company-submitted WID, to be corrected; 6/10/23: 23.700-29 added;; 8/12/23: 0%->15; 4/1/24: 28.874 added;; 14/3/24: 15%->55; 13/6/24: 55%->100; 4/9/24: 99%->100 / Impacted TSs and TRs: 23.700-29; 28.874
- 323: 8/12/23: 0%->5; 14/3/24: 0%->25; 2/4/24: WID:SP-231738->SP-240296; 3/4/24: 23.700-01 added;; 13/6/24: 25%->60; 4/9/24: 60%->100 / Impacted TSs and TRs: 23.700-01
- 324: 4/9/24: 0%->15; 26/9/24: WID:SP-240986->SP-241386; 5/12/24: 15%->65; 6/3/25: 65%->100; 5/6/25: 100%->100 / Impacted TSs and TRs: 23.501; 23.502; 23.503; 23.682; 23.228; 23.401
- 325: ; 4/9/24: 0%->5; 5/12/24: 5%->75; 8/1/25: WID:SP-241010->SP-241690; 6/3/25: 75%->100 / Impacted TSs and TRs: 23.558; 23.434; 23.289
- 326: ; 4/9/24: 0%->5
- 327: ; 4/9/24: 0%->5
- 328: ; 4/9/24: 0%->5
- 329: 24.301,23.040,27.007,24.229,29.122,29.214,29.508,29.512,29.513,29.514,29.272,29.128,29.336,29.502,29.571,29.230
- 333: ; 6/3/25: 0%->25; 6/6/25: 25%->100; 27/6/25: WID:SP-241949->SP-250514 / Impacted TSs and TRs: 28.541; 28.552; 28.554; 28.658; 28.540; 28.530 ; TS 28.657;TS 28.659;TS 28.707;TS 28.708;TS 28.709
- 334: No end date in initial WID SP-231317; 4/1/24: 33.700-29 added;; 14/3/24: 0%->10; 2/4/24: WID:SP-231790->SP-240232; 13/6/24: 10%->65; 5/9/24: 65%->75; 5/12/24: 75%->85; 6/3/25: 85%->100; 5/6/25: 100%->100 / Impacted TSs and TRs: 33.700-29
- 335: ; 6/3/25: 0%->35; 5/6/25: 35%->100 / Impacted TSs and TRs: 33.401
- 336: 13/6/24: 0%->10; 4/9/24: 10%->40; 26/9/24: 28.846 added;; 5/12/24: 40%->75; 5/12/24: FCD:12/12/2024->/25; 6/3/25: 75%->100 / Impacted TSs and TRs: 28.846
- 337: ; 6/6/25: 0%->90; 12/9/25: 90%->100; 12/9/25: FCD:Fri 06/06/->/25 / Impacted TSs and TRs: 32.240; 32.251; 32.255; 32.257; 32.260; 32.291; 32.298

| ID | WBS | Task | Duration | Start | Finish | Complete | Remaining | Actual finish | Total slack | Constraint | Resources | Work | Actual work | Acronym | PCG approved | WI rapporteur name | Release | TSG approved | WI rapporteur e-mail | Status Report |
| --- | --- | --- | --- | --- | --- | --- | --- | --- | --- | --- | --- | --- | --- | --- | --- | --- | --- | --- | --- | --- |
| 338 | 224 | **Non-Terrestrial Networks (NTN) for NR Phase 3** | 462.62d | 2023-12-13 A | 2025-03-03 | 91% | 43.38d |  |  |  |  | 9931h | 5275h | NR_NTN_Ph3 | 52 | Thales | Rel-19 | 102 |  |  |
| 339 | 224.1 | Core part: Non-Terrestrial Networks (NTN) for NR Phase 3 | 659.38d | 2023-12-13 A | 2025-09-09 A | 100% |  |  |  | finish no earlier than 2025-09-09 | R2 | 5275h | 5275h | NR_NTN_Ph3-Core | 52 | Nicolas Chuberre, Thales | Rel-19 | 102 | Nicolas.chuberre@thalesaleniaspace.com | RP-251931 |
| 340 | 224.2 | Perf. part: Non-Terrestrial Networks (NTN) for NR Phase 3 | 582d | 2024-08-18 A | 2026-03-03 | 80% | 116.4d |  | 37744.2d | finish no earlier than 2026-03-03 | R4 | 4656h |  | NR_NTN_Ph3-Perf | 52 | Nicolas Chuberre, Thales | Rel-19 | 102 | Nicolas.chuberre@thalesaleniaspace.com | RP-253156 |
| 341 | 225 | **Non-Terrestrial Networks (NTN) for Internet of Things (IoT) Phase 3 (for LTE)** | 462.62d | 2023-12-13 A | 2025-03-03 | 93% | 30.72d |  |  |  |  | 9467h | 5275h | IoT_NTN_Ph3 | 52 | Mediatek | Rel-19 | 102 |  |  |
| 342 | 225.1 | Core part: Non-Terrestrial Networks (NTN) for Internet of Things (IoT) Phase 3 | 659.38d | 2023-12-13 A | 2025-09-09 A | 100% |  |  |  | finish no earlier than 2025-09-09 | R2 | 5275h | 5275h | IoT_NTN_Ph3-Core | 52 | Mediatek | Rel-19 | 102 |  | RP-252503 |
| 343 | 225.2 | Perf. part: Non-Terrestrial Networks (NTN) for Internet of Things (IoT) Phase 3 | 524d | 2024-10-13 A | 2026-03-03 | 85% | 78.6d |  | 37744.2d | finish no earlier than 2026-03-03 | R4 | 4192h |  | IoT_NTN_Ph3-Perf | 52 | Mediatek | Rel-19 | 103 |  | RP-253690 |
| 344 | 226 | **Inter-RAT mode mobility support from E-UTRAN TN to NR NTN** | 197.62d | 2024-03-03 A | 2024-09-09 | 60% | 78.47d |  |  |  |  | 7636h | 4604h | LTE_TN_NR_NTN_mob | 52 | Thales | Rel-19 | 103 |  |  |
| 345 | 226.1 | Core part: Inter-RAT mode mobility support from E-UTRAN TN to NR NTN | 575.5d | 2024-03-03 A | 2025-09-09 A | 100% |  |  |  | finish no earlier than 2025-09-09 | R2 | 4604h | 4604h | LTE_TN_NR_NTN_mob-Core | 52 | Thales | Rel-19 | 103 |  | RP-251932 |
| 346 | 226.2 | UE Conformance - Inter-RAT mobility support from E-UTRAN TN to NR NTN | 379d | 2025-12-12 | 2026-12-12 |  |  |  | 37450.2d | finish no earlier than 2026-12-12 | R5 | 3032h |  | LTE_TN_NR_NTN_mob-UEConTest |  | China Unicom | Rel-19 |  |  |  |
| 347 | 227 | **Enhanced requirements and test methodology for NR NTN and IoT NTN** | 378.75d | 2024-03-03 A | 2025-03-03 | 71% | 108.45d |  |  |  |  | 14459h | 4604h | NR_IoT_NTN_req_test_enh | 52 | Samsung | Rel-19 | 103 |  |  |
| 348 | 227.1 | Core part: Enhanced requirements and conductive test methodology for NR NTN and IoT NTN | 575.5d | 2024-03-03 A | 2025-09-09 A | 100% |  |  |  | finish no earlier than 2025-09-09 | R4 | 4604h | 4604h | NR_IoT_NTN_req_test_enh-Core | 52 | Samsung | Rel-19 | 103 |  | RP-252074 |
| 349 | 227.2 | Perf. Part: Enhanced requirements and conductive test methodology for NR NTN and IoT NTN | 756.75d | 2024-03-03 A | 2026-03-03 | 90% | 75.67d |  | 37744.2d | finish no earlier than 2026-03-03 | R4 | 6054h |  | NR_IoT_NTN_req_test_enh-Perf | 52 | Samsung | Rel-19 | 103 |  | RP-253313 |
| 350 | 227.3 | UE Conformance - Enhanced requirements and conductive test methodology for NR NTN and IoT NTN | 475.12d | 2025-09-09 A | 2026-12-11 | 7% | 441.87d |  | 37451.4d | finish no earlier than 2026-12-11 | R5 | 3801h |  | NR_IoT_NTN_req_test_enh-UEConTest | 55 | Xiaomi | Rel-19 | 109 |  | RP-253474 |
| 351 | 228 | **Introduction of another NR NTN S-band (MSS band 2000-2020 MHz UL and 2180-2200 MHz DL)** | 378.88d | 2024-06-06 A | 2025-06-06 A | 100% |  |  |  |  |  | 5127h | 5127h | NR_NTN_Sband | 53 | Qualcomm | Rel-19 | 104 |  |  |
| 352 | 228.1 | Core part: Introduction of another NR NTN S-band (MSS band 2000-2020 MHz UL and 2180-2200 MHz DL) | 378.88d | 2024-06-06 A | 2025-06-06 A | 100% |  |  |  | finish no earlier than 2025-06-06 | R4 | 3031h | 3031h | NR_NTN_Sband-Core | 53 | Qualcomm | Rel-19 | 104 |  | RP-251476 |
| 353 | 228.2 | Perf. part: Introduction of another NR NTN S-band (MSS band 2000-2020 MHz UL and 2180-2200 MHz DL) | 262d | 2024-09-26 A | 2025-06-06 A | 100% |  |  |  | finish no earlier than 2025-06-06 | R4 | 2096h | 2096h | NR_NTN_Sband-Perf | 53 | Qualcomm | Rel-19 | 104 |  | RP-251476 |
| 354 | 229 | **Introduction of another IoT-NTN S-band (MSS band 2000-2020 MHz UL and 2180-2200 MHz DL)** | 378.88d | 2024-06-06 A | 2025-06-06 | 100% |  | 2025-12-12 |  |  |  | 5913h | 5913h | IoT_NTN_FDD_S_band | 53 | Mediatek | Rel-19 | 104 |  |  |
| 355 | 229.1 | Core part: Introduction of another IoT-NTN S-band (MSS band 2000-2020 MHz UL and 2180-2200 MHz DL) | 378.88d | 2024-06-06 A | 2025-06-06 A | 100% |  |  |  | finish no earlier than 2025-06-06 | R4 | 3031h | 3031h | IoT_NTN_FDD_S_band-Core | 53 | Mediatek | Rel-19 | 104 |  | RP-251290 |
| 356 | 229.2 | Perf. part: Introduction of another IoT-NTN S-band (MSS band 2000-2020 MHz UL and 2180-2200 MHz DL) | 262d | 2024-09-26 A | 2025-06-06 A | 100% |  |  |  | finish no earlier than 2025-06-06 | R4 | 2096h | 2096h | IoT_NTN_FDD_S_band-Perf | 53 | Mediatek | Rel-19 | 104 |  | RP-251290 |
| 357 | 229.3 | UE Conformance - Introduction of another IoT-NTN S-band (MSS band 2000-2020 MHz UL and 2180-2200 MHz DL) | 98.25d | 2025-09-09 A | 2025-12-12 A | 100% |  |  |  | finish no earlier than 2025-12-12 | R5 | 786h | 786h | IoT_NTN_FDD_S_band-UEConTest | 55 | Mediatek | Rel-19 | 109 |  | RP-253691 |
| 358 | 230 | **Introduction of Ku bands for NR NTN** | 280.62d | 2024-06-06 A | 2025-03-03 | 88% | 34.2d |  |  |  |  | 7451h | 3819h | NR_NTN_Ku_bands | 53 | Intelsat | Rel-19 | 104 |  |  |
| 359 | 230.1 | Core part: Introduction of Ku bands for NR NTN | 477.38d | 2024-06-06 A | 2025-09-09 A | 100% |  |  |  | finish no earlier than 2025-09-09 | R4 | 3819h | 3819h | NR_NTN_Ku_bands-Core | 53 | Intelsat | Rel-19 | 104 |  | RP-252582 |
| 360 | 230.2 | Perf. part: Introduction of Ku bands for NR NTN | 454d | 2024-12-20 A | 2026-03-03 | 75% | 113.5d |  | 37744.2d | finish no earlier than 2026-03-03 | R4 | 3632h |  | NR_NTN_Ku_bands-Perf | 53 | Intelsat | Rel-19 | 104 |  | RP-253404 |
| 361 | 231 | **New NR NTN bands to support Extended L-band and combined MSS L-band and Extended L-band ranges** | 378.88d | 2024-06-06 A | 2025-06-06 | 100% |  | 2025-09-09 |  |  |  | 6703h | 6703h | NR_NTN_combinedLband | 53 | Aalyria | Rel-19 | 104 |  |  |
| 362 | 231.1 | Core part: Introduction of new NR NTN bands to support the Extended L-band (UL 1668-1675MHz, DL 1518-1525MHz) and the combined MSS L-band and Extended L-band ranges (UL 1626.5-1660.5 MHz and 1668-1675 MHz, DL 1518-1559 MHz) | 477.38d | 2024-06-06 A | 2025-09-09 A | 100% |  |  |  | finish no earlier than 2025-09-09 | R4 | 3819h | 3819h | NR_NTN_combinedLband-Core | 53 | Aalyria | Rel-19 | 104 |  | RP-250982 |
| 363 | 231.2 | STOPPED - Perf. part: Introduction of new NR NTN bands to support the Extended L-band (UL 1668-1675MHz, DL 1518-1525MHz) and the combined MSS L-band and Extended L-band ranges (UL 1626.5-1660.5 MHz and 1668-1675 MHz, DL 1518-1559 MHz) | 360.5d | 2024-09-26 A | 2025-09-09 A | 100% |  |  |  | finish no earlier than 2025-09-09 | R4 | 2884h | 2884h | NR_NTN_combinedLband-Perf | 53 | Aalyria | Rel-19 | 104 |  | RP-250982 |

Notes:
- 338: 2/4/24: WID:RP-234078->RP-240775; 23/7/24: WID:RP-240775->RP-241667; 26/9/24: WID:RP-241667->RP-241789; 24/1/25: WID:RP-241789->RP-243300; 29/9/25: WID:RP-243300->RP-251954
- 339: 14/3/24: Compl:0%->5%; Stat Rep: ->RP-240091; Rapporteur: Thales->Nicolas Chuberre, Thales; Rap eMail: ->Nicolas.chuberre@thalesaleniaspace.com; ; 13/6/24: Compl:5%->25%; Stat Rep: RP-240091->RP-240923; ; 4/9/24: FCD:09/09/2025->25/09/2024; Compl:25%->45%; 11/9/25: Compl:90%->100%; Stat Rep: RP-251003->RP-251931;
- 340: 14/3/24: Stat Rep: ->RP-240091; Rapporteur: Thales->Nicolas Chuberre, Thales; Rap eMail: ->Nicolas.chuberre@thalesaleniaspace.com; ; 13/6/24: Stat Rep: RP-240091->RP-240923; ; 4/9/24: FCD:03/03/2026->26/03/2025; Stat Rep: RP-240923->RP-241742; ; 6/12/24: ; 3/12/25: Compl:0%->80%; WID: RP-251954->RP-243300; Stat Rep: RP-251931->RP-253156;
- 341: 2/4/24: WID:RP-234077->RP-240776; 23/7/24: WID:RP-240776->RP-241624; 26/9/24: WID:RP-241624->RP-242397; 24/1/25: WID:RP-242397->RP-243278; 3/4/25: WID:RP-243278->RP-250472; 29/9/25: WID:RP-250472->RP-252504
- 342: 13/6/24: Compl:0%->15%; Stat Rep: ->RP-241356; ; 4/9/24: FCD:09/09/2025->25/09/2024; Compl:15%->30%; Stat Rep: RP-241356->RP-242050; ; 6/12/24: FCD:09/09/2024->09/09/2025; Compl:30%->50%; Stat Rep: RP-242050->RP-242996; ; 6/3/25: FCD:26/02/2025->09/09/202; 11/9/25: Compl:90%->100%; Stat Rep: RP-251289->RP-252503;
- 343: 13/6/24: FCD:03/03/2026->12/12/2025; Stat Rep: ->RP-241356; ; 4/9/24: FCD:12/12/2025->26/03/2025; Stat Rep: RP-241356->RP-242050; ; 6/12/24: Stat Rep: RP-242050->RP-242996; ; 6/3/25: WID: RP-243278->RP-242397; Stat Rep: RP-242996->RP-250470; ; 6/6/25: Com; 3/12/25: Compl:50%->85%; WID: RP-252504->RP-250472; Stat Rep: RP-252503->RP-253690;
- 344: 23/7/24: WID:RP-240846->RP-240924
- 345: 13/6/24: Compl:0%->70%; Stat Rep: ->RP-240925; ; 4/9/24: FCD:09/09/2025->25/09/2024; Compl:70%->95%; WID: RP-240924->RP-240846; Stat Rep: RP-240925->RP-241741; ; 6/12/24: FCD:09/09/2024->09/09/2025; Compl:95%->96%; Stat Rep: RP-241741->RP-242463; ; 6/3/25; 11/9/25: Compl:99%->100%; Stat Rep: RP-251004->RP-251932;
- 347: 23/7/24: WID:RP-240857->RP-241281; 26/9/24: WID:RP-241281->RP-241985; 24/1/25: WID:RP-241985->RP-242901; 29/9/25: WID:RP-242901->RP-252076
- 348: 13/6/24: Stat Rep: ->RP-241280; ; 4/9/24: FCD:09/09/2025->25/09/2024; Compl:0%->16%; Stat Rep: RP-241280->RP-241984; ; 6/12/24: FCD:09/09/2024->09/09/2025; Compl:16%->50%; Stat Rep: RP-241984->RP-242592; ; 6/3/25: FCD:23/03/2025->09/09/2025; Compl:50%->65; 11/9/25: Compl:88%->100%; Stat Rep: RP-251015->RP-252074;
- 349: 13/6/24: Stat Rep: ->RP-241280; ; 4/9/24: FCD:03/03/2026->26/03/2025; Compl:0%->10%; Stat Rep: RP-241280->RP-241984; ; 6/12/24: FCD:03/03/2025->03/03/2026; Compl:10%->30%; Stat Rep: RP-241984->RP-242592; ; 6/3/25: FCD:22/07/2025->03/03/2026; Compl:30%->35; 3/12/25: Compl:70%->90%; Stat Rep: RP-252074->RP-253313;
- 350: tested: REL-19 WI NR_IoT_NTN_req_test_enh ; 3/12/25: FCD:Sat 12/12/26->Fri 11/12/26; Compl:0%->7%; Stat Rep: ->RP-253474;
- 351: 26/9/24: WID:RP-241661->RP-241885; 3/4/25: WID:RP-241885->RP-250488
- 352: 4/9/24: FCD:03/03/2025->25/06/2025; Compl:0%->20%; Stat Rep: ->RP-241884; ; 6/12/24: FCD:06/06/2025->03/03/2025; Compl:20%->50%; Stat Rep: RP-241884->RP-242615; ; 6/3/25: FCD:09/12/2024->06/06/2025; Compl:50%->70%; Stat Rep: RP-242615->RP-250487; ; 6/6/25: Compl:70%->100%; Stat Rep: RP-250487->RP-251476;
- 353: 4/9/24: FCD:06/06/2025->25/06/2025; Stat Rep: ->RP-241884; ; 6/12/24: Stat Rep: RP-241884->RP-242615; ; 6/3/25: Stat Rep: RP-242615->RP-250487; ; 6/6/25: Compl:0%->100%; Stat Rep: RP-250487->RP-251476;
- 354: 26/9/24: WID:RP-241662->RP-242062; 3/4/25: WID:RP-242062->RP-250474; 18/7/25: WID:RP-250474->RP-251820
- 355: 4/9/24: FCD:03/03/2025->25/06/2025; Compl:0%->20%; Stat Rep: ->RP-242061; ; 6/12/24: FCD:06/06/2025->03/03/2025; Compl:20%->50%; WID: RP-241662->RP-242062; Stat Rep: RP-242061->RP-242999; ; 6/3/25: FCD:09/12/2024->06/06/2025; Compl:50%->70%; Stat Rep: RP; 6/6/25: Compl:70%->100%; Stat Rep: RP-250473->RP-251290;
- 356: 4/9/24: FCD:06/06/2025->25/06/2025; Stat Rep: ->RP-242061; ; 6/12/24: WID: RP-241662->RP-242062; Stat Rep: RP-242061->RP-242999; ; 6/3/25: Stat Rep: RP-242999->RP-250473; ; 6/6/25: Compl:0%->100%; Stat Rep: RP-250473->RP-251290;
- 357: tested: REL-19 WI IoT_NTN_FDD_S_band ; 3/12/25: FCD:Tue 03/03/26->Fri 12/12/25; Compl:0%->100%; Stat Rep: ->RP-253691; ; 7/1/26: WID:RP-252507->RP-253692
- 358: 24/1/25: WID:RP-241690->RP-243314; 3/4/25: WID:RP-243314->RP-250799; 29/9/25: WID:RP-250799->RP-252911
- 359: 4/9/24: FCD:09/09/2025->24/09/2024; Compl:0%->15%; Stat Rep: ->RP-241788; ; 6/12/24: FCD:09/09/2024->09/09/2025; Compl:15%->30%; Stat Rep: RP-241788->RP-242946; ; 6/3/25: FCD:19/04/2025->09/09/2025; Compl:30%->50%; Stat Rep: RP-242946->RP-250466; ; 6/6/2; 30/9/25: 95%->100
- 360: 4/9/24: FCD:03/03/2026->26/03/2025; Stat Rep: ->RP-241788; ; 6/12/24: FCD:03/03/2025->03/03/2026; Stat Rep: RP-241788->RP-242946; ; 6/3/25: Stat Rep: RP-242946->RP-250466; ; 6/6/25: Compl:0%->50%; WID: RP-250799->RP-243314; Stat Rep: RP-250466->RP-251271; 3/12/25: Compl:0%->75%; Stat Rep: RP-252582->RP-253404;
- 361: 26/9/24: WID:RP-241689->RP-241856; 3/4/25: WID:RP-241856->RP-250752; rapporteur: Inmarsat=> Aalyria; 18/7/25: WID:RP-250752->RP-250983; 29/9/25: WID:RP-250983->RP-252893
- 362: 4/9/24: FCD:03/03/2025->25/03/2025; Compl:0%->15%; Stat Rep: ->RP-241782; ; 6/12/24: Compl:15%->35%; Stat Rep: RP-241782->RP-242601; ; 6/3/25: FCD:09/12/2024->06/06/2025; Compl:35%->70%; Stat Rep: RP-242601->RP-250751; ; 6/6/25: FCD:Fri 06/06/25->Tue 09/; 30/9/25: 90%->100
- 363: 4/9/24: FCD:06/06/2025->25/06/2025; Stat Rep: ->RP-241782; ; 6/12/24: Stat Rep: RP-241782->RP-242601; ; 6/3/25: Stat Rep: RP-242601->RP-250751; ; 6/6/25: FCD:Fri 06/06/25->Tue 09/09/25; Compl:0%->90%; Stat Rep: RP-250751->RP-250982; 29/9/25: Stopped at 9; 29/9/25: 90%->100

| ID | WBS | Task | Type | Duration | Start | Finish | Complete | Remaining | Total slack | Constraint | Resources | Work | Actual work | Acronym | PCG approved | WI rapporteur name | Release | TSG approved | Status Report | WI rapporteur e-mail |
| --- | --- | --- | --- | --- | --- | --- | --- | --- | --- | --- | --- | --- | --- | --- | --- | --- | --- | --- | --- | --- |
| 364 | 232 | **Introduction of additional operating NR bands for HAPS (High Altitude Platform Station)** |  | 182.12d | 2024-09-09 A | 2025-03-03 A | 100% |  |  |  |  | 2009h | 2009h | NR_HAPS_bands | 53 | SoftBank | Rel-19 | 105 |  |  |
| 365 | 232.1 | Core part: Introduction of additional operating NR bands for HAPS (High Altitude Platform Station) |  | 182.12d | 2024-09-09 A | 2025-03-03 A | 100% |  |  | finish no earlier than 2025-03-03 | R4 | 1457h | 1457h | NR_HAPS_bands-Core | 53 | SoftBank | Rel-19 | 105 | RP-250407 |  |
| 366 | 232.2 | Stopped - Perf. part: Introduction of additional operating NR bands for HAPS (High Altitude Platform Station) |  | 69d | 2024-09-09 A | 2024-12-12 A | 100% |  |  | finish no earlier than 2024-12-12 | R4 | 552h | 552h | NR_HAPS_bands-Perf | 53 | SoftBank | Rel-19 | 105 |  |  |
| 367 | 233 | Rel-19 XR (eXtended Reality), Metaverse | milestone | 0d? | 2016-03-15 A | 2016-03-15 A | 100% |  |  | start no earlier than 2016-03-15 |  |  |  |  |  |  | Rel-19 |  |  |  |
| 368 | 234 | **Localized Mobile Metaverse Services** |  | 1325.25d | 2022-03-10 A | 2025-09-09 A | 100% |  |  |  |  | 16671h | 16671h | Metaverse | 51 | Guttman, Erik, Samsung | Rel-19 | 100 |  | erik.guttman@samsung.com |
| 369 | 234.1 | Study on Localized Mobile Metaverse Services |  | 393d | 2022-03-10 A | 2023-09-09 A | 100% |  |  | finish no earlier than 2023-09-09 | S1 | 3144h | 3144h | FS_Metaverse | 48 | Guttman, Erik, Samsung | Rel-19 | 95 |  | erik.guttman@samsung.com |
| 370 | 234.2 | Stage 1 of Localized Mobile Metaverse Services |  | 135d | 2023-06-08 A | 2023-12-12 A | 100% |  |  | finish no earlier than 2023-12-12 | S1 | 1080h | 1080h | Metaverse | 51 | Guttman, Erik, Samsung | Rel-19 | 100 |  | erik.guttman@samsung.com |
| 371 | 234.3 | Application enablement for mobile metaverse services |  | 108d | 2024-07-16 A | 2024-10-28 A | 100% |  |  | start no earlier than 2024-07-16 | S6 | 864h | 864h | Metaverse_App | 53 | Shah, Sapan, Samsung | Rel-19 | 104 |  | <sapan.shah@samsung.com> |
| 372 | 234.4 | Study on application enablement for Localized Mobile Metaverse Services |  | 181d | 2024-01-03 A | 2024-09-09 A | 100% |  |  | finish no earlier than 2024-09-09 | S6 | 1448h | 1448h | FS_Metaverse_App | 52 | Shah, Sapan, Samsung | Rel-19 | 102 |  | sapan.shah@samsung.com |
| 373 | 234.5 | Study on security aspects of 5G Mobile Metaverse services |  | 446.12d | 2024-04-02 A | 2025-06-06 A | 100% |  |  | finish no earlier than 2025-06-06 | S3 | 3569h | 3569h | FS_Metaverse_Sec | 52 | Rohini Rajendran, | Rel-19 | 103 |  | r.rohini@samsung.com |
| 374 | 234.6 | **CT aspects of Application enablement for mobile metaverse services** |  | 378.88d | 2024-09-09 A | 2025-09-09 A | 100% |  |  |  |  | 6062h | 6062h | Metaverse_App | 53 | Vijay Sangameshwara, Samsung | Rel-19 | 105 |  | s.vijay@samsung.com |
| 375 | 234.6.1 | CT1 aspects of Application enablement for mobile metaverse services |  | 378.88d | 2024-09-09 A | 2025-09-09 A | 100% |  |  | finish no earlier than 2025-09-09 | C1 | 3031h | 3031h | Metaverse_App | 53 | Vijay Sangameshwara, Samsung | Rel-19 | 105 |  | s.vijay@samsung.com |
| 376 | 234.6.2 | CT3 aspects of Application enablement for mobile metaverse services |  | 378.88d | 2024-09-09 A | 2025-09-09 A | 100% |  |  | finish no earlier than 2025-09-09 | C3 | 3031h | 3031h | Metaverse_App | 53 | Vijay Sangameshwara, Samsung | Rel-19 | 105 |  | s.vijay@samsung.com |
| 377 | 234.7 | Security aspects of 5G Mobile Metaverse services |  | 63d | 2025-01-02 A | 2025-03-03 A | 100% |  |  | finish no earlier than 2025-03-03 | S3 | 504h | 504h | Metaverse_Sec | 54 | Rohini Rajendran, r.rohini@samsung.com | Rel-19 | 106 |  | Lihui Xiong, xionglihui@oppo.com |
| 378 | 235 | **Extended Reality and Media** |  | 1071.5d | 2023-03-16 A | 2026-01-13 | 80% | 215.17d |  |  |  | 25238h | 16938h |  | 53 |  | Rel-19 | 104 |  |  |
| 379 | 235.1 | Supporting UE Mobility for XR Services |  | 59d | 2023-03-16 A | 2023-05-11 A | 100% |  |  | finish no earlier than 2023-06-06 | S1 | 472h | 472h | XRMobility | 50 | Xiaonan Shi, ChinaMobile | Rel-19 | 99 |  | shixiaonan@chinamobile.com |
| 380 | 235.2 | Study on Extended Reality and Media service (XRM) Phase 2 |  | 181d | 2024-01-03 A | 2024-06-25 A | 100% |  |  | finish no earlier than 2024-09-09 | S2 | 1448h | 1448h | FS_XRM_Ph2 | 51 | Devaki Chandramouli (Nokia) | Rel-19 | 101 |  | devaki.chandramouli@nokia.com. |
| 381 | 235.3 | Extended Reality and Media service (XRM) Phase 2 |  | 132d | 2024-06-12 A | 2024-10-17 A | 100% |  |  | finish no earlier than 2024-12-12 | S2 | 1056h | 1056h | XRM_Ph2 | 53 | Georgios Gkellas (Nokia), | Rel-19 | 104 |  | Georgios.Gkellas@nokia.com. |
| 382 | 235.4 | **CT aspects of Extended Reality and Media service (XRM) Phase 2** |  | 291.88d | 2024-12-02 A | 2025-09-09 A | 100% |  |  |  |  | 7005h | 7005h | XRM_Ph2 | 53 | Ravindran, Parthasarathi, Nokia | Rel-19 | 104 |  | parthasarathi.ravindran@nokia.com |
| 383 | 235.4.1 | CT1 aspects of Extended Reality and Media service (XRM) Phase 2 |  | 291.88d | 2024-12-02 A | 2025-09-09 A | 100% |  |  | finish no earlier than 2026-01-13 | C1 | 2335h | 2335h | XRM_Ph2 | 53 | Ravindran, Parthasarathi, Nokia | Rel-19 | 104 |  | parthasarathi.ravindran@nokia.com |
| 384 | 235.4.2 | CT3 aspects of Extended Reality and Media service (XRM) Phase 2 |  | 291.88d | 2024-12-02 A | 2025-09-09 A | 100% |  |  | finish no earlier than 2026-01-13 | C3 | 2335h | 2335h | XRM_Ph2 | 53 | Ravindran, Parthasarathi, Nokia | Rel-19 | 104 |  | parthasarathi.ravindran@nokia.com |
| 385 | 235.4.3 | CT4 aspects of Extended Reality and Media service (XRM) Phase 2 |  | 291.88d | 2024-12-02 A | 2025-09-09 A | 100% |  |  | finish no earlier than 2026-01-13 | C4 | 2335h | 2335h | XRM_Ph2 | 53 | Ravindran, Parthasarathi, Nokia | Rel-19 | 104 |  | parthasarathi.ravindran@nokia.com |
| 386 | 235.5 | Charging Aspects for XRM phase 2 |  | 657.5d | 2025-09-10 A | 2027-06-06 | 10% | 591.75d | 37268d | finish no earlier than 2027-06-06 | S5 | 5260h |  | XRM_PH2-CH | 55 | Xiaoqian Jia (China Telecom) | Rel-20 | 109 |  | jiaxq1@chinatelecom.cn |
| 387 | 235.6 | Study on Application enabler for XR Services |  | 249d | 2024-01-03 A | 2024-12-12 | 99% | 2.49d | 0d | finish no earlier than 2024-12-12 | S6 | 1992h | 1992h | FS_XRApp | 52 | Zheng, Shaowen, CMCC | Rel-19 | 102 |  | zhengshaowen@chinamobile.com |
| 388 | 235.7 | Application enablement for XRM Services Phase 2 |  | 108d | 2024-07-16 A | 2024-10-28 | 99% | 1.08d | 0d | start no earlier than 2024-07-16 | S6 | 864h | 864h | XRM_Ph2_App | 53 | Zheng, Shaowen, CMCC | Rel-19 | 104 |  | zhengshaowen@chinamobile.com |

Notes:
- 364: 24/1/25: WID:RP-242373->RP-242891
- 365: 6/12/24: FCD:12/12/2024->03/03/2025; Compl:0%->99%; Stat Rep: ->RP-242890; ; 6/3/25: FCD:08/01/2025->03/03/2025; Compl:99%->100%; Stat Rep: RP-242890->RP-250407;
- 366: 24/1/25: Stopped at 0%
- 367: -
- 368: ; 6/9/23: 0%->80; 21/9/23: 22.156 added;; 8/12/23: 80%->100 / Impacted TSs and TRs: new 22.156, 22.261 ; 22.156
- 369: 5/4/22: 22.856 added;; 4/6/22: 0%->15; 9/9/22: 15%->40; 10/12/22: 40%->55; 17/3/23: 55%->75; 8/6/23: 75%->90; 8/6/23: FCD:03/03/2023->09/20; 8/12/23: 90%->100 / Impacted TSs and TRs: 22.856
- 370: ; 6/9/23: 0%->80; 21/9/23: 22.156 added;; 8/12/23: 80%->100 / Impacted TSs and TRs: new 22.156, 22.261 ; 22.156
- 371: ; 4/9/24: 0%->25; 26/9/24: WID:SP-241009->SP-241390; 26/9/24: 23.437 added;; 5/12/24: 25%->80; 6/3/25: 80%->100; 26/3/25: 23.438 added; / Impacted TSs and TRs: 23.434; 23.542; 23.558; 23.436 ; 23.437; 23.438
- 372: 8/12/23: 0%->10; 14/3/24: 0%->30; 3/4/24: 23.700-21 added;; 13/6/24: 30%->70; 4/9/24: 70%->100 / Impacted TSs and TRs: 23.700-21
- 373: 3/4/24: 33.721 added;; 13/6/24: 0%->20; 5/9/24: 20%->50; 5/12/24: 50%->70; 6/3/25: 70%->79; 6/3/25: FCD:12/12/2024->/25; 5/6/25: 79%->100; 5/6/25: FCD:Sat 25/01/->/25 / Impacted TSs and TRs: 33.721
- 374: Impacted TSs and TRs: 24.583, 24.545, 29.549
- 375: ; 26/9/24: 24.437 added;
- 377: ; 26/3/25: WID:SP-241775->SP-250075; 17/9/25: 0%->100 / Impacted TSs and TRs: 33.434
- 378: 29/9/25: FCD:Sun 06/06/27->Tue 13/01/26; Compl:67%->99%;
- 379: ; 17/3/23: 0%->50; 6/9/23: 50%->100; 3/12/25: 99%->100 / Impacted TSs and TRs: 22.261
- 380: 9/23: company-submitted WID, to be corrected; 6/10/23: 23.700-70 added;; 8/12/23: 0%->13; 14/3/24: 0%->45; 13/6/24: FCD:05/06/2024->/24; 13/6/24: 45%->90; 4/9/24: 90%->100 / Impacted TSs and TRs: 23.700-70
- 381: ; 4/9/24: 0%->5; 26/9/24: WID:SP-240990->SP-241322; 26/9/24: WID:SP-241322->SP-241385; 5/12/24: 5%->65; 6/3/25: 65%->100 / Impacted TSs and TRs: 23.501; 23.502; 23.503; 23.316
- 382: 29/9/25: FCD:Tue 09/09/25->Tue 13/01/26; WID: CP-251135->CP-252058; List of Impacted TS & TR updated; / Impacted TSs and TRs: 24.501, 29.122, 29.508, 29.512, 29.514, 29.522, 29.561, 29.281, 29.244, 29.502, 29.564, 29.571
- 383: 29/9/25: FCD:Tue 09/09/25->Tue 13/01/26; WID: CP-251135->CP-252058;
- 384: 29/9/25: FCD:Tue 09/09/25->Tue 13/01/26; WID: CP-251135->CP-252058;
- 385: 29/9/25: FCD:Tue 09/09/25->Tue 13/01/26; WID: CP-251135->CP-252058;
- 386: ; 4/12/25: 99%->10 / Impacted TSs and TRs: 32.255; 32.291; 32.298
- 387: 8/12/23: 0%->10; 14/3/24: 0%->20; 3/4/24: 23.700-23 added;; 13/6/24: 20%->65; 4/9/24: 65%->90; 5/12/24: 90%->100; 5/12/24: FCD:09/09/2024->12/24 / Impacted TSs and TRs: 23.700-23
- 388: ; 4/9/24: 0%->15; 26/9/24: WID:SP-241007->SP-241207; 5/12/24: 15%->90; 6/3/25: 90%->100 / Impacted TSs and TRs: 23.433; 23.558

| ID | WBS | Task | Type | Duration | Start | Finish | Complete | Remaining | Total slack | Constraint | Resources | Work | Actual work | Acronym | PCG approved | WI rapporteur name | WI rapporteur e-mail | Release | TSG approved | Status Report |
| --- | --- | --- | --- | --- | --- | --- | --- | --- | --- | --- | --- | --- | --- | --- | --- | --- | --- | --- | --- | --- |
| 389 | 235.8 | **CT aspects of Application enablement for XRM Services Phase 2** |  | 291.88d | 2024-12-02 A | 2025-09-09 A | 100% |  |  |  |  | 3933h | 3933h | XRM_Ph2_App | 53 | Zhenning, Huang, China Mobile | huangzhenning@chinamobile.com | Rel-19 | 104 |  |
| 390 | 235.8.1 | CT1 aspects of Application enablement for XRM Services Phase 2 |  | 202d | 2025-02-27 A | 2025-09-09 A | 100% |  |  | finish no earlier than 2025-09-09 | C1 | 1616h | 1616h | XRM_Ph2_App | 53 | Zhenning, Huang, China Mobile | huangzhenning@chinamobile.com | Rel-19 | 104 |  |
| 391 | 235.8.2 | CT3 aspects of Application enablement for XRM Services Phase 2 |  | 289.62d | 2024-12-02 A | 2025-09-09 A | 100% |  |  | finish no earlier than 2025-09-09 | C3 | 2317h | 2317h | XRM_Ph2_App | 53 | Zhenning, Huang, China Mobile | huangzhenning@chinamobile.com | Rel-19 | 104 |  |
| 392 | 235.9 | Protection of XRM Media related information |  | 21d | 2025-02-11 A | 2025-03-03 | 99% | 0.21d | 0d | finish no earlier than 2025-03-03 | S3 | 168h | 168h | XRM_Ph2-SEC | 54 | Daniel Cho | daniel.cho@ericsson.com | Rel-19 | 107 |  |
| 393 | 235.10 | OAM support for Extended Reality and Media service (XRM) phase 2 |  | 380d | 2025-06-05 A | 2026-06-06 | 90% | 38d | 37646d | finish no earlier than 2026-06-06 | S5 | 3040h |  | XRM_Ph2-OAM | 55 | Xie Pengxiang (ZTE), | xie.pengxiang@zte.com.cn | Rel-20 | 108 |  |
| 394 | 236 | **XR (eXtended Reality) for NR Phase 3** |  | 462.62d | 2023-12-13 A | 2025-03-03 | 50% | 229.14d |  |  |  | 15987h | 5275h | NR_XR_Ph3 | 52 | Nokia |  | Rel-19 | 102 |  |
| 395 | 236.1 | Core part: XR (eXtended Reality) for NR Phase 3 |  | 659.38d | 2023-12-13 A | 2025-09-09 A | 100% |  |  | finish no earlier than 2025-09-09 | R2 | 5275h | 5275h | NR_XR_Ph3-Core | 52 | Benoist Sebire, Nokia | benoist.sebire@nokia.com | Rel-19 | 102 | RP-252160 |
| 396 | 236.2 | Perf. part: XR (eXtended Reality) for NR Phase 3 |  | 582d | 2024-08-18 A | 2026-03-03 | 60% | 232.8d | 37744.2d | finish no earlier than 2026-03-03 | R4 | 4656h |  | NR_XR_Ph3-Perf | 52 | Benoist Sebire, Nokia | benoist.sebire@nokia.com | Rel-19 | 102 | RP-252160 |
| 397 | 236.3 | UE Conformance - XR (eXtended Reality) for NR Phase 3 |  | 757d | 2025-12-12 | 2027-12-12 |  |  | 37072.2d | finish no earlier than 2027-12-12 | R5 | 6056h |  | NR_XR_Ph3-UEConTest |  | Nokia |  | Rel-19 |  |  |
| 398 | 237 | **Indirect Network Sharing** |  | 1325.25d | 2022-03-10 A | 2025-09-09 A | 100% |  |  |  |  | 12652h | 12652h | TEI19_NetShare | 52 |  |  | Rel-19 | 103 |  |
| 399 | 237.1 | Study on Network Sharing Aspects |  | 371.75d | 2022-03-10 A | 2023-03-03 A | 100% |  |  | finish no earlier than 2023-09-09 | S1 | 2974h | 2974h | FS_NetShare | 48 | Wei, Qun, China Unicom | Weiqun5 <at> chinaunicom.cn | Rel-19 | 95 |  |
| 400 | 237.2 | (Stage 1 of) Indirect Network Sharing |  | 135d | 2023-06-08 A | 2023-12-12 A | 100% |  |  | finish no earlier than 2023-12-12 | S1 | 1080h | 1080h | NetShare | 51 | Wei, Qun, China Unicom | Weiqun5 <at> chinaunicom.cn | Rel-19 | 100 |  |
| 401 | 237.3 | (Stage 2 of) Indirect Network Sharing |  | 48d | 2024-04-02 A | 2024-06-06 A | 100% |  |  | finish no earlier than 2024-06-06 | S2 | 384h | 384h | TEI19_NetShare | 52 | Xing, Tianqi, China Unicom, | xingtq@chinaunicom.cn | Rel-19 | 103 |  |
| 402 | 237.4 | Charging enhancement for indirect network sharing |  | 132d | 2024-06-12 A | 2024-12-12 A | 100% |  |  | finish no earlier than 2024-12-12 | S5 | 1056h | 1056h | NetShare_CH | 53 | Robert Törnkvist, Ericsson, | robert.tornkvist@ericsson.com | Rel-19 | 104 |  |
| 403 | 237.5 | **CT aspects of indirect network sharing** |  | 378.88d | 2024-09-09 A | 2025-09-09 A | 100% |  |  |  |  | 7158h | 7158h | TEI19_NetShare | 53 | Xing Tianqi, China Unicom | xingtq@chinaunicom.cn | Rel-19 | 105 |  |
| 404 | 237.5.1 | CT1 aspects of indirect network sharing |  | 378.88d | 2024-09-09 A | 2025-09-09 A | 100% |  |  | finish no earlier than 2025-09-09 | C1 | 3031h | 3031h | TEI19_NetShare | 53 | Xing Tianqi, China Unicom | xingtq@chinaunicom.cn | Rel-19 | 105 |  |
| 405 | 237.5.2 | CT3 aspects of indirect network sharing |  | 137d | 2025-03-03 A | 2025-09-09 A | 100% |  |  | finish no earlier than 2025-09-09 | C3 | 1096h | 1096h | TEI19_NetShare | 53 | Xing Tianqi, China Unicom | xingtq@chinaunicom.cn | Rel-19 | 105 |  |
| 406 | 237.5.3 | CT4 aspects of indirect network sharing |  | 378.88d | 2024-09-09 A | 2025-09-09 A | 100% |  |  | finish no earlier than 2025-09-09 | C4 | 3031h | 3031h | TEI19_NetShare | 53 | Xing Tianqi, China Unicom | xingtq@chinaunicom.cn | Rel-19 | 105 |  |
| 407 | 238 | Management of Network Sharing Phase 3 |  | 132d | 2025-01-30 A | 2025-06-06 A | 100% |  |  | finish no earlier than 2025-06-06 | S5 | 1056h | 1056h | NetShare_OAM_Ph3 | 54 | ZhaoNing Wang (China Unicom) | wangzn18@chinaunicom.cn | Rel-19 | 106 |  |
| 408 | 239 | **Roaming Value-Added Services** |  | 1139.75d | 2022-06-02 A | 2025-06-06 A | 100% |  |  |  |  | 6262h | 6262h | TEI19_RVAS | 52 |  |  | Rel-19 | 103 |  |
| 409 | 239.1 | Study on roaming value added services |  | 138d | 2022-06-02 A | 2022-12-12 A | 100% |  |  | finish no earlier than 2022-12-12 | S1 | 1104h | 1104h | FS_RVAS | 49 | Peter Bleckert, Ericsson |  | Rel-19 | 96 |  |
| 410 | 239.2 | Roaming Value-Added Services |  | 22d | 2023-02-02 A | 2023-03-03 A | 100% |  |  | finish no earlier than 2023-03-03 | S1 | 176h | 176h | RVAS | 50 | Peter Bleckert, Ericsson |  | Rel-19 | 99 |  |
| 411 | 239.3 | Architecture support of roaming value-added services |  | 62d | 2024-03-13 A | 2024-06-06 A | 100% |  |  | finish no earlier than 2024-06-06 | S2 | 496h | 496h | TEI19_RVAS | 52 | Qian Chen, Ericsson, | qian.xb.chen@ericsson.com | Rel-19 | 103 |  |
| 412 | 239.4 | **CT aspects of Architecture support of roaming value-added services** |  | 280.38d | 2024-09-09 A | 2025-06-06 A | 100% |  |  |  |  | 4486h | 4486h | TEI19_RVAS | 52 | Frank Yong, Yang, Ericsson | frank.yong.yang@ericsson.com | Rel-19 | 103 |  |
| 413 | 239.4.1 | CT3 aspects of Architecture support of roaming value-added services |  | 280.38d | 2024-09-09 A | 2025-06-06 A | 100% |  |  | finish no earlier than 2025-06-06 | C3 | 2243h | 2243h | TEI19_RVAS | 52 | Frank Yong, Yang, Ericsson | frank.yong.yang@ericsson.com | Rel-19 | 103 |  |
| 414 | 239.4.2 | CT4 aspects of Architecture support of roaming value-added services |  | 280.38d | 2024-09-09 A | 2025-06-06 A | 100% |  |  | finish no earlier than 2025-06-06 | C4 | 2243h | 2243h | TEI19_RVAS | 52 | Frank Yong, Yang, Ericsson | frank.yong.yang@ericsson.com | Rel-19 | 103 |  |
| 415 | 240 | Rel-19 user plane | milestone | 0d? | 2016-03-15 A | 2016-03-15 A | 100% |  |  | start no earlier than 2016-03-15 |  |  |  |  |  |  |  | Rel-19 |  |  |
| 416 | 241 | Media Messaging Enhancements | manual | 100.5d | 2025-06-05 A | 2025-09-09 A | 100% |  |  | start no earlier than 2025-06-05 | S4 | 804h | 804h | MeME-MED | 55 | Thomas Stockhammer, Qualcomm Incorporated | tsto@qti.qualcomm.com | Rel-19 | 108 |  |
| 417 | 242 | Avatar Communications in AR Calls |  | 194.75d | 2025-03-06 A | 2025-09-09 A | 100% |  |  | start no earlier than 2025-03-06 | S4 | 1558h | 1558h | AvCall-MED | 54 | Bouazizi, Imed, Qualcomm, | bouazizi AT qti dot qualcomm dot com | Rel-19 | 107 |  |
| 418 | 243 | Study on immersive Real-Time Communication for WebRTC, Phase 2 |  | 280.38d | 2024-09-09 A | 2025-06-06 A | 100% |  |  | finish no earlier than 2025-06-06 | S4 | 2243h | 2243h | FS_iRTCW_Ph2 | 53 | Hakju Ryan Lee, Samsung Electronics, CO., LTD, | hakju00.lee@samsung.com | Rel-19 | 105 |  |
| 419 | 244 | Terminal Audio quality performance and Test methods for Immersive Audio Services, Phase 2 |  | 476.12d | 2024-09-09 A | 2025-12-12 A | 100% |  |  | finish no earlier than 2025-12-12 | S4 | 3809h | 3809h | ATIAS_Ph2 | 53 | Jan Reimes, HEAD acoustics GmbH, | jan.reimes@head-acoustics.com | Rel-19 | 105 |  |
| 420 | 245 | Study on Spatial Computing for AR Services |  | 477.38d | 2024-06-06 A | 2025-09-09 A | 100% |  |  | finish no earlier than 2025-09-09 | S4 | 3819h | 3819h | FS_ARSpatial | 53 | Hamza, Ahmed, InterDigital Canada | <Ahmed.Hamza@InterDigital.com> | Rel-19 | 104 |  |
| 421 | 246 | EVS Codec Extension for Immersive Voice and Audio Services, Phase 2 |  | 574.62d | 2024-06-06 A | 2025-12-12 A | 100% |  |  | finish no earlier than 2025-12-12 | S4 | 4597h | 4597h | IVAS_Codec_Ph2 | 53 | Su, Huan-yu, Huawei Technologies Co Ltd., | su.huanyu@huawei.com | Rel-19 | 104 |  |
| 422 | 247 | Study on Haptics in 5G Media Services |  | 189d | 2024-06-12 A | 2025-03-03 A | 100% |  |  | start no earlier than 2024-06-12 | S4 | 1512h | 1512h | FS_HapticsMedia | 53 | Gaëlle Martin-Cocher, InterDigital | (Gaelle.Martin-Cocher@InterDigital.com) | Rel-19 | 104 |  |

Notes:
- 389: Impacted TSs and TRs: 24.543, 24.548, 29.548, 29.549, 29.558
- 392: ; 17/9/25: 0%->100 / Impacted TSs and TRs: 33.501
- 393: ; 12/9/25: 0%->15; 4/12/25: 15%->90 / Impacted TSs and TRs: 28.540; 28.541; 28.552; 28.554
- 394: 2/4/24: WID:RP-234080->RP-240791; 26/9/24: WID:RP-240791->RP-241771; 24/1/25: WID:RP-241771->RP-243318; 3/4/25: WID:RP-243318->RP-250107
- 395: 14/3/24: Compl:0%->2%; Stat Rep: ->RP-240081; Rapporteur: Nokia->Benoist S bire, Nokia; Rap eMail: ->benoist.sebire@nokia.com; ; 13/6/24: Compl:2%->18%; Stat Rep: RP-240081->RP-240927; ; 4/9/24: FCD:09/09/2025->25/09/2024; Compl:18%->30%; Stat Rep: RP-240; 11/9/25: Compl:90%->100%; Stat Rep: RP-251002->RP-252160;
- 396: 14/3/24: Stat Rep: ->RP-240081; Rapporteur: Nokia->Benoist S bire, Nokia; Rap eMail: ->benoist.sebire@nokia.com; ; 13/6/24: Stat Rep: RP-240081->RP-240927; ; 4/9/24: FCD:03/03/2026->26/03/2025; Stat Rep: RP-240927->RP-241770; ; 6/12/24: FCD:03/03/2025->03; 23/1/26: 10%->60
- 399: 5/4/22: 22.851 added;; 4/6/22: 0%->10; 9/9/22: 10%->20; 10/12/22: 20%->75; 17/3/23: 75%->80; 17/3/23: FCD:12/12/2022->/23; 8/6/23: 80%->95; 8/6/23: FCD:03/03/2023->09/20; 6/9/23: 95%->100 / Impacted TSs and TRs: 22.851
- 400: ; 6/9/23: 0%->100 / Impacted TSs and TRs: 22.261
- 401: ; 13/6/24: FCD:12/12/2024->06/24; 13/6/24: 0%->100 / Impacted TSs and TRs: 23.501; 23.502
- 402: ; 5/12/24: 0%->100 / Impacted TSs and TRs: 32.240; 32.255; 32.256
- 403: Impacted TSs and TRs: 24.501,29.507,29.525,29.531,29.510,29.502,29.509,29.503,29.536
- 407: ; 6/3/25: 0%->50; 6/6/25: 50%->95; 12/9/25: 95%->100 / Impacted TSs and TRs: 28.552; 32.130; 28.541
- 409: 13/7/22: 22.877 added;; 9/9/22: 0%->60; 10/12/22: FCD:10/03/2023->12/22; 10/12/22: 60%->100 / Impacted TSs and TRs: 22.877
- 410: ; 17/3/23: 0%->100 / Impacted TSs and TRs: 22.261
- 411: ; 13/6/24: FCD:12/12/2024->/24; 13/6/24: 0%->100 / Impacted TSs and TRs: 23.501; 23.502
- 415: -
- 416: ; 12/9/25: 0%->100 / Impacted TSs and TRs: 26.143
- 417: ; 5/6/25: 0%->15; 12/9/25: 15%->100 / Impacted TSs and TRs: 26.264
- 418: 5/12/24: 0%->15; 6/3/25: 15%->35; 26/3/25: 26.830 added;; 5/6/25: 35%->100; 5/6/25: FCD:Mon 03/03/->/25 / Impacted TSs and TRs: 26.830
- 419: ; 6/3/25: 0%->25; 5/6/25: 25%->65; 5/6/25: FCD:Fri 06/06/->/25; 12/9/25: 65%->75; 12/9/25: FCD:Tue 09/09/->12/20; 4/12/25: 75%->100 / Impacted TSs and TRs: 26.259; 26.260; 26.261
- 420: 4/9/24: 0%->10; 26/9/24: 26.819 added;; 5/12/24: 10%->25; 6/3/25: 25%->45; 5/6/25: 45%->45; 5/6/25: FCD:Fri 14/02/->/25; 12/9/25: 45%->100 / Impacted TSs and TRs: 26.819
- 421: ; 4/9/24: 0%->5; 5/12/24: 5%->20; 5/12/24: FCD:06/06/2025->/25; 6/3/25: 20%->35; 26/3/25: WID:SP-241000->SP-250262; 26/3/25: FCD:19/04/2025->12/25; 5/6/25: 35%->65; 5/6/25: FCD:Fri 12/12/->/25; 12/9/25: 65%->80; 12/9/25: FCD:Tue 09/09/->12/20; 4/12/25: 80%->100 / Impacted TSs and TRs: 26.114; 26.117; 26.119; 26.249; 26.250; 26.252; 26.253; 26.258; 26.997
- 422: 4/9/24: WID:SP-240979->SP-241121; acron.: FS_HapticsMed-> FS_HapticsMedia; 4/9/24: 0%->15; 26/9/24: 26.854 added;; 5/12/24: 15%->60; 6/3/25: 60%->100 / Impacted TSs and TRs: 26.854

| ID | WBS | Task | Type | Duration | Start | Finish | Complete | Remaining | Total slack | Constraint | Resources | Work | Actual work | Acronym | PCG approved | WI rapporteur name | WI rapporteur e-mail | Release | TSG approved |
| --- | --- | --- | --- | --- | --- | --- | --- | --- | --- | --- | --- | --- | --- | --- | --- | --- | --- | --- | --- |
| 423 | 248 | **UPF enhancement for Exposure And SBA Phase 2** |  | 636.62d | 2024-01-04 A | 2025-09-09 A | 100% |  |  |  | S2 | 13287h | 13287h | UPEAS_Ph2 | 53 | Zhu Jinguo, ZTE | zhu.jinguo@zte.com.cn | Rel-19 | 105 |
| 424 | 248.1 | Study on UPF enhancement for Exposure And SBA Phase 2 |  | 113d | 2024-01-04 A | 2024-06-06 A | 100% |  |  | finish no earlier than 2024-06-06 | S2 | 904h | 904h | FS_UPEAS_Ph2 | 52 | Zhu Jinguo, ZTE | zhu.jinguo@zte.com.cn | Rel-19 | 102 |
| 425 | 248.2 | Stage 2 of UPF enhancement for Exposure And SBA Phase 2 |  | 132d | 2024-06-12 A | 2024-12-12 A | 100% |  |  | finish no earlier than 2024-12-12 | S2 | 1056h | 1056h | UPEAS_Ph2 | 53 | Zhu Jinguo, ZTE | zhu.jinguo@zte.com.cn | Rel-19 | 104 |
| 426 | 248.3 | **CT aspects of UPF enhancement for Exposure And SBA Phase 2** |  | 378.88d | 2024-09-09 A | 2025-09-09 A | 100% |  |  |  | C4 | 8446h | 8446h | UPEAS_Ph2 | 53 | Shuang Liang, ZTE | liang.shuang3@zte.com.cn | Rel-19 | 105 |
| 427 | 248.3.1 | CT3 aspects of UPF enhancement for Exposure And SBA Phase 2 |  | 378.88d | 2024-09-09 A | 2025-09-09 A | 100% |  |  | finish no earlier than 2025-09-09 | C3 | 3031h | 3031h | UPEAS_Ph2 | 53 | Shuang Liang, ZTE | liang.shuang3@zte.com.cn | Rel-19 | 105 |
| 428 | 248.3.2 | CT4 aspects of UPF enhancement for Exposure And SBA Phase 2 |  | 378.88d | 2024-09-09 A | 2025-09-09 A | 100% |  |  | finish no earlier than 2025-09-09 | C4 | 3031h | 3031h | UPEAS_Ph2 | 53 | Shuang Liang, ZTE | liang.shuang3@zte.com.cn | Rel-19 | 105 |
| 429 | 249 | Video Operating Points - Harmonization and Stereo MV-HEVC |  | 662.62d | 2024-03-13 A | 2025-12-12 A | 100% |  |  | finish no earlier than 2025-12-12 | S4 | 5301h | 5301h | VOPS | 52 | Waqar Zia | waqar_zia (at) apple.com | Rel-19 | 103 |
| 430 | 250 | Split rendering over IMS |  | 544.62d | 2024-04-02 A | 2025-09-09 A | 100% |  |  | finish no earlier than 2025-09-09 | S4 | 4357h | 4357h | SR_IMS | 52 | He, Shane, Nokia Corporation | shane.he@nokia.com | Rel-19 | 103 |
| 431 | 251 | Study on Media Messaging |  | 446.12d | 2024-04-02 A | 2025-06-06 A | 100% |  |  | finish no earlier than 2025-06-06 | S4 | 3569h | 3569h | FS_MeMe | 52 | Thomas Stockhammer, Qualcomm Incorporated, | tsto@qti.qualcomm.com | Rel-19 | 103 |
| 432 | 252 | Study on Advanced Media Delivery |  | 183d | 2024-04-02 A | 2024-12-12 A | 100% |  |  | finish no earlier than 2024-12-12 | S4 | 1464h | 1464h | FS_AMD | 52 | Thomas Stockhammer, Qualcomm Incorporated, | tsto@qti.qualcomm.com | Rel-19 | 103 |
| 433 | 253 | Stage 2 for Advanced Media Delivery |  | 63d | 2024-12-05 A | 2025-03-03 A | 100% |  |  | finish no earlier than 2025-03-03 | S4 | 504h | 504h | AMD-ARCH-MED | 54 | Thomas Stockhammer, Qualcomm Incorporated | tsto@qti.qualcomm.com | Rel-19 | 106 |
| 434 | 254 | Stage 3 for Advanced Media Delivery |  | 293d | 2025-03-05 A | 2025-12-12 A | 100% |  |  | finish no earlier than 2025-12-12 | S4 | 2344h | 2344h | AMD_PRO-MED | 54 | Thomas Stockhammer, Qualcomm Incorporated | tsto@qti.qualcomm.com, for all topics except OpenAPI | Rel-19 | 107 |
| 435 | 255 | **CT aspects of Advanced Media Delivery** |  | 99.5d | 2025-06-06 A | 2025-09-09 A | 100% |  |  |  |  | 1592h | 1592h | AMD_PRO-MED-CT | 54 | Hanna Lim, Qualcomm Incorporated | hannalim@qti.qualcomm.com | Rel-19 | 107 |
| 436 | 255.1 | DELETED - CT3 aspects of Advanced Media Delivery |  | 99.5d | 2025-06-06 A | 2025-09-09 A | 100% |  |  | finish no earlier than 2025-10-23 | C3 | 796h | 796h | AMD_PRO-MED-CT | 54 | Hanna Lim, Qualcomm Incorporated | hannalim@qti.qualcomm.com | Rel-19 | 107 |
| 437 | 255.2 | CT4 aspects of Advanced Media Delivery |  | 99.5d | 2025-06-06 A | 2025-09-09 A | 100% |  |  | finish no earlier than 2025-10-23 | C4 | 796h | 796h | AMD_PRO-MED-CT | 54 | Hanna Lim, Qualcomm Incorporated | hannalim@qti.qualcomm.com | Rel-19 | 107 |
| 438 | 256 | Study of 5G Real-time Transport Protocol Configurations, Phase 2 |  | 183d | 2024-04-02 A | 2024-12-12 A | 100% |  |  | start no earlier than 2024-04-02 | S4 | 1464h | 1464h | FS_5G_RTP_Ph2 | 52 | Igor Curcio, Nokia Corporation | igor.curcio@nokia.com | Rel-19 | 103 |
| 439 | 257 | 5G Real-time Transport Protocol Configurations, Phase 2 |  | 288.88d | 2024-12-05 A | 2025-09-09 A | 100% |  |  | finish no earlier than 2025-09-09 | S4 | 2311h | 2311h | 5G_RTP_Ph2 | 54 | Igor Curcio, Nokia Corporation | igor.curcio@nokia.com | Rel-19 | 106 |
| 440 | 258 | Study on Beyond 2D Video |  | 544.62d | 2024-04-02 A | 2025-09-09 A | 100% |  |  | finish no earlier than 2025-09-09 | S4 | 4357h | 4357h | FS_Beyond2D | 52 | Jiayi Xu, | xujiayi@chinamobile.com | Rel-19 | 103 |
| 441 | 259 | Rel-19 Verticals and Non Public Network | milestone | 0d? | 2016-03-15 A | 2016-03-15 A | 100% |  |  | start no earlier than 2016-03-15 |  |  |  |  |  |  |  | Rel-19 |  |
| 442 | 260 | **Common API Framework (CAPIF) Phase 3** |  | 767.12d | 2024-01-04 A | 2026-01-13 | 88% | 90.69d |  |  |  | 15577h | 13323h | CAPIF_Ph3 | 53 | Niranth Amogh, Nokia | niranth.amogh@nokia.com | Rel-19 | 105 |
| 443 | 260.1 | Study on CAPIF Phase 3 |  | 248d | 2024-01-04 A | 2024-12-12 | 96% | 9.92d | 0d | finish no earlier than 2024-12-12 | S6 | 1984h | 1984h | FS_CAPIF_Ph3 | 52 | Preciado Rojas, Diego, Nokia | diego.preciado_rojas@nokia.com | Rel-19 | 102 |
| 444 | 260.2 | Stage 2 of Common API Framework (CAPIF) Phase 3 |  | 72d | 2024-10-04 A | 2024-12-12 | 96% | 2.88d | 0d | finish no earlier than 2024-12-12 | S6 | 576h | 576h | CAPIF_Ph3 | 53 | Niranth Amogh, Nokia | niranth.amogh@nokia.com | Rel-19 | 105 |
| 445 | 260.3 | **CT aspects of Common API Framework (CAPIF) Phase 3** |  | 291.88d | 2024-12-02 A | 2025-09-09 A | 100% |  |  |  |  | 2335h | 2335h | CAPIF_Ph3 | 53 | Paul, Bhaskar, Nokia | bhaskar.paul@nokia.com | Rel-19 | 105 |
| 446 | 260.3.1 | CT3 aspects of Common API Framework (CAPIF) Phase 3 |  | 291.88d | 2024-12-02 A | 2025-09-09 A | 100% |  |  | finish no earlier than 2026-01-13 | C3 | 2335h | 2335h | CAPIF_Ph3 | 53 | Paul, Bhaskar, Nokia | bhaskar.paul@nokia.com | Rel-19 | 105 |
| 447 | 260.4 | Study on security aspects of CAPIF Phase 3 |  | 372.62d | 2024-06-12 A | 2025-06-06 | 96% | 14.9d | 0d | finish no earlier than 2025-06-06 | S3 | 2981h | 2981h | FS_CAPIF_Ph3-sec | 53 | Henry Leung ( Xiaomi) | lianghaoran@xiaomi.com | Rel-19 | 104 |
| 448 | 260.5 | Security aspects of CAPIF Phase3 |  | 132d | 2025-01-30 A | 2025-06-06 | 96% | 5.28d | 0d | finish no earlier than 2025-06-06 | S3 | 1056h | 1056h | CAPIF_Ph3_sec | 54 | 1st rapporteur: Henry Leung (Xiaomi), | lianghaoran@xiaomi.com | Rel-19 | 106 |
| 449 | 260.6 | Study on Charging Aspects of CAPIF |  | 274.38d | 2024-06-12 A | 2025-03-03 A | 100% |  |  | finish no earlier than 2025-03-03 | S5 | 2195h | 2195h | FS_CAPIF_Ph2_CH | 53 | João Rodrigues, Nokia, | joao.a.rodrigues@nokia.com | Rel-19 | 104 |
| 450 | 260.7 | Charging aspects of CAPIF |  | 174d | 2025-03-26 A | 2025-09-09 A | 100% |  |  | start no earlier than 2025-03-26 | S5 | 1392h | 1392h | CH_CAPIF_EXT | 54 | João Rodrigues, Nokia | joao.a.rodrigues@nokia.com | Rel-19 | 107 |
| 451 | 260.8 | Study on Charging Aspects of CAPIF phase 3 |  | 281.75d | 2025-06-05 A | 2026-03-03 | 30% | 197.22d | 37744.2d | finish no earlier than 2026-03-03 | S5 | 2254h |  | FS_CAPIF_Ph3_CH | 55 | ur: João Rodrigues (Nokia), | joao.a.rodrigues@nokia.com | Rel-20 | 108 |
| 452 | 260.9 | Deleted - Converged Charging aspects of CAPIF Phase 3 |  | 100.5d | 2025-06-05 A | 2025-09-09 A | 100% |  |  | finish no earlier than 2025-09-09 | S5 | 804h | 804h | CAPIF_Ph3_con-CH | 55 |  |  | Rel-19 | 108 |
| 453 | 261 | Enhanced OAM for management service exposure to external consumers through CAPIF |  | 199d | 2025-03-01 A | 2025-09-09 A | 100% |  |  | finish no earlier than 2025-09-09 | S5 | 1592h | 1592h | MExpo | 54 | Winnie Nakimuli (Nokia) | winnie.nakimuli@nokia.com | Rel-19 | 106 |
| 454 | 262 | Non-Public Network (NPN) security considerations |  | 12d | 2023-05-22 A | 2023-06-06 A | 100% |  |  | start no earlier than 2023-05-22 | S1 | 96h | 96h | SecNPN | 51 | Yinglin Chen, China Telecom | chenyl37@chinatelecom.cn | Rel-19 | 100 |
| 455 | 263 | Study on security for PLMN hosting a NPN |  | 181d | 2024-01-03 A | 2024-09-09 A | 100% |  |  | finish no earlier than 2024-09-09 | S3 | 1448h | 1448h | PLMNNPN_SEC | 52 | Jun Shen | shenjun6@chinatelecom.cn | Rel-19 | 102 |
| 456 | 264 | Security for PLMN hosting a NPN |  | 190.38d | 2024-12-05 A | 2025-06-06 A | 100% |  |  | finish no earlier than 2025-06-06 | S3 | 1523h | 1523h | PLMNNPN | 54 | Jun Shen | shenjun6@chinatelecom.cn | Rel-19 | 106 |

Notes:
- 423: Impacted TSs and TRs: 23.501; 23.502; 23.503
- 424: 14/3/24: 0%->45; 13/6/24: 45%->100
- 425: ; 4/9/24: 0%->65; 5/12/24: 65%->100 / Impacted TSs and TRs: 23.501; 23.502; 23.503
- 426: Impacted TSs and TRs: 29.244,29.503,29.504,29.510,29.564,29.571,29.508,29.512,29.513,29.514,29.519,29.522
- 429: 14/5/24: 26.265 added;; 13/6/24: 0%->15; 4/9/24: 15%->20; 4/9/24: 20%->; 5/12/24: 20%->45; 5/12/24: FCD:03/03/2025->/25; 6/3/25: 45%->70; 5/6/25: 70%->70; 5/6/25: FCD:Sat 18/01/->12/20; 5/6/25: WID:SP-240060->SP-250633; 27/6/25: WID:SP-250633->SP-250818; ; 4/12/25: 95%->100 / Impacted TSs and TRs: 26.265; 26.116; 26.118; 26.119; 26.143; 26.511
- 430: ; 14/5/24: 26.567 added;; 13/6/24: 0%->10; 4/9/24: 10%->25; 5/12/24: 25%->45; 5/12/24: FCD:03/03/2025->/25; 6/3/25: 45%->65; 5/6/25: 65%->95; 5/6/25: FCD:Sat 25/01/->/2025; 12/9/25: 95%->100 / Impacted TSs and TRs: 26.264 ; 26.567
- 431: 13/6/24: 0%->10; 13/6/24: FCD:12/12/2024->/25; 4/9/24: 10%->30; 5/12/24: 30%->60; 6/3/25: 60%->65; 6/3/25: FCD:03/03/2025->/25; 5/6/25: 65%->100; 5/6/25: FCD:Sat 25/01/->/25
- 432: ; 13/6/24: 0%->15; 16/7/24: WID:SP-240478->SP-241011; 4/9/24: 15%->30; 5/12/24: 30%->75; 6/3/25: 75%->100 / Impacted TSs and TRs: 26.802; 26.804
- 433: ; 6/3/25: 0%->100 / Impacted TSs and TRs: 26.501; 26.502
- 434: ; 5/6/25: 0%->40; 12/9/25: 40%->85; 4/12/25: 85%->100 / Impacted TSs and TRs: 26.510; 26.511; 26.512; 26.517; 26.532; 26.247; 26.510; 26.512; 26.517; 26.532
- 435: ; 29/9/25: FCD:Tue 09/09/25->Thu 23/10/25; WID: CP-251037->CP-252191; List of Impacted TS & TR updated; / Impacted TSs and TRs: 29.581
- 436: ; 29/9/25: FCD:Tue 09/09/25->Thu 23/10/25; WID: CP-251037->CP-252191; / Impacted TSs and TRs: 29.522, 29.580, 29.581
- 437: ; 29/9/25: FCD:Tue 09/09/25->Thu 23/10/25; WID: CP-251037->CP-252191; / Impacted TSs and TRs: 29.522, 29.580, 29.581
- 438: 14/5/24: 26.822 added;; 13/6/24: 0%->40; 4/9/24: 40%->65; 5/12/24: 65%->100 / Impacted TSs and TRs: 26.822
- 439: ; 6/3/25: 0%->35; 5/6/25: 35%->75; 5/6/25: FCD:Sun 15/06/->/25; 12/9/25: 75%->100 / Impacted TSs and TRs: 26.522; 26.510; 26.113
- 440: 14/5/24: 26.956 added;; 13/6/24: 0%->10; 4/9/24: 10%->17; 5/12/24: 17%->28; 6/3/25: 28%->50; 6/3/25: FCD:06/06/2025->/25; 5/6/25: 50%->70; 5/6/25: FCD:Fri 06/06/->/25; 12/9/25: 70%->100 / Impacted TSs and TRs: 26.956
- 441: -
- 442: ; 29/9/25: FCD:Tue 03/03/26->Tue 13/01/26; Compl:83%->96%; / Impacted TSs and TRs: 23.222
- 443: 14/3/24: 0%->20; 3/4/24: 23.700-22 added;; 13/6/24: 20%->55; 4/9/24: 55%->90; 5/12/24: 90%->100; 5/12/24: FCD:09/09/2024->12/24 / Impacted TSs and TRs: 23.700-22
- 444: ; 8/1/25: WID:SP-241381->SP-241694; 9/6/25: 0%->100 / Impacted TSs and TRs: 23.222
- 445: ; 29/9/25: WID: CP-243074->CP-252059; / Impacted TSs and TRs: 29.222
- 446: ; 29/9/25: FCD:Tue 09/09/25->Tue 13/01/26; WID: CP-243074->CP-252059; / Impacted TSs and TRs: 29.222
- 447: 5/9/24: 0%->20; 26/9/24: 33.700-22 added;; 5/12/24: 20%->60; 6/3/25: 60%->60; 5/6/25: 60%->100; 5/6/25: FCD:Thu 17/10/->/25 / Impacted TSs and TRs: 33.700-22
- 448: ; 26/3/25: WID:SP-241776->SP-250076; 5/6/25: 0%->100 / Impacted TSs and TRs: 33.122
- 449: 13/6/24: 0%->15; 4/9/24: 15%->35; 26/9/24: 28.849 added;; 5/12/24: 35%->75; 6/3/25: 75%->100; 12/9/25: FCD:Thu 17/10/->/24; 4/12/25: 96%->100 / Impacted TSs and TRs: 28.849
- 450: ; 6/6/25: 0%->70; 27/6/25: WID:SP-250366->SP-250820; 12/9/25: 70%->100; 4/12/25: 96%->100 / Impacted TSs and TRs: 32.240; 32.254; 32.291; 32.298
- 451: 18/7/25: 28.891 added;; 4/12/25: 96%->30 / Impacted TSs and TRs: 28.891
- 452: ; 12/9/25: 0%->100; 29/9/25: WID:SP-250509->SP- 251027. Stopped/deleted at 96% / Impacted TSs and TRs: 32.254; 32.291; 32.298
- 453: 6/3/25: 0%->15; 6/6/25: 15%->80; 12/9/25: 80%->100
- 454: Impacted TSs and TRs: 22.261
- 455: 4/1/24: 33.757 added;; 14/3/24: 0%->25; 13/6/24: 25%->70; 5/9/24: 70%->75; 5/12/24: 75%->95; 6/3/25: 95%->100; 5/6/25: 100%->100 / Impacted TSs and TRs: 33.757
- 456: ; 6/3/25: 0%->90; 5/6/25: 90%->100 / Impacted TSs and TRs: 33.501

| ID | WBS | Task | Duration | Start | Finish | Complete | Remaining | Actual start | Actual finish | Total slack | Constraint | Resources | Work | Actual work | Acronym | PCG approved | WI rapporteur name | WI rapporteur e-mail | Release | TSG approved | TSG stopped | Status Report |
| --- | --- | --- | --- | --- | --- | --- | --- | --- | --- | --- | --- | --- | --- | --- | --- | --- | --- | --- | --- | --- | --- | --- |
| 457 | 265 | **ProSe support in NPN** | 565.38d | 2024-03-13 A | 2025-09-09 A | 100% |  |  |  |  |  |  | 10750h | 10750h | TEI19_ProSe_NPN | 52 | Walter Dees, Philips International B.V., | walter.dees@philips.com | Rel-19 | 103 |  |  |
| 458 | 265.1 | Stage 2 of ProSe support in NPN | 62d | 2024-03-13 A | 2024-06-06 A | 100% |  |  |  |  | finish no earlier than 2024-06-06 | S2 | 496h | 496h | TEI19_ProSe_NPN | 52 | Walter Dees, Philips International B.V., | walter.dees@philips.com | Rel-19 | 103 |  |  |
| 459 | 265.2 | **CT aspects of ProSe support in NPN** | 378.88d | 2024-09-09 A | 2025-09-09 A | 100% |  |  |  |  |  |  | 10254h | 10254h | TEI19_ProSe_NPN | 52 | Li, Mingxue, China Telecom | limx36@chinatelecom.cn | Rel-19 | 103 |  |  |
| 460 | 265.2.1 | CT1 aspects of ProSe support in NPN | 378.88d | 2024-09-09 A | 2025-09-09 A | 100% |  |  |  |  | finish no earlier than 2025-09-09 | C1 | 3031h | 3031h | TEI19_ProSe_NPN | 52 | Li, Mingxue, China Telecom | limx36@chinatelecom.cn | Rel-19 | 103 |  |  |
| 461 | 265.2.2 | CT3 aspects of ProSe support in NPN | 262d | 2024-09-09 A | 2025-09-09 A | 100% |  |  |  |  | finish no earlier than 2025-09-09 | C3 | 2096h | 2096h | TEI19_ProSe_NPN | 52 | Li, Mingxue, China Telecom | limx36@chinatelecom.cn | Rel-19 | 103 |  |  |
| 462 | 265.2.3 | CT4 aspects of ProSe support in NPN | 378.88d | 2024-09-09 A | 2025-09-09 A | 100% |  |  |  |  | finish no earlier than 2025-09-09 | C4 | 3031h | 3031h | TEI19_ProSe_NPN | 52 | Li, Mingxue, China Telecom | limx36@chinatelecom.cn | Rel-19 | 103 |  |  |
| 463 | 265.2.4 | DELETED - CT6 aspects of ProSe support in NPN | 262d | 2024-12-30 A | 2025-09-09 A | 100% |  |  |  |  | finish no earlier than 2025-09-09 | C6 | 2096h | 2096h | TEI19_ProSe_NPN | 52 | Li, Mingxue, China Telecom | limx36@chinatelecom.cn | Rel-19 | 103 | 108 |  |
| 464 | 266 | **Rel-19 Enhancements of 3GPP Northbound and Application Layer Interfaces and APIs** | 465.88d | 2024-06-17 A | 2025-09-09 A | 100% |  |  |  |  |  |  | 7454h | 7454h | NBI19 | 51 | Abdessamad El Moatamid, Huawei | abdessamad.el.moatamid@huawei.com | Rel-19 | 101 |  |  |
| 465 | 266.1 | CT1 aspects of Rel-19 Enhancements of 3GPP Northbound and Application Layer Interfaces and APIs | 465.88d | 2024-06-17 A | 2025-09-09 A | 100% |  |  |  |  | finish no earlier than 2025-09-09 | C1 | 3727h | 3727h | NBI19 | 51 | Abdessamad El Moatamid, Huawei | abdessamad.el.moatamid@huawei.com | Rel-19 | 101 |  |  |
| 466 | 266.2 | CT3 aspects of Rel-19 Enhancements of 3GPP Northbound and Application Layer Interfaces and APIs | 465.88d | 2024-06-17 A | 2025-09-09 A | 100% |  |  |  |  | finish no earlier than 2025-09-09 | C3 | 3727h | 3727h | NBI19 | 51 | Abdessamad El Moatamid, Huawei | abdessamad.el.moatamid@huawei.com | Rel-19 | 101 |  |  |
| 467 | 267 | Rel-19 Radio: NR-only, band-related | 1d | 2019-03-07 | 2019-03-07 |  |  |  |  | 40387.9d |  |  |  |  |  |  |  |  | Rel-19 |  |  |  |
| 468 | 268 | **7MHz Channel Bandwidth for n26 and n5** | 495d | 2024-05-19 | 2025-09-08 | 99% | 0d | 2024-10-14 |  |  |  | R4 | 8986h | 6250h | NR_FR1_7MHz_BW | 54 | China Telecom |  | Rel-19 | 106 |  |  |
| 469 | 268.1 | Core part: 7MHz Channel Bandwidth for n26 and n5 | 342d | 2024-10-14 A | 2025-09-09 A | 100% |  |  |  |  | finish no earlier than 2025-09-09 | R4 | 2736h | 2736h | NR_FR1_7MHz_BW-Core | 54 | China Telecom |  | Rel-19 | 106 |  | RP-252543 |
| 470 | 268.2 | Perf. Part: 7MHz Channel Bandwidth for n26 and n5 | 439.25d | 2024-10-14 A | 2025-12-12 A | 100% |  |  |  |  | finish no earlier than 2025-12-12 | R4 | 3514h | 3514h | NR_FR1_7MHz_BW-Perf | 54 | China Telecom |  | Rel-19 | 106 |  | RP-253462 |
| 471 | 269 | **Introduction of the NR FDD 1.4 GHz band** | 196.75d | 2024-06-06 A | 2024-12-12 | 100% |  |  | 2025-03-03 |  |  | R4 | 5578h | 5578h | NR_FDD_1400MHz | 53 | MidWave Wireless |  | Rel-19 | 104 |  |  |
| 472 | 269.1 | Core part: Introduction of the NR FDD 1.4 GHz band | 280.62d | 2024-06-06 A | 2025-03-03 A | 100% |  |  |  |  | finish no earlier than 2025-03-03 | R4 | 2245h | 2245h | NR_FDD_1400MHz-Core | 53 | MidWave Wireless |  | Rel-19 | 104 |  | RP-250403 |
| 473 | 269.2 | Perf. part: Introduction of the NR FDD 1.4 GHz band | 280.62d | 2024-06-06 A | 2025-03-03 A | 100% |  |  |  |  | finish no earlier than 2025-03-03 | R4 | 2245h | 2245h | NR_FDD_1400MHz-Perf | 53 | MidWave Wireless |  | Rel-19 | 104 |  | RP-250403 |
| 474 | 270 | **Introduction of NR bands n87 and n88** | 280.62d | 2024-06-06 A | 2025-03-03 A | 100% |  |  |  |  |  | R4 | 6034h | 6034h | NR_bands_n87_n88 | 53 | Nokia |  | Rel-19 | 104 |  |  |
| 475 | 270.1 | Core part: Introduction of NR bands n87 and n88 | 280.62d | 2024-06-06 A | 2025-03-03 A | 100% |  |  |  |  | finish no earlier than 2025-03-03 | R4 | 2245h | 2245h | NR_bands_n87_n88-Core | 53 | Nokia |  | Rel-19 | 104 |  | RP-250149 |
| 476 | 270.2 | Perf. part: Introduction of NR bands n87 and n88 | 280.62d | 2024-06-06 A | 2025-03-03 A | 100% |  |  |  |  | finish no earlier than 2025-03-03 | R4 | 2245h | 2245h | NR_bands_n87_n88-Perf | 53 | Nokia |  | Rel-19 | 104 |  | RP-250149 |
| 477 | 271 | **Introduction of NR band n68** | 196.75d | 2024-06-06 A | 2024-12-12 | 100% |  |  | 2025-03-03 |  |  | R4 | 5578h | 5578h | NR_band_n68 | 53 | Ericsson |  | Rel-19 | 104 |  |  |
| 478 | 271.1 | Core part: Introduction of NR band n68 | 280.62d | 2024-06-06 A | 2025-03-03 A | 100% |  |  |  |  | finish no earlier than 2025-03-03 | R4 | 2245h | 2245h | NR_band_n68-Core | 53 | Ericsson |  | Rel-19 | 104 |  | RP-250525 |
| 479 | 271.2 | Perf. part: Introduction of NR band n68 | 280.62d | 2024-06-06 A | 2025-03-03 A | 100% |  |  |  |  | finish no earlier than 2025-03-03 | R4 | 2245h | 2245h | NR_band_n68-Perf | 53 | Ericsson |  | Rel-19 | 104 |  | RP-250525 |
| 480 | 272 | **Additional NR bands for NR features in Rel-19** | 99.5d | 2024-06-06 A | 2024-09-09 | 87% | 13.07d |  |  |  |  | R4 | 5927h | 4693h | NR_bands_xFeature_R19 | 53 | ZTE |  | Rel-19 | 104 |  |  |
| 481 | 272.1 | Core part: Additional NR bands for NR features in Rel-19 | 574.62d | 2024-06-06 A | 2025-12-12 A | 100% |  |  |  |  | finish no earlier than 2025-12-12 | R4 | 4597h | 4597h | NR_bands_xFeature_R19-Core | 53 | ZTE |  | Rel-19 | 104 |  | RP-253208 |
| 482 | 272.2 | UE Conformance - Additional NR bands for NR features in Rel-19 | 98.25d | 2025-09-09 A | 2025-12-12 | 10% | 88.42d |  |  | 37828.2d | finish no earlier than 2025-12-12 | R5 | 786h |  | NR_bands_xFeature_R19-UEConTest | 55 | ZTE |  | Rel-19 | 109 |  | RP-253056 |

Notes:
- 457: ; 13/6/24: FCD:12/12/2024->/24; 13/6/24: 0%->100 / Impacted TSs and TRs: 23.304; 23.501
- 458: ; 13/6/24: FCD:12/12/2024->/24; 13/6/24: 0%->100 / Impacted TSs and TRs: 23.304; 23.501
- 459: Impacted TSs and TRs: 23.122, 24.501, 24.554, 24.555, 29.525, 23.003
- 464: Impacted TSs and TRs: 24.558, 24.559, 24.549, 29.116, 29.122, 29.222, 29.255, 29.257, 29.343, 29.435, 29.486, 29.522, 29.538, 29.548, 29.549, 29.558, 29.583
- 468: 3/4/25: WID:RP-243323->RP-250373; rapporteur: T-Mobile => China Telecom; 18/7/25: WID:RP-250373->RP-251453
- 469: 6/3/25: FCD:07/09/2025->09/09/2025; Compl:0%->10%; Stat Rep: ->RP-250374; ; 6/6/25: Compl:10%->55%; Stat Rep: RP-250374->RP-251454; ; 11/9/25: Compl:55%->100%; Stat Rep: RP-251454->RP-252543;
- 470: 6/3/25: FCD:07/09/2025->03/03/2026; Stat Rep: ->RP-250374; ; 6/6/25: Compl:0%->20%; Stat Rep: RP-250374->RP-251454; ; 11/9/25: Compl:20%->80%; Stat Rep: RP-251454->RP-252543; ; 3/12/25: FCD:Tue 03/03/26->Fri 12/12/25; Compl:80%->100%; Stat Rep: RP-252543-; 7/1/26: WID:RP-251453->RP-253461
- 471: 26/9/24: WID:RP-241648->RP-242120; 3/4/25: WID:RP-242120->RP-250760
- 472: 4/9/24: FCD:12/12/2024->24/12/2024; Compl:0%->40%; Stat Rep: ->RP-242117; ; 6/12/24: FCD:12/12/2024->03/03/2025; Compl:40%->99%; WID: RP-242120->RP-241648; Stat Rep: RP-242117->RP-242494; ; 6/3/25: FCD:09/12/2024->03/03/2025; Compl:99%->100%; Stat Rep: RP-242494->RP-250403;
- 473: 4/9/24: FCD:03/03/2025->24/12/2024; Compl:0%->40%; Stat Rep: ->RP-242117; ; 6/12/24: FCD:12/12/2024->03/03/2025; Compl:40%->99%; WID: RP-242120->RP-241648; Stat Rep: RP-242117->RP-242494; ; 6/3/25: FCD:09/12/2024->03/03/2025; Compl:99%->100%; Stat Rep: RP-242494->RP-250403;
- 474: 26/9/24: WID:RP-241663->RP-242338; 24/1/25: WID:RP-242338->RP-242501
- 475: 4/9/24: FCD:12/12/2024->24/12/2024; Compl:0%->33%; Stat Rep: ->RP-241816; ; 6/12/24: FCD:12/12/2024->03/03/2025; Compl:33%->66%; Stat Rep: RP-241816->RP-242500; ; 6/3/25: FCD:09/12/2024->03/03/2025; Compl:66%->100%; Stat Rep: RP-242500->RP-250149;
- 476: 4/9/24: FCD:03/03/2025->25/03/2025; Compl:0%->33%; Stat Rep: ->RP-241816; ; 6/12/24: Compl:33%->66%; Stat Rep: RP-241816->RP-242500; ; 6/3/25: FCD:09/12/2024->03/03/2025; Compl:66%->100%; Stat Rep: RP-242500->RP-250149;
- 477: 24/1/25: WID:RP-241664->RP-242606; 3/4/25: WID:RP-242606->RP-250763
- 478: 4/9/24: FCD:12/12/2024->24/12/2024; Compl:0%->25%; WID: RP-241664->RP-231664; Stat Rep: ->RP-241861; ; 6/12/24: FCD:12/12/2024->03/03/2025; Compl:25%->60%; WID: RP-231664->RP-241664; Stat Rep: RP-241861->RP-242605; ; 6/3/25: FCD:09/12/2024->03/03/2025; Compl:60%->100%; Stat Rep: RP-242605->RP-250525;
- 479: 4/9/24: FCD:12/12/2024->24/12/2024; Compl:0%->25%; WID: RP-241664->RP-231664; Stat Rep: ->RP-241861; ; 6/12/24: FCD:12/12/2024->03/03/2025; Compl:25%->60%; WID: RP-231664->RP-241664; Stat Rep: RP-241861->RP-242605; ; 6/3/25: FCD:09/12/2024->03/03/2025; Compl:60%->100%; Stat Rep: RP-242605->RP-250525;
- 480: 26/9/24: WID:RP-241677->RP-241922; 24/1/25: WID:RP-241922->RP-242572; 3/4/25: WID:RP-242572->RP-250211; 18/7/25: WID:RP-250211->RP-251250; 29/9/25: WID:RP-251250->RP-252463
- 481: 4/9/24: FCD:09/09/2025->25/09/2024; Compl:0%->15%; Stat Rep: ->RP-241923; ; 6/12/24: FCD:09/09/2024->09/09/2025; Compl:15%->35%; Stat Rep: RP-241923->RP-242573; ; 6/3/25: FCD:19/04/2025->09/09/2025; Compl:35%->50%; Stat Rep: RP-242573->RP-250212; ; 6/6/2; 7/1/26: WID:RP-252463->RP-253207
- 482: tested: basket REL-19 WI NR_bands_xFeature_R19 which got exception in RP-252462 to complete by Dec.25; dependency to REL-18 WI NR_ENDC_RF_FR1_enh2-UEConTest ; 3/12/25: FCD:Sat 12/12/26->Fri 12/12/25; Compl:0%->10%; Stat Rep: ->RP-253056; ; 7/1/26: WID:RP-252139->RP-253057

| ID | WBS | Task | Duration | Start | Finish | Complete | Remaining | Actual finish | Total slack | Constraint | Resources | Work | Actual work | Acronym | PCG approved | WI rapporteur name | Release | TSG approved | Status Report | Impacted TSs and TRs | WI rapporteur e-mail |
| --- | --- | --- | --- | --- | --- | --- | --- | --- | --- | --- | --- | --- | --- | --- | --- | --- | --- | --- | --- | --- | --- |
| 483 | 273 | **Rel-19 NR CA/DC for x bands DL with y bands UL (x<7, y<3) and SUL/CA band combinations with a single SUL or two SUL cells** | 99.5d | 2024-06-06 A | 2024-09-09 | 100% |  | 2025-12-12 |  |  | R4 | 5141h | 5141h | NR_CADC_SUL_R19 | 53 | Ericsson | Rel-19 | 104 |  |  |  |
| 484 | 273.1 | Core part: Rel-19 NR Carrier Aggregation (CA)/Dual Connectivity (DC) for x bands DL with y bands UL (x<7, y<3) and Supplementary Uplink (SUL) band combinations/CA band combinations with a single SUL or two SUL cells | 574.62d | 2024-06-06 A | 2025-12-12 A | 100% |  |  |  | finish no earlier than 2025-12-12 | R4 | 4597h | 4597h | NR_CADC_SUL_R19-Core | 53 | Ericsson | Rel-19 | 104 | RP-253400 |  |  |
| 485 | 274 | **Multi-carrier enhancements for NR Phase 3** | 658.38d | 2024-09-09 A | 2026-06-06 | 67% | 214.63d |  | 37646d |  |  | 4497h | 3031h | NR_MC_enh2 | 53 | Lenovo | Rel-19 | 105 |  |  |  |
| 486 | 274.1 | Core part: Multi-carrier enhancements for NR Phase 3 | 378.88d | 2024-09-09 A | 2025-09-09 A | 100% |  |  |  | finish no earlier than 2025-09-09 | R1 | 3031h | 3031h | NR_MC_enh2-Core | 53 | Lenovo | Rel-19 | 105 | RP-252563 |  |  |
| 487 | 274.2 | UE Conformance - Multi-carrier enhancements for NR Phase 3 | 183.25d | 2025-12-12 | 2026-06-06 |  |  |  | 37646d | finish no earlier than 2026-06-06 | R5 | 1466h |  | NR_MC_enh2-UEConTest |  | Motorola Mobility | Rel-19 |  |  |  |  |
| 488 | 275 | Rel-19 Radio: NR-only, topics other than band | 1d | 2019-03-07 | 2019-03-07 |  |  |  | 40387.9d |  |  |  |  |  |  |  | Rel-19 |  |  |  |  |
| 489 | 276 | UE Conformance - New Rel-19 NR licensed bands and extension of existing NR bands | 754.88d | 2025-06-06 A | 2027-06-04 | 24% | 573.71d |  | 37270.1d | finish no earlier than 2027-06-04 | R5 | 6039h |  | NR_lic_bands_BW_R19-UEConTest | 55 | Huawei | Rel-19 | 108 | RP-253434 |  |  |
| 490 | 277 | **Low band carrier aggregation via switching** | 376d | 2025-03-06 A | 2026-03-03 | 67% | 124.01d |  | 37744.2d |  |  | 4560h | 1552h | NR_LBCA_Sw | 54 | Telus | Rel-19 | 106 |  |  |  |
| 491 | 277.1 | Core part: Low band carrier aggregation via switching | 194d | 2025-03-06 A | 2025-09-09 A | 100% |  |  |  | finish no earlier than 2025-09-09 | R4 | 1552h | 1552h | NR_LBCA_Sw-Core | 54 | Telus | Rel-19 | 106 | RP-252695 | 38.768 |  |
| 492 | 277.2 | Perf. part: Low band carrier aggregation via switching | 376d | 2025-03-06 A | 2026-03-03 | 50% | 188d |  | 37744.2d | start no earlier than 2025-03-06 | R4 | 3008h |  | NR_LBCA_Sw-Perf | 54 | Telus | Rel-19 | 106 | RP-253326 |  |  |
| 493 | 278 | **mmWave in NR: UE spurious emissions and EESS (Earth Exploration Satellite Service) protection** | 657.38d | 2024-09-09 A | 2026-06-05 | 99% | 5.28d |  | 37647d |  |  | 7510h | 4486h | NR_mmWave_protect | 53 | China Unicom | Rel-19 | 105 |  |  |  |
| 494 | 278.1 | Core part: mmWave in NR: UE spurious emissions and EESS (Earth Exploration Satellite Service) protection | 280.38d | 2024-09-09 A | 2025-06-06 A | 100% |  |  |  | finish no earlier than 2025-06-06 | R4 | 2243h | 2243h | NR_mmWave_protect-Core | 53 | China Unicom | Rel-19 | 105 | RP-251593 |  |  |
| 495 | 278.2 | Perf. part: mmWave in NR: UE spurious emissions and EESS (Earth Exploration Satellite Service) protection | 280.38d | 2024-09-09 A | 2025-06-06 A | 100% |  |  |  | finish no earlier than 2025-06-06 | R4 | 2243h | 2243h | NR_mmWave_protect-Perf | 53 | China Unicom | Rel-19 | 105 | RP-251593 |  |  |
| 496 | 278.3 | UE Conformance - mmWave in NR UE spurious emissions and EESS (Earth Exploration Satellite Service) protection | 378d | 2025-06-06 A | 2026-06-05 | 98% | 7.56d |  | 37647d | finish no earlier than 2026-06-05 | R5 | 3024h |  | NR_mmWave_protect-UEConTest | 55 | China Unicom | Rel-19 | 108 | RP-253155 |  |  |
| 497 | 279 | Study on spatial channel model for demodulation performance requirements for NR | 477.38d | 2024-06-06 A | 2025-09-09 A | 100% |  |  |  | finish no earlier than 2025-09-09 | R4 | 3819h | 3819h | FS_NR_demod_SCM | 53 | Nokia | Rel-19 | 104 | RP-252355 | 38.753 |  |
| 498 | 280 | Study on NR FR1 DL fragmented carriers | 378.88d | 2024-06-06 A | 2025-06-06 A | 100% |  |  |  | finish no earlier than 2025-06-06 | R4 | 3031h | 3031h | FS_NR_FR1_DL_Frag_Carrier | 53 | Mediatek | Rel-19 | 104 | RP-251287 | 38,755 |  |
| 499 | 281 | Study on channel modelling enhancements for 7-24GHz for NR | 560.88d | 2023-12-13 A | 2025-06-06 A | 100% |  |  |  | finish no earlier than 2025-06-06 | R1 | 4487h | 4487h | FS_NR_7_24GHz_CHmod | 52 | LEE Daewon, Intel Corporation | Rel-19 | 102 | RP-251240 |  | daewon.lee@intel.com |
| 500 | 282 | **Additional topological enhancements for NR** | 378.88d | 2024-09-09 A | 2025-09-09 A | 100% |  |  |  |  |  | 3031h | 3031h | NR_WAB_5GFemto | 53 | NTT DOCOMO | Rel-19 | 105 |  |  |  |
| 501 | 282.1 | Core part: Additional topological enhancements for NR | 378.88d | 2024-09-09 A | 2025-09-09 A | 100% |  |  |  | finish no earlier than 2025-09-09 | R3 | 3031h | 3031h | NR_WAB_5GFemto-Core | 53 | NTT DOCOMO | Rel-19 | 105 | RP-252481 |  |  |
| 502 | 283 | Study on additional topological enhancements for NR | 262d | 2024-09-09 A | 2025-09-09 A | 100% |  |  |  |  | R3 | 2096h | 2096h | FS_NR_WAB_5GFemto | 52 | Min, Tianyang, NTT DOCOMO | Rel-19 | 102 | RP-241963 | 38.799 | tianyang.min.ex@nttdocomo.com |
| 503 | 284 | **NR Sidelink: Intra-band Carrier Aggregation in ITS band** | 197.62d | 2024-03-03 A | 2024-09-09 | 100% |  | 2025-06-06 |  |  |  | 3816h | 3816h | NR_SL_intraB_CA_ITS | 52 | OPPO | Rel-19 | 103 |  |  |  |
| 504 | 284.1 | Core part: NR Sidelink: Intra-band Carrier Aggregation in ITS band | 477d | 2024-03-03 A | 2025-06-06 A | 100% |  |  |  | finish no earlier than 2025-06-06 | R4 | 3816h | 3816h | NR_SL_intraB_CA_ITS-Core | 52 | OPPO | Rel-19 | 103 | RP-250996 | 38,787 |  |
| 505 | 285 | **NR sidelink multi-hop relay** | 99.5d | 2024-06-06 A | 2024-09-09 | 100% |  | 2025-09-09 |  |  |  | 3819h | 3819h | NR_SL_relay_multihop | 53 | LG Electronics | Rel-19 | 104 |  |  |  |
| 506 | 285.1 | Core part: NR sidelink multi-hop relay | 477.38d | 2024-06-06 A | 2025-09-09 A | 100% |  |  |  | finish no earlier than 2025-09-09 | R2 | 3819h | 3819h | NR_SL_relay_multihop-Core | 53 | LG Electronics | Rel-19 | 104 | RP-251941 |  |  |

Notes:
- 483: 26/9/24: WID:RP-241674->RP-241833; 3/4/25: WID:RP-241833->RP-250214; 18/7/25: WID:RP-250214->RP-251806; 29/9/25: WID:RP-251806->RP-252440; 7/1/26: WID:RP-252440->RP-253401
- 484: 4/9/24: FCD:09/09/2025->25/09/2024; Compl:0%->20%; Stat Rep: ->RP-241832; ; 6/12/24: FCD:09/09/2024->09/09/2025; Compl:20%->34%; Stat Rep: RP-241832->RP-242753; ; 6/3/25: FCD:19/04/2025->09/09/2025; Compl:34%->35%; WID: RP-241833->RP-242754; Stat Rep: RP; 3/12/25: Compl:88%->100%; Stat Rep: RP-252439->RP-253400;
- 485: 24/1/25: WID:RP-242408->RP-242904; 29/9/25: WID:RP-242904->RP-252564
- 486: 6/12/24: FCD:09/09/2025->06/06/2025; Compl:0%->40%; Stat Rep: ->RP-242903; ; 6/3/25: FCD:16/03/2025->09/09/2025; Compl:40%->80%; Stat Rep: RP-242903->RP-250413; ; 6/6/25: Compl:80%->90%; Stat Rep: RP-250413->RP-251421; ; 11/9/25: Compl:90%->100%; Stat Rep: RP-251421->RP-252563; / Name changed from "Phase 2" to "Phase 3" (but acronym stayed as "_enh2"
- 489: tested: REL-19 WIs NR_FDD_1400MHz, NR_bands_n87_n88, NR_band_n68, NR_NTN_Sband, NR_NTN_combinedLband, NR_NTN_Ku_bands, NR_bands_CA_ENDC_R19_BWs, NR_FR1_7MHz_BW; compare NR_lic_bands_BW_R18-UEConTest; ; 11/9/25: FCD:Sun 06/06/27->Thu 03/06/27; Compl:0%->10; 7/1/26: WID:RP-252651->RP-253435
- 490: 3/4/25: WID:RP-243317->RP-250247; 18/7/25: WID:RP-250247->RP-251315; AT&T => Telus; 29/9/25: WID:RP-251315->RP-252694
- 491: 6/3/25: Compl:0%->10%; Stat Rep: ->RP-250246; ; 26/3/25: 38.768 added;; 6/6/25: Compl:10%->60%; Stat Rep: RP-250246->RP-251316; List of Impacted TS & TR updated; ; 11/9/25: Compl:60%->100%; Stat Rep: RP-251316->RP-252695; List of Impacted TS & TR updated;
- 492: 6/3/25: Stat Rep: ->RP-250246; ; 6/6/25: Stat Rep: RP-250246->RP-251316; ; 11/9/25: Stat Rep: RP-251316->RP-252695; ; 3/12/25: Compl:0%->50%; Stat Rep: RP-252695->RP-253326;
- 493: 24/1/25: WID:RP-242371->RP-242611; 3/4/25: WID:RP-242611->RP-250818; 18/7/25: WID:RP-250818->RP-251811
- 494: 6/12/24: Compl:0%->40%; Stat Rep: ->RP-242612; ; 6/3/25: FCD:16/03/2025->06/06/2025; Compl:40%->80%; Stat Rep: RP-242612->RP-250429; ; 6/6/25: Compl:80%->100%; Stat Rep: RP-250429->RP-251593;
- 495: 6/12/24: Compl:0%->40%; Stat Rep: ->RP-242612; ; 6/3/25: FCD:16/03/2025->06/06/2025; Compl:40%->80%; Stat Rep: RP-242612->RP-250429; ; 6/6/25: Compl:80%->100%; Stat Rep: RP-250429->RP-251593;
- 496: tested: REL-19 WI NR_mmWave_protect ; 11/9/25: Compl:0%->22%; Stat Rep: ->RP-251981; ; 3/12/25: FCD:Sat 06/06/26->Fri 05/06/26; Compl:22%->98%; WID: RP-251514->RP-250062; Stat Rep: RP-251981->RP-253155;
- 497: 4/9/24: FCD:06/06/2025->25/06/2025; Compl:0%->15%; Stat Rep: ->RP-241844; ; 26/9/24: WID:RP-241610->RP-241848; 26/9/24: 38.753 added;; 6/12/24: Compl:15%->40%; WID: RP-241848->RP-241610; Stat Rep: RP-241844->RP-242465; ; 6/3/25: FCD:14/02/2025->06/06/202; 11/9/25: Compl:70%->100%; Stat Rep: RP-251258->RP-252355; List of Impacted TS & TR updated;
- 498: 4/9/24: FCD:06/06/2025->25/06/2025; Compl:0%->5%; Stat Rep: ->RP-242054; ; 26/9/24: WID:RP-241669->RP-242404; 26/9/24: 38.755 added;; 6/12/24: Compl:5%->25%; Stat Rep: RP-242054->RP-243001; ; 24/1/25: WID:RP-242404->RP-243002; 6/3/25: FCD:14/02/2025->06/; 6/6/25: Compl:35%->100%; Stat Rep: RP-250469->RP-251287; List of Impacted TS & TR updated;
- 499: 14/3/24: Stat Rep: ->RP-240265; Rapporteur: Intel->LEE Daewon, Intel Corporation; Rap eMail: ->daewon.lee@intel.com; ; 13/6/24: Compl:0%->15%; Stat Rep: RP-240265->RP-241099; ; 4/9/24: FCD:06/06/2025->25/06/2025; Compl:15%->35%; Stat Rep: RP-241099->RP-24; 6/6/25: Compl:75%->100%; Stat Rep: RP-250066->RP-251240;
- 500: 24/1/25: WID:RP-242395->RP-243009; 29/9/25: WID:RP-243009->RP-252479
- 501: 6/12/24: Compl:0%->30%; Stat Rep: ->RP-243006; ; 6/3/25: FCD:20/05/2025->09/09/2025; Compl:30%->60%; Stat Rep: RP-243006->RP-250357; ; 6/6/25: Compl:60%->85%; Stat Rep: RP-250357->RP-251410; ; 11/9/25: Compl:85%->100%; Stat Rep: RP-251410->RP-252481;
- 502: 14/3/24: FCD:28/05/2021->09/09/2024; Stat Rep: ->RP-240320; Rapporteur: NTT DOCOMO->Min, Tianyang, NTT DOCOMO; Rap eMail: ->tianyang.min.ex@nttdocomo.com; ; 2/4/24: WID:RP-234041->RP-240319; 3/4/24: 38.799 added;; 13/6/24: Compl:0%->70%; Stat Rep: RP-2...; 26/9/24: 0%->100
- 503: 18/7/25: WID:RP-240840->RP-250997
- 504: 14/5/24: 38.787 added;; 13/6/24: Compl:0%->15%; Stat Rep: ->RP-241152; ; 4/9/24: FCD:09/09/2025->25/09/2024; Compl:15%->25%; Stat Rep: RP-241152->RP-241843; ; 6/12/24: FCD:09/09/2024->04/03/2024; Compl:25%->0%; Stat Rep: RP-241843->RP-242789; ; 6/3/25: FC; 6/6/25: FCD:Tue 09/09/25->Fri 06/06/25; Compl:90%->100%; Stat Rep: RP-250166->RP-250996; List of Impacted TS & TR updated;
- 505: 26/9/24: WID:RP-241609->RP-242349; 3/4/25: WID:RP-242349->RP-250188
- 506: 4/9/24: FCD:09/09/2025->25/09/2024; Compl:0%->15%; Stat Rep: ->RP-241750; ; 6/12/24: FCD:09/09/2024->09/09/2025; Compl:15%->40%; Stat Rep: RP-241750->RP-242529; ; 6/3/25: FCD:19/04/2025->09/09/2025; Compl:40%->60%; Stat Rep: RP-242529->RP-250187; ; 6/6/2; 11/9/25: Compl:85%->100%; Stat Rep: RP-250969->RP-251941;

| ID | WBS | Task | Duration | Start | Finish | Complete | Remaining | Actual finish | Total slack | Constraint | Resources | Work | Actual work | Acronym | PCG approved | WI rapporteur name | Release | TSG approved | WI rapporteur e-mail | Status Report | Impacted TSs and TRs |
| --- | --- | --- | --- | --- | --- | --- | --- | --- | --- | --- | --- | --- | --- | --- | --- | --- | --- | --- | --- | --- | --- |
| 507 | 286 | **NR MIMO Phase 5** | 462.62d | 2023-12-13 A | 2025-03-03 | 91% | 43.38d |  |  |  |  | 9931h | 5275h | NR_MIMO_Ph5 | 52 | Samsung | Rel-19 | 102 |  |  |  |
| 508 | 286.1 | Core part: NR MIMO Phase 5 | 659.38d | 2023-12-13 A | 2025-09-09 A | 100% |  |  |  | finish no earlier than 2025-09-09 | R1 | 5275h | 5275h | NR_MIMO_Ph5-Core | 52 | Eko Onggosanusi, Samsung | Rel-19 | 102 | eko.o@samsung.com | RP-252065 |  |
| 509 | 286.2 | Perf. part: NR MIMO Phase 5 | 582d | 2024-08-18 A | 2026-03-03 | 80% | 116.4d |  | 37744.2d | finish no earlier than 2026-03-03 | R4 | 4656h |  | NR_MIMO_Ph5-Perf | 52 | Eko Onggosanusi, Samsung | Rel-19 | 102 | eko.o@samsung.com | RP-253311 |  |
| 510 | 287 | **Evolution of NR duplex operation: Sub-band full duplex (SBFD)** | 462.62d | 2023-12-13 A | 2025-03-03 | 66% | 158.05d |  |  |  |  | 12963h | 5275h | NR_duplex_evo | 52 | Huawei | Rel-19 | 102 |  |  |  |
| 511 | 287.1 | Core part: Evolution of NR duplex operation: Sub-band full duplex (SBFD) | 659.38d | 2023-12-13 A | 2025-09-09 A | 100% |  |  |  | finish no earlier than 2025-09-09 | R1 | 5275h | 5275h | NR_duplex_evo-Core | 52 | Xinghua Song, He (Jackson) Wang, Huawei, Samsung | Rel-19 | 102 | songxinghua@huawei.com, h0809.wang@samsung.com | RP-252364 |  |
| 512 | 287.2 | Perf. part: Evolution of NR duplex operation: Sub-band full duplex (SBFD) | 582d | 2024-08-18 A | 2026-03-03 | 70% | 174.6d |  | 37744.2d | finish no earlier than 2026-03-03 | R4 | 4656h |  | NR_duplex_evo-Perf | 52 | Xinghua Song, He (Jackson) Wang, Huawei, Samsung | Rel-19 | 102 | songxinghua@huawei.com, h0809.wang@samsung.com | RP-253503 |  |
| 513 | 287.3 | UE Conformance - Evolution of NR duplex operation: Sub-band full duplex (SBFD) | 379d | 2025-12-12 | 2026-12-12 |  |  |  | 37450.2d | finish no earlier than 2026-12-12 | R5 | 3032h |  | NR_duplex_evo-UEConTest |  | Huawei | Rel-19 |  |  |  |  |
| 514 | 288 | **NR mobility enhancements Phase 4** | 462.62d | 2023-12-13 A | 2025-03-03 | 85% | 68.22d |  |  |  |  | 12630h | 7974h | NR_Mob_Ph4 | 52 | Apple | Rel-19 | 102 |  |  |  |
| 515 | 288.1 | Core part: NR mobility enhancements Phase 4 | 659.38d | 2023-12-13 A | 2025-09-09 A | 100% |  |  |  | finish no earlier than 2025-09-09 | R2 | 5275h | 5275h | NR_Mob_Ph4-Core | 52 | Naveen Palle, Apple Inc. | Rel-19 | 102 | naveen.palle@apple.com | RP-252108 |  |
| 516 | 288.2 | Perf. part: NR mobility enhancements Phase 4 | 582d | 2024-08-18 A | 2026-03-03 | 60% | 232.8d |  | 37744.2d | finish no earlier than 2026-03-03 | R4 | 4656h |  | NR_Mob_Ph4-Perf | 52 | Naveen Palle, Apple Inc. | Rel-19 | 102 | naveen.palle@apple.com | RP-253622 |  |
| 517 | 288.3 | Security aspects of NR mobility enhancement Phase 4 | 337.38d | 2024-07-16 A | 2025-06-06 A | 100% |  |  |  | finish no earlier than 2025-06-06 | S3 | 2699h | 2699h | NR_Mob_Ph4_Sec | 53 | Rajavelsamy R | Rel-19 | 104 | rajvel@samsung.com |  | 33.501 |
| 518 | 289 | **Data collection for SON (Self-Organising Networks)/MDT (Minimization of Drive Tests) in NR standalone and MR-DC (Multi-Radio Dual Connectivity) Phase 4** | 281.5d | 2023-12-13 A | 2024-09-09 | 100% |  | 2025-09-09 |  |  |  | 5275h | 5275h | NR_ENDC_SON_MDT_Ph4 | 52 | China Unicom | Rel-19 | 102 |  |  |  |
| 519 | 289.1 | Core part: Data collection for SON (Self-Organising Networks)/MDT (Minimization of Drive Tests) in NR standalone and MR-DC (Multi-Radio Dual Connectivity) Phase 4 | 659.38d | 2023-12-13 A | 2025-09-09 A | 100% |  |  |  | finish no earlier than 2025-09-09 | R3 | 5275h | 5275h | NR_ENDC_SON_MDT_Ph4-Core | 52 | Xufei Dong, China Unicom | Rel-19 | 102 | dongxf37@chinaunicom.cn | RP-252558 |  |
| 520 | 290 | Study on 6 GHz for LTE and NR | 1624d? | 2017-12-15 A | 2024-03-03 A | 100% |  |  |  | finish no earlier than 2024-03-03 | RP | 12992h | 12992h | FS_6GHz_LTE_NR | 40 | Dominique Everaere, Ericsson | Rel-19 | 78 | dominique.everaere@ericsson.com | RP-231702 | 37.890; 37.107 |
| 521 | 291 | Study on NR FR2 OTA (Over the Air) testing Phase 3 | 575.5d | 2024-03-03 A | 2025-09-09 A | 100% |  |  |  | finish no earlier than 2025-09-09 | R4 | 4604h | 4604h | FS_NR_FR2_OTA_Ph3 | 52 | Qualcomm | Rel-19 | 103 |  | RP-252375 | 38.771 |
| 522 | 292 | Study on IMT parameters for NR for 4400 to 4800 MHz, 7125 to 8400 MHz and 14800 to 15350 MHz | 2266.62d | 2019-03-07 A | 2025-03-03 A | 100% |  |  |  | finish no earlier than 2025-03-03 | R4 | 18133h | 18133h | FS_NR_IMT_4400_7125_14800MHz | 52 | Ericsson | Rel-19 | 103 |  | RP-250538 | 38.922 |
| 523 | 293 | **NR base station (BS) RF requirement evolution for FR1/FR2 and testing** | 378.75d | 2024-03-03 A | 2025-03-03 | 95% | 20.05d |  |  |  |  | 11436h | 5382h | NR_BS_RF_req_evo | 52 | ZTE | Rel-19 | 103 |  |  |  |
| 524 | 293.1 | Core part: NR base station (BS) RF requirement evolution for FR1/FR2 and testing | 672.75d | 2024-03-03 A | 2025-12-12 A | 100% |  |  |  | finish no earlier than 2025-12-12 | R4 | 5382h | 5382h | NR_BS_RF_req_evo-Core | 52 | ZTE | Rel-19 | 103 |  | RP-253516 | 38.908 |
| 525 | 293.2 | Perf. part: NR base station (BS) RF requirement evolution for FR1/FR2 and testing | 756.75d | 2024-03-03 A | 2026-03-03 | 90% | 75.67d |  | 37744.2d | finish no earlier than 2026-03-03 | R4 | 6054h |  | NR_BS_RF_req_evo-Perf | 52 | ZTE | Rel-19 | 103 |  | RP-253516 |  |
| 526 | 294 | **NR Radio Resource Management (RRM) Phase 5** | 378.75d | 2024-03-03 A | 2025-03-03 | 90% | 36.1d |  |  |  |  | 8796h | 4604h | NR_RRM_Ph5 | 52 | Apple | Rel-19 | 103 |  |  |  |
| 527 | 294.1 | Core part: NR Radio Resource Management (RRM) Phase 5 | 575.5d | 2024-03-03 A | 2025-09-09 A | 100% |  |  |  | finish no earlier than 2025-09-09 | R4 | 4604h | 4604h | NR_RRM_Ph5-Core | 52 | Apple | Rel-19 | 103 |  | RP-252493 |  |
| 528 | 294.2 | Perf. part: NR Radio Resource Management (RRM) Phase 5 | 524d | 2024-10-13 A | 2026-03-03 | 80% | 104.8d |  | 37744.2d | finish no earlier than 2026-03-03 | R4 | 4192h |  | NR_RRM_Ph5-Perf | 52 | Apple | Rel-19 | 103 |  | RP-253438 |  |
| 529 | 295 | **NR demodulation performance Phase 5** | 197.62d | 2024-03-03 A | 2024-09-09 | 55% | 88.09d |  |  |  |  | 8307h | 4604h | NR_demod_Ph5 | 52 | China Telecom | Rel-19 | 103 |  |  |  |
| 530 | 295.1 | Perf. part: NR demodulation performance Phase 5 | 575.5d | 2024-03-03 A | 2025-09-09 A | 100% |  |  |  | finish no earlier than 2025-09-09 | R4 | 4604h | 4604h | NR_demod_Ph5-Perf | 52 | China Telecom | Rel-19 | 103 |  | RP-252537 |  |
| 531 | 295.2 | UE Conformance - NR demodulation performance: Phase 5 | 462.88d | 2025-12-12 | 2027-03-03 |  |  |  | 37366.4d | finish no earlier than 2027-03-03 | R5 | 3703h |  | NR_demod_Ph5-UEConTest |  | China Telecom | Rel-19 |  |  |  |  |

Notes:
- 507: 2/4/24: WID:RP-234007->RP-240087; 26/9/24: WID:RP-240087->RP-242394
- 508: 14/3/24: Compl:0%->15%; Stat Rep: ->RP-240086; Rapporteur: Samsung->Eko Onggosanusi, Samsung; Rap eMail: ->eko.o@samsung.com; ; 13/6/24: Compl:15%->35%; WID: RP-240087->RP-234007; Stat Rep: RP-240086->RP-241051; ; 4/9/24: FCD:09/09/2025->25/09/2024; Compl; 11/9/25: Compl:95%->100%; Stat Rep: RP-251014->RP-252065;
- 509: 14/3/24: Stat Rep: ->RP-240086; Rapporteur: Samsung->Eko Onggosanusi, Samsung; Rap eMail: ->eko.o@samsung.com; ; 13/6/24: WID: RP-240087->RP-234007; Stat Rep: RP-240086->RP-241051; ; 4/9/24: FCD:03/03/2026->26/03/2025; WID: RP-234007->RP-240087; Stat Rep:; 3/12/25: Compl:40%->80%; Stat Rep: RP-252065->RP-253311;
- 510: 2/4/24: WID:RP-234035->RP-240789; 23/7/24: WID:RP-240789->RP-241614; 18/7/25: WID:RP-241614->RP-251874
- 511: 14/3/24: Compl:0%->7%; Stat Rep: ->RP-240171; Rapporteur: Huawei->Xinghua Song, He (Jackson) Wang, Huawei, Samsung; Rap eMail: ->songxinghua@huawei.com, h0809.wang@samsung.com; ; 13/6/24: Compl:7%->18%; Stat Rep: RP-240171->RP-241286; ; 4/9/24: FCD:09/09/; 11/9/25: Compl:93%->100%; Stat Rep: RP-251644->RP-252364;
- 512: 14/3/24: Stat Rep: ->RP-240171; Rapporteur: Huawei->Xinghua Song, He (Jackson) Wang, Huawei, Samsung; Rap eMail: ->songxinghua@huawei.com, h0809.wang@samsung.com; ; 13/6/24: Stat Rep: RP-240171->RP-241286; ; 4/9/24: FCD:03/03/2026->26/03/2025; Stat Rep: R; 3/12/25: Compl:25%->70%; Stat Rep: RP-252364->RP-253503;
- 514: 2/4/24: WID:RP-234036->RP-240299; 23/7/24: WID:RP-240299->RP-241515; 26/9/24: WID:RP-241515->RP-242356; 3/4/25: WID:RP-242356->RP-250339; 29/9/25: WID:RP-250339->RP-252111
- 515: 14/3/24: Stat Rep: ->RP-240298; Rapporteur: Apple->Naveen Palle, Apple Inc.; Rap eMail: ->naveen.palle@apple.com; ; 13/6/24: Compl:0%->5%; Stat Rep: RP-240298->RP-241514; ; 4/9/24: FCD:09/09/2025->25/09/2024; Compl:5%->20%; Stat Rep: RP-241514->RP-241915;; 11/9/25: Compl:91%->100%; Stat Rep: RP-251187->RP-252108;
- 516: 14/3/24: Stat Rep: ->RP-240298; Rapporteur: Apple->Naveen Palle, Apple Inc.; Rap eMail: ->naveen.palle@apple.com; ; 13/6/24: Stat Rep: RP-240298->RP-241514; ; 4/9/24: FCD:03/03/2026->26/03/2025; Stat Rep: RP-241514->RP-241915; ; 6/12/24: FCD:03/03/2025->0; 3/12/25: Compl:10%->60%; Stat Rep: RP-252108->RP-253622;
- 517: ; 6/3/25: 0%->70; 6/3/25: FCD:03/03/2025->/25; 5/6/25: 70%->100; 5/6/25: FCD:Thu 27/02/->/25
- 518: 29/9/25: WID:RP-234038->RP-252557
- 519: 14/3/24: Stat Rep: ->RP-240118; Rapporteur: China Unicom->Xufei Dong, China Unicom; Rap eMail: ->dongxf37@chinaunicom.cn; ; 13/6/24: Compl:0%->15%; Stat Rep: RP-240118->RP-241081; ; 4/9/24: FCD:09/09/2025->25/09/2024; Compl:15%->30%; Stat Rep: RP-241081->; 11/9/25: Compl:85%->100%; Stat Rep: RP-251000->RP-252558;
- 520: 27/3/18: Compl:0%->25%27/3/18: WID: RP-172804->RP-180168¦27/3/18: 37.890 added;¦27/3/18: 37.107 added;¦27/6/18: Compl:25%->30%¦27/6/18: CD:Fri 15/¦26/3/19: WID:RP-181019->RP-190681; 26/6/19: WID:RP-190681->RP-190957¦01/24: Rel-18->Rel-19; 2/1/24: WID:R...; 2/4/24: 98%->100
- 521: 13/6/24: Compl:0%->30%; Stat Rep: SI ->RP-241157; ; 23/7/24: WID:RP-240856->RP-241158; 4/9/24: FCD:09/09/2025->25/09/2024; Compl:30%->70%; Stat Rep: RP-241157->RP-241845; ; 26/9/24: WID:RP-241158->RP-242400; 26/9/24: 38.771 added;; 6/12/24: FCD:09/09/2024; 11/9/25: Compl:98%->100%; Stat Rep: RP-251277->RP-252375; List of Impacted TS & TR updated;
- 522: 14/5/24: 38.922 added;; 23/7/24: WID:RP-240787->RP-241326; 4/9/24: FCD:09/03/2021->24/12/2024; Compl:0%->50%; Stat Rep: SI ->RP-241840; ; 6/12/24: FCD:12/12/2024->03/03/2025; Compl:50%->95%; Stat Rep: RP-241840->RP-242943; ; 24/1/25: WID:RP-241326->RP-242; 6/3/25: FCD:28/04/2023->03/03/2025; Compl:95%->100%; Stat Rep: RP-242943->RP-250538;
- 523: 23/7/24: WID:RP-240829->RP-241284; 26/9/24: WID:RP-241284->RP-242010; 24/1/25: WID:RP-242010->RP-243270; 29/9/25: WID:RP-243270->RP-252578; 7/1/26: WID:RP-252578->RP-253517
- 524: 13/6/24: Compl:0%->10%; Stat Rep: ->RP-241285; ; 4/9/24: FCD:09/09/2025->25/09/2024; Compl:10%->20%; Stat Rep: RP-241285->RP-242011; ; 26/9/24: 38.908 added;; 6/12/24: FCD:09/09/2024->09/09/2025; Compl:20%->30%; Stat Rep: RP-242011->RP-242831; ; 6/3/25: F; 3/12/25: Compl:85%->100%; Stat Rep: RP-252577->RP-253516;
- 525: 13/6/24: Stat Rep: ->RP-241285; ; 4/9/24: FCD:03/03/2026->26/03/2025; Compl:0%->5%; Stat Rep: RP-241285->RP-242011; ; 6/12/24: FCD:03/03/2025->03/03/2026; Compl:5%->10%; Stat Rep: RP-242011->RP-242831; ; 6/3/25: FCD:22/07/2025->03/03/2026; Compl:10%->30%;; 3/12/25: Compl:60%->90%; Stat Rep: RP-252577->RP-253516;
- 526: 26/9/24: WID:RP-240830->RP-242380; 29/9/25: WID:RP-242380->RP-252494
- 527: 13/6/24: Compl:0%->5%; Stat Rep: ->RP-241268; ; 4/9/24: FCD:09/09/2025->25/09/2024; Compl:5%->25%; Stat Rep: RP-241268->RP-241971; ; 6/12/24: FCD:09/09/2024->09/09/2025; Compl:25%->60%; Stat Rep: RP-241971->RP-242569; ; 6/3/25: FCD:23/03/2025->09/09/2025;; 11/9/25: Compl:90%->100%; Stat Rep: RP-251343->RP-252493;
- 528: 13/6/24: Stat Rep: ->RP-241268; ; 4/9/24: FCD:03/03/2026->26/03/2025; Stat Rep: RP-241268->RP-241971; ; 6/12/24: FCD:03/03/2025->03/03/2026; Stat Rep: RP-241971->RP-242569; ; 6/3/25: Stat Rep: RP-242569->RP-250320; ; 6/6/25: Compl:0%->20%; Stat Rep: RP-25; 3/12/25: Compl:40%->80%; Stat Rep: RP-252493->RP-253438;
- 529: 23/7/24: WID:RP-240831->RP-241297; 29/9/25: WID:RP-251448->RP-252538
- 530: 13/6/24: FCD:03/03/2026->09/09/2025; Stat Rep: ->RP-241296; ; 4/9/24: FCD:09/09/2025->25/09/2024; Compl:0%->14%; Stat Rep: RP-241296->RP-241996; ; 6/12/24: FCD:09/09/2024->09/09/2025; Compl:14%->43%; Stat Rep: RP-241996->RP-242855; ; 6/3/25: FCD:23/03/202; 11/9/25: Compl:86%->100%; Stat Rep: RP-251447->RP-252537;

| ID | WBS | Task | Type | Duration | Start | Finish | Complete | Remaining | Actual finish | Total slack | Constraint | Resources | Work | Actual work | Acronym | PCG approved | WI rapporteur name | Release | TSG approved | Status Report | Impacted TSs and TRs |
| --- | --- | --- | --- | --- | --- | --- | --- | --- | --- | --- | --- | --- | --- | --- | --- | --- | --- | --- | --- | --- | --- |
| 532 | 296 | **NR channel BW less than 5MHz for FR1 Phase 2** |  | 1049.62d | 2024-03-03 A | 2026-12-11 | 61% | 408.63d |  | 37451.4d |  |  | 9076.6h | 4487.6h | NR_FR1_lessthan_5MHz_BW_Ph2 | 52 | Intel | Rel-19 | 103 |  |  |
| 533 | 296.1 | Core part: NR channel BW less than 5MHz for FR1 Phase 2 |  | 228.95d | 2024-03-03 A | 2025-03-03 A | 100% |  |  |  | finish no earlier than 2025-03-03 | R4 | 1831.6h | 1831.6h | NR_FR1_lessthan_5MHz_BW_Ph2-Core | 52 | Intel | Rel-19 | 103 | RP-250462 |  |
| 534 | 296.2 | Perf. part: NR channel BW less than 5MHz for FR1 Phase 2 |  | 332d | 2024-07-21 A | 2025-06-06 A | 100% |  |  |  | finish no earlier than 2025-06-06 | R4 | 2656h | 2656h | NR_FR1_lessthan_5MHz_BW_Ph2-Perf | 52 | Intel | Rel-19 | 103 | RP-251669 |  |
| 535 | 296.3 | UE Conformance - NR channel BW less than 5MHz for FR1 Phase 2 |  | 573.62d | 2025-06-06 A | 2026-12-11 | 23% | 441.69d |  | 37451.4d | finish no earlier than 2026-12-11 | R5 | 4589h |  | NR_FR1_lessthan_5MHz_BW_Ph2-UEConTest | 55 | China Telecom | Rel-19 | 108 | RP-253472 |  |
| 536 | 297 | **Enhancements for Air-to-ground network for NR** |  | 378.75d | 2024-03-03 A | 2025-03-03 | 93% | 27.07d |  |  |  |  | 8796h | 4604h | NR_ATG_enh | 52 | CMCC | Rel-19 | 103 |  |  |
| 537 | 297.1 | Core part: Enhancements for Air-to-ground network for NR |  | 575.5d | 2024-03-03 A | 2025-09-09 A | 100% |  |  |  | finish no earlier than 2025-09-09 | R4 | 4604h | 4604h | NR_ATG_enh-Core | 52 | CMCC | Rel-19 | 103 | RP-252602 |  |
| 538 | 297.2 | Perf. part: Enhancements for Air-to-ground network for NR |  | 524d | 2024-10-13 A | 2026-03-03 | 85% | 78.6d |  | 37744.2d | finish no earlier than 2026-03-03 | R4 | 4192h |  | NR_ATG_enh-Perf | 52 | CMCC | Rel-19 | 103 | RP-253477 |  |
| 539 | 298 | **Rel-19 High power UE (power class 1.5 or 2) for NR intra-band Carrier Aggregation (CA) or NR inter-band CA/Dual connectivity (DC) band combinations with/without NR Supplementary Uplink (UL)** |  | 99.5d | 2024-06-06 A | 2024-09-09 | 100% |  | 2025-12-12 |  |  |  | 4597h | 4597h | HPUE_NR_CADC_SUL_R19 | 53 | China Telecom | Rel-19 | 104 |  |  |
| 540 | 298.1 | Core part: Rel-19 High power UE (power class 1.5 or 2) for NR intra-band Carrier Aggregation (CA) or NR inter-band CA/Dual connectivity (DC) band combinations with/without NR Supplementary Uplink (UL) |  | 574.62d | 2024-06-06 A | 2025-12-12 A | 100% |  |  |  | finish no earlier than 2025-12-12 | R4 | 4597h | 4597h | HPUE_NR_CADC_SUL_R19-Core | 53 | China Telecom | Rel-19 | 104 | RP-253460 | 38.794; 38.746; 38.750; 38.792 |
| 541 | 299 | **Rel-19 High power UE (power class 1.5 and 2) for NR FR1 TDD/FDD single band for handheld/FWA UEs, and high power UE operation (power class 1) for FWVM (fixed-wireless/vehicle-mounted) use cases in a single NR band** |  | 99.5d | 2024-06-06 A | 2024-09-09 | 85% | 15.4d |  |  |  |  | 7621h | 4597h | HPUE_NR_FR1_bands_R19 | 53 | CMCC | Rel-19 | 104 |  |  |
| 542 | 299.1 | Core part: Rel-19 High power UE (power class 1.5 and 2) for NR FR1 TDD/FDD single band for handheld/FWA Ues, and high power UE operation (power class 2, 1.5 and 1) for FWVM (fixed-wireless/vehicle-mounted) use cases in a single NR band |  | 574.62d | 2024-06-06 A | 2025-12-12 A | 100% |  |  |  | finish no earlier than 2025-12-12 | R4 | 4597h | 4597h | HPUE_NR_FR1_bands_R19-Core | 53 | CMCC | Rel-19 | 104 | RP-253480 | 38.795 |
| 543 | 299.2 | UE Conformance - Rel-19 High power UE (power class 1.5 and 2) for NR FR1 TDD/FDD single band for handheld/FWA UEs, and high power UE operation (power class 2, 1.5 and 1) for FWVM (fixed-wireless/vehicle-mounted) use cases in a single NR band |  | 378d | 2025-06-06 A | 2026-06-05 | 61% | 147.42d |  | 37647d | finish no earlier than 2026-06-05 | R5 | 3024h |  | HPUE_NR_FR1_bands_R19-UEConTest | 55 | CMCC | Rel-19 | 108 | RP-253380 |  |
| 544 | 300 | **Introduction of Power Class 2 and UE 40MHz Channel Bandwidth in NR band n28** |  | 196.75d | 2024-06-06 A | 2024-12-12 | 100% |  | 2025-12-12 |  |  |  | 5391h | 5391h | NR_n28_PC2_40MHz_CBW | 53 | CMCC | Rel-19 | 104 |  |  |
| 545 | 300.1 | Core part: Introduction of Power Class 2 and UE 40MHz Channel Bandwidth in NR band n28 |  | 378.88d | 2024-06-06 A | 2025-06-06 A | 100% |  |  |  | finish no earlier than 2025-06-06 | R4 | 3031h | 3031h | NR_n28_PC2_40MHz_CBW-Core | 53 | CMCC | Rel-19 | 104 | RP-250273 |  |
| 546 | 300.2 | UE Conformance - Introduction of Power Class 2 and UE 40MHz Channel Bandwidth in NR band n28 |  | 295d | 2025-03-03 A | 2025-12-12 A | 100% |  |  |  | finish no earlier than 2025-12-12 | R5 | 2360h | 2360h | NR_n28_PC2_40MHz_CBW-UEConTest | 54 | CMCC | Rel-19 | 107 | RP-253378 |  |
| 547 | 301 | Rel-19 Radio: NR and LTE | milestone | 0d? | 2019-03-07 | 2019-03-07 |  |  |  | 40388.9d |  |  |  |  |  |  |  | Rel-19 |  |  |  |
| 548 | 302 | **Rel-19 downlink interruption for NR and EN-DC band combinations at dynamic Tx Switching in Uplink** |  | 99.5d | 2024-06-06 A | 2024-09-09 | 51% | 48.98d |  |  |  |  | 7522h | 3819h | DL_intrpt_combos_TxSW_R19 | 53 | China Telecom | Rel-19 | 104 |  |  |
| 549 | 302.1 | Core part: Rel-19 downlink interruption for NR and EN-DC band combinations at dynamic Tx Switching in Uplink |  | 477.38d | 2024-06-06 A | 2025-09-09 A | 100% |  |  |  | finish no earlier than 2025-09-09 | R4 | 3819h | 3819h | DL_intrpt_combos_TxSW_R19-Core | 53 | China Telecom | Rel-19 | 104 | RP-252539 | 37.887 |
| 550 | 302.2 | UE Conformance - Rel-19 downlink interruption for NR and EN-DC band combinations at dynamic Tx Switching in Uplink |  | 462.88d | 2025-12-12 | 2027-03-03 |  |  |  | 37366.4d | finish no earlier than 2027-03-03 | R5 | 3703h |  | DL_intrpt_combos_TxSW_R19-UEConTest |  | China Telecom | Rel-19 |  |  |  |
| 551 | 303 | **Adding channel bandwidth(s) support to existing NR bands and CA/ENDC combinations in REL-19** |  | 99.5d | 2024-06-06 A | 2024-09-09 | 100% |  | 2025-09-09 |  |  |  | 3819h | 3819h | NR_bands_CA_ENDC_R19_BWs | 53 | Ericsson | Rel-19 | 104 |  |  |
| 552 | 303.1 | Core part: Adding channel bandwidth(s) support to existing NR bands and CA/ENDC combinations in REL-19 |  | 477.38d | 2024-06-06 A | 2025-09-09 A | 100% |  |  |  | finish no earlier than 2025-09-09 | R4 | 3819h | 3819h | NR_bands_CA_ENDC_R19_BWs-Core | 53 | Ericsson | Rel-19 | 104 | RP-252019 |  |
| 553 | 304 | **Rel-19 High power UE (power class 1.5 or 2) for Dual Connectivity (DC) combinations of LTE band(s) and NR band(s)** |  | 99.5d | 2024-06-06 A | 2024-09-09 | 53% | 46.72d |  |  |  |  | 9186h | 4597h | HPUE_DC_LTE_NR_R19 | 53 | China Unicom | Rel-19 | 104 |  |  |
| 554 | 304.1 | Core part: Rel-19 High power UE (power class 1.5 or 2) for Dual Connectivity (DC) combinations of LTE band(s) and NR band(s) |  | 574.62d | 2024-06-06 A | 2025-12-12 A | 100% |  |  |  | finish no earlier than 2025-12-12 | R4 | 4597h | 4597h | HPUE_DC_LTE_NR_R19-Core | 53 | China Unicom | Rel-19 | 104 | RP-253529 | 37.898 |
| 555 | 304.2 | UE Conformance - Rel-19 High power UE (power class 1.5 or 2) for Dual Connectivity (DC) combinations of LTE band(s) and NR band(s) |  | 573.62d | 2025-06-06 A | 2026-12-11 | 6% | 539.21d |  | 37451.4d | finish no earlier than 2026-12-11 | R5 | 4589h |  | HPUE_DC_LTE_NR_R19-UEConTest | 55 | China Unicom | Rel-19 | 108 | RP-253154 |  |

Notes:
- 532: 23/7/24: WID:RP-240832->RP-241622; 24/1/25: WID:RP-241622->RP-243309; 3/4/25: WID:RP-243309->RP-250781; 18/7/25: WID:RP-250781->RP-251670
- 533: 13/6/24: Compl:0%->25%; Stat Rep: ->RP-241496; ; 4/9/24: FCD:12/12/2024->24/12/2024; Compl:25%->70%; Stat Rep: RP-241496->RP-242031; ; 6/12/24: FCD:12/12/2024->03/03/2025; Compl:73%->99%; Stat Rep: RP-242031->RP-243146; ; 6/3/25: FCD:12/11/2024->03/03/2025; Compl:99%->100%; Stat Rep: RP-243146->RP-250462;
- 534: 13/6/24: Stat Rep: ->RP-241496; ; 6/12/24: Stat Rep: RP-241496->RP-243146; ; 6/3/25: Compl:0%->30%; Stat Rep: RP-243146->RP-250462; ; 6/6/25: Compl:30%->100%; Stat Rep: RP-250462->RP-251669;
- 535: tested: REL-19 WI NR_FR1_lessthan_5MHz_BW_Ph2 ; 11/9/25: FCD:Sat 12/12/26->Thu 10/12/26; Compl:0%->5%; Stat Rep: ->RP-252551; ; 29/9/25: WID:RP-251455->RP-252552; 3/12/25: FCD:Sat 12/12/26->Fri 11/12/26; Compl:5%->23%; Stat Rep: RP-252551->RP-253472;
- 536: 23/7/24: WID:RP-240839->RP-241213; 26/9/24: WID:RP-241213->RP-242381; 24/1/25: WID:RP-242381->RP-243285
- 537: 13/6/24: Compl:0%->10%; Stat Rep: ->RP-241214; ; 4/9/24: FCD:09/09/2025->25/09/2024; Compl:10%->25%; Stat Rep: RP-241214->RP-241933; ; 6/12/24: FCD:09/09/2024->09/09/2025; Compl:25%->55%; Stat Rep: RP-241933->RP-242960; ; 6/3/25: FCD:23/03/2025->09/09/202; 11/9/25: Compl:90%->100%; Stat Rep: RP-251400->RP-252602;
- 538: 13/6/24: Stat Rep: ->RP-241214; ; 4/9/24: FCD:03/03/2026->26/03/2025; Stat Rep: RP-241214->RP-241933; ; 6/12/24: FCD:03/03/2025->03/03/2026; Stat Rep: RP-241933->RP-242960; ; 6/3/25: Stat Rep: RP-242960->RP-250271; ; 6/6/25: Compl:0%->33%; Stat Rep: RP-25; 3/12/25: Compl:50%->85%; Stat Rep: RP-252602->RP-253477;
- 539: 26/9/24: WID:RP-241679->RP-242003; 24/1/25: WID:RP-242003->RP-242754; 24/1/25: WID:RP-242754->RP-242865; 3/4/25: WID:RP-242865->RP-250806; 18/7/25: WID:RP-250806->RP-251450; 29/9/25: WID:RP-251450->RP-252540; 7/1/26: WID:RP-252540->RP-253837
- 540: 4/9/24: FCD:09/09/2025->25/09/2024; Compl:0%->10%; Stat Rep: ->RP-242004; ; 26/9/24: 38.794 added;; 26/9/24: 38.746 added;; 26/9/24: 38.750 added;; 26/9/24: 38.792 added;; 6/12/24: FCD:09/09/2024->09/09/2025; Compl:10%->30%; Stat Rep: RP-242004->RP-24286; 3/12/25: Compl:85%->100%; Stat Rep: RP-252541->RP-253460;
- 541: 26/9/24: WID:RP-241680->RP-241932; 18/7/25: WID:RP-241932->RP-251402; 29/9/25: WID:RP-251402->RP-252606
- 542: 4/9/24: FCD:09/09/2025->25/09/2024; Compl:0%->15%; Stat Rep: ->RP-241931; ; 26/9/24: 38.795 added;; 6/12/24: FCD:09/09/2024->09/09/2025; Compl:15%->30%; Stat Rep: RP-241931->RP-242959; ; 6/3/25: FCD:19/04/2025->09/09/2025; Compl:30%->55%; Stat Rep: RP-24; 7/1/26: WID:RP-252606->RP-253479
- 543: tested: REL-19 WI HPUE_NR_FR1_bands_R19-Core ; 11/9/25: Compl:0%->56%; Stat Rep: ->RP-252599; ; 29/9/25: WID:RP-251374->RP-252598; 3/12/25: FCD:Sat 06/06/26->Fri 05/06/26; Compl:56%->61%; Stat Rep: RP-252599->RP-253380; ; 7/1/26: WID:RP-252598->RP-253379
- 544: 26/9/24: WID:RP-241660->RP-241930; 24/1/25: WID:RP-241930->RP-243321
- 545: 4/9/24: FCD:12/12/2024->24/12/2024; Compl:0%->20%; Stat Rep: ->RP-241929; ; 6/12/24: Compl:20%->99%; Stat Rep: RP-241929->RP-242957; ; 6/3/25: FCD:15/10/2024->06/06/2025; Compl:99%->100%; Stat Rep: RP-242957->RP-250273;
- 546: 6/6/25: Compl:0%->54%; Stat Rep: ->RP-251380; ; 11/9/25: Compl:54%->92%; Stat Rep: RP-251380->RP-252597; ; 3/12/25: FCD:Tue 03/03/26->Fri 12/12/25; Compl:92%->100%; Stat Rep: RP-252597->RP-253378; ; 7/1/26: WID:RP-250249->RP-253377
- 547: -
- 548: basket WI; no Perf. part; compare DL_intrpt_combos_TxSW_R18; TR 37.8xx ; 3/4/25: WID:RP-241672->RP-250369
- 549: basket WI; no Perf. part; compare DL_intrpt_combos_TxSW_R18; TR 37.8xx ; 4/9/24: FCD:09/09/2025->25/09/2024; Compl:0%->10%; Stat Rep: ->RP-241999; ; 26/9/24: 37.887 added;; 6/12/24: FCD:09/09/2024->09/09/2025; Compl:10%->20%; Stat Rep: RP-241999->RP-2428; 11/9/25: Compl:80%->100%; Stat Rep: RP-251449->RP-252539; List of Impacted TS & TR updated;
- 551: basket WI; no Perf. part; compare: NR_bands_R18_BWs; TR 37.8xx ; 26/9/24: WID:RP-241684->RP-242402; 24/1/25: WID:RP-242402->RP-242604; 3/4/25: WID:RP-242604->RP-250524; 18/7/25: WID:RP-250524->RP-251160; 29/9/25: WID:RP-251160->RP-252020
- 552: basket WI; no Perf. part; compare: NR_bands_R18_BWs; TR 37.8xx ; 4/9/24: FCD:09/09/2025->25/09/2024; Compl:0%->5%; WID: RP-241684->RP-231684; Stat Rep: ->RP-241757; ; 6/12/24: FCD:09/09/2024->09/09/2025; Compl:5%->15%; Stat Rep: RP-241757->RP-242603; ; 6; 11/9/25: Compl:90%->100%; Stat Rep: RP-251159->RP-252019;
- 553: basket WI; no Perf. part; compare HPUE_FR1_DC_LTE_NR_R18 and DC_R19_xBLTE_yBNR ; 26/9/24: WID:RP-241678->RP-242341; 24/1/25: WID:RP-242341->RP-242609; 3/4/25: WID:RP-242609->RP-250424; 18/7/25: WID:RP-250424->RP-251595; 29/9/25: WID:RP-251595->RP-252336
- 554: basket WI; no Perf. part; compare HPUE_FR1_DC_LTE_NR_R18 and DC_R19_xBLTE_yBNR ; 4/9/24: FCD:09/09/2025->25/09/2024; Compl:0%->15%; Stat Rep: ->RP-242019; ; 26/9/24: 37.898 added;; 6/12/24: FCD:09/09/2024->09/09/2025; Compl:15%->30%; Stat Rep: RP-242019-; 7/1/26: WID:RP-252336->RP-253530
- 555: tested: REL-19 WI HPUE_DC_LTE_NR_R19-Core ; 11/9/25: FCD:Sat 12/12/26->Thu 10/12/26; Compl:0%->6%; Stat Rep: ->RP-251980; ; 3/12/25: FCD:Sat 12/12/26->Fri 11/12/26; Stat Rep: RP-251980->RP-253154;

| ID | WBS | Task | Type | Duration | Start | Finish | Complete | Remaining | Actual start | Actual finish | Total slack | Constraint | Resources | Work | Actual work | Acronym | PCG approved | WI rapporteur name | Release | TSG approved | Impacted TSs and TRs | Status Report |
| --- | --- | --- | --- | --- | --- | --- | --- | --- | --- | --- | --- | --- | --- | --- | --- | --- | --- | --- | --- | --- | --- | --- |
| 556 | 305 | **Simultaneous Rx/Tx band combinations for NR CA/DC, NR SUL and LTE/NR DC in Rel-19** |  | 99.5d | 2024-06-06 A | 2024-09-09 | 100% |  |  | 2025-12-12 |  |  |  | 4597h | 4597h | LTE_NR_R19_Simult_RxTx | 53 | Huawei | Rel-19 | 104 |  |  |
| 557 | 305.1 | Core part: Simultaneous Rx/Tx band combinations for NR CA/DC, NR SUL and LTE/NR DC in Rel-19 |  | 574.62d | 2024-06-06 A | 2025-12-12 A | 100% |  |  |  |  | finish no earlier than 2025-12-12 | R4 | 4597h | 4597h | LTE_NR_R19_Simult_RxTx-Core | 53 | Huawei | Rel-19 | 104 | 38.793 | RP-253507 |
| 558 | 306 | **Rel-19 Dual connectivity (DC) of x LTE band(s), y NR band(s) (1<=x<6, 1<=y<6, x+y<=6) and single or two NR Supplementary Uplink (SUL) bands** |  | 99.5d | 2024-06-06 A | 2024-09-09 | 100% |  |  | 2025-12-12 |  |  |  | 4597h | 4597h | DC_R19_xBLTE_yBNR | 53 | Nokia | Rel-19 | 104 |  |  |
| 559 | 306.1 | Core part: Rel-19 Dual connectivity (DC) of x LTE band(s), y NR band(s) (1<=x<6, 1<=y<6, x+y<=6) and single or two NR Supplementary Uplink (SUL) bands |  | 574.62d | 2024-06-06 A | 2025-12-12 A | 100% |  |  |  |  | finish no earlier than 2025-12-12 | R4 | 4597h | 4597h | DC_R19_xBLTE_yBNR-Core | 53 | Nokia | Rel-19 | 104 | 37.719-11-10; 37.719-11-11; 37.719-21-11 | RP-253519 |
| 560 | 307 | **UE RF enhancements for NR FR1/FR2 and EN-DC, Phase 4** |  | 378.75d | 2024-03-03 A | 2025-03-03 | 63% | 139.8d |  |  |  |  |  | 15934h | 4604h | NR_ENDC_RF_Ph4 | 52 | Huawei | Rel-19 | 103 |  |  |
| 561 | 307.1 | Core part: UE RF enhancements for NR FR1/FR2 and EN-DC, Phase 4 |  | 575.5d | 2024-03-03 A | 2025-09-09 A | 100% |  |  |  |  | finish no earlier than 2025-09-09 | R4 | 4604h | 4604h | NR_ENDC_RF_Ph4-Core | 52 | Huawei | Rel-19 | 103 |  | RP-252731 |
| 562 | 307.2 | Perf. part: UE RF enhancements for NR FR1/FR2 and EN-DC, Phase 4 |  | 756.75d | 2024-03-03 A | 2026-03-03 | 90% | 75.67d |  |  | 37744.2d | finish no earlier than 2026-03-03 | R4 | 6054h |  | NR_ENDC_RF_Ph4-Perf | 52 | Huawei | Rel-19 | 103 |  | RP-253504 |
| 563 | 307.3 | UE Conformance - UE RF enhancements for NR FR1/FR2 and EN-DC, Phase 4 |  | 659.5d | 2025-12-12 | 2027-09-09 |  |  |  |  | 37169.8d | finish no earlier than 2027-09-09 | R5 | 5276h |  | NR_ENDC_RF_Ph4-UEConTest |  | Huawei | Rel-19 |  |  |  |
| 564 | 308 | **Support of intra-band non-collocated EN-DC/NR-CA deployment Phase2: new receiver type(s)** |  | 378.75d | 2024-03-03 A | 2025-03-03 | 81% | 72.2d |  |  |  |  |  | 8796h | 4604h | NonCol_intraB_ENDC_NR_CA_Ph2 | 52 | KDDI | Rel-19 | 103 |  |  |
| 565 | 308.1 | Core part: Support of intra-band non-collocated EN-DC/NR-CA deployment Phase2: new receiver type(s) |  | 575.5d | 2024-03-03 A | 2025-09-09 A | 100% |  |  |  |  | finish no earlier than 2025-09-09 | R4 | 4604h | 4604h | NonCol_intraB_ENDC_NR_CA_Ph2-Core | 52 | KDDI | Rel-19 | 103 |  | RP-252366 |
| 566 | 308.2 | Perf. part: Support of intra-band non-collocated EN-DC/NR-CA deployment Phase2: new receiver type(s) |  | 524d | 2024-10-13 A | 2026-03-03 | 60% | 209.6d |  |  | 37744.2d | finish no earlier than 2026-03-03 | R4 | 4192h |  | NonCol_intraB_ENDC_NR_CA_Ph2-Perf | 52 | KDDI | Rel-19 | 103 |  | RP-253494 |
| 567 | 309 | **FR1 TRP, TRS and MIMO OTA testing enhancement Phase 3** |  | 378.75d | 2024-03-03 A | 2025-03-03 | 62% | 144.21d |  |  |  |  |  | 16722h | 4604h | TRP_TRS_MIMO_OTA_Ph3 | 52 | Vivo | Rel-19 | 103 |  |  |
| 568 | 309.1 | Core part: FR1 TRP (Total Radiated Power), TRS (Total Radiated Sensitivity) and MIMO OTA (Over the Air) testing enhancement Phase 3 |  | 575.5d | 2024-03-03 A | 2025-09-09 A | 100% |  |  |  |  | finish no earlier than 2025-09-09 | R4 | 4604h | 4604h | TRP_TRS_MIMO_OTA_Ph3-Core | 52 | Vivo | Rel-19 | 103 | 38.762 | RP-252010 |
| 569 | 309.2 | Perf. Part: FR1 TRP (Total Radiated Power), TRS (Total Radiated Sensitivity) and MIMO OTA (Over the Air) testing enhancement Phase 3 |  | 756.75d | 2024-03-03 A | 2026-03-03 | 95% | 37.84d |  |  | 37744.2d | finish no earlier than 2026-03-03 | R4 | 6054h |  | TRP_TRS_MIMO_OTA_Ph3-Perf | 52 | Vivo | Rel-19 | 103 |  | RP-253259 |
| 570 | 309.3 | UE Conformance - FR1 TRP (Total Radiated Power), TRS (Total Radiated Sensitivity) testing enhancement Phase 3 |  | 379d | 2025-12-12 | 2026-12-12 |  |  |  |  | 37450.2d | finish no earlier than 2026-12-12 | R5 | 3032h |  | TRP_TRS_OTA_Ph3-UEConTest |  | Apple | Rel-19 |  |  |  |
| 571 | 309.4 | UE Conformance - NR MIMO OTA (Over the Air) testing enhancement Phase 3 |  | 379d | 2025-12-12 | 2026-12-12 |  |  |  |  | 37450.2d | finish no earlier than 2026-12-12 | R5 | 3032h |  | MIMO_OTA_Ph3-UEConTest |  | Apple | Rel-19 |  |  |  |
| 572 | 310 | UE Conformance - Rel-19 NR CA and DC; and NR and LTE DC Configurations |  | 671.88d | 2025-03-03 A | 2026-12-11 | 5% | 638.28d |  |  | 37451.4d | finish no earlier than 2026-12-11 | R5 | 5375h |  | NR_CADC_NR_LTE_DC_R19-UEConTest | 54 | Huawei | Rel-19 | 107 |  | RP-253433 |
| 573 | 311 | Rel-19 Radio: LTE | milestone | 0d? | 2019-03-07 | 2019-03-07 |  |  |  |  | 40388.9d |  |  |  |  |  |  |  | Rel-19 |  |  |  |
| 574 | 312 | **New LTE band for 5G broadcast for region 3 utilizing a geosynchronous satellite** |  | 379d | 2025-03-03 A | 2026-03-03 | 87% | 49.81d |  |  | 37744.2d |  | R4 | 7646h | 4215.55h | LTE_band_5G_bcast_GSO | 54 | Astrum Mobile | Rel-19 | 107 |  |  |
| 575 | 312.1 | Core part: New LTE band for 5G broadcast for region 3 utilizing a geosynchronous satellite |  | 197.75d | 2025-03-03 A | 2025-09-09 A | 100% |  |  |  |  | finish no earlier than 2025-09-09 | R4 | 1582h | 1582h | LTE_band_5G_bcast_GSO-Core | 54 | Astrum Mobile | Rel-19 | 107 |  | RP-251943 |
| 576 | 312.2 | Perf. part: New LTE band for 5G broadcast for region 3 utilizing a geosynchronous satellite |  | 379d | 2025-03-03 A | 2026-03-03 | 80% | 75.8d |  |  | 37744.2d | finish no earlier than 2026-03-03 | R4 | 3032h |  | LTE_band_5G_bcast_GSO-Perf | 54 | Astrum Mobile | Rel-19 | 107 |  | RP-253391 |
| 577 | 313 | **LTE-based 5G Broadcast Phase 2** |  | 593.25d | 2024-05-19 | 2025-12-12 A | 100% |  | 2024-10-14 |  |  |  |  | 6016h | 6016h | LTE_terr_bcast_Ph2 | 54 | EBU | Rel-19 | 106 |  |  |
| 578 | 313.1 | Core part: LTE-based 5G Broadcast Phase 2 |  | 342d | 2024-10-14 A | 2025-09-09 A | 100% |  |  |  |  | finish no earlier than 2025-09-09 | R1 | 2736h | 2736h | LTE_terr_bcast_Ph2-Core | 54 | EBU | Rel-19 | 106 |  | RP-251975 |
| 579 | 313.2 | Perf. part: LTE-based 5G Broadcast Phase 2 |  | 410d | 2024-11-11 A | 2025-12-12 A | 100% |  |  |  |  | finish no earlier than 2025-12-12 | R4 | 3280h | 3280h | LTE_terr_bcast_Ph2-Perf | 54 | EBU | Rel-19 | 106 |  | RP-253112 |

Notes:
- 556: basket WI; no Perf. part; compare REL-18 WI LTE_NR_Simult_RxTx_R18 and REL-17 WI LTE_NR_Simult_RxTx; TR 37.8xx ; 26/9/24: WID:RP-241682->RP-242088; 18/7/25: WID:RP-242088->RP-251536; 7/1/26: WID:RP-251536->RP-253508
- 557: basket WI; no Perf. part; compare REL-18 WI LTE_NR_Simult_RxTx_R18 and REL-17 WI LTE_NR_Simult_RxTx; TR 37.8xx ; 4/9/24: FCD:09/09/2025->25/09/2024; Compl:0%->10%; Stat Rep: ->RP-242087; ; 26/9/24: 38.793 added;; 6/12/24: FCD:09/09/2024->09/09/2025; Comp; 3/12/25: Compl:80%->100%; Stat Rep: RP-252736->RP-253507;
- 558: 26/9/24: WID:RP-241673->RP-241786; 24/1/25: WID:RP-241786->RP-243257; 3/4/25: WID:RP-243257->RP-250143; 18/7/25: WID:RP-250143->RP-250966; 29/9/25: WID:RP-250966->RP-252016; 7/1/26: WID:RP-252016->RP-253520
- 559: 4/9/24: FCD:09/09/2025->25/09/2024; Compl:0%->10%; Stat Rep: ->RP-241785; ; 26/9/24: 37.719-11-11 added;; 26/9/24: 37.719-21-11 added;; 6/12/24: FCD:09/09/2024->09/09/2025; Compl:10%->15%; Stat Rep: RP-241785->RP-242535; ; 6/3/25: FCD:19/04/2025->09/09/2; 3/12/25: Compl:80%->100%; Stat Rep: RP-252015->RP-253519;
- 560: 23/7/24: WID:RP-240828->RP-241656; 3/4/25: WID:RP-241656->RP-250780; 18/7/25: WID:RP-250780->RP-251816
- 561: 13/6/24: Compl:0%->20%; Stat Rep: ->RP-241236; ; 4/9/24: FCD:09/09/2025->25/09/2024; Compl:20%->35%; Stat Rep: RP-241236->RP-242084; ; 6/12/24: FCD:09/09/2024->09/09/2025; Compl:35%->50%; Stat Rep: RP-242084->RP-243011; ; 6/3/25: FCD:23/03/2025->09/09/202; 11/9/25: Compl:80%->100%; Stat Rep: RP-251532->RP-252731;
- 562: 4/9/24: FCD:03/03/2026->26/03/2025; Compl:0%->15%; Stat Rep: ->RP-242084; ; 6/12/24: FCD:03/03/2025->03/03/2026; Compl:15%->20%; Stat Rep: RP-242084->RP-243011; ; 6/3/25: FCD:22/07/2025->03/03/2026; Stat Rep: RP-243011->RP-250280; ; 6/6/25: Compl:20%->60%; 3/12/25: Compl:70%->90%; Stat Rep: RP-252731->RP-253504;
- 564: 26/9/24: WID:RP-240838->RP-242083
- 565: 4/9/24: FCD:09/09/2025->25/09/2024; Compl:0%->35%; Stat Rep: ->RP-242079; ; 6/12/24: FCD:09/09/2024->09/09/2025; Compl:35%->45%; Stat Rep: RP-242079->RP-242842; ; 6/3/25: FCD:23/03/2025->09/09/2025; Compl:45%->50%; Stat Rep: RP-242842->RP-250279; ; 6/6/25; 11/9/25: Compl:80%->100%; Stat Rep: RP-251278->RP-252366;
- 566: 4/9/24: FCD:03/03/2026->26/03/2025; Stat Rep: ->RP-242079; ; 6/12/24: FCD:03/03/2025->03/03/2026; Stat Rep: RP-242079->RP-242842; ; 6/3/25: Stat Rep: RP-242842->RP-250279; ; 6/6/25: Stat Rep: RP-250279->RP-251278; ; 11/9/25: Stat Rep: RP-251278->RP-252366; 3/12/25: Compl:0%->60%; Stat Rep: RP-252366->RP-253494;
- 567: 23/7/24: WID:RP-240841->RP-241623; 24/1/25: WID:RP-241623->RP-243277; 3/4/25: WID:RP-243277->RP-250197; 29/9/25: WID:RP-250197->RP-252187
- 568: 13/6/24: Compl:0%->10%; Stat Rep: ->RP-241043; ; 4/9/24: FCD:09/09/2025->25/09/2024; Compl:10%->20%; Stat Rep: RP-241043->RP-241828; ; 26/9/24: 38.762 added;; 6/12/24: FCD:09/09/2024->09/09/2025; Compl:20%->45%; Stat Rep: RP-241828->RP-242623; ; 6/3/25: F; 11/9/25: Compl:90%->100%; Stat Rep: RP-251201->RP-252010; List of Impacted TS & TR updated;
- 569: 13/6/24: Stat Rep: ->RP-241043; ; 4/9/24: FCD:03/03/2026->26/03/2025; Compl:0%->5%; Stat Rep: RP-241043->RP-241828; ; 6/12/24: FCD:03/03/2025->03/03/2026; Compl:5%->25%; Stat Rep: RP-241828->RP-242623; ; 6/3/25: FCD:22/07/2025->03/03/2026; Compl:25%->35%;; 3/12/25: Compl:75%->95%; Stat Rep: RP-252010->RP-253259;
- 572: 6/6/25: FCD:Sat 12/12/26->Fri 11/12/26; Compl:0%->5%; Stat Rep: ->RP-251492; ; 11/9/25: FCD:Fri 11/12/26->Thu 10/12/26; Stat Rep: RP-251492->RP-252649; ; 3/12/25: FCD:Sat 12/12/26->Fri 11/12/26; Stat Rep: RP-252649->RP-253433;
- 573: -
- 574: 18/7/25: WID:RP-250788->RP-251419; 7/1/26: WID:RP-251419->RP-253395
- 575: 6/6/25: Compl:0%->75%; WID: RP-250788->RP-251419; Stat Rep: ->RP-251276; ; 11/9/25: Compl:75%->100%; Stat Rep: RP-251276->RP-251943;
- 576: 6/6/25: WID: RP-250788->RP-251419; Stat Rep: ->RP-251276; ; 11/9/25: Stat Rep: RP-251276->RP-251943; ; 3/12/25: Compl:0%->80%; Stat Rep: RP-251943->RP-253391;
- 577: 3/4/25: WID:RP-243290->RP-250794
- 578: 6/3/25: FCD:07/09/2025->09/09/2025; Compl:0%->40%; Stat Rep: ->RP-250238; ; 6/6/25: Compl:40%->95%; Stat Rep: RP-250238->RP-251143; ; 11/9/25: Compl:95%->100%; Stat Rep: RP-251143->RP-251975;
- 579: 6/3/25: Stat Rep: ->RP-250238; ; 6/6/25: Stat Rep: RP-250238->RP-251143; ; 11/9/25: Compl:0%->25%; Stat Rep: RP-251143->RP-251975; ; 3/12/25: Compl:25%->100%; Stat Rep: RP-251975->RP-253112;

| ID | WBS | Task | Type | Duration | Start | Finish | Complete | Remaining | Actual start | Actual finish | Total slack | Constraint | Resources | Work | Actual work | Acronym | PCG approved | WI rapporteur name | Release | TSG approved | Status Report | WI rapporteur e-mail |
| --- | --- | --- | --- | --- | --- | --- | --- | --- | --- | --- | --- | --- | --- | --- | --- | --- | --- | --- | --- | --- | --- | --- |
| 580 | 314 | **New bands for LTE based 5G terrestrial broadcast for early deployments** |  | 397.5d | 2024-05-19 | 2025-06-06 A | 100% |  | 2024-09-14 |  |  |  |  | 2200h | 2200h | LTE_terr_bcast_bands_sub_108 | 54 | EBU | Rel-19 | 106 |  |  |
| 581 | 314.1 | New bands for LTE based 5G terrestrial broadcast for early deployments |  | 275d | 2024-09-14 A | 2025-06-06 A | 100% |  |  |  |  | finish no earlier than 2025-06-06 | R4 | 2200h | 2200h | LTE_terr_bcast_bands_sub_108-Core | 54 | EBU | Rel-19 | 106 | RP-251141 |  |
| 582 | 315 | **Introduction of LTE FDD band in 1800–1830 MHz for Canada** |  | 280.62d | 2024-06-06 A | 2025-03-03 A | 100% |  |  |  |  |  |  | 4490h | 4490h | LTE_FDD_1800_1830MHz_CAN | 53 | Novamint | Rel-19 | 104 |  |  |
| 583 | 315.1 | Core part: Introduction of LTE FDD band in 1800–1830 MHz for Canada |  | 280.62d | 2024-06-06 A | 2025-03-03 A | 100% |  |  |  |  | finish no earlier than 2025-03-03 | R4 | 2245h | 2245h | LTE_FDD_1800_1830MHz_CAN-Core | 53 | Novamint | Rel-19 | 104 | RP-250105 |  |
| 584 | 315.2 | Perf.part: Introduction of LTE FDD band in 1800–1830 MHz for Canada |  | 280.62d | 2024-06-06 A | 2025-03-03 A | 100% |  |  |  |  | finish no earlier than 2025-03-03 | R4 | 2245h | 2245h | LTE_FDD_1800_1830MHz_CAN-Perf | 53 | Novamint | Rel-19 | 104 | RP-250105 |  |
| 585 | 316 | **Rel-19 High power UE (power class 2) and high power operation (power class 1) for fixed-wireless/vehicle-mounted use cases in a single LTE band** |  | 99.5d | 2024-06-06 A | 2024-09-09 | 100% |  |  | 2025-09-09 |  |  |  | 3819h | 3819h | HPUE_LTE_bands_R19 | 53 | Nokia | Rel-19 | 104 |  |  |
| 586 | 316.1 | Core part: Rel-19 High power UE (power class 2) and high power operation (power class 1) for fixed-wireless/vehicle-mounted use cases in a single LTE band |  | 477.38d | 2024-06-06 A | 2025-09-09 A | 100% |  |  |  |  | finish no earlier than 2025-09-09 | R4 | 3819h | 3819h | HPUE_LTE_bands_R19-Core | 53 | Nokia | Rel-19 | 104 | RP-250899 |  |
| 587 | 317 | **Rel-19 LTE-Advanced Carrier Aggregation for x bands (1<=x<= 6) DL with y bands (y=1, 2) UL** |  | 378.88d | 2024-06-06 A | 2025-06-06 | 100% |  |  | 2025-12-12 |  |  |  | 4597h | 4597h | LTE_CA_R19_xBDL_yBUL | 53 | Huawei | Rel-19 | 104 |  |  |
| 588 | 317.1 | Core part: Rel-19 LTE-Advanced Carrier Aggregation for x bands (1<=x<= 6) DL with y bands (y=1, 2) UL |  | 574.62d | 2024-06-06 A | 2025-12-12 A | 100% |  |  |  |  | finish no earlier than 2025-12-12 | R4 | 4597h | 4597h | LTE_CA_R19_xBDL_yBUL-Core | 53 | Huawei | Rel-19 | 104 | RP-253505 |  |
| 589 | 318 | Rel-19 other topics | milestone | 0d? | 2019-03-07 | 2019-03-07 |  |  |  |  | 40388.9d |  |  |  |  |  |  |  | Rel-19 |  |  |  |
| 590 | 319 | Specification of example algorithm for alternative f5* (f5**) function |  | 96.25d | 2025-03-06 A | 2025-06-06 A | 100% |  |  |  |  | finish no earlier than 2025-06-06 | S3 | 770h | 770h | Crypto_f5** | 54 | Ferhat Karakoc | Rel-19 | 107 |  | ferhat.karakoc@ericsson.com |
| 591 | 320 | Study on 3GPP Cryptographic Inventory |  | 190.38d | 2024-12-05 A | 2025-06-06 A | 100% |  |  |  |  | finish no earlier than 2025-06-06 | S3 | 1523h | 1523h | FS_CryptoInv | 54 | Stawros Orkopoulos | Rel-19 | 106 |  | stawros.orkopoulos@nokia.com |
| 592 | 321 | CHF Segmentation |  | 471.12d | 2024-06-12 A | 2025-09-09 A | 100% |  |  |  |  | finish no earlier than 2025-09-09 | S5 | 3769h | 3769h | CHFSeg | 53 | Cetinkaya Egemen Kemal,Verizon | Rel-19 | 104 |  | (egemen.cetinkaya@verizon.com) |
| 593 | 322 | **Introduction of BDS (BeiDou Navigation Satellite System) B2b Signal in A-GNSS for LTE and NR** |  | 658.38d | 2024-09-09 A | 2026-06-06 | 78% | 146.39d |  |  | 37646d |  |  | 6593h | 5127h | LCS_BDS_B2b_LTE_NR | 53 | CAICT | Rel-19 | 105 |  |  |
| 594 | 322.1 | Core part: Introduction of BDS (BeiDou Navigation Satellite System) B2b Signal in A-GNSS for LTE and NR |  | 378.88d | 2024-09-09 A | 2025-09-09 A | 100% |  |  |  |  | finish no earlier than 2025-09-09 | R2 | 3031h | 3031h | LCS_BDS_B2b_LTE_NR-Core | 53 | CAICT | Rel-19 | 105 | RP-252106 |  |
| 595 | 322.2 | Perf. part: Introduction of BDS (BeiDou Navigation Satellite System) B2b Signal in A-GNSS for LTE and NR |  | 262d | 2024-12-30 A | 2025-09-09 A | 100% |  |  |  |  | finish no earlier than 2025-09-09 | R4 | 2096h | 2096h | LCS_BDS_B2b_LTE_NR-Perf | 53 | CAICT | Rel-19 | 105 | RP-252106 |  |
| 596 | 322.3 | UE Conformance - Introduction of BDS (BeiDou Navigation Satellite System) B2b Signal in A-GNSS for LTE and NR |  | 183.25d | 2025-12-12 | 2026-06-06 |  |  |  |  | 37646d | finish no earlier than 2026-06-06 | R5 | 1466h |  | LCS_BDS_B2b_LTE_NR-UEConTest |  | CATT | Rel-19 |  |  |  |
| 597 | 323 | **Introduction of A-GNSS support for NavIC (Navigation with Indian Constellation) L1 SPS (Standard Positioning Service) in NR & LTE** |  | 378.88d | 2024-09-09 A | 2025-09-09 A | 100% |  |  |  |  |  |  | 4339h | 4339h | LCS_NAVIC_L1_SPS_NR_LTE | 53 | Reliance Jio | Rel-19 | 105 |  |  |
| 598 | 323.1 | Core part: Introduction of A-GNSS support for NavIC (Navigation with Indian Constellation) L1 SPS (Standard Positioning Service) in NR & LTE |  | 378.88d | 2024-09-09 A | 2025-09-09 A | 100% |  |  |  |  | finish no earlier than 2025-09-09 | R2 | 3031h | 3031h | LCS_NAVIC_L1_SPS_NR_LTE-Core | 53 | Reliance Jio | Rel-19 | 105 | RP-251554 |  |
| 599 | 323.2 | Perf. part: Introduction of A-GNSS support for NavIC (Navigation with Indian Constellation) L1 SPS (Standard Positioning Service) in NR & LTE |  | 163.5d | 2024-12-30 A | 2025-06-06 A | 100% |  |  |  |  | finish no earlier than 2025-06-06 | R4 | 1308h | 1308h | LCS_NAVIC_L1_SPS_NR_LTE-Perf | 53 | Reliance Jio | Rel-19 | 105 | RP-251554 |  |
| 600 | 324 | Data management regarding subscriptions and reporting |  | 265d | 2024-12-28 A | 2025-09-09 A | 100% |  |  |  |  | finish no earlier than 2025-09-09 | S5 | 2120h | 2120h | Data_SREP | 53 | Robert Petersen (Ericsson) | Rel-19 | 105 |  | robert.petersen@ericsson.com |
| 601 | 325 | Study on MC services support on IOPS mode of operation for 5G |  | 108d | 2024-07-16 A | 2024-12-12 A | 100% |  |  |  |  | finish no earlier than 2024-12-12 | S6 | 864h | 864h | FS_Generic_IOPS | 53 | FirstNet, Mark Lipford | Rel-19 | 104 |  | mark.lipford@firstnet.gov |
| 602 | 326 | MC services for generic support on IOPS mode of operation |  | 72d | 2024-09-04 A | 2024-12-12 A | 100% |  |  |  |  | finish no earlier than 2024-12-12 | S6 | 576h | 576h | Generic_IOPS | 53 | FirstNet, Mark Lipford | Rel-19 | 105 |  | mark.lipford@firstnet.gov |
| 603 | 327 | **Monitoring of signalling traffic in 5G** |  | 228.75d | 2024-05-06 A | 2024-12-12 A | 100% |  |  |  |  |  |  | 816h | 816h | MonSTra | 53 | Cristina Romaguera | Rel-19 | 105 |  | cristina.romaguera@vodafone.com |
| 604 | 327.1 | Stage 1 for MonSta |  | 24d | 2024-05-06 A | 2024-06-06 A | 100% |  |  |  |  | finish no earlier than 2024-06-06 | S1 | 192h | 192h | MonSTra | 53 | Cristina Romaguera | Rel-19 | 104 |  | cristina.romaguera@vodafone.com |
| 605 | 327.2 | Security for MonStra |  | 72d | 2024-10-04 A | 2024-12-12 A | 100% |  |  |  |  | finish no earlier than 2024-12-12 | S3 | 576h | 576h | MonStra-Sec | 53 | Vodafone, Susana Sabater | Rel-19 | 105 |  | susana.sabatr@vodafone.com |
| 606 | 327.3 | Management for MonStra |  | 6d | 2024-12-05 A | 2024-12-10 A | 100% |  |  |  |  | finish no earlier than 2024-12-12 | S5 | 48h | 48h | Monstra-OAM | 54 | Susana Sabater (Vodafone) | Rel-19 | 106 |  | susana.sabater@vodafone.com |

Notes:
- 580: 3/4/25: WID:RP-243268->RP-250793
- 581: 6/3/25: Compl:0%->40%; Stat Rep: ->RP-250235; ; 6/6/25: Compl:40%->100%; Stat Rep: RP-250235->RP-251141;
- 582: ; 26/9/24: WID:RP-241649->RP-241739; 24/1/25: WID:RP-241739->RP-242461
- 583: ; 4/9/24: FCD:12/12/2024->24/12/2024; Compl:0%->25%; Stat Rep: ->RP-241738; ; 6/12/24: FCD:12/12/2024->03/03/2025; Compl:25%->99%; Stat Rep: RP-241738->RP-242460; ; 6/3/25: FCD:09/12/2024->03/03/2025; Compl:99%->100%; Stat Rep: RP-242460->RP-250105;
- 584: ; 4/9/24: FCD:03/03/2025->25/03/2025; Stat Rep: ->RP-241738; ; 6/12/24: Compl:0%->99%; Stat Rep: RP-241738->RP-242460; ; 6/3/25: FCD:09/12/2024->03/03/2025; Compl:99%->100%; Stat Rep: RP-242460->RP-250105;
- 585: basket WI; no Perf. part; TR 36.8xx
- 586: basket WI; no Perf. part; TR 36.8xx ; 4/9/24: FCD:09/09/2025->25/09/2024; Compl:0%->10%; Stat Rep: ->RP-241814; ; 26/9/24: 36.767 added;; 6/12/24: FCD:09/09/2024->09/09/2025; WID: RP-241681->RP-242086; Stat Rep: RP-241814->RP-242499; ; 6/3/25: FCD:19/04/; 30/9/25: 10%->100 / Impacted TSs and TRs: 36,767
- 587: basket WI; no Perf. part; TR 36.8xx; compare REL-18 WI LTE_CA_R18_xBDL_yBUL ; 26/9/24: WID:RP-241676->RP-242086; 24/1/25: WID:RP-242086->RP-243014; 3/4/25: WID:RP-243014->RP-250282; 18/7/25: WID:RP-250282->RP-251534; 29/9/25: WID:RP-251534->RP-252735; 7/1/26: WID:RP-252735->RP-253506
- 588: basket WI; no Perf. part; TR 36.8xx; compare REL-18 WI LTE_CA_R18_xBDL_yBUL ; 4/9/24: FCD:09/09/2025->24/06/2025; Compl:0%->10%; Stat Rep: ->RP-242085; ; 26/9/24: 36.719-01-01 added;; 6/12/24: FCD:06/06/2025->09/09/2025; Compl:10%->31%; Stat Rep: RP-2420; 3/12/25: Compl:85%->100%; Stat Rep: RP-252733->RP-253505; / Impacted TSs and TRs: 36.719-01-01
- 589: -
- 590: ; 26/3/25: 35.249 added;; 26/3/25: 23.369 added;; 26/3/25: 23.700-14 added;; 17/9/25: 0%->100 / Impacted TSs and TRs: 33.102; 35.205; 35.231 ; 35.249; 23.369; 23.700-14
- 591: 6/3/25: 0%->25; 5/6/25: 25%->100
- 592: ; 4/9/24: 5%->25; 5/12/24: 25%->55; 6/3/25: 55%->60; 26/3/25: WID:SP-241001->SP-250122; 26/3/25: FCD:11/12/2024->/25; 6/6/25: 60%->90; 12/9/25: 90%->100 / Impacted TSs and TRs: 32.290; 32.291
- 593: 24/1/25: WID:RP-242413->RP-242459; 3/4/25: WID:RP-242459->RP-250767; 29/9/25: WID:RP-250767->RP-252083
- 594: 6/12/24: FCD:06/06/2025->09/09/2025; Compl:0%->70%; Stat Rep: ->RP-242580; ; 6/3/25: FCD:20/05/2025->09/09/2025; Compl:70%->99%; WID: RP-242459->RP-250330; Stat Rep: RP-242580->RP-250329; ; 6/6/25: Stat Rep: RP-250329->RP-251012; ; 11/9/25: Compl:99%->100%; Stat Rep: RP-251012->RP-252106;
- 595: 6/12/24: Stat Rep: ->RP-242580; ; 6/3/25: WID: RP-242459->RP-250330; Stat Rep: RP-242580->RP-250329; ; 6/6/25: Compl:0%->99%; Stat Rep: RP-250329->RP-251012; ; 11/9/25: Compl:99%->100%; Stat Rep: RP-251012->RP-252106;
- 597: 24/1/25: WID:RP-242414->RP-243247; 18/7/25: WID:RP-243247->RP-251552
- 598: 6/12/24: Compl:0%->50%; Stat Rep: ->RP-243246; ; 6/3/25: FCD:16/03/2025->06/06/2025; Compl:50%->80%; Stat Rep: RP-243246->RP-250047; ; 6/6/25: FCD:Fri 06/06/25->Tue 09/09/25; Compl:80%->99%; Stat Rep: RP-250047->RP-251554; ; 30/9/25: 99%->100
- 599: 6/12/24: Stat Rep: ->RP-243246; ; 6/3/25: Stat Rep: RP-243246->RP-250047; ; 6/6/25: FCD:Tue 09/09/25->Fri 06/06/25; Compl:0%->100%; Stat Rep: RP-250047->RP-251554;
- 600: ; 6/6/25: 0%->40; 12/9/25: 40%->100 / Impacted TSs and TRs: 28.537; 28.550; 28.532; 32.421; 32.422; 32.423; 28.404; 28.405; 28.622; 28.623
- 601: 4/9/24: 0%->40; 26/9/24: 23.700-09 added;; 5/12/24: 40%->100; 5/12/24: FCD:06/06/2025->12/24; 5/12/24: 40%->100 / Impacted TSs and TRs: 23.700-09
- 602: ; 5/12/24: 0%->100; 5/12/24: 100%->65; 6/3/25: 65%->100 / Impacted TSs and TRs: 23.180
- 603: ; 12/6/24: 0%->100 / Impacted TSs and TRs: 22.261
- 604: ; 12/6/24: 0%->100 / Impacted TSs and TRs: 22.261
- 605: ; 17/9/25: 0%->100 / Impacted TSs and TRs: 33.501
- 606: 5/12/24: 0%->80; 6/6/25: 80%->100

| ID | WBS | Task | Duration | Start | Finish | Complete | Constraint | Resources | Work | Actual work | Acronym | PCG approved | WI rapporteur name | WI rapporteur e-mail | Release | TSG approved |
| --- | --- | --- | --- | --- | --- | --- | --- | --- | --- | --- | --- | --- | --- | --- | --- | --- |
| 607 | 328 | **Enhancement of support for Edge Computing in 5G Core network - Phase 3** | 636.62d | 2024-01-04 A | 2025-09-09 A | 100% |  |  | 10526h | 10526h | eEDGE_5GC_Ph3 | 53 | Changhong Shan (Intel) | chang.hong.shan@intel.com | Rel-19 | 104 |
| 608 | 328.1 | Study on Enhancement of support for Edge Computing in 5G Core network - Phase 3 | 180d | 2024-01-04 A | 2024-09-09 A | 100% | finish no earlier than 2024-09-09 | S2 | 1440h | 1440h | FS_eEDGE_5GC_Ph3 | 52 | Changhong Shan (Intel) | chang.hong.shan@intel.com | Rel-19 | 102 |
| 609 | 328.2 | Study on Security Aspects of Enhancement of Support for Edge Computing in 5GC phase 3 | 183d | 2024-04-02 A | 2024-12-12 A | 100% | finish no earlier than 2024-12-12 | S3 | 1464h | 1464h | FS_EDGE_Ph3 | 52 | Ge Yao, | yaog9@chinaunicom.cn | Rel-19 | 103 |
| 610 | 328.3 | Security Aspects of Enhancement of Support for Edge Computing in 5GC phase 3 | 63d | 2025-01-02 A | 2025-03-03 A | 100% | finish no earlier than 2025-03-03 | S3 | 504h | 504h | EDGE_Ph3 | 54 | TBD |  | Rel-19 | 106 |
| 611 | 328.4 | Stage 2 of Enhancement of support for Edge Computing in 5G Core network - Phase 3 | 132d | 2024-06-12 A | 2024-12-12 A | 100% | finish no earlier than 2024-12-12 | S2 | 1056h | 1056h | eEDGE_5GC_Ph3 | 53 | Meghashree Dattatri Kedalagudde (Intel); | meghashree.dattatri.kedalagudde@intel.com | Rel-19 | 105 |
| 612 | 328.5 | **CT aspects of Enhancement of support for Edge Computing in 5G Core network - Phase 3** | 378.88d | 2024-09-09 A | 2025-09-09 A | 100% |  |  | 6062h | 6062h | eEDGE_5GC_Ph3 | 53 | Landais, Bruno, Nokia | bruno.landais@nokia.com | Rel-19 | 105 |
| 613 | 328.5.1 | CT3 aspects of Enhancement of support for Edge Computing in 5G Core network - Phase 3 | 378.88d | 2024-09-09 A | 2025-09-09 A | 100% | finish no earlier than 2025-09-09 | C3 | 3031h | 3031h | eEDGE_5GC_Ph3 | 53 | Landais, Bruno, Nokia | bruno.landais@nokia.com | Rel-19 | 105 |
| 614 | 328.5.2 | CT4 aspects of Enhancement of support for Edge Computing in 5G Core network - Phase 3 | 378.88d | 2024-09-09 A | 2025-09-09 A | 100% | finish no earlier than 2025-09-09 | C4 | 3031h | 3031h | eEDGE_5GC_Ph3 | 53 | Landais, Bruno, Nokia | bruno.landais@nokia.com | Rel-19 | 105 |
| 615 | 329 | **Multi-Access (ATSSS_Ph4)** | 636.62d | 2024-01-04 A | 2025-09-09 A | 100% |  |  | 13053h | 13053h | MASSS | 53 | Krisztian Kiss (Apple), | krisztian@apple.com | Rel-19 | 105 |
| 616 | 329.1 | Study on Multi-Access (DualSteer and ATSSS_Ph4) | 180d | 2024-01-04 A | 2024-09-09 A | 100% | finish no earlier than 2024-09-09 | S2 | 1440h | 1440h | FS_MASSS | 52 | Krisztian Kiss (Apple) | krisztian@apple.com | Rel-19 | 102 |
| 617 | 329.2 | Study on security aspects for Multi-Access (DualSteer + ATSSS Ph-4) | 183d | 2024-04-02 A | 2024-12-12 A | 100% | start no earlier than 2024-04-02 | S3 | 1464h | 1464h | FS_MASSS_Sec | 52 | Kolekar, Abhijeet (Intel) | abhijeet.kolekar@intel.com | Rel-19 | 103 |
| 618 | 329.3 | Stage 2 of Multi-Access (ATSSS_Ph4) | 132d | 2024-06-12 A | 2024-12-12 A | 100% | finish no earlier than 2024-12-12 | S2 | 1056h | 1056h | MASSS | 53 | Krisztian Kiss (Apple), | krisztian@apple.com | Rel-19 | 104 |
| 619 | 329.4 | **CT aspects of Multi-Access (ATSSS_Ph4)** | 378.88d | 2024-09-09 A | 2025-09-09 A | 100% |  |  | 9093h | 9093h | MASSS | 53 | Gupta, Vivek, Apple | vivek_g_gupta@apple.com | Rel-19 | 105 |
| 620 | 329.4.1 | CT1 aspects of Multi-Access (ATSSS_Ph4) | 378.88d | 2024-09-09 A | 2025-09-09 A | 100% | finish no earlier than 2025-09-09 | C1 | 3031h | 3031h | MASSS | 53 | Gupta, Vivek, Apple | vivek_g_gupta@apple.com | Rel-19 | 105 |
| 621 | 329.4.2 | CT3 aspects of Multi-Access (ATSSS_Ph4) | 378.88d | 2024-09-09 A | 2025-09-09 A | 100% | finish no earlier than 2025-09-09 | C3 | 3031h | 3031h | MASSS | 53 | Gupta, Vivek, Apple | vivek_g_gupta@apple.com | Rel-19 | 105 |
| 622 | 329.4.3 | CT4 aspects of Multi-Access (ATSSS_Ph4) | 378.88d | 2024-09-09 A | 2025-09-09 A | 100% | finish no earlier than 2025-09-09 | C4 | 3031h | 3031h | MASSS | 53 | Gupta, Vivek, Apple | vivek_g_gupta@apple.com | Rel-19 | 105 |
| 623 | 330 | **System architecture for Next Generation Real time Communication services Phase 2** | 746.38d | 2023-09-20 A | 2025-09-09 A | 100% |  |  | 19910h | 19910h | NG_RTC_Ph2 | 53 | Yi Jiang, China Mobile | jiangyi at chinamobile dot com | Rel-19 | 105 |
| 624 | 330.1 | Study on system architecture for next generation real time communication services phase 2 | 256d | 2023-09-20 A | 2024-09-09 A | 100% | finish no earlier than 2024-09-09 | S2 | 2048h | 2048h | FS_NG_RTC_Ph2 | 51 | Yi Jiang (China Mobile) | jiangyi@chinamobile.com | Rel-19 | 101 |
| 625 | 330.2 | Study on Charging aspects of next generation real time communication services phase 2 | 189d | 2024-06-12 A | 2024-12-11 A | 100% | finish no earlier than 2025-03-03 | S5 | 1512h | 1512h | FS_NG_RTC_Ph2_CH | 53 | Chen Ai, China Mobile | chenai@chinamobile.com | Rel-19 | 104 |
| 626 | 330.3 | Stage 2 of System architecture for Next Generation Real time Communication services Phase 2 | 471.12d | 2024-06-12 A | 2025-09-09 A | 100% | finish no earlier than 2025-09-09 | S2 | 3769h | 3769h | NG_RTC_Ph2 | 53 | Yi Jiang, China Mobile | jiangyi at chinamobile dot com | Rel-19 | 104 |
| 627 | 330.4 | **CT aspects of System architecture for Next Generation Real time Communication services Phase 2** | 378.88d | 2024-09-09 A | 2025-09-09 A | 100% |  |  | 11189h | 11189h | NG_RTC_Ph2 | 53 | Chen Xu, China Mobile | chenxu@chinamobile.com | Rel-19 | 105 |
| 628 | 330.4.1 | CT1 aspects of System architecture for Next Generation Real time Communication services Phase 2 | 378.88d | 2024-09-09 A | 2025-09-09 A | 100% | finish no earlier than 2025-09-09 | C1 | 3031h | 3031h | NG_RTC_Ph2 | 53 | Chen Xu, China Mobile | chenxu@chinamobile.com | Rel-19 | 105 |
| 629 | 330.4.2 | CT3 aspects of System architecture for Next Generation Real time Communication services Phase 2 | 378.88d | 2024-09-09 A | 2025-09-09 A | 100% | finish no earlier than 2025-09-09 | C3 | 3031h | 3031h | NG_RTC_Ph2 | 53 | Chen Xu, China Mobile | chenxu@chinamobile.com | Rel-19 | 105 |
| 630 | 330.4.3 | CT4 aspects of System architecture for Next Generation Real time Communication services Phase 2 | 378.88d | 2024-09-09 A | 2025-09-09 A | 100% | finish no earlier than 2025-09-09 | C4 | 3031h | 3031h | NG_RTC_Ph2 | 53 | Chen Xu, China Mobile | chenxu@chinamobile.com | Rel-19 | 105 |
| 631 | 330.4.4 | CT6 aspects of System architecture for Next Generation Real time Communication services Phase 2 | 262d | 2024-12-30 A | 2025-09-09 A | 100% | finish no earlier than 2025-09-09 | C6 | 2096h | 2096h | NG_RTC_Ph2 | 53 | Chen Xu, China Mobile | chenxu@chinamobile.com | Rel-19 | 105 |
| 632 | 330.5 | Charging aspects of next generation real time communication services phase 2 | 174d | 2025-03-26 A | 2025-09-09 A | 100% | start no earlier than 2025-03-26 | S5 | 1392h | 1392h | NG_RTC_Ph2-CH | 54 | Chen Ai, China Mobile | chenai@chinamobile.com | Rel-19 | 107 |

Notes:
- 607: ; 26/9/24: WID:SP-240996->SP-241284; 6/3/25: 82%-> / Impacted TSs and TRs: 23.501; 23.502; 23.548; 23.503
- 608: 14/3/24: 0%->50; 13/6/24: FCD:06/06/2024->/24; 13/6/24: 50%->90; 16/7/24: WID:SP-231796->SP-240962; 4/9/24: 90%->100
- 609: 3/4/24: 33.749 added;; 13/6/24: 0%->30; 5/9/24: 30%->60; 5/12/24: 60%->95; 6/3/25: 95%->100; 5/6/25: 100%->100 / Impacted TSs and TRs: 33.749
- 610: 17/9/25: 0%->100 / Impacted TSs and TRs: 33.501; 33.558
- 611: ; 4/9/24: 0%->30; 5/12/24: 30%->97; 8/1/25: WID:SP-240996->SP-241505 (Rapp change); 6/3/25: 97%->100 / Impacted TSs and TRs: 23.501; 23.502; 23.548; 23.503
- 612: Impacted TSs and TRs: 29.244, 29.502, 29.503, 29.504, 29.510, 29.556 , 29.571, 29.512, 29.513, 29.514, 29.519, 29.522, 29.591, 29.244, 29.502, 29.503, 29.504, 29.510, 29.556 , 29.571, 29.512, 29.513, 29.514, 29.519, 29.522, 29.591, 29.518
- 615: Impacted TSs and TRs: 23.501; 23.502; 23.503
- 616: 14/3/24: 0%->30; 2/4/24: WID:SP-231802->SP-240467; 2/4/24: FCD:09/09/2024->/24; 13/6/24: FCD:06/06/2024->/24; 13/6/24: 30%->70; 4/9/24: 70%->100
- 617: 3/4/24: 33.754 added;; 13/6/24: 0%->45; 5/9/24: 45%->95; 5/12/24: 95%->100; 6/3/25: 100%->100 / Impacted TSs and TRs: 33.754
- 618: ; 4/9/24: 0%->50; 26/9/24: WID:SP-240994->SP-241331; 5/12/24: 50%->100 / Impacted TSs and TRs: 23.501; 23.502; 23.503
- 619: Impacted TSs and TRs: 24.193, 24.501, 24.302, 27.007, 29.512, 29.244, 29.571
- 623: ; 16/7/24: WID:SP-240625->SP-240985 / Impacted TSs and TRs: 23.228; 23.502
- 624: 9/23: company-submitted WID, to be corrected; 6/10/23: 23.700-77 added;; 8/12/23: 0%->15; 14/3/24: 15%->45; 13/6/24: FCD:05/06/2024->/24; 13/6/24: 45%->95; 5/12/24: 95%->100 / Impacted TSs and TRs: 23.700-77
- 625: 13/6/24: 0%->10; 4/9/24: 10%->45; 26/9/24: 28.851 added;; 5/12/24: 45%->75; 5/12/24: FCD:12/12/2024->/25; 6/3/25: 75%->100 / Impacted TSs and TRs: 28.851
- 626: ; 16/7/24: WID:SP-240625->SP-240985; 4/9/24: 0%->10; 26/9/24: WID:SP-240985->SP-241384; 5/12/24: 10%->70; 6/3/25: 70%->98; 5/6/25: 98%->99; 4/12/25: 99%->100 / Impacted TSs and TRs: 23.228; 23.502
- 627: Impacted TSs and TRs: 24.186, 24.229, 24.275, 24.607, 29.522, 29.165, 29.175, 29.176, 29.562, 29.364, 29.510, 29.571, 29.328, 29.329, 29.230, 31.102, 31.103
- 632: ; 6/6/25: 0%->70; 27/6/25: WID:SP-250367->SP-250513; 12/9/25: 70%->100 / Impacted TSs and TRs: 32.254; 32.255; 32.260; 32.291; 32.298

| ID | WBS | Task | Duration | Start | Finish | Complete | Constraint | Resources | Work | Actual work | Acronym | PCG approved | WI rapporteur name | WI rapporteur e-mail | Release | TSG approved |
| --- | --- | --- | --- | --- | --- | --- | --- | --- | --- | --- | --- | --- | --- | --- | --- | --- |
| 633 | 331 | **Rel-19 Application Data Analytics Enablement Service** | 286.62d | 2024-12-07 A | 2025-09-09 A | 100% |  |  | 1606h | 1606h | TEI19_ADAES | 54 | Yue, Jing, Ericsson | jing.yue@ericsson.com | Rel-19 | 107 |
| 634 | 331.1 | Stage 2 of Rel-19 Application Data Analytics Enablement Service | 6d | 2024-12-07 A | 2024-12-12 A | 100% | finish no earlier than 2024-12-12 | S6 | 48h | 48h | TEI19_ADAES | 54 | Yue, Jing, Ericsson | jing.yue@ericsson.com | Rel-19 | 106 |
| 635 | 331.2 | **CT aspects of Rel-19 Application Data Analytics Enablement Service** | 194.75d | 2025-03-06 A | 2025-09-09 A | 100% |  |  | 1558h | 1558h | TEI19_ADAES | 54 | Pastushok, Igor, Ericsson | igor.pastushok@ericsson.com | Rel-19 | 107 |
| 636 | 331.2.1 | CT3 aspects of Rel-19 Application Data Analytics Enablement Service | 194.75d | 2025-03-06 A | 2025-09-09 A | 100% | start no earlier than 2025-03-06 | C3 | 1558h | 1558h | TEI19_ADAES | 54 | Pastushok, Igor, Ericsson | igor.pastushok@ericsson.com | Rel-19 | 107 |
| 637 | 332 | **MSISDN verification operation support to Nnef_UEId Service** | 188.12d | 2024-12-07 A | 2025-06-06 A | 100% |  |  | 842h | 842h | TEI19_MVOSNS | 54 | Rohit Abhishek (AT&T) | ra503n@att.com | Rel-19 | 107 |
| 638 | 332.1 | Stage 2 of MSISDN verification operation support to Nnef_UEId Service | 6d | 2024-12-07 A | 2024-12-12 A | 100% | finish no earlier than 2024-12-12 | S2 | 48h | 48h | TEI19_MVOSNS | 54 | Rohit Abhishek (AT&T) | ra503n@att.com | Rel-19 | 106 |
| 639 | 332.2 | **CT aspects of MSISDN verification operation support to Nnef_UEId Service** | 99.25d | 2025-03-03 A | 2025-06-06 A | 100% |  |  | 794h | 794h | TEI19_MVOSNS | 54 | Shahram Mohajeri, AT&T | sm7084@att.com | Rel-19 | 107 |
| 640 | 332.2.1 | CT3 aspects of MSISDN verification operation support to Nnef_UEId Service | 99.25d | 2025-03-03 A | 2025-06-06 A | 100% | finish no earlier than 2025-06-06 | C3 | 794h | 794h | TEI19_MVOSNS | 54 | Shahram Mohajeri, AT&T | sm7084@att.com | Rel-19 | 107 |
| 641 | 333 | **Network Controlled Network Slice Selection** | 286.62d | 2024-12-07 A | 2025-09-09 A | 100% |  |  | 3212h | 3212h | TEI19_SliceSel | 54 | Saito, Koji, KDDI | kj-saitou_at_kddi_dot_com | Rel-19 | 107 |
| 642 | 333.1 | Stage 2 of Network Controlled Network Slice Selection | 6d | 2024-12-07 A | 2024-12-12 A | 100% | finish no earlier than 2024-12-12 | S2 | 48h | 48h | TEI19_SliceSel | 54 | Saito, Koji, KDDI | kj-saitou_at_kddi_dot_com | Rel-19 | 106 |
| 643 | 333.2 | **CT aspects of Network Controlled Network Slice Selection** | 197.75d | 2025-03-03 A | 2025-09-09 A | 100% |  |  | 3164h | 3164h | TEI19_SliceSel | 54 | Xiaojian Yan, ZTE | yan.xiaojian@zte.com.cn | Rel-19 | 107 |
| 644 | 333.2.1 | CT3 aspects of Network Controlled Network Slice Selection | 197.75d | 2025-03-03 A | 2025-09-09 A | 100% | finish no earlier than 2025-09-09 | C3 | 1582h | 1582h | TEI19_SliceSel | 54 | Xiaojian Yan, ZTE | yan.xiaojian@zte.com.cn | Rel-19 | 107 |
| 645 | 333.2.2 | CT4 aspects of Network Controlled Network Slice Selection | 197.75d | 2025-03-03 A | 2025-09-09 A | 100% | finish no earlier than 2025-09-09 | C4 | 1582h | 1582h | TEI19_SliceSel | 54 | Xiaojian Yan, ZTE | yan.xiaojian@zte.com.cn | Rel-19 | 107 |
| 646 | 334 | **PRU Usage Extension supported by Core Network** | 188.12d | 2024-12-07 A | 2025-06-06 A | 100% |  |  | 608h | 608h | TEI19_PRUE | 54 | Hou, Yunjing, CATT | houyunjing@catt.cn | Rel-19 | 107 |
| 647 | 334.1 | Stage 2 of PRU Usage Extension supported by Core Network | 6d | 2024-12-07 A | 2024-12-12 A | 100% | finish no earlier than 2024-12-12 | S2 | 48h | 48h | TEI19_PRUE | 54 | Hou, Yunjing, CATT | houyunjing@catt.cn | Rel-19 | 106 |
| 648 | 334.2 | **CT aspects of PRU Usage Extension supported by Core Network** | 99.25d | 2025-03-03 A | 2025-06-06 A | 100% |  |  | 560h | 560h | TEI19_PRUE | 54 | Wang, Baixiao, CATT | wangbaixiao@cictmobile.com | Rel-19 | 107 |
| 649 | 334.2.1 | CT4 aspects of PRU Usage Extension supported by Core Network | 70d | 2025-03-03 A | 2025-06-06 A | 100% | finish no earlier than 2025-06-06 | C4 | 560h | 560h | TEI19_PRUE | 54 | Wang, Baixiao, CATT | wangbaixiao@cictmobile.com | Rel-19 | 107 |
| 650 | 335 | **On-demand broadcast of GNSS assistance data** | 544.62d | 2024-04-02 A | 2025-09-09 A | 100% |  |  | 5656h | 5656h | TEI19_OBGAD | 52 | Aihua Li, China Mobile | <liaihua@chinamobile.com> | Rel-19 | 103 |
| 651 | 335.1 | Stage 2 of On-demand broadcast of GNSS assistance data | 183d | 2024-04-02 A | 2024-12-12 A | 100% | start no earlier than 2024-04-02 | S2 | 1464h | 1464h | TEI19_OBGAD | 52 | Aihua Li, China Mobile | <liaihua@chinamobile.com> | Rel-19 | 103 |
| 652 | 335.2 | **CT aspects of On-demand broadcast of GNSS assistance data** | 378.88d | 2024-09-09 A | 2025-09-09 A | 100% |  | C4 | 4192h | 4192h | TEI19_OBGAD | 52 | Rong Wang, China Mobile | wangrongyjy@chinamobile.com | Rel-19 | 103 |
| 653 | 335.2.1 | CT4 aspects of On-demand broadcast of GNSS assistance data | 262d | 2024-09-09 A | 2025-09-09 A | 100% | finish no earlier than 2025-09-09 | C4 | 2096h | 2096h | TEI19_OBGAD | 52 | Rong Wang, China Mobile | wangrongyjy@chinamobile.com | Rel-19 | 103 |
| 654 | 336 | **ATSSS Rule Provisioning via 3GPP access connected to EPC** | 188.12d | 2024-12-07 A | 2025-06-06 A | 100% |  | S2 | 1569h | 1569h | TEI19_ARP3E | 54 | Chunhui Zhu (NEC) | zhu_chunhui@nec.cn | Rel-19 | 106 |
| 655 | 336.1 | Stage 2 of ATSSS Rule Provisioning via 3GPP access connected to EPC | 6d | 2024-12-07 A | 2024-12-12 A | 100% | finish no earlier than 2024-12-12 | S2 | 48h | 48h | TEI19_ARP3E | 54 | Chunhui Zhu (NEC) | zhu_chunhui@nec.cn | Rel-19 | 106 |
| 656 | 336.2 | **CT aspects of ATSSS Rule Provisioning via 3GPP access connected to EPC** | 1d | 2025-06-06 A | 2025-06-06 A | 100% |  | C1 | 16h | 16h | TEI19_ARP3E-CT | 54 | Chunhui Zhu (NEC) | zhu_chunhui@nec.cn | Rel-19 | 106 |
| 657 | 336.2.1 | CT1 aspects of ATSSS Rule Provisioning via 3GPP access connected to EPC | 1d | 2025-06-06 A | 2025-06-06 A | 100% | finish no earlier than 2024-12-12 | C1 | 8h | 8h | TEI19_ARP3E-CT | 54 | Chunhui Zhu (NEC) | zhu_chunhui@nec.cn | Rel-19 | 106 |

Notes:
- 633: Impacted TSs and TRs: 23.436
- 634: ; 3/4/25: 0%->100 / Impacted TSs and TRs: 23.436
- 635: Impacted TSs and TRs: 29.549
- 636: Impacted TSs and TRs: 29.549
- 637: Impacted TSs and TRs: 23.502; 23.501
- 638: ; 26/3/25: 0%->100 / Impacted TSs and TRs: 23.502; 23.501
- 639: Impacted TSs and TRs: 29.522
- 640: Impacted TSs and TRs: 29.522
- 641: Impacted TSs and TRs: 23.501; 23.502; 23.503
- 642: ; 26/3/25: 0%->100 / Impacted TSs and TRs: 23.501; 23.502; 23.503
- 643: Impacted TSs and TRs: 29.522, 29.534, 29.519, 29.507, 29.523, 29.502, 29.504, 29.518
- 647: 26/3/25: 0%->100
- 648: Impacted TSs and TRs: 29.572
- 649: Impacted TSs and TRs: 29.572
- 650: Impacted TSs and TRs: 23.502; 23.273
- 651: ; 4/9/24: 0%->100 / Impacted TSs and TRs: 23.502; 23.273
- 654: ; 26/3/25: 0%->100 / Impacted TSs and TRs: 23.502
- 655: ; 26/3/25: 0%->100 / Impacted TSs and TRs: 23.502
- 656: ; 26/3/25: 0%->100 / Impacted TSs and TRs: 24.193
- 657: ; 26/3/25: 0%->100 / Impacted TSs and TRs: 24.193

| ID | WBS | Task | Duration | Start | Finish | Complete | Actual finish | Constraint | Resources | Work | Actual work | Acronym | PCG approved | Impacted TSs and TRs | WI rapporteur e-mail | Release | TSG approved |
| --- | --- | --- | --- | --- | --- | --- | --- | --- | --- | --- | --- | --- | --- | --- | --- | --- | --- |
| 658 | 337 | **Minimize the Number of Policy Associations** | 269.12d | 2024-06-17 A | 2025-03-03 A | 100% |  |  |  | 4464h | 4464h | TEI19_MINPA | 52 | 23.502; 23.501; 23.503 | belen . pancorbo {@} ericsson . com) | Rel-19 | 103 |
| 659 | 337.1 | Stage 2 of Minimize the Number of Policy Associations | 269.12d | 2024-06-17 A | 2025-03-03 A | 100% |  | finish no earlier than 2025-03-03 | S2 | 1488h | 1488h | TEI19_MINPA | 51 |  | belen . pancorbo {@} ericsson . com) | Rel-19 | 101 |
| 660 | 337.2 | **CT Aspects on Minimize the Number of Policy Associations** | 269.12d | 2024-06-17 A | 2025-03-03 A | 100% |  |  |  | 2976h | 2976h | TEI19_MINPA | 51 | TS 29.503,TS 29.507,TS 29.513,TS 29.518,TS 29.525 | jones.lu@ericsson.com | Rel-19 | 101 |
| 661 | 337.2.1 | CT3 Aspects on Minimize the Number of Policy Associations | 186d | 2024-06-17 A | 2025-03-03 A | 100% |  | finish no earlier than 2025-03-03 | C3 | 1488h | 1488h | TEI19_MINPA | 51 |  | jones.lu@ericsson.com | Rel-19 | 101 |
| 662 | 337.2.2 | CT4 Aspects on Minimize the Number of Policy Associations | 186d | 2024-06-17 A | 2025-03-03 A | 100% |  | finish no earlier than 2025-03-03 | C4 | 1488h | 1488h | TEI19_MINPA | 51 |  | jones.lu@ericsson.com | Rel-19 | 101 |
| 663 | 338 | **Spending Limits for UE Policies in Roaming scenario** | 284.75d | 2024-03-13 A | 2024-12-12 A | 100% |  |  |  | 1048h | 1048h | TEI19_SLUPiR | 52 | 23.502; 23.501; 23.503 | uri dot baniel at oracle dot com | Rel-19 | 103 |
| 664 | 338.1 | Stage 2 of Spending Limits for UE Policies in Roaming scenario | 62d | 2024-03-13 A | 2024-06-06 A | 100% |  | finish no earlier than 2024-06-06 | S2 | 496h | 496h | TEI19_SLUPiR | 52 | 23.502; 23.501; 23.503 | uri dot baniel at oracle dot com | Rel-19 | 103 |
| 665 | 338.2 | **CT aspects of Spending Limits for UE Policies in Roaming scenario** | 98.25d | 2024-09-09 A | 2024-12-12 A | 100% |  |  |  | 552h | 552h | TEI19_SLUPiR | 52 |  | suny20@chinatelecom.cn | Rel-19 | 103 |
| 666 | 338.2.1 | CT3 aspects of Spending Limits for UE Policies in Roaming scenario | 69d | 2024-09-09 A | 2024-12-12 A | 100% |  | finish no earlier than 2024-12-12 | C3 | 552h | 552h | TEI19_SLUPiR | 52 |  | suny20@chinatelecom.cn | Rel-19 | 103 |
| 667 | 339 | **Enhancing Parameter Provisioning with static UE IP address and UP security policy** | 547.38d | 2023-12-26 A | 2025-06-06 A | 100% |  |  |  | 7019h | 7019h | TEI19_IP_SP_EXP | 52 | 23.501; 23.502 | stefan . rommer @ ericsson . com) | Rel-19 | 103 |
| 668 | 339.1 | Stage 2 of Enhancing Parameter Provisioning with static UE IP address and UP security policy | 365.25d | 2023-12-26 A | 2024-12-12 A | 100% |  | finish no earlier than 2024-12-12 | S2 | 2040h | 2040h | TEI19_IP_SP_EXP | 51 |  | stefan . rommer @ ericsson . com) | Rel-19 | 101 |
| 669 | 339.2 | **CT aspects of Enhancing Parameter Provisioning with static UE IP address and UP security policy** | 367.38d | 2024-06-17 A | 2025-06-06 A | 100% |  |  |  | 4979h | 4979h | TEI19_IP_SP_EXP | 51 | 29.503,29.522,29.503,29.522 | maria.liang@ericsson.co | Rel-19 | 101 |
| 670 | 339.2.1 | CT3 aspects of Enhancing Parameter Provisioning with static UE IP address and UP security policy | 367.38d | 2024-06-17 A | 2025-06-06 A | 100% |  | finish no earlier than 2025-06-06 | C3 | 2939h | 2939h | TEI19_IP_SP_EXP | 51 |  | maria.liang@ericsson.co | Rel-19 | 101 |
| 671 | 339.2.2 | CT4 aspects of Enhancing Parameter Provisioning with static UE IP address and UP security policy | 255d | 2024-06-17 A | 2025-06-06 A | 100% |  | finish no earlier than 2025-06-06 | C4 | 2040h | 2040h | TEI19_IP_SP_EXP | 51 |  | maria.liang@ericsson.co | Rel-19 | 101 |
| 672 | 340 | Multiple Location Procedure for Emergency LCS Routing | 197d | 2024-03-13 A | 2024-12-12 A | 100% |  | finish no earlier than 2024-12-12 | S2 | 1576h | 1576h | TEI19_MLR4RTR | 52 | 23.273 | Simon<dot>Ca<at> nokia<dash>sbell<dot>com | Rel-19 | 103 |
| 673 | 341 | Roaming traffic offloading via session breakout in HPLMN | 183d | 2024-04-02 A | 2024-12-12 A | 100% |  | start no earlier than 2024-04-02 | S2 | 1464h | 1464h | TEI19_HSBO | 52 | 23.501 | hs1207.kim@samsung.com | Rel-19 | 103 |
| 674 | 342 | **Deferred 5GC-MT-LR Procedure for Periodic Location Events based NRPPa Periodic Measurement Reports** | 368.62d | 2024-03-13 A | 2025-03-03 A | 100% |  |  |  | 2865h | 2865h | TEI19_DLPMR | 52 | 23.273 | richard.batorfi@ericsson.com | Rel-19 | 103 |
| 675 | 342.1 | Deferred 5GC-MT-LR Procedure for Periodic Location Events based NRPPa Periodic Measurement Reports | 197d | 2024-03-13 A | 2024-12-12 A | 100% |  | finish no earlier than 2024-12-12 | S2 | 1576h | 1576h | TEI19_DLPMR | 52 | 23.273 | richard.batorfi@ericsson.com | Rel-19 | 103 |
| 676 | 342.2 | **CT aspects of Deferred 5GC-MT-LR Procedure for Periodic Location Events based NRPPa Periodic Measurement Reports** | 66d | 2024-12-02 A | 2025-02-03 | 100% | 2025-03-03 |  | C4 | 1289h | 1289h | TEI19_DLPMR | 52 | 29.515, 29.518, 29.572 | jones.lu@ericsson.com | Rel-19 | 103 |
| 677 | 342.2.1 | CT4 aspects of Deferred 5GC-MT-LR Procedure for Periodic Location Events based NRPPa Periodic Measurement Reports | 95.12d | 2024-12-02 A | 2025-03-03 A | 100% |  | finish no earlier than 2025-03-03 | C4 | 761h | 761h | TEI19_DLPMR | 52 |  | jones.lu@ericsson.com | Rel-19 | 103 |
| 678 | 343 | **QoS monitoring enhancement** | 446.12d | 2024-04-02 A | 2025-06-06 A | 100% |  |  |  | 4870h | 4870h | TEI19_QME | 52 | 23.501; 23.502 | <liaihua@chinamobile.com> | Rel-19 | 103 |
| 679 | 343.1 | Stage 2 of QoS monitoring enhancement | 48d | 2024-04-02 A | 2024-06-06 A | 100% |  | finish no earlier than 2024-06-06 | S2 | 384h | 384h | TEI19_QME | 52 | 23.501; 23.502 | <liaihua@chinamobile.com> | Rel-19 | 103 |
| 680 | 343.2 | **CT aspects of QoS monitoring enhancement** | 280.38d | 2024-09-09 A | 2025-06-06 A | 100% |  |  |  | 4486h | 4486h | TEI19_QME | 52 | 29.122, 29.502, 29.512, 29.514, 29.522, 29.565 | huangzhenning@chinamobile.com | Rel-19 | 103 |
| 681 | 343.2.1 | CT3 aspects of QoS monitoring enhancement | 280.38d | 2024-09-09 A | 2025-06-06 A | 100% |  | finish no earlier than 2025-06-06 | C3 | 2243h | 2243h | TEI19_QME | 52 |  | huangzhenning@chinamobile.com | Rel-19 | 103 |
| 682 | 343.2.2 | CT4 aspects of QoS monitoring enhancement | 280.38d | 2024-09-09 A | 2025-06-06 A | 100% |  | finish no earlier than 2025-06-06 | C4 | 2243h | 2243h | TEI19_QME | 52 |  | huangzhenning@chinamobile.com | Rel-19 | 103 |

Notes:
- 658: WI rapporteur name: Ericsson, Belen Pancorbo
- 659: 13/6/24: 0%->100 / WI rapporteur name: Ericsson, Belen Pancorbo
- 660: WI rapporteur name: Jones Lu, Ericsson
- 661: WI rapporteur name: Jones Lu, Ericsson
- 662: WI rapporteur name: Jones Lu, Ericsson
- 663: ; 13/6/24: FCD:12/12/2024->/24; 13/6/24: 0%->100 / WI rapporteur name: uri baniel, oracle
- 664: ; 13/6/24: FCD:12/12/2024->/24; 13/6/24: 0%->100 / WI rapporteur name: uri baniel, oracle
- 665: WI rapporteur name: SUN, Yue, China Telecom
- 666: WI rapporteur name: SUN, Yue, China Telecom
- 667: WI rapporteur name: Stefan Rommer, Ericsson
- 668: 19/6/24: FCD:06/06/2025->12/20; 4/9/24: 0%->100 / WI rapporteur name: Stefan Rommer, Ericsson
- 669: WI rapporteur name: Maria Tianmei, Liang, Ericsson
- 670: WI rapporteur name: Maria Tianmei, Liang, Ericsson
- 671: WI rapporteur name: Maria Tianmei, Liang, Ericsson
- 672: ; 5/12/24: 0%->100 / WI rapporteur name: Simon Cai (Nokia Shanghai-Bell)Simon<dot>Ca<at> nokia<dash>sbell<dot>com
- 673: ; 5/12/24: 0%->100 / WI rapporteur name: Hyesung Kim, Samsung
- 674: WI rapporteur name: Richard, Batorfi, Ericsson,
- 675: ; 5/12/24: 0%->100 / WI rapporteur name: Richard, Batorfi, Ericsson,
- 676: WI rapporteur name: Jones Lu, Ericsson
- 677: WI rapporteur name: Jones Lu, Ericsson
- 678: ; 13/6/24: FCD:12/12/2024->/24; 13/6/24: 0%->100; 16/7/24: WID:SP-240489->SP-240961 / WI rapporteur name: Aihua Li, China Mobile
- 679: ; 13/6/24: FCD:12/12/2024->/24; 13/6/24: 0%->100; 16/7/24: WID:SP-240489->SP-240961 / WI rapporteur name: Aihua Li, China Mobile
- 680: WI rapporteur name: Huang, Zhenning, China Mobile
- 681: WI rapporteur name: Huang, Zhenning, China Mobile
- 682: WI rapporteur name: Huang, Zhenning, China Mobile

| ID | WBS | Task | Duration | Start | Finish | Complete | Constraint | Resources | Work | Actual work | Acronym | PCG approved | WI rapporteur name | WI rapporteur e-mail | Release | TSG approved | Status Report |
| --- | --- | --- | --- | --- | --- | --- | --- | --- | --- | --- | --- | --- | --- | --- | --- | --- | --- |
| 683 | 344 | **Subscription control for reference time distribution in EPS** | 284.75d | 2024-03-13 A | 2024-12-12 A | 100% |  |  | 1648h | 1648h | TEI19_TIME_SUB_EPS | 52 | Sebastian Speicher, Qualcomm | speicher AT qti DOT qualcomm DOT com) | Rel-19 | 103 |  |
| 684 | 344.1 | Stage 2 of Subscription control for reference time distribution in EPS | 197d | 2024-03-13 A | 2024-12-12 A | 100% | finish no earlier than 2024-12-12 | S2 | 1576h | 1576h | TEI19_TIME_SUB_EPS | 52 | Sebastian Speicher, Qualcomm | speicher AT qti DOT qualcomm DOT com) | Rel-19 | 103 |  |
| 685 | 344.2 | **CT aspects of Subscription control for reference time distribution in EPS** | 11.25d | 2024-12-02 A | 2024-12-12 A | 100% |  |  | 72h | 72h | TEI19_TIME_SUB_EPS | 52 | Hanna Lim, Qualcomm Incorporated | hannalim@qti.qualcomm.com | Rel-19 | 103 |  |
| 686 | 344.2.1 | CT4 aspects of Subscription control for reference time distribution in EPS | 9d | 2024-12-02 A | 2024-12-12 A | 100% | finish no earlier than 2024-12-12 | C4 | 72h | 72h | TEI19_TIME_SUB_EPS | 52 | Hanna Lim, Qualcomm Incorporated | hannalim@qti.qualcomm.com | Rel-19 | 103 |  |
| 687 | 345 | **Providing per-subscriber VLAN instructions from UDM and DN-AAA** | 547.38d | 2023-12-26 A | 2025-06-06 A | 100% |  |  | 7918h | 7918h | TEI19_VLANSUB | 52 | Stefan Rommer, Ericsson | stefan . rommer @ ericsson . com) | Rel-19 | 103 |  |
| 688 | 345.1 | Stage 2 of Providing per-subscriber VLAN instructions from UDM and DN-AAA | 365.25d | 2023-12-26 A | 2024-12-12 A | 100% | finish no earlier than 2024-12-12 | S2 | 2040h | 2040h | TEI19_VLANSUB | 51 | Stefan Rommer, Ericsson | stefan . rommer @ ericsson . com) | Rel-19 | 101 |  |
| 689 | 345.2 | **CT aspects of Providing per-subscriber VLAN instructions from UDM and DN-AAA** | 367.38d | 2024-06-17 A | 2025-06-06 A | 100% |  |  | 5878h | 5878h | TEI19_VLANSUB | 51 | Maria Tianmei, Liang, Ericsson | maria.liang@ericsson.co | Rel-19 | 101 |  |
| 690 | 345.2.1 | CT3 aspects of Providing per-subscriber VLAN instructions from UDM and DN-AAA | 367.38d | 2024-06-17 A | 2025-06-06 A | 100% | finish no earlier than 2025-06-06 | C3 | 2939h | 2939h | TEI19_VLANSUB | 51 | Maria Tianmei, Liang, Ericsson | maria.liang@ericsson.co | Rel-19 | 101 |  |
| 691 | 345.2.2 | CT4 aspects of Providing per-subscriber VLAN instructions from UDM and DN-AAA | 367.38d | 2024-06-17 A | 2025-06-06 A | 100% | finish no earlier than 2025-06-06 | C4 | 2939h | 2939h | TEI19_VLANSUB | 51 | Maria Tianmei, Liang, Ericsson | maria.liang@ericsson.co | Rel-19 | 101 |  |
| 692 | 346 | **NF discovery and selection by target PLMN** | 544.62d | 2024-04-02 A | 2025-09-09 A | 100% |  |  | 3415h | 3415h | TEI19_NFsel_by_tPLMN | 52 | Dr. Thomas Belling, Nokia, | thomas (dot) belling (at) nokia (dot) com | Rel-19 | 103 |  |
| 693 | 346.1 | Stage 2 of NF discovery and selection by target PLMN | 48d | 2024-04-02 A | 2024-06-06 A | 100% | finish no earlier than 2024-06-06 | S2 | 384h | 384h | TEI19_NFsel_by_tPLMN | 52 | Dr. Thomas Belling, Nokia, | thomas (dot) belling (at) nokia (dot) com | Rel-19 | 103 |  |
| 694 | 346.2 | **CT aspects of NF discovery and selection by target PLMN** | 378.88d | 2024-09-09 A | 2025-09-09 A | 100% |  |  | 3031h | 3031h | TEI19_NFsel_by_tPLMN | 52 | Landais, Bruno, Nokia | bruno.landais@nokia.com | Rel-19 | 103 |  |
| 695 | 346.2.1 | CT4 aspects of NF discovery and selection by target PLMN | 378.88d | 2024-09-09 A | 2025-09-09 A | 100% | finish no earlier than 2025-09-09 | C4 | 3031h | 3031h | TEI19_NFsel_by_tPLMN | 52 | Landais, Bruno, Nokia | bruno.landais@nokia.com | Rel-19 | 103 |  |
| 696 | 347 | **Integrated Sensing and Communication** | 665.88d | 2022-03-10 A | 2023-12-12 A | 100% |  |  | 4224h | 4224h | Sensing | 51 | Aleksiev, Vasil, Deutsche Telekom AG | vasil.aleksiev@magenta.at | Rel-19 | 100 |  |
| 697 | 347.1 | Study on Integrated Sensing and Communication | 393d | 2022-03-10 A | 2023-09-09 A | 100% | finish no earlier than 2023-09-09 | S1 | 3144h | 3144h | FS_Sensing | 48 | Aleksiev, Vasil, Deutsche Telekom | Vasil.Aleksiev@magenta.at | Rel-19 | 95 |  |
| 698 | 347.2 | Stage 1 of Integrated Sensing and Communication | 135d | 2023-06-08 A | 2023-12-12 A | 100% | finish no earlier than 2023-12-12 | S1 | 1080h | 1080h | Sensing | 51 | Aleksiev, Vasil, Deutsche Telekom AG | vasil.aleksiev@magenta.at | Rel-19 | 100 |  |
| 699 | 348 | Study on channel modelling for Integrated Sensing And Communication (ISAC) for NR | 560.88d | 2023-12-13 A | 2025-06-06 A | 100% | finish no earlier than 2025-06-06 | R1 | 4487h | 4487h | FS_Sensing_NR | 52 | Yingyang Li, Jerome Vogedes, Xiaomi, AT&T | liyingyang@xiaomi.com, jerome.vogedes@att.com | Rel-19 | 102 | RP-251474 |
| 700 | 349 | **Uncrewed Aerial System Phase 3** | 1238.25d | 2022-06-02 A | 2025-09-09 A | 100% |  |  | 28819h | 28819h | UAS_Ph3 | 51 | Pengtai Qin , China Mobile | qinpengtai@chinamobile.com | Rel-19 | 100 |  |
| 701 | 349.1 | Study on (Stage 1 of) UAV Phase 3 | 333d | 2022-06-02 A | 2023-09-09 A | 100% | finish no earlier than 2023-09-09 | S1 | 2664h | 2664h | FS_UAV_Ph3 | 49 | Pengtai Qin , China Mobile | qinpengtai@chinamobile.com | Rel-19 | 96 |  |
| 702 | 349.2 | Study on (Stage 2 of) Phase 3 for UAS, UAV and UAM | 180d | 2024-01-04 A | 2024-09-09 A | 100% | finish no earlier than 2024-09-09 | S2 | 1440h | 1440h | FS_UAS_Ph3 | 52 | LaeYoung Kim (LG Electronics) | laeyoung.kim@lge.com | Rel-19 | 102 |  |
| 703 | 349.3 | Stage 1 of Uncrewed Aerial System Phase 3 | 135d | 2023-06-08 A | 2023-12-12 A | 100% | finish no earlier than 2023-12-12 | S1 | 1080h | 1080h | UAS_Ph3 | 51 | Pengtai Qin , China Mobile | qinpengtai@chinamobile.com | Rel-19 | 100 |  |
| 704 | 349.4 | (Stage 2 of) UAS, UAV and UAM Phase 3 | 132d | 2024-06-12 A | 2024-12-12 A | 100% | finish no earlier than 2024-12-12 | S2 | 1056h | 1056h | UAS_Ph3 | 53 | LaeYoung Kim (LG Electronics) | laeyoung.kim@lge.com | Rel-19 | 104 |  |
| 705 | 349.5 | **CT aspects of UAS, UAV and UAM Phase 3** | 378.88d | 2024-09-09 A | 2025-09-09 A | 100% |  |  | 9093h | 9093h | UAS_Ph3 | 53 | Sunhee Kim, LG Electronics | sunhee.kim@lge.com | Rel-19 | 105 |  |
| 706 | 349.5.1 | CT1 aspects of UAS, UAV and UAM Phase 3 | 378.88d | 2024-09-09 A | 2025-09-09 A | 100% | finish no earlier than 2025-09-09 | C1 | 3031h | 3031h | UAS_Ph3 | 53 | Sunhee Kim, LG Electronics | sunhee.kim@lge.com | Rel-19 | 105 |  |
| 707 | 349.5.2 | CT3 aspects of UAS, UAV and UAM Phase 3 | 378.88d | 2024-09-09 A | 2025-09-09 A | 100% | finish no earlier than 2025-09-09 | C3 | 3031h | 3031h | UAS_Ph3 | 53 | Sunhee Kim, LG Electronics | sunhee.kim@lge.com | Rel-19 | 105 |  |
| 708 | 349.5.3 | CT4 aspects of UAS, UAV and UAM Phase 3 | 378.88d | 2024-09-09 A | 2025-09-09 A | 100% | finish no earlier than 2025-09-09 | C4 | 3031h | 3031h | UAS_Ph3 | 53 | Sunhee Kim, LG Electronics | sunhee.kim@lge.com | Rel-19 | 105 |  |
| 709 | 349.6 | Security of Uncrewed Aerial System Phase 3 | 63d | 2025-01-02 A | 2025-03-03 A | 100% | finish no earlier than 2025-03-03 | S3 | 504h | 504h | UAS_Ph3_Sec | 54 | Markus Hanhisalo, Ericsson | markus.hanhisalo@ericsson.com | Rel-19 | 106 |  |
| 710 | 349.7 | Charging for Uncrewed Aerial Systems Phase 3 | 174d | 2025-03-26 A | 2025-09-09 A | 100% | start no earlier than 2025-03-26 | S5 | 1392h | 1392h | UAS_Ph3-CH | 54 | Jia Dong, China Mobile | dongjia@chinamobile.com | Rel-19 | 107 |  |
| 711 | 349.8 | Application Architecture for UAS applications Phase 3 | 334d | 2023-09-07 A | 2024-12-12 A | 100% | finish no earlier than 2024-12-12 | S6 | 2672h | 2672h | UASAPP_Ph3 | 51 | Roy, Michel, InterDigital | michel.roy@interdigital.com | Rel-19 | 101 |  |

Notes:
- 683: ; 4/9/24: 0%->100
- 684: ; 4/9/24: 0%->100 / Impacted TSs and TRs: 23.401
- 685: Impacted TSs and TRs: 29.272, 29.274, 29.230, 23.008
- 687: Impacted TSs and TRs: 23.501; 23.502
- 688: 19/6/24: FCD:06/06/2025->12/20; 5/12/24: 0%->100
- 689: Impacted TSs and TRs: 29.503,29.561,29.230,29.244
- 692: ; 13/6/24: FCD:12/12/2024->/24; 13/6/24: 0%->100 / Impacted TSs and TRs: 23.501; 23.502
- 693: ; 13/6/24: FCD:12/12/2024->/24; 13/6/24: 0%->100 / Impacted TSs and TRs: 23.501; 23.502
- 696: 6/9/23: 0%->80; 8/12/23: 80%->100 / Impacted TSs and TRs: 22.137
- 697: 5/4/22: 22.837 added;; 4/6/22: 0%->10; 21/6/22: WID:SP-220084->SP-220717; 9/9/22: 10%->40; 10/12/22: 40%->65; 17/3/23: 65%->80; 8/6/23: 80%->90; 8/6/23: FCD:06/06/2023->09/20; 6/9/23: 90%->100 / Impacted TSs and TRs: 22.837
- 698: 6/9/23: 0%->80; 8/12/23: 80%->100 / Impacted TSs and TRs: 22.137
- 699: 14/3/24: Compl:0%->6%; Stat Rep: ->RP-240114; Rapporteur: Xiaomi->Yingyang Li, Jerome Vogedes, Xiaomi, AT&T; Rap eMail: ->liyingyang@xiaomi.com, jerome.vogedes@att.com; ; 2/4/24: WID:RP-234069->RP-240799; 13/6/24: Compl:6%->22%; Stat Rep: RP-240114->RP...; 6/6/25: Compl:70%->100%; Stat Rep: RP-250241->RP-251474;
- 700: 6/9/23: 0%->95; 8/12/23: 95%->100
- 701: 17/8/22: WID:SP-220444->SP-220680; 9/9/22: 0%->20; 23/9/22: WID:SP-220680->SP-220954; 10/12/22: 20%->45; 17/3/23: 45%->65; 8/6/23: 65%->95; 8/6/23: FCD:06/06/2023->09/20; 6/9/23: 95%->100
- 702: 14/3/24: 0%->50; 13/6/24: FCD:06/06/2024->/24; 13/6/24: 50%->90; 4/9/24: 90%->100
- 703: 6/9/23: 0%->95; 8/12/23: 95%->100
- 704: ; 4/9/24: 0%->65; 26/9/24: WID:SP-240997->SP-241287; 5/12/24: 65%->99; 6/3/25: 99%->100; 5/6/25: 100%->100 / Impacted TSs and TRs: 23.256; 23.288; 23.503; 23.502; 23.401
- 705: Impacted TSs and TRs: 24.501, 24.301, 27.007, 29.255, 29.256, 29.503, 29.517, 29.518, 29.520, 29.522, 29.552, 29.591
- 709: ; 17/9/25: 0%->100 / Impacted TSs and TRs: 33.256
- 710: ; 6/6/25: 0%->45; 27/6/25: WID:SP-250396->SP-250512; 12/9/25: 45%->100 / Impacted TSs and TRs: 32.240; 32.255; 32.256; 32.291; 32.298
- 711: ; 8/12/23: 0%->20; 14/3/24: 20%->40; 13/6/24: 40%->60; 16/7/24: WID:SP-230991->SP-240741; 4/9/24: 60%->75; 5/12/24: 75%->100 / Impacted TSs and TRs: 23.255; 23.434

| ID | WBS | Task | Duration | Start | Finish | Complete | Constraint | Resources | Work | Actual work | Acronym | PCG approved | WI rapporteur name | WI rapporteur e-mail | Release | TSG approved |
| --- | --- | --- | --- | --- | --- | --- | --- | --- | --- | --- | --- | --- | --- | --- | --- | --- |
| 712 | 349.9 | **CT Aspects of Application Layer Support for Uncrewed Aerial Systems (UAS), Phase 3** | 465.88d | 2024-06-17 A | 2025-09-09 A | 100% |  |  | 7454h | 7454h | UASAPP_Ph3 | 51 | Taimoor Abbas, InterDigital | taimoor.abbas@interdigital.com | Rel-19 | 101 |
| 713 | 349.9.1 | CT1 Aspects of Application Layer Support for Uncrewed Aerial Systems (UAS), Phase 3 | 465.88d | 2024-06-17 A | 2025-09-09 A | 100% | finish no earlier than 2025-09-09 | C1 | 3727h | 3727h | UASAPP_Ph3 | 51 | Taimoor Abbas, InterDigital | taimoor.abbas@interdigital.com | Rel-19 | 101 |
| 714 | 349.9.2 | CT3 Aspects of Application Layer Support for Uncrewed Aerial Systems (UAS), Phase 3 | 465.88d | 2024-06-17 A | 2025-09-09 A | 100% | finish no earlier than 2025-09-09 | C3 | 3727h | 3727h | UASAPP_Ph3 | 51 | Taimoor Abbas, InterDigital | taimoor.abbas@interdigital.com | Rel-19 | 101 |
| 715 | 349.10 | UAS security enhancements | 183d | 2024-04-02 A | 2024-12-12 A | 100% | start no earlier than 2024-04-02 | S3 | 1464h | 1464h | FS_UAS_Ph3_Sec | 52 | Markus Hanhisalo, | markus.hanhisalo@ericsson.com | Rel-19 | 103 |
| 716 | 350 | Study on Upper layer traffic steering, switching and split over dual 3GPP access | 333d | 2022-06-02 A | 2023-09-09 A | 100% | finish no earlier than 2023-09-09 | S1 | 2664h | 2664h | FS_DualSteer | 49 | Francesco Pica; Qualcomm |  | Rel-19 | 96 |
| 717 | 351 | Study on Charging aspects of Uncrewed Aerial Systems | 189d | 2024-06-12 A | 2024-12-11 A | 100% | finish no earlier than 2025-03-03 | S5 | 1512h | 1512h | FS_UAS_CH | 53 | Jia Dong, China Mobile, | dongjia@chinamobile.com | Rel-19 | 104 |
| 718 | 352 | Upper layer traffic steering and switching over dual 3GPP access | 4d | 2023-12-07 A | 2023-12-10 A | 100% | finish no earlier than 2023-12-12 | S1 | 32h | 32h | DualSteer | 52 | Pica Francesco, Qualcomm | fpica<at>qti.qualcomm.com | Rel-19 | 102 |
| 719 | 353 | Edge Computing Considering the Operational Needs of Service Hosting Environment | 16d | 2023-08-21 A | 2023-09-09 A | 100% | start no earlier than 2023-08-21 | S1 | 128h | 128h | EdgeOpNeeds | 51 | Yuying Zhang, China Telecom | zhangyy45@chinatelecom.cn | Rel-19 | 101 |
| 720 | 354 | **5G NR Femto** | 636.62d | 2024-01-04 A | 2025-09-09 A | 100% |  |  | 10968h | 10968h | 5G_Femto | 53 | Malla Reddy Sama | sama@docomolab-euro.com | Rel-19 | 104 |
| 721 | 354.1 | Study on System aspects of 5G NR Femto | 180d | 2024-01-04 A | 2024-09-09 A | 100% | finish no earlier than 2024-09-09 | S2 | 1440h | 1440h | FS_5G_Femto | 52 | Malla Reddy Sama (NTT DOCOMO) | sama@docomolab-euro.com | Rel-19 | 102 |
| 722 | 354.2 | System aspects of 5G NR Femto | 132d | 2024-06-12 A | 2024-12-12 A | 100% | finish no earlier than 2024-12-12 | S2 | 1056h | 1056h | 5G_Femto | 53 | Malla Reddy Sama | sama@docomolab-euro.com | Rel-19 | 104 |
| 723 | 354.3 | **CT aspects of 5G NR Femto** | 281.62d | 2024-12-12 A | 2025-09-09 A | 100% |  | C4 | 5952h | 5952h | 5G_Femto | 53 | Dojiri, Shunsuke, NTT DOCOMO | dojiri@nttdocomo.com | Rel-19 | 104 |
| 724 | 354.3.1 | CT3 aspects of 5G NR Femto | 263.75d | 2024-12-12 A | 2025-09-09 A | 100% | finish no earlier than 2025-09-09 | C3 | 2110h | 2110h | 5G_Femto | 53 | Dojiri, Shunsuke, NTT DOCOMO | dojiri@nttdocomo.com | Rel-19 | 104 |
| 725 | 354.3.2 | CT4 aspects of 5G NR Femto | 263.75d | 2024-12-12 A | 2025-09-09 A | 100% | finish no earlier than 2025-09-09 | C4 | 2110h | 2110h | 5G_Femto | 53 | Dojiri, Shunsuke, NTT DOCOMO | dojiri@nttdocomo.com | Rel-19 | 104 |
| 726 | 354.4 | Study on security aspects of 5G NR Femto Document for: Approval | 183d | 2024-04-02 A | 2024-12-12 A | 100% | start no earlier than 2024-04-02 | S3 | 1464h | 1464h | FS_5G_Femto_Sec | 52 | Peilin LIU (ZTE) | liu.peilin@zte.com.cn , | Rel-19 | 103 |
| 727 | 354.5 | Security aspects of 5G NR Femto | 132d | 2025-01-30 A | 2025-06-06 A | 100% | finish no earlier than 2025-06-06 | S3 | 1056h | 1056h | 5G_Femto_Sec | 54 | Liu,Peilin liu.peilin@zte.com.cn | Song,Hua songhua@chinamobile.com | Rel-19 | 106 |
| 728 | 355 | **Proximity-based Services in 5GS Phase 3** | 636.62d | 2024-01-04 A | 2025-09-09 A | 100% |  |  | 15754h | 15754h | 5G_ProSe_Ph3 | 52 | Hugh Shieh (AT&T) | hs6220@att.com | Rel-19 | 102 |
| 729 | 355.1 | Study on Proximity-based Services in 5GS Phase 3 | 180d | 2024-01-04 A | 2024-09-09 A | 100% | finish no earlier than 2024-09-09 | S2 | 1440h | 1440h | FS_5G_ProSe_Ph3 | 52 | Hugh Shieh (AT&T) | hs6220@att.com | Rel-19 | 102 |
| 730 | 355.2 | Proximity-based Services in 5GS Phase 3 | 132d | 2024-06-12 A | 2024-12-12 A | 100% | finish no earlier than 2024-12-12 | S2 | 1056h | 1056h | 5G_ProSe_Ph3 | 53 | Nassima Toumi (KPN N.V.) | nassima.toumi@tno.nl | Rel-19 | 104 |
| 731 | 355.3 | **CT aspects of Proximity-based Services in 5GS Phase 3** | 378.88d | 2024-09-09 A | 2025-09-09 A | 100% |  |  | 11189h | 11189h | 5G_ProSe_Ph3 | 53 | Zhao, Xiaoxue (CATT) | zhaoxiaoxue@cictmobile.com | Rel-19 | 105 |
| 732 | 355.3.1 | CT1 aspects of Proximity-based Services in 5GS Phase 3 | 378.88d | 2024-09-09 A | 2025-09-09 A | 100% | finish no earlier than 2025-09-09 | C1 | 3031h | 3031h | 5G_ProSe_Ph3 | 53 | Zhao, Xiaoxue (CATT) | zhaoxiaoxue@cictmobile.com | Rel-19 | 105 |
| 733 | 355.3.2 | CT3 aspects of Proximity-based Services in 5GS Phase 3 | 378.88d | 2024-09-09 A | 2025-09-09 A | 100% | finish no earlier than 2025-09-09 | C3 | 3031h | 3031h | 5G_ProSe_Ph3 | 53 | Zhao, Xiaoxue (CATT) | zhaoxiaoxue@cictmobile.com | Rel-19 | 105 |
| 734 | 355.3.3 | CT4 aspects of Proximity-based Services in 5GS Phase 3 | 378.88d | 2024-09-09 A | 2025-09-09 A | 100% | finish no earlier than 2025-09-09 | C4 | 3031h | 3031h | 5G_ProSe_Ph3 | 53 | Zhao, Xiaoxue (CATT) | zhaoxiaoxue@cictmobile.com | Rel-19 | 105 |
| 735 | 355.3.4 | CT6 aspects of Proximity-based Services in 5GS Phase 3 | 262d | 2024-12-30 A | 2025-09-09 A | 100% | finish no earlier than 2025-09-09 | C6 | 2096h | 2096h | 5G_ProSe_Ph3 | 53 | Zhao, Xiaoxue (CATT) | zhaoxiaoxue@cictmobile.com | Rel-19 | 105 |
| 736 | 355.4 | Security Aspects of Proximity Based Services in 5GS Phase 3 | 92.12d | 2024-12-05 A | 2025-03-03 A | 100% | finish no earlier than 2025-03-03 | S3 | 737h | 737h | 5G_ProSe_Sec_Ph3 | 54 | Ao Lei (Huawei) | leiao@huawei.com | Rel-19 | 106 |
| 737 | 355.5 | Charging for 5G ProSe Ph3 | 166.5d | 2024-12-28 A | 2025-06-06 A | 100% | finish no earlier than 2025-09-09 | S5 | 1332h | 1332h | 5G_ProSe_Ph3-CH | 53 | Xiaoqian Jia (China Telecom) | jiaxq1@chinatelecom.cn | Rel-19 | 105 |
| 738 | 356 | Study on Security Aspects of Enhancement for Proximity Based Services in 5GS Phase 3 | 183d | 2024-04-02 A | 2024-12-12 A | 100% | start no earlier than 2024-04-02 | S3 | 1464h | 1464h | FS_5G_ProSe_Ph3_SEC | 52 | Lei, Ao (Huawei) | leiao@huawei.com | Rel-19 | 103 |

Notes:
- 715: 3/4/24: 33.759 added;; 13/6/24: 0%->50; 5/12/24: 50%->100; 6/3/25: 100%->100 / Impacted TSs and TRs: 33.759
- 716: 13/7/22: 22.841 added;; 9/9/22: 0%->30; 10/12/22: 30%->60; 17/3/23: 60%->75; 8/6/23: 75%->90; 8/6/23: FCD:06/06/2023->09/20; 6/9/23: 90%->95; 8/12/23: 95%->100 / Impacted TSs and TRs: 22.841
- 717: 4/9/24: 0%->40; 26/9/24: 28.853 added;; 5/12/24: 40%->75; 5/12/24: FCD:12/12/2024->/25; 6/3/25: 75%->100 / Impacted TSs and TRs: 28.853
- 718: ; 8/12/23: 0%->95; 3/12/25: 95%->100 / Impacted TSs and TRs: 22.261
- 719: ; 6/9/23: 0%->100 / Impacted TSs and TRs: 22.261
- 720: ; 4/9/24: 0%->30; 26/9/24: WID:SP-240629->SP-241327 / Impacted TSs and TRs: 23.501; 23.502
- 721: 14/3/24: 0%->40; 13/6/24: FCD:06/06/2024->/24; 13/6/24: 40%->90; 4/9/24: 90%->100; 4/9/24: 100%->
- 722: ; 4/9/24: 0%->30; 26/9/24: WID:SP-240629->SP-241327; 5/12/24: 30%->100 / Impacted TSs and TRs: 23.501; 23.502
- 723: Impacted TSs and TRs: 29.503, 29.504, 29.505, 29.522, 29.571
- 726: 3/4/24: 33.745 added;; 13/6/24: 0%->30; 5/9/24: 30%->60; 5/12/24: 60%->98; 6/3/25: 98%->100; 5/6/25: 100%->100 / Impacted TSs and TRs: 33.745
- 727: 17/9/25: 0%->100
- 729: 14/3/24: 0%->45; 13/6/24: FCD:06/06/2024->/24; 13/6/24: 45%->90; 4/9/24: 90%->100
- 730: ; 4/9/24: 0%->70; 5/12/24: 70%->100 / Impacted TSs and TRs: 23.304
- 731: ; 26/9/24: WID:CP-242108->SP-241290 / Impacted TSs and TRs: 24.554, 24.555, 24.501, 24.587, 29.519, 29.522, 29.525, 29.503, 29.504, 29.518, 29.510, 29.555, 29.559, 29.571, 31.102
- 736: ; 6/3/25: 0%->95; 6/3/25: FCD:03/03/2025->/25; 5/6/25: 95%->100 / Impacted TSs and TRs: 33.503
- 737: ; 6/3/25: 0%->100; 12/9/25: 100%->100; 12/9/25: FCD:Tue 09/09/->/25 / Impacted TSs and TRs: 32.277; 32.291; 32.298
- 738: 3/4/24: 33.743 added;; 13/6/24: 0%->30; 5/9/24: 30%->60; 5/12/24: 60%->100 / Impacted TSs and TRs: 33.743

| ID | WBS | Task | Duration | Start | Finish | Complete | Constraint | Resources | Work | Actual work | Acronym | PCG approved | Impacted TSs and TRs | WI rapporteur name | WI rapporteur e-mail | Release | TSG approved |
| --- | --- | --- | --- | --- | --- | --- | --- | --- | --- | --- | --- | --- | --- | --- | --- | --- | --- |
| 739 | 357 | **Vehicle Mounted Relays Phase 2** | 538.12d | 2024-01-04 A | 2025-06-06 A | 100% |  |  | 6982h | 6982h | VMR_Ph2 | 53 | 23.501; 23.502; 23.273 | Hong Cheng (Qualcomm) | hongc@qti.qualcomm.com | Rel-19 | 105 |
| 740 | 357.1 | Study on Vehicle Mounted Relays Phase 2 | 180d | 2024-01-04 A | 2024-09-09 A | 100% | finish no earlier than 2024-09-09 | S2 | 1440h | 1440h | FS_VMR_Ph2 | 52 |  | Hong Cheng (Qualcomm) | hongc@qti.qualcomm.com | Rel-19 | 102 |
| 741 | 357.2 | Stage 2 of Vehicle Mounted Relays Phase 2 | 132d | 2024-06-12 A | 2024-12-12 A | 100% | finish no earlier than 2024-12-12 | S2 | 1056h | 1056h | VMR_Ph2 | 53 | 23.501; 23.502; 23.273 | Hong Cheng (Qualcomm) | hongc@qti.qualcomm.com | Rel-19 | 104 |
| 742 | 357.3 | **CT aspects of Vehicle Mounted Relays Phase 2** | 280.38d | 2024-09-09 A | 2025-06-06 A | 100% |  |  | 4486h | 4486h | VMR_Ph2 | 53 | 24.501, 23.041, 29.515 | Kim, Sunghoon, Qualcomm Incorporated | sunghoon@qti.qualcomm.com | Rel-19 | 105 |
| 743 | 357.3.1 | CT1 aspects of Vehicle Mounted Relays Phase 2 | 280.38d | 2024-09-09 A | 2025-06-06 A | 100% | finish no earlier than 2025-06-06 | C1 | 2243h | 2243h | VMR_Ph2 | 53 |  | Kim, Sunghoon, Qualcomm Incorporated | sunghoon@qti.qualcomm.com | Rel-19 | 105 |
| 744 | 357.3.2 | CT4 aspects of Vehicle Mounted Relays Phase 2 | 280.38d | 2024-09-09 A | 2025-06-06 A | 100% | finish no earlier than 2025-06-06 | C4 | 2243h | 2243h | VMR_Ph2 | 53 |  | Kim, Sunghoon, Qualcomm Incorporated | sunghoon@qti.qualcomm.com | Rel-19 | 105 |
| 745 | 358 | **Identifying non-3GPP Devices Connecting behind a UE or 5G-RG** | 636.62d | 2024-01-04 A | 2025-09-09 A | 100% |  |  | 11541h | 11541h | UIA_ARC | 53 |  | Michael Starsinic, Interdigital | Michael.Starsinic@Interdigital.com | Rel-19 | 105 |
| 746 | 358.1 | Study on User Identities and Authentication Architecture | 180d | 2024-01-04 A | 2024-09-09 A | 100% | finish no earlier than 2024-09-09 | S2 | 1440h | 1440h | FS_UIA_ARC | 52 | 23.700-32 | Michael Starsinic, Interdigital | Michael.Starsinic@Interdigital.com | Rel-19 | 102 |
| 747 | 358.2 | Stage 2 of Identifying non-3GPP Devices Connecting behind a UE or 5G-RG | 126d | 2024-06-20 A | 2024-12-12 A | 100% | finish no earlier than 2024-12-12 | S2 | 1008h | 1008h | UIA_ARC | 53 |  | Michael Starsinic, Interdigital | Michael.Starsinic@Interdigital.com | Rel-19 | 104 |
| 748 | 358.3 | **CT aspects of Identifying non-3GPP Devices Connecting behind a UE or 5G-RG** | 378.88d | 2024-09-09 A | 2025-09-09 A | 100% |  |  | 9093h | 9093h | UIA_ARC | 53 |  | Sethi, Anuj, InterDigital | anuj.sethi@interdigital.com | Rel-19 | 105 |
| 749 | 358.3.1 | CT1 aspects of Identifying non-3GPP Devices Connecting behind a UE or 5G-RG | 378.88d | 2024-09-09 A | 2025-09-09 A | 100% | finish no earlier than 2025-09-09 | C1 | 3031h | 3031h | UIA_ARC | 53 |  | Sethi, Anuj, InterDigital | anuj.sethi@interdigital.com | Rel-19 | 105 |
| 750 | 358.3.2 | CT3 aspects of Identifying non-3GPP Devices Connecting behind a UE or 5G-RG | 378.88d | 2024-09-09 A | 2025-09-09 A | 100% | finish no earlier than 2025-09-09 | C3 | 3031h | 3031h | UIA_ARC | 53 |  | Sethi, Anuj, InterDigital | anuj.sethi@interdigital.com | Rel-19 | 105 |
| 751 | 358.3.3 | CT4 aspects of Identifying non-3GPP Devices Connecting behind a UE or 5G-RG | 378.88d | 2024-09-09 A | 2025-09-09 A | 100% | finish no earlier than 2025-09-09 | C4 | 3031h | 3031h | UIA_ARC | 53 |  | Sethi, Anuj, InterDigital | anuj.sethi@interdigital.com | Rel-19 | 105 |
| 752 | 359 | Study on security aspects of User Identities and Authentication | 183d | 2024-04-02 A | 2024-12-12 A | 100% | start no earlier than 2024-04-02 | S3 | 1464h | 1464h | FS_UIA_Sec | 52 | 33.700-32 | Samir Ferdi, | Samir.Ferdi@InterDigital.com | Rel-19 | 103 |
| 753 | 360 | **FRMCS Phase 5** | 2463.38d | 2019-03-07 A | 2025-09-09 A | 100% |  | S1 | 28424h | 28424h | FRMCS_Ph5 |  |  |  |  | Rel-19 |  |
| 754 | 360.1 | Study on FRMCS Phase 5 | 460d | 2022-03-10 A | 2023-12-12 A | 100% | finish no earlier than 2023-12-12 | S1 | 3680h | 3680h | FS_FRMCS_Ph5 | 48 | 22.989 | Patrick WIMART, UIC | wimart@uic.org | Rel-19 | 95 |
| 755 | 360.2 | Stage 1 of Railways specific Enhancements to Mission Critical Services | 1804d | 2019-03-07 A | 2023-12-12 A | 100% | finish no earlier than 2025-09-09 | S1 | 14432h | 14432h | FRMCS_Ph5 | 51 | 22.280; 22.179; 22.289; 22.261 | Nikolopoulou, Vassiliki, UIC | nikolopoulou@uic.org | Rel-19 | 100 |
| 756 | 360.3 | Stage 2 of Railways specific Enhancements to Mission Critical Services | 399d | 2023-06-08 A | 2024-12-12 A | 100% | finish no earlier than 2024-12-12 | S6 | 3192h | 3192h | FRMCS_Ph5 | 51 | 23.280; 23.281; 23.282; 23.379; 23.283; 23.289 | Oettl, Martin, Nokia, | martin.oettl@nokia.com | Rel-19 | 100 |
| 757 | 360.4 | **CT aspects of Railways specific Enhancements to Mission Critical Services** | 378.88d | 2024-09-09 A | 2025-09-09 A | 100% |  |  | 3031h | 3031h | FRMCS_Ph5 | 51 | 24.379, 24.281, 24.282, 24.380, 24.484, 24.481 | Won, Sung Hwan, Nokia | sung.won@nokia.com | Rel-19 | 100 |
| 758 | 360.4.1 | CT1 aspects of Railways specific Enhancements to Mission Critical Services | 378.88d | 2024-09-09 A | 2025-09-09 A | 100% | finish no earlier than 2025-09-09 | C1 | 3031h | 3031h | FRMCS_Ph5 | 51 |  | Won, Sung Hwan, Nokia | sung.won@nokia.com | Rel-19 | 100 |
| 759 | 361 | Study on Supporting of Railway Smart Station Services | 776d | 2019-09-19 A | 2022-09-08 A | 100% | finish no earlier than 2022-09-08 | S1 | 6208h | 6208h | FS_RAILSS | 43 | New ; 22.890 | Han, Andrew Min-gyu, Hansung University | andyhan(at)hansung(dot)ac(dot)kr | Rel-19 | 85 |
| 760 | 362 | Study on Network of Service Robots with Ambient Intelligence | 400d | 2022-06-02 A | 2023-12-12 A | 100% | finish no earlier than 2023-12-12 | S1 | 3200h | 3200h | FS_SOBOT | 49 | 22.916 | LEE, Ki-Dong, LG Electronics | kidong.lee@lge.com | Rel-19 | 96 |
| 761 | 363 | Study on Interconnect of SNPN | 399d | 2023-06-08 A | 2024-06-27 A | 100% | finish no earlier than 2024-12-12 | S1 | 3192h | 3192h | FS_ISN | 50 | 22.848 | Thierry Bérisot, Novamint | tberisot@novamint.com | Rel-19 | 99 |
| 762 | 364 | Interconnect of SNPN | 13d | 2024-03-13 A | 2024-03-29 A | 100% | finish no earlier than 2024-03-29 | S1 | 104h | 104h | ISN | 52 | 22.261 | Thierry Bérisot, Novamint, | tberisot@novamint.com | Rel-19 | 103 |
| 763 | 365 | Edge Computing for Industrial Scenarios | 22d | 2023-02-02 A | 2023-03-03 A | 100% | finish no earlier than 2023-03-03 | S1 | 176h | 176h | EDGINDUS | 50 | 22.104 | Bruno Tossou, Orange | bruno.tossou@orange.com | Rel-19 | 99 |
| 764 | 366 | PS Data Off for IMS Data Channel Service | 22d | 2023-02-02 A | 2023-03-03 A | 100% | finish no earlier than 2023-03-03 | S1 | 176h | 176h | IMSDCDataOff | 50 | 22.011 | Yue Hu, China Mobile | huyueyjy@chinamobile.com | Rel-19 | 99 |
| 765 | 367 | Multi-path relay | 13d | 2022-09-01 A | 2022-09-19 A | 100% | start no earlier than 2022-09-01 | S1 | 104h | 104h | MultiRelay | 49 | 22.261 | Yuying Zhang, China Telecom | zhangyy45@chinatelecom.cn | Rel-19 | 97 |
| 766 | 368 | UE-to-UE multi-hop relay | 12d | 2023-05-22 A | 2023-06-06 A | 100% | start no earlier than 2023-05-22 | S1 | 96h | 96h | UEMHopRelay | 51 | 22.261; 22.280 | Lipford, Mark, FirstNet Authority, | mark.lipford@firstnet.gov | Rel-19 | 100 |
| 767 | 369 | Interworking of Non-3GPP Digital Terrestrial Broadcast Networks with 5GS Multicast Broadcast Services | 13d | 2022-09-01 A | 2022-09-19 A | 100% | start no earlier than 2022-09-01 | S1 | 104h | 104h | DTT4MBS | 49 | 22.261 | Saha, Anindya, Saankhya Labs | anindya@saankhyalabs.com | Rel-19 | 97 |

Notes:
- 740: 14/3/24: 0%->40; 2/4/24: WID:SP-231799->SP-240493; 13/6/24: FCD:06/06/2024->/24; 13/6/24: 40%->95; 5/12/24: 95%->100
- 741: ; 4/9/24: 0%->40; 5/12/24: 40%->100
- 746: 14/3/24: 0%->35; 14/3/24: 23.700-32 added;; 13/6/24: FCD:06/06/2024->/24; 13/6/24: 35%->90; 4/9/24: 90%->93; 5/12/24: 93%->100
- 747: 4/9/24: 0%->15; 5/12/24: 15%->90; 6/3/25: 90%->100; 5/6/25: 100%->100
- 752: 3/4/24: 33.700-32 added;; 13/6/24: 0%->35; 5/9/24: 35%->65; 5/12/24: 65%->100
- 754: ; 4/6/22: 0%->15; 21/6/22: WID:SP-220088->SP-220437. FS_FRMCS_Ph3->FS_FRMCS_Ph5; 9/9/22: 15%->30; 10/12/22: 30%->50; 8/6/23: 50%->80; 8/6/23: FCD:09/09/2023->12/20; 6/9/23: 80%->90; 8/12/23: 90%->100; 8/1/25: WID:SP-220437->SP-241693
- 755: ; 6/9/23: 0%->50; 8/12/23: 50%->100
- 756: ; 7/9/23: 0%->10; 8/12/23: 10%->30; 14/3/24: 30%->40. 14/5/24: acronym: enh4FRMCS ->FRMCS_Ph5 ; 13/6/24: 40%->55; 4/9/24: 55%->70; 5/12/24: 70%->100; 3/12/25: WID:SP-230780->SP-241693
- 759: ; 8/10/19: 22.890 added;; 6/12/19: 0%->5; 5/12/20: 5%->15; 19/3/21: FCD:12/06/2020->09/21; 19/3/21: 15%->30; 13/9/21: 30%->35; 10/12/21: 35%->45; 11/03/22: Rel-18->Rel-19; 9/9/22: 45%->100
- 760: 13/7/22: 22.916 added;; 9/9/22: 0%->10; 10/12/22: 10%->40; 17/3/23: FCD:03/03/2023->9/9/23; 17/3/23: 40%->70; 8/6/23: 70%->80; 8/6/23: FCD:09/09/2023->12/20; 6/9/23: 80%->90; 8/12/23: 90%->100
- 761: 8/6/23: 0%->30; 6/9/23: 30%->60; 8/12/23: FCD:12/12/2023->/2024; 8/12/23: 60%->65; 3/12/25: 40%->100
- 762: ; 14/3/24: 0%->100
- 763: ; 17/3/23: 0%->100
- 764: ; 9/8/23: 0%->100
- 765: ; 9/9/22: 0%->100
- 766: ; 8/6/23: 100%->
- 767: ; 9/9/22: 0%->100

| ID | WBS | Task | Type | Duration | Start | Finish | Complete | Actual finish | Constraint | Resources | Work | Actual work | Acronym | PCG approved | WI rapporteur name | WI rapporteur e-mail | Release | TSG approved |
| --- | --- | --- | --- | --- | --- | --- | --- | --- | --- | --- | --- | --- | --- | --- | --- | --- | --- | --- |
| 768 | 370 | **MPS for Messaging services** |  | 1144d | 2022-09-01 A | 2025-09-09 A | 100% |  |  |  | 11165h | 11165h | MPS4msg | 49 | Singh, Ray, Peraton Labs | rsingh@peratonlabs.com | Rel-19 | 97 |
| 769 | 370.1 | (stage 1 of) MPS for Messaging services |  | 13d | 2022-09-01 A | 2022-09-19 A | 100% |  | start no earlier than 2022-09-01 | S1 | 104h | 104h | MPS4msg | 49 | Singh, Ray, Peraton Labs | rsingh@peratonlabs.com | Rel-19 | 97 |
| 770 | 370.2 | (stage 2 of) MPS for IMS Messaging and SMS services |  | 132d | 2024-06-12 A | 2024-12-12 A | 100% |  | finish no earlier than 2024-12-12 | S2 | 1056h | 1056h | MPS4msg | 53 | Robert Streijl (Peraton Labs), | rstreijl@peratonlabs.com | Rel-19 | 104 |
| 771 | 370.3 | Study on MPS for IMS Messaging and SMS services |  | 114d | 2024-01-03 A | 2024-06-06 A | 100% |  | finish no earlier than 2024-06-06 | S2 | 912h | 912h | FS_MPS4msg | 51 | Robert Streijl (Peraton Labs) | rstreijl@peratonlabs.com | Rel-19 | 101 |
| 772 | 370.4 | **CT aspects of MPS for IMS Messaging and SMS services** |  | 378.88d | 2024-09-09 A | 2025-09-09 A | 100% |  |  |  | 9093h | 9093h | MPS4msg | 53 | Monnes, Peter (Peraton Labs) | pmonnes@peratonlabs.com | Rel-19 | 105 |
| 773 | 370.4.1 | CT1 aspects of MPS for IMS Messaging and SMS services |  | 378.88d | 2024-09-09 A | 2025-09-09 A | 100% |  | finish no earlier than 2025-09-09 | C1 | 3031h | 3031h | MPS4msg | 53 | Monnes, Peter (Peraton Labs) | pmonnes@peratonlabs.com | Rel-19 | 105 |
| 774 | 370.4.2 | CT3 aspects of MPS for IMS Messaging and SMS services |  | 378.88d | 2024-09-09 A | 2025-09-09 A | 100% |  | finish no earlier than 2025-09-09 | C3 | 3031h | 3031h | MPS4msg | 53 | Monnes, Peter (Peraton Labs) | pmonnes@peratonlabs.com | Rel-19 | 105 |
| 775 | 370.4.3 | CT4 aspects of MPS for IMS Messaging and SMS services |  | 378.88d | 2024-09-09 A | 2025-09-09 A | 100% |  | finish no earlier than 2025-09-09 | C4 | 3031h | 3031h | MPS4msg | 53 | Monnes, Peter (Peraton Labs) | pmonnes@peratonlabs.com | Rel-19 | 105 |
| 776 | 371 | **Minimization of Service Interruption During Core Network Failure Phase 2** |  | 1189.5d | 2022-09-01 A | 2025-10-23 | 100% | 2025-09-09 |  |  | 4753h | 4753h | MINT_Ph2 | 49 | Yinglin Chen, China Telecom | chenyl37@chinatelecom.cn | Rel-19 | 97 |
| 777 | 371.1 | Study on MINT support in EPS for 5G-only national roaming UE | manual | 182.12d | 2024-09-09 A | 2025-03-03 A | 100% |  | finish no earlier than 2024-12-12 | C1 | 1457h | 1457h | FS_MINT_Ph2 | 49 | Li Mingxue, China Telecom | limx36@chinatelecom.cn | Rel-19 | 97 |
| 778 | 371.2 | Stage 1 of Minimization of Service Interruption During Core Network Failure Phase 2 |  | 13d | 2022-09-01 A | 2022-09-13 A | 100% |  | finish no earlier than 2022-09-19 | S1 | 104h | 104h | MINT_Ph2 | 49 | Yinglin Chen, China Telecom | chenyl37@chinatelecom.cn | Rel-19 | 97 |
| 779 | 371.3 | **CT aspects of Minimization of Service Interruption During Core Network Failure Phase 2** |  | 99.5d | 2025-06-06 A | 2025-09-09 A | 100% |  |  | C1 | 3184h | 3184h | MINT_Ph2 | 49 | Li Mingxue, China Telecom | limx36@chinatelecom.cn | Rel-19 | 97 |
| 780 | 371.3.1 | CT1 aspects of Minimization of Service Interruption During Core Network Failure Phase 2 |  | 99.5d | 2025-06-06 A | 2025-09-09 A | 100% |  | finish no earlier than 2025-10-23 | C1 | 796h | 796h | MINT_Ph2 | 49 | Li Mingxue, China Telecom | limx36@chinatelecom.cn | Rel-19 | 97 |
| 781 | 371.3.2 | CT4 aspects of Minimization of Service Interruption During Core Network Failure Phase 2 |  | 99.5d | 2025-06-06 A | 2025-09-09 A | 100% |  | finish no earlier than 2025-09-09 | C4 | 796h | 796h | MINT_Ph2 | 49 | Li Mingxue, China Telecom | limx36@chinatelecom.cn | Rel-19 | 97 |
| 782 | 371.3.3 | CT6 aspects of Minimization of Service Interruption During Core Network Failure Phase 2 |  | 99.5d | 2025-06-06 A | 2025-09-09 A | 100% |  | finish no earlier than 2025-09-09 | C6 | 796h | 796h | MINT_Ph2 | 49 | Li Mingxue, China Telecom | limx36@chinatelecom.cn | Rel-19 | 97 |
| 783 | 371.4 | Charging aspects of MINT |  | 1d | 2025-09-09 A | 2025-09-09 A | 100% |  | finish no earlier than 2025-09-09 | S5 | 8h | 8h | MINT-CH | 55 | Robert Törnkvist, Ericsson | robert.tornkvist@ericsson.com | Rel-19 | 109 |
| 784 | 372 | Measurement Data Collection |  | 8d | 2022-12-09 A | 2022-12-20 A | 100% |  | finish no earlier than 2022-12-20 | S1 | 64h | 64h | MeasureData | 50 | Yingjun Zhou, ZTE Corporation | zhou.yingjun@zte.com.cn | Rel-19 | 98 |
| 785 | 373 | Local traffic routing for multi-access UE |  | 16d | 2023-08-21 A | 2023-09-09 A | 100% |  | start no earlier than 2023-08-21 | S1 | 128h | 128h | LTR_MA | 51 | Yinglin Chen, China Telecom | chenyl37@chinatelecom.cn | Rel-19 | 101 |
| 786 | 374 | Study on Diverse audio Capturing system for End-user Devices |  | 526d | 2022-12-13 A | 2024-12-12 A | 100% |  | finish no earlier than 2024-12-12 | S4 | 4208h | 4208h | FS_DaCED | 50 | Wang Bin, Xiaomi | wangbin23@xiaomi.com | Rel-19 | 98 |
| 787 | 375 | Study on Service aspects for supporting the eMMTel service |  | 399d | 2023-06-08 A | 2024-12-12 A | 100% |  | finish no earlier than 2024-12-12 | S6 | 3192h | 3192h | FS_eMMTelAPP | 51 | Liu, Yue, China Mobile | liuyueyjy@chinamobile.com | Rel-19 | 100 |
| 788 | 376 | **Application enablement aspects for MMTel** |  | 435.88d | 2024-07-16 A | 2025-09-09 A | 100% |  |  |  | 3980h | 3980h | MMTel_App | 53 | Liu, Yue, China Mobile | liuyueyjy@chinamobile.com | Rel-19 | 104 |
| 789 | 376.1 | Stage 2 of Application enablement aspects for MMTel |  | 108d | 2024-07-16 A | 2024-10-28 A | 100% |  | start no earlier than 2024-07-16 | S6 | 864h | 864h | MMTel_App | 53 | Liu, Yue, China Mobile | liuyueyjy@chinamobile.com | Rel-19 | 104 |
| 790 | 376.2 | **CT aspects of Application enablement aspects for MMTel** |  | 194.75d | 2025-03-06 A | 2025-09-09 A | 100% |  |  |  | 3116h | 3116h | MMTel_App | 53 | Liu, Yue, China Mobile | liuyueyjy@chinamobile.com | Rel-19 | 104 |
| 791 | 376.2.1 | CT1 aspects of Application enablement aspects for MMTel |  | 194.75d | 2025-03-06 A | 2025-09-09 A | 100% |  | start no earlier than 2025-03-06 | C1 | 1558h | 1558h | MMTel_App | 53 | Liu, Yue, China Mobile | liuyueyjy@chinamobile.com | Rel-19 | 104 |
| 792 | 376.2.2 | CT3 aspects of Application enablement aspects for MMTel |  | 194.75d | 2025-03-06 A | 2025-09-09 A | 100% |  | start no earlier than 2025-03-06 | C3 | 1558h | 1558h | MMTel_App | 53 | Liu, Yue, China Mobile | liuyueyjy@chinamobile.com | Rel-19 | 104 |

Notes:
- 768: ; 9/9/22: 0%->100 / Impacted TSs and TRs: 22.153
- 769: ; 9/9/22: 0%->100 / Impacted TSs and TRs: 22.153
- 770: ; 4/9/24: 0%->80; 5/12/24: 80%->100 / Impacted TSs and TRs: 23.401; 23.203; 23.501; 23.502; 23.503; 23.682; 23.204; 23.272; 23.228
- 771: 9/23: company-submitted WID, to be corrected; 6/10/23: 23.700-75 added;; 8/12/23: 0%->20; 14/3/24: 0%->70; 13/6/24: 70%->100; 4/9/24: 99%->100 / Impacted TSs and TRs: 23.700-75
- 772: Impacted TSs and TRs: 23.540, 24.229, 24.247, 24.301, 24.341, 29.122, 29.128, 29.213, 29.214, 29.228, 29.272, 29.336, 29.338, 24.501, 29.503, 29.513, 29.514, 29.518, 29.522, 29.562, 29.577, 23.540, 24.229, 24.247, 24.301, 24.341, 29.122, 29.128, 29.213, 29.214, 29.228, 29.272,
- 776: ; 9/9/22: 0%->100; 29/9/25: FCD:Tue 09/09/25->Thu 23/10/25; Compl:58%->30%; / Impacted TSs and TRs: 22.261
- 777: 3/4/25: WID:CP-242249->CP-243260
- 778: ; 9/9/22: 0%->100 / Impacted TSs and TRs: 22.261
- 779: ; 9/9/22: 0%->100; 29/9/25: FCD:Tue 09/09/25->Thu 23/10/25; WID: CP-251282->CP-252193; List of Impacted TS & TR updated; / Impacted TSs and TRs: 23.122, 24.301, 24.501, 29.272, 29.274, 29.503, 29.509, 31.102
- 780: ; 9/9/22: 0%->100; 29/9/25: FCD:Tue 09/09/25->Thu 23/10/25; WID: CP-251282->CP-252193; / Impacted TSs and TRs: 23.122, 24.301, 31.102
- 781: ; 9/9/22: 0%->100; 29/9/25: WID: CP-251282->CP-252193; / Impacted TSs and TRs: 23.122, 24.301, 31.102
- 782: ; 9/9/22: 0%->100; 29/9/25: WID: CP-251282->CP-252193; / Impacted TSs and TRs: 23.122, 24.301, 31.102
- 783: ; 4/12/25: 30%->100 / Impacted TSs and TRs: 32.240; 32.255; 32.256; 32.291; 32.298
- 784: ; 10/12/22: 0%->100 / Impacted TSs and TRs: 22.261
- 785: ; 6/9/23: 0%->100 / Impacted TSs and TRs: 22.261
- 786: ; 17/3/23: 0%->5; 17/3/23: 26.933 added;; 8/6/23: 5%->30; 7/9/23: 30%->35; 8/12/23: 35%->45; 14/3/24: 45%->70; 13/6/24: 70%->85; 4/9/24: 85%->90; 4/9/24: FCD:09/09/2024->12/24; 5/12/24: 90%->100 / Impacted TSs and TRs: 26.933
- 787: ; 30/6/23: 23.700-92 added;; 7/9/23: 0%->10; 8/12/23: 10%->20; 14/3/24: 20%->35; 13/6/24: 35%->70; 4/9/24: 70%->80; 5/12/24: 80%->100; 5/12/24: FCD:09/09/2024->12/24 / Impacted TSs and TRs: 23.222 ; 23.700-92
- 788: 4/9/24: 0%->10; 26/9/24: 23.792 added;; 5/12/24: 10%->60 / Impacted TSs and TRs: 23.792
- 789: 4/9/24: 0%->10; 26/9/24: 23.792 added;; 5/12/24: 10%->60; 6/3/25: 60%->100 / Impacted TSs and TRs: 23.792
- 790: Impacted TSs and TRs: 24.542
- 791: Impacted TSs and TRs: 24.542
- 792: Impacted TSs and TRs: 24.542

| ID | WBS | Task | Duration | Start | Finish | Complete | Remaining | Total slack | Constraint | Resources | Work | Actual work | Acronym | PCG approved | WI rapporteur name | WI rapporteur e-mail | Release | TSG approved |
| --- | --- | --- | --- | --- | --- | --- | --- | --- | --- | --- | --- | --- | --- | --- | --- | --- | --- | --- |
| 793 | 377 | **Enhanced application layer support for location services** | 854d | 2023-06-08 A | 2025-09-09 A | 100% |  |  |  |  | 9766h | 9766h | eLSAPP | 53 | Liping Wu, CATT | wuliping@cictmobile.com | Rel-19 | 105 |
| 794 | 377.1 | Study on enhanced application layer support for location services | 331d | 2023-06-08 A | 2024-09-09 A | 100% |  |  | finish no earlier than 2024-09-09 | S6 | 2648h | 2648h | FS_eLSAPP | 51 | Liping Wu, CATT | wuliping@cictmobile.com | Rel-19 | 100 |
| 795 | 377.2 | Stage 2 of Enhanced application layer support for location services | 132d | 2024-06-12 A | 2024-12-12 A | 100% |  |  | finish no earlier than 2024-12-12 | S6 | 1056h | 1056h | eLSAPP | 53 | Liping Wu, CATT | wuliping@cictmobile.com | Rel-19 | 104 |
| 796 | 377.3 | **CT aspects of Enhanced application layer support for location services** | 378.88d | 2024-09-09 A | 2025-09-09 A | 100% |  |  |  |  | 6062h | 6062h | eLSAPP | 53 | Wang, Baixiao (CATT) | wangbaixiao@cictmobile.com | Rel-19 | 105 |
| 797 | 377.3.1 | CT1 aspects of Enhanced application layer support for location services | 378.88d | 2024-09-09 A | 2025-09-09 A | 100% |  |  | finish no earlier than 2025-09-09 | C1 | 3031h | 3031h | eLSAPP | 53 | Wang, Baixiao (CATT) | wangbaixiao@cictmobile.com | Rel-19 | 105 |
| 798 | 377.3.2 | CT3 aspects of Enhanced application layer support for location services | 378.88d | 2024-09-09 A | 2025-09-09 A | 100% |  |  | finish no earlier than 2025-09-09 | C3 | 3031h | 3031h | eLSAPP | 53 | Wang, Baixiao (CATT) | wangbaixiao@cictmobile.com | Rel-19 | 105 |
| 799 | 378 | Sharing of administrative configuration between interconnected MC service systems | 399d | 2023-06-08 A | 2024-12-12 A | 100% |  |  | finish no earlier than 2024-12-12 | S6 | 3192h | 3192h | MCShAC | 51 | andreas.flander@bdbos.bund.de | andreas.flander@bdbos.bund.de | Rel-19 | 100 |
| 800 | 379 | **5GMSG Service phase 3** | 854d | 2023-06-08 A | 2025-09-09 A | 100% |  |  |  |  | 9326h | 9326h | 5GMARCH_Ph3 | 51 | Liu, Yue, China Mobile, | liuyueyjy@chinamobile.com | Rel-19 | 100 |
| 801 | 379.1 | Stage 2 of GMSG Service phase 3 | 399d | 2023-06-08 A | 2024-12-12 A | 100% |  |  | finish no earlier than 2024-12-12 | S6 | 3192h | 3192h | 5GMARCH_Ph3 | 51 | Liu, Yue, China Mobile, | liuyueyjy@chinamobile.com | Rel-19 | 100 |
| 802 | 379.2 | **CT aspects for enabling MSGin5G Service phase 3** | 291.88d | 2024-12-02 A | 2025-09-09 A | 100% |  |  |  |  | 4670h | 4670h | 5GMARCH_Ph3 | 51 | Liu, Yue, China Mobile | liuyueyjy@chinamobile.com | Rel-19 | 100 |
| 803 | 379.2.1 | CT1 aspects for enabling MSGin5G Service phase 3 | 291.88d | 2024-12-02 A | 2025-09-09 A | 100% |  |  | finish no earlier than 2025-09-09 | C1 | 2335h | 2335h | 5GMARCH_Ph3 | 51 | Liu, Yue, China Mobile | liuyueyjy@chinamobile.com | Rel-19 | 100 |
| 804 | 379.2.2 | CT3 aspects for enabling MSGin5G Service phase 3 | 291.88d | 2024-12-02 A | 2025-09-09 A | 100% |  |  | finish no earlier than 2025-09-09 | C3 | 2335h | 2335h | 5GMARCH_Ph3 | 51 | Liu, Yue, China Mobile | liuyueyjy@chinamobile.com | Rel-19 | 100 |
| 805 | 379.3 | Security aspects for MSGin5G Service Phase 3 | 183d | 2024-04-02 A | 2024-12-12 A | 100% |  |  | start no earlier than 2024-04-02 | S3 | 1464h | 1464h | 5GMARCH_SEC_Ph3 | 52 | Xiaoting Huang, | huangxiaoting@chinamobile.com | Rel-19 | 103 |
| 806 | 380 | Enhanced Mission Critical Architecture | 399d | 2023-06-08 A | 2024-12-12 A | 100% |  |  | finish no earlier than 2024-12-12 | S6 | 3192h | 3192h | enhMC | 51 | Negalaguli, Harish, Motorola Solutions, | harish.negalaguli@motorolasolutions.com | Rel-19 | 100 |
| 807 | 381 | **SEAL DD (Data Delivery) Phase 2** | 759.75d | 2023-09-07 A | 2025-09-09 A | 100% |  |  |  |  | 8734h | 8734h | SEALDD_Ph2 | 51 | Cuili Ge, Huawei | gecuili@huawei.com | Rel-19 | 101 |
| 808 | 381.1 | Stage 2 of SEAL DD (Data Delivery) Phase 2 | 334d | 2023-09-07 A | 2024-12-12 A | 100% |  |  | finish no earlier than 2024-12-12 | S6 | 2672h | 2672h | SEALDD_Ph2 | 51 | Cuili Ge, Huawei | gecuili@huawei.com | Rel-19 | 101 |
| 809 | 381.2 | **CT aspects of SEAL DD (Data Delivery) Phase 2** | 378.88d | 2024-09-09 A | 2025-09-09 A | 100% |  |  |  |  | 6062h | 6062h | SEALDD_Ph2 | 51 | Herrero Veron, Christian (Huawei) | Christian.Herrero at huawei.com | Rel-19 | 101 |
| 810 | 381.2.1 | CT1 aspects of SEAL DD (Data Delivery) Phase 2 | 378.88d | 2024-09-09 A | 2025-09-09 A | 100% |  |  | finish no earlier than 2025-09-09 | C1 | 3031h | 3031h | SEALDD_Ph2 | 51 | Herrero Veron, Christian (Huawei) | Christian.Herrero at huawei.com | Rel-19 | 101 |
| 811 | 381.2.2 | CT3 aspects of SEAL DD (Data Delivery) Phase 2 | 378.88d | 2024-09-09 A | 2025-09-09 A | 100% |  |  | finish no earlier than 2025-09-09 | C3 | 3031h | 3031h | SEALDD_Ph2 | 51 | Herrero Veron, Christian (Huawei) | Christian.Herrero at huawei.com | Rel-19 | 101 |
| 812 | 382 | **Architecture for enabling Edge Applications Phase 3** | 759.75d | 2023-09-07 A | 2025-09-09 A | 100% |  |  |  |  | 9227h | 9227h | EDGEAPP_Ph3 | 51 | Hyesung Kim, Samsung | hs1207.kim@samsung.com | Rel-19 | 101 |
| 813 | 382.1 | Stage 2 of enabling Edge Applications Phase 3 | 334d | 2023-09-07 A | 2024-12-12 A | 100% |  |  | finish no earlier than 2024-12-12 | S6 | 2672h | 2672h | EDGEAPP_Ph3 | 51 | Hyesung Kim, Samsung | hs1207.kim@samsung.com | Rel-19 | 101 |
| 814 | 382.2 | **CT aspects for Enabling Edge Applications Phase 3** | 465.88d | 2024-06-17 A | 2025-09-09 A | 100% |  |  |  |  | 6555h | 6555h | EDGEAPP_Ph3 | 51 | Narendranath Durga Tangudu, Samsung | n.tangudu@samsung.com | Rel-19 | 101 |
| 815 | 382.2.1 | CT1 aspects for Enabling Edge Applications Phase 3 | 465.88d | 2024-06-17 A | 2025-09-09 A | 100% |  |  | finish no earlier than 2025-09-09 | C1 | 3727h | 3727h | EDGEAPP_Ph3 | 51 | Narendranath Durga Tangudu, Samsung | n.tangudu@samsung.com | Rel-19 | 101 |
| 816 | 382.2.2 | CT3 aspects for Enabling Edge Applications Phase 3 | 353.5d | 2024-06-17 A | 2025-09-09 A | 100% |  |  | finish no earlier than 2025-09-09 | C3 | 2828h | 2828h | EDGEAPP_Ph3 | 51 | Narendranath Durga Tangudu, Samsung | n.tangudu@samsung.com | Rel-19 | 101 |
| 817 | 383 | Rel-19 miscellaneous Security | 1d | 2019-03-07 | 2019-03-07 |  |  | 40387.9d |  |  |  |  |  |  |  |  | Rel-19 |  |
| 818 | 384 | Security Assurance Specification for maintenance of 5G features | 240d | 2024-04-02 A | 2025-03-03 A | 100% |  |  | start no earlier than 2024-04-02 | S3 | 1920h | 1920h | SCAS_5G_Maint | 52 | Rong Wu (Huawei) | raina.wu@huawei.com | Rel-19 | 103 |
| 819 | 385 | 5G Security Assurance Specification (SCAS) for the Unified Data Repository (UDR) | 267d | 2023-09-06 A | 2024-05-21 | 80% | 53.4d | 38419.2d | finish no earlier than 2024-09-09 | S3 | 2136h |  | SCAS_5G_UDR | 51 | Andreas, Joerg, BSI Germany | joerg.andreas@bsi.bund.de | Rel-19 | 101 |
| 820 | 386 | 5G Security Assurance Specification (SCAS) for the Short Message Service Function (SMSF) | 267d | 2023-09-06 A | 2024-09-09 A | 100% |  |  | finish no earlier than 2024-09-09 | S3 | 2136h | 2136h | SCAS_5G_SMSF | 51 | Manjesh K. Hanawal, IIT Bombay | mhanawal@iitb.ac.in | Rel-19 | 101 |
| 821 | 387 | Addition of 256-bit security Algorithms | 130d | 2023-09-06 A | 2024-03-03 A | 100% |  |  | finish no earlier than 2024-03-03 | S3 | 1040h | 1040h | 256_Algo | 51 | Orkopoulos, Stawros | stawros.orkopoulos@nokia.com | Rel-19 | 101 |
| 822 | 388 | Addition of Milenage-256 algorithm | 249d | 2024-01-03 A | 2024-12-12 A | 100% |  |  | finish no earlier than 2024-12-12 | S3 | 1992h | 1992h | Milenage_256 | 52 | Mireille Pauliac | mireille.pauliac@thalesgroup.com | Rel-19 | 102 |
| 823 | 389 | Study on enabling a cryptographic algorithm transition to 256-bits | 249d | 2024-01-03 A | 2024-12-12 A | 100% |  |  | finish no earlier than 2024-12-12 | S3 | 1992h | 1992h | FS_CAT256 | 52 | Yuto Nakano | yt-nakano@kddi.com | Rel-19 | 102 |
| 824 | 390 | Study on enablers for Zero Trust Security | 249d | 2024-01-03 A | 2024-12-12 A | 100% |  |  | finish no earlier than 2024-12-12 | S3 | 1992h | 1992h | FS_eZTS | 52 | Sheeba Backia Mary Baskaran | smary@lenovo.com | Rel-19 | 102 |
| 825 | 391 | Mission critical security enhancements for release 19 | 248d | 2024-01-04 A | 2024-08-30 | 99% | 2.48d | 38314.1d | finish no earlier than 2024-12-12 | S3 | 1984h |  | MCXSec4 | 52 | Woodward, Tim, Motorola Solutions, Inc. | tim.woodward@motorolasolutions.com | Rel-19 | 102 |
| 826 | 392 | Study on the security support for the Next Generation Real Time Communication services phase 2 | 375d | 2024-01-03 A | 2024-12-30 A | 100% |  |  | finish no earlier than 2025-06-06 | S3 | 3000h | 3000h | FS_NG_RTC_SEC_Ph2 | 52 | Vlasios Tsiatsis | vlasios.tsiatsis@ericsson.com | Rel-19 | 102 |
| 827 | 393 | Security support for the Next Generation Real Time Communication services Phase 2 | 63d | 2025-01-02 A | 2025-03-03 A | 100% |  |  | finish no earlier than 2025-03-03 | S3 | 504h | 504h | NG_RTC_SEC_Ph2 | 54 | Vlasios Tsiatsis, Ericsson | vlasios.tsiatsis@ericsson.com | Rel-19 | 106 |
| 828 | 394 | Study of ACME for Automated Certificate Management in SBA | 249d | 2024-01-03 A | 2024-12-12 A | 100% |  |  | finish no earlier than 2024-12-12 | S3 | 1992h | 1992h | FS_ACME_SBA | 52 | Charles Eckel | eckelcu(at)cisco.com | Rel-19 | 102 |
| 829 | 395 | Automatic Certificate Management Environment (ACME) for the Service Based Architecture (SBA) | 190.38d | 2024-12-05 A | 2025-06-06 A | 100% |  |  | finish no earlier than 2025-06-06 | S3 | 1523h | 1523h | ACME_SBA | 54 | Charles Eckel (Cisco) | eckelcu(at)cisco.com | Rel-19 | 106 |
| 830 | 396 | Roaming and interconnect authorization aspects in indirect communication | 11.5d | 2025-06-27 A | 2025-07-07 A | 100% |  |  | finish no earlier than 2025-07-07 | S3 | 92h | 92h | SBA_RoamInt-SEC | 55 | Anja Jerichow | anja.jerichow@nokia.com | Rel-19 | 108 |
| 831 | 397 | Public key distribution and Issuer claim verification of the Access Token | 2d | 2025-06-05 A | 2025-06-06 A | 100% |  |  | finish no earlier than 2025-06-06 | S3 | 16h | 16h | SBA_KDATV-SEC | 55 | Mohsin Khan | mohsin.a.khan@ericsson.com | Rel-19 | 108 |
| 832 | 398 | 3GPP profiles for cryptographic algorithms and security protocols | 249d | 2024-01-03 A | 2024-12-12 A | 100% |  |  | finish no earlier than 2024-12-12 | S3 | 1992h | 1992h | CryptoSP | 52 | Mohsin Khan A | mohsin.a.khan@ericsson.com | Rel-19 | 102 |
| 833 | 399 | Study on mitigations against bidding down attacks | 249d | 2024-01-03 A | 2024-12-12 A | 100% |  |  | finish no earlier than 2024-12-12 | S3 | 1992h | 1992h | FS_MiBiDA | 52 | Noamen Ben Henda | noamen.ben.henda@huawei.com | Rel-19 | 102 |

Notes:
- 793: Impacted TSs and TRs: 23.434; 23.436
- 794: ; 30/6/23: 23.700-72 added;; 7/9/23: 0%->15; 8/12/23: 15%->25; 14/3/24: 25%->40; 2/4/24: WID:SP-230778->SP-240295; 2/4/24: FCD:05/06/2024->/24; 13/6/24: 40%->85; 13/6/24: WID:SP-240295->SP-230778; 4/9/24: 85%->100 / Impacted TSs and TRs: 23.434 ; 23.700-72
- 795: ; 4/9/24: 0%->30; 5/12/24: 30%->100 / Impacted TSs and TRs: 23.434; 23.436
- 799: ; 7/9/23: 0%->5; 8/12/23: 5%->40; 14/3/24: 40%->90; 13/6/24: 90%->90; 4/9/24: 90%->100 / Impacted TSs and TRs: 23.280; 23.379; 23.281; 23.282
- 800: 7/9/23: 0%->0; 8/12/23: 0%->20; 14/3/24: 20%->35; 13/6/24: 35%->40; 4/9/24: 40%->50
- 801: 7/9/23: 0%->0; 8/12/23: 0%->20; 14/3/24: 20%->35; 13/6/24: 35%->40; 4/9/24: 40%->50; 5/12/24: 50%->100; 5/12/24: FCD:09/09/2024->12/24
- 802: 7/9/23: 0%->0; 8/12/23: 0%->20; 14/3/24: 20%->35; 13/6/24: 35%->40; 4/9/24: 40%->50 / Impacted TSs and TRs: 24.538, 24.544, 24.546, 29.538
- 803: 7/9/23: 0%->0; 8/12/23: 0%->20; 14/3/24: 20%->35; 13/6/24: 35%->40; 4/9/24: 40%->50 / Impacted TSs and TRs: 24.538, 24.544, 24.546, 29.538
- 804: 7/9/23: 0%->0; 8/12/23: 0%->20; 14/3/24: 20%->35; 13/6/24: 35%->40; 4/9/24: 40%->50 / Impacted TSs and TRs: 24.538, 24.544, 24.546, 29.538
- 805: ; 13/6/24: 0%->70; 5/9/24: 70%->100 / Impacted TSs and TRs: 33.501
- 806: ; 7/9/23: WID:SP-230695->SP-230988; 7/9/23: 0%->5; 8/12/23: 5%->30; 14/3/24: 30%->40; 13/6/24: 40%->60; 4/9/24: 60%->75; 5/12/24: 75%->100; 8/1/25: WID:SP-230988->SP-241691 / Impacted TSs and TRs: 23.280; 23.379; 23.281; 23.282; 23.283; 23.289
- 807: 8/12/23: 0%->25; 14/3/24: 25%->35; 13/6/24: 35%->70
- 808: 8/12/23: 0%->25; 14/3/24: 25%->35; 13/6/24: 35%->70; 4/9/24: 70%->80; 5/12/24: 80%->100
- 809: Impacted TSs and TRs: 24.543, 24.548, 29.548, 29.549
- 812: ; 8/12/23: 0%->15; 14/3/24: 15%->35 / Impacted TSs and TRs: 23.558
- 813: ; 8/12/23: 0%->15; 14/3/24: 15%->35; 13/6/24: 35%->80; 4/9/24: 80%->85; 5/12/24: 85%->100 / Impacted TSs and TRs: 23.558
- 814: Impacted TSs and TRs: 24.558,29.558
- 815: 16/7/24: FCD:06/06/2025->/25
- 816: 16/7/24: 0%->100
- 818: 5/9/24: 0%->50; 5/12/24: 50%->100
- 819: ; 8/12/23: 0%->10; 3/4/24: 33.530 added;; 13/6/24: 10%->50; 5/9/24: 50%->60; 5/12/24: 60%->80 / Impacted TSs and TRs: 33.926 ; 33.530
- 820: 8/12/23: 0%->10; 4/1/24: 33.529 added;; 14/3/24: 10%->40; 13/6/24: 40%->70; 5/9/24: 70%->40; 5/9/24: 40%->100; 5/12/24: 100%->100 / Impacted TSs and TRs: 33.529
- 821: 8/12/23: 0%->10; 4/1/24: 35.248 added;; 14/3/24: 10%->100; 2/4/24: WID:SP-231159->SP-240476 / Impacted TSs and TRs: 35.248; 35.247; 35.246; 35.245; 35.244; 35.243; 35.242; 35.241; 35.240
- 822: 4/1/24: 35.237 added;; 4/1/24: 35.236 added;; 4/1/24: 35.235 added;; 4/1/24: 35.234 added;; 14/3/24: 0%->5; 5/9/24: 5%->65; 26/9/24: WID:SP-231792->SP-241087; 5/12/24: 65%->100 / Impacted TSs and TRs: 35.237; 35.236; 35.235; 35.234
- 823: 4/1/24: 33.700-41 added;; 14/3/24: 0%->10; 13/6/24: 10%->90; 5/9/24: 90%->100 / Impacted TSs and TRs: 33.700-41
- 824: 4/1/24: 33.794 added;; 14/3/24: 0%->20; 13/6/24: 20%->50; 5/9/24: 50%->75; 5/12/24: 75%->95; 6/3/25: 95%->100; 5/6/25: 100%->100 / Impacted TSs and TRs: 33.794
- 825: ; 14/3/24: 0%->10; 5/9/24: 10%->50; 5/12/24: 50%->90; 6/3/25: 90%->95; 5/6/25: 95%->99 / Impacted TSs and TRs: 33.180
- 826: 4/1/24: 33.790 added;; 14/3/24: 0%->17; 2/4/24: WID:SP-231785->SP-240233; 13/6/24: 17%->40; 5/9/24: 40%->60; 5/12/24: 60%->80; 6/3/25: 80%->80; 6/3/25: FCD:12/12/2024->/25; 5/6/25: 80%->100 / Impacted TSs and TRs: 33.790
- 827: ; 26/3/25: WID:SP-241778->SP-250078; 27/6/25: WID:SP-250078->SP-250649; 17/9/25: 0%->100 / Impacted TSs and TRs: 33.203
- 828: 4/1/24: 33.776 added;; 14/3/24: 0%->15; 13/6/24: 15%->45; 13/6/24: FCD:06/06/2024->12/24; 5/9/24: 45%->55; 5/12/24: 55%->100; 6/3/25: 100%->100; 5/6/25: 100%->100 / Impacted TSs and TRs: 33.776
- 829: ; 6/3/25: 0%->55; 5/6/25: 55%->100 / Impacted TSs and TRs: 33.310
- 830: ; 17/9/25: 0%->100 / Impacted TSs and TRs: 33.501
- 831: ; 17/9/25: 0%->100 / Impacted TSs and TRs: 33.501
- 832: ; 14/3/24: 0%->20; 13/6/24: 20%->50; 5/9/24: 50%->80; 5/12/24: 80%->100; 6/3/25: 100%->100; 5/6/25: 100%->100 / Impacted TSs and TRs: 33.127; 33.203; 33.210; 33.222; 33.246; 33.259; 33.303; 33.310; 33.401; 33.402; 33.434; 33.501
- 833: 4/1/24: 33.701 added;; 14/3/24: 0%->20; 13/6/24: 20%->85; 13/6/24: FCD:05/06/2024->12/24; 5/9/24: 85%->100 / Impacted TSs and TRs: 33.701

| ID | WBS | Task | Duration | Start | Finish | Complete | Remaining | Total slack | Constraint | Resources | Work | Actual work | Acronym | PCG approved | WI rapporteur name | WI rapporteur e-mail | Release | TSG approved |
| --- | --- | --- | --- | --- | --- | --- | --- | --- | --- | --- | --- | --- | --- | --- | --- | --- | --- | --- |
| 834 | 400 | **Mobility over non-3GPP access to avoid full primary authentication** | 637.62d | 2024-01-03 A | 2025-09-09 | 72% | 177.2d | 37925.5d |  |  | 5383h | 3391h | Non3GPPMob_Sec | 53 | Khare, Saurabh | saurabh.khare@nokia.com | Rel-19 | 104 |
| 835 | 400.1 | Study on Security for mobility over non-3GPP access to avoid full primary authentication | 249d | 2024-01-03 A | 2024-08-30 | 25% | 187d | 38314.1d | finish no earlier than 2024-12-12 | S3 | 1992h |  | FS_Non3GPPMob_Sec | 52 | Saurabh Khare, Nokia | Saurabh.Khare@nokia.com | Rel-19 | 102 |
| 836 | 400.2 | Security for mobility over non-3GPP access to avoid full primary authentication | 132d | 2024-08-07 A | 2024-12-12 A | 100% |  |  | finish no earlier than 2024-12-12 | S3 | 1056h | 1056h | Non3GPPMob_Sec | 53 | Khare, Saurabh | saurabh.khare@nokia.com | Rel-19 | 104 |
| 837 | 400.3 | CT aspects of security for mobility over non-3GPP access to avoid full primary authentication | 291.88d | 2024-12-02 A | 2025-09-09 A | 100% |  |  | finish no earlier than 2025-09-09 | C1 | 2335h | 2335h | Non3GPPMob_Sec | 53 | Nassar, Mohamed Amin, Nokia | mohamed.a.nassar@nokia.com | Rel-19 | 104 |
| 838 | 401 | Rel-19 miscellaneous OAM&charging | 1d | 2019-03-07 | 2019-03-07 |  |  | 40387.9d |  |  |  |  |  |  |  |  | Rel-19 |  |
| 839 | 402 | Charging Aspects of Ranging and Sidelink Positioning | 312.62d | 2024-05-06 A | 2025-03-03 A | 100% |  |  | finish no earlier than 2025-03-03 | S5 | 2501h | 2501h | Ranging_SL_CH | 53 | Zhiwei Mo, China Telecom, | mozw@chinatelecom.cn | Rel-19 | 104 |
| 840 | 403 | Charging aspects for Multi-Operator Core Network (MOCN) Network Sharing | 174d | 2025-03-26 A | 2025-09-09 A | 100% |  |  | start no earlier than 2025-03-26 | S5 | 1392h | 1392h | CH_MOCN_NetShare | 54 | Robert Törnkvist, Ericsson, | robert.tornkvist@ericsson.com | Rel-19 | 107 |
| 841 | 404 | Service Based Management Architecture enhancement phase 3 | 199d | 2025-03-01 A | 2025-09-09 A | 100% |  |  | finish no earlier than 2025-09-09 | S5 | 1592h | 1592h | SBMA_Ph3 | 54 | Kai Zhang (Huawei) | kai.zhangkai@huawei.com | Rel-19 | 106 |
| 842 | 405 | Study on Management Data Analytics (MDA) Phase 3 | 249d | 2024-01-03 A | 2024-12-12 A | 100% |  |  | finish no earlier than 2024-12-12 | S5 | 1992h | 1992h | FS_eMDAS_Ph3 | 52 | Brendan T Hassett (Huawei) | brendan.t.hassett@huawei.com | Rel-19 | 102 |
| 843 | 406 | Management Data Analytics phase 3 | 199d | 2025-03-01 A | 2025-09-09 A | 100% |  |  | finish no earlier than 2025-09-09 | S5 | 1592h | 1592h | eMDAS_Ph3 | 54 | Brendan T Hassett (Huawei) | brendan.t.hassett@huawei.com | Rel-19 | 106 |
| 844 | 407 | Study on intent driven management services for mobile network phase 3 | 249d | 2024-01-03 A | 2024-12-12 A | 100% |  |  | finish no earlier than 2024-12-12 | S5 | 1992h | 1992h | FS_IDMS_MN_Ph3 | 52 | Ruiyue Xu (Huawei) | xuruiyue@huawei.com | Rel-19 | 102 |
| 845 | 408 | Intent driven management services for mobile network phase 3 | 132d | 2025-01-30 A | 2025-06-06 A | 100% |  |  | finish no earlier than 2025-06-06 | S5 | 1056h | 1056h | IDMS_MN_Ph3 | 54 | Ruiyue Xu (Huawei) | xuruiyue@huawei.com | Rel-19 | 106 |
| 846 | 409 | Study on closed control loop management | 249d | 2024-01-03 A | 2024-12-12 A | 100% |  |  | finish no earlier than 2024-12-12 | S5 | 1992h | 1992h | FS_CCLM | 52 | Deepanshu Gautam (Samsung) | deepanshu.g@samsung.com | Rel-19 | 102 |
| 847 | 410 | Study on management aspects of Network Digital Twin | 249d | 2024-01-03 A | 2024-12-12 A | 100% |  |  | finish no earlier than 2024-12-12 | S5 | 1992h | 1992h | FS_NDT | 52 | Yushuang Hu (China Mobile) | huyushuang@chinamobile.com | Rel-19 | 102 |
| 848 | 411 | Management aspects of Network Digital Twins | 199d | 2025-03-01 A | 2025-09-09 A | 100% |  |  | finish no earlier than 2025-09-09 | S5 | 1592h | 1592h | NDT | 54 | Yushuang Hu (China Mobile) | huyushuang@chinamobile.com | Rel-19 | 106 |
| 849 | 412 | Study on Enablers for Security Monitoring | 249d | 2024-01-03 A | 2024-12-12 A | 100% |  |  | finish no earlier than 2024-12-12 | S5 | 1992h | 1992h | FS_SECM | 52 | Clifton Fernandes (Nokia) | clifton.fernandes@nokia.com | Rel-19 | 102 |
| 850 | 413 | Study on Service Based Management Architecture enhancement phase 3 | 249d | 2024-01-03 A | 2024-12-12 A | 100% |  |  | finish no earlier than 2024-12-12 | S5 | 1992h | 1992h | FS_SBMA_Ph3 | 52 | Kai Zhang (Huawei) | kai.zhangkai@huawei.com | Rel-19 | 102 |
| 851 | 414 | Study on Management of planned configurations | 180d | 2024-01-04 A | 2024-09-09 A | 100% |  |  | finish no earlier than 2024-09-09 | S5 | 1440h | 1440h | FS_PlanM | 52 | Olaf Pollakowski (Nokia) | olaf.pollakowski@nokia.com | Rel-19 | 102 |
| 852 | 415 | Management of planned configurations | 384.12d | 2024-09-04 A | 2025-09-09 A | 100% |  |  | finish no earlier than 2025-09-09 | S5 | 3073h | 3073h | PlanM | 53 | Olaf Pollakowski (Nokia) | olaf.pollakowski@nokia.com | Rel-19 | 105 |
| 853 | 416 | Closed Control Loop Management | 199d | 2025-03-01 A | 2025-09-09 A | 100% |  |  | finish no earlier than 2025-09-09 | S5 | 1592h | 1592h | CCLM | 54 | Deepanshu Gautam (Samsung) | deepanshu.g@samsung.com | Rel-19 | 106 |
| 854 | 417 | Data management phase 2 | 637.62d | 2024-01-03 A | 2025-09-09 A | 100% |  |  | finish no earlier than 2025-09-09 | S5 | 5101h | 5101h | MADCOL_Ph2 | 52 | Sreekumar Pothera Kalloor (Nokia) | sreekumar.pk@nokia.com | Rel-19 | 102 |
| 855 | 418 | Study on data management regarding subscriptions and reporting | 181d | 2024-01-03 A | 2024-09-09 A | 100% |  |  | finish no earlier than 2024-09-09 | S5 | 1448h | 1448h | FS_Data_SREP | 52 | Robert Petersen (Ericsson) | robert.petersen@ericsson.com | Rel-19 | 102 |
| 856 | 419 | 5G performance measurements and KPIs phase 4 | 637.62d | 2024-01-03 A | 2025-09-09 A | 100% |  |  | finish no earlier than 2025-09-09 | S5 | 5101h | 5101h | PM_KPI_5G_Ph4 | 52 | XiuMin Chen (China Telecom) | chenxiumin@chinatelecom.cn | Rel-19 | 102 |
| 857 | 420 | 5G Advanced NRM features phase 3 | 539.12d | 2024-01-03 A | 2025-06-06 A | 100% |  |  | finish no earlier than 2025-06-06 | S5 | 4313h | 4313h | AdNRM_Ph3 | 52 | Sean Sun (Nokia) | sean.sun@nokia-sbell.com | Rel-19 | 102 |
| 858 | 421 | Subscriber and Equipment Trace and QoE collection management | 637.62d | 2024-01-03 A | 2025-09-09 A | 100% |  |  | finish no earlier than 2025-09-09 | S5 | 5101h | 5101h | TraceQoE_OAM | 52 | Zu Qiang (Ericsson) | zu.qiang@ericsson.com | Rel-19 | 102 |
| 859 | 422 | Study on Management Aspects of NTN Phase 2 | 249d | 2024-01-03 A | 2024-12-12 A | 100% |  |  | finish no earlier than 2024-12-12 | S5 | 1992h | 1992h | FS_NTN_OAM_Ph2 | 52 | MingRui Sun (China Unicom) | sunmr19@chinaunicom.cn | Rel-19 | 102 |
| 860 | 423 | Study on management of IAB nodes | 249d | 2024-01-03 A | 2024-12-12 A | 100% |  |  | finish no earlier than 2024-12-12 | S5 | 1992h | 1992h | FS_NR_mobile_IAB_OAM | 52 | JunFeng Wang (Ericsson) | junfeng.a.wang@ericsson.com | Rel-19 | 102 |
| 861 | 424 | Management of IAB nodes | 296.25d | 2025-03-01 A | 2025-12-12 A | 100% |  |  | finish no earlier than 2025-12-12 | S5 | 2370h | 2370h | NR_mobile_IAB_OAM | 54 | JunFeng Wang (Ericsson) | junfeng.a.wang@ericsson.com | Rel-19 | 106 |
| 862 | 425 | Study on management aspects of RedCap feature | 249d | 2024-01-03 A | 2024-12-12 A | 100% |  |  | finish no earlier than 2024-12-12 | S5 | 1992h | 1992h | FS_NR_RedCap_OAM | 52 | Zhen Xing (China Unicom) | xingz12@chinaunicom.cn | Rel-19 | 102 |
| 863 | 426 | Study on Enhancement of Management Aspects related to NWDAF Phase 2 | 181d | 2024-01-03 A | 2024-09-09 A | 100% |  |  | finish no earlier than 2024-09-09 | S5 | 1448h | 1448h | FS_NWDAF_OAM_Ph2 | 52 | Song Zhao (China Telecom) | zhaosong1@chinatelecom.cn | Rel-19 | 102 |
| 864 | 427 | Enhancement of Management Aspects Related of NWDAF Phase 2 | 285.62d | 2024-09-04 A | 2025-06-06 A | 100% |  |  | finish no earlier than 2025-06-06 | S5 | 2285h | 2285h | NWDAF_OAM_Ph2 | 53 | Song Zhao (China Telecom) | zhaosong1@chinatelecom.cn | Rel-19 | 105 |
| 865 | 428 | Study on Management of Network Sharing Phase3 | 249d | 2024-01-03 A | 2024-12-12 A | 100% |  |  | finish no earlier than 2024-12-12 | S5 | 1992h | 1992h | FS_NetShare_OAM_Ph3 | 52 | ZhaoNing Wang (China Unicom) | wangzn18@chinaunicom.cn | Rel-19 | 102 |
| 866 | 429 | Study on Enhanced OAM for management exposure to external consumers | 249d | 2024-01-03 A | 2024-12-12 A | 100% |  |  | finish no earlier than 2024-12-12 | S5 | 1992h | 1992h | FS_MExpo | 52 | Srilakshmi Srinivasaraju (Nokia) | srilakshmi.s@nokia.com | Rel-19 | 102 |
| 867 | 430 | Rel-19 other | 1d | 2019-03-07 | 2019-03-07 |  |  | 40387.9d |  |  |  |  |  |  |  |  | Rel-19 |  |

Notes:
- 834: ; 26/9/24: WID:SP-240653->SP-241088 / Impacted TSs and TRs: 33.501
- 835: 4/1/24: 33.702 added;; 14/3/24: 0%->25 / Impacted TSs and TRs: 33.702
- 836: ; 26/9/24: WID:SP-240653->SP-241088; 17/9/25: 0%->100 / Impacted TSs and TRs: 33.501
- 837: Impacted TSs and TRs: 24.502
- 839: ; 4/9/24: 20%->50; 5/12/24: 50%->100. 12/09/25: Rel-18->Rel-19; 12/9/25: FCD:Sat 30/11/->03/25 / Impacted TSs and TRs: 32.240; 32.290; 32.271; 32.291; 32.298
- 840: ; 6/6/25: 0%->75; 27/6/25: WID:SP-250371->SP-250819; 12/9/25: 75%->100 / Impacted TSs and TRs: 32.130; 32.240; 32.255; 32.291; 32.298 ; 28.201
- 841: ; 6/3/25: 0%->40; 6/6/25: 40%->90; 12/9/25: 90%->100 / Impacted TSs and TRs: 32.156; 28.532; 28.533; 28.537; 28.622; 28.623; 28.530; 28.550; 32.421; 32.422; 32.423; 28.404; 28.405; 28.406; 28.552; 28.554; 28.558; 32.130; 28.313; 28.314; 28.623; 28.310; 28.530; 28.531; 28.111; 28.550; 28.621; 28.623; 32.421; 32.422; 28.404; 28.405;
- 842: 13/6/24: 0%->70; 16/7/24: WID:SP-231726->SP-240968; 4/9/24: 70%->90; 4/9/24: FCD:09/09/2024->12/24; 26/9/24: WID:SP-240968->SP-241157; 5/12/24: 90%->100
- 843: ; 6/3/25: 0%->30; 6/6/25: 30%->85; 12/9/25: 85%->100 / Impacted TSs and TRs: 28.104
- 844: 14/3/24: 0%->5; 13/6/24: 5%->70; 4/9/24: 70%->95; 4/9/24: FCD:09/09/2024->12/24; 5/12/24: 95%->100
- 845: ; 6/3/25: 0%->65; 6/6/25: 65%->100 / Impacted TSs and TRs: 28.312
- 846: 14/3/24: 0%->5; 13/6/24: 5%->40; 4/9/24: 40%->90; 4/9/24: FCD:09/09/2024->12/24; 5/12/24: 90%->100
- 847: 4/1/24: 28.915 added;; 14/3/24: 0%->5; 13/6/24: 5%->65; 13/6/24: WID:SP-231428->SP-231727; 4/9/24: 65%->95; 4/9/24: FCD:09/09/2024->12/24; 5/12/24: 95%->100 / Impacted TSs and TRs: 28.915
- 848: 6/3/25: 0%->10; 6/6/25: 10%->95; 12/9/25: 95%->100
- 849: 4/1/24: 28.870 added;; 4/9/24: 0%->90; 4/9/24: FCD:09/09/2024->12/24; 5/12/24: 90%->100 / Impacted TSs and TRs: 28.870
- 850: 13/6/24: 0%->45; 4/9/24: 45%->75; 4/9/24: FCD:09/09/2024->12/24; 5/12/24: 75%->100; 8/1/25: WID:SP-231725->SP-241569
- 851: 4/1/24: 28.872 added;; 13/6/24: 0%->60; 4/9/24: 60%->100 / Impacted TSs and TRs: 28.872
- 852: 26/9/24: 28.572 added;; 5/12/24: 0%->60; 6/3/25: 60%->75; 6/6/25: 75%->75; 6/6/25: FCD:Fri 06/06/->/25; 12/9/25: 75%->100 / Impacted TSs and TRs: 28.572
- 853: ; 6/3/25: 0%->10; 6/6/25: 10%->80; 12/9/25: 80%->100 / Impacted TSs and TRs: 28.535; 28.536; 28.622; 32.161
- 854: ; 13/6/24: 0%->50; 16/7/24: WID:SP-231746->SP-240877; 4/9/24: 50%->80; 5/12/24: 80%->88. 03/25: Rapporteur updated from sivaramakrishnan.swaminathan@nokia.com; 26/3/25: WID:SP-240877->SP-250116; 26/3/25: FCD:30/12/2024->/25; 6/6/25: 88%->88; 6/6/25: FCD:; 12/9/25: 88%->100 / Impacted TSs and TRs: 28.622; 28.623
- 855: 13/6/24: 0%->60; 4/9/24: 60%->100
- 856: ; 13/6/24: 0%->20; 4/9/24: 20%->30; Rapporteur update: Xiebaoguo->Ruan bang qiu (ruan.bangqiu@zte.com.cn); 26/9/24: WID:SP-231747->SP-241155; 5/12/24: 30%->65; 6/3/25: 65%->75; 6/6/25: 75%->90; 6/6/25: FCD:Mon 30/12/->/25; 27/6/25: WID:SP-241155->SP-2505; 12/9/25: 90%->100 / Impacted TSs and TRs: 28.552; 32.425; 28.554; 28.532; 28.550; 28.558; 32.404; 32.401
- 857: ; 13/6/24: 0%->15; 16/7/24: WID:SP-231745->SP-240875; 4/9/24: 15%->30; 5/12/24: 30%->60; 8/1/25: WID:SP-240875->SP-241565; 6/3/25: 60%->75; 26/3/25: WID:SP-241565->SP-250123; 26/3/25: FCD:30/12/2024->/25; 6/6/25: 75%->100 / Impacted TSs and TRs: 28.540; 28.541; 28.622; 28.623
- 858: ; 13/6/24: 0%->20; 4/9/24: 20%->40; 5/12/24: 40%->75; 6/3/25: 75%->80; 26/3/25: WID:SP-231748->SP-250115; 6/6/25: FCD:Mon 30/12/->/25; 12/9/25: 80%->100 / Impacted TSs and TRs: 32.421; 32.422; 32.423; 28.404; 28.405; 28.406; 28.622; 28.623
- 859: 13/6/24: 0%->65; 4/9/24: 65%->90; 4/9/24: FCD:09/09/2024->12/24; 5/12/24: 90%->100
- 860: 13/6/24: 0%->40; 13/6/24: FCD:09/09/2024->12/24; 4/9/24: 40%->90; 5/12/24: 90%->100
- 861: ; 6/6/25: 0%->70; 12/9/25: 70%->90; 12/9/25: FCD:Tue 09/09/->12/25; 4/12/25: 90%->100; 4/12/25: 100%-> / Impacted TSs and TRs: 28.541; 28.540; 28.531; 28.314; 28.315
- 862: 13/6/24: 0%->50; 4/9/24: 50%->75; 4/9/24: FCD:09/09/2024->12/24; 5/12/24: 75%->100
- 863: 13/6/24: 0%->75; 4/9/24: 75%->100
- 864: ; 5/12/24: 0%->60; 6/3/25: 60%->65; 6/6/25: 65%->100 / Impacted TSs and TRs: 28.552; 28.541
- 865: 13/6/24: 0%->50; 16/7/24: WID:SP-231731->SP-240966; 4/9/24: 50%->90; 4/9/24: FCD:09/09/2024->12/24; 5/12/24: 90%->100
- 866: 14/3/24: 0%->5; 13/6/24: 5%->50; 16/7/24: WID:SP-231728->SP-240967; 4/9/24: 50%->60; 4/9/24: FCD:09/09/2024->12/24; 5/12/24: 60%->100; 8/1/25: WID:SP-240967->SP-241570

| ID | WBS | Task | Type | Duration | Start | Finish | Complete | Actual start | Actual finish | Constraint | Resources | Work | Actual work | Acronym | PCG approved | WI rapporteur name | WI rapporteur e-mail | Release | TSG approved |
| --- | --- | --- | --- | --- | --- | --- | --- | --- | --- | --- | --- | --- | --- | --- | --- | --- | --- | --- | --- |
| 868 | 431 | **Reducing Information Exposure over SBI** |  | 855d | 2023-06-07 A | 2025-09-09 A | 100% |  |  |  |  | 2938h | 2938h | RedInfExp_SBI | 51 | Nivedya P S, Samsung | nivedya.ps@samsung.com | Rel-19 | 100 |
| 869 | 431.1 | Study on Reducing Information Exposure over SBI |  | 136d | 2023-06-07 A | 2023-12-12 A | 100% |  |  | finish no earlier than 2023-12-12 | C4 | 1088h | 1088h | FS_RedInfExp_SBI | 51 | Varini Gupta, Samsung | varini.gupta@samsung.com | Rel-19 | 100 |
| 870 | 431.2 | Reducing Information Exposure over SBI |  | 231.25d | 2024-12-02 A | 2025-09-09 A | 100% |  |  | finish no earlier than 2025-09-09 | C4 | 1850h | 1850h | RedInfExp_SBI | 51 | Nivedya P S, Samsung | nivedya.ps@samsung.com | Rel-19 | 100 |
| 871 | 432 | Study on IMS Disaster Prevention and Restoration Enhancement |  | 576.75d | 2022-08-25 A | 2024-03-03 A | 100% |  |  | finish no earlier than 2024-03-03 | C4 | 3192h | 3192h | FS_IMS_RES | 49 | Liu, Liu, China Telecom | liuliu66@chinatelecom.cn | Rel-19 | 96 |
| 872 | 433 | **IMS Disaster Prevention and Restoration Enhancement** |  | 477.38d | 2024-06-06 | 2025-09-09 A | 100% | 2025-06-06 |  |  |  | 2388h | 2388h | IMS_RES-CT | 49 | Liu, Liu, China Telecom | liuliu66@chinatelecom.cn | Rel-19 | 96 |
| 873 | 433.1 | CT1 aspects of IMS Disaster Prevention and Restoration Enhancement | manual | 99.5d | 2025-06-06 A | 2025-09-09 A | 100% |  |  | finish no earlier than 2025-09-09 | C1 | 796h | 796h | IMS_RES-CT | 49 | Liu, Liu, China Telecom | liuliu66@chinatelecom.cn | Rel-19 | 96 |
| 874 | 433.2 | CT3 aspects of IMS Disaster Prevention and Restoration Enhancement | manual | 99.5d | 2025-06-06 A | 2025-09-09 A | 100% |  |  | finish no earlier than 2025-09-09 | C3 | 796h | 796h | IMS_RES-CT | 49 | Liu, Liu, China Telecom | liuliu66@chinatelecom.cn | Rel-19 | 96 |
| 875 | 433.3 | CT4 aspects of IMS Disaster Prevention and Restoration Enhancement | manual | 99.5d | 2025-06-06 A | 2025-09-09 A | 100% |  |  | finish no earlier than 2025-09-09 | C4 | 796h | 796h | IMS_RES-CT | 49 | Liu, Liu, China Telecom | liuliu66@chinatelecom.cn | Rel-19 | 96 |
| 876 | 434 | Study on Film Grain Synthesis |  | 331d | 2023-06-08 A | 2024-09-09 A | 100% |  |  | finish no earlier than 2025-03-03 | S4 | 2648h | 2648h | FS_FGS | 51 | Brian Lee (Dolby Laboratories) | Brian.Lee@dolby.com | Rel-19 | 100 |
| 877 | 435 | Study of Avatars in Real-Time Communication Services |  | 456d | 2023-06-08 A | 2025-03-03 A | 100% |  |  | finish no earlier than 2025-03-03 | S4 | 3648h | 3648h | FS_AVATAR | 51 | Bouazizi, Imed, Qualcomm Incorporated | bouazizi AT qti DOT qualcomm DOT com | Rel-19 | 100 |
| 878 | 436 | **Service Based Interface Protocol Improvements Release 19** |  | 465.88d | 2024-06-17 A | 2025-09-09 A | 100% |  |  |  |  | 7454h | 7454h | SBIProtoc19 | 51 | Wang Rong, China Mobile | wangrongyjy@chinamobile.com | Rel-19 | 101 |
| 879 | 436.1 | CT3 aspects of Service Based Interface Protocol Improvements Release 19 |  | 465.88d | 2024-06-17 A | 2025-09-09 A | 100% |  |  | finish no earlier than 2025-09-09 | C3 | 3727h | 3727h | SBIProtoc19 | 51 | Wang Rong, China Mobile | wangrongyjy@chinamobile.com | Rel-19 | 101 |
| 880 | 436.2 | CT4 aspects of Service Based Interface Protocol Improvements Release 19 |  | 465.88d | 2024-06-17 A | 2025-09-09 A | 100% |  |  | finish no earlier than 2025-09-09 | C4 | 3727h | 3727h | SBIProtoc19 | 51 | Wang Rong, China Mobile | wangrongyjy@chinamobile.com | Rel-19 | 101 |
| 881 | 437 | **Lower Selection-priority for PLMN Selection** |  | 477.38d | 2024-06-06 A | 2025-09-09 A | 100% |  |  |  |  | 7912h | 7912h | LoSePLMN | 51 | Wang Rong, China Mobile | wangrongyjy@chinamobile.com | Rel-19 | 101 |
| 882 | 437.1 | Stage 1 for Lower Selection-priority for PLMN Selection |  | 34.25d | 2025-08-08 A | 2025-09-09 A | 100% |  |  | finish no earlier than 2025-09-09 | S1 | 274h | 274h | LoSePLMN-REQ | 55 | Cristina Romaguera, Vodafone | cristina.romaguera@vodafone.com | Rel-19 | 109 |
| 883 | 437.2 | **CT aspects of Lower Selection-priority for PLMN Selection** |  | 477.38d | 2024-06-06 A | 2025-09-09 A | 100% |  |  |  |  | 7638h | 7638h | LoSePLMN-CT | 51 | Yang Lu; Vodafone | yang.lu@vodafone.com | Rel-19 | 101 |
| 884 | 437.2.1 | CT aspects of Lower Selection-priority for PLMN Selection |  | 477.38d | 2024-06-06 A | 2025-09-09 A | 100% |  |  | start no earlier than 2024-06-06 | C1 | 3819h | 3819h | LoSePLMN-CT | 51 | Yang Lu; Vodafone | yang.lu@vodafone.com | Rel-19 | 101 |
| 885 | 437.2.2 | CT aspects of Lower Selection-priority for PLMN Selection |  | 477.38d | 2024-06-06 A | 2025-09-09 A | 100% |  |  | start no earlier than 2024-06-06 | C6 | 3819h | 3819h | LoSePLMN-CT | 51 | Yang Lu; Vodafone | yang.lu@vodafone.com | Rel-19 | 101 |
| 886 | 438 | Subscriber Data Migration |  | 465.88d | 2024-06-17 A | 2025-09-09 A | 100% |  |  | finish no earlier than 2025-09-09 | C4 | 3727h | 3727h | SUBDMIG | 51 | Jesus de Gregorio, Ericsson | Jesus de Gregorio, jesus.de.gregorio@ericsson.com | Rel-19 | 101 |
| 887 | 439 | Rel-19 Enhancements of Network Automation Enablers |  | 465.88d | 2024-06-17 A | 2025-09-09 A | 100% |  |  | finish no earlier than 2025-09-09 | C3 | 3727h | 3727h | eNetAE19 | 51 | Xuefei Zhang (Huawei) | summer.xuefei@huawei.com | Rel-19 | 101 |
| 888 | 440 | **Protocol for AI Data Collection from UPF** |  | 675.12d | 2024-06-17 A | 2026-03-30 | 100% |  | 2025-09-09 |  |  | 11181h | 11181h | PAIDC_UPF | 51 | Huang Zhenning, China Mobile | huangzhenning@chinamobile.com | Rel-19 | 101 |
| 889 | 440.1 | Study on Protocol for AI Data Collection from UPF |  | 465.88d | 2024-06-17 A | 2025-09-09 A | 100% |  |  | finish no earlier than 2025-09-09 | C4 | 3727h | 3727h | FS_PAIDC_UPF | 51 | Huang Zhenning, China Mobile | huangzhenning@chinamobile.com | Rel-19 | 101 |
| 890 | 440.2 | **CT aspects of PAIDC_UPF** |  | 465.88d | 2024-06-17 A | 2025-09-09 A | 100% |  |  |  |  | 7454h | 7454h | PAIDC_UPF | 51 | Wang Rong, China Mobile | wangrongyjy@chinamobile.com | Rel-19 | 101 |
| 891 | 440.2.1 | CT3 aspects of PAIDC_UPF |  | 465.88d | 2024-06-17 A | 2025-09-09 A | 100% |  |  | finish no earlier than 2026-03-30 | C3 | 3727h | 3727h | PAIDC_UPF | 51 | Wang Rong, China Mobile | wangrongyjy@chinamobile.com | Rel-19 | 101 |
| 892 | 440.2.2 | CT4 aspects of PAIDC_UPF |  | 465.88d | 2024-06-17 A | 2025-09-09 A | 100% |  |  | finish no earlier than 2026-03-30 | C4 | 3727h | 3727h | PAIDC_UPF | 51 | Wang Rong, China Mobile | wangrongyjy@chinamobile.com | Rel-19 | 101 |

Notes:
- 868: 30/6/23: 29.857 added;; 3/4/25: WID:CP-243019->CP-243308
- 869: 30/6/23: 29.857 added; / Impacted TSs and TRs: 29.857
- 870: 30/6/23: 29.857 added; / Impacted TSs and TRs: 29.510, 29.500
- 871: 21/9/23: 29.866 added; / Impacted TSs and TRs: 29.xxx; 29.866
- 872: Impacted TSs and TRs: 23.380, 24.229, 23.334, 29.244, 29.500, 29.562, 29.228, 29.229, 29.230, 29.334, 29.214, 29.514, 29.212, 29.512, 29.213, 29.513
- 876: ; 7/9/23: 0%->10; 8/12/23: 10%->20; 8/12/23: FCD:12/12/2023->/2024; 14/3/24: 20%->30; 14/3/24: FCD:03/03/2024->3/3/25; Rel-18->Rel-19; 13/6/24: 30%->; 4/9/24: 30%->100; 4/9/24: FCD:03/03/2025->09/24; 4/9/24: WID:SP-230539->SP-241120 ; 26/9/24: WID:SP-...; 26/9/24: 26.855 added; / Impacted TSs and TRs: 26.955 ; 26.855
- 877: 7/9/23: 0%->5; 21/9/23: 26.813 added;; 8/12/23: 5%->20; 14/3/24: 20%->30; 14/3/24: FCD:03/03/2024->12/24; ; Rel-18->Rel-19; 13/6/24: 30%->50; 4/9/24: 50%->55; 5/12/24: 55%->60; 5/12/24: FCD:12/12/2024->/25; 6/3/25: 60%->100 / Impacted TSs and TRs: 26.813
- 881: 29/9/25: Compl:54%->52%;
- 882: ; 12/9/25: 0%->100; 12/9/25: 100%->100 / Impacted TSs and TRs: 22.011
- 883: 29/9/25: List of Impacted TS & TR updated; / Impacted TSs and TRs: 23.122, 24.368, 31.102
- 886: Impacted TSs and TRs: 23.527,29.503,29.504,29.510,29.571
- 887: Impacted TSs and TRs: 29.508, 29.517, 29.520, 29.522, 29.552, 29.574, 29.575, 29.576, 29.591
- 888: 29/9/25: FCD:Tue 09/09/25->Mon 30/03/26; Compl:97%->98%;
- 890: 29/9/25: FCD:Tue 09/09/25->Mon 30/03/26; WID: CP-252016->CP-252243; / Impacted TSs and TRs: 29.564, 29.508
- 891: 29/9/25: FCD:Tue 09/09/25->Mon 30/03/26; WID: CP-252016->CP-252243; / Impacted TSs and TRs: 29.564, 29.508
- 892: 29/9/25: FCD:Tue 09/09/25->Mon 30/03/26; WID: CP-252016->CP-252243; / Impacted TSs and TRs: 29.564, 29.508

| ID | WBS | Task | Type | Duration | Start | Finish | Complete | Remaining | Total slack | Constraint | Resources | Work | Actual work | Acronym | PCG approved | WI rapporteur name | WI rapporteur e-mail | Release | TSG approved | Status Report | TSG stopped |
| --- | --- | --- | --- | --- | --- | --- | --- | --- | --- | --- | --- | --- | --- | --- | --- | --- | --- | --- | --- | --- | --- |
| 893 | 441 | **IMS Stage-3 IETF Protocol Alignment** |  | 465.88d | 2024-06-17 A | 2025-09-09 A | 100% |  |  |  |  | 7454h | 7454h | IMSProtoc19 | 51 | Won, Sung Hwan, Nokia | sung.won@nokia.com | Rel-19 | 101 |  |  |
| 894 | 441.1 | CT1 aspects of IMS Stage-3 IETF Protocol Alignment |  | 465.88d | 2024-06-17 A | 2025-09-09 A | 100% |  |  | finish no earlier than 2025-09-09 | C1 | 3727h | 3727h | IMSProtoc19 | 51 | Won, Sung Hwan, Nokia | sung.won@nokia.com | Rel-19 | 101 |  |  |
| 895 | 441.2 | CT3 aspects of IMS Stage-3 IETF Protocol Alignment |  | 465.88d | 2024-06-17 A | 2025-09-09 A | 100% |  |  | finish no earlier than 2025-09-09 | C3 | 3727h | 3727h | IMSProtoc19 | 51 | Won, Sung Hwan, Nokia | sung.won@nokia.com | Rel-19 | 101 |  |  |
| 896 | 442 | **Protocol enhancements for Mission Critical Services** |  | 465.88d | 2024-06-17 A | 2025-09-09 A | 100% |  |  |  |  | 10030h | 10030h | MCProtoc19 | 51 | Magnus Tränk, Ericsson | magnus.trank@ericsson.com | Rel-19 | 101 |  |  |
| 897 | 442.1 | CT1 aspects of Protocol enhancements for Mission Critical Services |  | 465.88d | 2024-06-17 A | 2025-09-09 A | 100% |  |  | finish no earlier than 2025-09-09 | C1 | 3727h | 3727h | MCProtoc19 | 51 | Magnus Tränk, Ericsson | magnus.trank@ericsson.com | Rel-19 | 101 |  |  |
| 898 | 442.2 | CT3 aspects of Protocol enhancements for Mission Critical Services |  | 465.88d | 2024-06-17 A | 2025-09-09 A | 100% |  |  | finish no earlier than 2025-09-09 | C3 | 3727h | 3727h | MCProtoc19 | 51 | Magnus Tränk, Ericsson | magnus.trank@ericsson.com | Rel-19 | 101 |  |  |
| 899 | 442.3 | CT4 aspects of Protocol enhancements for Mission Critical Services |  | 322d | 2024-11-03 A | 2025-09-09 A | 100% |  |  | finish no earlier than 2025-09-09 | C4 | 2576h | 2576h | MCProtoc19 | 51 | Magnus Tränk, Ericsson | magnus.trank@ericsson.com | Rel-19 | 101 |  |  |
| 900 | 443 | **Enhancement of controlling RAT utilization** |  | 465.88d | 2024-06-17 A | 2025-09-09 A | 100% |  |  |  |  | 7454h | 7454h | ECRATU | 51 | Yang Lu, Vodafone | yang.lu@vodafone.com | Rel-19 | 101 |  |  |
| 901 | 443.1 | CT1 aspects of Enhancement of controlling RAT utilization |  | 465.88d | 2024-06-17 A | 2025-09-09 A | 100% |  |  | finish no earlier than 2025-09-09 | C1 | 3727h | 3727h | ECRATU | 51 | Yang Lu, Vodafone | yang.lu@vodafone.com | Rel-19 | 101 |  |  |
| 902 | 443.2 | CT4 aspects of Enhancement of controlling RAT utilization |  | 465.88d | 2024-06-17 A | 2025-09-09 A | 100% |  |  | finish no earlier than 2025-09-09 | C4 | 3727h | 3727h | ECRATU | 51 | Yang Lu, Vodafone | yang.lu@vodafone.com | Rel-19 | 101 |  |  |
| 903 | 444 | Enhanced Mission Critical Location Management |  | 465.88d | 2024-06-17 A | 2025-09-09 A | 100% |  |  | finish no earlier than 2025-09-09 | C1 | 3727h | 3727h | enhMCLoc | 51 | Magnus Tränk, Ericsson | magnus.trank@ericsson.com | Rel-19 | 101 |  |  |
| 904 | 445 | Alignment of eCall over IMS with CEN |  | 280.38d | 2024-09-09 A | 2025-06-06 A | 100% |  |  | finish no earlier than 2025-06-06 | C1 | 2243h | 2243h | eCallCEN | 51 | Osama Lotfallah, Qualcomm Incorporated | osamal@qti.qualcomm.com | Rel-19 | 101 |  |  |
| 905 | 446 | UE Conformance - Alignment of eCall over IMS with CEN |  | 554.75d | 2024-09-14 A | 2026-03-03 | 96% | 22.19d | 37744.2d | finish no earlier than 2026-03-03 | R5 | 4438h |  | eCallCEN-UEConTest | 54 | Qualcomm |  | Rel-19 | 106 | RP-253177 |  |
| 906 | 447 | Rel-19 Enhancements of UE Policy |  | 244.75d | 2024-12-02 A | 2025-09-09 A | 100% |  |  | finish no earlier than 2025-09-09 | C3 | 1958h | 1958h | UEP19 | 51 | Susana Fernández, Ericsson | Susana.fernandez@ericsson.com | Rel-19 | 101 |  |  |
| 907 | 448 | Rel-19 Enhancements of SM Policy |  | 197.75d | 2025-03-03 A | 2025-09-09 A | 100% |  |  | finish no earlier than 2025-09-09 | C3 | 1582h | 1582h | SMPC19 | 51 | Chi Zhang, Huawei | margo.zhangchi@huawei.com | Rel-19 | 101 |  |  |
| 908 | 449 | CT Aspects for IP Domain usage |  | 197.75d | 2025-03-03 A | 2025-09-09 A | 100% |  |  | finish no earlier than 2025-09-09 | C3 | 1582h | 1582h | IPD | 51 | Zhenning Huang, China Mobile | huangzhenning@chinamobile.com | Rel-19 | 101 |  |  |
| 909 | 450 | NAS layer overhead reduction for data transfer using CP CIoT |  | 291.88d | 2024-12-02 A | 2025-09-09 A | 100% |  |  | finish no earlier than 2026-01-13 | C1 | 2335h | 2335h | NORDAT_CP | 51 | Amer Catovic | amerc@qti.qualcomm.com | Rel-19 | 101 |  |  |
| 910 | 451 | **Support for PWS in Satellite E-UTRAN and Satellite NG-RAN** |  | 197.75d | 2025-03-03 A | 2025-09-09 A | 100% |  |  |  |  | 3140h | 3140h | PWS_NTN | 51 | Amer Catovic | amerc@qti.qualcomm.com | Rel-19 | 101 |  |  |
| 911 | 451.1 | CT1 aspects of Support for PWS in Satellite E-UTRAN and Satellite NG-RAN |  | 197.75d | 2025-03-03 A | 2025-09-09 A | 100% |  |  | finish no earlier than 2025-09-09 | C1 | 1582h | 1582h | PWS_NTN | 51 | Amer Catovic | amerc@qti.qualcomm.com | Rel-19 | 101 |  |  |
| 912 | 451.2 | DELETED - CT4 aspects of Support for PWS in Satellite E-UTRAN and Satellite NG-RAN |  | 194.75d | 2025-03-06 A | 2025-09-09 A | 100% |  |  | start no earlier than 2025-03-06 | C4 | 1558h | 1558h | PWS_NTN | 51 | Amer Catovic | amerc@qti.qualcomm.com | Rel-19 | 101 |  | 108 |
| 913 | 452 | **Stage-3 5GS NAS protocol development 18** |  | 465.88d | 2024-06-17 A | 2025-09-09 A | 100% |  |  |  |  | 7454h | 7454h | 5GProtoc19 | 49 | Sedlacek, Ivo, Ericsson, | ivo <dot> sedlacek <at> ericsson <dot> com | Rel-19 | 96 |  |  |
| 914 | 452.1 | Stage-3 5GS NAS protocol development 18 general aspects |  | 465.88d | 2024-06-17 A | 2025-09-09 A | 100% |  |  | finish no earlier than 2025-09-09 | C1 | 3727h | 3727h | 5GProtoc19 | 49 | Sedlacek, Ivo, Ericsson, | ivo <dot> sedlacek <at> ericsson <dot> com | Rel-19 | 96 |  |  |
| 915 | 452.2 | Stage-3 5GS NAS protocol development 18 non 3GPP aspects |  | 465.88d | 2024-06-17 A | 2025-09-09 A | 100% |  |  | finish no earlier than 2025-09-09 | C1 | 3727h | 3727h | 5GProtoc19-non3GPP | 49 | Sedlacek, Ivo, Ericsson, | ivo <dot> sedlacek <at> ericsson <dot> com | Rel-19 | 96 |  |  |
| 916 | 453 | **Stage-3 SAE Protocol Development** |  | 465.88d | 2024-06-17 A | 2025-09-09 A | 100% |  |  |  |  | 7454h | 7454h | SAES19 | 49 | Sethi, Anuj, InterDigital |  | Rel-19 | 96 |  |  |
| 917 | 453.1 | Stage-3 SAE Protocol Development general |  | 465.88d | 2024-06-17 A | 2025-09-09 A | 100% |  |  | finish no earlier than 2025-09-09 | C1 | 3727h | 3727h | SAES19 | 49 | Sethi, Anuj, InterDigital |  | Rel-19 | 96 |  |  |
| 918 | 453.2 | Stage-3 SAE Protocol Development non 3GPP |  | 465.88d | 2024-06-17 A | 2025-09-09 A | 100% |  |  | finish no earlier than 2025-09-09 | C1 | 3727h | 3727h | SAES19-non3GPP | 49 | Sethi, Anuj, InterDigital |  | Rel-19 | 96 |  |  |
| 919 | 454 | Lawful Interception Rel-19 |  | 385d | 2023-03-24 A | 2024-03-30 | 15% | 327.25d | 38473.2d | finish no earlier than 2024-09-09 | S3LI | 3080h |  | LI19 | 49 | Koen Jaspers, PIDS | kbj@xs4all.nl | Rel-19 | 97 |  |  |
| 920 | 455 | Lawful Interception Guidance Rel-19 |  | 165d | 2024-07-16 A | 2024-12-22 | 52% | 79.2d | 38196.4d | finish no earlier than 2025-03-03 | S3LI | 1320h |  | LI19_Guide | 53 | Nag Rao, Nokia, | nagaraja.rao@nokia.com | Rel-19 | 104 |  |  |
| 921 | 456 | Harmonization of test case definitions for cross-RAT usability |  | 280.75d | 2025-06-06 | 2026-03-03 |  |  | 37744.2d | finish no earlier than 2026-03-03 | C6 | 2246h |  | TestHarmon_CrossRAT | 54 | Arne Marquordt, COMPRION GmbH | amarquordt@comprion.com | Rel-19 | 106 |  |  |
| 922 | 457 | (Small) Technical Enhancements and Improvements for Rel-19 |  | 67d | 2022-09-09 A | 2022-11-12 |  | 67d | 38994.2d | finish no earlier than 2022-12-12 |  |  |  | TEI19 | 47 |  |  | Rel-19 | 92 |  |  |
| 923 | 458 | Test - (Small) Technical Enhancements and Improvements for Rel-18 |  | 67d | 2022-09-09 | 2022-11-12 |  |  | 38994.2d | finish no earlier than 2022-11-12 | R5 | 536h |  | TEI19_Test |  |  |  | Rel-19 |  |  |  |
| 924 | 459 | LI Handling of Protected Services |  | 281.75d | 2025-06-05 | 2026-03-03 |  |  | 37744.2d | finish no earlier than 2026-03-03 | S3LI | 2254h |  | FS_LIHOPES | 55 | Mats Näslund, NDRE | mats.naslund@fra.se | Rel-19 | 108 |  |  |
| 925 | 460 | --- RELEASE 18 --- | milestone | 0d? | 2016-03-15 A | 2016-03-15 A | 100% |  |  | start no earlier than 2016-03-15 |  |  |  |  |  |  |  | Rel-18 |  |  |  |
| 926 | 461 | Rel-18 Satellite (5GSAT), NTN | milestone | 0d? | 2016-03-15 A | 2016-03-15 A | 100% |  |  | start no earlier than 2016-03-15 |  |  |  |  |  |  |  | Rel-18 |  |  |  |

Notes:
- 893: Impacted TSs and TRs: 23.218, 24.229, 24.930, 24.186, 29.163, 29.165, 29.292
- 900: Impacted TSs and TRs: 24.301, 24.501, 23.122, 29.272, 29.503
- 903: Impacted TSs and TRs: 24.281,24.282,24.283,24.379,24.481,24.482,24.483,24.484,29.379
- 904: Impacted TSs and TRs: 24.229
- 905: 6/3/25: Compl:0%->80%; Stat Rep: ->RP-250112; ; 6/6/25: FCD:Fri 06/06/25->Fri 12/12/25; Compl:80%->90%; Stat Rep: RP-250112->RP-251190; ; 11/9/25: FCD:Fri 12/12/25->Tue 03/03/26; Compl:90%->94%; Stat Rep: RP-251190->RP-251962; ; 29/9/25: WID:RP-242495->RP; 3/12/25: Compl:94%->96%; Stat Rep: RP-251962->RP-253177;
- 906: Impacted TSs and TRs: 29.525, 29.523, 29.519, 29.522, 29.513
- 907: Impacted TSs and TRs: 29.512, 29.513
- 908: Impacted TSs and TRs: 29.213, 29.513
- 909: 29/9/25: FCD:Tue 09/09/25->Tue 13/01/26; WID: CP-250251->CP-252195; / Impacted TSs and TRs: 24.301, 24.007
- 910: Impacted TSs and TRs: 23.041
- 919: ; 16/3/23: WID:SP-220752->SP-230242; 16/3/23: FCD:03/03/2024->9/9/2024. Rapporteur changed from Alex Leadbeater; 5/9/24: 0%->10; 5/12/24: 10%->15; 26/3/25: WID:SP-230242->SP-250372; 27/6/25: WID:SP-250372->SP-250817; 18/7/25: 33.129-2 added;; 18/7/25: 33.129-1 added; / Impacted TSs and TRs: 33.107; 33.108; 33.126; 33.127; 33.128 ; 33.129-2; 33.129-2; 33.129-1
- 920: 5/12/24: 0%->52
- 921: Impacted TSs and TRs: 31.117, 31.121, 31.124, 31.127
- 924: 27/6/25: WID:SP-250445->SP-250813; 18/7/25: 33.727 added; / Impacted TSs and TRs: 33.727
- 925: -
- 926: -

| ID | WBS | Task | Duration | Start | Finish | Complete | Remaining | Actual finish | Total slack | Constraint | Resources | Work | Actual work | Acronym | PCG approved | WI rapporteur name | WI rapporteur e-mail | Release | TSG approved | Status Report |
| --- | --- | --- | --- | --- | --- | --- | --- | --- | --- | --- | --- | --- | --- | --- | --- | --- | --- | --- | --- | --- |
| 927 | 462 | **5G system with satellite backhaul** | 947.5d | 2021-06-11 A | 2023-12-12 A | 100% |  |  |  |  |  | 8248h | 8248h | 5GSATB | 47 | Xu Hui, CATT | xuhui@catt.cn | Rel-18 | 92 |  |
| 928 | 462.1 | Stage 1 of 5GSATB | 6d | 2021-06-11 A | 2021-06-18 A | 100% |  |  |  | finish no earlier than 2021-06-20 | S1 | 48h | 48h | 5GSATB | 47 | Xu Hui, CATT | xuhui@catt.cn | Rel-18 | 92 |  |
| 929 | 462.2 | Study on Support of Satellite Backhauling in 5GS | 315d | 2021-12-20 A | 2023-03-03 A | 100% |  |  |  | finish no earlier than 2023-03-12 | S2 | 2520h | 2520h | FS_5GSATB | 48 | Hucheng Wang, CATT | wanghucheng@catt.cn | Rel-18 | 94 |  |
| 930 | 462.3 | Stage 2 of 5GSATB | 192d | 2022-09-12 A | 2023-06-06 A | 100% |  |  |  | finish no earlier than 2023-06-06 | S2 | 1536h | 1536h | 5GSATB | 49 | Hucheng Wang, CATT | wanghucheng@catt.cn | Rel-18 | 97 |  |
| 931 | 462.4 | CT3 aspects of 5GSATB | 259d | 2022-12-16 A | 2023-12-12 A | 100% |  |  |  | finish no earlier than 2023-12-12 | C3 | 2072h | 2072h | 5GSATB | 49 | Hou, Yunjing, CATT | houyunjing@catt.cn | Rel-18 | 97 |  |
| 932 | 462.5 | CT4 aspects of 5GSATB | 259d | 2022-12-16 A | 2023-12-12 A | 100% |  |  |  | finish no earlier than 2023-12-12 | C4 | 2072h | 2072h | 5GSATB | 49 | Hou, Yunjing, CATT | houyunjing@catt.cn | Rel-18 | 97 |  |
| 933 | 463 | Charging aspects of Satellite Backhaul in 5GS | 63d | 2023-12-07 A | 2024-03-03 A | 100% |  |  |  | finish no earlier than 2024-03-03 | S5 | 504h | 504h | 5GSATB_CH | 52 | Yingying, Liu, CATT | liuyingying@cictmobile.com | Rel-18 | 102 |  |
| 934 | 464 | Management aspects of 5G system supporting satellite backhaul | 63d | 2023-12-07 A | 2024-03-03 A | 100% |  |  |  | finish no earlier than 2024-03-03 | S5 | 504h | 504h | 5GSATB_OAM | 52 | Wen Qi, China Telecom | qiw@chinatelecom.cn | Rel-18 | 102 |  |
| 935 | 465 | 5G system with satellite access to Support Control and/or Video Surveillance | 64d | 2021-06-11 A | 2021-09-08 A | 100% |  |  |  | finish no earlier than 2021-09-08 | S1 | 512h | 512h | SCVS | 47 | Dong Chen, Xiaomi | chendong7@xiaomi.com | Rel-18 | 92 |  |
| 936 | 466 | Study on 5GC enhancement for satellite access Phase 2 | 256d | 2021-12-20 A | 2022-12-12 A | 100% |  |  |  | finish no earlier than 2022-12-12 | S2 | 2048h | 2048h | FS_5GSAT_Ph2 | 48 | Fine, Jean-Yves, Thales | jean-yves.fine@thalesgroup.com. | Rel-18 | 94 |  |
| 937 | 467 | **Satellite access Phase 2** | 467d | 2022-12-09 A | 2024-03-03 A | 100% |  |  |  |  |  | 6168h | 6168h | 5GSAT_Ph2 | 50 | Rapporteur: Jean-Yves Fine, Thales | jean-yves.fine@thalesgroup.com | Rel-18 | 98 |  |
| 938 | 467.1 | (Stage 2 of 5GSAT_Ph2) 5GC/EPC enhancement for satellite access Phase 2 | 128d | 2022-12-09 A | 2023-06-06 A | 100% |  |  |  | finish no earlier than 2023-06-06 | S2 | 1024h | 1024h | 5GSAT_Ph2 | 50 | Rapporteur: Jean-Yves Fine, Thales | jean-yves.fine@thalesgroup.com | Rel-18 | 98 |  |
| 939 | 467.2 | CT1 aspects of 5GSAT_Ph2 | 257d | 2023-03-13 A | 2024-03-03 A | 100% |  |  |  | finish no earlier than 2024-03-03 | C1 | 2056h | 2056h | 5GSAT_Ph2 | 50 | Amer Catovic, Qualcomm Incorporated | amerc@qti.qualcomm.com | Rel-18 | 99 |  |
| 940 | 467.3 | deleted - CT6 aspects of 5GSAT_Ph2 | 257d | 2023-03-13 A | 2024-03-03 A | 100% |  |  |  | finish no earlier than 2024-03-03 | C6 | 2056h | 2056h | 5GSAT_Ph2 | 50 | Amer Catovic, Qualcomm Incorporated | amerc@qti.qualcomm.com | Rel-18 | 99 |  |
| 941 | 467.4 | Charging aspects of 5GSAT | 129d | 2023-09-07 A | 2024-03-03 A | 100% |  |  |  | finish no earlier than 2024-03-03 | S5 | 1032h | 1032h | 5GSAT_Ph2_CH | 51 | Yingying, Liu, CATT | liuyingying@cictmobile.com | Rel-18 | 101 |  |
| 942 | 468 | **NR NTN (Non-Terrestrial Networks) enhancements** | 1596.5d | 2021-12-13 A | 2026-03-03 | 80% | 312.13d |  | 37744.2d |  |  | 14897h | 10416h | NR_NTN_enh | 48 | Thales |  | Rel-18 | 94 |  |
| 943 | 468.1 | Core part: NR NTN (Non-Terrestrial Networks) enhancements | 652d | 2021-12-13 A | 2024-06-06 A | 100% |  |  |  | finish no earlier than 2024-06-06 | R2 | 5216h | 5216h | NR_NTN_enh-Core | 48 | Nicolas Chuberre, Thales | Nicolas.chuberre@thalesaleniaspace.com | Rel-18 | 94 | RP-240921 |
| 944 | 468.2 | Perf. part: NR NTN (Non-Terrestrial Networks) enhancements | 650d | 2021-12-15 A | 2024-06-06 A | 100% |  |  |  | finish no earlier than 2024-06-06 | R2 | 5200h | 5200h | NR_NTN_enh-Perf | 48 | Nicolas Chuberre, Thales | Nicolas.chuberre@thalesaleniaspace.com | Rel-18 | 94 | RP-240921 |
| 945 | 468.3 | UE Conformance - NR NTN (non-Terrestrial Networks) enhancements plus CT aspects | 560.12d | 2024-09-09 A | 2026-03-03 | 35% | 364.08d |  | 37744.2d | finish no earlier than 2026-03-03 | R5 | 4481h |  | NR_NTN_enh_plus_CT-UEConTest | 53 | Qualcomm |  | Rel-18 | 105 | RP-253370 |
| 946 | 469 | **IoT (Internet of Things) NTN (non-terrestrial network) enhancements** | 1134.62d | 2021-12-13 A | 2024-12-12 | 100% |  | 2025-12-12 |  |  |  | 14302h | 14302h | IoT_NTN_enh | 48 | MediaTek |  | Rel-18 | 94 |  |
| 947 | 469.1 | Core part: IoT (Internet of Things) NTN (non-terrestrial network) enhancements | 523d | 2021-12-13 A | 2023-12-12 A | 100% |  |  |  | finish no earlier than 2023-12-12 | R2 | 4184h | 4184h | IoT_NTN_enh-Core | 48 | Abhishek Roy, MediaTek | abhishek.roy@mediatek.com | Rel-18 | 94 | RP-233260 |
| 948 | 469.2 | Perf. Part: IoT (Internet of Things) NTN (non-terrestrial network) enhancements | 592d | 2022-03-07 A | 2024-06-06 A | 100% |  |  |  | finish no earlier than 2024-06-06 | R4 | 4736h | 4736h | IoT_NTN_enh-Perf | 48 | Abhishek Roy, MediaTek | abhishek.roy@mediatek.com | Rel-18 | 95 | RP-241350 |
| 949 | 469.3 | UE Conformance - IoT (Internet of Things) NTN (non-terrestrial network) enhancements plus CT1 aspects | 672.75d | 2024-03-03 A | 2025-12-12 A | 100% |  |  |  | finish no earlier than 2025-12-12 | R5 | 5382h | 5382h | IoT_NTN_enh_plus_CT1-UEConTest | 52 | CMCC |  | Rel-18 | 103 | RP-253374 |
| 950 | 470 | **Introduction of the satellite L-/S-band for NR** | 377.88d | 2022-12-13 A | 2023-12-12 A | 100% |  |  |  |  |  | 4192h | 4192h | NR_NTN_LSband | 50 | Apple |  | Rel-18 | 98 |  |
| 951 | 470.1 | Core part: Introduction of the satellite L-/S-band for NR | 262d | 2022-12-13 A | 2023-12-12 A | 100% |  |  |  | finish no earlier than 2023-12-12 | R4 | 2096h | 2096h | NR_NTN_LSband-Core | 50 | Alexander Sayenko, Apple Inc. | asayenko@apple.com | Rel-18 | 98 | RP-233306 |
| 952 | 470.2 | Perf. part: Introduction of the satellite L-/S-band for NR | 262d | 2022-12-13 A | 2023-12-12 A | 100% |  |  |  | finish no earlier than 2023-12-12 | R4 | 2096h | 2096h | NR_NTN_LSband-Perf | 50 | Alexander Sayenko, Apple Inc. | asayenko@apple.com | Rel-18 | 98 | RP-233306 |
| 953 | 471 | Study on Security Aspects of Satellite Access | 125d | 2022-09-12 A | 2023-03-03 A | 100% |  |  |  | finish no earlier than 2023-03-03 | S3 | 1000h | 1000h | FS_5GSAT_Sec | 49 | Wei Lu, Xiaomi | luwei10@xiaomi.com | Rel-18 | 97 |  |
| 954 | 472 | Study on Management Aspects of IoT NTN Enhancements | 264d | 2022-06-02 A | 2023-06-06 A | 100% |  |  |  | finish no earlier than 2023-06-06 | S5 | 2112h | 2112h | FS_IoT_NTN | 49 | Sun Mingrui, China Unicom | sunmr19@chinaunicom.cn | Rel-18 | 96 |  |
| 955 | 473 | Study on requirements and use cases for network verified UE location for Non-Terrestrial-Networks (NTN) in NR | 11d | 2022-06-01 A | 2022-06-15 A | 100% |  |  |  | start no earlier than 2022-06-01 | RP | 88h | 88h | FS_NR_NTN_netw_verif_UE_loc | 49 | Thales |  | Rel-18 | 96 |  |
| 956 | 474 | Study on charging aspects of Satellite in 5GS | 401d | 2022-06-01 A | 2023-12-12 A | 100% |  |  |  | start no earlier than 2022-06-01 | S5 | 3208h | 3208h | FS_5GSAT_CH | 50 | Yingying, Liu, CATT | liuyingying@cictmobile.com | Rel-18 | 98 |  |

Notes:
- 927: ; 11/6/21: 0%->100; / Impacted TSs and TRs: 22.261
- 928: ; 11/6/21: 0%->100; / Impacted TSs and TRs: 22.261
- 929: 21/1/22: 23.700-27 added;; 12/3/22: 0%->15; 4/6/22: 15%->60; 12/9/22: 60%->80; 10/12/22: 80%->100 / Impacted TSs and TRs: 23.700-27
- 930: ; 10/12/22: 0%->30; 15/3/23: FCD:03/03/2023->06/23; 15/3/23: 30%->65; 15/3/23: WID:SP-220808->SP-230111; 8/6/23: 65%->100 / Impacted TSs and TRs: 23.501; 23.502; 23.503
- 931: 6/6/23: Compl:30%->60% / Impacted TSs and TRs: 29.512; 29.514; 29.522; 29.525; 29.513; 29.502; 29.244; 29.564
- 932: Impacted TSs and TRs: 29.512; 29.514; 29.522; 29.525; 29.513; 29.502; 29.244; 29.564
- 933: SP-231707 shows UID 1020023 but this duplicates with SP-231706, so changed here to 1020024.; 15/3/24: 0%->100; 2/4/24: WID:SP-231707->SP-240266 / Impacted TSs and TRs: 32.240; 32.255; 32.256; 32.254; 32.257; 32.291; 32.298
- 934: ; 14/3/24: 0%->100 / Impacted TSs and TRs: 28.541; 28.552
- 935: ; 10/12/21: 0%->100 / Impacted TSs and TRs: 22.261
- 936: 21/1/22: 23.700-28 added;; 12/3/22: 0%->12; 4/6/22: 12%->50; 12/9/22: 50%->75; 12/9/22: FCD:12/09/2022->12/22; 10/12/22: 75%->100 / Impacted TSs and TRs: 23.700-28
- 937: Impacted TSs and TRs: 23.501; 23.502; 23.503; 23.401
- 938: ; 15/3/23: 0%->70; 15/3/23: WID:SP-221344->SP-230109; 8/6/23: 70%->100 / Impacted TSs and TRs: 23.501; 23.502; 23.503; 23.401
- 939: 6/6/23: Compl:0%->10% / Impacted TSs and TRs: 24.501.24.301.23.122.27.007.29.122.29.522.31.102
- 940: ; 15/3/24: 0%->100 / Impacted TSs and TRs: 24.501.24.301.23.122.27.007.29.122.29.522.31.102
- 941: ; 8/12/23: 0%->35; 14/3/24: 35%->100 / Impacted TSs and TRs: 32.255; 32.256; 32.291; 32.298
- 942: compare REL-17 WI NR_NTN_solutions; 5/4/22: WID:RP-213690->RP-220953; 12/7/22: WID:RP-220953->RP-221819; 23/9/22: WID:RP-221819->RP-222654; 9/1/23: WID:RP-222654->RP-223534; 29/3/23: WID:RP-223534->RP-230809; 6/10/23: WID:RP-230809->RP-232669; 2/1/24: ...; 2/4/24: WID:RP-234011->RP-240779
- 943: compare REL-17 WI NR_NTN_solutions; 22/3/22: Stat Rep: ->RP-220383; 20/6/22: FCD:12/12/2023->23/12/2022; Compl:0%->5%; Stat Rep: RP-220383->RP-221170 / 1746; Rapporteur: Thales->Nicolas Chuberre, Thales; Rap eMail: ->Nicolas.chuberre@thalesaleniaspace....; 13/6/24: Compl:99%->100%; WID: RP-240779->RP-232669; Stat Rep: RP-240127->RP-240921;
- 944: ; ; 20/6/22: WG: R4->R2; FCD:12/06/2024->24/06/2022; Stat Rep: RP-220383->RP-221170 / 1746; Rapporteur: Thales->Nicolas Chuberre, Thales; Rap eMail: ->Nicolas.chuberre@thalesaleniaspace.com13/7/22: FCD:24/06/2022->06/20 ...; 9/12/22: FCD:24/06/2023->0...; 13/6/24: Compl:35%->100%; WID: RP-240779->RP-232669; Stat Rep: RP-240127->RP-240921;
- 945: 6/12/24: Compl:0%->6%; Stat Rep: ->RP-242899; ; 6/3/25: FCD:24/07/2025->12/12/2025; Compl:6%->10%; Stat Rep: RP-242899->RP-250397; ; 6/6/25: Compl:10%->15%; Stat Rep: RP-250397->RP-251231; ; 18/7/25: WID:RP-242024->RP-251230; 11/9/25: Compl:15%->20%; Sta; 3/12/25: FCD:Fri 12/12/25->Tue 03/03/26; Compl:20%->35%; Stat Rep: RP-252049->RP-253370;
- 946: no Perf. part; 5/4/22: WID:RP-213596->RP-220979; 12/7/22: WID:RP-220979->RP-221806; 9/1/23: WID:RP-221806->RP-223519; 2/1/24: WID:RP-223519->RP-234073; 23/7/24: WID:RP-234073->RP-241351
- 947: no Perf. Part. Slight misalignment in UID numberring scheme (940104 instead of 941104) but it was decided to leave it as such to avoid further potential problems by changing a UID; 20/6/22: FCD:12/12/2023->23/12/2022; Compl:0%->3%; Stat Rep: ->RP-22155...; 8/12/23: Compl:82%->100%; Stat Rep: RP-232310->RP-233260;
- 948: 20/6/22: WG: R4->R2; FCD:07/06/2024->24/06/2022; Stat Rep: ->RP-221553 / 1759; Rapporteur: MediaTek->Abhishek Roy, MediaTek; Rap eMail: ->abhishek.roy@mediatek.com ...; 17/3/23: FCD:23/12/2022->06/06/2024; Stat Rep: ->RP-230633; Rapporteur: MediaTek...; 13/6/24: Compl:40%->100%; Stat Rep: RP-240446->RP-241350;
- 949: 13/6/24: Compl:0%->16%; WID: RP-240784->RP-240144; Stat Rep: ->RP-241198; ; 23/7/24: WID:RP-240144->RP-241197; 4/9/24: FCD:12/12/2025->25/12/2024; Compl:16%->27%; Stat Rep: RP-241198->RP-241950; ; 26/9/24: WID:RP-241197->RP-241949; 6/12/24: FCD:12/12/2024; 3/12/25: Compl:87%->100%; Stat Rep: RP-252594->RP-253374;
- 950: 29/3/23: WID:RP-223485->RP-230706; 8/6/23: 38.741 added;; 2/1/24: WID:RP-230706->RP-234043 / Impacted TSs and TRs: 38.741
- 951: 17/3/23: FCD:12/12/2023->08/09/2023; Compl:0%->10%; Stat Rep: ->RP-230154; Rapporteur: Apple->Alexander Sayenko, Apple Inc.; Rap eMail: ->asayenko@apple.com; 31/3/23: FCD:08/09/2023->12/12/2023; Stat Rep: RP-230154->RP-230707; ...; 6/9/23: Compl:50%->...; 8/12/23: Compl:80%->100%; Stat Rep: RP-231967->RP-233306;
- 952: 17/3/23: Compl:0%->50%; Stat Rep: ->RP-230154; Rapporteur: Apple->Alexander Sayenko, Apple Inc.; Rap eMail: ->asayenko@apple.com; 31/3/23: Stat Rep: RP-230154->RP-230707; ...; 6/9/23: Compl:90%->95%; WID: RP-230706->RP-231179; Stat Rep: RP-230707->RP-...; 8/12/23: Compl:95%->100%; Stat Rep: RP-231967->RP-233306;
- 953: 23/9/22: 33.700-28 added;; 11/12/22: 0%->15; 17/3/23: 15%->25; 8/6/23: 25%->100; 7/9/23: 100%-> / Impacted TSs and TRs: 33.700-28
- 954: 12/9/22: 0%->30; 11/12/22: 30%->75; 11/12/22: FCD:12/12/2022->/23; 17/3/23: 75%->95; 17/3/23: FCD:03/03/2023->/23; 8/6/23: 95%->100
- 956: 17/3/23: 0%->5; 17/3/23: 22.844 added;; 8/6/23: 5%->30; 7/9/23: 0%->80; 8/12/23: 80%->100; 8/12/23: 99%->100 / Impacted TSs and TRs: 22.844

| ID | WBS | Task | Type | Duration | Start | Finish | Complete | Actual finish | Constraint | Resources | Work | Actual work | Acronym | PCG approved | WI rapporteur name | Release | TSG approved | WI rapporteur e-mail | Status Report |
| --- | --- | --- | --- | --- | --- | --- | --- | --- | --- | --- | --- | --- | --- | --- | --- | --- | --- | --- | --- |
| 957 | 475 | **30 MHz Channel Bandwidth for NR NTN (non-terrestrial networks) in FR1 (frequency range 1)** |  | 97.25d | 2023-06-07 A | 2023-09-08 A | 100% |  |  | R4 | 1088h | 1088h | NR_NTN_CBW_30MHz | 51 | Thales | Rel-18 | 100 |  |  |
| 958 | 475.1 | Core part: 30 MHz Channel Bandwidth for NR NTN (non-terrestrial networks) in FR1 (frequency range 1) |  | 68d | 2023-06-07 A | 2023-09-08 A | 100% |  | finish no earlier than 2023-09-08 | R4 | 544h | 544h | NR_NTN_CBW_30MHz-Core | 51 | Dorin Panaitopol, THALES | Rel-18 | 100 | dorin.panaitopol@thalesgroup.com | RP-232646 |
| 959 | 476 | **Introduction of the Extended L-band (UL 1668-1675MHz, DL 1518-1525MHz) for IoT NTN** |  | 856d | 2023-03-03 A | 2025-06-06 A | 100% |  |  | R4 | 12551h | 12551h | IoT_NTN_extLband | 50 | Inmarsat | Rel-18 | 99 |  |  |
| 960 | 476.1 | Core part: Introduction of the Extended L-band (UL 1668-1675MHz, DL 1518-1525MHz) for IoT NTN |  | 263d | 2023-03-03 A | 2024-03-03 A | 100% |  | finish no earlier than 2024-03-03 | R4 | 2104h | 2104h | IoT_NTN_extLband-Core | 50 | Luca Lodigiani, Inmarsat | Rel-18 | 99 | Luca.lodigiani@inmarsat.com | RP-232609 |
| 961 | 476.2 | Perf. part: Introduction of the Extended L-band (UL 1668-1675MHz, DL 1518-1525MHz) for IoT NTN |  | 333d | 2023-03-03 A | 2024-06-06 A | 100% |  | finish no earlier than 2024-06-06 | R4 | 2664h | 2664h | IoT_NTN_extLband-Perf | 50 | Luca Lodigiani, Inmarsat | Rel-18 | 99 | Luca.lodigiani@inmarsat.com | RP-232609 |
| 962 | 476.3 | UE Conformance - Introduction of the Extended L-band (UL 1668-1675MHz, DL 1518-1525MHz) for IoT NTN |  | 378.88d | 2024-06-06 A | 2025-06-06 A | 100% |  | finish no earlier than 2025-06-06 | R5 | 3031h | 3031h | IoT_NTN_extLband-UEConTest | 53 | Mediatek | Rel-18 | 104 |  | RP-251292 |
| 963 | 477 | **Introduction of FDD LTE band (L+S band) for IoT NTN operation** |  | 757.75d | 2023-03-03 A | 2025-03-03 | 100% | 2024-12-12 |  | R4 | 9576h | 9576h | IoT_NTN_FDD_LS_band | 50 | MediaTek | Rel-18 | 99 |  |  |
| 964 | 477.1 | Core part: Introduction of FDD LTE band (L+S band) for IoT NTN operation |  | 204d | 2023-03-03 A | 2023-12-12 A | 100% |  | finish no earlier than 2023-12-12 | R4 | 1632h | 1632h | IoT_NTN_FDD_LS_band-Core | 50 | Huanren FU, MediaTek Inc. | Rel-18 | 99 | huanren.fu@mediatek.com | RP-241352 |
| 965 | 477.2 | Perf. part: Introduction of FDD LTE band (L+S band) for IoT NTN operation |  | 332d | 2023-03-06 A | 2024-06-06 A | 100% |  | finish no earlier than 2024-06-06 | R4 | 2656h | 2656h | IoT_NTN_FDD_LS_band-Perf | 50 | Huanren FU, MediaTek Inc. | Rel-18 | 99 | huanren.fu@mediatek.com | RP-241352 |
| 966 | 477.3 | UE Conformance - Introduction of FDD LTE band (L+S band) for IoT NTN operation |  | 136d | 2024-06-06 A | 2024-12-12 A | 100% |  | finish no earlier than 2024-12-12 | R5 | 1088h | 1088h | IoT_NTN_FDD_LS_band-UEConTest | 53 | Mediatek | Rel-18 | 104 |  | RP-242991 |
| 967 | 478 | **NB-IoT/eMTC Core and Perf requirements for NTN** |  | 745.5d | 2022-03-15 A | 2024-03-03 A | 100% |  |  |  | 6640h | 6640h | LTE_NBIOT_eMTC_NTN_req | 48 | MediaTek | Rel-18 | 95 |  |  |
| 968 | 478.1 | Core part: NB-IoT (Narrowband IoT)/eMTC (enhanced Machine Type Communication) core & performance requirements for Non-Terrestrial Networks (NTN) |  | 188d | 2022-03-15 A | 2022-12-01 A | 100% |  | finish no earlier than 2022-12-01 | R4 | 1504h | 1504h | LTE_NBIoT_eMTC_NTN_req-Core | 48 | Tim Frost, MediaTek Inc. | Rel-18 | 95 | Tim.frost@mediatek.com | RP-223231 |
| 969 | 478.2 | Perf. part: NB-IoT (Narrowband IoT)/eMTC (enhanced Machine Type Communication) core & performance requirements for Non-Terrestrial Networks (NTN) |  | 321d | 2022-03-15 A | 2023-06-06 A | 100% |  | finish no earlier than 2023-06-06 | R4 | 2568h | 2568h | LTE_NBIoT_eMTC_NTN_req-Perf | 48 | Hsuanli Lin, MediaTek Inc. | Rel-18 | 95 | hsuanli.lin@mediatek.com | RP-230634 |
| 970 | 478.3 | UE Conformance - NB-IoT (Narrowband IoT)/eMTC (enhanced Machine Type Communication) core & performance requirements for Non-Terrestrial Networks (NTN) |  | 321d | 2022-12-13 A | 2024-03-03 A | 100% |  | finish no earlier than 2024-03-03 | R5 | 2568h | 2568h | LTE_NBIOT_eMTC_NTN_req-UEConTest | 50 | Dan SONG, Danbo Fu (MediaTek), CMCC, MediaTek Inc. | Rel-18 | 98 | songdan@chinamobile.com, Danbo.Fu@mediatek.com | RP-240146 |
| 971 | 479 | Rel-18 Internet of Things (IoT), MTC, Energy, complexity saving | milestone | 0d? | 2016-03-15 A | 2016-03-15 A | 100% |  | start no earlier than 2016-03-15 |  |  |  |  |  |  | Rel-18 |  |  |  |
| 972 | 480 | **Personal IoT and Residential networks** |  | 1395.88d | 2020-06-25 A | 2024-03-03 A | 100% |  |  |  | 14272h | 14272h | PIRates | 47 | Xiaowan Ke, vivo Mobile Communications Ltd | Rel-18 | 93 | xiaowan.ke@vivo.com |  |
| 973 | 480.1 | Study on Personal IoT Networks |  | 252d | 2020-06-25 A | 2021-06-11 A | 100% |  | finish no earlier than 2021-06-12 | S1 | 2016h | 2016h | FS_PIN | 45 | Adrian Buckley, vivo Mobile Communications | Rel-18 | 88 | adrian.buckley@vivo.com |  |
| 974 | 480.2 | Study on Enhancements for Residential 5G |  | 252d | 2020-06-25 A | 2021-06-11 A | 100% |  | finish no earlier than 2021-06-12 | S1 | 2016h | 2016h | FS_Resident | 45 | Toon Norp, KPN | Rel-18 | 88 | toon.norp@tno.nl |  |
| 975 | 480.3 | Stage 1 of PIRates |  | 66d | 2021-09-10 A | 2021-12-10 A | 100% |  | finish no earlier than 2021-12-12 | S1 | 528h | 528h | PIRates | 47 | Xiaowan Ke, vivo Mobile Communications Ltd | Rel-18 | 93 | xiaowan.ke@vivo.com |  |
| 976 | 480.4 | Study on Personal IoT Networks |  | 315d | 2021-12-20 A | 2023-03-03 A | 100% |  | finish no earlier than 2023-03-03 | S2 | 2520h | 2520h | FS_PIN | 48 | Zhenhua Xie, vivo Mobile Communications Ltd | Rel-18 | 94 | zhenhua.xie@vivo.com |  |
| 977 | 480.5 | (Stage 2 of) Personal IoT Networks |  | 128d | 2022-12-09 A | 2023-06-06 A | 100% |  | finish no earlier than 2023-06-06 | S2 | 1024h | 1024h | PIN | 50 | Zhenhua Xie, vivo | Rel-18 | 98 | zhenhua.xie@vivo.com |  |
| 978 | 480.6 | CT1 aspects of PIN |  | 257d | 2023-03-13 A | 2024-03-03 A | 100% |  | finish no earlier than 2024-03-03 | C1 | 2056h | 2056h | PIN | 50 | Hui Wang, vivo | Rel-18 | 99 | wanghui.wh@vivo.com |  |
| 979 | 480.7 | CT3 aspects of PIN |  | 257d | 2023-03-13 A | 2024-03-03 A | 100% |  | finish no earlier than 2024-03-03 | C3 | 2056h | 2056h | PIN | 50 | Hui Wang, vivo | Rel-18 | 99 | wanghui.wh@vivo.com |  |
| 980 | 480.8 | CT4 aspects of PIN |  | 257d | 2023-03-13 A | 2024-03-03 A | 100% |  | finish no earlier than 2024-03-03 | C4 | 2056h | 2056h | PIN | 50 | Hui Wang, vivo | Rel-18 | 99 | wanghui.wh@vivo.com |  |

Notes:
- 957: 6/10/23: WID:RP-231499->RP-232647
- 958: 6/9/23: Compl:0%->50%; Stat Rep: ->RP-231568; Rapporteur: Thales->Dorin Panaitopol, THALES; Rap eMail: ->dorin.panaitopol@thalesgroup.com; ; 21/9/23: FCD:12/12/2023->08/09/2023; Compl:50%->100%; Stat Rep: RP-231568->RP-232646;
- 959: 7/9/23: WID:RP-230790->RP-231487; 6/10/23: WID:RP-231487->RP-232686; 2/1/24: WID:RP-232686->RP-233856; 2/4/24: WID:RP-233856->RP-240741
- 960: ; 7/6/23: Compl:0%->11%; 6/9/23: FCD:09/09/2023->22/09/2023; Compl:11%->30%; WID: RP-230790->RP-231487; Stat Rep: ->RP-232459; Rapporteur: Inmarsat->Luca Lodigiani, Inmarsat; Rap eMail: ->Luca.lodigiani@inmarsat.com; ; 21/9/23: FCD:22/09/2023->12/12/2...; 2/4/24: 90%->100
- 961: 6/9/23: WID: RP-230790->RP-231487; Stat Rep: ->RP-232459; Rapporteur: Inmarsat->Luca Lodigiani, Inmarsat; Rap eMail: ->Luca.lodigiani@inmarsat.com; ; 21/9/23: FCD:12/12/2023->06/06/2024; Stat Rep: RP-232459->RP-232609; ; 8/12/23: FCD:06/06/2024->12/12...; 23/7/24: 0%->100
- 962: 4/9/24: FCD:06/06/2025->25/06/2025; Compl:0%->5%; Stat Rep: ->RP-242049; ; 6/12/24: Compl:5%->95%; Stat Rep: RP-242049->RP-242993; ; 6/3/25: FCD:14/02/2025->06/06/2025; Stat Rep: RP-242993->RP-250476; ; 6/6/25: Compl:95%->100%; Stat Rep: RP-250476->RP-251292;
- 963: 2/1/24: WID:RP-230792->RP-234060; 2/4/24: WID:RP-234060->RP-240451; 23/7/24: WID:RP-240451->RP-241353
- 964: ; 7/6/23: Compl:0%->30%; 6/9/23: Compl:30%->60%; WID: RP-230792->RP-231479; Stat Rep: ->RP-232313; Rapporteur: MediaTek->Aijun CAO, MediaTek Inc.; Rap eMail: ->aijun.cao@mediatek.com; ; 8/12/23: Compl:60%->100%; Stat Rep: RP-232313->RP-233258; ; 4/1/2...; 13/6/24: WID: RP-240451->RP-233259; Stat Rep: RP-240450->RP-241352; / Impacted TSs and TRs: 36.764
- 965: ; 7/6/23: CD:06/06/2024->06/06/2023; 6/9/23: FCD:06/06/2023->06/06/2024; WID: RP-230792->RP-231479; Stat Rep: ->RP-232313; Rapporteur: MediaTek->Aijun CAO, MediaTek Inc.; Rap eMail: ->aijun.cao@mediatek.com; ; 8/12/23: Stat Rep: RP-232313->RP-233258; ...; 13/6/24: Compl:50%->100%; WID: RP-234060->RP-233259; Stat Rep: RP-240450->RP-241352;
- 966: 4/9/24: FCD:03/03/2025->25/03/2025; Compl:0%->95%; Stat Rep: ->RP-242048; ; 6/12/24: FCD:03/03/2025->12/12/2024; Compl:95%->99%; Stat Rep: RP-242048->RP-242991; ; 24/1/25: WID:RP-241354->RP-242992; 24/1/25: 99%->100
- 967: TS 36.10x, TS 36.10y; RAN4 requirements for REL-17 WI LTE_NBIOT_eMTC_NTN-Core ; 12/7/22: WID:RP-220938->RP-221556; 9/1/23: WID:RP-221556->RP-223437; 23/7/24: 99%->100
- 968: TS 36.10x, TS 36.10y; RAN4 requirements for REL-17 WI LTE_NBIOT_eMTC_NTN-Core ; 20/6/22: FCD:15/12/2022->22/12/2022; Stat Rep: ->RP-221555; Rapporteur: MediaTek->Tim Frost, MediaTek Inc.; Rap eMail: ->tim dot frost at mediatek dot com13/7/22: 36.1...;...; 9/1/23: 100%->100 / Impacted TSs and TRs: 36.102; 36.105; 36.108
- 969: TS 36.1XX; RAN4 requirements for REL-17 WI LTE_NBIOT_eMTC_NTN-Core ; 6/6/22: CD:15/06/2023->23/06/2022; 6/6/22: Stat Rep: ->RP-221555; 20/6/22: Rapporteur: MediaTek->Tim Frost, MediaTek Inc.; Rap eMail: ->tim dot frost at mediatek dot com13/7/22: ...;...; ; ; ; ; ; ; ; ; ; ; ; ; ; ; ; ; ; ; ; ; ; ; ; ; ; ; ; ; ; ; ; ; ; ; ; ; ; ; ; ; ; ; ; ; ; 7/6/23: Compl:45%->100% / Impacted TSs and TRs: 36.181
- 970: 17/3/23: Compl:0%->30%; Stat Rep: ->RP-230284; Rapporteur: CMCC->Dan SONG, Danbo Fu (MediaTek), CMCC, MediaTek Inc.; Rap eMail: ->songdan@chinamobile.com, Danbo.Fu@mediatek.com; 17/3/23: 36.521-4 added;; 29/3/23: WID:RP-223064->RP-230285; ...; 21/9/23...; 2/4/24: WID:RP-223064->RP-240147 / Impacted TSs and TRs: 36.521-4
- 971: -
- 972: ; 10/12/21: WID:SP-211055->SP-211505 (chg rapporteur) / Impacted TSs and TRs: 22.261
- 973: 28/7/20: 22.859 added;; 12/9/20: 0%->15; 5/12/20: 15%->50; 19/3/21: FCD:17/03/2021->06/21; 19/3/21: 50%->75; 11/6/21: 75%->90; 13/9/21: 90%->100 / Impacted TSs and TRs: 22.859
- 974: 28/7/20: 22.858 added;; 12/9/20: 0%->30; 5/12/20: 30%->50; 19/3/21: FCD:17/03/2021->06/21; 19/3/21: 50%->75; 11/6/21: 75%->85; 13/9/21: 85%->100 / Impacted TSs and TRs: 22.858
- 975: ; 13/9/21: 0%->85; 10/12/21: 85%->100; 10/12/21: WID:SP-211055->SP-211505 / Impacted TSs and TRs: 22.261
- 976: 21/1/22: 23.700-88 added;; 12/3/22: 0%->20; 4/6/22: 20%->60; 12/9/22: 60%->75; 12/9/22: FCD:12/09/2022->12/22; 10/12/22: 75%->95; 15/3/23: FCD:12/12/2022->03/23; 15/3/23: 95%->100; 15/3/23: WID:SP-211643->SP-230089 / Impacted TSs and TRs: 23.700-88
- 977: 10/1/23: FCD clarified to be June (and not March) by e-mail; 15/3/23: 0%->60; 8/6/23: 60%->100 / Impacted TSs and TRs: 23.501; 23.502; 23.503
- 978: 6/6/23: Compl:0%->50% / Impacted TSs and TRs: 24.501.24.526.29.512.29.513.29.519.29.522.29.525.23.008.29.502.29.503.29.504.29.505.29.244
- 979: 9/6/23: 0%->20 / Impacted TSs and TRs: 24.501.24.526.29.512.29.513.29.519.29.522.29.525.23.008.29.502.29.503.29.504.29.505.29.244
- 980: Impacted TSs and TRs: 24.501.24.526.29.512.29.513.29.519.29.522.29.525.23.008.29.502.29.503.29.504.29.505.29.244

| ID | WBS | Task | Type | Duration | Start | Finish | Complete | Remaining | Actual start | Actual finish | Total slack | Constraint | Resources | Work | Actual work | Acronym | PCG approved | WI rapporteur name | WI rapporteur e-mail | Release | TSG approved | Impacted TSs and TRs | Status Report |
| --- | --- | --- | --- | --- | --- | --- | --- | --- | --- | --- | --- | --- | --- | --- | --- | --- | --- | --- | --- | --- | --- | --- | --- |
| 981 | 481 | **Application layer support for Personal IoT Network** |  | 582d | 2021-12-13 A | 2024-03-03 A | 100% |  |  |  |  |  |  | 7224h | 7224h | PINAPP | 50 | Huazhang Lv, vivo Mobile Communications Ltd, | huazhang.lv@vivo.com | Rel-18 | 99 |  |  |
| 982 | 481.1 | Study on Application layer support for Personal IoT Networks |  | 261d | 2021-12-13 A | 2022-12-12 A | 100% |  |  |  |  | finish no earlier than 2022-12-12 | S6 | 2088h | 2088h | FS_PINAPP | 48 | Huazhang Lv, vivo Mobile Communications Ltd | huazhang.lv@vivo.com | Rel-18 | 94 | 23.700-78; 24.583 |  |
| 983 | 481.2 | Stage 2 of PINAPP |  | 128d | 2022-12-09 A | 2023-06-06 A | 100% |  |  |  |  | finish no earlier than 2023-06-06 | S6 | 1024h | 1024h | PINAPP | 50 | Huazhang Lv, vivo Mobile Communications Ltd, | huazhang.lv@vivo.com | Rel-18 | 98 | 23.542 |  |
| 984 | 481.3 | CT1 aspects of PINAPP |  | 257d | 2023-03-13 A | 2024-03-03 A | 100% |  |  |  |  | finish no earlier than 2024-03-03 | C1 | 2056h | 2056h | PINAPP | 50 | Yizhong ZHANG, vivo | yizhong.zhang@vivo.com | Rel-18 | 99 | 27.007 |  |
| 985 | 481.4 | CT3 aspects of PINAPP |  | 257d | 2023-03-13 A | 2024-03-03 A | 100% |  |  |  |  | finish no earlier than 2024-03-15 | C3 | 2056h | 2056h | PINAPP | 50 | Yizhong ZHANG, vivo | yizhong.zhang@vivo.com | Rel-18 | 99 | 27.007; 29.583 |  |
| 986 | 482 | Study on Personal IoT Networks Security Aspects |  | 197d | 2022-06-02 A | 2023-03-03 A | 100% |  |  |  |  | finish no earlier than 2023-03-03 | S3 | 1576h | 1576h | FS_PIN_Sec | 49 | Zhenhua Xie, vivo Mobile Communications Co. Ltd | zhuenhua.xie@vivo.com | Rel-18 | 96 | 33.882 |  |
| 987 | 483 | Study on Application Capability Exposure for IoT Platforms |  | 261d | 2021-06-11 A | 2022-06-09 A | 100% |  |  |  |  | finish no earlier than 2022-06-12 | S6 | 2088h | 2088h | FS_ACE_IOT | 47 | Mladin, Catalina; Convida Wireless | Mladin.Catalina@convidawireless.com | Rel-18 | 92 | 23.700-97 |  |
| 988 | 484 | See also IoT_NTN_en under Satellite and LPHP under Verticals | milestone | 0d? | 2016-03-15 A | 2016-03-15 A | 100% |  |  |  |  | start no earlier than 2016-03-15 |  |  |  |  |  |  |  | Rel-18 |  |  |  |
| 989 | 485 | See also " NB-IoT/eMTC requirements for NTN" (UID 950074) under Satellite | milestone | 0d? | 2016-03-15 A | 2016-03-15 A | 100% |  |  |  |  | start no earlier than 2016-03-15 |  |  |  |  |  |  |  | Rel-18 |  |  |  |
| 990 | 486 | Study on low-power wake-up signal and receiver for NR |  | 523d | 2021-12-13 A | 2023-12-12 A | 100% |  |  |  |  | finish no earlier than 2023-12-12 | R1 | 4184h | 4184h | FS_NR_LPWUS | 48 | Xueming Pan, vivo | panxueming@vivo.com | Rel-18 | 94 | 38.869 | RP-233067 |
| 991 | 487 | **Enhanced support of reduced capability NR devices** |  | 1135.62d | 2021-12-12 A | 2024-12-12 | 93% | 84.02d |  |  |  |  |  | 13910h | 7856h | NR_redcap_enh | 49 | Ericsson |  | Rel-18 | 97 |  |  |
| 992 | 487.1 | Core part: Enhanced support of reduced capability NR devices |  | 330d | 2022-09-08 A | 2023-12-12 A | 100% |  |  |  |  | finish no earlier than 2023-12-12 | R1 | 2640h | 2640h | NR_redcap_enh-Core | 49 | Johan BERGMAN, Ericsson | johan.bergman@ericsson.com | Rel-18 | 97 |  | RP-233636 |
| 993 | 487.2 | Perf. part: Enhanced support of reduced capability NR devices |  | 456d | 2022-09-13 A | 2024-06-06 A | 100% |  |  |  |  | finish no earlier than 2024-06-06 | R1 | 3648h | 3648h | NR_redcap_enh-Perf | 49 | Johan BERGMAN, Ericsson | johan.bergman@ericsson.com | Rel-18 | 97 |  | RP-241124 |
| 994 | 487.3 | Study on further NR RedCap (reduced capability) UE complexity reduction |  | 196d | 2021-12-12 A | 2022-09-09 A | 100% |  |  |  |  | finish no earlier than 2022-09-09 | R1 | 1568h | 1568h | FS_NR_redcap_enh | 48 | Johan BERGMAN, Ericsson | johan.bergman@ericsson.com | Rel-18 | 94 | 38.865 | RP-221160 |
| 995 | 487.4 | UE Conformance - Enhanced support of reduced capability NR devices plus CT1 aspects |  | 756.75d | 2024-03-03 A | 2026-03-03 | 83% | 128.65d |  |  | 37744.2d | finish no earlier than 2026-03-03 | R5 | 6054h |  | NR_redcap_enh_plus_CT1-UEConTest | 52 | China Unicom |  | Rel-18 | 103 |  | RP-253153 |
| 996 | 488 | Study on RedCap Phase 2 |  | 256d | 2021-12-20 A | 2022-12-12 A | 100% |  |  |  |  | finish no earlier than 2022-12-12 | S2 | 2048h | 2048h | FS_REDCAP_Ph2 | 48 | Qian, Chen, Ericsson | qian.xb.chen@ericsson.com | Rel-18 | 94 | 23.700-68 |  |
| 997 | 489 | **NR RedCap UE with long eDRX for RRC_INACTIVE State** |  | 261d | 2022-12-15 | 2023-12-13 | 100% |  | 2022-09-12 | 2023-12-12 |  |  |  | 5150h | 5150h | NR_REDCAP_Ph2 | 49 | Qian, Chen, Ericsson | qian.xb.chen@ericsson.com | Rel-18 | 97 | 23.501; 23.502 |  |
| 998 | 489.1 | (Stage 2 of) NR RedCap UE with long eDRX for RRC_INACTIVE State |  | 124.75d | 2022-09-12 A | 2023-03-03 A | 100% |  |  |  |  | finish no earlier than 2023-03-03 | S2 | 998h | 998h | NR_REDCAP_Ph2 | 49 | Qian, Chen, Ericsson | qian.xb.chen@ericsson.com | Rel-18 | 97 | 23.501; 23.502 ; 28.876 |  |
| 999 | 489.2 | CT4 aspects of NR_REDCAP_Ph2 |  | 260d | 2022-12-15 A | 2023-12-12 A | 100% |  |  |  |  |  | C4 | 2080h | 2080h | NR_REDCAP_Ph2 | 49 | Frank Yong Yang, Ericsson | frank.yong.yang@ericsson.com | Rel-18 | 97 | 24.008; 29.502; 29.518 |  |
| 1000 | 489.3 | CT1 aspects of NR_REDCAP_Ph2 |  | 259d | 2022-12-16 A | 2023-12-12 A | 100% |  |  |  |  | finish no earlier than 2023-12-12 | C1 | 2072h | 2072h | NR_REDCAP_Ph2 | 49 | Frank Yong Yang, Ericsson | frank.yong.yang@ericsson.com | Rel-18 | 97 | 24.008; 29.502; 29.518 |  |
| 1001 | 490 | **Adding new NR FDD bands for RedCap (Reduced Capability) in Rel-18** |  | 754.5d | 2023-03-06 A | 2025-03-03 A | 100% |  |  |  |  |  |  | 3176h | 3176h | NR_FDD_bands_R18_redcap | 50 | Ericsson |  | Rel-18 | 99 |  |  |
| 1002 | 490.1 | Core part: Adding new NR FDD bands for RedCap (Reduced Capability) in Rel-18 |  | 203d | 2023-03-06 A | 2023-12-12 A | 100% |  |  |  |  | finish no earlier than 2023-12-12 | R4 | 1624h | 1624h | NR_FDD_bands_R18_redcap-Core | 50 | Chunhui Zhang, Ericsson | Chunhui.Zhang@ericsson.com | Rel-18 | 99 |  | RP-232xyz |
| 1003 | 490.2 | UE Conformance - New NR FDD bands for RedCap (Reduced Capability) in Rel-18 |  | 194d | 2024-08-28 A | 2025-03-03 A | 100% |  |  |  |  | finish no earlier than 2025-03-03 | R5 | 1552h | 1552h | NR_FDD_bands_R18_redcap-UEConTest | 54 | Ericsson |  | Rel-18 | 106 |  | RP-250288 |
| 1004 | 491 | **Network energy savings for NR** |  | 1512.5d | 2021-12-13 A | 2025-12-12 A | 100% |  |  |  |  |  |  | 12630h | 12630h | Netw_Energy_NR | 50 | Huawei |  | Rel-18 | 98 |  |  |
| 1005 | 491.1 | Core part: Network energy savings for NR |  | 262d | 2022-12-13 A | 2023-12-12 A | 100% |  |  |  |  | finish no earlier than 2023-12-12 | R1 | 2096h | 2096h | Netw_Energy_NR-Core | 50 | Yi Wang, Huawei | wangyi6@huawei.com | Rel-18 | 98 |  | RP-233655 |
| 1006 | 491.2 | Perf. part: Network energy savings for NR |  | 390d | 2022-12-14 A | 2024-06-06 A | 100% |  |  |  |  | finish no earlier than 2024-06-06 | R4 | 3120h | 3120h | Netw_Energy_NR-Perf | 50 | Yi Wang, Huawei | wangyi6@huawei.com | Rel-18 | 98 |  | RP-241239 |
| 1007 | 491.3 | UE Conformance - Network energy savings for NR |  | 672.75d | 2024-03-03 A | 2025-12-12 A | 100% |  |  |  |  | finish no earlier than 2025-12-12 | R5 | 5382h | 5382h | Netw_Energy_NR-UEConTest | 52 | Huawei |  | Rel-18 | 103 |  | RP-253429 |
| 1008 | 491.4 | Study on network energy savings for NR |  | 254d | 2021-12-13 A | 2022-12-01 A | 100% |  |  |  |  | finish no earlier than 2022-12-01 | R1 | 2032h | 2032h | FS_Netw_Energy_NR | 48 | Yi Wang, Huawei | wangyi6@huawei.com | Rel-18 | 94 | 38.864 | RP-223002 |
| 1009 | 492 | Rel-18 Uncrewed Aerial Vehicles (UAV), UAS, UAM | milestone | 0d? | 2016-03-15 A | 2016-03-15 A | 100% |  |  |  |  | start no earlier than 2016-03-15 |  |  |  |  |  |  |  | Rel-18 |  |  |  |

Notes:
- 982: 7/1/22: 23.700-78 added;; 12/3/22: WID:SP-211515->SP-220095; 12/3/22: 0%->15; 4/6/22: 15%->40; 12/9/22: 40%->60; 12/9/22: FCD:12/09/2022->12/20; 11/12/22: 60%->100; 31/3/23: 24.583 added;
- 983: 17/3/23: FCD:03/03/2023->/23; 17/3/23: 0%->50; 17/3/23: 23.542 added;; 8/6/23: 50%->100
- 984: 6/6/23: Compl:0%->40%
- 985: 31/3/23: 29.583 added;; 9/6/23: 5%->10
- 986: 13/7/22: 33.882 added;; 12/9/22: 0%->20; 11/12/22: 20%->50; 17/3/23: 50%->60; 8/6/23: 60%->100
- 987: 2/7/21: 23.700-97 added;; 13/9/21: 0%->15; 13/12/21: 15%->40; 12/3/22: 40%->55; 12/3/22: FCD:11/03/2022->6/22; 12/3/22: WID:SP-210478->SP-220093; 4/6/22: 55%->60; 12/9/22: 60%->75; 11/12/22: 75%->75; 17/3/23: 75%->95; 8/6/23: 95%->100
- 988: -
- 989: -
- 990: 21/1/22: 38.869 added;; 22/3/22: Stat Rep: ->RP-2205966/6/22: CD:12/12/2023->23/12/20226/6/22: Stat Rep: RP-220596->RP-221270; 20/6/22: Rapporteur: vivo->Xiaodong Shen, vivo Communication Technology; Rap eMail: ->shenxiaodong@vivo.com12/7/22: WID:R...;...; 8/12/23: Compl:85%->100%; Stat Rep: RP-231812->RP-233067; Rapporteur: Xiaodong Shen, vivo Communication Technology->Xueming Pan, vivo; Rap eMail: shenxiaodong@vivo.com->panxueming@vivo.com;
- 991: 9/1/23: WID:RP-222675->RP-223544; 6/10/23: WID:RP-223544->RP-232671; 2/1/24: WID:RP-232671->RP-233637
- 992: 9/12/22: FCD:10/12/2023->01/12/2023; Compl:0%->15%; Stat Rep: ->RP-222827; Rapporteur: Ericsson->Johan BERGMAN, Ericsson; Rap eMail: ->johan.bergman@ericsson.com; 17/3/23: FCD:30/11/2023->12/12/2023; Compl:15%->30%; Stat Rep: RP-222827->RP-230111; ;.....; 8/12/23: Compl:75%->100%; Stat Rep: RP-231628->RP-233636;
- 993: 9/12/22: WG: R4->R1; FCD:10/06/2023->01/06/2024; Stat Rep: ->RP-222827; Rapporteur: Ericsson->Johan BERGMAN, Ericsson; Rap eMail: ->johan.bergman@ericsson.com; 17/3/23: Stat Rep: RP-222827->RP-230111; ...; 6/9/23: FCD:06/06/2023->06/06/2024; Stat Rep:...; 23/7/24: 100%->100
- 994: TR 38.8xx; compare REL-17 SI FS_NR_redcap and REL-17 WI NR_redcap; 21/1/22: 38.865 added;; 22/3/22: Stat Rep: ->RP-220470 ; 6/6 ; 20/6/22: Rapporteur: Ericsson->Johan BERGMAN, Ericsson; Rap eMail: ->johan.bergman@ericsson.com12/7/22: WID:RP-213661-...; 23/9/22: 0%->100
- 995: 13/6/24: Compl:0%->5%; Stat Rep: ->RP-240919; ; 23/7/24: WID:RP-240054->RP-240920; 4/9/24: FCD:12/12/2025->25/12/2024; Compl:5%->28%; Stat Rep: RP-240919->RP-241883; ; 6/12/24: FCD:12/12/2024->12/12/2025; Compl:28%->53%; Stat Rep: RP-241883->RP-242486; ; ; 7/1/26: WID:RP-242487->RP-253055
- 996: 21/01/22: name corrected; 21/1/22: 23.700-68 added;; 12/3/22: 0%->30; 12/3/22: WID:SP-211635->SP-220074; 4/6/22: 30%->70; 12/9/22: 70%->99; 12/9/22: FCD:12/09/2022->12/22; 10/12/22: 99%->100
- 998: ; 10/12/22: 0%->60; 15/3/23: WID:SP-220803->SP-230171; 15/3/23: 60%->95; 8/6/23: 95%->100; 4/1/24: 28.876 added;
- 999: 6/6/23: Compl:60%->90%
- 1001: 2/1/24: WID:RP-230743->RP-232894
- 1002: ; 7/6/23: Compl:0%->40%; 6/9/23: Compl:40%->50%; WID: RP-230743->RP-231049; Stat Rep: ->RP-231881; Rapporteur: Ericsson->Chunhui Zhang, Ericsson; Rap eMail: ->Chunhui.Zhang@ericsson.com; ; 8/12/23: Compl:50%->100%; Stat Rep: RP-231881->RP-232xyz;
- 1003: 6/3/25: FCD:09/09/2025->03/03/2025; Compl:0%->100%; Stat Rep: ->RP-250288; ; 3/4/25: WID:RP-242648->RP-250289
- 1004: 2/1/24: WID:RP-223540->RP-234009
- 1005: 17/3/23: FCD:12/12/2023->08/09/2023; Compl:0%->15%; Stat Rep: ->RP-230565; Rapporteur: Huawei->Yi Wang, Huawei; Rap eMail: ->wangyi6@huawei.com; 31/3/23: FCD:08/09/2023->12/12/2023; Stat Rep: RP-230565->RP-230714; ;...; 6/9/23: Compl:55%->75%; Stat Re...; 8/12/23: Compl:75%->100%; Stat Rep: RP-231926->RP-233655;
- 1006: 17/3/23: Stat Rep: ->RP-230565; Rapporteur: Huawei->Yi Wang, Huawei; Rap eMail: ->wangyi6@huawei.com; 31/3/23: FCD:06/06/2024->06/06/2023; Stat Rep: RP-230565->RP-230714; ...; 6/9/23: FCD:06/06/2023->06/06/2024; Stat Rep: RP-230714->RP-231926; ; 8/12/...; 23/7/24: 100%->100
- 1007: 13/6/24: Compl:0%->5%; Stat Rep: ->RP-241378; ; 4/9/24: FCD:12/12/2025->25/12/2024; Compl:5%->24%; Stat Rep: RP-241378->RP-242075; ; 6/12/24: FCD:12/12/2024->12/12/2025; Compl:24%->54%; Stat Rep: RP-242075->RP-243092; ; 6/3/25: FCD:28/05/2025->12/12/2025;; 7/1/26: WID:RP-240291->RP-253430
- 1008: 21/1/22: 38.864 added;; 22/3/22: Stat Rep: ->RP-220296; 5/4/22: WID:RP-213554->RP-220297 ; 6/6/22: Compl:0%->10% 20/6/22: Rapporteur: Huawei->Yi Wang, Huawei; Rap eMail: ->wangyi6@huawei.com12/7/22: WID:RP-220297->RP-221443; 9/12/22: FCD:22/12/2022->...; 29/3/23: WID:RP-221443->RP-230566
- 1009: -

| ID | WBS | Task | Type | Duration | Start | Finish | Complete | Remaining | Total slack | Constraint | Resources | Work | Actual work | Acronym | PCG approved | WI rapporteur name | WI rapporteur e-mail | Release | TSG approved | Status Report |
| --- | --- | --- | --- | --- | --- | --- | --- | --- | --- | --- | --- | --- | --- | --- | --- | --- | --- | --- | --- | --- |
| 1010 | 493 | **Further Architecture Enhancement for UAV and UAM** |  | 833.5d | 2021-12-20 A | 2024-03-03 A | 100% |  |  |  |  | 13896h | 13896h | UAS_Ph2 | 50 | Faccin, Stefano, Qualcomm Incorporated | sfaccin@qti.qualcomm.com | Rel-18 | 99 |  |
| 1011 | 493.1 | Study on Phase 2 of UAS, UAV and UAM |  | 256d | 2021-12-20 A | 2022-12-12 A | 100% |  |  | finish no earlier than 2022-12-12 | S2 | 2048h | 2048h | FS_UAS_Ph2 | 48 | Stefano Faccin | sfaccin@qti.qualcomm.com | Rel-18 | 94 |  |
| 1012 | 493.2 | (Stage 2 of UAS Ph2) Further Architecture Enhancement for UAV and UAM |  | 128d | 2022-12-09 A | 2023-06-06 A | 100% |  |  | finish no earlier than 2023-06-06 | S2 | 1024h | 1024h | UAS_Ph2 | 50 | Faccin, Stefano, Qualcomm Incorporated | sfaccin@qti.qualcomm.com | Rel-18 | 98 |  |
| 1013 | 493.3 | Study on Security of Phase 2 for UAS, UAV and UAM |  | 197d | 2022-06-02 A | 2023-03-03 A | 100% |  |  | finish no earlier than 2023-03-03 | S3 | 1576h | 1576h | FS_UAS_Ph2_SEC | 49 | Escott, Adrian, Qualcomm Incorporated, | aescott@qti.qualcomm.com | Rel-18 | 96 |  |
| 1014 | 493.4 | Security of UAV and UAM Phase 2 |  | 128d | 2023-03-16 A | 2023-09-09 A | 100% |  |  | finish no earlier than 2023-09-09 | S3 | 1024h | 1024h | UAS_Ph2 | 50 | Escott, Adrian, Qualcomm Incorporated | aescott@qti.qualcomm.com | Rel-18 | 99 |  |
| 1015 | 493.5 | CT1 aspects of UAS Ph2 |  | 257d | 2023-03-13 A | 2024-03-03 A | 100% |  |  | finish no earlier than 2024-03-03 | C1 | 2056h | 2056h | UAS_Ph2 | 50 | Kim, Sunghoon, Qualcomm Incorporated | sunghoon@qti.qualcomm.com | Rel-18 | 99 |  |
| 1016 | 493.6 | CT3 aspects of UAS Ph2 |  | 257d | 2023-03-13 A | 2024-03-03 A | 100% |  |  | finish no earlier than 2024-03-03 | C3 | 2056h | 2056h | UAS_Ph2 | 50 | Kim, Sunghoon, Qualcomm Incorporated | sunghoon@qti.qualcomm.com | Rel-18 | 99 |  |
| 1017 | 493.7 | CT4 aspects of UAS Ph2 |  | 257d | 2023-03-13 A | 2024-03-03 A | 100% |  |  | finish no earlier than 2024-03-03 | C4 | 2056h | 2056h | UAS_Ph2 | 50 | Kim, Sunghoon, Qualcomm Incorporated | sunghoon@qti.qualcomm.com | Rel-18 | 99 |  |
| 1018 | 493.8 | CT6 aspects of UAS Ph2 |  | 257d | 2023-03-13 A | 2024-03-03 A | 100% |  |  | finish no earlier than 2024-03-03 | C6 | 2056h | 2056h | UAS_Ph2 | 50 | Kim, Sunghoon, Qualcomm Incorporated | sunghoon@qti.qualcomm.com | Rel-18 | 99 |  |
| 1019 | 494 | Study on enhanced architecture for UAS Applications |  | 326d | 2021-09-13 A | 2022-12-12 A | 100% |  |  | finish no earlier than 2022-12-12 | S6 | 2608h | 2608h | FS_eUASAPP | 47 | Monrad, Atle, InterDigital | atle.monrad@interdigital.com | Rel-18 | 93 |  |
| 1020 | 495 | **Architecture for UAS Applications, Phase 2** |  | 476.38d | 2022-09-09 A | 2023-12-12 A | 100% |  |  |  |  | 5688h | 5688h | UASAPP_Ph2 | 49 | Monrad, Atle, InterDigital | atle.monrad@interdigital.com | Rel-18 | 97 |  |
| 1021 | 495.1 | Stage 2 of UASAPP_Ph2 |  | 193d | 2022-09-09 A | 2023-06-06 A | 100% |  |  | finish no earlier than 2023-06-06 | S6 | 1544h | 1544h | UASAPP_Ph2 | 49 | Monrad, Atle, InterDigital | atle.monrad@interdigital.com | Rel-18 | 97 |  |
| 1022 | 495.2 | CT1 aspects of UASAPP_Ph2 |  | 259d | 2022-12-16 A | 2023-12-12 A | 100% |  |  | finish no earlier than 2023-12-12 | C1 | 2072h | 2072h | UASAPP_Ph2 | 49 | Taimoor Abbas, InterDigital | taimoor.abbas@interdigital.com | Rel-18 | 97 |  |
| 1023 | 495.3 | CT3 aspects of UASAPP_Ph2 |  | 259d | 2022-12-16 A | 2023-12-12 A | 100% |  |  | finish no earlier than 2023-12-12 | C3 | 2072h | 2072h | UASAPP_Ph2 | 49 | Taimoor Abbas, InterDigital | taimoor.abbas@interdigital.com | Rel-18 | 97 |  |
| 1024 | 496 | **NR support for UAV (Uncrewed Aerial Vehicles)** |  | 1596.5d | 2021-12-13 A | 2026-03-03 | 79% | 335.41d | 37744.2d |  | R2 | 11400h | 8360.01h | NR_UAV | 48 | Nokia |  | Rel-18 | 94 |  |
| 1025 | 496.1 | Core part: NR support for UAV (Uncrewed Aerial Vehicles) |  | 523d | 2021-12-13 A | 2023-12-12 A | 100% |  |  | finish no earlier than 2023-12-12 | R2 | 4184h | 4184h | NR_UAV-Core | 48 | Jedrzej Stanczak, Nokia, Nokia Shanghai Bell | jedrzej.stanczak@nokia.com | Rel-18 | 94 | RP-233385 |
| 1026 | 496.2 | UE Conformance - NR Support for UAV (Uncrewed Aerial Vehicles) plus CT1 aspects |  | 379d | 2025-03-03 A | 2026-03-03 | 50% | 189.5d | 37744.2d | finish no earlier than 2026-03-03 | R5 | 3032h |  | NR_UAV_plus_CT1-UEConTest | 54 | China Unicom |  | Rel-18 | 107 | RP-253152 |
| 1027 | 497 | **Enhanced LTE Support for UAV (Uncrewed Aerial Vehicles)** |  | 295.12d | 2023-03-03 A | 2023-12-12 A | 100% |  |  |  | R2 | 3264h | 3264h | LTE_UAV_enh | 50 | Nokia |  | Rel-18 | 99 |  |
| 1028 | 497.1 | Core part: Enhanced LTE Support for UAV (Uncrewed Aerial Vehicles) |  | 204d | 2023-03-03 A | 2023-12-12 A | 100% |  |  | finish no earlier than 2023-12-12 | R2 | 1632h | 1632h | LTE_UAV_enh-Core | 50 | Jedrzej Stanczak, Nokia, Nokia Shanghai Bell | jedrzej.stanczak@nokia.com | Rel-18 | 99 | RP-233388 |
| 1029 | 498 | Rel-18 Sidelink, Proximity, Location and Positioning | milestone | 0d? | 2016-03-15 A | 2016-03-15 A | 100% |  |  | start no earlier than 2016-03-15 |  |  |  |  |  |  |  | Rel-18 |  |  |
| 1030 | 499 | **Ranging-based Service and sidelink positioning** |  | 1395.88d | 2020-06-25 A | 2024-03-03 A | 100% |  |  |  |  | 15904h | 15904h | Ranging | 46 | Xiaowei jiang, Xiaomi | jiangxiaowei@xiaomi.com | Rel-18 | 91 |  |
| 1031 | 499.1 | Study on Ranging |  | 252d | 2020-06-25 A | 2021-06-11 A | 100% |  |  | finish no earlier than 2021-06-12 | S1 | 2016h | 2016h | FS_Ranging | 45 | Xiaowei jiang | jiangxiaowei@xiaomi.com | Rel-18 | 88 |  |
| 1032 | 499.2 | Stage 1 for Ranging |  | 62d | 2021-03-18 A | 2021-06-11 A | 100% |  |  | finish no earlier than 2021-06-12 | S1 | 496h | 496h | Ranging | 46 | Xiaowei jiang, Xiaomi | jiangxiaowei@xiaomi.com | Rel-18 | 91 |  |
| 1033 | 499.3 | Study on Ranging based services and sidelink positioning |  | 256d | 2021-12-20 A | 2022-12-12 A | 100% |  |  | finish no earlier than 2022-12-12 | S2 | 2048h | 2048h | FS_Ranging_SL | 48 | Shen, Sherry (Yang), Xiaomi, | shenyang6@xiaomi.com | Rel-18 | 94 |  |
| 1034 | 499.4 | Stage 2 of Ranging_SL |  | 128d | 2022-12-09 A | 2023-06-06 A | 100% |  |  | finish no earlier than 2023-06-06 | S2 | 1024h | 1024h | Ranging_SL | 50 | Shen, Sherry (Yang), Xiaomi | shenyang6@xiaomi.com | Rel-18 | 98 |  |
| 1035 | 499.5 | Study on Security Aspects of Ranging Based Services and Sidelink Positioning |  | 197d | 2022-06-02 A | 2023-03-03 A | 100% |  |  | finish no earlier than 2023-03-03 | S3 | 1576h | 1576h | FS_Ranging_SL_Sec | 49 | Wei Lu, Xiaomi, | luwei10@xiaomi.com | Rel-18 | 96 |  |
| 1036 | 499.6 | Security Aspects of Ranging_SL |  | 128d | 2023-03-16 A | 2023-09-09 A | 100% |  |  | finish no earlier than 2023-09-09 | S3 | 1024h | 1024h | Ranging_SL_Sec | 50 | Lu, Wei, Xiaomi | luwei10@xiaomi.com | Rel-18 | 99 |  |
| 1037 | 499.7 | CT1 aspects of Ranging_SL |  | 257d | 2023-03-13 A | 2024-03-03 A | 100% |  |  | finish no earlier than 2024-03-03 | C1 | 2056h | 2056h | Ranging_SL | 50 | Tingfang Tang, Xiaomi | tangtingfang@xiaomi.com | Rel-18 | 99 |  |
| 1038 | 499.8 | CT3 aspects of Ranging_SL |  | 257d | 2023-03-13 A | 2024-03-03 A | 100% |  |  | finish no earlier than 2024-03-03 | C3 | 2056h | 2056h | Ranging_SL | 50 | Tingfang Tang, Xiaomi | tangtingfang@xiaomi.com | Rel-18 | 99 |  |
| 1039 | 499.9 | CT4 aspects of Ranging_SL |  | 257d | 2023-03-13 A | 2024-03-03 A | 100% |  |  | finish no earlier than 2024-03-03 | C4 | 2056h | 2056h | Ranging_SL | 50 | Tingfang Tang, Xiaomi | tangtingfang@xiaomi.com | Rel-18 | 99 |  |
| 1040 | 499.10 | Charging Aspects of Ranging and Sidelink Positioning |  | 194d | 2023-06-08 A | 2024-03-03 A | 100% |  |  | finish no earlier than 2024-03-03 | S5 | 1552h | 1552h | FS_Ranging_SL_CH | 51 | Zhiwei Mo, China Telecom, | mozw<at>chinatelecom<dot>cn | Rel-18 | 100 |  |

Notes:
- 1010: 10/1/23: FCD clarified to be June (and not March) by e-mail / Impacted TSs and TRs: 23.256
- 1011: ; 21/1/22: 23.700-58 added;; 12/3/22: 0%->20; 4/6/22: 20%->50; 4/6/22: FCD:10/06/2022->09/22; 12/9/22: 50%->80; 12/9/22: FCD:12/09/2022->12/22; 10/12/22: 80%->98; 15/3/23: 98%->100 / Impacted TSs and TRs: 23.256 ; 23.700-58
- 1012: 10/1/23: FCD clarified to be June (and not March) by e-mail ; 15/3/23: 0%->85; 15/3/23: WID:SP-221323->SP-230091; 8/6/23: 85%->100 / Impacted TSs and TRs: 23.256
- 1013: 13/7/22: 33.891 added;; 11/12/22: 0%->65; 17/3/23: 65%->100 / Impacted TSs and TRs: 33.891
- 1014: ; 8/6/23: 0%->60; 7/9/23: 60%->100 / Impacted TSs and TRs: 33.256
- 1015: 31/3/23: 24.578 added;; 31/3/23: 24.577 added;6/6/23: Compl:0%->50% / Impacted TSs and TRs: 24.501.23.122.24.587.27.007.29.255.29.513.29.519.29.522.29.525.29.256.23.008.29.503.29.505.29.510.29.518.29.571.31.102; 24.578; 24.577
- 1016: 9/6/23: 0%->30 / Impacted TSs and TRs: 24.501.23.122.24.587.27.007.29.255.29.513.29.519.29.522.29.525.29.256.23.008.29.503.29.505.29.510.29.518.29.571.31.102
- 1017: 6/6/23: Compl:0%->10% / Impacted TSs and TRs: 24.501.23.122.24.587.27.007.29.255.29.513.29.519.29.522.29.525.29.256.23.008.29.503.29.505.29.510.29.518.29.571.31.102
- 1018: Impacted TSs and TRs: 24.501.23.122.24.587.27.007.29.255.29.513.29.519.29.522.29.525.29.256.23.008.29.503.29.505.29.510.29.518.29.571.31.102
- 1019: 13/12/21: 0%->10; 13/12/21: WID:SP-210954->SP-211511; 13/12/21: FCD:Fri 10/06/->09/22; 12/3/22: 10%->30; 12/3/22: WID:SP-211511->SP-22009; 22/3/22: 23.700-55 added;; 4/6/22: 30%->50; 4/6/22: WID:SP-22009->SP-220465; 12/9/22: 50%->80; 12/9/22: FCD:12/09...; 11/12/22: 80%->100 / Impacted TSs and TRs: 23.700-55
- 1020: Impacted TSs and TRs: 23.255
- 1021: ; 11/12/22: 0%->25; 9/1/23: WID:SP-220915->SP-221228; 17/3/23: 25%->65; 17/3/23: FCD:03/03/2023->/23; 8/6/23: 65%->100 / Impacted TSs and TRs: 23.255
- 1022: 6/6/23: Compl:5%->60% / Impacted TSs and TRs: 27.007; 24.257; 29.257
- 1023: ; 9/6/23: 0%->40 / Impacted TSs and TRs: 27.007; 24.257; 29.257
- 1024: no Perf. part; no RAN1 spec affected so far; 9/1/23: WID:RP-213600->RP-223545; 29/3/23: WID:RP-223545->RP-230782; 2/1/24: WID:RP-230782->RP-233386
- 1025: no Perf. part; no RAN1 spec affected so far; 20/6/22: FCD:12/12/2023->23/12/2022; Stat Rep: ->RP-221498; Rapporteur: Nokia->Jedrzej Stanczak, Nokia, Nokia Shanghai Bell; Rap eMail: ->jedrzej.stanczak@nokia.com13/7/22: FCD:23/12/2022->12/20...; 17/3/23:...; 8/12/23: Compl:80%->100%; Stat Rep: RP-231864->RP-233385;
- 1026: 6/6/25: Compl:0%->28%; Stat Rep: ->RP-251507; ; 11/9/25: Compl:28%->42%; Stat Rep: RP-251507->RP-251977; ; 3/12/25: Compl:42%->50%; Stat Rep: RP-251977->RP-253152; ; 7/1/26: WID:RP-250062->RP-253054
- 1027: 2/1/24: WID:RP-230783->RP-233389
- 1028: ; 7/6/23: Compl:0%->60%; 6/9/23: Compl:60%->80%; Stat Rep: ->RP-231865; Rapporteur: Nokia->Jedrzej Stanczak, Nokia, Nokia Shanghai Bell; Rap eMail: ->jedrzej.stanczak@nokia.com; ; 8/12/23: Compl:80%->100%; Stat Rep: RP-231865->RP-233388;
- 1029: -
- 1030: Impacted TSs and TRs: 22.261
- 1031: 28/7/20: 22.855 added;; 12/9/20: 0%->40; 5/12/20: 40%->80; 19/3/21: FCD:17/03/2021->06/21; 19/3/21: 80%->85; 11/6/21: 85%->100 / Impacted TSs and TRs: 22.855
- 1032: ; 11/6/21: 0%->100 / Impacted TSs and TRs: 22.261
- 1033: 21/1/22: 23.700-86 added;; 12/3/22: 0%->15; 4/6/22: 15%->60; 12/9/22: 60%->70; 10/12/22: 70%->85; 15/3/23: 85%->100 / Impacted TSs and TRs: 23.700-86
- 1034: "Architecture Enhancement to support Ranging based services and Sidelink Positioning" ; 15/3/23: 0%->50; 15/3/23: WID:SP-221325->SP-230106; 17/3/23: 23.586 added;; 8/6/23: 50%->100 / Impacted TSs and TRs: 23.304; 23.287; 23.273; 23.502; 23.503 ; 23.586
- 1035: 13/7/22: 33.893 added;; 12/9/22: 0%->20; 11/12/22: 20%->40; 17/3/23: 40%->70; 8/6/23: 70%->100 / Impacted TSs and TRs: 33.893
- 1036: 31/3/23: 33.533 added;; 8/6/23: 0%->40; 30/6/23: WID:SP-230159->SP-230769; 7/9/23: 40%->100 / Impacted TSs and TRs: 33.533
- 1037: ; 31/3/23: 24.514 added;6/6/23: Compl:0%->15% / Impacted TSs and TRs: 24.501.24.554.24.555.24.571.24.587.24.588.29.122.29.522.29.525.29.519.29.503.29.504.29.505.29.510.29.515.29.571.29.572; 24.514
- 1038: ; 16/7/24: 99%->100 / Impacted TSs and TRs: 24.501.24.554.24.555.24.571.24.587.24.588.29.122.29.522.29.525.29.519.29.503.29.504.29.505.29.510.29.515.29.571.29.572
- 1039: 6/6/23: Compl:0%->30%; 4/1/24: 29.586 added; / Impacted TSs and TRs: 24.501.24.554.24.555.24.571.24.587.24.588.29.122.29.522.29.525.29.519.29.503.29.504.29.505.29.510.29.515.29.571.29.572; 29.586
- 1040: 30/6/23: 28.845 added;; 7/9/23: 0%->15; 8/12/23: 15%->70; 8/12/23: FCD:12/12/2023->/2024; 14/3/24: 70%->100 / Impacted TSs and TRs: 28.845

| ID | WBS | Task | Duration | Start | Finish | Complete | Remaining | Actual start | Actual finish | Total slack | Constraint | Resources | Work | Actual work | Acronym | PCG approved | Impacted TSs and TRs | WI rapporteur name | WI rapporteur e-mail | Release | TSG approved | Status Report |
| --- | --- | --- | --- | --- | --- | --- | --- | --- | --- | --- | --- | --- | --- | --- | --- | --- | --- | --- | --- | --- | --- | --- |
| 1041 | 500 | **5GC LoCation Services - Phase 3** | 373d | 2022-09-30 | 2024-03-03 A | 100% |  | 2021-12-20 |  |  |  |  | 11104h | 11104h | 5G_eLCS_Ph3 | 49 | 23.273 | Ming Ai, CATT | aiming@catt.cn | Rel-18 | 97 |  |
| 1042 | 500.1 | Study on Enhancement to the 5GC LoCation Services-Phase 3 | 256d | 2021-12-20 A | 2022-12-12 A | 100% |  |  |  |  | finish no earlier than 2022-12-12 | S2 | 2048h | 2048h | FS_eLCS_Ph3 | 48 | 23.700-71 | Ming Ai, CATT | aiming@catt.cn, Primary Rapporteur. | Rel-18 | 94 |  |
| 1043 | 500.2 | (stage 2 of) 5GC LoCation Services - Phase 3 | 259d | 2022-09-30 A | 2023-06-06 A | 100% |  |  |  |  | finish no earlier than 2023-06-06 | S2 | 1424h | 1424h | 5G_eLCS_Ph3 | 49 | 23.273 | Ming Ai, CATT | aiming@catt.cn | Rel-18 | 97 |  |
| 1044 | 500.3 | CT1 aspects of 5G_eLCS_Ph3 | 318d | 2022-12-16 A | 2024-03-03 A | 100% |  |  |  |  | finish no earlier than 2024-03-03 | C1 | 2544h | 2544h | 5G_eLCS_Ph3 | 49 | 23.273 | Wang, Baixiao, CATT | wangbaixiao@cictmobile.com | Rel-18 | 97 |  |
| 1045 | 500.4 | CT3 aspects of 5G_eLCS_Ph3 | 318d | 2022-12-16 A | 2024-03-03 A | 100% |  |  |  |  | finish no earlier than 2024-03-03 | C3 | 2544h | 2544h | 5G_eLCS_Ph3 | 49 | 23.273 | Wang, Baixiao, CATT | wangbaixiao@cictmobile.com | Rel-18 | 97 |  |
| 1046 | 500.5 | CT4 aspects of 5G_eLCS_Ph3 | 318d | 2022-12-16 A | 2024-03-03 A | 100% |  |  |  |  | finish no earlier than 2024-03-03 | C4 | 2544h | 2544h | 5G_eLCS_Ph3 | 49 | 23.273 | Wang, Baixiao, CATT | wangbaixiao@cictmobile.com | Rel-18 | 97 |  |
| 1047 | 501 | Charging aspects of 5GC LoCation Services | 75.5d | 2025-03-26 A | 2025-06-06 A | 100% |  |  |  |  | start no earlier than 2025-03-26 | S5 | 604h | 604h | CH_5G_eLCS_Ph3 | 54 | 32.271; 32.290; 32.291; 32.298 | Zhiwei Mo, China Telecom | mozw@chinatelecom.cn | Rel-19 | 107 |  |
| 1048 | 502 | **Expanded and improved NR positioning** | 1315.75d | 2022-12-13 A | 2026-06-05 | 73% | 351.8d |  |  | 37647d |  |  | 18023h | 11432h | NR_pos_enh2 | 50 |  | Intel |  | Rel-18 | 98 |  |
| 1049 | 502.1 | Core part: Expanded and improved NR positioning | 583d | 2022-12-13 A | 2025-03-03 A | 100% |  |  |  |  | finish no earlier than 2025-03-24 | R1 | 4664h | 4664h | NR_pos_enh2-Core | 50 | 38.355 | Debdeep Chatterjee | debdeep.chatterjee@intel.com | Rel-18 | 98 | RP-241919 |
| 1050 | 502.2 | Perf. part: Expanded and improved NR positioning | 524d | 2022-12-15 A | 2024-05-04 | 99% | 5.24d |  |  | 38436.8d | finish no earlier than 2024-12-12 | R4 | 4192h | 3648h | NR_pos_enh2-Perf | 50 |  | Debdeep Chatterjee | debdeep.chatterjee@intel.com | Rel-18 | 98 | RP-242766 |
| 1051 | 502.3 | UE Conformance - Expanded and improved NR positioning | 755.88d | 2024-06-06 A | 2026-06-05 | 21% | 597.14d |  |  | 37647d | finish no earlier than 2026-06-05 | R5 | 6047h |  | NR_pos_enh2-UEConTest | 53 |  | CATT |  | Rel-18 | 104 | RP-253448 |
| 1052 | 502.4 | Study on expanded and improved NR positioning | 390d | 2022-12-13 A | 2024-06-05 A | 100% |  |  |  |  |  | R1 | 3120h | 3120h | FS_NR_pos_enh2 | 48 | 38.859 | Debdeep Chatterjee, Intel Corporation | debdeep.chatterjee@intel.com | Rel-18 | 94 | RP-222982 |
| 1053 | 503 | **NR sidelink evolution** | 2072.75d | 2021-12-13 A | 2027-06-06 | 68% | 670.8d |  |  | 37268d |  |  | 13874h | 9384h | NR_SL_enh2 | 48 |  | OPPO |  | Rel-18 | 94 |  |
| 1054 | 503.1 | Core part: NR sidelink evolution | 523d | 2021-12-13 A | 2023-12-12 A | 100% |  |  |  |  | finish no earlier than 2023-12-12 | R1 | 4184h | 4184h | NR_SL_enh2-Core | 48 | 38.786 | Kevin Lin, OPPO | Kevin.Lin@oppo.com | Rel-18 | 94 | RP-232786 |
| 1055 | 503.2 | Perf. part: NR sidelink evolution | 650d | 2021-12-15 A | 2024-06-06 A | 100% |  |  |  |  | finish no earlier than 2024-06-06 | R1 | 5200h | 5200h | NR_SL_enh2-Perf | 48 |  | Kevin Lin, OPPO | Kevin.Lin@oppo.com | Rel-18 | 94 | RP-240928 |
| 1056 | 503.3 | UE Conformance - NR sidelink evolution | 561.25d | 2025-12-12 | 2027-06-06 |  |  |  |  | 37268d | finish no earlier than 2027-06-06 | R5 | 4490h |  | NR_SL_enh2-UEConTest |  |  | CATT |  | Rel-18 |  |  |
| 1057 | 504 | **NR sidelink relay enhancements** | 1134.62d | 2021-12-13 A | 2024-12-12 | 68% | 367.2d |  |  |  |  |  | 13874h | 9384h | NR_SL_relay_enh | 48 |  | LG Electronics |  | Rel-18 | 94 |  |
| 1058 | 504.1 | Core part: NR sidelink relay enhancements | 523d | 2021-12-13 A | 2023-12-12 A | 100% |  |  |  |  | finish no earlier than 2023-12-12 | R2 | 4184h | 4184h | NR_SL_relay_enh-Core | 48 |  | Youngdae LEE, LG Electronics Inc. | youngdae.lee@lge.com | Rel-18 | 94 | RP-232971 |
| 1059 | 504.2 | Perf. part: NR sidelink relay enhancements | 650d | 2021-12-15 A | 2024-06-06 A | 100% |  |  |  |  | finish no earlier than 2024-06-06 | R2 | 5200h | 5200h | NR_SL_relay_enh-Perf | 48 |  | Youngdae LEE, LG Electronics Inc. | youngdae.lee@lge.com | Rel-18 | 94 | RP-241088 |
| 1060 | 504.3 | UE Conformance - NR sidelink relay enhancements | 561.25d | 2025-12-12 | 2027-06-06 |  |  |  |  | 37268d | finish no earlier than 2027-06-06 | R5 | 4490h |  | NR_SL_relay_enh-UEConTest |  |  | CATT |  | Rel-18 |  |  |
| 1061 | 505 | **Mobile Terminated-Small Data Transmission (MT-SDT) for NR** | 1134.62d | 2021-12-13 A | 2024-12-12 | 100% |  |  | 2025-12-12 |  |  |  | 8781h | 8781h | NR_MT_SDT | 48 |  | ZTE |  | Rel-18 | 94 |  |
| 1062 | 505.1 | Core part: Mobile Terminated-Small Data Transmission (MT-SDT) for NR | 523d | 2021-12-13 A | 2023-12-12 A | 100% |  |  |  |  | finish no earlier than 2023-12-12 | R2 | 4184h | 4184h | NR_MT_SDT-Core | 48 |  | Eswar Vutukuri, ZTE Corporation | eswar.vutukuri@zte.com.cn | Rel-18 | 94 | RP-232887 |
| 1063 | 505.2 | UE Conformance - Mobile Terminated-Small Data Transmission (MT-SDT) for NR | 574.62d | 2024-06-06 A | 2025-12-12 A | 100% |  |  |  |  | finish no earlier than 2025-12-12 | R5 | 4597h | 4597h | NR_MT_SDT-UEConTest | 53 |  | Qualcomm |  | Rel-18 | 104 | RP-253181 |
| 1064 | 506 | **Study on Proximity based Services Phase 2** | 461.75d | 2021-12-20 A | 2023-03-10 A | 100% |  |  |  |  |  | S2 | 6704h | 6704h | FS_5G_ProSe_Ph2 | 48 | 23.700-33 | Deng, Qiang, CATT | dengqiang1@catt.cn, Primary Rapporteur. | Rel-18 | 95 |  |
| 1065 | 506.1 | Study on Stage 2 for Proximity based Services Phase 2 | 256d | 2021-12-20 A | 2022-12-12 A | 100% |  |  |  |  | finish no earlier than 2022-12-12 | S2 | 2048h | 2048h | FS_5G_ProSe_Ph2 | 48 | 23.700-33 | Deng, Qiang, CATT | dengqiang1@catt.cn, Primary Rapporteur. | Rel-18 | 94 |  |
| 1066 | 506.2 | Study on Security Aspects of Proximity Based Services Phase 2 | 262d | 2022-03-10 A | 2023-03-10 A | 100% |  |  |  |  | finish no earlier than 2023-03-12 | S3 | 2096h | 2096h | FS_5G_ProSe_Ph2 | 48 | 33.740; 33.741 | Wei Zhou, CATT | zhouwei@catt.cn | Rel-18 | 95 |  |

Notes:
- 1042: 21/1/22: 23.700-71 added;; 12/3/22: 0%->15; 12/3/22: WID:SP-211637->SP-220069; 4/6/22: 15%->55; 4/6/22: FCD:12/09/2022->12/22; 12/9/22: 55%->80; 10/12/22: 80%->100
- 1043: ; 10/12/22: WID:SP-220811->SP-221123; 10/12/22: 0%->30; 10/12/22: 0%->30; 9/1/23: WID:SP-221123->SP-221338; 15/3/23: 30%->65; 15/3/23: WID:SP-221338->SP-230093; 15/3/23: FCD:03/03/2023->06/20; 8/6/23: 65%->100
- 1044: 6/6/23: Compl:5%->15%
- 1045: ; 9/6/23: 20%->30
- 1046: ; 9/6/23: 25%->65
- 1047: ; 6/6/25: 0%->100; 12/9/25: FCD:Tue 09/09/->/25
- 1048: 29/3/23: WID:RP-223549->RP-230328; 6/10/23: WID:RP-230328->RP-232670; 2/1/24: WID:RP-232670->RP-233382; 2/4/24: WID:RP-233382->RP-240778; 23/7/24: WID:RP-240778->RP-241186
- 1049: 17/3/23: Compl:0%->15%; Stat Rep: ->RP-230327; Rapporteur: Intel->Debdeep Chatterjee, Intel Corporation; Rap eMail: ->debdeep.chatterjee@intel.com; 17/3/23: 38.355 added;; ;...; 6/9/23: Compl:50%->70%; WID: RP-230328->RP-231460; Stat Rep: RP-230327->R...; 4/9/24: FCD:03/03/2024->24/03/2025; Compl:99%->100%; Stat Rep: RP-240302->RP-241919;
- 1050: Study in Rel-17 UID820025; 13/12/21: 0%->15; 12/3/22: 15%->30; 22/3/22: 23.545 added;; 4/6/22: 30%->50; 12/9/22: 50%->55; 11/12/22: 55%->65; 11/12/22: FCD:09/12/2022->/23; 9/1/23: WID:SP-210957->SP-221233; 17/3/23: 65%->75; 8/6/23: 75%->100; 30/6/23: ...; 6/12/24: FCD:24/09/2024->12/12/2024; Compl:100%->99%; Stat Rep: RP-241919->RP-242766;
- 1051: 4/9/24: FCD:06/06/2026->26/06/2025; Compl:0%->5%; Stat Rep: ->RP-242124; ; 26/9/24: WID:RP-241342->RP-242125; 6/12/24: FCD:06/06/2025->05/06/2026; Compl:5%->6%; WID: RP-242125->RP-241342; Stat Rep: RP-242124->RP-243121; ; 6/3/25: FCD:23/10/2025->05/06/20; 7/1/26: WID:RP-241342->RP-253839
- 1052: compare REL-17 SI FS_NR_pos; TR 38.8xx; 21/1/22: 38.859 added; ; 6/6/22: Compl:0%->12% 20/6/22: Rapporteur: Intel->Alexey Khoryaev, Intel Corporation; Rap eMail: ->alexey.khoryaev@intel.com12/7/22: WID:RP-213588->RP-221814 ;...; 23/9/22: WID:RP-213588...; 9/1/23: 0%->100
- 1053: TR 38.8xx; compare REL-17 WI NR_SL_enh; 5/4/22: WID:RP-213678->RP-220300; 12/7/22: WID:RP-220300->RP-221798; 23/9/22: WID:RP-221798->RP-221938; 9/1/23: WID:RP-221938->RP-222806; 29/3/23: WID:RP-222806->RP-230077; 2/1/24: WID:RP-230077->RP-232789
- 1054: TR 38.8xx; compare REL-17 WI NR_SL_enh; 22/3/22: Stat Rep: ->RP-220320 6/6/22: Compl:0%->7% ; ; 20/6/22: Rapporteur: OPPO->Kevin Lin, OPPO; Rap eMail: ->Kevin.Lin@oppo.com13/7/22: FCD:23/12/2022->12/20 ; ...; 9/12/22: FCD:23/12/2022->01/12/2023; Comp...; 8/12/23: Compl:85%->100%; Stat Rep: RP-231583->RP-232786;
- 1055: ; 22/3/22: CD:12/09/2023->12/06/2024; 22/3/22: Stat Rep: ->RP-220320 6/6/22: CD:12/06/2024->24/06/2022 6/6/22: ; 20/6/22: WG: R4->R1; Rapporteur: OPPO->Kevin Lin, OPPO; Rap eMail: ->Kevin.Lin@oppo.com13/7/22: FCD:24/06/2022->06/20 ; ...; 9/12/22: FCD...; 23/7/24: 100%->100
- 1057: compare REL-17 WI NR_SL_relay; 6/1/22: WID:RP-213585->RP-212819; 5/4/22: WID:RP-212819->RP-221010; 12/7/22: WID:RP-221010->RP-221262; 9/1/23: WID:RP-221262->RP-223501; 2/1/24: WID:RP-223501->RP-232972
- 1058: compare REL-17 WI NR_SL_relay; 22/3/22: WID: RP-212819->RP-213585; 22/3/22: Stat Rep: ->RP-220524 ; 6/6/22: CD:12/12/2023->23/12/2022 ; 20/6/22: Rapporteur: LG Electronics->Youngdae LEE, LG Electronics; Rap eMail: ->youngdae.lee@lge.com13/7/22: ...;...; 8/12/23: Compl:80%->100%; Stat Rep: RP-231725->RP-232971;
- 1059: ; 22/3/22: CD:24/06/2024->12/06/2024; 22/3/22: WID: RP-212819->RP-213585; 22/3/22: Stat Rep: ->RP-220524 6/6/22: CD:12/06/2024->24/06/2022 20/6/22: WG: R4->R2; FCD:24/06/2022->22/06/2022; Rapporteur: LG Electronics->Youngdae LEE, LG Electronics;...;...; 13/6/24: Compl:50%->100%; Stat Rep: RP-240128->RP-241088;
- 1061: no Perf. part; 9/1/23: WID:RP-213583->RP-222993; 2/1/24: WID:RP-222993->RP-234010
- 1062: no Perf. part ; 6/6/22: CD:12/09/2023->23/09/2022 6/6/22: Stat Rep: RP-220215->RP-221310; 20/6/22: Rapporteur: ZTE->Eswar Vutukuri, ZTE Corporation; Rap eMail: ->eswar.vutukuri@zte.com.cn13/7/22: FCD:23/09/2022->09/20 ...; 9/12/22: FCD:23/09/2022->01...; 8/12/23: Compl:99%->100%; Stat Rep: RP-232648->RP-232887;
- 1063: 4/9/24: FCD:12/12/2025->25/12/2024; Compl:0%->10%; Stat Rep: ->RP-241914; ; 6/12/24: FCD:12/12/2024->12/12/2025; Compl:10%->40%; Stat Rep: RP-241914->RP-242496; ; 6/3/25: FCD:24/06/2025->12/12/2025; Compl:40%->65%; Stat Rep: RP-242496->RP-250111; ; 6/6/2; 3/12/25: Compl:95%->100%; Stat Rep: RP-251961->RP-253181;
- 1064: 21/1/22: 23.700-33 added;; 12/3/22: 0%->20; 14/3/24: 95%->100
- 1065: 21/1/22: 23.700-33 added;; 12/3/22: 0%->20; 4/6/22: 20%->55; 12/9/22: 55%->75; 10/12/22: 75%->100
- 1066: 4/6/22: 0%->5; 13/7/22: 33.740 added;; 13/7/22: 33.741 added;; 12/9/22: 5%->40; 11/12/22: 40%->75; 17/3/23: 75%->80; 8/6/23: 80%->90

| ID | WBS | Task | Type | Duration | Start | Finish | Complete | Constraint | Resources | Work | Actual work | Acronym | PCG approved | WI rapporteur name | WI rapporteur e-mail | Release | TSG approved |
| --- | --- | --- | --- | --- | --- | --- | --- | --- | --- | --- | --- | --- | --- | --- | --- | --- | --- |
| 1067 | 507 | **Proximity-based Services in 5GS Phase 2** |  | 457.62d? | 2022-09-27 A | 2023-12-12 A | 100% |  |  | 10760h | 10760h | 5G_ProSe_Ph2 | 49 | Deng Qiang, CATT | dengqiang1@catt.cn | Rel-18 | 97 |
| 1068 | 507.1 | (stage 2 of) Proximity-based Services in 5GS Phase 2 |  | 262d? | 2022-09-27 A | 2023-06-06 A | 100% | finish no earlier than 2023-06-06 | S2 | 1448h | 1448h | 5G_ProSe_Ph2 | 49 | Deng Qiang, CATT | dengqiang1@catt.cn | Rel-18 | 97 |
| 1069 | 507.2 | CT1 aspects of 5G_ProSe_Ph2 |  | 259d | 2022-12-16 A | 2023-12-12 A | 100% | finish no earlier than 2023-12-12 | C1 | 2072h | 2072h | 5G_ProSe_Ph2 | 49 | Duan, Xiaoyan, CATT | duanxiaoyan@catt.cn | Rel-18 | 97 |
| 1070 | 507.3 | CT3 aspects of 5G_ProSe_Ph2 |  | 259d | 2022-12-16 A | 2023-12-12 A | 100% | finish no earlier than 2023-12-12 | C3 | 2072h | 2072h | 5G_ProSe_Ph2 | 49 | Duan, Xiaoyan, CATT | duanxiaoyan@catt.cn | Rel-18 | 97 |
| 1071 | 507.4 | CT4 aspects of 5G_ProSe_Ph2 |  | 259d | 2022-12-16 A | 2023-12-12 A | 100% | finish no earlier than 2023-12-12 | C4 | 2072h | 2072h | 5G_ProSe_Ph2 | 49 | Duan, Xiaoyan, CATT | duanxiaoyan@catt.cn | Rel-18 | 97 |
| 1072 | 507.5 | CT6 aspects of 5G_ProSe_Ph2 |  | 259d | 2022-12-16 A | 2023-12-12 A | 100% | finish no earlier than 2023-12-12 | C6 | 2072h | 2072h | 5G_ProSe_Ph2 | 49 | Duan, Xiaoyan, CATT | duanxiaoyan@catt.cn | Rel-18 | 97 |
| 1073 | 507.6 | Security Aspects of Proximity-based Services in 5GS Phase 2 |  | 128d | 2023-03-16 A | 2023-09-09 A | 100% | finish no earlier than 2023-09-09 | S3 | 1024h | 1024h | 5G_ProSe_Ph2 | 50 | Wei Zhou, CATT | zhouwei@catt.cn | Rel-18 | 99 |
| 1074 | 508 | **5G-enabled fused location service capability exposure** |  | 1032.38d | 2021-06-11 A | 2024-03-03 A | 100% |  |  | 7752h | 7752h | 5GFLS | 50 | Liping Wu, CATT | wuliping@cictmobile.com | Rel-18 | 99 |
| 1075 | 508.1 | Study on 5G-enabled fused location service capability exposure |  | 327d | 2021-06-11 A | 2022-09-12 A | 100% | finish no earlier than 2022-09-12 | S6 | 2616h | 2616h | FS_5GFLS | 47 | Zhang, Ling, CATT | zhangling@catt.cn | Rel-18 | 92 |
| 1076 | 508.2 | Stage 2 of 5GFLS |  | 128d | 2022-12-09 A | 2023-06-06 A | 100% | finish no earlier than 2023-06-06 | S6 | 1024h | 1024h | 5GFLS | 50 | Liping Wu, CATT | wuliping@cictmobile.com | Rel-18 | 98 |
| 1077 | 508.3 | CT1 aspects of 5GFLS |  | 257d | 2023-03-13 A | 2024-03-03 A | 100% | finish no earlier than 2024-03-03 | C1 | 2056h | 2056h | 5GFLS | 50 | Zhao, Xiaoxue, CATT | zhaoxiaoxue@cictmobile.com | Rel-18 | 99 |
| 1078 | 508.4 | CT3 aspects of 5GFLS |  | 257d | 2023-03-13 A | 2024-03-03 A | 100% | finish no earlier than 2024-03-03 | C3 | 2056h | 2056h | 5GFLS | 50 | Zhao, Xiaoxue, CATT | zhaoxiaoxue@cictmobile.com | Rel-18 | 99 |
| 1079 | 509 | See also MCOver5GProSe under Mission Critical and LPHP under Verticals | milestone | 0d? | 2016-03-15 A | 2016-03-15 A | 100% | start no earlier than 2016-03-15 |  |  |  |  |  |  |  | Rel-18 |  |
| 1080 | 510 | Rel-18 Verticals, Industries, Factories, Northbound API | milestone | 0d? | 2016-03-15 A | 2016-03-15 A | 100% | start no earlier than 2016-03-15 |  |  |  |  |  |  |  | Rel-18 |  |
| 1081 | 511 | Service exposure interfaces for industry |  | 7d | 2021-09-10 A | 2021-09-20 A | 100% | finish no earlier than 2021-09-20 | S1 | 56h | 56h | EXPOSE | 47 | Joachim W. Walewski | joachim.walewski@siemens.com | Rel-18 | 93 |
| 1082 | 512 | Guidelines for CAPIF Usage |  | 266d | 2023-09-07 A | 2024-09-09 A | 100% | finish no earlier than 2024-09-09 | S6 | 2128h | 2128h | CAPIF_EXT | 51 | Junpei Uoshima, NTT DOCOMO | junpei.uoshima.mt@nttdocomo.com | Rel-18 | 101 |
| 1083 | 513 | **Generic group management, exposure and communication enhancements** |  | 833.5d | 2021-12-20 A | 2024-03-03 A | 100% |  |  | 9144h | 9144h | GMEC | 49 | Qianghua Zhu, Huawei | zhuqianghua@huawei.com | Rel-18 | 97 |
| 1084 | 513.1 | Study on generic group management, exposure and communication enhancements |  | 256d | 2021-12-20 A | 2022-12-12 A | 100% | finish no earlier than 2022-12-12 | S2 | 2048h | 2048h | FS_GMEC | 48 | Qianghua Zhu, Huawei | zhuqianghua@huawei.com | Rel-18 | 94 |
| 1085 | 513.2 | Stage 2 of GMEC |  | 116d | 2022-09-23 A | 2023-03-03 A | 100% | finish no earlier than 2023-03-03 | S2 | 928h | 928h | GMEC | 49 | Qianghua Zhu, Huawei | zhuqianghua@huawei.com | Rel-18 | 97 |
| 1086 | 513.3 | CT3 aspects of GMEC |  | 257d | 2023-03-13 A | 2024-03-03 A | 100% | finish no earlier than 2024-03-03 | C3 | 2056h | 2056h | GMEC | 49 | El Moatamid, Abdessamad, Huawei | abdessamad.el.moatamid@huawei.com | Rel-18 | 97 |
| 1087 | 513.4 | CT4 aspects of GMEC |  | 257d | 2023-03-13 A | 2024-03-03 A | 100% | finish no earlier than 2024-03-03 | C4 | 2056h | 2056h | GMEC | 49 | El Moatamid, Abdessamad, Huawei | abdessamad.el.moatamid@huawei.com | Rel-18 | 97 |
| 1088 | 513.5 | CT1 aspects of GMEC |  | 257d | 2023-03-13 A | 2024-03-03 A | 100% | finish no earlier than 2024-03-03 | C1 | 2056h | 2056h | GMEC | 49 | El Moatamid, Abdessamad, Huawei | abdessamad.el.moatamid@huawei.com | Rel-18 | 97 |
| 1089 | 514 | Application layer support for Factories of the Future (FF) |  | 387d | 2021-09-10 A | 2023-03-03 A | 100% | finish no earlier than 2023-03-03 | S6 | 3096h | 3096h | FFAPP | 47 | Shao Weixiang, ZTE Corporation | shao.weixiang@zte.com.cn | Rel-18 | 93 |
| 1090 | 515 | **Service Enabler Architecture Layer for Verticals Phase 3** |  | 661.62d | 2021-12-10 A | 2023-09-09 A | 100% |  |  | 8319.84h | 8319.84h | SEAL_Ph3 | 48 | Basavaraj (Basu) Pattan, Samsung | basavarajjp@samsung.com | Rel-18 | 94 |
| 1091 | 515.1 | Stage 2 of SEAL_Ph3 |  | 387.98d | 2021-12-12 A | 2023-06-06 A | 100% | finish no earlier than 2023-06-06 | S6 | 3103.84h | 3103.84h | SEAL_Ph3 | 48 | Basavaraj (Basu) Pattan, Samsung | basavarajjp@samsung.com | Rel-18 | 94 |
| 1092 | 515.2 | CT1 aspects of SEAL_Ph3 |  | 262d | 2021-12-12 A | 2022-12-12 A | 100% | finish no earlier than 2022-12-12 | C1 | 2096h | 2096h | SEAL_Ph3 | 48 | Vijay Sangameshwara (Samsung Electronics) | s.vijay@samsung.com | Rel-18 | 94 |
| 1093 | 515.3 | CT3 aspects of SEAL_Ph3 |  | 262d | 2021-12-10 A | 2022-12-09 A | 100% | finish no earlier than 2022-12-12 | C3 | 2096h | 2096h | SEAL_Ph3 | 48 | Vijay Sangameshwara (Samsung Electronics) | s.vijay@samsung.com | Rel-18 | 94 |
| 1094 | 515.4 | Security aspects of SEAL_Ph3 |  | 128d | 2023-03-16 A | 2023-09-09 A | 100% | finish no earlier than 2023-09-09 | S3 | 1024h | 1024h | SEAL_Ph3 | 50 | Rajavelsamy Rajadurai, Samsung | rajvel@samsung.com | Rel-18 | 99 |

Notes:
- 1067: Impacted TSs and TRs: 23.304; 23.501; 23.502; 23.503
- 1068: ; 9/1/23: WID:SP-220806->SP-221206; 15/3/23: WID:SP-221206->SP-230097; 15/3/23: 0%->80; 15/3/23: FCD:03/03/2023->/23; 8/6/23: 80%->100 / Impacted TSs and TRs: 23.304; 23.501; 23.502; 23.503
- 1069: ; 9/6/23: 15%->70 / Impacted TSs and TRs: 24.554; 24.555; 23.122; 24.501; 24.526; 24.587; 27.007; 29.513; 29.519; 29.522; 29.525; 29.559; 29.553; 23.008; 29.503; 29.505; 29.510; 29.518; 29.571; 29.509; 31.102
- 1070: ; 9/6/23: 0%->20 / Impacted TSs and TRs: 24.554; 24.555; 23.122; 24.501; 24.526; 24.587; 27.007; 29.513; 29.519; 29.522; 29.525; 29.559; 29.553; 23.008; 29.503; 29.505; 29.510; 29.518; 29.571; 29.509; 31.102
- 1071: 6/6/23: Compl:0%->30% / Impacted TSs and TRs: 24.554; 24.555; 23.122; 24.501; 24.526; 24.587; 27.007; 29.513; 29.519; 29.522; 29.525; 29.559; 29.553; 23.008; 29.503; 29.505; 29.510; 29.518; 29.571; 29.509; 31.102
- 1072: Impacted TSs and TRs: 24.554; 24.555; 23.122; 24.501; 24.526; 24.587; 27.007; 29.513; 29.519; 29.522; 29.525; 29.559; 29.553; 23.008; 29.503; 29.505; 29.510; 29.518; 29.571; 29.509; 31.102
- 1073: ; 8/6/23: 0%->90; 8/12/23: 90%->95; 15/3/24: 95%->100 / Impacted TSs and TRs: 33.503
- 1074: Impacted TSs and TRs: 23.434
- 1075: 2/7/21: 23.700-96 added;; 13/9/21: 0%->20; 13/12/21: 20%->40; 13/12/21: WID:SP-210477->SP-211512; 13/12/21: FCD:Fri 11/03/->06/22; 12/3/22: FCD:10/06/2022->9/22; 12/3/22: WID:SP-211512->SP-220097; 4/6/22: 40%->55; 12/9/22: 55%->75; 11/12/22: 75%->100 / Impacted TSs and TRs: 23.700-96
- 1076: ; 17/3/23: 0%->60; 17/3/23: FCD:03/03/2023->/23; 8/6/23: 60%->100 / Impacted TSs and TRs: 23.434
- 1077: 6/6/23: Compl:0%->60% / Impacted TSs and TRs: 24.545; 29.549
- 1078: ; 9/6/23: 0%->70 / Impacted TSs and TRs: 24.545; 29.549
- 1079: -
- 1080: -
- 1081: ; 13/12/21: 0%->100 / Impacted TSs and TRs: 22.261
- 1082: 8/12/23: 0%->20; 4/1/24: 23.946 added;; 14/3/24: 20%->55; 13/6/24: 55%->80; 4/9/24: 80%->90; 5/12/24: 90%->100; 8/1/25: WID:SP-231161->SP-241692 (change Rel-19->Rel-18) / Impacted TSs and TRs: 23.946
- 1083: ; 10/12/22: 0%->30; 9/1/23: WID:SP-220989->SP-221339 / Impacted TSs and TRs: 23.501; 23.502; 23.503
- 1084: 21/1/22: 23.700-74 added;; 12/3/22: 0%->25; 4/6/22: 25%->70; 12/9/22: 70%->90; 10/12/22: 90%->95; 10/12/22: FCD:12/09/2022->12/22; 15/3/23: 95%->100 / Impacted TSs and TRs: 23.700-74
- 1085: ; 10/12/22: 0%->30; 9/1/23: WID:SP-220989->SP-221339; 15/3/23: WID:SP-221339->SP-230101; 15/3/23: 30%->70; 8/6/23: 70%->100 / Impacted TSs and TRs: 23.501; 23.502; 23.503
- 1086: 6/6/23: Compl:15%->40%6/6/23: WID: CP-230118->CP-231194 / Impacted TSs and TRs: 29.122.29.512.29.513.29.519.29.522.29.525.29.565.29.502.29.503.29.504.29.505.29.571.24.501.24.526
- 1087: 6/6/23: Compl:5%->40%6/6/23: WID: CP-230118->CP-231194 / Impacted TSs and TRs: 29.122.29.512.29.513.29.519.29.522.29.525.29.565.29.502.29.503.29.504.29.505.29.571.24.501.24.526
- 1088: 6/6/23: Compl:0%->75%6/6/23: WID: CP-230118->CP-231194 / Impacted TSs and TRs: 29.122.29.512.29.513.29.519.29.522.29.525.29.565.29.502.29.503.29.504.29.505.29.571.24.501.24.526
- 1089: Impacted TSs and TRs: 23.434 ; 23.545
- 1090: Impacted TSs and TRs: 23.434
- 1091: ; 12/3/22: 0%->5; 4/6/22: 5%->20; 12/9/22: 20%->35; 11/12/22: 35%->60. Acronym: eSEAL_Ph2->SEAL_Ph3; 11/12/22: FCD:12/12/2022->/23; 17/3/23: WID:SP-211518->SP-230276; 17/3/23: FCD:03/03/2023->6/6//23; change rapport (was Basavaraj (Basu) Pattan, Samsu...; 8/6/23: 90%->100 / Impacted TSs and TRs: 23.434
- 1092: 6/6/23: Compl:10%->45% / Impacted TSs and TRs: 24.544; 24.545; 24.546; 24.547; 24.548; 24.549; 29.549
- 1093: 9/6/23: 15%->45 / Impacted TSs and TRs: 24.544; 24.545; 24.546; 24.547; 24.548; 24.549; 29.549
- 1094: ; 8/6/23: 0%->80; 15/3/24: 80%->100 / Impacted TSs and TRs: 33.434

| ID | WBS | Task | Type | Duration | Start | Finish | Complete | Constraint | Resources | Work | Actual work | Acronym | PCG approved | WI rapporteur name | WI rapporteur e-mail | Release | TSG approved |
| --- | --- | --- | --- | --- | --- | --- | --- | --- | --- | --- | --- | --- | --- | --- | --- | --- | --- |
| 1095 | 516 | **SEAL data delivery enabler for vertical applications** |  | 934.88d | 2021-09-13 A | 2024-03-03 A | 100% |  |  | 9264h | 9264h | SEALDD | 49 | Niranth Amogh, Huawei Telecommunications India | namogh@huawei.com | Rel-18 | 97 |
| 1096 | 516.1 | Study on SEAL data delivery enabler for vertical applications |  | 261d | 2021-09-13 A | 2022-09-12 A | 100% | finish no earlier than 2022-09-12 | S6 | 2088h | 2088h | FS_SEALDD | 47 | Niranth Amogh, Huawei Telecommunications India | namogh@huawei.com | Rel-18 | 93 |
| 1097 | 516.2 | (Stage 2 of Seal DD) SEAL data delivery enabler for vertical applications |  | 193d | 2022-09-09 A | 2023-06-06 A | 100% | finish no earlier than 2023-06-06 | S6 | 1544h | 1544h | SEALDD | 49 | Niranth Amogh, Huawei Telecommunications India | namogh@huawei.com | Rel-18 | 97 |
| 1098 | 516.3 | CT1 aspects of SEALDD |  | 318d | 2022-12-16 A | 2024-03-03 A | 100% | finish no earlier than 2024-03-03 | C1 | 2544h | 2544h | SEALDD | 49 | Herrero Veron, Christian (Huawei) | Christian.Herrero at huawei.com | Rel-18 | 97 |
| 1099 | 516.4 | CT3 aspects of SEALDD |  | 318d | 2022-12-16 A | 2024-03-03 A | 100% | finish no earlier than 2024-03-03 | C3 | 2544h | 2544h | SEALDD | 49 | Herrero Veron, Christian (Huawei) | Christian.Herrero at huawei.com | Rel-18 | 97 |
| 1100 | 516.5 | Security aspects of SEAL Data Delivery enabler |  | 68d | 2023-06-08 A | 2023-09-09 A | 100% | finish no earlier than 2023-09-09 | S3 | 544h | 544h | SEALDD | 51 | Ao Lei, Huawei, | leiao@huawei.com | Rel-18 | 100 |
| 1101 | 517 | Low Power High Accuracy Positioning for industrial IoT scenarios |  | 62d | 2021-03-18 A | 2021-06-11 A | 100% | finish no earlier than 2021-06-12 | S1 | 496h | 496h | LPHAP | 46 | Yuan Wang, Huawei | wangyuan5@huawei.com | Rel-18 | 91 |
| 1102 | 518 | Subscriber-aware Northbound API access |  | 13d | 2020-09-01 A | 2020-09-17 A | 100% | finish no earlier than 2020-09-17 | S1 | 104h | 104h | SNA | 45 | Minokuchi, Atsushi, NTT DOCOMO | minokuchi at nttdocomo dot com | Rel-18 | 89 |
| 1103 | 519 | **Application enablement aspects for subscriber-aware northbound API access** |  | 481.5d | 2022-06-02 A | 2023-09-09 A | 100% |  |  | 4723.6h | 4723.6h | SNAAPP | 49 | Suzuki, Yuji, NTT DOCOMO | yuuji.suzuki.rm@nttdocomo.com | Rel-18 | 96 |
| 1104 | 519.1 | Stage 2 of SNAAPP |  | 196.45d | 2022-06-02 A | 2023-03-03 A | 100% | finish no earlier than 2023-03-03 | S6 | 1571.6h | 1571.6h | SNAAPP | 49 | Suzuki, Yuji, NTT DOCOMO | yuuji.suzuki.rm@nttdocomo.com | Rel-18 | 96 |
| 1105 | 519.2 | Study on SNAAPP securitY |  | 138d | 2022-06-02 A | 2022-12-12 A | 100% | finish no earlier than 2022-12-12 | S3 | 1104h | 1104h | FS_SNAAPPY | 49 | Zugenmaier, Alf, NTT DOCOMO, | zugenmai@hm.edu | Rel-18 | 96 |
| 1106 | 519.3 | Security aspects of SNAPP |  | 128d | 2023-03-16 A | 2023-09-09 A | 100% | finish no earlier than 2023-09-09 | S3 | 1024h | 1024h | SNAAPPY | 50 | Zugenmaier, Alf, NTT DOCOMO | zugenmai@hm.edu | Rel-18 | 99 |
| 1107 | 519.4 | CT3 aspects of SNAAPP |  | 128d | 2023-03-16 A | 2023-09-09 A | 100% | finish no earlier than 2023-09-09 | C3 | 1024h | 1024h | SNAAPP | 50 | Eitoku, Haruka, NTT | haruka.eitoku@ntt.com | Rel-18 | 99 |
| 1108 | 520 | **Smart Energy and Infrastructure** |  | 553d | 2020-06-25 A | 2021-12-10 A | 100% |  |  | 3064h | 3064h | SEI | 47 | XIA Xu, China Telecom | xiaxu@chinatelecom.cn | Rel-18 | 92 |
| 1109 | 520.1 | Study on 5G Smart Energy and Infrastructure |  | 252d | 2020-06-25 A | 2021-06-11 A | 100% | finish no earlier than 2021-06-12 | S1 | 2016h | 2016h | FS_5GSEI | 45 | XIA Xu, China Telecom | xiaxu@chinatelecom.cn | Rel-18 | 88 |
| 1110 | 520.2 | Stage 1 of Smart Energy and Infrastructure |  | 131d | 2021-06-11 A | 2021-12-10 A | 100% | finish no earlier than 2021-12-12 | S1 | 1048h | 1048h | SEI | 47 | XIA Xu, China Telecom | xiaxu@chinatelecom.cn | Rel-18 | 92 |
| 1111 | 521 | Study on Network and Service Operations for Energy Utilities |  | 387d | 2021-12-13 A | 2023-06-06 A | 100% | finish no earlier than 2023-06-06 | S5 | 3096h | 3096h | FS_NSOEU | 48 | Erik Guttman , Samsung | erik.guttman@samsung.com | Rel-18 | 94 |
| 1112 | 522 | Study on application enablement aspects for subscriber-aware northbound API access |  | 261d | 2021-06-11 A | 2022-06-10 A | 100% | finish no earlier than 2022-06-12 | S6 | 2088h | 2088h | FS_SNAAPP | 47 | Suzuki, Yuji, NTT DOCOMO | yuuji.suzuki.rm@nttdocomo.com | Rel-18 | 92 |
| 1113 | 523 | **Rel-18 Enhancements of 3GPP Northbound and Application Layer interfaces and APIs** |  | 458d | 2022-06-03 A | 2024-03-03 A | 100% |  |  | 7320h | 7320h | NBI18 | 49 | Abdessamad El Moatamid, Huawei | abdessamad.el.moatamid@huawei.com | Rel-18 | 96 |
| 1114 | 523.1 | CT1 aspects of NBI18 |  | 457d | 2022-06-06 A | 2024-03-03 A | 100% | finish no earlier than 2024-03-03 | C1 | 3656h | 3656h | NBI18 | 49 | Abdessamad El Moatamid, Huawei | abdessamad.el.moatamid@huawei.com | Rel-18 | 96 |
| 1115 | 523.2 | CT3 aspects of NBI18 |  | 458d | 2022-06-03 A | 2024-03-03 A | 100% | finish no earlier than 2024-03-03 | C3 | 3664h | 3664h | NBI18 | 49 | Abdessamad El Moatamid, Huawei | abdessamad.el.moatamid@huawei.com | Rel-18 | 96 |
| 1116 | 524 | Study on Structure of Charging for Verticals |  | 264d | 2022-12-09 A | 2023-12-12 A | 100% | finish no earlier than 2023-12-12 | S5 | 2112h | 2112h | FS_SCV | 50 | CHEN SHAN, Huawei | chenshan@huawei.com | Rel-18 | 98 |
| 1117 | 525 | Charging Aspects of B2B |  | 130d | 2023-09-06 A | 2024-03-03 A | 100% | finish no earlier than 2024-03-03 | S5 | 1040h | 1040h | B2B_CH | 51 | Deng, Yimeng, Huawei | dengyimeng at huawei dot com | Rel-18 | 101 |
| 1118 | 526 | Rel-18 Mission Critical and emergencies | milestone | 0d? | 2016-03-15 A | 2016-03-15 A | 100% | start no earlier than 2016-03-15 |  |  |  |  |  |  |  | Rel-18 |  |
| 1119 | 527 | Mission critical security enhancements phase 3 |  | 322d | 2021-12-10 A | 2023-03-03 A | 100% | finish no earlier than 2023-03-03 | S3 | 2576h | 2576h | MCXSec3 | 48 | Woodward, Tim, Motorola Solutions, Inc. | tim.woodward@motorolasolutions.com | Rel-18 | 94 |

Notes:
- 1095: ; 23/9/22: 23.433 added; / Impacted TSs and TRs: 23.434 ; 23.433
- 1096: 13/12/21: 0%->30; 12/3/22: 30%->45; 22/3/22: 23.700-34 added;; 4/6/22: 45%->60; 4/6/22: FCD:10/06/2022->09/22; 4/6/22: WID:SP-210955->SP-220467; 12/9/22: 60%->85; 11/12/22: 85%->100 / Impacted TSs and TRs: 23.700-34
- 1097: ; 23/9/22: 23.433 added;; 11/12/22: 0%->60; 9/1/23: WID:SP-220914->SP-221232; 17/3/23: 60%->85; 17/3/23: FCD:03/03/2023->/23; 8/6/23: 85%->100 / Impacted TSs and TRs: 23.434 ; 23.433; 23.558
- 1098: 30/6/23: WID:CP-230338->CP-231284 / Impacted TSs and TRs: 24.544; 24.545; 24.546; 24.547; 24.548; 24.549; 24.538; 29.549; 29.538; 29.558
- 1099: 31/3/23: 29.548 added;; 9/6/23: 5%->25 / Impacted TSs and TRs: 24.544; 24.545; 24.546; 24.547; 24.548; 24.549; 24.538; 29.549; 29.538; 29.558; 29.548
- 1100: ; 15/3/24: 0%->100 / Impacted TSs and TRs: 33.434
- 1101: ; 19/3/21: 0%->40; 11/6/21: 40%->100 / Impacted TSs and TRs: 22.104; 22.261
- 1102: Impacted TSs and TRs: 22.261
- 1103: ; 11/12/22: 0%->55 / Impacted TSs and TRs: 23.222; 23.434
- 1104: ; 11/12/22: 0%->55; 17/3/23: 15%->90; 8/6/23: 90%->100 / Impacted TSs and TRs: 23.222; 23.434
- 1105: 13/7/22: 33.884 added;; 12/9/22: 0%->10; 11/12/22: 10%->50; 17/3/23: 50%->60; 8/6/23: 60%->100 / Impacted TSs and TRs: 33.884
- 1106: ; 8/6/23: 0%->50; 8/12/23: 50%->85; 15/3/24: 85%->100 / Impacted TSs and TRs: 33.122
- 1107: Impacted TSs and TRs: 29.222
- 1108: Impacted TSs and TRs: 22.104;22.261
- 1109: 28/7/20: 22.867 added;; 12/9/20: 0%->20; 5/12/20: 20%->60; 19/3/21: FCD:17/03/2021->06/21; 19/3/21: 60%->75; 11/6/21: 75%->90; 13/9/21: 90%->100 / Impacted TSs and TRs: 22.867
- 1110: ; 13/9/21: 0%->95; 10/12/21: 95%->100 / Impacted TSs and TRs: 22.104;22.261
- 1111: 7/1/22: 28.902 added;; 4/6/22: 0%->25; 12/9/22: 25%->45; 12/9/22: FCD:12/12/2022->03/23; 11/12/22: 45%->55; 11/12/22: FCD:10/03/2023->/23; 17/3/23: 55%->79; 8/6/23: 79%->100 / Impacted TSs and TRs: 28.902
- 1112: 2/7/21: 23.700-95 added;; 13/9/21: 0%->20; 13/12/21: 20%->65; 12/3/22: 65%->75; 12/3/22: FCD:11/03/2022->6/22; 12/3/22: WID:SP-210476->SP-220094; 4/6/22: 75%->85; 12/9/22: 85%->90; 11/12/22: 90%->100 / Impacted TSs and TRs: 23.700-95
- 1113: 30/6/23: WID:CP-221105->CP-231190
- 1114: 6/6/23: Compl:25%->40%6/6/23: WID: CP-221105->CP-231190; 9/6/23: 40%->45; 9/6/23: 45%-> / Impacted TSs and TRs: 24.558
- 1115: 6/6/23: Compl:30%->60%6/6/23: WID: CP-221105->CP-231190 / Impacted TSs and TRs: 29.116; 29.122; 29.222; 29.255; 29.257; 29.343; 29.486; 29.522; 29.538; 29.549; 29.558
- 1116: 16/3/23: WID:SP-221161->SP-230178; 17/3/23: 0%->8; 17/3/23: 28.843 added;; 8/6/23: 8%->80; 8/6/23: FCD:06/06/2023->12/23; 7/9/23: 80%->100 / Impacted TSs and TRs: 28.843
- 1117: ; 8/12/23: 0%->80; 14/3/24: 80%->100 / Impacted TSs and TRs: 32.240; 32.290
- 1118: -
- 1119: ; 4/6/22: 0%->10; 12/9/22: 10%->15; 11/12/22: 15%->35; 17/3/23: 35%->75; 8/6/23: 75%->100 / Impacted TSs and TRs: 33.180

| ID | WBS | Task | Type | Duration | Start | Finish | Complete | Constraint | Resources | Work | Actual work | Acronym | PCG approved | WI rapporteur name | WI rapporteur e-mail | Release | TSG approved | TSG stopped |
| --- | --- | --- | --- | --- | --- | --- | --- | --- | --- | --- | --- | --- | --- | --- | --- | --- | --- | --- |
| 1120 | 528 | **Enhanced Mission Critical Push-to-talk architecture phase 4** |  | 843.88d | 2021-12-10 A | 2024-03-03 A | 100% |  |  | 4136h | 4136h | enh4MCPTT | 48 | Harish Negalaguli (Motorola Solutions) | harish.negalaguli@motorolasolutions.com | Rel-18 | 94 |  |
| 1121 | 528.1 | Stage 2 of enh4MCPTT |  | 322d | 2021-12-10 A | 2023-03-03 A | 100% | finish no earlier than 2023-03-03 | S6 | 2576h | 2576h | enh4MCPTT | 48 | Harish Negalaguli (Motorola Solutions) | harish.negalaguli@motorolasolutions.com | Rel-18 | 94 |  |
| 1122 | 528.2 | CT aspects of enh4MCPTT |  | 195d | 2023-06-07 A | 2024-03-03 A | 100% | finish no earlier than 2024-03-03 | C1 | 1560h | 1560h | enh4MCPTT | 51 | Kiran Kapale, Samsung, | kiran.kapale@samsung.com | Rel-18 | 100 |  |
| 1123 | 529 | **Gateway UE function for Mission Critical Communication** |  | 1395.88d | 2020-06-25 A | 2024-03-03 A | 100% |  |  | 6200h | 6200h | MCGWUE | 47 | Oettl, Martin, Nokia | martin.oettl@nokia.com | Rel-18 | 93 |  |
| 1124 | 529.1 | Study of Gateway UE function for Mission Critical Communication |  | 323d | 2020-06-25 A | 2021-09-20 A | 100% | finish no earlier than 2021-09-20 | S6 | 2584h | 2584h | FS_MCGWUE | 45 | Oettl, Martin, Nokia | martin.oettl@nokia.com | Rel-18 | 88 |  |
| 1125 | 529.2 | (Stage 2 of) Gateway UE function for Mission Critical Communication |  | 196d | 2021-09-10 A | 2022-06-10 A | 100% | finish no earlier than 2022-06-12 | S6 | 1568h | 1568h | MCGWUE | 47 | Oettl, Martin, Nokia | martin.oettl@nokia.com | Rel-18 | 93 |  |
| 1126 | 529.3 | CT1 aspects of MCGWUE |  | 256d | 2023-03-13 A | 2024-03-03 A | 100% | finish no earlier than 2024-03-03 | C1 | 2048h | 2048h | MCGWUE | 47 | Magnus Tränk, Ericsson | magnus.trank@ericsson.com | Rel-18 | 93 |  |
| 1127 | 530 | **Mission Critical Services over 5MBS** |  | 1804d | 2019-03-07 A | 2023-12-12 A | 100% |  |  | 8912h | 8912h | MCOver5MBS | 47 | Wendler, Ingo, UIC | ingo.wendler@sbb.ch | Rel-18 | 93 |  |
| 1128 | 530.1 | Stage 2 of Mission Critical Services over 5MBS |  | 1140.12d | 2019-03-07 A | 2022-03-11 A | 100% | finish no earlier than 2022-03-12 | S6 | 6296h | 6296h | MCOver5MBS | 47 | Wendler, Ingo, UIC | ingo.wendler@sbb.ch | Rel-18 | 93 |  |
| 1129 | 530.2 | CT1 aspects of Mission Critical Services over 5MBS |  | 327d | 2022-09-13 A | 2023-12-12 A | 100% | finish no earlier than 2023-12-12 | C1 | 2616h | 2616h | MCOver5MBS | 49 | Chen, Ying, TD Tech Ltd. | chenying@td-tech.com | Rel-18 | 97 |  |
| 1130 | 531 | **Mission Critical Services over 5GProSe** |  | 1804d | 2019-03-07 A | 2023-12-12 A | 100% |  |  | 9960h | 9960h | MCOver5GProSe | 48 | Yanmei YANG, Huawei | yangyanmei@huawei.com | Rel-18 | 94 |  |
| 1131 | 531.1 | Stage 2 of Mission Critical Services over 5GProSe |  | 1331.88d | 2019-03-07 A | 2022-09-12 A | 100% | finish no earlier than 2022-09-12 | S6 | 7344h | 7344h | MCOver5GProSe | 48 | Yanmei YANG, Huawei | yangyanmei@huawei.com | Rel-18 | 94 |  |
| 1132 | 531.2 | CT1 aspects of Mission Critical Services over 5GProSe |  | 327d | 2022-09-13 A | 2023-12-12 A | 100% | finish no earlier than 2023-12-12 | C1 | 2616h | 2616h | MCOver5GProSe | 49 | Mengdi Ji, Huawei | jimengdi@huawei.com, | Rel-18 | 97 |  |
| 1133 | 532 | Stopped - ProSe Secondary Authentication |  | 125d | 2022-09-12 A | 2023-03-03 A | 100% | finish no earlier than 2023-03-03 | S3 | 1000h | 1000h | PROSESA | 49 | Samir Ferdi , Interdigital | samir. ferdi @ interdigital . com | Rel-18 | 97 | 101 |
| 1134 | 533 | Sharing administrative configuration between interconnected MCX Service systems |  | 66d | 2021-09-10 A | 2021-12-10 A | 100% | finish no earlier than 2021-12-12 | S1 | 528h | 528h | SACI_MCS | 47 | Toobe, Jens, BDBOS | jens.toobe@bdbos.bmi.bund.de | Rel-18 | 93 |  |
| 1135 | 534 | Ad hoc Group Communication support in Mission Critical Services |  | 7d | 2021-09-10 A | 2021-09-20 A | 100% | finish no earlier than 2021-09-20 | S1 | 56h | 56h | AHGC | 47 | Erik.Guttman, Samsung | Erik.Guttman@samsung.com | Rel-18 | 93 |  |
| 1136 | 535 | **Mission Critical ad hoc group Communications** |  | 467d | 2022-12-09 A | 2024-03-03 A | 100% |  | S6 | 4624h | 4624h | MC_AHGC | 50 | Kiran Gurudev Kapale, Samsung | kiran.kapale@samsung.com | Rel-18 | 98 |  |
| 1137 | 535.1 | Stage 2 of Mission Critical ad hoc group Communications |  | 128d | 2022-12-09 A | 2023-06-06 A | 100% | finish no earlier than 2023-06-06 | S6 | 1024h | 1024h | MC_AHGC | 50 | Kiran Gurudev Kapale, Samsung | kiran.kapale@samsung.com | Rel-18 | 98 |  |
| 1138 | 535.2 | CT1 aspects of Mission Critical ad hoc group Communications |  | 127d | 2023-09-09 A | 2024-03-03 A | 100% | start no earlier than 2023-09-09 | C1 | 1016h | 1016h | MC_AHGC | 50 | Kiran Gurudev Kapale, Samsung | kiran.kapale@samsung.com | Rel-18 | 98 |  |
| 1139 | 536 | Study on sharing administrative configuration between interconnected MCX Service systems |  | 582d | 2019-09-19 A | 2021-12-10 A | 100% | finish no earlier than 2021-12-12 | S1 | 4656h | 4656h | FS_SACI_MCS | 43 | Toobe, Jens, BDBOS | jens.toobe at bdbos.bmi.bund.de | Rel-18 | 85 |  |
| 1140 | 537 | Study on sharing of administrative configuration between interconnected MC service systems |  | 320d | 2021-12-13 A | 2023-03-03 A | 100% | finish no earlier than 2023-03-03 | S6 | 2560h | 2560h | FS_MCShAC | 48 | Azem, Dania, BDBOS | dania.azem@bdbos.bmi.bund.de | Rel-18 | 94 |  |
| 1141 | 538 | Study on Mission Critical ad hoc group communications |  | 261d | 2021-12-13 A | 2022-12-12 A | 100% | finish no earlier than 2022-12-12 | S6 | 2088h | 2088h | FS_MCAHGC | 48 | Arunprasath Ramamoorthy, Samsung | arun.prasath@samsung.com | Rel-18 | 94 |  |
| 1142 | 539 | Study on Mission Critical services support over 5G System |  | 1048d? | 2018-06-06 A | 2022-06-10 A | 100% | finish no earlier than 2022-06-12 | S6 | 8384h | 8384h | FS_MCOver5GS | 41 | Verweij, Kees, The Police of the Netherlands | kees.verweij@politie.nl | Rel-18 | 80 |  |
| 1143 | 540 | Rel-18 Artificial Intelligence (AI)/Machine Learning (ML) | milestone | 0d? | 2016-03-15 A | 2016-03-15 A | 100% | start no earlier than 2016-03-15 |  |  |  |  |  |  |  | Rel-18 |  |  |

Notes:
- 1120: ; 12/3/22: 0%->10; 4/6/22: 10%->30; 12/9/22: 30%->55; 11/12/22: 55%->65; 17/3/23: 65%->80 / Impacted TSs and TRs: 23.379; 23.280; 23.281; 23.282; 23.283
- 1121: ; 12/3/22: 0%->10; 4/6/22: 10%->30; 12/9/22: 30%->55; 11/12/22: 55%->65; 17/3/23: 65%->80; 8/6/23: 80%->100 / Impacted TSs and TRs: 23.379; 23.280; 23.281; 23.282; 23.283
- 1122: ; 30/6/23: 24.283 added; / Impacted TSs and TRs: 24.281; 24.282; 24.379; 24.380; 24.481; 24.482; 24.483; 24.484; 24.581; 24.582; 29.379; 29.380; 29.582 ; 24.283
- 1123: Impacted TSs and TRs: 23.280; 23.289; 23.281; 23.282; 23.379
- 1124: 13/9/20: 0%->10; 25/9/20: 23.700-79 added;; 5/12/20: 10%->30; 21/3/21: 30%->40; 11/6/21: 40%->60; 13/9/21: 60%->100 / Impacted TSs and TRs: 23.700-79
- 1125: ; 13/12/21: 0%->50; 12/3/22: 50%->75; 4/6/22: 75%->90; 12/9/22: 90%->100 / Impacted TSs and TRs: 23.280; 23.289; 23.281; 23.282; 23.379
- 1126: Impacted TSs and TRs: 24.281.24.282.24.379.24.380.24.483.24.484.24.581.24.582
- 1127: ; 13/12/21: 0%->30; 12/3/22: 30%->50; 12/3/22: FCD:11/03/2022->9/22; 4/6/22: 50%->85 / Impacted TSs and TRs: 23.289
- 1128: ; 13/12/21: 0%->30; 12/3/22: 30%->50; 12/3/22: FCD:11/03/2022->9/22; 4/6/22: 50%->85; 12/9/22: 0%->98; 12/9/22: FCD:10/06/2020->03/22; 11/12/22: 98%->100 / Impacted TSs and TRs: 23.289
- 1129: 6/6/23: Compl:20%->40% / Impacted TSs and TRs: 24.281; 24.282; 24.379; 24.380; 24.481; 24.483; 24.484; 42.581; 24.582
- 1130: ; 12/3/22: 0%->50; 4/6/22: 50%->87 / Impacted TSs and TRs: 23.289
- 1131: ; 12/3/22: 0%->50; 4/6/22: 50%->87; 12/9/22: 0%->100; 12/9/22: FCD:10/06/2020->09/22 / Impacted TSs and TRs: 23.289
- 1132: 3/24: rapporteur changed (was weihaitao@huawei.com) / Impacted TSs and TRs: 24.281; 24.282; 24.379; 24.380; 24.481; 24.483; 24.484; 24.581; 24.582
- 1133: ; 17/3/23: 0%->30; 8/6/23: 30%->90. 9/23: stopped at 90% / Impacted TSs and TRs: 33.503
- 1134: ; 13/9/21: 0%->80; 10/12/21: 80%->100 / Impacted TSs and TRs: 22.280
- 1135: ; 10/12/21: 0%->100 / Impacted TSs and TRs: 22.280
- 1136: ; 11/12/22: 0%->35; 17/3/23: FCD:03/03/2023->/23; 17/3/23: 35%->85; 8/6/23: 85%->100 / Impacted TSs and TRs: 23.280; 23.379; 23.281; 23.282
- 1137: ; 11/12/22: 0%->35; 17/3/23: FCD:03/03/2023->/23; 17/3/23: 35%->85; 8/6/23: 85%->100 / Impacted TSs and TRs: 23.280; 23.379; 23.281; 23.282
- 1138: Impacted TSs and TRs: 24.379, 24.380, 24.281, 24.581, 24.282, 24.582, 24.481, 24.483, 24.484
- 1139: ; 8/10/19: 22.881 added;; 6/12/19: 0%->5; 12/9/20: 5%->20; 19/3/21: 20%->55; 19/3/21: FCD:12/06/2020->12/21; 11/6/21: 55%->90; 13/9/21: 90%->100 / Impacted TSs and TRs: New ; 22.881
- 1140: 7/1/22: 23.700-38 added;; 12/3/22: 0%->5; 4/6/22: 5%->25; 12/9/22: 25%->25; 11/12/22: 25%->65; 17/3/23: 65%->80; 8/6/23: 80%->100 / Impacted TSs and TRs: 23.700-38
- 1141: 7/1/22: 23.700-76 added;; 12/3/22: 0%->25; 4/6/22: 25%->75; 12/9/22: 75%->90; 12/9/22: FCD:12/09/2022->12/22; 11/12/22: 90%->95; 17/3/23: 95%->100 / Impacted TSs and TRs: 23.700-76
- 1142: 6/8/18: 23.783 added;¦10/9/18: 0%->5¦7/12/18: 5%->35¦7/12/18: FCD:03/19->09/19¦14/12/18: WID:SP-180383->SP-181136. 03/19: Rel corrected (was shown as Rel-17); 31/5/19: 35%->40; 26/3/20: FCD:12/09/2019->09/20; 26/3/20: 40%->45; Rel-16->17; 03/22:Rel17-> / Impacted TSs and TRs: New; 23.783
- 1143: -

| ID | WBS | Task | Type | Duration | Start | Finish | Complete | Remaining | Total slack | Constraint | Resources | Work | Actual work | Acronym | PCG approved | Release | TSG approved | Status Report |
| --- | --- | --- | --- | --- | --- | --- | --- | --- | --- | --- | --- | --- | --- | --- | --- | --- | --- | --- |
| 1144 | 541 | **AI/ML model transfer in 5GS** |  | 762.25d | 2019-12-06 A | 2021-12-10 A | 100% |  |  |  |  | 4216h | 4216h | AIML_MT | 47 | Rel-18 | 92 |  |
| 1145 | 541.1 | Study on traffic characteristics and performance requirements for AI/ML model transfer in 5GS |  | 396d | 2019-12-06 A | 2021-06-11 A | 100% |  |  | finish no earlier than 2021-06-12 | S1 | 3168h | 3168h | FS_AIML_MT | 44 | Rel-18 | 86 |  |
| 1146 | 541.2 | Stage 1 of AMMT |  | 131d | 2021-06-11 A | 2021-12-10 A | 100% |  |  | finish no earlier than 2021-12-12 | S1 | 1048h | 1048h | AIML_MT | 47 | Rel-18 | 92 |  |
| 1147 | 542 | Study on Artificial Intelligence (AI)/Machine Learning (ML) for NR air interface |  | 523d | 2021-12-13 A | 2023-12-12 A | 100% |  |  | finish no earlier than 2023-12-12 | R1 | 4184h | 4184h | FS_NR_AIML_air | 48 | Rel-18 | 94 | RP-233132 |
| 1148 | 543 | **Artificial Intelligence (AI)/Machine Learning (ML)** |  | 833.5d | 2021-12-20 A | 2024-03-03 A | 100% |  |  |  |  | 8656h | 8656h | AIMLsys | 50 | Rel-18 | 98 |  |
| 1149 | 543.1 | Study on Security and Privacy of AI/ML-based Services and Applications in 5G |  | 184d | 2022-06-21 A | 2023-03-03 A | 100% |  |  | finish no earlier than 2023-03-03 | S3 | 1472h | 1472h | FS_AIML | 49 | Rel-18 | 96 |  |
| 1150 | 543.2 | Study on 5G System Support for AI/ML-based Services |  | 256d | 2021-12-20 A | 2022-12-12 A | 100% |  |  | finish no earlier than 2022-12-12 | S2 | 2048h | 2048h | FS_AIMLsys | 48 | Rel-18 | 94 |  |
| 1151 | 543.3 | (Stage 2 for AIML) System Support for AI/ML-based Services |  | 128d | 2022-12-09 A | 2023-06-06 A | 100% |  |  | finish no earlier than 2023-06-06 | S2 | 1024h | 1024h | AIMLsys | 50 | Rel-18 | 98 |  |
| 1152 | 543.4 | CT3 aspects of AIML |  | 257d | 2023-03-13 A | 2024-03-03 A | 100% |  |  | finish no earlier than 2024-03-03 | C3 | 2056h | 2056h | AIMLsys | 50 | Rel-18 | 99 |  |
| 1153 | 543.5 | CT4 aspects of AIML |  | 257d | 2023-03-13 A | 2024-03-03 A | 100% |  |  | finish no earlier than 2024-03-03 | C4 | 2056h | 2056h | AIMLsys | 50 | Rel-18 | 99 |  |
| 1154 | 544 | **Artificial Intelligence (AI)/Machine Learning (ML) for NG-RAN** |  | 523d | 2021-12-13 A | 2023-05-01 | 80% | 104.59d | 38817.8d |  |  | 4184h |  | NR_AIML_NGRAN | 48 | Rel-18 | 94 |  |
| 1155 | 544.1 | Core part: Artificial Intelligence (AI)/Machine Learning (ML) for NG-RAN |  | 523d | 2021-12-13 A | 2023-05-01 | 80% | 104.6d | 38817.8d | finish no earlier than 2023-12-12 | R3 | 4184h |  | NR_AIML_NGRAN-Core | 48 | Rel-18 | 94 | RP-232673 |
| 1156 | 545 | Study on the security aspects of Artificial Intelligence (AI)/Machine Learning (ML) for the NG-RAN |  | 197d | 2022-06-02 A | 2023-03-03 A | 100% |  |  | finish no earlier than 2023-03-03 | S3 | 1576h | 1576h | FS_NR_AIML_NGRAN_SEC | 49 | Rel-18 | 96 |  |
| 1157 | 546 | Study on AI/ML management |  | 387d | 2021-12-13 A | 2023-06-06 A | 100% |  |  | finish no earlier than 2023-06-06 | S5 | 3096h | 3096h | FS_AIML_MGMT | 48 | Rel-18 | 94 |  |
| 1158 | 547 | AI/ML management |  | 253d | 2023-03-17 A | 2024-03-03 A | 100% |  |  | finish no earlier than 2024-03-03 | S5 | 2024h | 2024h | AIML_MGT | 50 | Rel-18 | 99 |  |
| 1159 | 548 | NEF Charging enhancement to support AI/ML in 5GS |  | 4d | 2023-12-07 A | 2023-12-12 A | 100% |  |  | finish no earlier than 2023-12-12 | S5 | 32h | 32h | AIMLsysNEF_CH | 52 | Rel-18 | 102 |  |
| 1160 | 549 | Rel-18 Multicast and Broadcast Services (MBS) | milestone | 0d? | 2016-03-15 A | 2016-03-15 A | 100% |  |  | start no earlier than 2016-03-15 |  |  |  |  |  | Rel-18 |  |  |
| 1161 | 550 | **Enhancements of NR Multicast and Broadcast Services** |  | 1596.5d | 2021-12-13 A | 2026-03-03 | 67% | 534.18d | 37744.2d |  |  | 7192h | 4184h | NR_MBS_enh | 48 | Rel-18 | 94 |  |
| 1162 | 550.1 | Core part: Enhancements of NR Multicast and Broadcast Services |  | 523d | 2021-12-13 A | 2023-12-12 A | 100% |  |  | finish no earlier than 2023-12-12 | R2 | 4184h | 4184h | NR_MBS_enh-Core | 48 | Rel-18 | 94 | RP-232992 |
| 1163 | 550.2 | UE Conformance - Enhancements of NR Multicast and Broadcast Services including CT aspects |  | 376d | 2025-03-06 A | 2026-03-03 | 20% | 300.8d | 37744.2d | finish no earlier than 2026-03-03 | R5 | 3008h |  | NR_MBS_enh_5MBS_Ph2-UEConTest | 54 | Rel-18 | 106 | RP-253450 |
| 1164 | 551 | **5G multicast-broadcast services Phase 2** |  | 833.5d | 2021-12-20 A | 2024-03-03 A | 100% |  |  |  |  | 11360h | 11360h | 5MBS_Ph2 | 50 | Rel-18 | 98 |  |
| 1165 | 551.1 | Study on architectural enhancements for 5G multicast-broadcast services Phase 2 |  | 256d | 2021-12-20 A | 2022-12-12 A | 100% |  |  | finish no earlier than 2022-12-12 | S2 | 2048h | 2048h | FS_5MBS_Ph2 | 48 | Rel-18 | 94 |  |
| 1166 | 551.2 | (Stage 2 of 5MBS_Ph2) Architectural enhancements for 5G multicast-broadcast services Phase 2 |  | 128d | 2022-12-09 A | 2023-06-06 A | 100% |  |  | finish no earlier than 2023-06-06 | S2 | 1024h | 1024h | 5MBS_Ph2 | 50 | Rel-18 | 98 |  |
| 1167 | 551.3 | CT1 aspects for 5MBS_Ph2 |  | 257d | 2023-03-13 A | 2024-03-03 A | 100% |  |  | finish no earlier than 2024-03-03 | C1 | 2056h | 2056h | 5MBS_Ph2 | 50 | Rel-18 | 99 |  |
| 1168 | 551.4 | CT3 aspects for 5MBS_Ph2 |  | 257d | 2023-03-13 A | 2024-03-03 A | 100% |  |  | finish no earlier than 2024-03-03 | C3 | 2056h | 2056h | 5MBS_Ph2 | 50 | Rel-18 | 99 |  |
| 1169 | 551.5 | CT4 aspects for 5MBS_Ph2 |  | 257d | 2023-03-13 A | 2024-03-03 A | 100% |  |  | finish no earlier than 2024-03-03 | C4 | 2056h | 2056h | 5MBS_Ph2 | 50 | Rel-18 | 99 |  |
| 1170 | 551.6 | Security Enhancements for 5G Multicast-Broadcast Services Phase 2 |  | 68d | 2023-06-08 A | 2023-09-09 A | 100% |  |  | finish no earlier than 2023-09-09 | S3 | 544h | 544h | 5MBS_Ph2 | 51 | Rel-18 | 100 |  |
| 1171 | 551.7 | Study on security enhancements for 5G multicast-broadcast services Phase 2 |  | 197d | 2022-06-02 A | 2023-03-03 A | 100% |  |  | finish no earlier than 2023-03-03 | S3 | 1576h | 1576h | FS_5MBS_SEC_Ph2 | 49 | Rel-18 | 96 |  |

Notes:
- 1144: Impacted TSs and TRs: 22.261 / WI rapporteur name: Jia SHEN, OPPO, sj@oppo.com
- 1145: 28/7/20: 33.852 added;; 12/9/20: 0%->40; 5/12/20: 40%->70; 19/3/21: FCD:12/03/2021->06/21; 19/3/21: 70%->75; 11/6/21: 75%->95; 13/9/21: 95%->100. 06/22: FS_AMMT->FS_AIML_MT; 21/6/22: WID:SP-191040->SP-220441 / Impacted TSs and TRs: 22.874 / WI rapporteur name: Jia SHEN, Oppo . / WI rapporteur e-mail: sj@oppo.com
- 1146: ; 13/9/21: 0%->80; 11/3/22: 80%->10006/22: AMMT->AIML_MT; 21/6/22: WID:SP-210587->SP-220440 / Impacted TSs and TRs: 22.261 / WI rapporteur name: Jia SHEN, OPPO, sj@oppo.com
- 1147: TR 38.8xx; compare REL-18 WI NR_AIML_NGRAN-Core; 21/1/22: 38.843 added;; 22/3/22: Stat Rep: ->RP-220534 ; 6/6/22: Compl:0%->5% 20/6/22: Acronym:FS_NR_AIML_air->FS_NR_AIML_Air; Rapporteur: Qualcomm->Juan Montojo, Qualcomm; Rap eMail: ->juanm@qti....;...; 18/7/25: WID:RP-250792->RP-251186 / Impacted TSs and TRs: 38.843 / WI rapporteur name: Juan Montojo (RAN1); Mattias Frenne (RAN2); Xiaofeng Liu (RAN4), Qualcomm; Ericsson; CAICT / WI rapporteur e-mail: juanm@qti.qualcomm.com; mattias.frenne@ericsson.com; liuxiaofeng1@caict.ac.cn
- 1148: 10/12/22: 0%->5; 3/1/24: WID:SP-221329->SP-231278 / Impacted TSs and TRs: 23.501; 23.502; 23.503; 23.288 / WI rapporteur name: Alla Goldner, Oppo / WI rapporteur e-mail: v-alla.goldner@oppo.com
- 1149: 13/7/22: 33.898 added;; 12/9/22: 0%->5; 11/12/22: 5%->25; 17/3/23: 25%->35; 7/9/23: 35%->100 / Impacted TSs and TRs: 33.898 / WI rapporteur name: Marcus Wong, OPPO / WI rapporteur e-mail: marcus.wong@oppo.com
- 1150: 21/1/22: 23.700-80 added;; 12/3/22: 0%->10; 12/3/22: WID:SP-211648->SP-220071; 4/6/22: 10%->60; 12/9/22: 60%->70; 10/12/22: 70%->100; 10/12/22: FCD:12/09/2022->12/22 / Impacted TSs and TRs: 23.700-80 / WI rapporteur name: Alla Goldner, Oppo / WI rapporteur e-mail: v-alla.goldner@oppo.com
- 1151: 10/12/22: 0%->5; 15/3/23: WID:SP-221329->SP-230095; 15/3/23: 5%->50; 8/6/23: 50%->100; 3/1/24: WID:SP-230095->SP-231278 / Impacted TSs and TRs: 23.501; 23.502; 23.503; 23.288 / WI rapporteur name: Alla Goldner, Oppo / WI rapporteur e-mail: v-alla.goldner@oppo.com
- 1152: 31/3/23: 29.543 added;6/6/23: Compl:10%->50% / Impacted TSs and TRs: 29.122.29.513.29.514.29.517.29.591.29.519.29.520.29.521.29.522.29.244.29.503.29.504.29.505.29.510; 29.543 / WI rapporteur name: Tangudu, Narendranath Durga, Samsung / WI rapporteur e-mail: n.tangudu@samsung.com
- 1153: 6/6/23: Compl:0%->60% / Impacted TSs and TRs: 29.122.29.513.29.514.29.517.29.591.29.519.29.520.29.521.29.522.29.244.29.503.29.504.29.505.29.510 / WI rapporteur name: Tangudu, Narendranath Durga, Samsung / WI rapporteur e-mail: n.tangudu@samsung.com
- 1154: no Perf. part; compare REL-18 SI FS_NR_AIML_air; 5/4/22: WID:RP-213602->RP-220635; 2/1/24: WID:RP-220635->RP-233441 / WI rapporteur name: CMCC
- 1155: no Perf. part; compare REL-18 SI FS_NR_AIML_air; 20/6/22: FCD:23/06/2023->23/06/2022; WID: RP-220635->RP-213602; Stat Rep: ->RP-221381; Rapporteur: CMCC->Fang Xie, Angelo Centonza, CMCC, Ericsson; Rap eMail: ->xiefang@chinamobile.com, angelo.centonza@e...; 21/9/23: Stat Rep: RP-232235->RP-232673; / WI rapporteur name: Fang Xie, Angelo Centonza, CMCC, Ericsson / WI rapporteur e-mail: xiefang@chinamobile.com, angelo.centonza@ericsson.com
- 1156: 13/7/22: 33.877 added; 17/8/22: WID in SP-220529 marked as withdrawn in SA#96 tdoc list; 12/9/22: 0%->10; 11/12/22: 10%->30; 17/3/23: 30%->70. 030/6/23: "undeleted" as per Mirko+Vlasios email; 7/9/23: 70%->100 / Impacted TSs and TRs: 33.877 / WI rapporteur name: Tsiatsis, Vlasios, Ericsson / WI rapporteur e-mail: vlasios.tsiatsis@ericsson.com
- 1157: 7/1/22: 28.908 added;; 4/6/22: 0%->10; 12/9/22: 10%->55; 12/9/22: FCD:12/09/2022->03/23; 11/12/22: 55%->85; 11/12/22: FCD:10/03/2023->/23; 8/6/23: 85%->; 8/6/23: FCD:03/03/2023->/23; 8/6/23: 85%->100 / Impacted TSs and TRs: 28.908 / WI rapporteur name: Yao, Yizhi, Intel / WI rapporteur e-mail: yizhi<dot>yao<at>intel<dot>com
- 1158: ; 8/6/23: 0%->20; 7/9/23: 20%->35; 14/3/24: 35%->100; 14/3/24: FCD:12/12/2023->/24 / Impacted TSs and TRs: 28.105; 28.552; 32.425; 28.554; 28.541 / WI rapporteur name: Yao, Yizhi, Intel / WI rapporteur e-mail: yizhi<dot>yao<at>intel<dot>com
- 1159: ; 14/3/24: 0%->100; 14/3/24: 100%->100 / Impacted TSs and TRs: 32.254; 32.291 / WI rapporteur name: Alla Goldner, OPPO / WI rapporteur e-mail: v-alla.goldner@oppo.com
- 1160: -
- 1161: no Perf. part; compare REL-17 WI NR_MBS-Core; 12/7/22: WID:RP-213568->RP-221458; 6/10/23: WID:RP-221458->RP-231829; 2/1/24: WID:RP-231829->RP-232993 / WI rapporteur name: CATT
- 1162: no Perf. part; compare REL-17 WI NR_MBS-Core; 22/3/22: Stat Rep: ->RP-220734 ; 6/6/22: CD:12/12/2023->23/12/2022 ; 6/6/22: Stat Rep: RP-220734->RP-221459; 20/6/22: Rapporteur: CATT->Erlin Zeng, CATT; Rap eMail: ->erlin.zeng@catt.cn13/7/22: FCD:23...;...; 8/12/23: Compl:75%->100%; Stat Rep: RP-231830->RP-232992; Rapporteur: Erlin Zeng, CATT->Rui Zhou, CATT; Rap eMail: erlin.zeng@catt.cn->zhourui@catt.cn; / WI rapporteur name: Rui Zhou, CATT / WI rapporteur e-mail: zhourui@catt.cn
- 1163: 6/3/25: Compl:0%->5%; Stat Rep: ->RP-250503; ; 3/4/25: WID:RP-243116->RP-250504; 6/6/25: FCD:Thu 13/11/25->Fri 12/12/25; WID: RP-250504->RP-243116; Stat Rep: RP-250503->RP-251630; ; 11/9/25: Compl:5%->10%; Stat Rep: RP-251630->RP-252723; ; 3/12/25: FCD:Fri 12/12/25->Tue 03/03/26; Compl:10%->20%; Stat Rep: RP-252723->RP-253450; / WI rapporteur name: CATT
- 1164: Impacted TSs and TRs: 23.501; 23.502; 23.247 / WI rapporteur name: Meng Li, Huawei, Huawei / WI rapporteur e-mail: raymond.limeng@huawei.com
- 1165: 21/1/22: 23.700-47 added;; 12/3/22: 0%->15; 12/3/22: WID:SP-211645->SP-220072; 4/6/22: 15%->55; 12/9/22: 55%->75; 12/9/22: FCD:12/09/2022->12/22; 10/12/22: 75%->100 / Impacted TSs and TRs: 23.700-47 / WI rapporteur name: Meng Li, Huawei / WI rapporteur e-mail: raymond.limeng@huawei.com
- 1166: ; 15/3/23: WID:SP-221131->SP-230099; 15/3/23: 0%->75; 8/6/23: 75%->100 / Impacted TSs and TRs: 23.501; 23.502; 23.247 / WI rapporteur name: Meng Li, Huawei, Huawei / WI rapporteur e-mail: raymond.limeng@huawei.com
- 1167: 6/6/23: Compl:0%->65%; 30/6/23: WID:CP-230023->CP-231024. 03/24: rapporteur changed (was giorgi.gulbani@huawei.com) / WI rapporteur name: Rezagah, Roya, Huawei / WI rapporteur e-mail: roya.rezagah@huawei.com
- 1168: ; 9/6/23: 15%->40 / WI rapporteur name: Rezagah, Roya, Huawei / WI rapporteur e-mail: roya.rezagah@huawei.com
- 1169: ; 17/3/23: 5%->206/6/23: Compl:20%->70% / WI rapporteur name: Rezagah, Roya, Huawei / WI rapporteur e-mail: roya.rezagah@huawei.com
- 1170: ; 15/3/24: 0%->100 / Impacted TSs and TRs: 33.501 / WI rapporteur name: Longhua Guo, Huawei Technologies / WI rapporteur e-mail: guolonghua@huawei.com
- 1171: 13/7/22: 33.883 added;; 12/9/22: 0%->12; 11/12/22: 12%->50; 17/3/23: 50%->55; 8/6/23: 55%->100 / Impacted TSs and TRs: 33.883 / WI rapporteur name: Longhua Guo, Huawei Technologies / WI rapporteur e-mail: guolonghua@huawei.com

| ID | WBS | Task | Type | Duration | Start | Finish | Complete | Remaining | Total slack | Constraint | Resources | Work | Actual work | Acronym | PCG approved | WI rapporteur name | Release | TSG approved | WI rapporteur e-mail | Status Report | TSG stopped |
| --- | --- | --- | --- | --- | --- | --- | --- | --- | --- | --- | --- | --- | --- | --- | --- | --- | --- | --- | --- | --- | --- |
| 1172 | 552 | **New bands and bandwidth allocation for 5G terrestrial broadcast - part 2** |  | 1881.12d | 2021-06-15 A | 2026-06-05 | 64% | 676.83d | 37647d |  |  | 9939h | 4680h | LTE_terr_bcast_bands_part2 | 47 | EBU | Rel-18 | 92 |  |  |  |
| 1173 | 552.1 | Core part: New bands and bandwidth allocation for 5G terrestrial broadcast - part 2 |  | 585d | 2021-06-15 A | 2023-09-08 A | 100% |  |  | finish no earlier than 2023-09-08 | R4 | 4680h | 4680h | LTE_terr_bcast_bands_part2-Core | 47 | Gene Fong, Qualcomm Incorporated | Rel-18 | 92 | gfong@qti.qualcomm.com | RP-235288 |  |
| 1174 | 552.2 | UE Conformance - New bands and bandwidth allocation for LTE based 5G terrestrial broadcast |  | 657.38d | 2024-09-09 A | 2026-06-05 | 32% | 447.01d | 37647d | finish no earlier than 2026-06-05 | R5 | 5259h |  | LTE_terr_bcast_bands_part2-UEConTest | 53 | Qualcomm | Rel-18 | 105 |  | RP-253372 |  |
| 1175 | 553 | **UE pre-configuration for 5MBS** |  | 379d | 2023-03-03 A | 2024-03-03 A | 100% |  |  |  |  | 2056h | 2056h | UEConfig5MBS | 47 | Herrero-Veron, Christian(Huawei) | Rel-18 | 92 | Christian.Herrero@huawei.com |  |  |
| 1176 | 553.1 | CT1 aspects of UEConfig5MBS |  | 369.5d | 2023-03-13 A | 2024-03-03 A | 100% |  |  | finish no earlier than 2024-03-03 | C1 | 2056h | 2056h | UEConfig5MBS | 47 | Herrero-Veron, Christian(Huawei) | Rel-18 | 92 | Christian.Herrero@huawei.com |  |  |
| 1177 | 553.2 | CT6 aspects of UEConfig5MBS | milestone | 0d | 2023-03-03 A | 2023-03-03 A | 100% |  |  | finish no earlier than 2023-03-24 | C6 |  |  | UEConfig5MBS | 47 | Herrero-Veron, Christian(Huawei) | Rel-18 | 92 | Christian.Herrero@huawei.com |  |  |
| 1178 | 554 | See also MCOver5MBS under Mission Critical | milestone | 0d? | 2016-03-15 A | 2016-03-15 A | 100% |  |  | start no earlier than 2016-03-15 |  |  |  |  |  |  | Rel-18 |  |  |  |  |
| 1179 | 555 | See also TEI18_MBS4V2X under Autonomous Driving | milestone | 0d? | 2016-03-15 A | 2016-03-15 A | 100% |  |  | start no earlier than 2016-03-15 |  |  |  |  |  |  | Rel-18 |  |  |  |  |
| 1180 | 556 | Rel-18 Slice | milestone | 0d? | 2016-03-15 A | 2016-03-15 A | 100% |  |  | start no earlier than 2016-03-15 |  |  |  |  |  |  | Rel-18 |  |  |  |  |
| 1181 | 557 | Study on 5G NR UE full stack testing for Network Slicing |  | 400d | 2021-03-12 A | 2022-09-22 A | 100% |  |  | finish no earlier than 2022-09-22 | R5 | 3200h | 3200h | FS_NR_Slice_Test | 46 | Dan SONG, Yu SHI, CMCC, CU | Rel-18 | 91 | songdan@chinamobile.com, shiyu19@chinaunicom.cn | RP-221363 |  |
| 1182 | 558 | Study on network slice management capability exposure |  | 580d | 2021-03-18 A | 2023-06-06 A | 100% |  |  | finish no earlier than 2023-06-06 | S5 | 4640h | 4640h | FS_NSCE | 46 | Xiaobo Yu, Alibaba Group | Rel-18 | 91 | shibo.yxb@alibaba-inc.com |  |  |
| 1183 | 559 | **Enhanced Access to and Support of Network Slice** |  | 1395.88d | 2020-06-25 A | 2024-03-03 A | 100% |  |  |  |  | 7216h | 7216h | EASNS | 46 | Chun, SungDuck, LG Electronics Inc. | Rel-18 | 91 | sungduck.chun@lge.com |  |  |
| 1184 | 559.1 | Study on EASNS |  | 190d | 2020-06-25 A | 2021-03-17 A | 100% |  |  | finish no earlier than 2021-03-17 | S1 | 1520h | 1520h | FS_EASNS | 45 | Chun, SungDuck, LG Electronics Inc | Rel-18 | 88 | sungduck.chun@lge.com |  |  |
| 1185 | 559.2 | Stage 1 for EASNS |  | 127d | 2021-03-18 A | 2021-09-10 A | 100% |  |  | finish no earlier than 2021-09-12 | S1 | 1016h | 1016h | EASNS | 46 | Chun, SungDuck, LG Electronics Inc. | Rel-18 | 91 | sungduck.chun@lge.com |  |  |
| 1186 | 559.3 | Stopped – CT1 aspects of Slice-based PLMN Selection |  | 195d | 2023-06-07 A | 2024-03-03 A | 100% |  |  | finish no earlier than 2024-03-03 | C1 | 1560h | 1560h | PLMNsel_NS | 51 | Shuang Liang, ZTE | Rel-18 | 100 | liang.shuang3@zte.com.cn |  | CP-102 |
| 1187 | 559.4 | Stopped – CT4 aspects of Slice-based PLMN Selection |  | 195d | 2023-06-07 A | 2024-03-03 A | 100% |  |  | finish no earlier than 2024-03-03 | C4 | 1560h | 1560h | PLMNsel_NS | 51 | Shuang Liang, ZTE | Rel-18 | 100 | liang.shuang3@zte.com.cn |  | CP-102 |
| 1188 | 559.5 | Stopped – CT6 aspects of Slice-based PLMN Selection |  | 195d | 2023-06-07 A | 2024-03-03 A | 100% |  |  | finish no earlier than 2024-03-03 | C6 | 1560h | 1560h | PLMNsel_NS | 51 | Shuang Liang, ZTE | Rel-18 | 100 | liang.shuang3@zte.com.cn |  | CP-102 |
| 1189 | 560 | **Network Slicing Phase 3** |  | 1883.25d | 2021-12-20 A | 2026-12-12 | 78% | 407.16d | 37450.2d |  |  | 14024h | 10992h | eNS_Ph3 | 50 | ZHU Jinguo, ZTE | Rel-18 | 98 | zhu.jinguo@zte.com.cn |  |  |
| 1190 | 560.1 | Study on Enhancement of Network Slicing Phase 3 |  | 256d | 2021-12-20 A | 2022-12-12 A | 100% |  |  | finish no earlier than 2022-12-12 | S2 | 2048h | 2048h | FS_eNS_Ph3 | 48 | ZHU Jinguo, ZTE | Rel-18 | 94 | zhu.jinguo@zte.com.cn |  |  |
| 1191 | 560.2 | Study on enhanced security for network slicing Phase 3 |  | 197d | 2022-06-02 A | 2023-03-03 A | 100% |  |  | finish no earlier than 2023-03-03 | S3 | 1576h | 1576h | FS_eNS_Ph3 | 49 | Zander Lei, Huawei | Rel-18 | 96 | lei.zhongding@huawei.com |  |  |
| 1192 | 560.3 | Stage 2 of Network Slicing Phase 3 |  | 128d | 2022-12-09 A | 2023-06-06 A | 100% |  |  | finish no earlier than 2023-06-06 | S2 | 1024h | 1024h | eNS_Ph3 | 50 | ZHU Jinguo, ZTE | Rel-18 | 98 | zhu.jinguo@zte.com.cn |  |  |
| 1193 | 560.4 | CT1 aspects of Network Slicing Phase 3 |  | 257d | 2023-03-13 A | 2024-03-03 A | 100% |  |  | finish no earlier than 2024-03-03 | C1 | 2056h | 2056h | eNS_Ph3 | 50 | Hannah Wang, ZTE | Rel-18 | 99 | wang.menghan@zte.com.cn |  |  |
| 1194 | 560.5 | CT3 aspects of Network Slicing Phase 3 |  | 257d | 2023-03-13 A | 2024-03-03 A | 100% |  |  | finish no earlier than 2024-03-03 | C3 | 2056h | 2056h | eNS_Ph3 | 50 | Hannah Wang, ZTE | Rel-18 | 99 | wang.menghan@zte.com.cn |  |  |
| 1195 | 560.6 | CT4 aspects of Network Slicing Phase 3 |  | 257d | 2023-03-13 A | 2024-03-03 A | 100% |  |  | finish no earlier than 2024-03-03 | C4 | 2056h | 2056h | eNS_Ph3 | 50 | Hannah Wang, ZTE | Rel-18 | 99 | wang.menghan@zte.com.cn |  |  |
| 1196 | 560.7 | Network Slice Replacement charging |  | 22d | 2024-02-02 A | 2024-03-03 A | 100% |  |  | finish no earlier than 2024-03-03 | S5 | 176h | 176h | eNS_Ph3_CH | 52 | Maryse Gardella, MATRIXX Software, | Rel-18 | 103 | Maryse dot Gardella at Matrixx dot com) |  |  |
| 1197 | 560.8 | UE Conformance - Network Slicing Phase 3 |  | 379d | 2025-12-12 | 2026-12-12 |  |  | 37450.2d | finish no earlier than 2026-12-12 | R5 | 3032h |  | eNS_Ph3-UEConTest |  | ZTE | Rel-18 |  |  |  |  |

Notes:
- 1172: RAN4 part for WI LTE_terr_bcast_bands_part1-Core; REL--independent starting from REL-17; no Perf. part ; 5/4/22: WID:RP-211145->RP-220518; 23/9/22: WID:RP-220518->RP-222224; 9/1/23: WID:RP-222224->RP-223378
- 1173: RAN4 part for WI LTE_terr_bcast_bands_part1-Core; REL--independent starting from REL-17; no Perf. part ; 13/9/21: CD:Wed 15/03/23->Wed 23/03/22 ; 22/3/22: CD:23/03/2022->12/06/2023; 22/3/22: Stat Rep: RP ; 6/6/22: CD:12/06/2023->23/0 ; 20/6/22: Rappor...; 6/10/23: WID:RP-231216->RP-232590 / Impacted TSs and TRs: 36.792
- 1174: 6/12/24: Compl:0%->5%; Stat Rep: ->RP-242900; ; 6/3/25: FCD:24/07/2025->12/12/2025; Compl:5%->15%; Stat Rep: RP-242900->RP-250398; ; 6/6/25: Stat Rep: RP-250398->RP-251233; ; 11/9/25: Compl:15%->30%; Stat Rep: RP-251233->RP-252051; ; 3/12/25: FCD:Fri 12/12/25->Fri 05/06/26; Compl:30%->32%; Stat Rep: RP-252051->RP-253372;
- 1175: Impacted TSs and TRs: 31.102
- 1176: 6/6/23: Compl:85%->95%6/6/23: CD:24/03/2023->03/03/2024 / Impacted TSs and TRs: 31.102
- 1177: Impacted TSs and TRs: 31.102
- 1178: -
- 1179: -
- 1180: -
- 1181: TR 38.9XX; compare RAN2 REL-17 SI FS_NR_slice; related to REL-15 WI 5GS_Ph1 and REL-16 WI eNS) ; 2/7/21: 0%->10; 13/9/21: Compl:10%->28%; ; 29/9/21: WID:RP-210371->RP-211977; 04/22: Rel-17->Rel-18; 20/6/22: FCD:22/03/2022->22/09/2022; Compl:28%->82%; ...; 23/9/22: 100%->100
- 1182: ; 11/6/21: 0%->5; 11/6/21: FCD:Fri 10/12/->12/21; 13/9/21: 5%->25; 13/12/21: 25%->65; 13/12/21: FCD:Fri 10/12/->03/22; 12/3/22: Rel-17->Rel-18; 22/3/22: WID:SP-210131->SP-220350; 4/6/22: 65%->80; 4/6/22: FCD:11/03/2022->03/23; 12/9/22: 80%->83; 12/9/2...; 8/6/23: 92%->100 / Impacted TSs and TRs: New
- 1183: Impacted TSs and TRs: 22.261
- 1184: 12/9/20: 0%->20; 25/9/20: 22.835 added;; 5/12/20: 20%->60; 19/3/21: 60%->85; 11/6/21: 85%->100 / Impacted TSs and TRs: 22.835
- 1185: ; 11/6/21: 0%->100 / Impacted TSs and TRs: 22.261
- 1186: 8/8/23: acronym changed SbPS to PLMNsel_NS / Impacted TSs and TRs: 23.122; 24.501; 29.503; 29.504; 29.505; 29.509; 29.544; 29.550; 31.102; 31.111
- 1187: stopped / Impacted TSs and TRs: 23.122; 24.501; 29.503; 29.504; 29.505; 29.509; 29.544; 29.550; 31.102; 31.111
- 1188: stopped / Impacted TSs and TRs: 23.122; 24.501; 29.503; 29.504; 29.505; 29.509; 29.544; 29.550; 31.102; 31.111
- 1189: Impacted TSs and TRs: 23.501; 23.502; 23.503
- 1190: 21/1/22: 23.700-41 added;; 21/1/22: 23.700-17 added;; 12/3/22: 0%->5; 12/3/22: WID:SP-211641->SP-220073; 4/6/22: 5%->50; 12/9/22: 50%->70; 12/9/22: FCD:12/09/2022->12/22; 10/12/22: 70%->100 / Impacted TSs and TRs: 23.700-41; 23.700-17
- 1191: 13/7/22: 33.886 added;; 11/12/22: 0%->15; 17/3/23: 15%->50; 8/6/23: 50%->90; 15/3/24: 90%->100 / Impacted TSs and TRs: 33.886
- 1192: ; 15/3/23: WID:SP-221327->SP-230104; 15/3/23: 0%->50; 8/6/23: 50%->100 / Impacted TSs and TRs: 23.501; 23.502; 23.503
- 1193: 6/6/23: Compl:0%->40% / Impacted TSs and TRs: 24.501.29.244.29.502.29.503.29.510.29.531.29.536.29.507.29.512.29.513.29.519.29.522
- 1194: ; 9/6/23: 0%->30 / Impacted TSs and TRs: 24.501.29.244.29.502.29.503.29.510.29.531.29.536.29.507.29.512.29.513.29.519.29.522
- 1195: 6/6/23: Compl:5%->45% / Impacted TSs and TRs: 24.501.29.244.29.502.29.503.29.510.29.531.29.536.29.507.29.512.29.513.29.519.29.522
- 1196: ; 2/4/24: 0%->100 / Impacted TSs and TRs: 32.255; 32.256; 32.291; 32.298

| ID | WBS | Task | Type | Duration | Start | Finish | Complete | Actual finish | Total slack | Constraint | Resources | Work | Actual work | Acronym | PCG approved | WI rapporteur name | Release | TSG approved | WI rapporteur e-mail | Status Report |
| --- | --- | --- | --- | --- | --- | --- | --- | --- | --- | --- | --- | --- | --- | --- | --- | --- | --- | --- | --- | --- |
| 1198 | 561 | **Network Slicing Phase 3: NR aspects** |  | 295.12d | 2023-03-03 A | 2023-12-12 A | 100% |  |  |  | R3 | 3264h | 3264h | eNS_Ph3-NR | 50 | ZTE | Rel-18 | 99 |  |  |
| 1199 | 561.1 | Core part: Network Slicing Phase 3: NR aspects |  | 204d | 2023-03-03 A | 2023-12-12 A | 100% |  |  | finish no earlier than 2023-12-12 | R3 | 1632h | 1632h | eNS_Ph3-NR-Core | 50 | Dapeng Li, ZTE | Rel-18 | 99 | Li.dapeng@zte.com.cn | RP-232866 |
| 1200 | 562 | Network slicing provisioning rules |  | 525d | 2021-12-10 A | 2023-12-12 A | 100% |  |  | finish no earlier than 2023-12-12 | S5 | 4200h | 4200h | NSRULE | 48 | Robert Petersen, Ericsson | Rel-18 | 94 | robert.petersen@ericsson.com |  |
| 1201 | 563 | Study on intent-driven management for network slicing |  | 460d | 2022-03-10 A | 2023-12-12 A | 100% |  |  | finish no earlier than 2023-12-12 | S5 | 3680h | 3680h | FS_NETSLICE_IDMS | 48 | Jan Groenendijk , Ericsson | Rel-18 | 95 | Jan.Groenendijk@ericsson.com |  |
| 1202 | 564 | Intent driven Management Service for Mobile Network phase 2 |  | 195d | 2023-03-16 A | 2023-12-12 A | 100% |  |  | finish no earlier than 2023-12-12 | S5 | 1560h | 1560h | IDMS_MN_ph2 | 50 | Xu Ruiyue, Huawei | Rel-18 | 99 | Xuruiyue@huawei.com |  |
| 1203 | 565 | Study on enhanced security for network slicing Phase 2 |  | 192d | 2021-03-18 A | 2021-12-10 A | 100% |  |  | finish no earlier than 2021-12-12 | S3 | 1536h | 1536h | FS_eNS2_SEC | 46 | Zander Lei, Huawei | Rel-18 | 91 | lei.zhongding@huawei.com |  |
| 1204 | 566 | Study on Media Streaming aspects of Network Slicing Phase 2 |  | 391d | 2022-06-15 A | 2023-12-12 A | 100% |  |  | finish no earlier than 2023-12-12 | S4 | 3128h | 3128h | FS_MS_NS_Ph2 | 49 | Prakash Kolan, samsung | Rel-18 | 96 | p.kolan@samsung.com |  |
| 1205 | 567 | Enhanced security for Phase 2 network slicing |  | 66d | 2021-12-10 A | 2022-03-11 A | 100% |  |  | finish no earlier than 2022-03-11 | S3 | 528h | 528h | eNS2_SEC | 48 | Lei, Zander, Huawei | Rel-18 | 94 | lei.zhongding@huawei.com |  |
| 1206 | 568 | Study on Network Slice Capability Exposure for Application Layer Enablement |  | 388d | 2021-03-18 A | 2022-09-12 A | 100% |  |  | finish no earlier than 2022-09-12 | S6 | 3104h | 3104h | FS_NSCALE | 46 | Zheng, Shaowen, CMCC | Rel-18 | 91 | zhengshaowen@chinamobile.com |  |
| 1207 | 569 | **Network Slice Capability Exposure for Application Layer Enablement** |  | 675.88d | 2022-06-02 A | 2024-03-15 A | 100% |  |  |  |  | 12672h | 12672h | NSCALE | 49 | Zheng, Shaowen, CMCC | Rel-18 | 96 | zhengshaowen@chinamobile.com |  |
| 1208 | 569.1 | (Stage 2 of NSCALE) Network Slice Capability Exposure for Application Layer Enablement |  | 197d | 2022-06-02 A | 2023-03-03 A | 100% |  |  | finish no earlier than 2023-03-03 | S6 | 1576h | 1576h | NSCALE | 49 | Zheng, Shaowen, CMCC | Rel-18 | 96 | zhengshaowen@chinamobile.com |  |
| 1209 | 569.2 | CT1 aspects of NSCALE |  | 459d | 2022-06-02 A | 2024-03-03 A | 100% |  |  | finish no earlier than 2024-03-15 | C1 | 3672h | 3672h | NSCALE | 49 | Huang Zhenning, China Mobile | Rel-18 | 96 | huangzhenning@chinamobile.com |  |
| 1210 | 569.3 | CT3 aspects of NSCALE |  | 459d | 2022-06-02 A | 2024-03-03 A | 100% |  |  | finish no earlier than 2024-03-15 | C3 | 3672h | 3672h | NSCALE | 49 | Huang Zhenning, China Mobile | Rel-18 | 96 | huangzhenning@chinamobile.com |  |
| 1211 | 569.4 | CT4 aspects of NSCALE |  | 469d | 2022-06-02 A | 2024-03-15 A | 100% |  |  | finish no earlier than 2024-03-15 | C4 | 3752h | 3752h | NSCALE | 49 | Huang Zhenning, China Mobile | Rel-18 | 96 | huangzhenning@chinamobile.com |  |
| 1212 | 570 | Study on new UICC application for network slice-specific authentication and authorization (NSSAA) |  | 332d | 2022-06-03 A | 2023-09-09 A | 100% |  |  | finish no earlier than 2023-09-09 | C6 | 2656h | 2656h | FS_NS_Slice-USIM | 49 | COLLET, Hervé, Thales | Rel-18 | 96 | herve.collet@thalesgroup.com |  |
| 1213 | 571 | Study on Charging Aspects for Network Slicing Phase 2 |  | 559d | 2021-01-12 A | 2023-03-03 A | 100% |  |  | finish no earlier than 2023-03-03 | S5 | 4472h | 4472h | FS_NETSLICE_CH_Ph2 | 46 | Matrixx, Gerald Görmer | Rel-18 | 90 | Gerald dot Goermer at Matrixx dot com |  |
| 1214 | 572 | Charging Aspects of Network Slicing Phase 2 |  | 322d | 2022-12-12 A | 2024-03-03 A | 100% |  |  | finish no earlier than 2024-03-03 | S5 | 2576h | 2576h | NETSLICE_CH_Ph2 | 50 | Gerald Görmer, MATRIXX Software | Rel-18 | 98 | Gerald dot Goermer at Matrixx dot com |  |
| 1215 | 573 | Enhancement of Network Slicing UICC application for network slice-specific authentication and authorization |  | 178d | 2023-06-30 A | 2024-03-03 A | 100% |  |  | finish no earlier than 2024-03-03 | C6 | 1424h | 1424h | eNS_UICC | 51 | COLLET, Hervé, Thales | Rel-18 | 100 | herve.collet@thalesgroup.com |  |
| 1216 | 574 | Rel-18 eXtended, Augmented and Virtual Reality (XR, AR, VR), immersive | milestone | 0d? | 2019-03-07 | 2019-03-07 |  |  | 40388.9d |  |  |  |  |  |  |  | Rel-18 |  |  |  |
| 1217 | 575 | **XR (eXtended Reality) enhancements for NR** |  | 1134.62d | 2021-12-13 A | 2024-12-12 | 100% | 2025-12-12 |  |  |  | 10038h | 10038h | NR_XR_enh | 50 | Nokia | Rel-18 | 98 |  |  |
| 1218 | 575.1 | Core part: XR (eXtended Reality) enhancements for NR |  | 262d | 2022-12-13 A | 2023-12-12 A | 100% |  |  | finish no earlier than 2023-12-12 | R2 | 2096h | 2096h | NR_XR_enh-Core | 50 | Benoist S bire, Nokia | Rel-18 | 98 | benoist.sebire@nokia.com | RP-232779 |
| 1219 | 575.2 | Study on XR (eXtended Reality) enhancements for NR |  | 320d | 2021-12-13 A | 2023-03-03 A | 100% |  |  | finish no earlier than 2023-03-03 | R2 | 2560h | 2560h | FS_NR_XR_enh | 48 | Benoist S bire, Nokia | Rel-18 | 94 | benoist.sebire@nokia.com | RP-230276 |
| 1220 | 575.3 | UE Conformance - XR (eXtended Reality) enhancements for NR plus CT1 aspects |  | 672.75d | 2024-03-03 A | 2025-12-12 A | 100% |  |  | finish no earlier than 2025-12-12 | R5 | 5382h | 5382h | NR_XR_enh_plus_CT1-UEConTest | 52 | Nokia | Rel-18 | 103 |  | RP-253514 |
| 1221 | 576 | **Architecture Enhancements for XR (Extended Reality) and media service** |  | 833.5d | 2021-12-20 A | 2024-03-03 A | 100% |  |  |  |  | 9240h | 9240h | XRM | 50 | Dan WANG, China Mobile | Rel-18 | 99 | wangdanyjy@chinamobile.com |  |
| 1222 | 576.1 | Study on architecture enhancement for XR and media services |  | 256d | 2021-12-20 A | 2022-12-12 A | 100% |  |  | finish no earlier than 2022-12-12 | S2 | 2048h | 2048h | FS_XRM | 48 | Dan Wang, China Mobile | Rel-18 | 94 | wangdanyjy@chinamobile.com |  |
| 1223 | 576.2 | (Stage 2 for XRM) Architecture Enhancements for XR (Extended Reality) and media service |  | 128d | 2022-12-09 A | 2023-06-06 A | 100% |  |  | finish no earlier than 2023-06-06 | S2 | 1024h | 1024h | XRM | 50 | Dan WANG, China Mobile | Rel-18 | 98 | wangdanyjy@chinamobile.com |  |
| 1224 | 576.3 | CT1 aspects of XRM |  | 257d | 2023-03-13 A | 2024-03-03 A | 100% |  |  | finish no earlier than 2024-03-03 | C1 | 2056h | 2056h | XRM | 50 | Zhennning Huang, China Mobile | Rel-18 | 99 | huangzhenning@chinamobile.com |  |
| 1225 | 576.4 | CT3 aspects of XRM |  | 257d | 2023-03-13 A | 2024-03-03 A | 100% |  |  | finish no earlier than 2024-03-03 | C3 | 2056h | 2056h | XRM | 50 | Zhennning Huang, China Mobile | Rel-18 | 99 | huangzhenning@chinamobile.com |  |
| 1226 | 576.5 | CT4 aspects of XRM |  | 257d | 2023-03-13 A | 2024-03-03 A | 100% |  |  | finish no earlier than 2024-03-03 | C4 | 2056h | 2056h | XRM | 50 | Zhennning Huang, China Mobile | Rel-18 | 99 | huangzhenning@chinamobile.com |  |
| 1227 | 577 | Study on immersive Real-time Communication for WebRTC Phase 2 |  | 519d | 2022-03-10 A | 2024-03-03 A | 100% |  |  | finish no earlier than 2024-03-03 | S4 | 4152h | 4152h | FS_eiRTCW | 48 | Yoshihiro INOUE, NTT | Rel-18 | 95 | Yoshihiro.inoue@ntt-at.co.jp |  |
| 1228 | 578 | Immersive Real-time Communication for WebRTC |  | 586d | 2022-03-15 A | 2024-06-06 A | 100% |  |  | finish no earlier than 2024-06-06 | S4 | 4688h | 4688h | iRTCW | 48 | Kyunghun Jung, Facebook | Rel-18 | 95 | kyunghun@fb.com |  |
| 1229 | 579 | Study on Smartly Tethering AR Glasses |  | 324d | 2022-03-10 A | 2023-06-06 A | 100% |  |  | finish no earlier than 2023-06-06 | S4 | 2592h | 2592h | FS_SmarTAR | 48 | Thomas Stockhammer, Qualcomm Incorporated | Rel-18 | 95 | tsto@qti.qualcomm.com |  |
| 1230 | 580 | Media Capabilities for Augmented Reality |  | 519d | 2022-03-10 A | 2024-03-03 A | 100% |  |  | finish no earlier than 2024-03-03 | S4 | 4152h | 4152h | MeCAR | 48 | Emmanuel Thomas, Xiaomi | Rel-18 | 95 | thomase@xiaomi.com |  |
| 1231 | 581 | IMS-based AR Conversational Services |  | 528d | 2022-06-03 A | 2024-06-06 A | 100% |  |  | finish no earlier than 2024-06-06 | S4 | 4224h | 4224h | IBACS | 49 | Gunkel, Simon, KPN N.V. | Rel-18 | 96 | Simon.Gunkel@tno.nl |  |
| 1232 | 582 | Generic architecture for RT and AR/MR |  | 263d | 2022-06-03 A | 2023-06-06 A | 100% |  |  | finish no earlier than 2023-06-06 | S4 | 2104h | 2104h | GA4RTAR | 49 | Hakju Ryan Lee, Samsung | Rel-18 | 96 | hakju00.lee@samsung.com |  |
| 1233 | 583 | Real-time Transport Protocol Configurations |  | 458d | 2022-06-03 A | 2024-03-03 A | 100% |  |  | finish no earlier than 2024-03-03 | S4 | 3664h | 3664h | 5G_RTP | 49 | Igor Curcio, Nokia Corporation | Rel-18 | 96 | igor.curcio@nokia.com |  |
| 1234 | 584 | Terminal Audio quality performance and Test methods for Immersive Audio Services |  | 1374.88d | 2019-03-07 A | 2024-06-06 A | 100% |  |  | finish no earlier than 2024-06-06 | S4 | 10999h | 10999h | ATIAS | 42 | Stéphane Ragot, Orange | Rel-18 | 83 | stephane.ragot@orange.com |  |

Notes:
- 1198: 2/1/24: WID:RP-230787->RP-232793
- 1199: ; 7/6/23: Compl:0%->30%; 6/9/23: Compl:30%->70%; WID: RP-230787->RP-231396; Stat Rep: ->RP-231889; Rapporteur: ZTE->Dapeng Li, ZTE; Rap eMail: ->Li.dapeng@zte.com.cn; ; 8/12/23: Compl:70%->100%; Stat Rep: RP-231889->RP-232866;
- 1200: ; 4/6/22: 0%->35; 12/9/22: 35%->45; 12/9/22: FCD:12/09/2022->06/23; 11/12/22: 45%->55; 17/3/23: 55%->60; 8/6/23: 60%->60; 8/6/23: FCD:09/06/2023->12/24; 7/9/23: 60%->70; 7/9/23: FCD:12/12/2024->12/23; 8/12/23: 70%->100 / Impacted TSs and TRs: 28.531; 28.541
- 1201: 5/4/22: 28.836 added;; 11/9/22: FCD:12/09/2022->06/23; 12/9/22: 0%->40; 12/9/22: FCD:12/06/2023->12/22; 11/12/22: 40%->50; 11/12/22: FCD:12/12/2022->/23; 8/6/23: 50%->85; 8/6/23: FCD:06/06/2023->/23; 7/9/23: 85%->85; 7/9/23: FCD:09/09/2023->12/23; 8/12/23: 85%->100 / Impacted TSs and TRs: 28.836
- 1202: ; 8/6/23: 0%->40; 8/6/23: 40%->; 7/9/23: 40%->75; 8/12/23: 75%->100; 4/1/24: 28.914 added; / Impacted TSs and TRs: 28.312 ; 28.914
- 1203: ; 19/3/21: 0%->10; 9/4/21: FCD:11/06/2021->09/21; 11/6/21: 10%->15; 11/6/21: FCD:Wed 08/09/->12/21; 2/7/21: 33.874 added;; 13/9/21: 15%->30; 13/3/22: Rel-17->Rel-18; 4/6/22: 30%->100 / Impacted TSs and TRs: New ; 33.874
- 1204: 3/8/22: 26.941 added; 17/8/22: FS_eNS_Ph3->FS_MS_NS_Ph2; WID:SP-220615->SP-220675; 12/9/22: 0%->15; 11/12/22: 15%->20; 11/12/22: FCD:10/03/2023->/23; 17/3/23: 20%->25; 17/3/23: FCD:06/06/2023->12/23; 8/6/23: 25%->40; 7/9/23: 40%->65; 8/12/23: 65%->100 / Impacted TSs and TRs: 26.941
- 1205: 12/3/22: 0%->70; 13/3/22: Rel-17->Rel-18; 4/6/22: 70%->100 / Impacted TSs and TRs: 33.501;
- 1206: 2/7/21: 23.700-99 added;; 13/9/21: 0%->25; 13/12/21: 25%->55; 13/12/21: FCD:Fri 11/03/->06/22; 13/12/21: WID:SP-210177->SP-211509; 12/3/22: 55%->70; 4/6/22: 70%->85; 12/9/22: 85%->95; 12/9/22: FCD:10/06/2022->09/22; 11/12/22: 95%->100 / Impacted TSs and TRs: 23.700-99
- 1207: ; 13/7/22: 23.435 added;; 12/9/22: 0%->10; 11/12/22: 10%->30; 17/3/23: 30%->70; 8/6/23: 70%->100 / Impacted TSs and TRs: 23.434 ; 23.435
- 1208: ; 13/7/22: 23.435 added;; 12/9/22: 0%->10; 11/12/22: 10%->30; 17/3/23: 30%->70; 8/6/23: 70%->100 / Impacted TSs and TRs: 23.434 ; 23.435
- 1209: Impacted TSs and TRs: 24.549
- 1210: Impacted TSs and TRs: 29.222, 29.520, 29.522, 29.549
- 1211: Impacted TSs and TRs: 29.536
- 1212: 13/7/22: 31.826 added; / Impacted TSs and TRs: 31.826
- 1213: 21/3/21: 0%->15; 13/9/21: 15%->50; 13/9/21: FCD:Fri 10/09/->12/21; 12/3/22: 50%->70; 4/6/22: 70%->75; 4/6/22: FCD:10/12/2021->03/23; 21/6/22: 75%->100. 13/7/22: moved Rel-17->Rel-18, as per Gerald e-mail 21/06/22, 15:03; 12/9/22: 100%->85; 11/12/22: 85...; 17/3/23: 95%->100
- 1214: ; 16/3/23: FCD:09/09/2023->12/20; 16/3/23: WID:SP-221159->SP-230176; 17/3/23: 0%->5; 17/3/23: 28.203 added;; 8/6/23: 5%->40; 7/9/23: 40%->50; 8/12/23: 50%->75; 8/12/23: FCD:12/12/2023->/2024; 3/1/24: WID:SP-230176->SP-231448; 14/3/24: 75%->100 / Impacted TSs and TRs: 32.240; 32.290; 32.291; 32.298; 32.297 ; 28.203
- 1215: 21/9/23: 31.105 added; / Impacted TSs and TRs: 31.105
- 1216: -
- 1217: 29/3/23: WID:RP-223502->RP-230786; 2/1/24: WID:RP-230786->RP-232778
- 1218: 17/3/23: Compl:0%->10%; Stat Rep: ->RP-230277; Rapporteur: Nokia->Benoist S bire, Nokia; Rap eMail: ->benoist.sebire@nokia.com; 31/3/23: WID: RP-230786->RP-223502; Stat Rep: RP-230277->RP-230785; ;...; 6/9/23: Compl:45%->68%; Stat Rep: RP-230785->RP-2...; 8/12/23: Compl:68%->100%; Stat Rep: RP-231606->RP-232779;
- 1219: TR 38.8xx; basic XR functionality introduced in REL-15 WI NR_newRAT; 22/3/22: Stat Rep: ->RP-220511; 5/4/22: WID:RP-213587->RP-220285 6/6 ; 20/6/22: Rapporteur: Nokia->Benoist S bire, Nokia; Rap eMail: ->benoist.sebire@nokia.com13/7/22: 38.835 add...;...; 17/3/23: Compl:80%->100%; Stat Rep: RP-223429->RP-230276; / Impacted TSs and TRs: 38.835
- 1220: 13/6/24: Compl:0%->5%; Stat Rep: ->RP-240936; ; 23/7/24: WID:RP-240088->RP-241588; 4/9/24: FCD:12/12/2025->25/12/2024; Compl:5%->40%; Stat Rep: RP-240936->RP-241790; ; 6/12/24: FCD:12/12/2024->12/12/2025; Compl:40%->60%; Stat Rep: RP-241790->RP-242607; ; ; 7/1/26: WID:RP-241588->RP-253513
- 1221: Impacted TSs and TRs: 23.501; 23.502; 23.503
- 1222: 21/1/22: 23.700-60 added;; 12/3/22: 0%->15; 4/6/22: 15%->40; 4/6/22: FCD:12/09/2022->12/22; 21/6/22: WID:SP-211646->SP-220705; 12/9/22: 40%->75; 10/12/22: 75%->100 / Impacted TSs and TRs: 23.700-60
- 1223: 15/3/23: WID:SP-221326->SP-230092; 15/3/23: 0%->55; 8/6/23: 55%->98; 7/9/23: 98%->100 / Impacted TSs and TRs: 23.501; 23.502; 23.503
- 1224: 6/6/23: Compl:20%->65%6/6/23: WID: CP-230115->CP-231196; 2/4/24: 0%->98 / Impacted TSs and TRs: 29.122.29.508.29.512.29.514.29.522.29.591.29.281.29.244.29.564
- 1225: 6/6/23: Compl:20%->65%6/6/23: WID: CP-230115->CP-231196 / Impacted TSs and TRs: 29.122.29.508.29.512.29.514.29.522.29.591.29.281.29.244.29.564
- 1226: 6/6/23: Compl:0%->65%6/6/23: WID: CP-230115->CP-231196 / Impacted TSs and TRs: 29.122.29.508.29.512.29.514.29.522.29.591.29.281.29.244.29.564
- 1227: 4/6/22: 0%->10; 17/8/22: FS_iRTCW_Ph2->FS_eiRTCW ; 12/9/22: 10%->30; 16/3/23: WID:SP-220239->SP-230166; 16/3/23: FCD:06/06/2023->3/3/24. Rapporteur changed from Naotaka MORITA, NTT .; 17/3/23: 30%->35; 17/3/23: FCD:03/03/2024->/24; 8/6/23: 35%->45; 7/9...; 14/3/24: 70%->100 / Impacted TSs and TRs: 26.930
- 1228: 5/4/22: 26.113 added;; 4/6/22: 0%->5; 12/9/22: 5%->10; 11/12/22: 10%->20; 11/12/22: WID:SP-220241->SP-221032; 17/3/23: 20%->30; 8/6/23: 30%->55; 7/9/23: WID:SP-221032->SP-230977; 7/9/23: FCD:12/12/2023->/24; 8/12/23: 55%->60; 14/3/24: FCD:03/03/2024->/...; 13/6/24: 75%->100 / Impacted TSs and TRs: 26.113
- 1229: ; 5/4/22: 26.806 added;; 4/6/22: 0%->30; 12/9/22: 30%->40; 12/9/22: FCD:10/03/2023->03/23; 11/12/22: 40%->60; 17/3/23: 60%->70; 17/3/23: FCD:03/03/2023->/23; 8/6/23: 70%->100 / Impacted TSs and TRs: 26.998 ; 26.806
- 1230: ; 5/4/22: 26.119 added;; 4/6/22: 0%->8; 12/9/22: 8%->15; 11/12/22: 15%->30; 11/12/22: FCD:10/03/2023->12/23; 17/3/23: 30%->40; 8/6/23: 40%->60; 7/9/23: 60%->65; 7/9/23: FCD:12/12/2023->/24; 8/12/23: 65%->80; 8/12/23: FCD:03/03/2024->/2024; 14/3/24: 80%->100 / Impacted TSs and TRs: 26.511; 26.117; 26.925; 26.XXX ; 26.119
- 1231: 3/8/22: 26.264 added; 17/8/22: IMS4AR->IBACS; 17/8/22: WID:SP-220609->SP-220668; 12/9/22: 0%->5; 11/12/22: 5%->15; 11/12/22: FCD:08/12/2023->12/23; 16/3/23: WID:SP-220668->SP-230165; 17/3/23: 15%->20; 8/6/23: 20%->30; 8/6/23: FCD:12/12/2023->03/20; 8/1...; 13/6/24: 70%->100 / Impacted TSs and TRs: 26.264
- 1232: 17/8/22: GA4RTARMR-> GA4RTAR; 17/8/22: WID:SP-220611->SP-220672; 12/9/22: 0%->25; 11/12/22: 25%->60; 11/12/22: FCD:08/12/2023->03/23; 17/3/23: 60%->70; 17/3/23: FCD:03/03/2023->/23; 8/6/23: 70%->100
- 1233: 3/8/22: 26.522 added; 17/8/22: RTPconfig->5G_RTP; 12/9/22: 0%->3; 11/12/22: 3%->7; 11/12/22: FCD:08/06/2023->/23; 17/3/23: 7%->15; 17/3/23: FCD:06/06/2023->12/23; 8/6/23: 15%->35; 8/6/23: FCD:12/12/2023->03/20; 8/6/23: WID:SP-220613->SP-230541; 7/9/23:...; 14/3/24: 60%->100 / Impacted TSs and TRs: 26.522
- 1234: 31/5/19: 0%->10; 25/3/20: 10%->15; 5/12/20: 15%->20; 5/12/20: FCD:04/12/2020->12/20. 12/21: Rel-17->Rel-18; 4/6/22: 20%->; 11/12/22: 20%->25; 11/12/22: FCD:02/12/2022->12/23; 17/3/23: 25%->30; 8/6/23: 30%->40; 7/9/23: 40%->50; 7/9/23: FCD:12/12/2023->/...; 13/6/24: 70%->100 / Impacted TSs and TRs: 26.260; new

| ID | WBS | Task | Type | Duration | Start | Finish | Complete | Constraint | Resources | Work | Actual work | Acronym | PCG approved | WI rapporteur name | WI rapporteur e-mail | Release | TSG approved |
| --- | --- | --- | --- | --- | --- | --- | --- | --- | --- | --- | --- | --- | --- | --- | --- | --- | --- |
| 1235 | 585 | **EVS Codec Extension for Immersive Voice and Audio Services** |  | 2551.5d? | 2017-09-08 A | 2024-06-06 A | 100% |  |  | 15248h | 15248h | IVAS_Codec | 39 | Bin Wang, Huawei Technologies Co Ltd | binbin.wang@huawei.com | Rel-18 | 77 |
| 1236 | 585.1 | EVS Codec Extension for Immersive Voice and Audio Services |  | 1764d? | 2017-09-08 A | 2024-06-06 A | 100% | finish no earlier than 2024-06-06 | S4 | 14112h | 14112h | IVAS_Codec | 39 | Bin Wang, Huawei Technologies Co Ltd | binbin.wang@huawei.com | Rel-18 | 77 |
| 1237 | 585.2 | CT3 aspects of IVAS_Codec |  | 71d? | 2024-03-03 A | 2024-06-06 A | 100% | finish no earlier than 2024-06-06 | C3 | 568h | 568h | IVAS_Codec | 39 | Landais, Bruno, Nokia | bruno.landais@nokia.com | Rel-18 | 77 |
| 1238 | 585.3 | CT4 aspects of IVAS_Codec |  | 71d? | 2024-03-03 A | 2024-06-06 A | 100% | finish no earlier than 2024-06-06 | C4 | 568h | 568h | IVAS_Codec | 39 | Landais, Bruno, Nokia | bruno.landais@nokia.com | Rel-18 | 77 |
| 1239 | 586 | Immersive Audio for Split Rendering Scenarios |  | 324d | 2023-03-16 A | 2024-06-06 A | 100% | finish no earlier than 2024-06-06 | S4 | 2592h | 2592h | ISAR | 50 | Stefan Bruhn, Dolby Laboratories Inc | stefan.bruhn@dolby.com | Rel-18 | 99 |
| 1240 | 587 | Split Rendering Media Service Enabler |  | 528d | 2022-06-03 A | 2024-06-06 A | 100% | finish no earlier than 2024-06-06 | S4 | 4224h | 4224h | SR_MSE | 49 | Bouazizi, Imed, Qualcomm Incorporated | bouazizi@qti.qualcomm.com | Rel-18 | 96 |
| 1241 | 588 | Study on AR and MR QoE Metrics |  | 458d | 2022-06-03 A | 2024-03-03 A | 100% | finish no earlier than 2024-03-03 | S4 | 3664h | 3664h | FS_ARMRQoE | 49 | Shuai Gao, chinaunicom | gaos30@chinaunicom.cn | Rel-18 | 96 |
| 1242 | 589 | Study on Audio Aspects for Glasses-type AR/MR Devices |  | 135d | 2022-06-03 A | 2022-12-08 A | 100% | finish no earlier than 2022-12-08 | S4 | 1080h | 1080h | FS_Audio_5GSTAR | 49 | Stéphane Ragot, Orange | stephane.ragot@orange.com | Rel-18 | 96 |
| 1243 | 590 | Rel-18 Transportations (Railways, V2X) | milestone | 0d? | 2016-03-15 A | 2016-03-15 A | 100% | start no earlier than 2016-03-15 |  |  |  |  |  |  |  | Rel-18 |  |
| 1244 | 591 | Study on Off-Network for Rail |  | 382d | 2020-06-25 A | 2021-12-10 A | 100% | finish no earlier than 2021-12-12 | S1 | 3056h | 3056h | FS_OffNetRail | 45 | Guillaume Gach | Ext.gach <at> uic.org | Rel-18 | 88 |
| 1245 | 592 | Study of Interconnection and Migration Aspects for Railways |  | 321d | 2020-06-25 A | 2021-09-16 A | 100% | finish no earlier than 2021-09-16 | S6 | 2568h | 2568h | FS_IRail | 45 | Oettl, Martin, Nokia | martin.oettl@nokia.com | Rel-18 | 88 |
| 1246 | 593 | **Interconnection and Migration Aspects for Railways** |  | 673.12d | 2022-03-03 A | 2023-12-12 A | 100% |  |  | 5768h | 5768h | IRail | 48 | Oettl, Martin, Nokia | martin.oettl@nokia.com | Rel-18 | 95 |
| 1247 | 593.1 | Stage 2 of Irail |  | 203d | 2022-03-03 A | 2022-12-12 A | 100% | finish no earlier than 2022-12-12 | S6 | 1624h | 1624h | IRail | 48 | Oettl, Martin, Nokia | martin.oettl@nokia.com | Rel-18 | 95 |
| 1248 | 593.2 | CT1 aspects of eMCSMI_IRail |  | 259d | 2022-12-16 A | 2023-12-12 A | 100% | finish no earlier than 2023-12-12 | C1 | 2072h | 2072h | eMCSMI_IRail | 48 | Won, Sung Hwan, Nokia | sung.won@nokia.com | Rel-18 | 95 |
| 1249 | 593.3 | deleted - CT4 aspects of eMCSMI_IRail |  | 259d | 2022-12-16 A | 2023-12-12 A | 100% | finish no earlier than 2023-12-12 | C4 | 2072h | 2072h | eMCSMI_IRail | 48 | Won, Sung Hwan, Nokia | sung.won@nokia.com | Rel-18 | 95 |
| 1250 | 594 | Study on FRMCS Phase 4 |  | 266d | 2020-12-04 A | 2021-12-10 A | 100% | finish no earlier than 2021-12-12 | S1 | 2128h | 2128h | FS_FRMCS_Ph4 | 46 | Guillaume Gach; UIC | Guillaume Gach; gach <at> uic.org | Rel-18 | 90 |
| 1251 | 595 | Study on enhancements to application layer support for V2X services; Phase 2 |  | 261d | 2021-09-13 A | 2022-09-12 A | 100% | finish no earlier than 2022-09-12 | S6 | 2088h | 2088h | FS_eV2XAPP2 | 47 | Niranth Amogh, Huawei Telecommunications India | namogh@huawei.com | Rel-18 | 93 |
| 1252 | 596 | **Application layer support for V2X services; Phase 3** |  | 561.25d | 2022-09-09 A | 2024-03-03 A | 100% |  |  | 6632h | 6632h | V2XAPP_Ph3 | 49 | Niranth Amogh, Huawei Telecommunications India | namogh@huawei.com | Rel-18 | 97 |
| 1253 | 596.1 | Stage 2 of V2XAPP_Ph3 |  | 193d | 2022-09-09 A | 2023-06-06 A | 100% | finish no earlier than 2023-06-06 | S6 | 1544h | 1544h | V2XAPP_Ph3 | 49 | Niranth Amogh, Huawei Telecommunications India | namogh@huawei.com | Rel-18 | 97 |
| 1254 | 596.2 | CT1 aspects of V2XAPP_Ph3 |  | 318d | 2022-12-16 A | 2024-03-03 A | 100% | finish no earlier than 2024-03-03 | C1 | 2544h | 2544h | V2XAPP_Ph3 | 49 | Herrero Veron, Christian (Huawei) | Christian.Herrero at huawei.com | Rel-18 | 97 |
| 1255 | 596.3 | CT3 aspects of V2XAPP_Ph3 |  | 318d | 2022-12-16 A | 2024-03-03 A | 100% | finish no earlier than 2024-03-03 | C3 | 2544h | 2544h | V2XAPP_Ph3 | 49 | Herrero Veron, Christian (Huawei) | Christian.Herrero at huawei.com | Rel-18 | 97 |
| 1256 | 597 | **MBS support for V2X services** |  | 558d | 2022-09-12 A | 2024-03-03 A | 100% |  |  | 4120h | 4120h | TEI18_MBS4V2X | 49 | LaeYoung Kim (LG Electronics), | laeyoung.kim@lge.com | Rel-18 | 97 |
| 1257 | 597.1 | (Stage 2 of) MBS support for V2X services |  | 125d | 2022-09-12 A | 2023-03-03 A | 100% | finish no earlier than 2023-03-03 | S2 | 1000h | 1000h | TEI18_MBS4V2X | 49 | LaeYoung Kim (LG Electronics), | laeyoung.kim@lge.com | Rel-18 | 97 |
| 1258 | 597.2 | CT1 aspects of MBS support for V2X services |  | 195d | 2023-06-07 A | 2024-03-03 A | 100% | finish no earlier than 2024-03-03 | C1 | 1560h | 1560h | TEI18_MBS4V2X | 51 | Herrero Veron, Christian (Huawei) | Christian.Herrero at huawei.com | Rel-18 | 100 |
| 1259 | 597.3 | CT6 aspects of MBS support for V2X services |  | 195d | 2023-06-07 A | 2024-03-03 A | 100% | finish no earlier than 2024-03-03 | C6 | 1560h | 1560h | TEI18_MBS4V2X | 51 | Herrero Veron, Christian (Huawei) | Christian.Herrero at huawei.com | Rel-18 | 101 |

Notes:
- 1235: 15/12/17: 0%->5¦16/3/18: 5%->10¦7/6/18: 10%->15¦10/9/18: 15%->20¦7/3/19: 20%->25; 31/5/19: 25%->30; 13/9/19: FCD:11/12/2020->06/20; 13/9/19: 30%->26; 6/12/19: 26%->27; 5/12…; 12/21: Rel-17->Rel-18; 4/6/22: 30%->35; 12/9/22: 35%->40; 11/12/22: 40%->45; ...; 8/12/23: 75%->78 / Impacted TSs and TRs: 26.114; new; 26.258; 26.256; 26.255; 26.254; 26.253; 26.251; 26.252; 26.250; 26.997
- 1236: 15/12/17: 0%->5¦16/3/18: 5%->10¦7/6/18: 10%->15¦10/9/18: 15%->20¦7/3/19: 20%->25; 31/5/19: 25%->30; 13/9/19: FCD:11/12/2020->06/20; 13/9/19: 30%->26; 6/12/19: 26%->27; 5/12…; 12/21: Rel-17->Rel-18; 4/6/22: 30%->35; 12/9/22: 35%->40; 11/12/22: 40%->45; ...; 13/6/24: 80%->100 / Impacted TSs and TRs: 26.114; new; 26.258; 26.256; 26.255; 26.254; 26.253; 26.251; 26.252; 26.250; 26.997
- 1237: Impacted TSs and TRs: 23.333, 29.333, 23.334, 29.334, 29.162, 29.238, 29.163, 29.332, 29.292, 29.232, 24.229
- 1238: Impacted TSs and TRs: 23.333, 29.333, 23.334, 29.334, 29.162, 29.238, 29.163, 29.332, 29.292, 29.232, 24.229
- 1239: ; 8/6/23: 0%->10; 8/6/23: 26.566 added;; 8/6/23: 26.866 added;; 8/6/23: 26.865 added;; 7/9/23: 10%->15; 8/12/23: 15%->25; 8/12/23: WID:SP-230167->SP-231291; 14/3/24: 25%->35; 14/3/24: FCD:03/03/2024->/24; 3/4/24: 26.249 added; 26.996 added;; 13/6/24: 35%->100 / Impacted TSs and TRs: 26.119 ; 26.566; 26.866; 26.865; 26.249; 26.996
- 1240: 3/8/22: 26.565 added;; 17/8/22: WID:SP-220612->SP-220685; 12/9/22: 0%->5; 11/12/22: 5%->15; 11/12/22: FCD:08/12/2023->09/23; 17/3/23: 15%->25; 17/3/23: FCD:09/09/2023->12/23; 8/6/23: 25%->40; 8/6/23: FCD:12/12/2023->03/20; 7/9/23: 40%->50; 8/12/23: 50%...; 13/6/24: 85%->100 / Impacted TSs and TRs: 26.565
- 1241: 13/7/22: 26.812 added;; 17/8/22: WID:SP-220616->SP-220708; 12/9/22: 0%->5; 11/12/22: 5%->10; 17/3/23: 10%->15; 8/6/23: 15%->27; 7/9/23: 27%->50; 7/9/23: FCD:12/12/2023->/24; 8/12/23: 50%->65; 14/3/24: 65%->100 / Impacted TSs and TRs: 26.812
- 1242: 17/8/22: FS_ARMRglass->FS_Audio_5GSTAR; 12/9/22: 0%->5; 11/12/22: 5%->100 / Impacted TSs and TRs: 26.998;
- 1243: -
- 1244: 28/7/20: 22.990 added;; 12/9/20: 0%->10; 5/12/20: 10%->30; 19/3/21: FCD:17/03/2021->12/21; 19/3/21: 30%->50; 13/9/21: 50%->90; 10/12/21: 90%->100 / Impacted TSs and TRs: 22.990
- 1245: 13/9/20: 0%->10; 25/9/20: 23.700-90 added;; 21/3/21: 10%->15; 11/6/21: 15%->30; 13/9/21: 30%->60; 13/12/21: 60%->85; 12/3/22: 85%->100 / Impacted TSs and TRs: 23.700-90
- 1246: Impacted TSs and TRs: 23.280; 23.281; 23.282; 23.379
- 1247: ; 4/6/22: 0%->40; 12/9/22: 40%->60; 11/12/22: 60%->75; 17/3/23: 75%->85; 8/6/23: 85%->100 / Impacted TSs and TRs: 23.280; 23.281; 23.282; 23.379
- 1248: 6/6/23: Compl:10%->15% / Impacted TSs and TRs: 24.379; 24.380; 24.282; 24.481; 24.483; 24.484; 24.482; 24.281; 24.581; 24.582; 29.283
- 1249: 2/4/24: deleted at 100% / Impacted TSs and TRs: 24.379; 24.380; 24.282; 24.481; 24.483; 24.484; 24.482; 24.281; 24.581; 24.582; 29.283
- 1250: 22.989 ; 19/3/21: FCD:12/09/2021->12/21; 19/3/21: 0%->20; 13/9/21: 20%->80; 10/12/21: 80%->100; 21/6/22: WID:SP-201038->SP-220436. FS_eFRMCS -> FS_FRMCS_Ph4
- 1251: 13/12/21: 0%->30; 22/3/22: 23.700-64 added;; 4/6/22: 30%->65; 4/6/22: FCD:10/06/2022->09/22; 4/6/22: WID:SP-210956->SP-220466; 12/9/22: 65%->85; 11/12/22: 85%->100 / Impacted TSs and TRs: 23.700-64
- 1252: Impacted TSs and TRs: 23.286; 23.434
- 1253: ; 11/12/22: 0%->45; 9/1/23: WID:SP-220916->SP-221229; 17/3/23: 45%->75; 17/3/23: FCD:03/03/2023->/23; 8/6/23: 75%->100 / Impacted TSs and TRs: 23.286; 23.434
- 1254: 6/6/23: Compl:0%->20%; 30/6/23: WID:CP-223107->CP-231285 / Impacted TSs and TRs: 24.486; 24.544; 24.545; 24.546; 24.547; 24.548; 29.549; 29.486; 24.549; 29.558
- 1255: Impacted TSs and TRs: 24.486; 24.544; 24.545; 24.546; 24.547; 24.548; 29.549; 29.486; 24.549; 29.558
- 1256: ; 22/3/23: 0%->100 / Impacted TSs and TRs: 23.287; 23.501
- 1257: ; 22/3/23: 0%->100 / Impacted TSs and TRs: 23.287; 23.501
- 1258: Impacted TSs and TRs: 24.587; 24.588; 31.102
- 1259: Impacted TSs and TRs: 24.587; 24.588; 31.102

| ID | WBS | Task | Type | Duration | Start | Finish | Complete | Remaining | Total slack | Constraint | Resources | Work | Actual work | Acronym | PCG approved | WI rapporteur name | Release | TSG approved | WI rapporteur e-mail | Status Report |
| --- | --- | --- | --- | --- | --- | --- | --- | --- | --- | --- | --- | --- | --- | --- | --- | --- | --- | --- | --- | --- |
| 1260 | 598 | **Enhanced NR support for high speed train scenario in frequency range 2 (FR2)** |  | 1039.38d | 2022-03-15 A | 2024-12-12 | 71% | 301.06d |  |  |  | 14624h | 7792h | NR_HST_FR2_enh | 48 | Samsung | Rel-18 | 95 |  |  |
| 1261 | 598.1 | Core part: Enhanced NR support for high speed train scenario in frequency range 2 (FR2) |  | 389d | 2022-03-15 A | 2023-09-08 A | 100% |  |  | finish no earlier than 2023-09-22 | R4 | 3112h | 3112h | NR_HST_FR2_enh-Core | 48 | WANG, He (Jackson), Samsung | Rel-18 | 95 | h0809.wang@samsung.com | RP- 241272 |
| 1262 | 598.2 | Perf. part: Enhanced NR support for high speed train scenario in frequency range 2 (FR2) |  | 585d | 2022-03-16 A | 2024-06-06 A | 100% |  |  | finish no earlier than 2024-06-06 | R4 | 4680h | 4680h | NR_HST_FR2_enh-Perf | 48 | WANG, He (Jackson), Samsung | Rel-18 | 95 | h0809.wang@samsung.com | RP- 241272 |
| 1263 | 598.3 | UE Conformance - Enhanced NR support for high speed train scenario in frequency range 2 (FR2) |  | 854d | 2024-03-03 A | 2026-06-05 | 38% | 529.48d | 37647d | finish no earlier than 2026-06-05 | R5 | 6832h |  | NR_HST_FR2_enh-UEConTest | 52 | Samsung | Rel-18 | 103 |  | RP-253316 |
| 1264 | 599 | Rel-18 User Plane traffic and services | milestone | 0d? | 2016-03-15 A | 2016-03-15 A | 100% |  |  | start no earlier than 2016-03-15 |  |  |  |  |  |  | Rel-18 |  |  |  |
| 1265 | 600 | **Evolution of IMS Multimedia Telephony Service** |  | 2357.62d | 2019-09-19 A | 2025-12-12 A | 100% |  |  |  |  | 24393h | 24393h | eMMTEL | 47 | Hu Yue, China Mobile | Rel-18 | 92 | huyueyjy@chinamobile.com |  |
| 1266 | 600.1 | Study on evolution of IMS multimedia telephony service |  | 515d | 2019-09-19 A | 2021-09-08 A | 100% |  |  | finish no earlier than 2021-09-08 | S1 | 4120h | 4120h | FS_MMTELin5G | 43 | Yan Di, China Mobile | Rel-18 | 85 | yandi@chinamobile.com |  |
| 1267 | 600.2 | Stage 1 of Evolution of IMS Multimedia Telephony Service |  | 131d | 2021-06-11 A | 2021-12-10 A | 100% |  |  | finish no earlier than 2021-12-12 | S1 | 1048h | 1048h | eMMTEL | 47 | Hu Yue, China Mobile | Rel-18 | 92 | huyueyjy@chinamobile.com |  |
| 1268 | 600.3 | Study on system architecture for next generation real time communication services |  | 315d | 2021-12-20 A | 2023-03-03 A | 100% |  |  | finish no earlier than 2023-03-03 | S2 | 2520h | 2520h | FS_NG_RTC | 48 | Yi Jiang | Rel-18 | 94 | jiangyi at chinamobile dot com |  |
| 1269 | 600.4 | System architecture for Next Generation Real time Communication services |  | 192d | 2022-09-12 A | 2023-06-06 A | 100% |  |  | finish no earlier than 2023-06-06 | S2 | 1536h | 1536h | NG_RTC | 49 | Yi Jiang, China Mobile | Rel-18 | 97 | jiangyi at chinamobile dot com |  |
| 1270 | 600.5 | CT1 aspects of NG_RTC |  | 257d | 2023-03-13 A | 2024-03-03 A | 100% |  |  | finish no earlier than 2024-03-03 | C1 | 2056h | 2056h | NG_RTC | 49 | Chen Xu, China Mobile | Rel-18 | 97 | chenxu@chinamobile.com |  |
| 1271 | 600.6 | CT3 aspects of NG_RTC |  | 257d | 2023-03-13 A | 2024-03-03 A | 100% |  |  | finish no earlier than 2024-03-03 | C3 | 2056h | 2056h | NG_RTC | 49 | Chen Xu, China Mobile | Rel-18 | 97 | chenxu@chinamobile.com |  |
| 1272 | 600.7 | CT4 aspects of NG_RTC |  | 257d | 2023-03-13 A | 2024-03-03 A | 100% |  |  | finish no earlier than 2024-03-03 | C4 | 2056h | 2056h | NG_RTC | 49 | Chen Xu, China Mobile | Rel-18 | 97 | chenxu@chinamobile.com |  |
| 1273 | 600.8 | CT6 aspects of NG_RTC |  | 257d | 2023-03-13 A | 2024-03-03 A | 100% |  |  | finish no earlier than 2024-03-03 | C6 | 2056h | 2056h | NG_RTC | 49 | Chen Xu, China Mobile | Rel-18 | 97 | chenxu@chinamobile.com |  |
| 1274 | 600.9 | Study on security support for Next Generation Real Time Communication services |  | 264d | 2022-06-02 A | 2023-06-06 A | 100% |  |  | finish no earlier than 2023-06-06 | S3 | 2112h | 2112h | FS_NG_RTC_SEC | 49 | Fei, Li, Huawei | Rel-18 | 96 | Austin.lifei@huawei.com |  |
| 1275 | 600.10 | Security support for Next Generation Real Time Communication services |  | 128d | 2023-03-16 A | 2023-09-09 A | 100% |  |  | finish no earlier than 2023-09-09 | S3 | 1024h | 1024h | NG_RTC_SEC | 50 | Fei, Li, Huawei | Rel-18 | 99 | Austin.lifei@huawei.com |  |
| 1276 | 600.11 | UE Conformance - IMS Data Channel for NG RTC (Real Time Communication) |  | 476.12d | 2024-09-09 A | 2025-12-12 A | 100% |  |  | finish no earlier than 2025-12-12 | R5 | 3809h | 3809h | NG_RTC_IMS_dataCH-UEConTest | 53 | Huawei | Rel-18 | 105 |  | RP-253431 |
| 1277 | 601 | Charging Aspects of IMS Data Channel |  | 194d | 2023-06-08 A | 2024-03-03 A | 100% |  |  | finish no earlier than 2024-03-03 | S5 | 1552h | 1552h | IDC_CH | 51 | Chen, Ai, China Mobile, | Rel-18 | 100 | chenai at chinamobile dot com |  |
| 1278 | 602 | **Access Traffic Steering, Switch and Splitting support in the 5G system architecture; Phase 3** |  | 1589.25d | 2021-12-20 A | 2026-03-03 | 94% | 90.46d | 37744.2d |  |  | 12784h | 9752h | ATSSS_Ph3 | 49 | Apostolis Salkintzis, Lenovo | Rel-18 | 97 | y1026c@lenovo.com |  |
| 1279 | 602.1 | Study on Access Traffic Steering, Switching and Splitting support in the 5G system architecture; Phase 3 |  | 256d | 2021-12-20 A | 2022-12-12 A | 100% |  |  | finish no earlier than 2022-12-12 | S2 | 2048h | 2048h | FS_ATSSS_Ph3 | 48 | Salkintzis, Apostolis, Lenovo, | Rel-18 | 94 | y1026c@lenovo.com |  |
| 1280 | 602.2 | Stage 2 of ATSSS_Ph3 |  | 192d | 2022-09-12 A | 2023-06-06 A | 100% |  |  | finish no earlier than 2023-06-06 | S2 | 1536h | 1536h | ATSSS_Ph3 | 49 | Apostolis Salkintzis, Lenovo | Rel-18 | 97 | y1026c@lenovo.com |  |
| 1281 | 602.3 | CT1 aspects of ATSSS_Ph3 |  | 257d | 2023-03-13 A | 2024-03-03 A | 100% |  |  | finish no earlier than 2024-03-03 | C1 | 2056h | 2056h | ATSSS_Ph3 | 49 | Atarius, Roozbeh, Lenovo | Rel-18 | 97 | ratarius@motorola.com |  |
| 1282 | 602.4 | CT3 aspects of ATSSS_Ph3 |  | 257d | 2023-03-13 A | 2024-03-03 A | 100% |  |  | finish no earlier than 2024-03-03 | C3 | 2056h | 2056h | ATSSS_Ph3 | 49 | Atarius, Roozbeh, Lenovo | Rel-18 | 97 | ratarius@motorola.com |  |
| 1283 | 602.5 | CT4 aspects of ATSSS_Ph3 |  | 257d | 2023-03-13 A | 2024-03-03 A | 100% |  |  | finish no earlier than 2024-03-03 | C4 | 2056h | 2056h | ATSSS_Ph3 | 49 | Atarius, Roozbeh, Lenovo | Rel-18 | 97 | ratarius@motorola.com |  |
| 1284 | 602.6 | UE Conformance - Access Traffic Steering, Switch and Splitting support in the 5G system architecture; Phase 3 |  | 379d | 2025-03-03 A | 2026-03-03 | 76% | 90.96d | 37744.2d | finish no earlier than 2026-03-03 | R5 | 3032h |  | ATSSS_Ph3-UEConTest | 54 | China Telecom | Rel-18 | 107 |  | RP-253383 |
| 1285 | 603 | Study on UPF enhancement for Exposure And SBA |  | 256d | 2021-12-20 A | 2022-12-12 A | 100% |  |  | finish no earlier than 2022-12-12 | S2 | 2048h | 2048h | FS_UPEAS | 48 | Yan Han, China Mobile | Rel-18 | 94 | hanyan@chinamobile.com |  |

Notes:
- 1260: compare REL-17 WI NR_HST_FR2 ; 23/9/22: WID:RP-220985->RP-222272
- 1261: compare REL-17 WI NR_HST_FR2 ; 6/6/22: CD:15/09/2023->23/09/2022 ; 6/6/22: Stat Rep: ->RP-221405; 20/6/22: Rapporteur: Samsung->WANG, He (Jackson), Samsung; Rap eMail: ->h0809.wang@samsung.com13/7/22: FCD:23/09/2022->09/20 ...; 9/12/22: FCD:23/09/202...; 13/6/24: FCD:22/09/2023->08/09/2023; Stat Rep: RP-240367->RP- 241272;
- 1262: 6/6/22: CD:15/03/2024->24/03/2023 6/6/22: Stat Rep: ->RP-221405; 20/6/22: Rapporteur: Samsung->WANG, He (Jackson), Samsung; Rap eMail: ->h0809.wang@samsung.com13/7/22: FCD:24/03/2023->03/20 ; ...; 9/12/22: FCD:24/03/2023->01/03/2024; Stat Rep: RP-...; 13/6/24: Compl:90%->100%; Stat Rep: RP-240367->RP- 241272;
- 1263: 13/6/24: Compl:0%->5%; Stat Rep: ->RP-241278; ; 4/9/24: FCD:12/12/2025->25/12/2024; Compl:5%->36%; Stat Rep: RP-241278->RP-241981; ; 6/12/24: FCD:12/12/2024->12/12/2025; Compl:36%->38%; Stat Rep: RP-241981->RP-242595; ; 6/3/25: FCD:28/05/2025->12/12/2025;; 3/12/25: FCD:Fri 12/12/25->Fri 05/06/26; Stat Rep: RP-252078->RP-253316;
- 1264: -
- 1265: Impacted TSs and TRs: 22.261;22.173
- 1266: ; 8/10/19: 22.873 added;; 6/12/19: 0%->10; 12/9/20: 10%->15; 5/12/20: 15%->40; 19/3/21: 40%->75; 19/3/21: FCD:11/12/2020->09/21; 11/6/21: 75%->95; 13/9/21: 95%->100 / Impacted TSs and TRs: New ; 22.873
- 1267: ; 13/9/21: 0%->100 / Impacted TSs and TRs: 22.261;22.173
- 1268: 21/1/22: 23.700-87 added;; 12/3/22: 0%->20; 5/4/22: WID:SP-211644->SP-220288; 4/6/22: 20%->55; 12/9/22: 55%->79; 12/9/22: FCD:12/09/2022->12/22; 10/12/22: 79%->85; 15/3/23: 85%->100; 16/3/23: FCD:12/12/2022->/23 / Impacted TSs and TRs: 23.700-87
- 1269: ; 15/3/23: WID:SP-220804->SP-230098; 15/3/23: 0%->60; 15/3/23: FCD:03/03/2023->/23; 8/6/23: 60%->100 / Impacted TSs and TRs: 23.228; 23.502
- 1270: ; 31/3/23: 24.186 added;6/6/23: Compl:0%->15% / Impacted TSs and TRs: 24.229.24.275.29.214.29.514.29.165.29.510.29.562.29.228.29.229.29.328.29.329.29.364.29.333.23.333; 24.186
- 1271: Impacted TSs and TRs: 24.229.24.275.29.214.29.514.29.165.29.510.29.562.29.228.29.229.29.328.29.329.29.364.29.333.23.333
- 1272: ; 31/3/23: 29.176 added;; 31/3/23: 29.175 added;6/6/23: Compl:0%->25%; 4/1/24: 29.330 added; / Impacted TSs and TRs: 24.229.24.275.29.214.29.514.29.165.29.510.29.562.29.228.29.229.29.328.29.329.29.364.29.333.23.333; 29.176; 29.175; 29.330
- 1273: ; 31/3/23: 29.176 added;; 31/3/23: 29.175 added;6/6/23: Compl:0%->25%; 4/1/24: 29.330 added; / Impacted TSs and TRs: 24.229.24.275.29.214.29.514.29.165.29.510.29.562.29.228.29.229.29.328.29.329.29.364.29.333.23.333; 29.176; 29.175; 29.330
- 1274: 13/7/22: 33.890 added;; 12/9/22: 0%->40; 11/12/22: 40%->70; 17/3/23: 70%->90; 8/6/23: 90%->100 / Impacted TSs and TRs: 33.890
- 1275: ; 15/3/24: 0%->100 / Impacted TSs and TRs: 33.328
- 1276: 6/12/24: Compl:0%->5%; Stat Rep: ->RP-243093; ; 6/3/25: FCD:24/07/2025->12/12/2025; Compl:5%->21%; Stat Rep: RP-243093->RP-250451; ; 6/6/25: Compl:21%->71%; Stat Rep: RP-250451->RP-251491; ; 11/9/25: Compl:71%->99%; Stat Rep: RP-251491->RP-252648; ; 3/12; 7/1/26: WID:RP-242078->RP-253432
- 1277: ; 8/12/23: 0%->40; 14/3/24: 40%->100 / Impacted TSs and TRs: 32.260; 32.255; 32.291; 32.298
- 1278: ; 9/1/23: WID:SP-220813->SP-221334 / Impacted TSs and TRs: 23.501; 23.502; 23.503
- 1279: 21/1/22: 23.700-53 added;; 12/3/22: 0%->20; 4/6/22: 20%->70; 12/9/22: 70%->80; 12/9/22: FCD:12/09/2022->12/22; 10/12/22: 80%->100 / Impacted TSs and TRs: 23.700-53
- 1280: ; 9/1/23: WID:SP-220813->SP-221334; 15/3/23: 0%->85; 15/3/23: FCD:03/03/2023->/23; 8/6/23: 85%->100 / Impacted TSs and TRs: 23.501; 23.502; 23.503
- 1281: 6/6/23: Compl:0%->50% / Impacted TSs and TRs: 24.193.24.501.24.302.29.512.29.244.29.502.29.518.29.274.29.571.29.510
- 1282: 9/6/23: 0%->60 / Impacted TSs and TRs: 24.193.24.501.24.302.29.512.29.244.29.502.29.518.29.274.29.571.29.510
- 1283: 6/6/23: Compl:5%->50% / Impacted TSs and TRs: 24.193.24.501.24.302.29.512.29.244.29.502.29.518.29.274.29.571.29.510
- 1284: 6/6/25: Compl:0%->5%; Stat Rep: ->RP-250896; ; 11/9/25: Compl:5%->59%; Stat Rep: RP-250896->RP-251997; ; 3/12/25: Compl:59%->76%; Stat Rep: RP-251997->RP-253383;
- 1285: 21/1/22: 23.700-62 added;; 12/3/22: 0%->20; 4/6/22: 20%->60; 4/6/22: FCD:12/09/2022->12/22; 21/6/22: WID:SP-211652->SP-220417; 12/9/22: 60%->80; 10/12/22: 80%->98; 15/3/23: 98%->100 / Impacted TSs and TRs: 23.700-62

| ID | WBS | Task | Type | Duration | Start | Finish | Complete | Constraint | Resources | Work | Actual work | Acronym | PCG approved | WI rapporteur name | WI rapporteur e-mail | Release | TSG approved |
| --- | --- | --- | --- | --- | --- | --- | --- | --- | --- | --- | --- | --- | --- | --- | --- | --- | --- |
| 1286 | 604 | **UPF enhancement for Exposure and SBA** |  | 558d | 2022-09-12 A | 2024-03-03 A | 100% |  |  | 5232h | 5232h | UPEAS | 49 | Yan Han, China Mobile | hanyan@chinamobile.com | Rel-18 | 97 |
| 1287 | 604.1 | Stage 2 of UPEAS |  | 192d | 2022-09-12 A | 2023-06-06 A | 100% | finish no earlier than 2023-06-06 | S2 | 1536h | 1536h | UPEAS | 49 | Yan Han, China Mobile | hanyan@chinamobile.com | Rel-18 | 97 |
| 1288 | 604.2 | CT4 aspects of UPF enhancement for exposure and SBA |  | 231d | 2023-03-13 A | 2024-03-03 A | 100% | finish no earlier than 2024-03-03 | C4 | 1848h | 1848h | UPEAS | 49 | Rong Wang, China Mobile | wangrongyjy@chinamobile.com | Rel-18 | 97 |
| 1289 | 604.3 | CT3 aspects of UPF enhancement for exposure and SBA |  | 231d | 2023-04-18 A | 2024-03-03 A | 100% | finish no earlier than 2024-03-03 | C3 | 1848h | 1848h | UPEAS | 49 | Rong Wang, China Mobile | wangrongyjy@chinamobile.com | Rel-18 | 97 |
| 1290 | 605 | **Tactile and multi-modality communication services** |  | 385.25d | 2020-12-04 A | 2021-12-10 A | 100% |  |  | 1616h | 1616h | TACMM | 47 | Xiaonan Shi, CMCC | shixiaonan@chinamobile.com | Rel-18 | 93 |
| 1291 | 605.1 | Study on TACMM |  | 136d | 2020-12-04 A | 2021-06-11 A | 100% | finish no earlier than 2021-06-12 | S1 | 1088h | 1088h | FS_TACMM | 46 | Shi, Xiaonan, China Mobile | shixiaonan@chinamobile.com | Rel-18 | 90 |
| 1292 | 605.2 | Stage 1 of TACMM |  | 66d | 2021-09-10 A | 2021-12-10 A | 100% | finish no earlier than 2021-12-12 | S1 | 528h | 528h | TACMM | 47 | Xiaonan Shi, CMCC | shixiaonan@chinamobile.com | Rel-18 | 93 |
| 1293 | 606 | Rel-18 Edge computing | milestone | 0d? | 2016-03-15 A | 2016-03-15 A | 100% | start no earlier than 2016-03-15 |  |  |  |  |  |  |  | Rel-18 |  |
| 1294 | 607 | **Architecture for enabling Edge Applications Phase 2** |  | 476.38d | 2022-09-09 A | 2023-12-12 A | 100% |  |  | 5167.84h | 5167.84h | EDGEAPP_Ph2 | 49 | Sapan Shah, Samsung | sapan.shah@samsung.com | Rel-18 | 97 |
| 1295 | 607.1 | (Stage 2 of EDGEAPP_Ph2) Architecture for enabling Edge Applications Phase 2 |  | 125.98d | 2022-09-09 A | 2023-03-03 A | 100% | finish no earlier than 2023-03-03 | S6 | 1007.84h | 1007.84h | EDGEAPP_Ph2 | 49 | Sapan Shah, Samsung | sapan.shah@samsung.com | Rel-18 | 97 |
| 1296 | 607.2 | CT1 aspects of EDGEAPP_Ph2 |  | 260d | 2022-12-15 A | 2023-12-12 A | 100% | finish no earlier than 2023-12-12 | C1 | 2080h | 2080h | EDGEAPP_Ph2 | 49 | Narendranath Durga Tangudu | n.tangudu@samsung.com | Rel-18 | 97 |
| 1297 | 607.3 | CT3 aspects of EDGEAPP_Ph2 |  | 260d | 2022-12-15 A | 2023-12-12 A | 100% | finish no earlier than 2023-12-12 | C3 | 2080h | 2080h | EDGEAPP_Ph2 | 49 | Narendranath Durga Tangudu | n.tangudu@samsung.com | Rel-18 | 97 |
| 1298 | 608 | Edge Application Standards in 3GPP and alignment with External Organizations |  | 400d | 2022-06-02 A | 2023-12-12 A | 100% | finish no earlier than 2023-12-12 | S6 | 3200h | 3200h | EDGEAPP_EXT | 49 | Meghashree Dattatri Kedalagudde, Intel | meghashree.dattatri.kedalagudde@intel.com | Rel-18 | 96 |
| 1299 | 609 | Study on enhanced architecture for enabling Edge Applications |  | 261d | 2021-06-11 A | 2022-06-10 A | 100% | finish no earlier than 2022-06-12 | S6 | 2088h | 2088h | FS_eEDGEAPP | 47 | Gupta, Nishant, Samsung | nishant.gup@samsung.com | Rel-18 | 92 |
| 1300 | 610 | **Edge Computing Phase 2** |  | 931.62d | 2021-12-20 A | 2024-06-06 A | 100% |  |  | 17480h | 17480h | FS_EDGE_Ph2 | 48 | Patrice Hédé, Huawei Technologies | patrice dot hede at huawei dot com | Rel-18 | 95 |
| 1301 | 610.1 | Study on Edge Computing phase 2 |  | 370.75d | 2021-12-20 A | 2022-12-12 A | 100% |  | S2 | 2048h | 2048h | FS_EDGE_Ph2 | 48 | Patrice Hédé, Huawei Technologies | patrice dot hede at huawei dot com | Rel-18 | 95 |
| 1302 | 610.2 | Study on Stage 2 of Edge Computing phase 2 |  | 256d | 2021-12-20 A | 2022-12-12 A | 100% | finish no earlier than 2022-12-12 | S2 | 2048h | 2048h | FS_EDGE_Ph2 | 48 | Patrice Hédé, Huawei Technologies | patrice dot hede at huawei dot com | Rel-18 | 94 |
| 1303 | 610.3 | Study on Security of Edge Computing phase 2 |  | 198d | 2022-03-10 A | 2022-12-12 A | 100% | finish no earlier than 2022-12-12 | S3 | 1584h | 1584h | FS_EDGE_Ph2 | 48 | Bo Zhang, Huawei | zhangbo6@huawei.com | Rel-18 | 95 |
| 1304 | 610.4 | (stage 2 of) Edge Computing Phase 2 |  | 183d | 2022-09-23 A | 2023-06-06 A | 100% | finish no earlier than 2023-06-06 | S2 | 1464h | 1464h | EDGE_Ph2 | 49 | Patrice Hédé, Huawei Technologies | patrice dot hede at huawei dot com | Rel-18 | 97 |
| 1305 | 610.5 | CT1 aspects of EDGE_Ph2 |  | 388d | 2022-12-16 A | 2024-06-06 A | 100% |  | C1 | 3104h | 3104h | EDGE_Ph2 | 49 | Qi Caixia, Huawei | caixia.qi@huawei.com | Rel-18 | 97 |
| 1306 | 610.6 | CT3 aspects of EDGE_Ph2 |  | 388d | 2022-12-16 A | 2024-06-06 A | 100% |  | C3 | 3104h | 3104h | EDGE_Ph2 | 49 | Qi Caixia, Huawei | caixia.qi@huawei.com | Rel-18 | 97 |
| 1307 | 610.7 | CT4 aspects of EDGE_Ph2 |  | 388d | 2022-12-16 A | 2024-06-06 A | 100% |  | C4 | 3104h | 3104h | EDGE_Ph2 | 49 | Qi Caixia, Huawei | caixia.qi@huawei.com | Rel-18 | 97 |
| 1308 | 610.8 | Security Aspects of Support for Edge Computing in 5GC phase 2 |  | 128d | 2023-03-16 A | 2023-09-09 A | 100% | finish no earlier than 2023-09-09 | S3 | 1024h | 1024h | EDGE_Ph2 | 50 | Bo Zhang, Huawei Technologies | zhangbo6@huawei.com | Rel-18 | 99 |
| 1309 | 611 | Rel-18 Non-Public Networks | milestone | 0d? | 2016-03-15 A | 2016-03-15 A | 100% | start no earlier than 2016-03-15 |  |  |  |  |  |  |  | Rel-18 |  |

Notes:
- 1286: ; 10/12/22: 0%->20 / Impacted TSs and TRs: 23.501; 23.502; 23.503
- 1287: ; 10/12/22: 0%->20; 15/3/23: WID:SP-220809->SP-230103; 15/3/23: 20%->75; 15/3/23: FCD:03/03/2023->/23; 8/6/23: 75%->100 / Impacted TSs and TRs: 23.501; 23.502; 23.503
- 1288: 17/3/23: 10%->406/6/23: Compl:40%->70% / Impacted TSs and TRs: 29.510.29.564.29.244.29.571.29.508.29.522.29.512.29.513.29.514.29.565.29.574.29.575.29.552
- 1289: 9/6/23: 0%->90 / Impacted TSs and TRs: 29.510.29.564.29.244.29.571.29.508.29.522.29.512.29.513.29.514.29.565.29.574.29.575.29.552
- 1290: Impacted TSs and TRs: 22.261
- 1291: 10/2/21: 22.847 added;; 19/3/21: 0%->30; 11/6/21: 30%->40; 13/9/21: 40%->85; 14/9/21: WID:SP-201039->SP-210209; 10/12/21: 85%->100 / Impacted TSs and TRs: 22.847
- 1292: ; 10/12/21: 0%->100 / Impacted TSs and TRs: 22.261
- 1293: -
- 1295: ; 12/9/22: 0%->5; 11/12/22: 0%->30; 9/1/23: WID:SP-220917->SP-221231; 17/3/23: 30%->70; 8/6/23: 70%->100 / Impacted TSs and TRs: 23.558; 23.958
- 1296: ; 6/6/23: Compl:5%->40%; 6/6/23: WID: CP-223207->CP-231197 / Impacted TSs and TRs: 24.558; 29.558; 29.222
- 1297: ; 6/6/23: Compl:10%->40%; 6/6/23: WID: CP-223207->CP-231197 / Impacted TSs and TRs: 24.558; 29.558; 29.222
- 1298: 13/7/22: 23.958 added;; 12/9/22: 0%->5; 12/9/22: WID:SP-220468->SP-220912; 17/3/23: 5%->10; 8/6/23: 10%->50; 7/9/23: 50%->65; 13/9/23: FCD:06/06/2023->12/20; 13/9/23: WID:SP-220990->SP-231156; 15/3/24: 65%->98; 13/6/24: 98%->100; 13/6/24: WID:SP-231156->SP-220990 / Impacted TSs and TRs: 23.958
- 1299: 2/7/21: 23.700-98 added;; 13/9/21: 0%->10; 13/12/21: 10%->45; 13/12/21: WID:SP-210479->SP-211510; 13/12/21: FCD:Fri 11/03/->06/22; 12/3/22: 45%->55; 4/6/22: 55%->75; 12/9/22: 75%->90; 11/12/22: 90%->100 / Impacted TSs and TRs: 23.700-98
- 1300: 21/1/22: 23.700-48 added;; 12/3/22: 0%->13; 12/3/22: FCD:12/09/2022->12/22; 12/3/22: WID:SP-211638->SP-220070 / Impacted TSs and TRs: 23.700-48
- 1301: 21/1/22: 23.700-48 added;; 12/3/22: 0%->13; 12/3/22: FCD:12/09/2022->12/22; 12/3/22: WID:SP-211638->SP-220070 / Impacted TSs and TRs: 23.700-48
- 1302: 21/1/22: 23.700-48 added;; 12/3/22: 0%->13; 12/3/22: FCD:12/09/2022->12/22; 12/3/22: WID:SP-211638->SP-220070; 4/6/22: 13%->55; 12/9/22: 55%->83; 10/12/22: 83%->100 / Impacted TSs and TRs: 23.700-48
- 1303: 4/6/22: 0%->30; 13/7/22: 33.739 added;; 12/9/22: 30%->40; 11/12/22: 40%->70; 17/3/23: 70%->80; 8/6/23: 80%->90; 15/3/24: 90%->100 / Impacted TSs and TRs: 33.739
- 1304: ; 10/12/22: 0%->15; 9/1/23: WID:SP-220987->SP-221337; 15/3/23: WID:SP-221337->SP-230112; 15/3/23: 15%->80; 15/3/23: FCD:03/03/2023->/23; 8/6/23: 80%->100 / Impacted TSs and TRs: 23.548; 23.501; 23.502; 23.503
- 1305: 9/6/23: 30%->35 / Impacted TSs and TRs: 29.510; 29.502; 29.503; 29.504; 29.505; 29.571; 29.556; 29.508; 29.512; 29.514; 29.513; 29.522; 29.519
- 1306: 9/6/23: 30%->35 / Impacted TSs and TRs: 29.510; 29.502; 29.503; 29.504; 29.505; 29.571; 29.556; 29.508; 29.512; 29.514; 29.513; 29.522; 29.519
- 1307: ; 6/6/23: Compl:20%->45%; 16/7/24: WID:CP-233026->CP-241027 / Impacted TSs and TRs: 29.510; 29.502; 29.503; 29.504; 29.505; 29.571; 29.556; 29.508; 29.512; 29.514; 29.513; 29.522; 29.519
- 1308: 31/3/23: WID:SP-230152->SP-230366; 7/9/23: 0%->95; 15/3/24: 95%->100 / Impacted TSs and TRs: 33.558; 33.501
- 1309: -

| ID | WBS | Task | Type | Duration | Start | Finish | Complete | Remaining | Total slack | Constraint | Resources | Work | Actual work | Acronym | PCG approved | WI rapporteur name | WI rapporteur e-mail | Release | TSG approved | Status Report |
| --- | --- | --- | --- | --- | --- | --- | --- | --- | --- | --- | --- | --- | --- | --- | --- | --- | --- | --- | --- | --- |
| 1310 | 612 | **5G Networks Providing Access to Localized Services** |  | 370.75d | 2020-09-16 A | 2021-09-08 A | 100% |  |  |  |  | 2056h | 2056h | PALS | 47 | Lola Awoniyi-Oteri, qualcomm | oawoniyi@qti.qualcomm.com | Rel-18 | 92 |  |
| 1311 | 612.1 | Study on PALS |  | 193d | 2020-09-16 A | 2021-06-11 A | 100% |  |  | finish no earlier than 2021-06-11 | S1 | 1544h | 1544h | FS_PALS | 45 | Jack Nasielski | jackn <at> qti.qualcomm.com | Rel-18 | 89 |  |
| 1312 | 612.2 | Stage 1 of PALS |  | 64d | 2021-06-11 A | 2021-09-08 A | 100% |  |  | finish no earlier than 2021-09-08 | S1 | 512h | 512h | PALS | 47 | Lola Awoniyi-Oteri, qualcomm | oawoniyi@qti.qualcomm.com | Rel-18 | 92 |  |
| 1313 | 613 | **Non-Public Networks Phase 2** |  | 1596.5d | 2021-12-13 A | 2026-03-03 | 91% | 149.52d | 37744.2d |  |  | 25317h | 20048h | eNPN_Ph2 | 49 | Hedman, Peter, Ericsson | peter . hedman @ ericsson . com | Rel-18 | 97 |  |
| 1314 | 613.1 | Study on enhanced support of Non-Public Networks phase 2 |  | 256d | 2021-12-20 A | 2022-12-12 A | 100% |  |  | finish no earlier than 2022-12-12 | S2 | 2048h | 2048h | FS_eNPN_Ph2 | 48 | Hedman, Peter, Ericsson | peter . hedman @ ericsson . com | Rel-18 | 94 |  |
| 1315 | 613.2 | Stage 2 of Non-Public Networks Phase 2 |  | 192d | 2022-09-12 A | 2023-06-06 A | 100% |  |  | finish no earlier than 2023-06-06 | S2 | 1536h | 1536h | eNPN_Ph2 | 49 | Hedman, Peter, Ericsson | peter . hedman @ ericsson . com | Rel-18 | 97 |  |
| 1316 | 613.3 | Study on security aspects of enhanced support of Non-Public Networks phase 2 |  | 197d | 2022-06-02 A | 2023-03-03 A | 100% |  |  | finish no earlier than 2023-03-03 | S3 | 1576h | 1576h | FS_eNPN_Ph2_SEC | 49 | Jost, Christine, Ericsson, | (christine.jost@ericsson.com) | Rel-18 | 96 |  |
| 1317 | 613.4 | Security aspects of support of Non-Public Networks phase 2 |  | 128d | 2023-03-16 A | 2023-09-09 A | 100% |  |  | finish no earlier than 2023-09-09 | S3 | 1024h | 1024h | eNPN_Ph2 | 50 | Jost, Christine, Ericsson | christine.jost@ericsson.com | Rel-18 | 99 |  |
| 1318 | 613.5 | CT1 aspects of eNPN_Ph2 |  | 318d | 2022-12-16 A | 2024-03-03 A | 100% |  |  | finish no earlier than 2024-03-03 | C1 | 2544h | 2544h | eNPN_Ph2 | 49 | Sedlacek, Ivo, Ericsson | ivo <dot> sedlacek <at> ericsson <dot> com | Rel-18 | 97 |  |
| 1319 | 613.6 | CT3 aspects of eNPN_Ph2 |  | 319d | 2022-12-15 A | 2024-03-03 A | 100% |  |  | finish no earlier than 2024-03-03 | C3 | 2552h | 2552h | eNPN_Ph2 | 49 | Sedlacek, Ivo, Ericsson | ivo <dot> sedlacek <at> ericsson <dot> com | Rel-18 | 97 |  |
| 1320 | 613.7 | CT4 aspects of eNPN_Ph2 |  | 319d | 2022-12-15 A | 2024-03-03 A | 100% |  |  | finish no earlier than 2024-03-03 | C4 | 2552h | 2552h | eNPN_Ph2 | 49 | Sedlacek, Ivo, Ericsson | ivo <dot> sedlacek <at> ericsson <dot> com | Rel-18 | 97 |  |
| 1321 | 613.8 | Study on Charging Aspects for Enhanced Support of Non-Public Networks |  | 320d | 2021-12-13 A | 2023-03-03 A | 100% |  |  | finish no earlier than 2023-03-03 | S5 | 2560h | 2560h | FS_eNPN_CH | 48 | Chen, Ai, China Mobile | chenai@chinamobile.com | Rel-18 | 94 |  |
| 1322 | 613.9 | Charging Aspects for Enhanced Support of Non-Public Networks |  | 254d | 2023-03-16 A | 2024-03-03 A | 100% |  |  | finish no earlier than 2024-03-03 | S5 | 2032h | 2032h | eNPN_CH | 50 | Chen, Ai, China Mobile | chenai at chinamobile dot com | Rel-18 | 99 |  |
| 1323 | 613.10 | Core part: Non-Public Networks Phase 2: NG-RAN aspects |  | 203d | 2023-03-06 A | 2023-12-12 A | 100% |  |  | finish no earlier than 2023-12-12 | R3 | 1624h | 1624h | eNPN_Ph2-NGRAN-Core | 50 | Shengnan Liu, China Telecom | liushn@chinatelecom.cn | Rel-18 | 99 | RP-233567 |
| 1324 | 613.11 | UE Conformance - Non-Public Networks Phase 2: NG-RAN aspects plus CT1 aspects |  | 658.62d | 2024-06-06 A | 2026-03-03 | 55% | 296.38d | 37744.2d | finish no earlier than 2026-03-03 | R5 | 5269h |  | eNPN_Ph2-NGRAN_plus_CT1-UEConTest | 53 | China Telecom |  | Rel-18 | 104 | RP-253469 |
| 1325 | 614 | Rel-18 AM and UE Policy | milestone | 0d? | 2016-03-15 A | 2016-03-15 A | 100% |  |  | start no earlier than 2016-03-15 |  |  |  |  |  |  |  | Rel-18 |  |  |
| 1326 | 615 | Study on enhancement of 5G UE Policy |  | 256d | 2021-12-20 A | 2022-12-12 A | 100% |  |  | finish no earlier than 2022-12-12 | S2 | 2048h | 2048h | FS_eUEPO | 43 | Changhong Shan, Intel | chang.hong.shan@intel.com | Rel-18 | 84 |  |
| 1327 | 616 | **Enhancement of 5G UE Policy** |  | 659.38d | 2022-09-09 A | 2024-06-06 A | 100% |  |  |  |  | 10856h | 10856h | eUEPO | 49 | Changhong Shan, Intel | chang.hong.shan@intel.com | Rel-18 | 97 |  |
| 1328 | 616.1 | (Stage 2 of) Enhancement of 5G UE Policy |  | 193d | 2022-09-09 A | 2023-06-06 A | 100% |  |  | finish no earlier than 2023-06-06 | S2 | 1544h | 1544h | eUEPO | 49 | Changhong Shan, Intel | chang.hong.shan@intel.com | Rel-18 | 97 |  |
| 1329 | 616.2 | CT1 aspects of eUEPO |  | 388d | 2022-12-16 A | 2024-06-06 A | 100% |  |  |  | C1 | 3104h | 3104h | eUEPO | 49 | Thomas Luetzenkirchen, Intel | thomas.luetzenkirchen@intel.com | Rel-18 | 97 |  |
| 1330 | 616.3 | CT3 aspects of eUEPO |  | 388d | 2022-12-16 A | 2024-06-06 A | 100% |  |  |  | C3 | 3104h | 3104h | eUEPO | 49 | Thomas Luetzenkirchen, Intel | thomas.luetzenkirchen@intel.com | Rel-18 | 97 |  |
| 1331 | 616.4 | CT4 aspects of eUEPO |  | 388d | 2022-12-16 A | 2024-06-06 A | 100% |  |  |  | C4 | 3104h | 3104h | eUEPO | 49 | Thomas Luetzenkirchen, Intel | thomas.luetzenkirchen@intel.com | Rel-18 | 97 |  |
| 1332 | 617 | **Spending Limits for AM and UE Policies in the 5GC** |  | 473.12d | 2022-09-12 A | 2023-12-12 A | 100% |  |  |  |  | 3712h | 3712h | TEI18_SLAMUP | 49 | Baniel, Uriuri dot baniel at oracle dot com | uri dot baniel at oracle dot com | Rel-18 | 97 |  |
| 1333 | 617.1 | Stage 2 of TEI18_SLAMUP |  | 192d | 2022-09-12 A | 2023-06-06 A | 100% |  |  | finish no earlier than 2023-06-06 | S2 | 1536h | 1536h | TEI18_SLAMUP | 49 | Baniel, Uriuri dot baniel at oracle dot com | uri dot baniel at oracle dot com | Rel-18 | 97 |  |
| 1334 | 617.2 | CT3 aspects on TEI18_SLAMUP |  | 136d | 2023-06-07 A | 2023-12-12 A | 100% |  |  | finish no earlier than 2023-12-12 | C3 | 1088h | 1088h | TEI18_SLAMUP | 51 | SUN, Yue, China Telecom | suny20@chinatelecom.cn | Rel-18 | 100 |  |
| 1335 | 617.3 | CT4 aspects on TEI18_SLAMUP |  | 136d | 2023-06-07 A | 2023-12-12 A | 100% |  |  | finish no earlier than 2023-12-12 | C4 | 1088h | 1088h | TEI18_SLAMUP | 52 | SUN, Yue, China Telecom | suny20@chinatelecom.cn | Rel-18 | 102 |  |

Notes:
- 1310: Impacted TSs and TRs: 22.261
- 1311: 5/12/20: 0%->35; 19/3/21: 35%->77; 11/6/21: 77%->95; 13/9/21: 95%->100 / Impacted TSs and TRs: 22.844
- 1312: ; 10/12/21: 0%->100 / Impacted TSs and TRs: 22.261
- 1313: ; 10/12/22: 0%->50 / Impacted TSs and TRs: 23.501; 23.502; 23.402
- 1314: 21/1/22: 23.700-08 added;; 12/3/22: 0%->10; 4/6/22: 10%->50; 4/6/22: FCD:12/09/2022->12/22; 21/6/22: WID:SP-211656->SP-220418; 12/9/22: 50%->75; 12/9/22: FCD:12/12/2022->12/22; 10/12/22: 75%->98; 15/3/23: 98%->100 / Impacted TSs and TRs: 23.700-08
- 1315: ; 10/12/22: 0%->50; 9/1/23: WID:SP-220805->SP-221340; 15/3/23: 50%->90; 15/3/23: WID:SP-221340->SP-230096; 15/3/23: FCD:03/03/2023->/23; 8/6/23: 90%->100 / Impacted TSs and TRs: 23.501; 23.502; 23.402
- 1316: 13/7/22: 33.858 added;; 12/9/22: 0%->10; 11/12/22: 10%->60; 17/3/23: 60%->78; 8/6/23: 78%->99; 15/3/24: 99%->100 / Impacted TSs and TRs: 33.858
- 1317: ; 8/6/23: 0%->65; 7/9/23: 65%->90; 14/3/24: 90%->100 / Impacted TSs and TRs: 33.501
- 1318: ; 6/6/23: Compl:33%->60%; 30/6/23: WID:CP-223104->CP-231286 / Impacted TSs and TRs: 23.122; 24.229; 24.302; 24.501; 24.502; 24.526; 29.507; 29.512; 29.513; 29.525; 23.003; 29.518; 29.503; 29.550
- 1319: ; 9/6/23: 30%->60 / Impacted TSs and TRs: 23.122; 24.229; 24.302; 24.501; 24.502; 24.526; 29.507; 29.512; 29.513; 29.525; 23.003; 29.518; 29.503; 29.550
- 1320: ; 6/6/23: Compl:50%->65% / Impacted TSs and TRs: 23.122; 24.229; 24.302; 24.501; 24.502; 24.526; 29.507; 29.512; 29.513; 29.525; 23.003; 29.518; 29.503; 29.550
- 1321: 7/1/22: 28.828 added;; 12/9/22: 0%->60; 11/12/22: 60%->75; 17/3/23: 75%->100 / Impacted TSs and TRs: 28.828
- 1322: ; 8/6/23: 0%->10; 7/9/23: 10%->30; 8/12/23: 30%->65; 14/3/24: 65%->100 / Impacted TSs and TRs: 32.255; 32.256; 28.203; 32.291; 32.298
- 1323: ; 7/6/23: Compl:0%->97%; 6/9/23: FCD:09/09/2023->22/09/2023; Compl:97%->100%; WID: RP-230788->RP-231185; Stat Rep: ->RP-232261; Rapporteur: China Telecom->Shengnan Liu, China Telecom; Rap eMail: ->liushn@chinatelecom.cn; ; 21/9/23: FCD:22/09/2023->12/1...; 2/1/24: WID:RP-231185->RP-233569
- 1324: 6/12/24: Compl:0%->5%; Stat Rep: ->RP-242870; ; 6/3/25: FCD:24/06/2025->12/12/2025; Compl:5%->17%; Stat Rep: RP-242870->RP-250379; ; 6/6/25: Compl:17%->32%; Stat Rep: RP-250379->RP-251463; ; 11/9/25: Compl:32%->50%; Stat Rep: RP-251463->RP-252549; ; 3/12/25: FCD:Fri 12/12/25->Tue 03/03/26; Compl:50%->55%; Stat Rep: RP-252549->RP-253469;
- 1325: -
- 1326: 26/6/19: 23.760 added; 21/01/22: moved Rel-17 to Rel-18 at SA#94e. Deletion of 940072, temporarily mistakenly added as FS_eUEPO_Ph2; WID:SP-190449->SP-211649; 12/3/22: 0%->25; 4/6/22: 25%->70; 4/6/22: FCD:12/09/2022->12/22; 12/9/22: 70%->80; 10/12/22: ...; 15/3/23: 95%->100 / Impacted TSs and TRs: New ; 23.760
- 1327: Impacted TSs and TRs: 23.501; 23.502; 23.503
- 1328: ; 9/1/23: WID:SP-220980->SP-221342; 15/3/23: 0%->65; 15/3/23: WID:SP-221342->SP-230094; 15/3/23: FCD:03/03/2023->/23; 8/6/23: 65%->100 / Impacted TSs and TRs: 23.501; 23.502; 23.503
- 1329: ; 6/6/23: Compl:10%->30%; 6/6/23: WID: CP-230276->CP-231192; 23/7/24: WID:CP-240080->CP-241076 / Impacted TSs and TRs: 24.008.24.301.24.501.24.526.29.512.29.513.29.519.29.520.29.522.29.525.29.244.29.564
- 1330: ; 6/6/23: Compl:10%->40%; 6/6/23: WID: CP-230276->CP-231192 / Impacted TSs and TRs: 24.008.24.301.24.501.24.526.29.512.29.513.29.519.29.520.29.522.29.525.29.244.29.564
- 1331: ; 6/6/23: Compl:10%->30%; 6/6/23: WID: CP-230276->CP-231192 / Impacted TSs and TRs: 24.008.24.301.24.501.24.526.29.512.29.513.29.519.29.520.29.522.29.525.29.244.29.564
- 1332: ; 22/3/23: 0%->80; 22/3/23: FCD:12/12/2022->06/20 / Impacted TSs and TRs: 23.503; 23.501; 23.502
- 1333: ; 22/3/23: 0%->80; 22/3/23: FCD:12/12/2022->06/20; 8/6/23: 80%->100 / Impacted TSs and TRs: 23.503; 23.501; 23.502
- 1334: Impacted TSs and TRs: 29.513; 29.519; 29.594
- 1335: Impacted TSs and TRs: 29.513; 29.519; 29.594

| ID | WBS | Task | Type | Duration | Start | Finish | Complete | Actual finish | Constraint | Resources | Work | Actual work | Acronym | PCG approved | Impacted TSs and TRs | WI rapporteur name | WI rapporteur e-mail | Release | TSG approved |
| --- | --- | --- | --- | --- | --- | --- | --- | --- | --- | --- | --- | --- | --- | --- | --- | --- | --- | --- | --- |
| 1336 | 618 | **Rel-18 Enhancements of UE Policy** |  | 1247d | 2019-03-07 A | 2023-12-13 | 100% | 2023-12-12 |  |  | 19920h | 19920h | UEP18 | 49 | 29.525; 29.507; 29.513; 29.518 | Fuencisla García, Ericsson | fuencisla.garcia@ericsson.com | Rel-18 | 97 |
| 1337 | 618.1 | CT3 aspects of UEP18 |  | 1246d | 2019-03-07 A | 2023-12-12 A | 100% |  | finish no earlier than 2023-12-12 | C3 | 9968h | 9968h | UEP18 | 49 | 29.525; 29.507; 29.513 | Fuencisla García, Ericsson | fuencisla.garcia@ericsson.com | Rel-18 | 97 |
| 1338 | 618.2 | CT4 aspects of UEP18 |  | 1244d | 2019-03-11 A | 2023-12-12 A | 100% |  | finish no earlier than 2023-12-12 | C4 | 9952h | 9952h | UEP18 | 49 | 29.518 | Fuencisla García, Ericsson | fuencisla.garcia@ericsson.com | Rel-18 | 97 |
| 1339 | 619 | **5G AM Policy** |  | 1887.88d | 2019-03-07 A | 2024-03-03 A | 100% |  |  |  | 5640h | 5640h | AMP | 49 | 23.501; 23.502; 23.503 | Chen, Zhuoyi, China Telecom | chenzy34@chinatelecom.cn | Rel-18 | 97 |
| 1340 | 619.1 | Study on 5G AM Policy |  | 191d | 2021-12-20 A | 2022-09-12 A | 100% |  | finish no earlier than 2022-09-12 | S2 | 1528h | 1528h | FS_AMP | 48 | 23.700-89 | Chen, Zhuoyi, China Telecom | chenzy34@chinatelecom.cn | Rel-18 | 94 |
| 1341 | 619.2 | Stage 2 of 5G AM Policy | milestone | 0d | 2019-03-07 A | 2019-03-07 A | 100% |  | finish no earlier than 2023-03-03 | S2 |  |  | AMP | 49 | 23.501; 23.502; 23.503 | Chen, Zhuoyi, China Telecom | chenzy34@chinatelecom.cn | Rel-18 | 97 |
| 1342 | 619.3 | CT3 aspects of 5G AM Policy |  | 257d | 2023-03-13 A | 2024-03-03 A | 100% |  | finish no earlier than 2024-03-03 | C3 | 2056h | 2056h | AMP | 49 | 29.507; 29.513; 29.274 | SUN, Yue, China Telecom | suny20@chinatelecom.cn | Rel-18 | 97 |
| 1343 | 619.4 | CT4 aspects of 5G AM Policy |  | 257d | 2023-03-13 A | 2024-03-03 A | 100% |  | finish no earlier than 2024-03-03 | C4 | 2056h | 2056h | AMP | 49 | 29.507; 29.513; 29.274 | SUN, Yue, China Telecom | suny20@chinatelecom.cn | Rel-18 | 97 |
| 1344 | 620 | **Dynamically Changing AM Policies in the 5GC Phase 2** |  | 651.25d | 2021-12-20 A | 2023-09-09 A | 100% |  |  |  | 10272h | 10272h | TEI18_DCAMP_Ph2 | 49 | 23.502 | Yubing Liu | liuyb9@chinatelecom.cn | Rel-18 | 97 |
| 1345 | 620.1 | Stage 2 of TEI18_DCAMP_Ph2 |  | 382d | 2021-12-20 A | 2023-06-06 A | 100% |  | finish no earlier than 2023-06-06 | S2 | 3056h | 3056h | TEI18_DCAMP_Ph2 | 49 | 23.502 | Yubing Liu | liuyb9@chinatelecom.cn | Rel-18 | 97 |
| 1346 | 620.2 | CT3 aspects on Dynamically Changing AM Policies in the 5GC Phase 2 |  | 451d | 2021-12-20 A | 2023-09-09 A | 100% |  | finish no earlier than 2023-09-09 | C3 | 3608h | 3608h | TEI18_DCAMP_Ph2 | 49 | 29.513; 29.519; 29.522; 29.534 | SUN, Yue, China Telecom | suny20@chinatelecom.cn | Rel-18 | 97 |
| 1347 | 620.3 | CT4 aspects on Dynamically Changing AM Policies in the 5GC Phase 2 |  | 451d | 2021-12-20 A | 2023-09-09 A | 100% |  | finish no earlier than 2023-09-09 | C4 | 3608h | 3608h | TEI18_DCAMP_Ph2 | 49 | 29.513; 29.519; 29.522; 29.534 | SUN, Yue, China Telecom | suny20@chinatelecom.cn | Rel-18 | 97 |
| 1348 | 621 | Rel-18 User plane improvements | milestone | 0d? | 2016-03-15 A | 2016-03-15 A | 100% |  | start no earlier than 2016-03-15 |  |  |  |  |  |  |  |  | Rel-18 |  |
| 1349 | 622 | Study on new HEVC profiles and operating points |  | 194d | 2023-06-08 A | 2024-03-03 A | 100% |  | start no earlier than 2023-06-08 | S4 | 1552h | 1552h | FS_HEVC_Profiles | 51 | 26.955 ; 26.966 | Waqar Zia | waqar_zia (at) apple.com | Rel-18 | 100 |
| 1350 | 623 | Study on 5G Media Service Enablers |  | 261d | 2021-12-13 A | 2022-12-12 A | 100% |  | finish no earlier than 2022-12-12 | S4 | 2088h | 2088h | FS_5G_MSE | 48 |  | Thomas Stockhammer, Qualcomm Incorporated | tsto@qti.qualcomm.com | Rel-18 | 94 |
| 1351 | 624 | UE Testing Phase 2 |  | 459d | 2022-06-02 A | 2024-03-03 A | 100% |  | finish no earlier than 2024-03-03 | S4 | 3672h | 3672h | eUET | 49 | 26.131; 26.132; 26.801 ; 26.130 | Stéphane Ragot, Orange | stephane.ragot@orange.com | Rel-18 | 96 |
| 1352 | 625 | 5G Media Streaming Audio codec phase 2 for 5G-Advanced |  | 61d | 2022-12-09 A | 2023-03-03 A | 100% |  | finish no earlier than 2023-03-03 | S4 | 488h | 488h | 5GMS_Audio_Ph2 | 50 | 26.117; 26.511 | Frédéric Gabin (Dolby Laboratories Inc.) | frederic.gabin@dolby.com | Rel-18 | 98 |
| 1353 | 626 | 5G Media Streaming Architecture Phase 2 |  | 264d | 2022-06-02 A | 2023-06-06 A | 100% |  | finish no earlier than 2023-06-06 | S4 | 2112h | 2112h | 5GMS_Ph2 | 49 | 26.501 | Iraj Sodagar, Tencent | <irajs@live.com> | Rel-18 | 96 |
| 1354 | 627 | Enhanced Multiparty RTT |  | 322d | 2022-12-12 A | 2024-03-03 A | 100% |  | finish no earlier than 2024-03-03 | S4 | 2576h | 2576h | MP_RTT | 50 | 26.114 ; 26.982 | Huan-yu Su, Huawei | su.huanyu@huawei.com | Rel-18 | 98 |
| 1355 | 628 | Traffic Models and Quality Evaluation Methods for Media and XR Services in 5G Systems |  | 905d | 2020-03-25 A | 2023-09-09 A | 100% |  | finish no earlier than 2023-09-09 | S4 | 7240h | 7240h | FS_XRTraffic | 44 | 26.925 | Thomas Stockhammer | tsto@qti.qualcomm.com | Rel-18 | 87 |
| 1356 | 629 | 5G-Advanced media profiles for messaging services |  | 194d | 2023-06-08 A | 2024-03-03 A | 100% |  | finish no earlier than 2024-03-03 | S4 | 1552h | 1552h | PROMISE | 51 | 26.140; 26.141 ; 26.143 | Frédéric Gabin (Dolby Laboratories Inc.) – | frederic.gabin@dolby.com | Rel-18 | 100 |
| 1357 | 630 | 5G Media Streaming Protocols Phase 2 |  | 264d | 2023-06-08 A | 2024-06-06 A | 100% |  | finish no earlier than 2024-06-06 | S4 | 2112h | 2112h | 5GMS_Pro_Ph2 | 51 | 26.512; 26.247; 26.517; 26.532 ; 26.510 | Thomas Stockhammer, Qualcomm Incorporated, | tsto@qti.qualcomm.com | Rel-18 | 100 |
| 1358 | 631 | Rel-18 Other topics | milestone | 0d? | 2016-03-15 A | 2016-03-15 A | 100% |  | start no earlier than 2016-03-15 |  |  |  |  |  |  |  |  | Rel-18 |  |
| 1359 | 632 | AKMA service disabling in roaming |  | 22d | 2024-02-02 A | 2024-03-03 A | 100% |  | start no earlier than 2024-02-02 | S3 | 176h | 176h | AKMA_Disable | 52 |  | Khare, Saurabh | saurabh.khare@nokia.com | Rel-18 | 103 |

Notes:
- 1337: ; 6/6/23: Compl:20%->50%
- 1339: ; 10/12/22: 0%->80; 9/1/23: WID:SP-220807->SP-221335
- 1340: 21/1/22: 23.700-89 added;; 4/6/22: 0%->80; 21/6/22: WID:SP-211642->SP-220647; 12/9/22: 80%->100
- 1341: ; 10/12/22: 0%->80; 9/1/23: WID:SP-220807->SP-221335; 15/3/23: 80%->100;
- 1342: ; 6/6/23: Compl:0%->85%; 6/6/23: CD:16/06/2023->09/09/2023; 6/6/23: WID: CP-230116->CP-231302
- 1343: ; 6/6/23: Compl:0%->90%; 6/6/23: WID: CP-230116->CP-231302
- 1345: ; 16/3/23: FCD:12/09/2022->/23; 16/3/23: WID:SP-220799->SP-230102
- 1346: ; 6/6/23: Compl:0%->80%; 6/6/23: CD:12/09/2022->09/09/2023
- 1347: ; 6/6/23: Compl:0%->80%; 6/6/23: CD:12/09/2022->09/09/2023
- 1348: -
- 1349: ; 7/9/23: 0%->30; 21/9/23: 26.966 added;; 8/12/23: 30%->65; 14/3/24: 65%->100
- 1350: 12/3/22: 0%->20; 4/6/22: 20%->30; 12/9/22: 30%->60; 12/9/22: FCD:12/09/2022->12/22; 11/12/22: 60%->100
- 1351: ; 3/8/22: 26.130 added; 17/8/22: UETest_Ph2-> eUET; 12/9/22: 0%->10; 11/12/22: 10%->15; 17/3/23: 15%->20; 8/6/23: 20%->30; 7/9/23: 30%->35; 7/9/23: FCD:12/12/2023->/24; 8/12/23: 35%->65; 14/3/24: 65%->100
- 1352: 17/3/23: 0%->100
- 1353: 17/8/22: 5GMSA_Ph2-> 5GMS_Ph2; 17/8/22: WID:SP-220614->SP-220667; 12/9/22: 0%->15; 11/12/22: 15%->25; 16/3/23: WID:SP-220667->SP-230164; 16/3/23: FCD:03/03/2023->/23; 17/3/23: 25%->50; 8/6/23: 50%->100
- 1354: ; 17/3/23: 0%->5; 8/6/23: 5%->30; 7/9/23: 30%->50; 8/12/23: 50%->75; 8/12/23: FCD:12/12/2023->/2024; 8/12/23: WID:SP-221346->SP-231290; 3/1/24: WID:SP-231290->SP-231709; 14/3/24: 75%->100; 3/4/24: 26.982 added;
- 1355: 10/6/20: 0%->15; 28/06/20: Rel-16->Rel-17; 5/12/20: 15%->40; 21/3/21: 40%->50; 21/3/21: FCD:18/06/2020->09/21; 11/6/21: 50%->65. 2/7/21: name change from "Study on Typical Traffic Characteristics for XR Services and other Media"; 13/9/21: 65%->70; 13/1...; 7/9/23: 95%->100
- 1356: 30/6/23: 26.143 added;; 7/9/23: 0%->15; 8/12/23: 15%->40; 14/3/24: 40%->100
- 1357: ; 7/9/23: WID:SP-230543->SP-230976; 7/9/23: 0%->25; ; 21/9/23: 26.510 added;; 8/12/23: 25%->55; 14/3/24: 55%->75; 14/3/24: FCD:03/03/2024->/24; 13/6/24: 75%->100
- 1358: -
- 1359: 15/3/24: 0%->100

| ID | WBS | Task | Duration | Start | Finish | Complete | Constraint | Resources | Work | Actual work | Acronym | PCG approved | WI rapporteur name | WI rapporteur e-mail | Release | TSG approved |
| --- | --- | --- | --- | --- | --- | --- | --- | --- | --- | --- | --- | --- | --- | --- | --- | --- |
| 1360 | 633 | **Support for Wireless and Wireline Convergence Phase 2** | 833.5d? | 2021-12-20 A | 2024-03-03 A | 100% |  |  | 16384h | 16384h | 5WWC_Ph2 | 49 | Laurent Thiebaut, Nokia | Laurent.thiebaut@nokia.com | Rel-18 | 97 |
| 1361 | 633.1 | Study on the support for 5WWC Phase 2 | 256d? | 2021-12-20 A | 2022-12-12 A | 100% | finish no earlier than 2022-12-12 | S2 | 2048h | 2048h | FS_5WWC_Ph2 | 43 | Laurent Thiebaut, Nokia | laurent.thiebaut@nokia.com | Rel-18 | 84 |
| 1362 | 633.2 | Study on Security aspects for 5WWC Phase 2 | 197d | 2022-06-02 A | 2023-03-03 A | 100% | finish no earlier than 2023-03-03 | S3 | 1576h | 1576h | FS_5WWC_Ph2_Sec | 49 | Saurabh Khare, Nokia | Saurabh.khare@nokia.com | Rel-18 | 96 |
| 1363 | 633.3 | Stage 2 of 5WWC_Ph2 | 382d | 2021-12-20 A | 2023-06-06 A | 100% | finish no earlier than 2023-06-06 | S2 | 3056h | 3056h | 5WWC_Ph2 | 49 | Laurent Thiebaut, Nokia | Laurent.thiebaut@nokia.com | Rel-18 | 97 |
| 1364 | 633.4 | CT1 aspects of 5WWC_Ph2 | 318d | 2022-12-16 A | 2024-03-03 A | 100% | finish no earlier than 2024-03-03 | C1 | 2544h | 2544h | 5WWC_Ph2 | 49 | Nassar, Mohamed A.(Nokia) | mohamed.a.nassar@nokia.com | Rel-18 | 97 |
| 1365 | 633.5 | CT3 aspects of 5WWC_Ph2 | 318d | 2022-12-16 A | 2024-03-03 A | 100% | finish no earlier than 2024-03-03 | C3 | 2544h | 2544h | 5WWC_Ph2 | 49 | Nassar, Mohamed A.(Nokia) | mohamed.a.nassar@nokia.com | Rel-18 | 97 |
| 1366 | 633.6 | CT4 aspects of 5WWC_Ph2 | 319d | 2022-12-15 A | 2024-03-03 A | 100% | finish no earlier than 2024-03-03 | C4 | 2552h | 2552h | 5WWC_Ph2 | 49 | Nassar, Mohamed A.(Nokia) | mohamed.a.nassar@nokia.com | Rel-18 | 97 |
| 1367 | 633.7 | Security aspects for 5WWC Phase 2 | 128d | 2023-03-16 A | 2023-09-09 A | 100% | finish no earlier than 2023-09-09 | S3 | 1024h | 1024h | 5WWC_Ph2_Sec | 50 | Khare, Saurabh, Nokia | saurabh.khare@nokia.com | Rel-18 | 99 |
| 1368 | 633.8 | Charging Aspects of 5WWC phase 2 | 130d | 2023-09-06 A | 2024-03-03 A | 100% | finish no earlier than 2024-03-03 | S5 | 1040h | 1040h | 5WWC_Ph2 | 51 | Sun Mingrui, China Unicom | sunmr19@chinaunicom.cn | Rel-18 | 101 |
| 1369 | 634 | **Enhancement of NSAC for maximum number of UEs with at least one PDU session/PDN connection** | 476.38d | 2022-09-09 A | 2023-12-12 A | 100% |  |  | 4616h | 4616h | eNSAC | 49 | ZHU Jinguo, ZTE | zhu.jinguo@zte.com.cn | Rel-18 | 97 |
| 1370 | 634.1 | Stage 2 of eNSAC | 193d | 2022-09-09 A | 2023-06-06 A | 100% | finish no earlier than 2023-06-06 | S2 | 1544h | 1544h | eNSAC | 49 | ZHU Jinguo, ZTE | zhu.jinguo@zte.com.cn | Rel-18 | 97 |
| 1371 | 634.2 | CT3 aspects of eNSAC | 124d | 2022-12-15 A | 2023-06-06 A | 100% | finish no earlier than 2023-06-06 | C3 | 992h | 992h | eNSAC | 49 | Li, Zhijun, ZTE | li.zhijun3@zte.com.cn | Rel-18 | 97 |
| 1372 | 634.3 | CT4 aspects of eNSAC | 260d | 2022-12-15 A | 2023-12-12 A | 100% | finish no earlier than 2023-12-12 | C4 | 2080h | 2080h | eNSAC | 49 | Li, Zhijun, ZTE | li.zhijun3@zte.com.cn | Rel-18 | 97 |
| 1373 | 635 | Management Data Analytics phase 2 | 378d | 2022-09-23 A | 2024-03-03 A | 100% | finish no earlier than 2024-03-03 | S5 | 3024h | 3024h | eMDAS_Ph2 | 49 | Yao, Yizhi, Intel | yizhi<dot>yao<at>intel<dot>com | Rel-18 | 97 |
| 1374 | 636 | **Application Data Analytics Enablement Service** | 840.75d | 2021-12-13 A | 2024-03-03 A | 100% |  |  | 9296h | 9296h | ADAES | 49 | Pateromichelakis, Emmanouil (Manos) | epateromiche@lenovo.com | Rel-18 | 97 |
| 1375 | 636.1 | Study on Application Data Analytics Enablement Service | 196d | 2021-12-13 A | 2022-09-12 A | 100% | finish no earlier than 2022-09-12 | S6 | 1568h | 1568h | FS_ADAES | 48 | Pateromichelakis, Emmanouil (Manos) | epateromiche@lenovo.com | Rel-18 | 94 |
| 1376 | 636.2 | Stage 2 of ADAES | 192d | 2022-09-12 A | 2023-06-06 A | 100% | finish no earlier than 2023-06-06 | S6 | 1536h | 1536h | ADAES | 49 | Pateromichelakis, Emmanouil (Manos) | epateromiche@lenovo.com | Rel-18 | 97 |
| 1377 | 636.3 | CT1 aspects of ADAES | 387d | 2022-09-12 A | 2024-03-03 A | 100% | finish no earlier than 2024-03-03 | C1 | 3096h | 3096h | ADAES | 49 | Atarius, Roozbeh, Lenovo | ratarius@motorola.com | Rel-18 | 97 |
| 1378 | 636.4 | CT3 aspects of ADAES | 387d | 2022-09-12 A | 2024-03-03 A | 100% | finish no earlier than 2024-03-03 | C3 | 3096h | 3096h | ADAES | 49 | Atarius, Roozbeh, Lenovo | ratarius@motorola.com | Rel-18 | 97 |
| 1379 | 637 | Study on Seamless UE context recovery | 191d | 2021-12-20 A | 2022-09-12 A | 100% | finish no earlier than 2022-09-12 | S2 | 1528h | 1528h | FS_SUECR | 48 | Lalith Kumar | lalith.kumar@samsung.com | Rel-18 | 94 |
| 1380 | 638 | **Seamless UE context recovery** | 380d | 2022-09-08 A | 2023-09-09 A | 100% |  |  | 5152h | 5152h | SUECR | 49 | Lalith kumar, Samsung | lalith.kumar@samsung.com | Rel-18 | 97 |
| 1381 | 638.1 | Stage 2 of Seamless UE context recovery | 68d | 2022-09-08 A | 2022-12-12 A | 100% | finish no earlier than 2022-12-12 | S2 | 544h | 544h | SUECR | 49 | Lalith kumar, Samsung | lalith.kumar@samsung.com | Rel-18 | 97 |
| 1382 | 638.2 | CT1 aspects of Seamless UE context recovery | 192d | 2022-12-16 A | 2023-09-09 A | 100% | finish no earlier than 2023-09-09 | C1 | 1536h | 1536h | SUECR | 49 | Hashmi, Danish Ehsan, Samsung | danis.hashmi@samsung.com | Rel-18 | 97 |
| 1383 | 638.3 | CT3 aspects of Seamless UE context recovery | 192d | 2022-12-16 A | 2023-09-09 A | 100% | finish no earlier than 2023-09-09 | C3 | 1536h | 1536h | SUECR | 49 | Hashmi, Danish Ehsan, Samsung | danis.hashmi@samsung.com | Rel-18 | 97 |
| 1384 | 638.4 | CT4 aspects of Seamless UE context recovery | 192d | 2022-12-16 A | 2023-09-09 A | 100% | finish no earlier than 2023-09-09 | C4 | 1536h | 1536h | SUECR | 49 | Hashmi, Danish Ehsan, Samsung | danis.hashmi@samsung.com | Rel-18 | 97 |

Notes:
- 1360: Impacted TSs and TRs: 23.501; 23.502; 23.503
- 1361: 26/6/19: 23.700-16 added; 21/01/22: moved Rel-17 to Rel-18 at SA#94e. Deletion of 940062, temporarily mistakenly added as FS_5WWV_Ph3; WID:SP-190562->SP-211640; 12/3/22: 0%->30. 4/6/22: 30%->60; 21/6/22: WID:SP-211640...; 12/9/22: FCD:12/09/2022->12/20...; 15/3/23: 90%->100 / Impacted TSs and TRs: 23.700-17
- 1362: 13/7/22: 33.887 added;; 12/9/22: 0%->30; 11/12/22: 30%->60; 9/1/23: WID:SP-220528->SP-221144; 17/3/23: 60%->80; 8/6/23: 80%->100 / Impacted TSs and TRs: 33.887
- 1363: ; 15/3/23: 30%->45; 15/3/23: WID:SP-220904->SP-230100; 15/3/23: FCD:12/12/2022->/23; 31/3/23: WID:SP-230100->SP-230367; 8/6/23: 45%->100 / Impacted TSs and TRs: 23.501; 23.502; 23.503
- 1364: ; 6/6/23: Compl:50%->60%; 30/6/23: WID:CP-223114->CP-231302; 30/6/23: WID:CP-231302->CP-231287 / Impacted TSs and TRs: 24.501; 24.502; 24.526; 29.513; 29.525; 23.003; 29.522
- 1365: ; 9/6/23: 15%->40 / Impacted TSs and TRs: 24.501; 24.502; 24.526; 29.513; 29.525; 23.003; 29.522
- 1366: ; 6/6/23: Compl:40%->65% / Impacted TSs and TRs: 24.501; 24.502; 24.526; 29.513; 29.525; 23.003; 29.522
- 1367: ; 8/6/23: 0%->80; 15/3/24: 80%->100 / Impacted TSs and TRs: 33.501
- 1368: ; 8/12/23: 0%->40; 14/3/24: 40%->100 / Impacted TSs and TRs: 32.255; 32.291; 32.298
- 1369: Impacted TSs and TRs: 23.501; 23.502
- 1370: ; 16/3/23: FCD:03/03/2023->/23; 16/3/23: WID:SP-220988->SP-230113; 8/6/23: 0%->100 / Impacted TSs and TRs: 23.501; 23.502
- 1371: Impacted TSs and TRs: 29.510; 29.536; 29.571; 29.122; 29.522
- 1372: ; 6/6/23: Compl:0%->25% / Impacted TSs and TRs: 29.510; 29.536; 29.571; 29.122; 29.522
- 1373: ; 11/12/22: 0%->5; 17/3/23: 5%->15; 8/6/23: 15%->25; 8/6/23: 25%->25; 7/9/23: 25%->50; 8/12/23: 50%->87; 8/12/23: FCD:12/12/2023->/2024; 14/3/24: 87%->100; 2/4/24: WID:SP-220981->SP-240267 / Impacted TSs and TRs: 28.104; 28.552; 32.425; 28.554; 28.541; 28.622; 28.623; 28.533
- 1374: ; 23/9/22: 23.436 added;; 11/12/22: 0%->45; 11/12/22: 45%-> / Impacted TSs and TRs: 23.434 ; 23.436
- 1375: 7/1/22: 23.700-36 added;; 12/3/22: 0%->15; 4/6/22: 15%->55; 12/9/22: 55%->95; 11/12/22: 95%->100 / Impacted TSs and TRs: 23.700-36
- 1376: ; 23/9/22: 23.436 added;; 11/12/22: 0%->45; 11/12/22: 45%->; 17/3/23: FCD:03/03/2023->/23; 17/3/23: WID:SP-220913->SP-230275; 17/3/23: 45%->80; 8/6/23: 80%->100 / Impacted TSs and TRs: 23.434 ; 23.436
- 1377: 31/3/23: 24.559 added;; 6/6/23: Compl:0%->5% / Impacted TSs and TRs: 29.549; 24.559
- 1378: 9/6/23: 0%->5 / Impacted TSs and TRs: 29.549
- 1379: 21/1/22: 23.700-61 added;; 12/3/22: 0%->25; 4/6/22: 25%->100 / Impacted TSs and TRs: 23.700-61
- 1380: Impacted TSs and TRs: 23.501; 23.502
- 1381: ; 10/12/22: 0%->100 / Impacted TSs and TRs: 23.501; 23.502
- 1382: ; 6/6/23: Compl:90%->95% / Impacted TSs and TRs: 24.501; 27.007; 29.122; 29.522; 29.518
- 1383: ; 9/6/23: 60%->80 / Impacted TSs and TRs: 24.501; 27.007; 29.122; 29.522; 29.518
- 1384: Impacted TSs and TRs: 24.501; 27.007; 29.122; 29.522; 29.518

| ID | WBS | Task | Duration | Start | Finish | Complete | Constraint | Resources | Work | Actual work | Acronym | PCG approved | Impacted TSs and TRs | WI rapporteur name | WI rapporteur e-mail | Release | TSG approved |
| --- | --- | --- | --- | --- | --- | --- | --- | --- | --- | --- | --- | --- | --- | --- | --- | --- | --- |
| 1385 | 639 | **5G System Enabler for Service Function Chaining** | 833.5d | 2021-12-20 A | 2024-03-03 A | 100% |  |  | 10280h | 10280h | SFC | 49 | 23.501; 23.502; 23.503 | Meghashree Dattatri Kedalagudde, Intel | meghashree.dattatri.kedalagudde@intel.com | Rel-18 | 97 |
| 1386 | 639.1 | Stage 2 of 5G System Enabler for Service Function Chaining | 193d | 2022-09-09 A | 2023-06-06 A | 100% | finish no earlier than 2023-06-06 | S2 | 1544h | 1544h | SFC | 49 | 23.501; 23.502; 23.503 | Meghashree Dattatri Kedalagudde, Intel | meghashree.dattatri.kedalagudde@intel.com | Rel-18 | 97 |
| 1387 | 639.2 | CT3 aspects of SFC | 318d | 2022-12-16 A | 2024-03-03 A | 100% | finish no earlier than 2024-03-03 | C3 | 2544h | 2544h | SFC | 49 | 29.244; 29.512; 29.513; 29.514; 29.519; 29.522 | Yue Sun, China Telecom | suny20@chinatelecom.cn | Rel-18 | 97 |
| 1388 | 639.3 | CT4 aspects of SFC | 518d | 2021-12-20 A | 2023-12-12 A | 100% | finish no earlier than 2023-12-12 | C4 | 4144h | 4144h | SFC | 49 | 29.244; 29.512; 29.513; 29.514; 29.519; 29.522 | Yue Sun, China Telecom | suny20@chinatelecom.cn | Rel-18 | 97 |
| 1389 | 639.4 | Study on System Enabler for Service Function Chaining | 256d | 2021-12-20 A | 2022-12-12 A | 100% | finish no earlier than 2022-12-12 | S2 | 2048h | 2048h | FS_SFC | 48 | 23.700-18 | Meghashree D Kedalagudde, Intel | meghashree.dattatri.kedalagudde@intel.com | Rel-18 | 94 |
| 1390 | 640 | Study on Extensions to the TSC Framework to support Deterministic Networking (DetNet) | 256d | 2021-12-20 A | 2022-12-12 A | 100% | finish no earlier than 2022-12-12 | S2 | 2048h | 2048h | FS_DetNet | 48 | 23.700-46 | Miklós, György, Ericsson | gyorgy.miklos@ericsson.com | Rel-18 | 94 |
| 1391 | 641 | **Extensions to the TSC Framework to support DetNet** | 562.25d | 2022-09-08 A | 2024-03-03 A | 100% |  |  | 10784h | 10784h | DetNet | 49 | 23.501; 23.502; 23.503 | Miklós, György, Ericsson | gyorgy.miklos@ericsson.com | Rel-18 | 97 |
| 1392 | 641.1 | Stage 2 of Extensions to the TSC Framework to support DetNet | 194d | 2022-09-08 A | 2023-06-06 A | 100% | finish no earlier than 2023-06-06 | S2 | 1552h | 1552h | DetNet | 49 | 23.501; 23.502; 23.503 | Miklós, György, Ericsson | gyorgy.miklos@ericsson.com | Rel-18 | 97 |
| 1393 | 641.2 | CT1 aspects of Detnet | 259d | 2022-12-16 A | 2023-12-12 A | 100% | finish no earlier than 2023-12-12 | C1 | 2072h | 2072h | DetNet | 49 | 24.539; 29.244; 29.513; 29.512; 29.514 | Fuencisla García, Ericsson | fuencisla.garcia@ericsson.com | Rel-18 | 97 |
| 1394 | 641.3 | **CT3 aspects of Detnet** | 459.75d | 2022-12-16 A | 2024-03-03 A | 100% |  | C3 | 5088h | 5088h | DetNet | 49 | 24.539; 29.244; 29.513; 29.512; 29.514 | Fuencisla García, Ericsson | fuencisla.garcia@ericsson.com | Rel-18 | 97 |
| 1395 | 641.3.1 | (IETF) CT3 part of DetNet (draft-ietf-detnet-yang) | 318d | 2022-12-16 A | 2024-03-03 A | 100% | finish no earlier than 2024-03-03 | C3-IETF | 2544h | 2544h | DetNet | 49 | 29.513, 29.565 | Fuencisla García, Ericsson | fuencisla.garcia@ericsson.com | Rel-18 | 97 |
| 1396 | 641.4 | CT4 aspects of Detnet | 259d | 2022-12-16 A | 2023-12-12 A | 100% | finish no earlier than 2023-12-12 | C4 | 2072h | 2072h | DetNet | 49 | 24.539; 29.244; 29.513; 29.512; 29.514 | Fuencisla García, Ericsson | fuencisla.garcia@ericsson.com | Rel-18 | 97 |
| 1397 | 642 | **Multiple location report for MT-LR Immediate Location Request for regulatory services** | 281.75d | 2022-09-08 A | 2023-06-06 A | 100% |  |  | 1528h | 1528h | TEI18_MLR | 49 | 23.273 | Joul, Christopher, T-Mobile USA | chris.joul@t-mobile.com | Rel-18 | 97 |
| 1398 | 642.1 | Stage 2 of TEI18_MLR | 68d | 2022-09-08 A | 2022-12-12 A | 100% | finish no earlier than 2022-12-12 | S2 | 544h | 544h | TEI18_MLR | 49 | 23.273 | Joul, Christopher, T-Mobile USA | chris.joul@t-mobile.com | Rel-18 | 97 |
| 1399 | 642.2 | CT4 aspects on TEI18_MLR | 123d | 2022-12-16 A | 2023-06-06 A | 100% | finish no earlier than 2023-12-12 | C4 | 984h | 984h | TEI18_MLR | 49 | 29.571; 29.518 | Jones Yunjie, Lu, Ericsson | jones.lu@ericsson.com | Rel-18 | 97 |
| 1400 | 643 | **TEI18 on Enhancement of Application Detection Event Exposure** | 281.75d | 2022-09-08 A | 2023-06-06 A | 100% |  |  | 2008h | 2008h | TEI18_ADEE | 49 | 23.503; 23.502 | Aihua Li, China Mobile | liaihua@chinamobile.com | Rel-18 | 97 |
| 1401 | 643.1 | Stage 2 of TEI18_ADEE | 127d | 2022-09-08 A | 2023-03-03 A | 100% | finish no earlier than 2023-03-03 | S2 | 1016h | 1016h | TEI18_ADEE | 49 | 23.503; 23.502 | Aihua Li, China Mobile | liaihua@chinamobile.com | Rel-18 | 97 |
| 1402 | 643.2 | CT3 aspects of TEI18_ADEE | 124d | 2022-12-15 A | 2023-06-06 A | 100% | finish no earlier than 2023-06-06 | C3 | 992h | 992h | TEI18_ADEE | 49 | 29.522; 29.514; 29.512 | Zhenning Huang, China Mobile | huangzhenning@chinamobile.com | Rel-18 | 97 |
| 1403 | 644 | **General Support of IPv6 Prefix Delegation in 5GS** | 477.38d | 2022-09-08 A | 2023-12-12 A | 100% |  |  | 7232h | 7232h | TEI18_IPv6PD | 49 | 23.501; 23.502; 23.503; 23.304; 23.316 | Gan, Judy, Ericsson | Judy.Gan.Juying@ericsson.com | Rel-18 | 97 |
| 1404 | 644.1 | Stage 2 of TEI18_IPv6PD | 127d | 2022-09-08 A | 2023-03-03 A | 100% | finish no earlier than 2023-03-03 | S2 | 1016h | 1016h | TEI18_IPv6PD | 49 | 23.501; 23.502; 23.503; 23.304; 23.316 | Gan, Judy, Ericsson | Judy.Gan.Juying@ericsson.com | Rel-18 | 97 |
| 1405 | 644.2 | CT1 aspects of TEI18_IPv6PD | 259d | 2022-12-16 A | 2023-12-12 A | 100% | finish no earlier than 2023-12-12 | C1 | 2072h | 2072h | TEI18_IPv6PD | 49 | 24.501; 29.561; 29.512; 29.521; 29.244; 29.513 | Maria Tianmei, Liang, Ericsson | Maria.liang@ericsson.com | Rel-18 | 97 |
| 1406 | 644.3 | CT3 aspects of TEI18_IPv6PD | 259d | 2022-12-16 A | 2023-12-12 A | 100% | finish no earlier than 2023-12-12 | C3 | 2072h | 2072h | TEI18_IPv6PD | 49 | 24.501; 29.561; 29.512; 29.521; 29.244; 29.513 | Maria Tianmei, Liang, Ericsson | Maria.liang@ericsson.com | Rel-18 | 97 |
| 1407 | 644.4 | CT4 aspects of TEI18_IPv6PD | 259d | 2022-12-16 A | 2023-12-12 A | 100% | finish no earlier than 2023-12-12 | C4 | 2072h | 2072h | TEI18_IPv6PD | 49 | 24.501; 29.561; 29.512; 29.521; 29.244; 29.513 | Maria Tianmei, Liang, Ericsson | Maria.liang@ericsson.com | Rel-18 | 97 |
| 1408 | 645 | **Secondary DN Authentication and authorization in EPC IWK cases** | 562.25d | 2022-09-08 A | 2024-03-03 A | 100% |  |  | 8176h | 8176h | TEI18_SDNAEPC | 49 | 23.501; 23.502 | Laurent Thiebaut, Nokia | Laurent.thiebaut@nokia.com | Rel-18 | 97 |
| 1409 | 645.1 | Stage 2 of Secondary DN Authentication and authorization in EPC IWK cases | 68d | 2022-09-08 A | 2022-12-12 A | 100% | finish no earlier than 2022-12-12 | S2 | 544h | 544h | TEI18_SDNAEPC | 49 | 23.501; 23.502 | Laurent Thiebaut, Nokia | Laurent.thiebaut@nokia.com | Rel-18 | 97 |
| 1410 | 645.2 | CT1 aspects of TEI18_SDNAEPC | 318d | 2022-12-16 A | 2024-03-03 A | 100% | finish no earlier than 2024-03-03 | C1 | 2544h | 2544h | TEI18_SDNAEPC | 49 | 24.501; 24.301; 24.008; 29.561; 29.274 | Nassar, Mohamed A.(Nokia) | mohamed.a.nassar@nokia.com | Rel-18 | 97 |
| 1411 | 645.3 | CT3 aspects of TEI18_SDNAEPC | 318d | 2022-12-16 A | 2024-03-03 A | 100% | finish no earlier than 2024-03-03 | C3 | 2544h | 2544h | TEI18_SDNAEPC | 49 | 24.501; 24.301; 24.008; 29.561; 29.274 | Nassar, Mohamed A.(Nokia) | mohamed.a.nassar@nokia.com | Rel-18 | 97 |
| 1412 | 645.4 | CT4 aspects of TEI18_SDNAEPC | 318d | 2022-12-16 A | 2024-03-03 A | 100% | finish no earlier than 2024-03-03 | C4 | 2544h | 2544h | TEI18_SDNAEPC | 49 | 24.501; 24.301; 24.008; 29.561; 29.274 | Nassar, Mohamed A.(Nokia) | mohamed.a.nassar@nokia.com | Rel-18 | 97 |

Notes:
- 1386: ; 9/1/23: WID:SP-220802->SP-221336; 15/3/23: 0%->60; 15/3/23: WID:SP-221336->SP-230120; 15/3/23: FCD:03/03/2023->/23; 8/6/23: 60%->100
- 1387: ; 6/6/23: Compl:10%->90%; 6/6/23: CD:12/12/2023->03/03/2024; 6/6/23: WID: CP-223210->CP-231193. 2/4/23: rapporteur: Thomas Luetzenkirchen, Intel-> Yue Sun, China Telecom
- 1388: ; 6/6/23: Compl:100%->80%; 6/6/23: CD:12/12/2022->12/12/2023; 6/6/23: WID: CP-223210->CP-231193. 2/4/23: rapporteur: Thomas Luetzenkirchen, Intel-> Yue Sun, China Telecom
- 1389: 21/1/22: 23.700-18 added;; 12/3/22: 0%->25; 4/6/22: 25%->60; 21/6/22: WID:SP-211594->SP-220415: rap change; 12/9/22: 60%->80; 12/9/22: FCD:12/09/2022->12/22; 10/12/22: 80%->100
- 1390: 21/1/22: 23.700-46 added;; 12/3/22: 0%->10; 4/6/22: 10%->70; 12/9/22: 70%->90; 12/9/22: FCD:12/09/2022->12/22; 15/3/23: 90%->100
- 1392: ; 15/3/23: WID:SP-220801->SP-230172; 15/3/23: FCD:03/03/2023->/23; 8/6/23: 95%->100
- 1393: ; 6/6/23: Compl:90%->100%; 6/6/23: WID: CP-223206->CP-231195
- 1394: ; 6/6/23: Compl:50%->80%; 6/6/23: CD:12/12/2023->03/03/2024; 6/6/23: WID: CP-223206->CP-231195
- 1395: CT3 part complete. SA2 reference cleanup pending
- 1396: ; 6/6/23: Compl:10%->80%; 6/6/23: WID: CP-223206->CP-231195
- 1398: ; 10/12/22: 0%->100
- 1399: ; 6/6/23: Compl:80%->100%; 6/6/23: CD:12/12/2023->06/06/2023
- 1401: ; 22/3/23: 0%->100
- 1402: ; 6/6/23: Compl:0%->100%
- 1404: ; 22/3/23: 0%->100
- 1405: ; 6/6/23: Compl:95%->100%; 6/6/23: WID: CP-223203->CP-230121
- 1409: ; 10/12/22: 0%->100
- 1410: ; 6/6/23: Compl:80%->90%
- 1411: ; 9/6/23: 96%->

| ID | WBS | Task | Duration | Start | Finish | Complete | Constraint | Resources | Work | Actual work | Acronym | PCG approved | WI rapporteur name | WI rapporteur e-mail | Release | TSG approved | Status Report |
| --- | --- | --- | --- | --- | --- | --- | --- | --- | --- | --- | --- | --- | --- | --- | --- | --- | --- |
| 1413 | 646 | **Message Service within the 5G system (MSGin5G) Phase 2** | 460d | 2022-03-10 A | 2023-12-12 A | 100% |  |  | 5400h | 5400h | 5GMARCH_Ph2 | 48 | Liu, Yue, China Mobile | liuyueyjy@chinamobile.com | Rel-18 | 95 |  |
| 1414 | 646.1 | Stage 2 of 5GMARCH_Ph2 | 257d | 2022-03-10 A | 2023-03-03 A | 100% | finish no earlier than 2023-03-03 | S6 | 2056h | 2056h | 5GMARCH_Ph2 | 48 | Liu, Yue, China Mobile | liuyueyjy@chinamobile.com | Rel-18 | 95 |  |
| 1415 | 646.2 | CT1 aspects of 5GMARCH_Ph2 | 198d | 2023-03-13 A | 2023-12-12 A | 100% | finish no earlier than 2023-12-15 | C1 | 1584h | 1584h | 5GMARCH_Ph2 | 48 | Liu, Yue, China Mobile | liuyueyjy@chinamobile.com | Rel-18 | 95 |  |
| 1416 | 646.3 | CT3 aspects of 5GMARCH_Ph2 | 198d | 2023-03-13 A | 2023-12-12 A | 100% | finish no earlier than 2023-12-15 | C3 | 1584h | 1584h | 5GMARCH_Ph2 | 48 | Liu, Yue, China Mobile | liuyueyjy@chinamobile.com | Rel-18 | 95 |  |
| 1417 | 646.4 | Security aspects of MSGin5G Ph2 | 22d | 2023-02-02 A | 2023-03-03 A | 100% | finish no earlier than 2023-03-03 | S3 | 176h | 176h | 5GMARCH_Ph2_SEC | 50 | Huang Xiaoting, China Mobile | huangxiaoting@chinamobile.com | Rel-18 | 99 |  |
| 1418 | 647 | **5G Timing Resiliency System** | 1395.88d | 2020-06-25 A | 2024-03-03 A | 100% |  |  | 12720h | 12720h | 5TRS | 46 | Betsy Covell, Nokia | betsy.covell@nokia.com | Rel-18 | 91 |  |
| 1419 | 647.1 | Study on 5TRS | 187d | 2020-06-25 A | 2021-03-12 A | 100% | finish no earlier than 2021-03-12 | S1 | 1496h | 1496h | FS_5TRS | 45 | Betsy Covell, Nokia | betsy.covell@nokia.com | Rel-18 | 88 |  |
| 1420 | 647.2 | Study on 5G Timing Resiliency and TSC&URLLC enhancements | 256d | 2021-12-20 A | 2022-12-12 A | 100% | finish no earlier than 2022-12-12 | S2 | 2048h | 2048h | FS_5TRS_URLLC | 48 | Devaki Chandramouli | Devaki.chandramouli@nokia.com | Rel-18 | 94 |  |
| 1421 | 647.3 | Stage 1 for 5TRS | 127d | 2021-03-18 A | 2021-09-10 A | 100% | finish no earlier than 2021-09-12 | S1 | 1016h | 1016h | 5TRS | 46 | Betsy Covell, Nokia | betsy.covell@nokia.com | Rel-18 | 91 |  |
| 1422 | 647.4 | Stage 2 of Timing Resiliency and URLLC enhancements | 125d | 2022-09-12 A | 2023-03-03 A | 100% | finish no earlier than 2023-03-03 | S2 | 1000h | 1000h | TRS_URLLC | 49 | Devaki Chandramouli | Devaki.chandramouli@nokia.com | Rel-18 | 97 |  |
| 1423 | 647.5 | CT1 aspects of TRS_URLLC | 318d | 2022-12-16 A | 2024-03-03 A | 100% | finish no earlier than 2024-03-03 | C1 | 2544h | 2544h | TRS_URLLC | 49 | Apostolos Papageorgiou (Nokia) | apostolos.papageorgiou@nokia.com | Rel-18 | 97 |  |
| 1424 | 647.6 | CT3 aspects of TRS_URLLC | 318d | 2022-12-16 A | 2024-03-03 A | 100% | finish no earlier than 2024-03-03 | C3 | 2544h | 2544h | TRS_URLLC | 49 | Apostolos Papageorgiou (Nokia) | apostolos.papageorgiou@nokia.com | Rel-18 | 97 |  |
| 1425 | 647.7 | CT4 aspects of TRS_URLLC | 259d | 2022-12-16 A | 2023-12-12 A | 100% | finish no earlier than 2023-12-12 | C4 | 2072h | 2072h | TRS_URLLC | 49 | Apostolos Papageorgiou (Nokia) | apostolos.papageorgiou@nokia.com | Rel-18 | 97 |  |
| 1426 | 648 | Study on Management Aspects of URLLC | 324d | 2022-03-10 A | 2023-06-06 A | 100% | finish no earlier than 2023-06-06 | S5 | 2592h | 2592h | FS_URLLC_Mgt | 48 | Wang,Zhaoning,China Unicom | wangzn18@chinaunicom.cn | Rel-18 | 95 |  |
| 1427 | 649 | Study on enhancement for resiliency of gNB-CU (Central Unit)-CP (Control Plane) | 204d | 2021-12-13 A | 2022-09-22 A | 100% | finish no earlier than 2022-09-22 | R3 | 1632h | 1632h | FS_gNB_CU_CP_resiliency | 48 | Masato Taniguchi, NTT DOCOMO, INC. | masato.taniguchi.mf@nttdocomo.com | Rel-18 | 94 | RP-221439 |
| 1428 | 650 | **NR Timing Resiliency and URLLC enhancements** | 295.12d | 2023-03-03 A | 2023-12-12 A | 100% |  | R3 | 3264h | 3264h | TRS_URLLC-NR | 50 | Nokia |  | Rel-18 | 99 |  |
| 1429 | 650.1 | Core part: NR Timing Resiliency and URLLC enhancements | 204d | 2023-03-03 A | 2023-12-12 A | 100% | finish no earlier than 2023-12-12 | R3 | 1632h | 1632h | TRS_URLLC-NR-Core | 50 | Sean Kelley, Nokia | sean.kelley@nokia.com | Rel-18 | 99 | RP-232864 |
| 1430 | 651 | **Vehicle-Mounted Relays** | 1309.88d | 2020-09-16 A | 2024-03-03 A | 100% |  |  | 9760h | 9760h | VMR | 47 | Francesco Pica, Qualcomm | fpica@qti.qualcomm.com | Rel-18 | 93 |  |
| 1431 | 651.1 | Study on VMR | 256d | 2020-09-16 A | 2021-09-08 A | 100% | finish no earlier than 2021-09-08 | S1 | 2048h | 2048h | FS_VMR | 45 | Francesco Pica | fpica@qti.qualcomm.com | Rel-18 | 89 |  |
| 1432 | 651.2 | Stage 1 of VMR | 66d | 2021-09-10 A | 2021-12-10 A | 100% | finish no earlier than 2021-12-12 | S1 | 528h | 528h | VMR | 47 | Francesco Pica, Qualcomm | fpica@qti.qualcomm.com | Rel-18 | 93 |  |
| 1433 | 651.3 | (Stage 2 for VMR) Architecture Enhancements for Vehicle Mounted Relays | 128d | 2022-12-09 A | 2023-06-06 A | 100% | finish no earlier than 2023-06-06 | S2 | 1024h | 1024h | VMR | 50 | Cheng, Hong, Qualcomm Incorporated, | hongc@qti.qualcomm.com | Rel-18 | 98 |  |
| 1434 | 651.4 | CT1 aspects of VMR | 257d | 2023-03-13 A | 2024-03-03 A | 100% | finish no earlier than 2024-03-03 | C1 | 2056h | 2056h | VMR | 50 | Kim, Sunghoon, Qualcomm Incorporated | sunghoon@qti.qualcomm.com | Rel-18 | 99 |  |
| 1435 | 651.5 | CT4 aspects of VMR | 257d | 2023-03-13 A | 2024-03-03 A | 100% | finish no earlier than 2024-03-03 | C4 | 2056h | 2056h | VMR | 50 | Kim, Sunghoon, Qualcomm Incorporated | sunghoon@qti.qualcomm.com | Rel-18 | 99 |  |
| 1436 | 651.6 | Study on Architecture Enhancements for Vehicle Mounted Relays | 256d | 2021-12-20 A | 2022-12-12 A | 100% | finish no earlier than 2022-12-12 | S2 | 2048h | 2048h | FS_VMR | 48 | Cheng, Hong, Qualcomm Incorporated, | hongc@qti.qualcomm.com | Rel-18 | 94 |  |

Notes:
- 1413: ; 4/6/22: 0%->30; 12/9/22: 30%->55; 11/12/22: 55%->70 / Impacted TSs and TRs: 23.554
- 1414: ; 4/6/22: 0%->30; 12/9/22: 30%->55; 11/12/22: 55%->70; 17/3/23: 70%->80; 8/6/23: 80%->100 / Impacted TSs and TRs: 23.554
- 1415: ; 6/6/23: Compl:0%->15% / Impacted TSs and TRs: 24.538; 24.544; 24.546; 29.538; 29.222
- 1416: 9/6/23: 0%->80 / Impacted TSs and TRs: 24.538; 24.544; 24.546; 29.538; 29.222
- 1417: ; 8/6/23: 0%->100 / Impacted TSs and TRs: 33.501
- 1418: Impacted TSs and TRs: 22.261; 22.104
- 1419: 28/7/20: 22.878 added;; 12/9/20: 0%->10; 5/12/20: 10%->75; 19/3/21: FCD:16/12/2020->03/21; 19/3/21: 75%->97; 11/6/21: 97%->100 / Impacted TSs and TRs: 22.878
- 1420: 21/1/22: 23.700-25 added;; 12/3/22: 0%->25; 4/6/22: 25%->65; 12/9/22: 65%->83; 12/9/22: FCD:12/09/2022->12/22; 10/12/22: 83%->98; 15/3/23: 98%->100 / Impacted TSs and TRs: 23.700-25
- 1421: ; 11/6/21: 0%->100 / Impacted TSs and TRs: 22.261; 22.104
- 1422: ; 10/12/22: 0%->50; 9/1/23: WID:SP-220814->SP-221341; 15/3/23: 50%->80; 15/3/23: WID:SP-221341->SP-230107; 8/6/23: 80%->100 / Impacted TSs and TRs: 23.501; 23.502; 23.503
- 1423: ; 6/6/23: Compl:70%->95%; 6/6/23: WID: CP-223205->CP-231198; 30/6/23: WID:CP-231198->CP-231360 / Impacted TSs and TRs: 24.501; 29.122; 29.507; 29.512; 29.513; 29.514; 29.522; 29.534; 29.565; 29.503; 29.504; 29.505; 29.518; 29.571; 29.244.24.539
- 1424: ; 6/6/23: Compl:25%->75%; 6/6/23: WID: CP-223205->CP-231198 / Impacted TSs and TRs: 24.501; 29.122; 29.507; 29.512; 29.513; 29.514; 29.522; 29.534; 29.565; 29.503; 29.504; 29.505; 29.518; 29.571; 29.244.24.539
- 1425: ; 6/6/23: Compl:40%->55%; 6/6/23: WID: CP-223205->CP-231198; 30/6/23: 29.585 added; / Impacted TSs and TRs: 24.501; 29.122; 29.507; 29.512; 29.513; 29.514; 29.522; 29.534; 29.565; 29.503; 29.504; 29.505; 29.518; 29.571; 29.244; 29.585
- 1426: 5/4/22: 28.832 added;; 4/6/22: 0%->15; 12/9/22: 15%->40; 12/9/22: FCD:12/09/2022->03/23; 11/12/22: 40%->60; 17/3/23: 60%->62; 17/3/23: FCD:03/03/2023->/23; 8/6/23: 62%->100; 30/6/23: WID:SP-220146->SP-230772 / Impacted TSs and TRs: 28.832
- 1427: ; 22/3/22: CD:12/09/2022->12/09/2023; 22/3/22: Stat Rep: ->RP-2205556/6/22: CD:12/09/2023->22/09/20226/6/22: Stat Rep: RP-220555->RP-221439; 20/6/22: Rapporteur: NTT DOCOMO->Masato Taniguchi, NTT DOCOMO, INC.; Rap eMail: ->masato.taniguchi.mf@nttdocomo...; 23/9/22: 38.879 added; / Impacted TSs and TRs: 38.879
- 1428: 2/1/24: WID:RP-230754->RP-232863
- 1429: ; ...; 6/9/23: Compl:25%->60%; WID: RP-230754->RP-231106; Stat Rep: ->RP-231581; Rapporteur: Nokia->Sean Kelley, Nokia; Rap eMail: ->sean.kelley@nokia.com; ; 8/12/23: Compl:60%->100%; Stat Rep: RP-231581->RP-232864;
- 1430: Impacted TSs and TRs: 22.261
- 1431: 5/12/20: 0%->35; 19/3/21: FCD:11/06/2021->09/21; 19/3/21: 35%->60; 11/6/21: 60%->85; 13/9/21: 85%->100 / Impacted TSs and TRs: 22.839
- 1432: ; 13/9/21: 0%->95; 14/12/21: 95%->100 / Impacted TSs and TRs: 22.261
- 1433: ; 10/12/22: 0%->20; 15/3/23: WID:SP-221328->SP-230105; 15/3/23: 20%->40; 8/6/23: 40%->100; 4/1/24: 28.875 added; / Impacted TSs and TRs: 23.501; 23.502; 23.503; 23.273 ; 28.875
- 1434: ; 6/6/23: Compl:0%->20% / Impacted TSs and TRs: 23.122.23.041.24.501.24.526.27.007.29.513.29.519.29.522.29.525.23.008.29.503.29.505.29.510.29.515.29.518.29.571.29.572
- 1435: ; 6/6/23: Compl:0%->25% / Impacted TSs and TRs: 23.122.23.041.24.501.24.526.27.007.29.513.29.519.29.522.29.525.23.008.29.503.29.505.29.510.29.515.29.518.29.571.29.572
- 1436: 21/1/22: 23.700-05 added;; 12/3/22: 0%->20; 4/6/22: 20%->55; 12/9/22: 55%->80; 12/9/22: FCD:12/09/2022->12/22; 10/12/22: 80%->100 / Impacted TSs and TRs: 23.700-05

| ID | WBS | Task | Duration | Start | Finish | Complete | Remaining | Total slack | Constraint | Resources | Work | Actual work | Acronym | PCG approved | WI rapporteur name | Release | TSG approved | WI rapporteur e-mail | Status Report |
| --- | --- | --- | --- | --- | --- | --- | --- | --- | --- | --- | --- | --- | --- | --- | --- | --- | --- | --- | --- |
| 1437 | 652 | **Mobile IAB (Integrated Access and Backhaul) for NR** | 938.88d | 2021-12-13 A | 2024-06-06 A | 100% |  |  |  |  | 9384h | 9384h | NR_mobile_IAB | 48 | Qualcomm | Rel-18 | 94 |  |  |
| 1438 | 652.1 | Core part: Mobile IAB (Integrated Access and Backhaul) for NR | 523d | 2021-12-13 A | 2023-12-12 A | 100% |  |  | finish no earlier than 2023-12-12 | R3 | 4184h | 4184h | NR_mobile_IAB-Core | 48 | Georg Hampel, Qualcomm Incorporated | Rel-18 | 94 | ghampel@qti.qualcomm.com | RP-241123 |
| 1439 | 652.2 | Perf. part: Mobile IAB (Integrated Access and Backhaul) for NR | 650d | 2021-12-15 A | 2024-06-06 A | 100% |  |  | finish no earlier than 2024-06-06 | R3 | 5200h | 5200h | NR_mobile_IAB-Perf | 48 | Georg Hampel, Qualcomm Incorporated | Rel-18 | 94 | ghampel@qti.qualcomm.com | RP-241123 |
| 1440 | 653 | **Enhancement on NR QoE management and optimizations for diverse services** | 755.88d | 2021-12-13 A | 2023-12-12 A | 100% |  |  |  |  | 4184h | 4184h | NR_QoE_enh | 48 | China Unicom | Rel-18 | 94 |  |  |
| 1441 | 653.1 | Core part: Enhancement on NR QoE management and optimizations for diverse services | 523d | 2021-12-13 A | 2023-12-12 A | 100% |  |  | finish no earlier than 2023-12-12 | R3 | 4184h | 4184h | NR_QoE_enh-Core | 48 | Pei Li, China Unicom | Rel-18 | 94 | lip104@chinaunicom.cn | RP-233603 |
| 1442 | 654 | Study on Key Quality Indicators (KQIs) for 5G service experience | 582d | 2021-12-13 A | 2024-03-03 A | 100% |  |  | finish no earlier than 2024-03-03 | S5 | 4656h | 4656h | FS_KQI_5G | 48 | Man WANG, Huawei | Rel-18 | 94 | wangman1@huawei.com |  |
| 1443 | 655 | Additional NRM features phase 2 | 519d | 2022-03-10 A | 2024-03-03 A | 100% |  |  | finish no earlier than 2024-03-03 | S5 | 4152h | 4152h | AdNRM_ph2 | 48 | Sean Sun, Nokia | Rel-18 | 95 | sean.sun@nokia-sbell.com |  |
| 1444 | 656 | **MPS when access to EPC/5GC is WLAN** | 1693.88d | 2021-09-10 A | 2026-03-03 | 95% | 86.87d | 37744.2d |  |  | 10510h | 8264h | MPS_WLAN | 48 | Singh, Ray; Peraton Labs | Rel-18 | 94 | rsingh@peratonlabs.com |  |
| 1445 | 656.1 | Stage 1 of MPS_WLAN | 66d | 2021-09-10 A | 2021-12-10 A | 100% |  |  | finish no earlier than 2021-12-12 | S1 | 528h | 528h | MPS_WLAN | 47 | Singh, Ray; Peraton Labs | Rel-18 | 93 | rsingh@peratonlabs.com |  |
| 1446 | 656.2 | Stage 2 of MPS_WLAN | 382d | 2021-12-20 A | 2023-06-06 A | 100% |  |  | finish no earlier than 2023-06-06 | S2 | 3056h | 3056h | MPS_WLAN | 48 | Robert C Streijl; Peraton Labs | Rel-18 | 94 | rstreijl@peratonlabs.com |  |
| 1447 | 656.3 | CT1 aspects of MPS_WLAN | 195d | 2023-06-07 A | 2024-03-03 A | 100% |  |  | finish no earlier than 2024-03-03 | C1 | 1560h | 1560h | MPS_WLAN | 51 | Monnes, Peter, Peraton Labs | Rel-18 | 100 | pmonnes@peratonlabs.com |  |
| 1448 | 656.4 | CT4 aspects of MPS_WLAN | 195d | 2023-06-07 A | 2024-03-03 A | 100% |  |  | finish no earlier than 2024-03-03 | C4 | 1560h | 1560h | MPS_WLAN | 51 | Monnes, Peter, Peraton Labs | Rel-18 | 100 | pmonnes@peratonlabs.com |  |
| 1449 | 656.5 | CT6 aspects of MPS_WLAN | 195d | 2023-06-07 A | 2024-03-03 A | 100% |  |  | finish no earlier than 2024-03-03 | C6 | 1560h | 1560h | MPS_WLAN | 51 | Monnes, Peter, Peraton Labs | Rel-18 | 100 | pmonnes@peratonlabs.com |  |
| 1450 | 656.6 | UE Conformance - MPS when access to EPC/5GC is WLAN | 280.75d | 2025-06-06 A | 2026-03-03 | 76% | 67.38d | 37744.2d | finish no earlier than 2026-03-03 | R5 | 2246h |  | MPS_WLAN-UEConTest | 55 | China Telecom | Rel-18 | 108 |  | RP-253384 |
| 1451 | 657 | **Further enhancement of data collection for SON (Self-Organising Networks)/MDT (Minimization of Drive Tests) in NR and EN-DC** | 1114.25d | 2021-01-01 A | 2023-12-12 A | 100% |  |  |  |  | 9360h | 9360h | NR_ENDC_SON_MDT_enh2 | 48 | CMCC | Rel-18 | 94 |  |  |
| 1452 | 657.1 | Core part: Further enhancement of data collection for SON (Self-Organising Networks)/MDT (Minimization of Drive Tests) in NR and EN-DC | 770d | 2021-01-01 A | 2023-12-12 A | 100% |  |  | finish no earlier than 2023-12-12 | R3 | 6160h | 6160h | NR_ENDC_SON_MDT_enh2-Core | 48 | Liang LIU, CMCC | Rel-18 | 94 | liuliang@chinamobile.com | RP-233437 |
| 1453 | 657.2 | UE Conformance - Enhancement of data collection for SON (Self-Organising Networks)/MDT (Minimization of Drive Tests) in NR standalone and MR-DC (Multi-Radio Dual Connectivity) | 400d | 2022-03-15 A | 2023-09-22 A | 100% |  |  | finish no earlier than 2023-09-22 | R5 | 3200h | 3200h | NR_ENDC_SON_MDT_enh-UEConTest | 48 | Danni Song, CMCC | Rel-17 | 95 | songdan@chinamobile.com | RP-232241 |
| 1454 | 658 | Self-Configuration of RAN Network Entities | 584d | 2021-12-10 A | 2024-03-03 A | 100% |  |  | finish no earlier than 2024-03-03 | S5 | 4672h | 4672h | RANSC | 48 | Hu, Yaxi, China Mobile | Rel-18 | 94 | huyaxi@cmdi.chinamobile.com |  |
| 1455 | 659 | Support for Service Function Chaining | 71d | 2020-12-04 A | 2021-03-12 A | 100% |  |  | finish no earlier than 2021-03-12 | S1 | 568h | 568h | SFChain | 46 | Ellen Liao; Intel | Rel-18 | 90 | ellen.c.liao at intel.com |  |
| 1456 | 660 | Data Integrity in 5GS | 6d | 2021-03-18 A | 2021-03-25 A | 100% |  |  | finish no earlier than 2021-03-25 | S1 | 48h | 48h | DI_5G | 46 | Qun wei, China Unicom | Rel-18 | 91 | Weiqun5 <at> chinaunicom.cn |  |
| 1457 | 661 | **Signal level Enhanced Network Selection** | 551.88d | 2022-09-16 A | 2024-03-01 A | 100% |  |  |  | S1 | 5056h | 5056h | SENSE | 47 | Bischinger, Kurt; Deutsche Telekom | Rel-18 | 92 | kurt.bischinger@magenta.at |  |
| 1458 | 661.1 | CT1 aspects of SENSE | 123d | 2022-12-16 A | 2023-06-06 A | 100% |  |  | finish no earlier than 2023-06-06 | C1 | 984h | 984h | SENSE | 49 | Reinhard Lauster, Deutsche Telekom | Rel-18 | 97 | reinhard.lauster@magenta.at |  |
| 1459 | 661.2 | CT6 aspects of SENSE | 1d | 2022-09-16 A | 2022-09-16 A | 100% |  |  | finish no earlier than 2022-09-16 | C6 | 8h | 8h | SENSE | 49 | Reinhard Lauster, Deutsche Telekom | Rel-18 | 97 | reinhard.lauster@magenta.at |  |
| 1460 | 661.3 | UE Conformance - Signal level Enhanced Network Selection | 126d | 2023-09-09 A | 2024-03-01 A | 100% |  |  | finish no earlier than 2024-03-01 | R5 | 1008h | 1008h | SENSE-UEContest | 51 | Ya Zhao, Huawei Technologies. Co., Ltd | Rel-18 | 101 | zhaoya@hisilicon.com | RP-240288 |
| 1461 | 662 | SECAM and SCAS for 3GPP virtualized network products | 322d | 2021-12-10 A | 2023-03-03 A | 100% |  |  | finish no earlier than 2023-03-03 | S3 | 2576h | 2576h | VNP_SECAM_SCAS | 48 | Qi Minpeng, China Mobile | Rel-18 | 94 | qiminpeng@chinamobile.com |  |
| 1462 | 663 | Security Assurance Specification (SCAS) for 5G Rel-17 Features | 198d | 2022-03-10 A | 2022-12-12 A | 100% |  |  | finish no earlier than 2022-12-12 | S3 | 1584h | 1584h | SCAS_5G_Ph2 | 48 | Rong Wu, Huawei Technologies Co., Ltd. | Rel-18 | 95 | Raina.wu@huawei.com |  |
| 1463 | 664 | Study on URSP rules to securely identify applications | 197d | 2022-06-02 A | 2023-03-03 A | 100% |  |  | finish no earlier than 2023-03-03 | S3 | 1576h | 1576h | FS_USIA | 49 | Andreas Kunz, Lenovo | Rel-18 | 96 | akunz@lenovo.com |  |
| 1464 | 665 | Study on 5G security enhancement against false base stations | 1113d? | 2018-09-06 A | 2022-12-09 A | 100% |  |  | finish no earlier than 2022-12-12 | S3 | 8904h | 8904h | FS_5GFBS | 41 | Ivy Guo, Apple | Rel-18 | 81 | ivy_guo@apple.com |  |
| 1465 | 666 | Security Enhancement on RRCResumeRequest Message Protection | 138d | 2022-06-02 A | 2022-12-12 A | 100% |  |  | finish no earlier than 2022-12-12 | S3 | 1104h | 1104h | SERP | 49 | Ivy Guo, Apple | Rel-18 | 96 | <ivy_guo@apple.com> |  |

Notes:
- 1437: compare REL-16 WI NR_IAB and REL-17 WI NR_IAB_enh; no Perf. part; 5/4/22: WID:RP-213601->RP-220843; 12/7/22: WID:RP-220843->RP-221815; 23/9/22: WID:RP-221815->RP-222671; 6/10/23: WID:RP-222671->RP-232643; 2/1/24: WID:RP-232643->RP-233320; 2/4/24: WID:RP-233320->RP-240104
- 1438: compare REL-16 WI NR_IAB and REL-17 WI NR_IAB_enh;; 22/3/22: Stat Rep: ->RP-220430 6/6/22: CD:12/12/2023->23/12/2022 6/6/22: Stat Rep: RP- ; 20/6/22: Rapporteur: Qualcomm->Georg Hampel, Qualcomm Incorporated; Rap eMail: ->ghampel@qti.qualcomm.com13...;...; 13/6/24: WID: RP-240104->RP-240319; Stat Rep: RP-240103->RP-241123;
- 1439: ; 22/3/22: CD:24/06/2024->12/06/2024; 22/3/22: Stat Rep: ->RP-220430 ; 6/6/22: CD:12/06/2024->24/06/2022 ; 6/6/22: Stat Rep: RP-220430->RP ; 20/6/22: WG: R4->R3; Rapporteur: Qualcomm->Georg Hampel, Qualcomm Incorporated; Rap eMail: ->ghampel@qti.qualco...; 13/6/24: Compl:60%->100%; WID: RP-240104->RP-240319; Stat Rep: RP-240103->RP-241123;
- 1440: compare REL-17 WI NR_QoE-Core; QoE = Quality of Experience; no Perf. part; 12/7/22: WID:RP-213594->RP-221803; 9/1/23: WID:RP-221803->RP-223488
- 1441: compare REL-17 WI NR_QoE-Core; QoE = Quality of Experience; no Perf. part; 20/6/22: FCD:12/12/2023->23/12/2022; Stat Rep: ->RP-221244; Rapporteur: China Unicom->Pei Li, China Unicom; Rap eMail: ->lip104@chinaunicom.cn13/7/22: FCD:23/12/2022->12/20;...;...; 8/12/23: Compl:70%->100%; Stat Rep: RP-232394->RP-233603;
- 1442: 7/1/22: 28.863 added;; 4/6/22: 0%->10; 12/9/22: 10%->20; 11/12/22: FCD:12/12/2022->/23; 17/3/23: 20%->35; 17/3/23: FCD:03/03/2023->/23; 8/6/23: 35%->; 8/6/23: FCD:06/06/2023->/24; 7/9/23: 35%->65; 8/12/23: 65%->100; 3/1/24: WID:SP-211433->SP-231432 / Impacted TSs and TRs: 28.863
- 1443: 4/6/22: 0%->7; 12/9/22: 7%->30; 12/9/22: FCD:11/03/2022->03/23; 11/12/22: 30%->55; 17/3/23: 55%->65; 8/6/23: 65%->80; 8/6/23: FCD:03/03/2023->/24; 8/6/23: 80%->; 7/9/23: 80%->88; 8/12/23: 88%->99; 3/1/24: WID:SP-220351->SP-231440; 14/3/24: 99%->100
- 1445: 10/12/21: 0%->100 / Impacted TSs and TRs: 22.153
- 1446: ; 10/12/22: 0%->0; 10/12/22: FCD:12/09/2022->03/23; 15/3/23: 0%->50; 15/3/23: WID:SP-211595->SP-230108; 15/3/23: FCD:03/03/2023->/23; 8/6/23: 50%->100 / Impacted TSs and TRs: 23.401; 23.402; 23.501; 23.502
- 1447: Impacted TSs and TRs: 23.003; 24.302; 24.502; 29.273
- 1448: Impacted TSs and TRs: 23.003; 24.302; 24.502; 29.273
- 1449: Impacted TSs and TRs: 23.003; 24.302; 24.502; 29.273
- 1450: MPS = Multimedia Priority Service; tested: CT1 REL-18 WI MPS_WLAN ; 11/9/25: Compl:0%->5%; Stat Rep: ->RP-252013; ; 3/12/25: Compl:5%->76%; Stat Rep: RP-252013->RP-253384;
- 1451: compare REL-16 WI NR_SON_MDT-Core and REL-17 WI NR_ENDC_SON_MDT_enh-Core; no Perf. part; 5/4/22: WID:RP-213553->RP-221000; 12/7/22: WID:RP-221000->RP-221825; 2/1/24: WID:RP-221825->RP-233438
- 1452: compare REL-16 WI NR_SON_MDT-Core and REL-17 WI NR_ENDC_SON_MDT_enh-Core; no Perf. part; 20/6/22: FCD:31/12/2021->23/12/2022; Stat Rep: ->RP-221372; Rapporteur: CMCC->Liang LIU, CMCC; Rap eMail: ->liuliang@chinamobile.com13/7/22: FCD:23/12/2022->12...;...; 8/12/23: Compl:80%->100%; Stat Rep: RP-232234->RP-233437;
- 1453: tested: REL-17 WI NR_ENDC_SON_MDT_enh 6/6/22: Compl:0%->5% 6/6/22: CD:15/06/2 ; 20/6/22: Rapporteur: CMCC->Luting Kong, CMCC; Rap eMail: ->kongluting@chinamobile.com12/7/22: WID:RP-220620->RP-221365 ...; 9/12/22: FCD:23/06/2023->01/06/2023; Compl:7%-...; 6/10/23: WID:RP-223069->RP-232426
- 1454: ; 7/1/22: 28.317 added;; 4/6/22: 0%->5; 11/12/22: 5%->45; 17/3/23: 45%->50; 17/3/23: FCD:06/06/2023->12/23; 8/6/23: 50%->55; 8/6/23: 55%->55; 7/9/23: 55%->65; 8/12/23: 65%->90; 8/12/23: FCD:12/12/2023->/2024; 14/3/24: 90%->100 / Impacted TSs and TRs: 28.313; ; 28.317
- 1455: 22.261; 22.101; 22.115 ; 5/12/20: 0%->100
- 1456: ; 19/3/21: 0%->100 / Impacted TSs and TRs: 22.261
- 1457: ; 11/6/21: 0%->40; 10/12/21: 40%->100 / Impacted TSs and TRs: 22.011
- 1458: ; 6/6/23: Compl:65%->95%; 6/6/23: CD:16/12/2022->06/06/2023 / Impacted TSs and TRs: 23.122; 24.501; 27.007
- 1459: Impacted TSs and TRs: 31.102
- 1460: 8/12/23: Compl:0%->5%; Stat Rep: ->RP-233769; Rapporteur: Huawei->Ya Zhao, Huawei Technologies. Co., Ltd; Rap eMail: ->zhaoya@hisilicon.com; ; 2/1/24: WID:RP-232362->RP-233770; 14/3/24: FCD:05/06/2024->01/03/2024; Compl:5%->100%; Stat Rep: RP-233769->RP-240288;
- 1461: 7/1/22: 33.527 added;; 12/9/22: 0%->40; 11/12/22: 40%->65; 17/3/23: 65%->75; 15/3/24: 75%->100 / Impacted TSs and TRs: 33.527; 33.927; 33.936
- 1462: ; 4/6/22: 0%->10; 17/3/23: 10%->30; 15/3/24: 30%->100 / Impacted TSs and TRs: 33.926; 33.117; 33.511; 33.512; 33.513; 33.514; 33.515; 33.516; 33.517; 33.518; 33.519; 33.520; 33.521; 33.522; 33.326
- 1463: 13/7/22: 33.892 added;; 12/9/22: 0%->30; 11/12/22: 30%->50; 17/3/23: 50%->80; 7/9/23: 80%->100 / Impacted TSs and TRs: 33.892
- 1464: 7/12/18: 0%->10¦20/3/19: FCD:019->09/19¦20/3/19: 10%->50; 31/5/19: 50%->65; 13/9/19: 65%->66; 13/9/19: FCD:12/09/2019->12/20; 6/12/19: 66%->75; 6/12/19: FCD:12/12/2019->03/20; 25/03/20: Rel-16->Rel-17; 26/6/20: 75%->80; 26/6/20: FCD:12/03/2020->12/20; ; 8/6/23: 90%->100 / Impacted TSs and TRs: New
- 1465: 7/9/23: 0%->100

| ID | WBS | Task | Type | Duration | Start | Finish | Complete | Constraint | Resources | Work | Actual work | Acronym | PCG approved | WI rapporteur name | WI rapporteur e-mail | Release | TSG approved |
| --- | --- | --- | --- | --- | --- | --- | --- | --- | --- | --- | --- | --- | --- | --- | --- | --- | --- |
| 1466 | 667 | **Stage-3 5GS NAS protocol development 18** |  | 577.88d | 2022-06-03 A | 2023-12-12 A | 100% |  |  | 6384h | 6384h | 5GProtoc18 | 49 | Sedlacek, Ivo, Ericsson, | ivo <dot> sedlacek <at> ericsson <dot> com | Rel-18 | 96 |
| 1467 | 667.1 | Stage-3 5GS NAS protocol development 18 general aspects |  | 399d | 2022-06-03 A | 2023-12-12 A | 100% | finish no earlier than 2023-12-12 | C1 | 3192h | 3192h | 5GProtoc18 | 49 | Sedlacek, Ivo, Ericsson, | ivo <dot> sedlacek <at> ericsson <dot> com | Rel-18 | 96 |
| 1468 | 667.2 | Stage-3 5GS NAS protocol development 18 non 3GPP aspects |  | 399d | 2022-06-03 A | 2023-12-12 A | 100% | finish no earlier than 2023-12-12 | C1 | 3192h | 3192h | 5GProtoc18-non3GPP | 49 | Sedlacek, Ivo, Ericsson, | ivo <dot> sedlacek <at> ericsson <dot> com | Rel-18 | 96 |
| 1469 | 668 | **Stage-3 SAE Protocol Development** |  | 577.88d | 2022-06-03 A | 2023-12-12 A | 100% |  |  | 9576h | 9576h | SAES18 | 49 | Sethi, Anuj, InterDigital |  | Rel-18 | 96 |
| 1470 | 668.1 | Stage-3 SAE Protocol Development general |  | 399d | 2022-06-03 A | 2023-12-12 A | 100% | finish no earlier than 2023-12-12 | C1 | 3192h | 3192h | SAES18 | 49 | Sethi, Anuj, InterDigital |  | Rel-18 | 96 |
| 1471 | 668.2 | Stage-3 SAE Protocol Development CSFB |  | 399d | 2022-06-03 A | 2023-12-12 A | 100% | finish no earlier than 2023-12-12 | C1 | 3192h | 3192h | SAES18-CSFB | 49 | Sethi, Anuj, InterDigital |  | Rel-18 | 96 |
| 1472 | 668.3 | Stage-3 SAE Protocol Development non 3GPP |  | 399d | 2022-06-03 A | 2023-12-12 A | 100% | finish no earlier than 2023-12-12 | C1 | 3192h | 3192h | SAES18-non3GPP | 49 | Sethi, Anuj, InterDigital |  | Rel-18 | 96 |
| 1473 | 669 | **Protocol enhancements for Mission Critical Services** |  | 662.75d | 2022-06-03 A | 2024-03-03 A | 100% |  |  | 10984h | 10984h | MCProtoc18 | 49 | AXELL, Jörgen, Ericsson | jorgen.axell@ericsson.com | Rel-18 | 96 |
| 1474 | 669.1 | CT1 aspects of MCProtoc18 |  | 458d | 2022-06-03 A | 2024-03-03 A | 100% | finish no earlier than 2024-03-03 | C1 | 3664h | 3664h | MCProtoc18 | 49 | Magnus Tränk, Ericsson | magnus.trank@ericsson.com | Rel-18 | 96 |
| 1475 | 669.2 | CT3 aspects of MCProtoc18 |  | 457d | 2022-06-06 A | 2024-03-03 A | 100% | finish no earlier than 2024-03-03 | C3 | 3656h | 3656h | MCProtoc18 | 49 | Magnus Tränk, Ericsson | magnus.trank@ericsson.com | Rel-18 | 96 |
| 1476 | 669.3 | CT4 aspects of MCProtoc18 |  | 458d | 2022-06-03 A | 2024-03-03 A | 100% | finish no earlier than 2024-03-03 | C4 | 3664h | 3664h | MCProtoc18 | 49 | Magnus Tränk, Ericsson | magnus.trank@ericsson.com | Rel-18 | 96 |
| 1477 | 670 | MPS for Supplementary Services |  | 135d | 2022-06-03 A | 2022-12-08 A | 100% | finish no earlier than 2022-12-08 | C1 | 1080h | 1080h | MPSSupServ | 49 | Peter Monnes, Peraton Labs | pmonnes@peratonlabs.com | Rel-18 | 96 |
| 1478 | 671 | **IMS Stage-3 IETF Protocol Alignment** |  | 577.88d | 2022-06-03 A | 2023-12-12 A | 100% |  |  | 6384h | 6384h | IMSProtoc18 | 49 | Won, Sung Hwan, Nokia | sung(dot)won(at)nokia(dot)com | Rel-18 | 96 |
| 1479 | 671.1 | CT1 aspects of IMSProtoc18 |  | 399d | 2022-06-03 A | 2023-12-12 A | 100% | finish no earlier than 2023-12-12 | C1 | 3192h | 3192h | IMSProtoc18 | 49 | Won, Sung Hwan, Nokia | sung(dot)won(at)nokia(dot)com | Rel-18 | 97 |
| 1480 | 671.2 | CT3 aspects of IMSProtoc18 |  | 399d | 2022-06-03 A | 2023-12-12 A | 100% | finish no earlier than 2023-12-12 | C3 | 3192h | 3192h | IMSProtoc18 | 49 | Won, Sung Hwan, Nokia | sung(dot)won(at)nokia(dot)com | Rel-18 | 97 |
| 1481 | 672 | Enhancement of Shared Data ID and Handling |  | 753.75d | 2022-03-07 A | 2024-03-03 A | 100% | finish no earlier than 2024-03-03 | C4 | 4176h | 4176h | ShDatID_H | 49 | Jing, Hao, Huawei | hao.jing@huawei.com | Rel-18 | 96 |
| 1482 | 673 | UE conformance test for NB-IoT/eMTC Non-Terrestrial Networks in EPS |  | 378.88d | 2024-09-09 A | 2025-09-09 A | 100% | finish no earlier than 2025-09-09 | C6 | 834.4h | 834.4h | IoT_SAT_UEConTest | 49 | Daiwei Zhou, MediaTek Inc | daiwei.zhou@mediatek.com | Rel-18 | 96 |
| 1483 | 674 | Test method of GBA_U Based APIs |  | 280.38d | 2024-09-09 A | 2025-06-06 A | 100% | finish no earlier than 2025-06-06 | C6 | 627.2h | 627.2h | TEST_GBA_U_APIs | 49 | Huo Weijing(China Mobile) | huoweijing@chinamobile.com | Rel-18 | 96 |
| 1484 | 675 | Rel-18 enhancements of session management policy control |  | 375.88d | 2022-12-15 A | 2023-12-12 A | 100% | start no earlier than 2022-12-15 | C3 | 2080h | 2080h | SMPC18 | 49 | Xiaoyun Zhou, Huawei | zhouxiaoyun8@huawei.com | Rel-18 | 96 |
| 1485 | 676 | Deleted - SMS over IMS to emergency centre |  | 7d | 2022-06-02 A | 2022-06-08 A | 100% | finish no earlier than 2022-06-12 | S1 | 56h | 56h | SMS2ECdeleted | 49 | Bruno Tossou, Orange | bruno.tossou@orange.com | Rel-18 | 96 |
| 1486 | 677 | Enhancements on Service-based support for SMS in 5GC |  | 287.62d | 2023-03-13 A | 2023-12-15 A | 100% | finish no earlier than 2023-12-15 | C4 | 1584h | 1584h | eSMS_SBI | 49 | Liu, Liu, China Telecom | liuliu66@chinatelecom.cn | Rel-18 | 96 |
| 1487 | 678 | **Modified PRINS for roaming service providers in 5G** |  | 34d | 2023-08-08 A | 2023-09-09 A | 100% |  | S1 | 600h | 600h | Roaming5G | 51 | Targali, Yousif, Verizon | yousif.targali@verizon.com | Rel-18 | 101 |
| 1488 | 678.1 | Stage 1 of Roaming5G |  | 25d | 2023-08-08 A | 2023-09-09 A | 100% | start no earlier than 2023-08-08 | S1 | 200h | 200h | Roaming5G | 51 | Targali, Yousif, Verizon | yousif.targali@verizon.com | Rel-18 | 101 |
| 1489 | 678.2 | Stage 3 of Roaming5G |  | 25d | 2023-08-08 A | 2023-09-09 A | 100% | start no earlier than 2023-08-08 | S3 | 200h | 200h | Roaming5G | 51 | Targali, Yousif, Verizon | yousif.targali@verizon.com | Rel-18 | 101 |
| 1490 | 679 | NRF API enhancements to avoid signalling and storing of redundant data |  | 98d | 2023-12-12 A | 2024-03-15 A | 100% | finish no earlier than 2024-03-15 | C4 | 560h | 560h | NRFe | 49 | Wiehe, Ulrich, Nokia | ulrich.wiehe@nokia.com | Rel-18 | 96 |
| 1491 | 680 | Rel-18 Other Security aspects | milestone | 0d? | 2016-03-15 A | 2016-03-15 A | 100% | start no earlier than 2016-03-15 |  |  |  |  |  |  |  | Rel-18 |  |
| 1492 | 681 | Security Assurance Specification for AKMA Anchor Function Function (AAnF) |  | 257d | 2022-03-10 A | 2023-03-03 A | 100% | finish no earlier than 2023-03-03 | S3 | 2056h | 2056h | SCAS_5G_AAnF | 48 | Xiaoting Huang, China Mobile | huangxiaoting@chinamobile.com | Rel-18 | 95 |
| 1493 | 682 | 5G Security Assurance Specification (SCAS) for the Policy Control Function (PCF) |  | 195d | 2023-03-16 A | 2023-12-12 A | 100% | finish no earlier than 2023-12-12 | S3 | 1560h | 1560h | SCAS_5G_PCF | 50 | Andreas, Joerg, BSI Germany | joerg.andreas@bsi.bund.de | Rel-18 | 99 |
| 1494 | 683 | IETF DTLS protocol profile for AKMA and GBA |  | 128d | 2022-12-09 A | 2023-06-06 A | 100% | finish no earlier than 2023-06-06 | S3 | 1024h | 1024h | AKMA_GBA_DTLS | 50 | Liu, yuze, ZTE | liu.yuze@zte.com.cn | Rel-18 | 98 |
| 1495 | 684 | IETF OSCORE protocol profiles for GBA and AKMA |  | 197d | 2022-12-09 A | 2023-09-09 A | 100% | finish no earlier than 2023-09-09 | S3 | 1576h | 1576h | AKMA_GBA_OSCORE | 50 | Tsiatsis, Vlasios, Ericsson | vlasios.tsiatsis@ericsson.com | Rel-18 | 98 |
| 1496 | 685 | SCAS for split-gNB product classes |  | 257d | 2022-03-10 A | 2023-03-03 A | 100% | finish no earlier than 2023-03-03 | S3 | 2056h | 2056h | SCAS_5G_split_gNB | 48 | Escott, Adrian, Qualcomm Incorporated | aescott@qti.qualcomm.com | Rel-18 | 95 |

Notes:
- 1466: ; 6/6/23: Compl:30%->40% / Impacted TSs and TRs: 23.040; 23.041; 23.122; 24.007; 24.008; 24.011; 24.173; 24.229; 24.301; 24.302; 24.305; 24.341; 24.368; 24.501; 24.502; 24.526; 27.007
- 1467: Impacted TSs and TRs: 23.040; 23.041; 23.122; 24.007; 24.008; 24.011; 24.173; 24.229; 24.301; 24.302; 24.305; 24.341; 24.368; 24.501; 24.502; 24.526; 27.007
- 1468: Impacted TSs and TRs: 23.040; 23.041; 23.122; 24.007; 24.008; 24.011; 24.173; 24.229; 24.301; 24.302; 24.305; 24.341; 24.368; 24.501; 24.502; 24.526; 27.007
- 1469: ; 6/6/23: Compl:30%->40% / Impacted TSs and TRs: 23.122; 24.008; 24.167; 24.229; 24.301; 24.302; 24.303; 24.304; 24.305; 24.312; 29.018; 29.118; 24.368
- 1470: Impacted TSs and TRs: 23.122; 24.008; 24.167; 24.229; 24.301; 24.302; 24.303; 24.304; 24.305; 24.312; 29.018; 29.118; 24.368
- 1471: Impacted TSs and TRs: 23.122; 24.008; 24.167; 24.229; 24.301; 24.302; 24.303; 24.304; 24.305; 24.312; 29.018; 29.118; 24.368
- 1472: Impacted TSs and TRs: 23.122; 24.008; 24.167; 24.229; 24.301; 24.302; 24.303; 24.304; 24.305; 24.312; 29.018; 29.118; 24.368
- 1473: ; 20/6/22: FCD:12/12/2023->08/12/2023Rapporteur: ->AXELL, Jörgen, EricssonRap eMail: ->jorgen.axell@ericsson.comList of Impacted TS & TR updated / Impacted TSs and TRs: 24.229; 24.281; 24.282; 24.379; 24.380; 24.481; 24.482; 24.483; 24.484; 24.581; 24.582; 29.379; 29.380; 29.582; 29.165; 29.283
- 1474: ; 20/6/22: FCD:12/12/2023->08/12/2023Rapporteur: ->AXELL, Jörgen, EricssonRap eMail: ->jorgen.axell@ericsson.comList of Impacted TS & TR updated; 9/6/23: 30%->40 / Impacted TSs and TRs: 24.229; 24.281; 24.282; 24.379; 24.380; 24.481; 24.482; 24.483; 24.484; 24.581; 24.582; 29.379; 29.380; 29.582; 29.165; 29.283
- 1475: ; 20/6/22: FCD:12/12/2023->08/12/2023Rapporteur: ->AXELL, Jörgen, EricssonRap eMail: ->jorgen.axell@ericsson.comList of Impacted TS & TR updated; 9/6/23: 10%->30 / Impacted TSs and TRs: 24.229; 24.281; 24.282; 24.379; 24.380; 24.481; 24.482; 24.483; 24.484; 24.581; 24.582; 29.379; 29.380; 29.582; 29.165; 29.283
- 1476: ; 20/6/22: FCD:12/12/2023->08/12/2023Rapporteur: ->AXELL, Jörgen, EricssonRap eMail: ->jorgen.axell@ericsson.comList of Impacted TS & TR updated; 6/6/23: Compl:... / Impacted TSs and TRs: 24.229; 24.281; 24.282; 24.379; 24.380; 24.481; 24.482; 24.483; 24.484; 24.581; 24.582; 29.379; 29.380; 29.582; 29.165; 29.283
- 1477: 20/6/22: FCD:12/12/2022->08/12/2022WID: C1-221271->CP-221271Rapporteur: Peter Monnes, Peraton Labs ->Peter Monnes, Peraton LabsRap eMail: pmonnes@peratonlabs.com ->pmonnes@peratonlabs.comList of Impacted TS & TR updated / Impacted TSs and TRs: 24.229; 24.173; 24.629; 24.605; 24.239; 24.604; 24.642
- 1478: Impacted TSs and TRs: 23.218; 24.229; 24.930; 29.163; 29.165; 29.292
- 1479: ; 6/6/23: Compl:30%->40% / Impacted TSs and TRs: 23.218; 24.229; 24.930; 29.163; 29.165; 29.292
- 1480: 9/6/23: 30%->60 / Impacted TSs and TRs: 23.218; 24.229; 24.930; 29.163; 29.165; 29.292
- 1481: ; 6/6/23: Compl:0%->40% / Impacted TSs and TRs: 29.503; 29.504; 29.505
- 1484: ; 6/6/23: Compl:25%->60% / Impacted TSs and TRs: 29.512; 29.513; 29.514
- 1485: ; 4/6/22: 0%->45; 12/9/22: 45%->100 / Impacted TSs and TRs: 22.101
- 1486: ; 6/6/23: Compl:0%->50% / Impacted TSs and TRs: 23.540; 29.338; 29.329; 29.230
- 1487: 9/23: company-submitted WID, to be corrected / Impacted TSs and TRs: 22.261; 33.501
- 1488: 9/23: company-submitted WID, to be corrected / Impacted TSs and TRs: 22.261
- 1489: 9/23: company-submitted WID, to be corrected; 8/12/23: 100%->100 / Impacted TSs and TRs: 33.501
- 1490: Impacted TSs and TRs: 29.510, 29.571, 29.504
- 1491: -
- 1492: ; 4/6/22: 0%->10; 13/7/22: 33.537 added;; 11/12/22: 10%->70; 17/3/23: 70%->90; 8/6/23: 90%->95; 15/3/24: 95%->100 / Impacted TSs and TRs: 33.926 ; 33.537
- 1493: ; 31/3/23: 33.528 added;; 7/9/23: 0%->40; 7/9/23: FCD:09/09/2023->12/23; 15/3/24: 40%->100 / Impacted TSs and TRs: 33.926 ; 33.528
- 1494: ; 8/6/23: 0%->90; 7/9/23: 90%->100 / Impacted TSs and TRs: 33.535; 33.220; 33.222
- 1495: ; 8/6/23: 0%->80; 7/9/23: FCD:06/06/2023->/23; 15/3/24: 80%->100 / Impacted TSs and TRs: 33.535; 33.220; 33.222
- 1496: ; 4/6/22: 0%->5; 13/7/22: 33.742 added;; 12/9/22: 5%->25; 11/12/22: 25%->60; 17/3/23: 60%->85; 17/3/23: 33.523 added;; 8/6/23: 85%->99; 15/3/24: 99%->100 / Impacted TSs and TRs: 33.926 ; 33.742; 33.523

| ID | WBS | Task | Type | Duration | Start | Finish | Complete | Remaining | Total slack | Constraint | Resources | Work | Actual work | Acronym | PCG approved | Impacted TSs and TRs | WI rapporteur name | WI rapporteur e-mail | Release | TSG approved | Status Report |
| --- | --- | --- | --- | --- | --- | --- | --- | --- | --- | --- | --- | --- | --- | --- | --- | --- | --- | --- | --- | --- | --- |
| 1497 | 686 | **Home network triggered primary authentication** |  | 750.75d | 2022-03-10 A | 2024-03-03 A | 100% |  |  |  | S3 | 7776h | 7776h | HN_Auth | 50 | 33.501; 33.535 | He Li, Huawei | LIHE2@HUAWEI.COM | Rel-18 | 98 |  |
| 1498 | 686.1 | Study of Security aspect of home network triggered primary authentication |  | 198d | 2022-03-10 A | 2022-12-12 A | 100% |  |  | finish no earlier than 2022-12-12 | S3 | 1584h | 1584h | FS_HN_Auth | 48 |  | He Li, Huawei | LIHE2@HUAWEI.COM | Rel-18 | 95 |  |
| 1499 | 686.2 | Security aspects of home network triggered primary authentication |  | 128d | 2022-12-09 A | 2023-06-06 A | 100% |  |  | finish no earlier than 2023-06-06 | S3 | 1024h | 1024h | HN_Auth | 50 | 33.501; 33.535 | He Li, Huawei | LIHE2@HUAWEI.COM | Rel-18 | 98 |  |
| 1500 | 686.3 | CT aspects of home network triggered primary authentication |  | 127d | 2023-09-09 A | 2024-03-03 A | 100% |  |  | finish no earlier than 2024-03-03 | C4 | 1016h | 1016h | HN_Auth | 50 | 29.503, 29.504, 29.505, 29.518 | Jing, Hao, Huawei | hao.jing@huawei.com | Rel-18 | 98 |  |
| 1501 | 687 | Study on AKMA Phase 2 |  | 198d | 2022-03-10 A | 2022-12-12 A | 100% |  |  | finish no earlier than 2022-12-12 | S3 | 1584h | 1584h | FS_AKMA_Ph2 | 48 | 33.737 | Xiaoting Huang, China Mobile | huangxiaoting@chinamobile.com | Rel-18 | 95 |  |
| 1502 | 688 | AKMA phase 2 |  | 128d | 2023-03-16 A | 2023-09-09 A | 100% |  |  | finish no earlier than 2023-09-09 | S3 | 1024h | 1024h | AKMA_Ph2 | 50 | 33.535 | Huang Xiaoting, China Mobile | huangxiaoting@chinamobile.com | Rel-18 | 99 |  |
| 1503 | 689 | Study of privacy of identifiers over radio access |  | 320d | 2021-12-13 A | 2023-03-03 A | 100% |  |  | finish no earlier than 2023-03-03 | S3 | 2560h | 2560h | FS_Id_Prvc | 48 | 33.870 | Brusilovsky, Alec, Interdigital | alec.brusilovsky@interdigital.com | Rel-18 | 94 |  |
| 1504 | 690 | Study on Security Impacts of Virtualisation |  | 1043d | 2018-12-13 A | 2022-12-09 A | 100% |  |  | finish no earlier than 2022-12-12 | S3 | 8344h | 8344h | FS_SIV | 42 |  | Alex Leadbeater, BT Plc | alex.leadbeater@bt.com | Rel-18 | 82 |  |
| 1505 | 691 | Study on Zero Trust Security principles in mobile networks |  | 197d | 2022-06-02 A | 2023-03-03 A | 100% |  |  | finish no earlier than 2023-03-03 | S3 | 1576h | 1576h | FS_ZTS | 49 | 33.894 | Sheeba Backia Mary B, Lenovo | smary@lenovo.com | Rel-18 | 96 |  |
| 1506 | 692 | Study of Security aspects on User Consent for 3GPP Services Phase 2 |  | 197d | 2022-06-02 A | 2023-03-03 A | 100% |  |  | finish no earlier than 2023-03-03 | S3 | 1576h | 1576h | FS_UC3S_Ph2 | 49 | 33.896 | Rong Wu, Huawei, | Raina.wu@huawei.com | Rel-18 | 96 |  |
| 1507 | 693 | Security aspects on User Consent for 3GPP services Phase 2 |  | 27d | 2023-05-01 A | 2023-06-06 A | 100% |  |  | start no earlier than 2023-05-01 | S3 | 216h | 216h | UC3S_SEC_Ph2 | 51 | 33.501 | Rong Wu, Huawei Technologies, | Raina.wu@huawei.com | Rel-18 | 100 |  |
| 1508 | 694 | Security Assurance Specification for 5G Phase 3 |  | 130d | 2023-09-06 A | 2024-03-03 A | 100% |  |  | finish no earlier than 2024-03-03 | S3 | 1040h | 1040h | SCAS_5G_Ph3 | 51 | 33.926 | Wu, Rong, Huawei Technologies Co., Ltd. | Raina.wu@huawei.com | Rel-18 | 101 |  |
| 1509 | 695 | Rel-18 NR-only: topics other than band | milestone | 0d? | 2019-03-07 | 2019-03-07 |  |  | 40388.9d |  |  |  |  |  |  |  |  |  | Rel-18 |  |  |
| 1510 | 696 | **NR demodulation performance evolution** |  | 1039.38d | 2022-03-15 A | 2024-12-12 | 97% | 34.69d |  |  |  | 11045h | 5776h | NR_demod_enh3 | 48 |  | China Telecom |  | Rel-18 | 95 |  |
| 1511 | 696.1 | Core part: NR demodulation performance evolution |  | 136d | 2023-06-07 A | 2023-12-12 A | 100% |  |  | finish no earlier than 2023-12-12 | R4 | 1088h | 1088h | NR_demod_enh3-Core | 51 |  | Jingzhou Wu, China Telecom | wujingzhou@chinatelecom.cn | Rel-18 | 100 | RP-233584 |
| 1512 | 696.2 | Perf. part: NR demodulation performance evolution |  | 586d | 2022-03-15 A | 2024-06-06 A | 100% |  |  | finish no earlier than 2024-06-06 | R4 | 4688h | 4688h | NR_demod_enh3-Perf | 48 | 38.878 | Jingzhou Wu, China Telecom | wujingzhou@chinatelecom.cn | Rel-18 | 95 | RP-241293 |
| 1513 | 696.3 | UE Conformance - NR demodulation performance evolution |  | 658.62d | 2024-06-06 A | 2026-03-03 | 93% | 46.1d | 37744.2d | finish no earlier than 2026-03-03 | R5 | 5269h |  | NR_demod_enh3-UEConTest | 53 |  | China Telecom |  | Rel-18 | 104 | RP-253468 |
| 1514 | 697 | **NR channel raster enhancement** |  | 1329.12d | 2023-03-06 A | 2026-09-09 | 42% | 774.75d | 37547.6d |  | R4 | 15752h | 1983.66h | NR_channel_raster_enh | 50 |  | Ericsson |  | Rel-18 | 99 |  |
| 1515 | 697.1 | Core part: NR channel raster enhancement |  | 261d | 2023-03-06 A | 2023-11-13 | 95% | 13.05d | 38615.8d | finish no earlier than 2024-03-01 | R4 | 2088h |  | NR_channel_raster_enh-Core | 50 |  | Christian Bergljung, Ericsson | Christian.Bergljung@ericsson.com | Rel-18 | 99 | RP-233392 |
| 1516 | 697.2 | UE Conformance - Channel raster enhancement |  | 378.88d | 2025-09-09 A | 2026-09-09 | 5% | 359.93d | 37547.6d | finish no earlier than 2026-09-09 | R5 | 3031h |  | NR_channel_raster_enh-UEConTest | 55 |  | China Telecom |  | Rel-18 | 109 | RP-253471 |
| 1517 | 698 | **Rel-18 4Rx for NR bands for FWA (Fixed Wireless Access) UEs (<2.6GHz) and handheld UEs (1GHz to 2.6GHz)** |  | 938.75d | 2022-12-13 A | 2025-06-06 A | 100% |  |  |  |  | 8151h | 8151h | 4Rx_NR_bands_R18 | 50 |  | ZTE |  | Rel-18 | 98 |  |
| 1518 | 698.1 | Core part: Rel-18 4Rx for NR bands for FWA (Fixed Wireless Access) UEs (<2.6GHz) and handheld UEs (1GHz to 2.6GHz) |  | 320d | 2022-12-13 A | 2024-03-01 A | 100% |  |  | finish no earlier than 2024-03-01 | R4 | 2560h | 2560h | 4Rx_NR_bands_R18-Core | 50 |  | Wubin, Zhou, ZTE | zhou.wubin@zte.com.cn | Rel-18 | 98 | RP-240252 |
| 1519 | 698.2 | Stopped - Perf. part: Rel-18 4Rx for NR bands for FWA (Fixed Wireless Access) UEs (<2.6GHz) and handheld UEs (1GHz to 2.6GHz) |  | 320d | 2022-12-13 A | 2024-03-01 A | 100% |  |  | finish no earlier than 2024-03-01 | R4 | 2560h | 2560h | 4Rx_NR_bands_R18-Perf | 50 |  | Wubin, Zhou, ZTE | zhou.wubin@zte.com.cn | Rel-18 | 98 | RP-240252 |
| 1520 | 698.3 | UE Conformance - 4Rx for NR bands for FWA (Fixed Wireless Access) UEs (<2.6GHz) and handheld UEs (1GHz to 2.6GHz) |  | 378.88d | 2024-06-06 A | 2025-06-06 A | 100% |  |  | finish no earlier than 2025-06-06 | R5 | 3031h | 3031h | 4Rx_NR_bands_R18-UEConTest | 53 |  | ZTE |  | Rel-18 | 104 | RP-250990 |

Notes:
- 1497: ; 15/3/24: 99%->100
- 1498: 4/6/22: 0%->30; 12/9/22: 30%->60; 11/12/22: 60%->80; 17/3/23: 80%->100
- 1499: ; 7/9/23: 0%->100
- 1501: 4/6/22: 0%->15; 13/7/22: 33.737 added;; 12/9/22: 15%->35; 23/9/22: WID:SP-220327->SP-220991; 11/12/22: 35%->70; 17/3/23: 70%->80; 8/6/23: 80%->95; 15/3/24: 95%->100
- 1502: ; 8/6/23: 0%->95; 15/3/24: 95%->100
- 1503: 7/1/22: 33.870 added;; 12/3/22: 0%->5; 4/6/22: 5%->10; 12/9/22: 10%->12; 17/3/23: 12%->25; 8/6/23: 25%->40; 7/9/23: 40%->80; 15/3/24: 80%->100
- 1504: 20/3/19: 0%->2¦20/3/19: 0%->2; 31/5/19: 2%->10; 13/9/19: FCD:19/09/2019->12/20; 13/9/19: 10%->12; 6/12/19: 12%->45; 6/12/19: FCD:12/12/2019->03/20; 25/03/20: Rel-16->Rel-17; 26/6/20: FCD:12/03/2020->12/20; 5/12/20: FCD:15/12/2020->03/20; 19/3/21: 45%-> ; 7/9/23: 62%->100
- 1505: 13/7/22: 33.894 added; 17/8/22: WID:SP-220536->SP-220674; 12/9/22: 0%->6; 11/12/22: 6%->25; 17/3/23: 25%->30; 8/6/23: 30%->40; 7/9/23: 40%->100
- 1506: 13/7/22: 33.896 added;; 12/9/22: 0%->10; 11/12/22: 10%->50; 17/3/23: 50%->100
- 1507: ; 15/3/24: 0%->100
- 1508: ; 8/12/23: 0%->10; 15/3/24: 10%->100
- 1509: -
- 1510: compare REL-16 NR_perf_enh, REL-17 NR_demod_enh2; no Core part; TR 38.8XX ; 29/3/23: WID:RP-220932->RP-230314; 6/10/23: WID:RP-230314->RP-232685; 2/1/24: WID:RP-232685->RP-233586; 23/7/24: WID:RP-233586->RP-241292
- 1511: 6/9/23: Compl:0%->33%; Stat Rep: ->RP-232250; Rapporteur: China Telecom->Jingzhou Wu, China Telecom; Rap eMail: ->wujingzhou@chinatelecom.cn; ; 8/12/23: Compl:33%->100%; Stat Rep: RP-232250->RP-233584;
- 1512: compare REL-16 NR_perf_enh, REL-17 NR_demod_enh2; no Core part; TR 38.8XX ; 20/6/22: FCD:15/12/2023->23/12/2022; Stat Rep: ->RP-221287; Rapporteur: China Telecom->Jingzhou Wu, China Telecom; Rap eMail: ->wujingzhou@chinatelecom.cn12/7/22: WID:RP-2...;...; 13/6/24: Compl:80%->100%; Stat Rep: RP-240348->RP-241293;
- 1513: 4/9/24: FCD:12/12/2025->25/12/2024; Compl:0%->8%; Stat Rep: ->RP-241995; ; 6/12/24: FCD:12/12/2024->12/12/2025; Compl:8%->41%; Stat Rep: RP-241995->RP-242854; ; 6/3/25: FCD:24/06/2025->12/12/2025; Compl:41%->57%; Stat Rep: RP-242854->RP-250378; ; 6/6/25:; 3/12/25: FCD:Fri 12/12/25->Tue 03/03/26; Compl:80%->93%; Stat Rep: RP-252548->RP-253468;
- 1514: 2/1/24: WID:RP-230813->RP-234025
- 1515: ; 7/6/23: Compl:0%->25%; ;...; 6/9/23: Compl:25%->50%; WID: RP-230813->RP-231469; Stat Rep: ->RP-231756; Rapporteur: Ericsson->Christian Bergljung, Ericsson; Rap eMail: ->Christian.Bergljung@ericsson.com; ; 8/12/23: FCD:12/12/2023->01/03/2024; Compl:50%->95%; Stat Rep: RP-231756->RP-233392;
- 1516: tested: REL-18 WI NR_channel_raster_enh ; 3/12/25: Compl:0%->5%; Stat Rep: ->RP-253471;
- 1517: 29/3/23: WID:RP-223541->RP-230137; 6/10/23: WID:RP-230137->RP-231844; 2/1/24: WID:RP-231844->RP-234004; 2/4/24: WID:RP-234004->RP-240251
- 1518: 17/3/23: Compl:0%->30%; Stat Rep: ->RP-230138; Rapporteur: ZTE->Wubin, Zhou, ZTE; Rap eMail: ->zhou.wubin@zte.com.cn; 7/6/23: Compl:30%->35%; 6/9/23: Compl:35%->60%; WID: RP-230137->RP-231119; Stat Rep: RP-230138->RP-231845; ; 8/12/23: FCD:12/12/2023-...; 14/3/24: Compl:65%->100%; WID: RP-234004->RP-234003; Stat Rep: RP-232928->RP-240252;
- 1519: 17/3/23: Compl:0%->30%; Stat Rep: ->RP-230138; Rapporteur: ZTE->Wubin, Zhou, ZTE; Rap eMail: ->zhou.wubin@zte.com.cn; 7/6/23: Compl:30%->35%; 6/9/23: Compl:35%->60%; WID: RP-230137->RP-231119; Stat Rep: RP-230138->RP-231845; ; 8/12/23: FCD:12/12/2023-...; 2/4/24: stopped at 65%
- 1520: 4/9/24: FCD:06/06/2025->25/06/2025; Compl:0%->13%; Stat Rep: ->RP-241772; ; 6/12/24: Compl:13%->52%; Stat Rep: RP-241772->RP-242810; ; 24/1/25: WID:RP-241093->RP-242811; 6/3/25: FCD:14/02/2025->06/06/2025; Compl:52%->95%; Stat Rep: RP-242810->RP-250163; ; 6/6/25: Compl:95%->100%; Stat Rep: RP-250163->RP-250990;

| ID | WBS | Task | Duration | Start | Finish | Complete | Remaining | Actual finish | Total slack | Constraint | Resources | Work | Actual work | Acronym | PCG approved | WI rapporteur name | Release | TSG approved | Impacted TSs and TRs | WI rapporteur e-mail | Status Report | TSG stopped |
| --- | --- | --- | --- | --- | --- | --- | --- | --- | --- | --- | --- | --- | --- | --- | --- | --- | --- | --- | --- | --- | --- | --- |
| 1521 | 699 | **High power UE (power class 1.5) for NR FR1 TDD single band** | 1034d | 2022-09-12 A | 2025-06-06 | 72% | 286.54d |  | 38024d |  |  | 9440h | 6824h | HPUE_NR_FR1_TDD_R18 | 49 | CMCC | Rel-18 | 97 |  |  |  |  |
| 1522 | 699.1 | Core part: High power UE (power class 1.5) for NR FR1 TDD single band | 328d | 2022-09-12 A | 2023-12-12 A | 100% |  |  |  | finish no earlier than 2023-12-12 | R4 | 2624h | 2624h | HPUE_NR_FR1_TDD_R18-Core | 49 | Chunxia Guo, CMCC | Rel-18 | 97 | 38.895 | guochunxia@chinamobile.com | RP-233448 |  |
| 1523 | 699.2 | Perf. part: High power UE (power class 1.5) for NR FR1 TDD single band | 327d | 2023-01-31 | 2023-12-12 |  |  |  | 38584.9d | finish no earlier than 2023-12-12 | R4 | 2616h |  | HPUE_NR_FR1_TDD_R18-Perf | 49 | Chunxia Guo, CMCC | Rel-18 | 97 |  | guochunxia@chinamobile.com | RP-223053 |  |
| 1524 | 699.3 | UE Conformance - High power UE (power class 1.5) for NR FR1 TDD single band | 525d | 2023-06-08 A | 2025-06-06 A | 100% |  |  |  | finish no earlier than 2025-06-06 | R5 | 4200h | 4200h | HPUE_NR_FR1_TDD_R18-UEConTest | 51 | Dan SONG (CMCC), Yuxin Hao (Huawei), CMCC, Huawei | Rel-18 | 100 |  | songdan@chinamobile.com, haoyuxin@huawei.com | RP-241200 |  |
| 1525 | 700 | **High power UE (power class 2) for NR FR1 FDD single band** | 851.88d | 2022-09-12 A | 2024-12-12 | 100% |  | 2025-09-09 |  |  |  | 14144h | 14144h | HPUE_NR_FR1_FDD_R18 | 49 | China Unicom | Rel-18 | 97 |  |  |  |  |
| 1526 | 700.1 | Core part: High power UE (power class 2) for NR FR1 FDD single band | 457d | 2022-09-12 A | 2024-06-06 A | 100% |  |  |  | finish no earlier than 2024-06-06 | R4 | 3656h | 3656h | HPUE_NR_FR1_FDD_R18-Core | 49 | Basaier Jialade, China Unicom | Rel-18 | 97 | 38.896 | basejld@chinaunicom.cn | RP-241315 |  |
| 1527 | 700.2 | Perf. part: High power UE (power class 2) for NR FR1 FDD single band | 457d | 2022-09-12 A | 2024-06-06 A | 100% |  |  |  | finish no earlier than 2024-06-06 | R4 | 3656h | 3656h | HPUE_NR_FR1_FDD_R18-Perf | 49 | Basaier Jialade, China Unicom | Rel-18 | 97 |  | basejld@chinaunicom.cn | RP-241315 |  |
| 1528 | 700.3 | UE Conformance - High power UE (power class 2) for NR FR1 FDD single band | 854d | 2023-06-08 A | 2025-09-09 A | 100% |  |  |  | finish no earlier than 2025-09-09 | R5 | 6832h | 6832h | HPUE_NR_FR1_FDD_R18-UEConTest | 51 | Shi，Yu, China Unicom | Rel-18 | 100 |  | shiyu19@chinaunicom.cn | RP-251978 |  |
| 1529 | 701 | **High power UE (power class 1.5 or 2) for intra-band Carrier Aggregation combinations of a single NR FR1 TDD band** | 656.12d | 2022-09-12 A | 2024-06-06 A | 100% |  |  |  |  |  | 6736h | 6736h | HPUE_NR_FR1_TDD_intra_CA_R18 | 49 | Huawei | Rel-18 | 97 |  |  |  |  |
| 1530 | 701.1 | Core part: High power UE (power class 1.5 or 2) for intra-band Carrier Aggregation combinations of a single NR FR1 TDD band | 457d | 2022-09-12 A | 2024-06-06 A | 100% |  |  |  | finish no earlier than 2024-06-06 | R4 | 3656h | 3656h | HPUE_NR_FR1_TDD_intra_CA_R18-Core | 49 | Lingyu Kong, Huawei, HiSilicon | Rel-18 | 97 | 38.897 | konglingyu4@hisilicon.com | RP-241253 |  |
| 1531 | 701.2 | Stopped - Perf. part: High power UE (power class 1.5 or 2) for intra-band Carrier Aggregation combinations of a single NR FR1 TDD band | 385d | 2022-09-13 A | 2024-03-01 A | 100% |  |  |  | finish no earlier than 2024-03-01 | R4 | 3080h | 3080h | HPUE_NR_FR1_TDD_intra_CA_R18-Perf | 49 | Lingyu Kong, Huawei, HiSilicon | Rel-18 | 97 |  | konglingyu4@hisilicon.com | RP-233204 | 102 |
| 1532 | 702 | **Rel-18 High power UE (power class 1,5 and 2) for a single FR1 NR TDD band in UL of NR inter-band CA/DC combinations with/without NR SUL (supplementary uplink) with y bands downlink (y=2,3,4,5,6) and x bands uplink (x=1,2)** | 656.12d | 2022-09-12 A | 2024-06-06 A | 100% |  |  |  |  |  | 3664h | 3664h | HPUE_FR1_TDD_NR_CADC_SUL_R18 | 49 | China Telecom | Rel-18 | 97 |  |  |  |  |
| 1533 | 702.1 | Core part: Rel-18 High power UE (power class 1,5 and 2) for a single FR1 NR TDD band in UL of NR inter-band CA/DC combinations with/without NR SUL (supplementary uplink) with y bands downlink (y=2,3,4,5,6) and x bands uplink (x=1,2) | 457d | 2022-09-12 A | 2024-06-06 A | 100% |  |  |  | finish no earlier than 2024-06-06 | R4 | 3656h | 3656h | HPUE_FR1_TDD_NR_CADC_SUL_R18-Core | 49 | Lei GAO, China Telecom | Rel-18 | 97 | 38.899 | gaol8@chinatelecom.cn | RP-241303 |  |
| 1534 | 702.2 | Stopped: Perf. part: Rel-18 High power UE (power class 1,5 and 2) for a single FR1 NR TDD band in UL of NR inter-band CA/DC combinations with/without NR SUL (supplementary uplink) with y bands downlink (y=2,3,4,5,6) and x bands uplink (x=1,2) | 1d | 2022-09-12 A | 2022-09-12 A | 100% |  |  |  | finish no earlier than 2022-09-12 | R4 | 8h | 8h | HPUE_FR1_TDD_NR_CADC_SUL_R18-Perf | 49 | Lei GAO, China Telecom | Rel-18 | 97 |  | gaol8@chinatelecom.cn | RP-241303 |  |
| 1535 | 703 | **Rel-18 High power UE (power class 2) for a single FR1 NR FDD band in UL of NR intra-band and inter-band CA/DC combinations with y bands downlink (y=1,2,3,4,5,6) and x bands uplink (x=1)** | 656.12d | 2022-09-12 A | 2024-06-06 A | 100% |  |  |  |  |  | 6744h | 6744h | HPUE_FR1_FDD_NR_CADC_R18 | 49 | China Unicom | Rel-18 | 97 |  |  |  |  |
| 1536 | 703.1 | Core part: Rel-18 High power UE (power class 2) for a single FR1 NR FDD band in UL of NR intra-band and inter-band CA/DC combinations with y bands downlink (y=1,2,3,4,5,6) and x bands uplink (x=1) | 457d | 2022-09-12 A | 2024-06-06 A | 100% |  |  |  | finish no earlier than 2024-06-06 | R4 | 3656h | 3656h | HPUE_FR1_FDD_NR_CADC_R18-Core | 49 | Basaier Jialade, China Unicom | Rel-18 | 97 | 38.850 | basejld@chinaunicom.cn | RP-241318 |  |
| 1537 | 703.2 | Stopped - Perf. Part: Rel-18 High power UE (power class 2) for a single FR1 NR FDD band in UL of NR intra-band and inter-band CA/DC combinations with y bands downlink (y=1,2,3,4,5,6) and x bands uplink (x=1) | 386d | 2022-09-12 A | 2024-03-01 A | 100% |  |  |  | finish no earlier than 2024-03-01 | R4 | 3088h | 3088h | HPUE_FR1_FDD_NR_CADC_R18-Perf | 49 | Basaier Jialade, China Unicom | Rel-18 | 97 |  | basejld@chinaunicom.cn | RP-241318 | 102 |
| 1538 | 704 | **Adding new channel bandwidth(s) support to existing NR bands** | 560.12d | 2022-09-08 A | 2024-03-01 A | 100% |  |  |  |  |  | 3104h | 3104h | NR_bands_R18_BWs | 49 | Ericsson | Rel-18 | 97 |  |  |  |  |
| 1539 | 704.1 | Core part: Adding new channel bandwidth(s) support to existing NR bands | 388d | 2022-09-08 A | 2024-03-01 A | 100% |  |  |  | finish no earlier than 2024-03-01 | R4 | 3104h | 3104h | NR_bands_R18_BWs-Core | 49 | Dominique Everaere, Ericsson | Rel-18 | 97 |  | dominique.everaere@erisson.com | RP-240275 |  |
| 1540 | 705 | **Enhancement of Multiple Input Multiple Output (MIMO) Over-the-Air (OTA) test methodology and requirement for NR UEs** | 1038.25d | 2022-09-08 A | 2025-06-06 A | 100% |  |  |  |  | R4 | 15087h | 15087h | NR_MIMO_OTA_enh | 49 | CAICT | Rel-18 | 97 | 38.761 |  |  |  |
| 1541 | 705.1 | Core part: Enhancement of Multiple Input Multiple Output (MIMO) Over-the-Air (OTA) test methodology and requirement for NR UEs | 330d | 2022-09-08 A | 2023-12-12 A | 100% |  |  |  | finish no earlier than 2023-12-12 | R4 | 2640h | 2640h | NR_MIMO_OTA_enh-Core | 49 | Zhu, Siting, CAICT | Rel-18 | 97 |  | zhusiting@caict.ac.cn | RP-241290 |  |
| 1542 | 705.2 | Perf. Part: Enhancement of Multiple Input Multiple Output (MIMO) Over-the-Air (OTA) test methodology and requirement for NR UEs | 457d | 2022-09-12 A | 2024-06-06 A | 100% |  |  |  | finish no earlier than 2024-06-06 | R4 | 3656h | 3656h | NR_MIMO_OTA_enh-Perf | 49 | Zhu, Siting, CAICT | Rel-18 | 97 |  | zhusiting@caict.ac.cn | RP-241290 |  |
| 1543 | 705.3 | UE Conformance - Enhancement of Multiple Input Multiple Output (MIMO) Over-the-Air (OTA) test methodology and requirements for NR UEs | 378.88d | 2024-06-06 A | 2025-06-06 A | 100% |  |  |  | finish no earlier than 2025-06-06 | R5 | 3031h | 3031h | NR_MIMO_OTA_enh-UEConTest | 53 | Apple | Rel-18 | 104 |  |  | RP-251177 |  |
| 1544 | 706 | **Rel-18 NR Carrier Aggregation (CA) band combinations with two SUL cells** | 460.62d | 2022-12-13 A | 2024-03-01 A | 100% |  |  |  |  |  | 5120h | 5120h | NR_2SUL_cell_combos_R18 | 50 | CMCC | Rel-18 | 98 |  |  |  |  |
| 1545 | 706.1 | Core part: Rel-18 NR Carrier Aggregation (CA) band combinations with two SUL cells | 320d | 2022-12-13 A | 2024-03-01 A | 100% |  |  |  | finish no earlier than 2024-03-01 | R4 | 2560h | 2560h | NR_2SUL_cell_combos_R18-Core | 50 | Xiaoran ZHANG, CMCC | Rel-18 | 98 | 38.718-00-02 | zhangxiaoran@chinamobile.com | RP-240159 |  |
| 1546 | 706.2 | Stopped - Perf. part: Rel-18 NR Carrier Aggregation (CA) band combinations with two SUL cells | 320d | 2022-12-13 A | 2024-03-01 A | 100% |  |  |  | finish no earlier than 2024-03-01 | R4 | 2560h | 2560h | NR_2SUL_cell_combos_R18-Perf | 50 | Xiaoran ZHANG, CMCC | Rel-18 | 98 |  | zhangxiaoran@chinamobile.com | RP-233445 |  |

Notes:
- 1521: 9/1/23: WID:RP-222351->RP-223499
- 1522: 9/12/22: FCD:12/12/2023->01/12/2023; Compl:0%->30%; Stat Rep: ->RP-223053; Rapporteur: CMCC->Chunxia Guo, CMCC; Rap eMail: ->guochunxia@chinamobile.com; 17/3/23: FCD:30/11/2023->12/12/2023; Stat Rep: RP-223053->RP-230280; 17/3/23: 38.895 added;; ;...;...; 8/12/23: Compl:67%->100%; Stat Rep: RP-232239->RP-233448;
- 1523: 9/12/22: FCD:12/12/2023->01/12/2023; Stat Rep: ->RP-223053; Rapporteur: CMCC->Chunxia Guo, CMCC; Rap eMail: ->guochunxia@chinamobile.com;
- 1524: 21/9/23: Compl:0%->29%; Stat Rep: ->RP-232245; Rapporteur: CMCC->Dan SONG (CMCC), Yuxin Hao (Huawei), CMCC, Huawei; Rap eMail: ->songdan@chinamobile.com, haoyuxin@huawei.com; ; 8/12/23: Compl:29%->35%; Stat Rep: RP-232245->RP-233416; ; 14/3/24: FCD:05/...; 23/7/24: WID:RP-231152->RP-241199
- 1525: 9/1/23: WID:RP-222625->RP-222967; 29/3/23: WID:RP-222967->RP-230352; 6/10/23: WID:RP-230352->RP-232216; 2/1/24: WID:RP-232216->RP-233031; 2/4/24: WID:RP-233031->RP-240120; 23/7/24: WID:RP-240120->RP-241314
- 1526: 9/12/22: FCD:12/12/2023->01/12/2023; Compl:0%->10%; Stat Rep: ->RP-222965; Rapporteur: China Unicom->Basaier Jialade, China Unicom; Rap eMail: ->basejld@chinaunicom.cn; 17/3/23: FCD:30/11/2023->12/12/2023; Stat Rep: RP-222965->RP-230353; 17/3/23: ...;...; 13/6/24: Compl:90%->100%; Stat Rep: RP-240119->RP-241315;
- 1527: 9/12/22: FCD:12/12/2023->01/12/2023; Compl:0%->10%; Stat Rep: ->RP-222965; Rapporteur: China Unicom->Basaier Jialade, China Unicom; Rap eMail: ->basejld@chinaunicom.cn; 17/3/23: FCD:30/11/2023->12/12/2023; Stat Rep: RP-222965->RP-230353; ;...; 6/9/23:...; 13/6/24: Compl:90%->100%; Stat Rep: RP-240119->RP-241315;
- 1528: 6/9/23: Compl:0%->5%; Stat Rep: ->RP-231549; Rapporteur: China Unicom->Shi，Yu, China Unicom; Rap eMail: ->shiyu19@chinaunicom.cn; ; 8/12/23: Stat Rep: RP-231549->RP-232773; ; 2/1/24: WID:RP-230869->RP-232774; 14/3/24: FCD:05/06/2024->12/12/2024; Compl:...; 29/9/25: WID:RP-232774->RP-251979
- 1529: 9/1/23: WID:RP-222647->RP-223356; 29/3/23: WID:RP-223356->RP-230479; 6/10/23: WID:RP-230479->RP-232377; 2/1/24: WID:RP-232377->RP-233975; 2/4/24: WID:RP-233975->RP-240428; 23/7/24: WID:RP-240428->RP-241254
- 1530: 9/12/22: FCD:12/12/2023->01/12/2023; Compl:0%->20%; WID: RP-222647->RP- 222647; Stat Rep: ->RP-223355; Rapporteur: Huawei->Lingyu Kong, Huawei, HiSilicon; Rap eMail: ->konglingyu4@hisilicon.com; 17/3/23: FCD:30/11/2023->12/12/2023; Compl:20%->30%; W.....; 13/6/24: Compl:85%->100%; Stat Rep: RP-240426->RP-241253;
- 1531: 9/12/22: FCD:12/12/2023->01/12/2023; WID: RP-222647->RP- 222647; Stat Rep: ->RP-223355; Rapporteur: Huawei->Lingyu Kong, Huawei, HiSilicon; Rap eMail: ->konglingyu4@hisilicon.com; 17/3/23: WID: RP-223356->RP- 223356; Stat Rep: RP-223355->RP-230478; ; ...; 2/1/24: Stopped at 80% at RAN#102
- 1532: 9/1/23: WID:RP-222623->RP-223496; 29/3/23: WID:RP-223496->RP-230309; 6/10/23: WID:RP-230309->RP-232256; 2/1/24: WID:RP-232256->RP-233561; 2/4/24: WID:RP-233561->RP-240763; 23/7/24: WID:RP-240763->RP-241302
- 1533: 9/12/22: FCD:12/12/2023->01/12/2023; Compl:0%->15%; Stat Rep: ->RP-222941; Rapporteur: China Telecom->Lei GAO, China Telecom; Rap eMail: ->gaol8@chinatelecom.cn; 17/3/23: FCD:30/11/2023->12/12/2023; Compl:15%->30%; Stat Rep: RP-222941->RP-230310; ...;...; 13/6/24: Compl:90%->100%; Stat Rep: RP-240356->RP-241303;
- 1534: 9/12/22: FCD:12/12/2023->01/12/2022; Stat Rep: ->RP-222941; Rapporteur: China Telecom->Lei GAO, China Telecom; Rap eMail: ->gaol8@chinatelecom.cn; 17/3/23: FCD:01/12/2022->12/12/2023; Stat Rep: RP-222941->RP-230310; ;...; 6/9/23: WID: RP-230309->RP-23...; 23/7/24: 0%->100
- 1535: 9/1/23: WID:RP-222626->RP-222968; 29/3/23: WID:RP-222968->RP-230354; 2/1/24: WID:RP-230354->RP-234017; 2/4/24: WID:RP-234017->RP-240123; 23/7/24: WID:RP-240123->RP-241317
- 1536: 9/12/22: FCD:12/06/2023->01/12/2023; Compl:0%->10%; Stat Rep: ->RP-222966; Rapporteur: China Unicom->Basaier Jialade, China Unicom; Rap eMail: ->basejld@chinaunicom.cn; 17/3/23: FCD:30/11/2023->12/12/2023; Stat Rep: RP-222966->RP-230355; 17/3/23: ...;...; 13/6/24: Compl:80%->100%; Stat Rep: RP-240122->RP-241318;
- 1537: 9/12/22: FCD:12/06/2023->01/12/2023; Compl:0%->10%; Stat Rep: ->RP-222966; Rapporteur: China Unicom->Basaier Jialade, China Unicom; Rap eMail: ->basejld@chinaunicom.cn; 17/3/23: FCD:30/11/2023->12/12/2023; Stat Rep: RP-222966->RP-230355; ;...; 6/9/23:...; 13/6/24: Stat Rep: RP-240122->RP-241318;
- 1538: 9/1/23: WID:RP-222629->RP-222898; 29/3/23: WID:RP-222898->RP-230756; 6/10/23: WID:RP-230756->RP-231706; 2/1/24: WID:RP-231706->RP-232952
- 1539: 9/12/22: FCD:10/12/2023->01/12/2023; Compl:0%->2%; Stat Rep: ->RP-222899; Rapporteur: Ericsson->Dominique Everaere, Ericsson; Rap eMail: ->dominique.everaere@erisson.com; 17/3/23: FCD:30/11/2023->12/12/2023; Compl:2%->5%; Stat Rep: RP-222899->RP-230.....; 14/3/24: Compl:70%->100%; Stat Rep: RP-232951->RP-240275;
- 1540: 9/1/23: WID:RP-222668->RP-223509; 6/10/23: WID:RP-223509->RP-232679; 6/10/23: 38.761 added;; 2/1/24: WID:RP-232679->RP-233742; 2/4/24: WID:RP-233742->RP-240736
- 1541: 9/12/22: FCD:10/12/2023->01/12/2023; Compl:0%->20%; Stat Rep: ->RP-223185; Rapporteur: CAICT->Zhu, Siting, CAICT; Rap eMail: ->zhusiting@caict.ac.cn; 17/3/23: FCD:30/11/2023->12/12/2023; Compl:20%->35%; Stat Rep: RP-223185->RP-230367; ...; 6/9/23: Com...; 13/6/24: Stat Rep: RP-240406->RP-241290;
- 1542: 9/12/22: FCD:10/06/2024->01/06/2024; Stat Rep: ->RP-223185; Rapporteur: CAICT->Zhu, Siting, CAICT; Rap eMail: ->zhusiting@caict.ac.cn; 17/3/23: Stat Rep: RP-223185->RP-230367; ;...; 6/9/23: FCD:06/06/2023->06/06/2024; Compl:20%->30%; Stat Rep: RP-2303...; 13/6/24: Compl:70%->100%; Stat Rep: RP-240406->RP-241290;
- 1543: 4/9/24: FCD:06/06/2025->25/06/2025; Compl:0%->45%; ; 6/12/24: Compl:45%->65%; Stat Rep: ->RP-242479; ; 6/3/25: FCD:14/02/2025->06/06/2025; Compl:65%->80%; Stat Rep: RP-242479->RP-250154; ; 6/6/25: Compl:80%->100%; Stat Rep: RP-250154->RP-251177;
- 1544: 29/3/23: WID:RP-223553->RP-230719; 6/10/23: WID:RP-230719->RP-232688; 2/1/24: WID:RP-232688->RP-233446; 2/4/24: WID:RP-233446->RP-240796
- 1545: 17/3/23: Compl:0%->10%; Stat Rep: ->RP-230298; Rapporteur: CMCC->Xiaoran ZHANG, CMCC; Rap eMail: ->zhangxiaoran@chinamobile.com; 17/3/23: 38.718-00-02 added;; 31/3/23: Stat Rep: RP-230298->RP-230718; ;...; 6/9/23: Compl:30%->50%; Stat Rep: RP-230718->...; 14/3/24: Compl:70%->100%; Stat Rep: RP-233445->RP-240159;
- 1546: 17/3/23: FCD:12/12/2023->06/06/2024; Compl:0%->10%; Stat Rep: ->RP-230298; Rapporteur: CMCC->Xiaoran ZHANG, CMCC; Rap eMail: ->zhangxiaoran@chinamobile.com; 31/3/23: FCD:06/06/2024->12/12/2023; Stat Rep: RP-230298->RP-230718; ;...; 6/9/23: Compl:30%->...; 2/4/24: stopped at 70%

| ID | WBS | Task | Duration | Start | Finish | Complete | Remaining | Actual finish | Total slack | Constraint | Resources | Work | Actual work | Acronym | PCG approved | WI rapporteur name | Release | TSG approved | WI rapporteur e-mail | Status Report | Impacted TSs and TRs |
| --- | --- | --- | --- | --- | --- | --- | --- | --- | --- | --- | --- | --- | --- | --- | --- | --- | --- | --- | --- | --- | --- |
| 1547 | 707 | **NR support for dedicated spectrum less than 5MHz for FR1** | 1134.62d | 2021-12-13 A | 2024-12-12 | 100% |  | 2025-12-12 |  |  |  | 14766h | 14766h | NR_FR1_lessthan_5MHz_BW | 48 | Nokia | Rel-18 | 94 |  |  |  |
| 1548 | 707.1 | Core part: NR support for dedicated spectrum less than 5MHz for FR1 | 523d | 2021-12-13 A | 2023-12-12 A | 100% |  |  |  | finish no earlier than 2023-12-12 | R4 | 4184h | 4184h | NR_FR1_lessthan_5MHz_BW-Core | 48 | Man Hung Ng, Nokia | Rel-18 | 94 | man_hung.ng@nokia.com | RP-232749 |  |
| 1549 | 707.2 | Perf. part: NR support for dedicated spectrum less than 5MHz for FR1 | 650d | 2021-12-15 A | 2024-06-06 A | 100% |  |  |  | finish no earlier than 2024-06-06 | R4 | 5200h | 5200h | NR_FR1_lessthan_5MHz_BW-Perf | 48 | Man Hung Ng, Nokia | Rel-18 | 94 | man_hung.ng@nokia.com | RP-240063 |  |
| 1550 | 707.3 | UE Conformance - NR support for dedicated spectrum less than 5MHz for FR1 | 672.75d | 2024-03-03 A | 2025-12-12 A | 100% |  |  |  | finish no earlier than 2025-12-12 | R5 | 5382h | 5382h | NR_FR1_lessthan_5MHz_BW-UEConTest | 52 | Nokia | Rel-18 | 103 |  | RP-253052 |  |
| 1551 | 708 | **Enhancement of NR Dynamic Spectrum Sharing (DSS)** | 938.88d | 2021-12-13 A | 2024-06-06 A | 100% |  |  |  |  |  | 9384h | 9384h | NR_DSS_enh | 48 | Ericsson | Rel-18 | 94 |  |  |  |
| 1552 | 708.1 | Core part: Enhancement of NR Dynamic Spectrum Sharing (DSS) | 523d | 2021-12-13 A | 2023-12-12 A | 100% |  |  |  | finish no earlier than 2023-12-12 | R1 | 4184h | 4184h | NR_DSS_enh-Core | 48 | Ravikiran Nory, Ericsson | Rel-18 | 94 | ravikiran.nory@ericsson.com | RP-232956 |  |
| 1553 | 708.2 | Perf. part: Enhancement of NR Dynamic Spectrum Sharing (DSS) | 650d | 2021-12-15 A | 2024-06-06 A | 100% |  |  |  | finish no earlier than 2024-06-06 | R1 | 5200h | 5200h | NR_DSS_enh-Perf | 48 | Ravikiran Nory, Ericsson | Rel-18 | 94 | ravikiran.nory@ericsson.com | RP-241174 |  |
| 1554 | 709 | **Multi-carrier enhancements for NR** | 1134.62d | 2021-12-13 A | 2024-12-12 | 99% | 8.89d |  |  |  |  | 15438h | 9384h | NR_MC_enh | 48 | NTT DOCOMO | Rel-18 | 94 |  |  |  |
| 1555 | 709.1 | Core part: Multi-carrier enhancements for NR | 523d | 2021-12-13 A | 2023-12-12 A | 100% |  |  |  | finish no earlier than 2023-12-12 | R1 | 4184h | 4184h | NR_MC_enh-Core | 48 | Hiroki Harada, NTT DOCOMO, INC. | Rel-18 | 94 | hiroki.harada.sv@nttdocomo.com | RP-241266 |  |
| 1556 | 709.2 | Perf. part: Multi-carrier enhancements for NR | 650d | 2021-12-15 A | 2024-06-06 A | 100% |  |  |  | finish no earlier than 2024-06-06 | R1 | 5200h | 5200h | NR_MC_enh-Perf | 48 | Hiroki Harada, NTT DOCOMO, INC. | Rel-18 | 94 | hiroki.harada.sv@nttdocomo.com | RP-241266 |  |
| 1557 | 709.3 | UE Conformance - Multi-carrier enhancements for NR | 756.75d | 2024-03-03 A | 2026-03-03 | 98% | 15.13d |  | 37744.2d | finish no earlier than 2026-03-03 | R5 | 6054h |  | NR_MC_enh-UEConTest | 52 | China Telecom | Rel-18 | 103 |  | RP-253467 |  |
| 1558 | 710 | **Further NR coverage enhancements** | 1134.62d | 2021-12-13 A | 2024-12-12 | 93% | 76.48d |  |  |  |  | 16216h | 9384h | NR_cov_enh2 | 48 | China Telecom | Rel-18 | 94 |  |  |  |
| 1559 | 710.1 | Core part: Further NR coverage enhancements | 523d | 2021-12-13 A | 2023-12-12 A | 100% |  |  |  | finish no earlier than 2023-12-12 | R1 | 4184h | 4184h | NR_cov_enh2-Core | 48 | Nanxi LI, China Telecom | Rel-18 | 94 | linanxi@chinatelecom.cn | RP-233557 |  |
| 1560 | 710.2 | Perf. part: Further NR coverage enhancements | 650d | 2021-12-15 A | 2024-06-06 A | 100% |  |  |  | finish no earlier than 2024-06-06 | R1 | 5200h | 5200h | NR_cov_enh2-Perf | 48 | Nanxi LI, China Telecom | Rel-18 | 94 | linanxi@chinatelecom.cn | RP-241294 |  |
| 1561 | 710.3 | UE Conformance - Further NR coverage enhancements | 854d | 2024-03-03 A | 2026-06-05 | 84% | 136.64d |  | 37647d | finish no earlier than 2026-06-05 | R5 | 6832h |  | NR_cov_enh2-UEConTest | 52 | China Telecom | Rel-18 | 103 |  | RP-253466 |  |
| 1562 | 711 | **NR MIMO evolution for downlink and uplink** | 1134.62d | 2021-12-13 A | 2024-12-12 | 89% | 119.51d |  |  |  |  | 16216h | 9384h | NR_MIMO_evo_DL_UL | 48 | Samsung | Rel-18 | 94 |  |  |  |
| 1563 | 711.1 | Core part: NR MIMO evolution for downlink and uplink | 523d | 2021-12-13 A | 2023-12-12 A | 100% |  |  |  | finish no earlier than 2023-12-12 | R1 | 4184h | 4184h | NR_MIMO_evo_DL_UL-Core | 48 | Eko Onggosanusi, Samsung | Rel-18 | 94 | eko.o@samsung.com | RP-232913 |  |
| 1564 | 711.2 | Perf. part: NR MIMO evolution for downlink and uplink | 650d | 2021-12-15 A | 2024-06-06 A | 100% |  |  |  | finish no earlier than 2024-06-06 | R1 | 5200h | 5200h | NR_MIMO_evo_DL_UL-Perf | 48 | Eko Onggosanusi, Samsung | Rel-18 | 94 | eko.o@samsung.com | RP-241282 |  |
| 1565 | 711.3 | UE Conformance - NR MIMO evolution for downlink and uplink | 854d | 2024-03-03 A | 2026-06-05 | 75% | 213.5d |  | 37647d | finish no earlier than 2026-06-05 | R5 | 6832h |  | NR_MIMO_evo_DL_UL-UEConTest | 52 | Samsung | Rel-18 | 103 |  | RP-253317 |  |
| 1566 | 712 | Study on evolution of NR duplex operation | 523d | 2021-12-13 A | 2023-12-12 A | 100% |  |  |  | finish no earlier than 2023-12-12 | R1 | 4184h | 4184h | FS_NR_duplex_evo | 48 | Fei WANG, CMCC | Rel-18 | 94 | wangfei@chinamobile.com | RP-233435 | 38.858 |
| 1567 | 713 | **NR network-controlled repeaters** | 660.38d | 2022-09-08 A | 2024-06-06 A | 100% |  |  |  |  |  | 9944h | 9944h | NR_netcon_repeater | 49 | ZTE | Rel-18 | 97 |  |  |  |
| 1568 | 713.1 | Core part: NR network-controlled repeaters | 330d | 2022-09-08 A | 2023-12-12 A | 100% |  |  |  | finish no earlier than 2023-12-12 | R1 | 2640h | 2640h | NR_netcon_repeater-Core | 49 | Nan Zhang, ZTE | Rel-18 | 97 | Zhang.nan152@zte.com.cn | RP-240930 |  |
| 1569 | 713.2 | Perf. part: NR network-controlled repeaters | 457d | 2022-09-12 A | 2024-06-06 A | 100% |  |  |  | finish no earlier than 2024-06-06 | R1 | 3656h | 3656h | NR_netcon_repeater-Perf | 49 | Nan Zhang, ZTE | Rel-18 | 97 | Zhang.nan152@zte.com.cn | RP-240930 |  |
| 1570 | 713.3 | Study on NR network-controlled repeaters | 456d | 2022-09-08 A | 2024-06-05 A | 100% |  |  |  |  | R1 | 3648h | 3648h | FS_NR_netcon_repeater | 48 | Nan Zhang, ZTE | Rel-18 | 94 | Zhang.nan152@zte.com.cn | RP-221231 | 38.867 |

Notes:
- 1547: 5/4/22: WID:RP-213603->RP-220401; 23/9/22: WID:RP-220401->RP-222645; 29/3/23: WID:RP-222645->RP-230186; 6/10/23: WID:RP-230186->RP-231713; 2/1/24: WID:RP-231713->RP-234027
- 1548: ; 22/3/22: Stat Rep: ->RP-220402 6/6/22: CD:12/12/2023->13/12/2022 6/6/22: Stat Rep: RP-220402->RP-221415; 20/6/22: FCD:13/12/2022->23/12/2022; Rapporteur: Nokia->Toni L hteensuo, Nokia; Rap eMail: ->toni.h.lahteensuo@nokia.com13/7/22: FCD:23/12/20...;...; 8/12/23: Compl:95%->100%; Stat Rep: RP-231712->RP-232749;
- 1549: ; 22/3/22: CD:23/06/2023->12/06/2024; 22/3/22: Stat Rep: ->RP-220402 ; 6/6/22: CD:12/06/2024->24/06/2022 ; 6/6/22: Stat Rep: RP-220402->RP-221415; 20/6/22: Rapporteur: Nokia->Toni L hteensuo, Nokia; Rap eMail: ->toni.h.lahteensuo@nokia.com13/7/22: ...;...; 23/7/24: 70%->100
- 1550: 13/6/24: Compl:0%->22%; Stat Rep: ->RP-240908; ; 4/9/24: FCD:12/12/2025->25/12/2024; Compl:22%->43%; Stat Rep: RP-240908->RP-241737; ; 6/12/24: FCD:12/12/2024->12/12/2025; Compl:43%->46%; Stat Rep: RP-241737->RP-242457; ; 6/3/25: FCD:28/05/2025->12/12/202; 7/1/26: WID:RP-250882->RP-253053
- 1551: compare REL-17 WI NR_DSS-Core; 12/7/22: WID:RP-213575->RP-221622; 2/1/24: WID:RP-221622->RP-232957
- 1552: compare REL-17 WI NR_DSS-Core; 22/3/22: Stat Rep: ->RP-220589 ; 6/6/22: Compl:0%->40% ; 20/6/22: Rapporteur: Ericsson->Ravikiran Nory, Ericsson; Rap eMail: ->ravikiran.nory@ericsson.com13/7/22: FCD:23/12/2022->12/20 ; ...; 9/12/22: FCD:23/12/2022->01...; 8/12/23: Compl:95%->100%; Stat Rep: RP-232132->RP-232956;
- 1553: ; 22/3/22: CD:24/06/2024->12/06/2024; 22/3/22: Stat Rep: ->RP-220589 ; 6/6/22: CD:12/06/2024->24/06/2022 ; 6/6/22: Stat Rep: RP-220589->RP-221621; 20/6/22: WG: R4->R1; Rapporteur: Ericsson->Ravikiran Nory, Ericsson; Rap eMail: ->ravikiran.nory@ericsson...; 23/7/24: 100%->100
- 1554: 5/4/22: WID:RP-213577->RP-220834; 12/7/22: WID:RP-220834->RP-221435; 23/9/22: WID:RP-221435->RP-222251; 2/1/24: WID:RP-222251->RP-234012
- 1555: ; 22/3/22: CD:23/06/2023->12/06/2023; 22/3/22: Stat Rep: ->RP-220616 ; 6/6/22: Compl:0%->10% 20/6/22: Rapporteur: NTT DOCOMO->Hiroki Harada, NTT DOCOMO, INC.; Rap eMail: ->hiroki.harada@docomo-lab.com13/7/22: FCD:23/12/2022->12/20 ...; 23/9/22: WID:RP-...; 13/6/24: WID: RP-222251->RP-240321; Stat Rep: RP-240070->RP-241266;
- 1556: ; 22/3/22: Stat Rep: ->RP-220616 6/6/22: CD:12/12/2023->24/06/2022 6/6/22: Stat Rep: RP-220616->RP-221436; 20/6/22: WG: R4->R1; Rapporteur: NTT DOCOMO->Hiroki Harada, NTT DOCOMO, INC.; Rap eMail: ->hiroki.harada@docomo-lab.com13/7/22: FCD:24/06/2...;...; 23/7/24: 100%->100
- 1557: 13/6/24: Compl:0%->18%; Stat Rep: ->RP-241301; ; 4/9/24: FCD:12/12/2025->25/12/2024; Compl:18%->80%; Stat Rep: RP-241301->RP-242000; ; 6/12/24: FCD:12/12/2024->12/12/2025; Compl:80%->87%; Stat Rep: RP-242000->RP-242852; ; 6/3/25: FCD:28/05/2025->12/12/202; 3/12/25: FCD:Fri 12/12/25->Tue 03/03/26; Compl:97%->98%; Stat Rep: RP-252547->RP-253467;
- 1558: compare REL-17 WI NR_cov_enh; 5/4/22: WID:RP-213579->RP-220937; 12/7/22: WID:RP-220937->RP-221858; 2/1/24: WID:RP-221858->RP-233558; 23/7/24: WID:RP-233558->RP-241295
- 1559: compare REL-17 WI NR_cov_enh; 22/3/22: Stat Rep: ->RP-220566 ; 6/6/22: CD:12/12/2023->23/12/2022 ; 6/6/22: WID: RP-220937->RP- 220937 ; 6/6/22: Stat Rep: RP-220566->RP-221282; 20/6/22: Rapporteur: China Telecom->Nanxi LI, China Telecom; Rap eMail: ->li...; 8/12/23: Compl:85%->100%; Stat Rep: RP-232272->RP-233557;
- 1560: ; 22/3/22: CD:24/06/2024->12/06/2024; 22/3/22: Stat Rep: ->RP-220566 6/6/22: CD:12/06/2024->24/06/2022 6/6/22: WID: RP-220937->RP- 220937 6/6/22: Stat Rep: RP-220566->RP-221282; 20/6/22: WG: R4->R1; Rapporteur: China Telecom->Nanxi LI, China Telecom; R...; 23/7/24: 100%->100
- 1561: 13/6/24: Compl:0%->5%; Stat Rep: ->RP-241300; ; 4/9/24: FCD:12/12/2025->25/12/2024; Compl:5%->28%; Stat Rep: RP-241300->RP-241992; ; 6/12/24: FCD:12/12/2024->12/12/2025; Compl:28%->29%; Stat Rep: RP-241992->RP-242851; ; 6/3/25: FCD:28/05/2025->12/12/2025;; 3/12/25: FCD:Fri 12/12/25->Fri 05/06/26; Compl:76%->84%; Stat Rep: RP-252546->RP-253466;
- 1562: compare REL-16 WI NR_eMIMO and REL-17 WI NR_feMIMO; 9/1/23: WID:RP-213598->RP-223276; 2/1/24: WID:RP-223276->RP-233028
- 1563: compare REL-16 WI NR_eMIMO and REL-17 WI NR_feMIMO; 22/3/22: Stat Rep: ->RP-220669 6/6/22: Compl:0%->10% 20/6/22: Rapporteur: Samsung->Eko Onggosanusi, Samsung; Rap eMail: ->eko.o@samsung.com13/7/22: FCD:23/12/2022->12/20 ;...; 9/12/22: FCD:23/12/202...; 8/12/23: Compl:90%->100%; Stat Rep: RP-231717->RP-232913;
- 1564: ; 22/3/22: CD:24/06/2024->12/06/2024; 22/3/22: Stat Rep: ->RP-220669 6/6/22: CD:12/06/2024->24/06/2022 6/6/22: Stat Rep: RP-220669->RP-221393; 20/6/22: WG: R4->R1; Rapporteur: Samsung->Eko Onggosanusi, Samsung; Rap eMail: ->eko.o@samsung.com13/7/...;...; 23/7/24: 100%->100
- 1565: 13/6/24: Compl:0%->5%; Stat Rep: ->RP-241279; ; 4/9/24: FCD:12/12/2025->25/12/2024; Compl:5%->19%; Stat Rep: RP-241279->RP-241982; ; 6/12/24: FCD:12/12/2024->12/12/2025; Compl:19%->37%; Stat Rep: RP-241982->RP-242596; ; 6/3/25: FCD:28/05/2025->12/12/2025;; 3/12/25: FCD:Fri 12/12/25->Fri 05/06/26; Compl:60%->75%; Stat Rep: RP-252079->RP-253317;
- 1566: 21/1/22: 38.858 added;; 22/3/22: Stat Rep: ->RP-220632; 5/4/22: WID:RP-213591->RP-220633 6/6/22: Compl:0%->10% 20/6/22: Rapporteur: CMCC->Fei WANG, CMCC; Rap eMail: ->wangfei@chinamobile.com12/7/22: WID:RP-220633->RP-221352; 13/7/22: FCD:23/12...; 23/...; 8/12/23: Compl:94%->100%; Stat Rep: RP-232231->RP-233435;
- 1567: 9/1/23: WID:RP-222673->RP-223505; 29/3/23: WID:RP-223505->RP-230175; 2/1/24: WID:RP-230175->RP-232886
- 1568: 9/12/22: FCD:10/12/2023->01/12/2023; Compl:0%->80%; Stat Rep: ->RP-222874; Rapporteur: ZTE->Nan Zhang, ZTE; Rap eMail: ->Zhang.nan152@zte.com.cn; 17/3/23: FCD:30/11/2023->12/12/2023; Compl:80%->90%; WID: RP-222673->RP-223505; Stat Rep: RP-222874->RP.....; 13/6/24: Stat Rep: RP-240112->RP-240930;
- 1569: 9/12/22: WG: R4->R1; FCD:10/06/2024->01/06/2024; Stat Rep: ->RP-222874; Rapporteur: ZTE->Nan Zhang, ZTE; Rap eMail: ->Zhang.nan152@zte.com.cn; 17/3/23: WID: RP-222673->RP-223505; Stat Rep: RP-222874->RP-230174; ...; 6/9/23: FCD:06/06/2023->06/06/2024;...; 23/7/24: 100%->100
- 1570: compare REL-17 WI NR_repeaters; TR 38.8xx; 21/1/22: 38.867 added;; 22/3/22: Stat Rep: ->RP-220214 6/6/22: Compl:0%->40% ; 20/6/22: Rapporteur: ZTE->Nan Zhang, ZTE; Rap eMail: ->Zhang.nan152@zte.com.cn12/7/22: WID:RP-213700->RP-221229 ;...; 23/9/22: 0%->100

| ID | WBS | Task | Duration | Start | Finish | Complete | Remaining | Total slack | Constraint | Resources | Work | Actual work | Acronym | PCG approved | WI rapporteur name | Release | TSG approved | WI rapporteur e-mail | Status Report | Impacted TSs and TRs |
| --- | --- | --- | --- | --- | --- | --- | --- | --- | --- | --- | --- | --- | --- | --- | --- | --- | --- | --- | --- | --- |
| 1571 | 714 | **Further NR mobility enhancements** | 1134.62d | 2021-12-13 A | 2024-12-12 | 97% | 38.84d |  |  |  | 15895h | 9848h | NR_Mob_enh2 | 48 | MediaTek | Rel-18 | 94 |  |  |  |
| 1572 | 714.1 | Core part: Further NR mobility enhancements | 581d | 2021-12-13 A | 2024-03-01 A | 100% |  |  | finish no earlier than 2024-03-01 | R2 | 4648h | 4648h | NR_Mob_enh2-Core | 48 | Li-Chuan Tseng, MediaTek Inc. | Rel-18 | 94 | li-chuan.tseng@mediatek.com | RP-241347 |  |
| 1573 | 714.2 | Perf. part: Further NR mobility enhancements | 650d | 2021-12-15 A | 2024-06-06 A | 100% |  |  | finish no earlier than 2024-06-06 | R2 | 5200h | 5200h | NR_Mob_enh2-Perf | 48 | Li-Chuan Tseng, MediaTek Inc. | Rel-18 | 94 | li-chuan.tseng@mediatek.com | RP-241347 |  |
| 1574 | 714.3 | UE Conformance - Further NR mobility enhancements | 755.88d | 2024-06-06 A | 2026-06-05 | 91% | 68.03d | 37647d | finish no earlier than 2026-06-05 | R5 | 6047h |  | NR_Mob_enh2-UEConTest | 53 | Mediatek | Rel-18 | 104 |  | RP-253688 |  |
| 1575 | 715 | **In-Device Co-existence (IDC) enhancements for NR and MR-DC** | 1693.75d | 2021-12-13 A | 2026-06-05 | 91% | 160.17d | 37647d |  |  | 10231h | 4184h | NR_IDC_enh | 48 | Xiaomi | Rel-18 | 94 |  |  |  |
| 1576 | 715.1 | Core part: In-Device Co-existence (IDC) enhancements for NR and MR-DC | 523d | 2021-12-13 A | 2023-12-12 A | 100% |  |  | finish no earlier than 2023-12-12 | R2 | 4184h | 4184h | NR_IDC_enh-Core | 48 | Yumin Wu, Xiaomi | Rel-18 | 94 | wuyumin@xiaomi.com | RP-233484 |  |
| 1577 | 715.2 | UE Conformance - In-Device Co-existence (IDC) enhancements for NR and MR-DC | 755.88d | 2024-06-06 A | 2026-06-05 | 84% | 120.94d | 37647d | finish no earlier than 2026-06-05 | R5 | 6047h |  | NR_IDC_enh-UEConTest | 53 | CMCC | Rel-18 | 104 |  | RP-253375 |  |
| 1578 | 716 | **BS/UE EMC enhancements for NR and LTE** | 660.62d | 2022-03-15 A | 2023-12-12 A | 100% |  |  |  |  | 7312h | 7312h | NR_LTE_EMC_enh | 48 | Ericsson | Rel-18 | 95 |  |  |  |
| 1579 | 716.1 | Core part: BS/UE EMC enhancements for NR and LTE | 457d | 2022-03-15 A | 2023-12-12 A | 100% |  |  | finish no earlier than 2023-12-12 | R4 | 3656h | 3656h | NR_LTE_EMC_enh-Core | 48 | Aurelian Bria, Ericsson | Rel-18 | 95 | Aurelian.Bria@ericsson.com | RP-233683 |  |
| 1580 | 716.2 | Perf. part: BS/UE EMC enhancements for NR and LTE | 457d | 2022-03-15 A | 2023-12-12 A | 100% |  |  | finish no earlier than 2023-12-12 | R4 | 3656h | 3656h | NR_LTE_EMC_enh-Perf | 48 | Aurelian Bria, Ericsson | Rel-18 | 95 | Aurelian.Bria@ericsson.com | RP-233683 |  |
| 1581 | 717 | **Air-to-ground network for NR** | 1221.5d | 2022-03-15 A | 2025-06-06 | 93% | 85.01d |  |  |  | 14493h | 7768h | NR_ATG | 48 | CMCC | Rel-18 | 95 |  |  |  |
| 1582 | 717.1 | Core part: Air-to-ground network for NR | 457d | 2022-03-15 A | 2023-12-12 A | 100% |  |  | finish no earlier than 2023-12-12 | R4 | 3656h | 3656h | NR_ATG-Core | 48 | Guo Chunxia, CMCC | Rel-18 | 95 | guochunxia@chinamobile.com | RP-240158 |  |
| 1583 | 717.2 | Perf. part: Air-to-ground network for NR | 514d | 2022-03-16 A | 2024-03-01 A | 100% |  |  | finish no earlier than 2024-03-01 | R4 | 4112h | 4112h | NR_ATG-Perf | 48 | Guo Chunxia, CMCC | Rel-18 | 95 | guochunxia@chinamobile.com | RP-240158 |  |
| 1584 | 717.3 | UE Conformance - Air-to-ground network for NR | 840.62d | 2023-12-13 A | 2026-03-03 | 85% | 126.09d | 37744.2d | finish no earlier than 2026-03-03 | R5 | 6725h |  | NR_ATG-UEConTest | 52 | Dan SONG, CMCC | Rel-18 | 102 | songdan@chinamobile.com | RP-253376 |  |
| 1585 | 718 | **NR RF requirements enhancement for frequency range 2 (FR2), Phase 3** | 1123.25d | 2022-03-15 A | 2025-03-03 | 91% | 101.13d |  |  |  | 15176h | 8344h | NR_RF_FR2_req_Ph3 | 48 | Nokia | Rel-18 | 95 |  |  |  |
| 1586 | 718.1 | Core part: NR RF requirements enhancement for frequency range 2 (FR2), Phase 3 | 457d | 2022-03-15 A | 2023-12-12 A | 100% |  |  | finish no earlier than 2023-12-12 | R4 | 3656h | 3656h | NR_RF_FR2_req_Ph3-Core | 48 | Hisashi Onozawa, Nokia | Rel-18 | 95 | hisashi.onozawa@nokia.com | RP-240939 | 38.891 |
| 1587 | 718.2 | Perf. part: NR RF requirements enhancement for frequency range 2 (FR2), Phase 3 | 586d | 2022-03-15 A | 2024-06-06 A | 100% |  |  | finish no earlier than 2024-06-06 | R4 | 4688h | 4688h | NR_RF_FR2_req_Ph3-Perf | 48 | Hisashi Onozawa, Nokia | Rel-18 | 95 | hisashi.onozawa@nokia.com | RP-240939 |  |
| 1588 | 718.3 | UE Conformance - NR RF requirements enhancement for frequency range 2 (FR2), Phase 3 | 854d | 2024-03-03 A | 2026-06-05 | 80% | 170.8d | 37647d | finish no earlier than 2026-06-05 | R5 | 6832h |  | NR_RF_FR2_req_Ph3-UEConTest | 52 | Apple | Rel-18 | 103 |  | RP-253202 |  |
| 1589 | 719 | **Requirement for NR frequency range 2 (FR2) multi-Rx chain DL reception** | 648.12d | 2022-03-15 A | 2023-11-30 | 82% | 119.83d |  |  |  | 14391h | 8344h | NR_FR2_multiRX_DL | 48 | Bin Han, Qualcomm Incorporated | Rel-18 | 95 | binhan@qti.qualcomm.com | RP-223153 |  |
| 1590 | 719.1 | Core part: Requirement for NR frequency range 2 (FR2) multi-Rx chain DL reception | 457d | 2022-03-15 A | 2023-12-12 A | 100% |  |  | finish no earlier than 2023-12-12 | R4 | 3656h | 3656h | NR_FR2_multiRX_DL-Core | 48 | Sumant Iyer, Qualcomm Inc. | Rel-18 | 95 | sumanti@qti.qualcomm.com | RP-241535 | 38.751 |
| 1591 | 719.2 | Perf. part: Requirement for NR frequency range 2 (FR2) multi-Rx chain DL reception | 586d | 2022-03-15 A | 2024-06-06 A | 100% |  |  | finish no earlier than 2024-06-06 | R4 | 4688h | 4688h | NR_FR2_multiRX_DL-Perf | 48 | Sumant Iyer, Qualcomm Inc. | Rel-18 | 95 | sumanti@qti.qualcomm.com | RP-241535 |  |
| 1592 | 719.3 | UE Conformance - Requirement for NR frequency range 2 (FR2) multi-Rx chain DL reception | 755.88d | 2024-06-06 A | 2026-06-05 | 56% | 332.58d | 37647d | finish no earlier than 2026-06-05 | R5 | 6047h |  | NR_FR2_multiRX_DL-UEConTest | 53 | Qualcomm | Rel-18 | 104 |  | RP-253371 |  |
| 1593 | 720 | **Even Further RRM enhancement for NR and MR-DC** | 843.62d | 2022-03-15 A | 2024-06-06 A | 100% |  |  |  |  | 8328h | 8328h | NR_RRM_enh3 | 48 | Apple | Rel-18 | 95 |  |  |  |
| 1594 | 720.1 | Core part: Even Further RRM enhancement for NR and MR-DC | 457d | 2022-03-15 A | 2023-12-12 A | 100% |  |  | finish no earlier than 2023-12-12 | R4 | 3656h | 3656h | NR_RRM_enh3-Core | 48 | Jie Cui, Apple | Rel-18 | 95 | jie_cui@apple.com | RP-241267 |  |
| 1595 | 720.2 | Perf. part: Even Further RRM enhancement for NR and MR-DC | 584d | 2022-03-17 A | 2024-06-06 A | 100% |  |  | finish no earlier than 2024-06-06 | R4 | 4672h | 4672h | NR_RRM_enh3-Perf | 48 | Jie Cui, Apple | Rel-18 | 95 | jie_cui@apple.com | RP-241267 |  |

Notes:
- 1571: compare REL-16 WI NR_Mob_enh; 12/7/22: WID:RP-213565->RP-221799; 23/9/22: WID:RP-221799->RP-222332; 9/1/23: WID:RP-222332->RP-223520; 2/1/24: WID:RP-223520->RP-233970
- 1572: compare REL-16 WI NR_Mob_enh; 22/3/22: CD:12/12/2023->12/09/2023; 22/3/22: Stat Rep: ->RP-220760 6/6/22: CD:12/09/2023->23/09/2022 6/6/22: Stat Re ; 20/6/22: Acronym:NR_Mob_enh2-Core->NR_mob_enh2-Core; Rapporteur: MediaTek->Li-Chuan Tseng, MediaTek Inc...; 13/6/24: Stat Rep: RP-240443->RP-241347;
- 1573: ; 22/3/22: CD:24/06/2024->12/12/2023; 22/3/22: Stat Rep: ->RP-220760 ; 6/6/22: CD:12/12/2023->23/12/2022 ; 6/6/22: Stat Rep: RP-220760->RP-221557; 20/6/22: Acronym:NR_Mob_enh2-Perf->NR_mob_enh2-Perf; WG: R4->R2; Rapporteur: MediaTek->Li-Chuan Tseng, Me...; 13/6/24: Compl:35%->100%; Stat Rep: RP-240443->RP-241347;
- 1574: 4/9/24: FCD:12/12/2025->25/12/2024; Compl:0%->20%; Stat Rep: ->RP-242047; ; 6/12/24: FCD:12/12/2024->12/12/2025; Compl:20%->40%; Stat Rep: RP-242047->RP-242990; ; 6/3/25: FCD:24/06/2025->12/12/2025; Compl:40%->55%; Stat Rep: RP-242990->RP-250475; ; 6/6/2; 3/12/25: FCD:Fri 12/12/25->Fri 05/06/26; Compl:80%->91%; Stat Rep: RP-252501->RP-253688;
- 1575: MR-DC: Multi-RAT Dual Connectivity; no Perf. part; 12/7/22: WID:RP-213589->RP-221281; 2/1/24: WID:RP-221281->RP-233485
- 1576: MR-DC: Multi-RAT Dual Connectivity; no Perf. part; 20/6/22: Acronym:NR_IDC_enh-Core->NR_IDC_Enh-Core; FCD:12/12/2023->23/12/2022; Stat Rep: ->RP-221280; Rapporteur: Xiaomi->Yumin Wu, Xiaomi; Rap eMail: ->wuyumin@xiaomi.com13/7/22: FCD:23/12/2022->1...;...; 8/12/23: Compl:99%->100%; Stat Rep: RP-232631->RP-233484;
- 1577: 4/9/24: FCD:06/06/2026->26/06/2025; Compl:0%->5%; Stat Rep: ->RP-241948; ; 6/12/24: FCD:06/06/2025->05/06/2026; Compl:5%->18%; Stat Rep: RP-241948->RP-242978; ; 6/3/25: FCD:23/10/2025->05/06/2026; Compl:18%->39%; Stat Rep: RP-242978->RP-250252; ; 6/6/25:; 3/12/25: FCD:Sat 06/06/26->Fri 05/06/26; Compl:60%->84%; Stat Rep: RP-252595->RP-253375;
- 1578: compare REL-15 WI AASenh_BS_LTE_UTRA ; 2/1/24: WID:RP-220916->RP-233976
- 1579: compare REL-15 WI AASenh_BS_LTE_UTRA ; 6/6/22: CD:15/06/2023->23/09/2022 ; 6/6/22: Stat Rep: ->RP-221165; 20/6/22: Rapporteur: Ericsson->Aurelian Bria, Ericsson; Rap eMail: ->aurelian.bria@ericsson.com13/7/22: FCD:23/09/2022->09/20 ;...; 9/12/22: FCD...; 8/12/23: Compl:95%->100%; Stat Rep: RP-232637->RP-233683;
- 1580: compare REL-15 WI AASenh_BS_LTE_UTRA 6/6/22: CD:15/12/2023->23/12/2022 6/6/22: Stat Rep: ->RP-221165; 20/6/22: Rapporteur: Ericsson->Aurelian Bria, Ericsson; Rap eMail: ->aurelian.bria@ericsson.com13/7/22: FCD:23/12/2022->12/20...; 9/12/22: FCD:23/12...; 8/12/23: Compl:80%->100%; Stat Rep: RP-232637->RP-233683;
- 1581: TR 38.8xx ; 12/7/22: WID:RP-220962->RP-221369; 29/3/23: WID:RP-221369->RP-230279; 2/1/24: WID:RP-230279->RP-234023; 2/4/24: WID:RP-234023->RP-240732
- 1582: TR 38.8xx 6/6/22: CD:15/12/2023->23/12/20226/6/22: Stat Rep: ->RP-221370; 20/6/22: Rapporteur: CMCC->Shao Zhe, CMCC; Rap eMail: ->Shaozhe@chinamobile.com13/7/22: FCD:23/12/2022->12/20 ...; 9/12/22: FCD:23/12/2022->01/12/2023; Compl:5%->20%; Stat Rep...; 14/3/24: Stat Rep: RP-233443->RP-240158;
- 1583: 6/6/22: CD:15/03/2024->24/03/2023 6/6/22: Stat Rep: ->RP-221370; 20/6/22: Rapporteur: CMCC->Shao Zhe, CMCC; Rap eMail: ->Shaozhe@chinamobile.com13/7/22: FCD:24/03/2023->03/20 ;...; 9/12/22: FCD:24/03/2023->01/03/2024; Stat Rep: RP-221370->RP-2230...; 14/3/24: Compl:80%->100%; Stat Rep: RP-233443->RP-240158;
- 1584: 14/3/24: Compl:0%->50%; Stat Rep: ->RP-240148; Rapporteur: CMCC->Dan SONG, CMCC; Rap eMail: ->songdan@chinamobile.com; ; 2/4/24: WID:RP-233412->RP-240750. corrected: Rel-19->Rel-18; 13/6/24: WID: RP-240750->RP-233412; Stat Rep: RP-240148->RP-241201; ; ...; 3/12/25: FCD:Fri 12/12/25->Tue 03/03/26; Compl:80%->85%; Stat Rep: RP-252596->RP-253376;
- 1585: compare REL-16 WI NR_RF_FR2_req_enh and REL-17 WI NR_RF_FR2_req_enh2 ; 12/7/22: WID:RP-220967->RP-221862; 23/9/22: WID:RP-221862->RP-222228; 9/1/23: WID:RP-222228->RP-222909; 2/1/24: WID:RP-222909->RP-232791; 23/7/24: WID:RP-232791->RP-240940
- 1586: compare REL-16 WI NR_RF_FR2_req_enh and REL-17 WI NR_RF_FR2_req_enh2 6/6/22: CD:15/12/2023->23/12/2022 6/6/22: Stat Rep: ; 20/6/22: Rapporteur: Nokia->Vasenkari, Petri, Nokia; Rap eMail: ->Petri.j.vasenkari@nokia.com13/7/22: FCD:23/12/2022->12/20...;...; 13/6/24: Stat Rep: RP-232790->RP-240939;
- 1587: ; 6/6/22: CD:15/03/2024->24/03/2023 ; 6/6/22: Stat Rep: ->RP-221207; 20/6/22: Rapporteur: Nokia->Vasenkari, Petri, Nokia; Rap eMail: ->Petri.j.vasenkari@nokia.com13/7/22: FCD:24/03/2023->03/20 ; ;...; 9/12/22: FCD:24/03/2023->01/03/2024; Compl:10%...; 13/6/24: FCD:01/03/2024->06/06/2024; Compl:85%->100%; Stat Rep: RP-232790->RP-240939;
- 1588: 13/6/24: Compl:0%->5%; Stat Rep: ->RP-241175; ; 4/9/24: FCD:03/03/2025->25/03/2025; Compl:5%->15%; Stat Rep: RP-241175->RP-242219; ; 6/12/24: Compl:15%->40%; Stat Rep: RP-242219->RP-242600; ; 6/3/25: FCD:12/11/2024->06/06/2025; Stat Rep: RP-242600->RP-250; 3/12/25: FCD:Fri 12/12/25->Fri 05/06/26; Stat Rep: RP-251506->RP-253202;
- 1589: ; 12/7/22: WID:RP-220974->RP-221753; 9/12/22: Acronym:NR_FR2_multiRX_DL->FS_NR_FR2_OTA_enh; FCD:01/03/2024->01/12/2023; Compl:11%->25%; WID: RP-221753->RP-222652; Stat Rep: ->RP-223153; Rapporteur: Qualcomm->Bin Han, Qualcomm Incorporated; Rap eMail:...; 23/7/24: WID:RP-234020->RP-241534
- 1590: 6/6/22: CD:15/09/2023->23/09/2022 6/6/22: WID: RP-220974->R4-220974 6/6/22: Stat Rep: ->RP-221225; 20/6/22: Stat Rep: RP-221225->RP-221225 / 1752; Rapporteur: Qualcomm->Sumant Iyer, Qualcomm Inc.; Rap eMail: ->sumanti@qti.qualcomm.com13/7/22: FC...;...; 13/6/24: WID: RP-233076->RP-234020; Stat Rep: RP-240297->RP-241535;
- 1591: 6/6/22: CD:15/03/2024->24/09/2022 6/6/22: WID: RP-220974->R4-220974 6/6/22: Stat Rep: ->RP-221225; 20/6/22: FCD:24/09/2022->24/03/2023; Stat Rep: RP-221225->RP-221225 / 1752; Rapporteur: Qualcomm->Sumant Iyer, Qualcomm Inc.; Rap eMail: ->sumanti@qt...; 13/6/24: FCD:01/03/2024->06/06/2024; Compl:85%->100%; Stat Rep: RP-240297->RP-241535;
- 1592: 4/9/24: FCD:12/12/2025->25/12/2024; Compl:0%->5%; Stat Rep: ->RP-242040; ; 6/12/24: FCD:12/12/2024->12/12/2025; Compl:5%->9%; Stat Rep: RP-242040->RP-242898; ; 6/3/25: FCD:24/06/2025->12/12/2025; Compl:9%->20%; Stat Rep: RP-242898->RP-250396; ; 6/6/25: C; 3/12/25: FCD:Fri 12/12/25->Fri 05/06/26; Compl:45%->56%; Stat Rep: RP-252050->RP-253371;
- 1593: compare REL-16 WI NR_RRM_enh and REL-17 WI NR_RRM_enh2; RAN1/2 impact to be checked ; 12/7/22: WID:RP-220977->RP-221696; 2/1/24: WID:RP-221696->RP-233496
- 1594: compare REL-16 WI NR_RRM_enh and REL-17 WI NR_RRM_enh2; RAN1/2 impact to be checked ; 20/6/22: FCD:15/12/2023->23/12/2022; Stat Rep: ->RP-221697; Rapporteur: Apple->Jie Cui, Apple; Rap eMail: ->jie_cui@apple.com13/7/22: FCD:23/12/2022->12/20; ...; 9/1...; 13/6/24: Stat Rep: RP-240490->RP-241267;
- 1595: 6/6/22: CD:15/06/2024->24/06/2022 6/6/22: Stat Rep: ->RP-221697; 20/6/22: Rapporteur: Apple->Jie Cui, Apple; Rap eMail: ->jie_cui@apple.com13/7/22: FCD:24/06/2022->06/20 ; ...; 9/12/22: FCD:24/06/2023->01/06/2024; WID: RP-220977->RP-221696; Stat ...; 13/6/24: Compl:50%->100%; Stat Rep: RP-240490->RP-241267;

| ID | WBS | Task | Type | Duration | Start | Finish | Complete | Remaining | Total slack | Constraint | Resources | Work | Actual work | Acronym | PCG approved | Release | TSG approved | Impacted TSs and TRs | WI rapporteur e-mail | Status Report |
| --- | --- | --- | --- | --- | --- | --- | --- | --- | --- | --- | --- | --- | --- | --- | --- | --- | --- | --- | --- | --- |
| 1596 | 721 | **Further RF requirements enhancement for NR and EN-DC in frequency range 1 (FR1)** |  | 1221.5d | 2022-03-15 A | 2025-06-06 | 81% | 226.69d |  |  |  | 16741h | 8344h | NR_ENDC_RF_FR1_enh2 | 48 | Rel-18 | 95 |  |  |  |
| 1597 | 721.1 | Core part: Further RF requirements enhancement for NR and EN-DC in frequency range 1 (FR1) |  | 457d | 2022-03-15 A | 2023-12-12 A | 100% |  |  | finish no earlier than 2023-12-12 | R4 | 3656h | 3656h | NR_ENDC_RF_FR1_enh2-Core | 48 | Rel-18 | 95 | 38.881 | leo.liuye@huawei.com | RP-233185 |
| 1598 | 721.2 | Perf. part: Further RF requirements enhancement for NR and EN-DC in frequency range 1 (FR1) |  | 586d | 2022-03-15 A | 2024-06-06 A | 100% |  |  | finish no earlier than 2024-06-06 | R4 | 4688h | 4688h | NR_ENDC_RF_FR1_enh2-Perf | 48 | Rel-18 | 95 |  | leo.liuye@huawei.com | RP-241240 |
| 1599 | 721.3 | UE Conformance - Further RF requirements enhancement for NR and EN-DC in frequency range 1 |  | 1049.62d | 2024-03-03 A | 2026-12-11 | 63% | 388.36d | 37451.4d | finish no earlier than 2026-12-11 | R5 | 8397h |  | NR_ENDC_RF_FR1_enh2-UEConTest | 52 | Rel-18 | 103 |  |  | RP-253428 |
| 1600 | 722 | **Support of intra-band non-collocated EN-DC/NR-CA deployment** |  | 660.62d | 2022-03-15 A | 2023-12-12 | 97% | 16.52d | 38584.9d |  |  | 7304h | 3648h | NonCol_intraB_ENDC_NR_CA | 48 | Rel-18 | 95 |  |  |  |
| 1601 | 722.1 | Core part: Support of intra-band non-collocated EN-DC/NR-CA deployment |  | 457d | 2022-03-15 A | 2023-05-30 | 95% | 22.85d | 38788.5d | finish no earlier than 2023-12-12 | R4 | 3656h |  | NonCol_intraB_ENDC_NR_CA-Core | 48 | Rel-18 | 95 |  | ui-suzuki@kddi.com | RP-232113 |
| 1602 | 722.2 | Perf. part: Support of intra-band non-collocated EN-DC/NR-CA deployment |  | 456d | 2022-03-16 A | 2023-12-12 A | 100% |  |  | finish no earlier than 2023-12-12 | R4 | 3648h | 3648h | NonCol_intraB_ENDC_NR_CA-Perf | 48 | Rel-18 | 95 |  | ui-suzuki@kddi.com | RP-232113 |
| 1603 | 723 | **Further enhancements on NR and MR-DC measurement gaps and measurements without gaps** |  | 1501.25d | 2022-03-15 A | 2026-03-03 | 97% | 52.44d | 37744.2d |  |  | 12825h | 8344h | NR_MG_enh2 | 48 | Rel-18 | 95 |  |  |  |
| 1604 | 723.1 | Core part: Further enhancements on NR and MR-DC measurement gaps and measurements without gaps |  | 457d | 2022-03-15 A | 2023-12-12 A | 100% |  |  | finish no earlier than 2023-12-12 | R4 | 3656h | 3656h | NR_MG_enh2-Core | 48 | Rel-18 | 95 |  | ato.yu@mediatek.com, meng.zhang@intel.com | RP-241349 |
| 1605 | 723.2 | Perf. part: Further enhancements on NR and MR-DC measurement gaps and measurements without gaps |  | 586d | 2022-03-15 A | 2024-06-06 A | 100% |  |  | finish no earlier than 2024-06-06 | R4 | 4688h | 4688h | NR_MG_enh2-Perf | 48 | Rel-18 | 95 |  | ato.yu@mediatek.com, meng.zhang@intel.com | RP-241349 |
| 1606 | 723.3 | UE Conformance - Further enhancements on NR and MR-DC measurement gaps and measurements without gaps |  | 560.12d | 2024-09-09 A | 2026-03-03 | 90% | 56.01d | 37744.2d | finish no earlier than 2026-03-03 | R5 | 4481h |  | NR_MG_enh2-UEConTest | 53 | Rel-18 | 105 |  |  | RP-253689 |
| 1607 | 724 | **Dual Transmission/Reception (Tx/Rx) Multi-SIM for NR** |  | 1316.75d | 2021-12-13 A | 2025-06-06 A | 100% |  |  |  | R2 | 19992h | 19992h | NR_DualTxRx_MUSIM | 48 | Rel-18 | 94 |  |  |  |
| 1608 | 724.1 | Core part: Dual Transmission/Reception (Tx/Rx) Multi-SIM for NR |  | 523d | 2021-12-13 A | 2023-12-12 A | 100% |  |  | finish no earlier than 2023-12-12 | R2 | 4184h | 4184h | NR_DualTxRx_MUSIM-Core | 48 | Rel-18 | 94 |  | Yangxiaodong5g@vivo.com | RP-233070 |
| 1609 | 724.2 | Perf. Part: Dual Transmission/Reception (Tx/Rx) Multi-SIM for NR |  | 586d | 2022-03-15 A | 2024-06-06 A | 100% |  |  | finish no earlier than 2024-06-06 | R2 | 4688h | 4688h | NR_DualTxRx_MUSIM-Perf | 48 | Rel-18 | 95 |  | Yangxiaodong5g@vivo.com | RP-241045 |
| 1610 | 724.3 | UE Conformance - Dual Transmission/Reception (Tx/Rx) Multi-SIM for NR |  | 477d | 2024-03-03 A | 2025-06-06 A | 100% |  |  | finish no earlier than 2025-06-06 | R5 | 3816h | 3816h | NR_DualTxRx_MUSIM-UEConTest | 52 | Rel-18 | 103 |  |  | RP-250894 |
| 1611 | 725 | Rel-18 NR-only: band related | milestone | 0d? | 2019-03-07 | 2019-03-07 |  |  | 40388.9d |  |  |  |  |  |  | Rel-18 |  |  |  |  |
| 1612 | 726 | **Addition of FDD NR bands using the uplink from n28 and the downlink of n75 and n76** |  | 291.88d | 2023-03-06 A | 2023-12-12 A | 100% |  |  |  | R4 | 4872h | 4872h | NR_FDD_ULn28_DLn75_n76 | 50 | Rel-18 | 99 |  |  |  |
| 1613 | 726.1 | Core part: Addition of FDD NR bands using the uplink from n28 and the downlink of n75 and n76 |  | 203d | 2023-03-06 A | 2023-12-12 A | 100% |  |  | finish no earlier than 2023-12-12 | R4 | 1624h | 1624h | NR_FDD_ULn28_DLn75_n76-Core | 50 | Rel-18 | 99 |  | Wael.boukleyhasan@vodafone.com | RP- 233244 |
| 1614 | 726.2 | Perf. part: Addition of FDD NR bands using the uplink from n28 and the downlink of n75 and n76 |  | 203d | 2023-03-06 A | 2023-12-12 A | 100% |  |  | finish no earlier than 2023-12-12 | R4 | 1624h | 1624h | NR_FDD_ULn28_DLn75_n76-Perf | 50 | Rel-18 | 99 |  | Wael.boukleyhasan@vodafone.com | RP- 233244 |
| 1615 | 727 | **Complete the specification support for BandWidth Part operation without restriction in NR** |  | 474.88d | 2023-03-06 A | 2024-06-06 A | 100% |  |  |  | R4 | 6920h | 6920h | NR_BWP_wor | 50 | Rel-18 | 99 |  |  |  |
| 1616 | 727.1 | Core part: Complete the specification support for BandWidth Part operation without restriction in NR |  | 203d | 2023-03-06 A | 2023-12-12 A | 100% |  |  | finish no earlier than 2023-12-12 | R4 | 1624h | 1624h | NR_BWP_wor-Core | 50 | Rel-18 | 99 |  | diogo.martins@vodafone.com | RP-241057 |
| 1617 | 727.2 | Perf. part: Complete the specification support for BandWidth Part operation without restriction in NR |  | 330d | 2023-03-08 A | 2024-06-06 A | 100% |  |  | finish no earlier than 2024-06-06 | R4 | 2640h | 2640h | NR_BWP_wor-Perf | 50 | Rel-18 | 99 |  | diogo.martins@vodafone.com | RP-241057 |
| 1618 | 728 | **Introduction of NR bands n31 and n72** |  | 98.38d | 2023-09-09 A | 2023-12-12 A | 100% |  |  |  | R4 | 1632h | 1632h | NR_bands_n31_n72 | 51 | Rel-18 | 101 |  |  |  |
| 1619 | 728.1 | Core part: Introduction of NR bands n31 and n72 |  | 68d | 2023-09-09 A | 2023-12-12 A | 100% |  |  | finish no earlier than 2023-12-12 | R4 | 544h | 544h | NR_bands_n31_n72-Core | 51 | Rel-18 | 101 |  | petri.j.vasenkari@nokia.com | RP-233181 |
| 1620 | 728.2 | Perf. part: Introduction of NR bands n31 and n72 |  | 68d | 2023-09-09 A | 2023-12-12 A | 100% |  |  | finish no earlier than 2023-12-12 | R4 | 544h | 544h | NR_bands_n31_n72-Perf | 51 | Rel-18 | 101 |  | petri.j.vasenkari@nokia.com | RP-233181 |

Notes:
- 1596: compare REL-16 WI NR_RF_FR1 and REL-17 WI NR_RF_FR1_enh ; 12/7/22: WID:RP-220987->RP-221496; 9/1/23: WID:RP-221496->RP-223478; 29/3/23: WID:RP-223478->RP-230753; 6/10/23: WID:RP-230753->RP-232366; 2/1/24: WID:RP-232366->RP-233186 / WI rapporteur name: Huawei
- 1597: compare REL-16 WI NR_RF_FR1 and REL-17 WI NR_RF_FR1_enh 6/6/22: CD:15/12/2023->23/12/2022 6/6/22: Stat Rep: ->RP-221495; 20/6/22: Rapporteur: Huawei->Liu Ye, Huawei, HiSilicon; Rap eMail: ->leo.liuye@huawei.com13/7/22: FCD:23/12/2022->12/20; 13/7...;...; 8/12/23: Compl:80%->100%; Stat Rep: RP-232365->RP-233185; / WI rapporteur name: Ye Liu, Huawei
- 1598: ; 6/6/22: CD:15/06/2024->24/06/2022 ; 6/6/22: Stat Rep: ->RP-221495; 20/6/22: Rapporteur: Huawei->Liu Ye, Huawei, HiSilicon; Rap eMail: ->leo.liuye@huawei.com13/7/22: FCD:24/06/2022->06/20 ; ;...; 9/12/22: FCD:23/06/2023->31/05/2024; Compl:10%->20...; 13/6/24: Compl:90%->100%; Stat Rep: RP-240411->RP-241240; / WI rapporteur name: Ye Liu, Huawei
- 1599: 13/6/24: Compl:0%->5%; Stat Rep: ->RP-241377; ; 4/9/24: FCD:06/06/2025->25/06/2025; Compl:5%->12%; Stat Rep: RP-241377->RP-242074; ; 6/12/24: Compl:12%->34%; Stat Rep: RP-242074->RP-243091; ; 6/3/25: FCD:17/01/2025->12/12/2025; Compl:34%->35%; Stat Rep: R; 3/12/25: FCD:Fri 12/12/25->Fri 11/12/26; Compl:59%->63%; Stat Rep: RP-252646->RP-253428; / WI rapporteur name: Huawei
- 1600: ; 12/7/22: WID:RP-221012->RP-221809; 23/9/22: WID:RP-221809->RP-222309; 29/3/23: WID:RP-222309->RP-230742; 2/1/24: WID:RP-230742->RP-233513 / WI rapporteur name: KDDI
- 1601: ; 20/6/22: FCD:15/09/2023->23/09/2022; Stat Rep: ->RP-221742; Rapporteur: KDDI->Yasuki Suzuki; Rap eMail: ->ui-suzuki@kddi.com13/7/22: FCD:23/09/2022->09/20 ...; 9/12/22: FCD:23/09/2022->01/09/2023; Compl:10%->20%; Stat Rep: RP-221742->RP-222956;...; 6/9/23: FCD:09/09/2023->12/12/2023; Compl:92%->95%; WID: RP-230742->RP-231066; Stat Rep: RP-230461->RP-232113; / WI rapporteur name: Yasuki Suzuki, KDDI
- 1602: ; 20/6/22: FCD:15/12/2023->23/12/2022; Stat Rep: ->RP-221742; Rapporteur: KDDI->Yasuki Suzuki; Rap eMail: ->ui-suzuki@kddi.com13/7/22: FCD:23/12/2022->12/20 ...; 9/12/22: FCD:23/12/2022->01/12/2023; Stat Rep: RP-221742->RP-222956; Rapporteur: Yas...; 2/4/24: 70%->100 / WI rapporteur name: Yasuki Suzuki, KDDI
- 1603: compare REL-14 WI LTE_meas_gap_enh and REL-17 WI NR_MG_enh ; 5/4/22: WID:RP-221018 ->RP-220772; 23/9/22: WID:RP-220772->RP-222337; 29/3/23: WID:RP-222337->RP-230755; 6/10/23: WID:RP-230755->RP-232440; 2/1/24: WID:RP-232440->RP-234021 / WI rapporteur name: MediaTek
- 1604: compare REL-14 WI LTE_meas_gap_enh and REL-17 WI NR_MG_enh ; 20/6/22: FCD:15/12/2023->23/12/2022; WID: RP-220772->RP-221018; Stat Rep: ->RP-221560; Rapporteur: MediaTek->Ato (Tsang-Wei) YU, Rui HUANG, MediaTek Inc., Intel Corporation; Rap eMail: ->ato...; 13/6/24: Stat Rep: RP-240445->RP-241349; / WI rapporteur name: Tsang-Wei (Ato) YU, Meng ZHANG, MediaTek Inc., Intel Corporation
- 1605: ; 6/6/22: CD:15/06/2024->24/06/2022 ; 6/6/22: WID: RP-220772->RP-221018 ; 6/6/22: Stat Rep: ->RP-221560; 20/6/22: Rapporteur: MediaTek->Ato (Tsang-Wei) YU, Rui HUANG, MediaTek Inc., Intel Corporation; Rap eMail: ->ato.yu@mediatek.com, rui.huang@int...; 13/6/24: Compl:35%->100%; Stat Rep: RP-240445->RP-241349; / WI rapporteur name: Tsang-Wei (Ato) YU, Meng ZHANG, MediaTek Inc., Intel Corporation
- 1606: 6/12/24: Compl:0%->10%; Stat Rep: ->RP-242994; ; 24/1/25: WID:RP-242046->RP-242995; 6/3/25: FCD:24/07/2025->12/12/2025; Compl:10%->35%; WID: RP-242995->RP-242046; Stat Rep: RP-242994->RP-250477; ; 6/6/25: Compl:35%->55%; Stat Rep: RP-250477->RP-251293; ;; 3/12/25: FCD:Fri 12/12/25->Tue 03/03/26; Compl:70%->90%; Stat Rep: RP-252502->RP-253689; / WI rapporteur name: Mediatek
- 1607: compare REL-17 WI LTE_NR_MUSIM-Core; no Perf. part; 5/4/22: WID:RP-213584->RP-220955; 9/1/23: WID:RP-220955->RP-223492; 29/3/23: WID:RP-223492->RP-230751; 2/1/24: WID:RP-230751->RP-233071 / WI rapporteur name: vivo
- 1608: 6/6/22: CD:12/09/2023->23/12/2022 6/6/22: Stat Rep: ->RP-221273; 20/6/22: Rapporteur: vivo->Xiaodong Yang, vivo; Rap eMail: ->Yangxiaodong5g@vivo.com13/7/22: FCD:23/12/2022->12/20 ...; 9/12/22: FCD:23/12/2022->01/12/2023; Compl:5%->20%; Stat Rep: RP...; 8/12/23: Compl:65%->100%; Stat Rep: RP-231817->RP-233070; / WI rapporteur name: Xiaodong Yang, vivo
- 1609: 20/6/22: WG: R4->R2; FCD:14/06/2024->24/06/2022; Stat Rep: ->RP-221273; Rapporteur: vivo->Xiaodong Yang, vivo; Rap eMail: ->Yangxiaodong5g@vivo.com13/7/22: FCD:24/06/2022->06/20 ;...; 17/3/23: FCD:06/06/2023->06/06/2024; Stat Rep: RP-221273->RP-2303...; 13/6/24: Compl:30%->100%; Stat Rep: RP-240136->RP-241045; / WI rapporteur name: Xiaodong Yang, vivo
- 1610: 13/6/24: Compl:0%->5%; Stat Rep: ->RP-240909; ; 4/9/24: FCD:06/06/2025->25/06/2025; Compl:5%->14%; Stat Rep: RP-240909->RP-241957; ; 6/12/24: Compl:14%->72%; Stat Rep: RP-241957->RP-242471; ; 6/3/25: FCD:17/01/2025->06/06/2025; Compl:72%->90%; Stat Rep: R; 18/7/25: WID:RP-240045->RP-250895 / WI rapporteur name: China Telecom
- 1611: -
- 1612: 6/10/23: WID:RP-230791->RP-232636; 2/1/24: WID:RP-232636->RP-233245 / WI rapporteur name: Vodafone
- 1613: ; 7/6/23: Compl:0%->43%; 6/9/23: FCD:09/09/2023->22/09/2023; Compl:43%->80%; WID: RP-230791->RP-231476; Stat Rep: ->RP-231747; Rapporteur: Vodafone->Wael Boukley Hasan, Vodafone; Rap eMail: ->Wael.boukleyhasan@vodafone.com; ; 21/9/23: FCD:22/09/2023->1...; 8/12/23: Compl:80%->100%; Stat Rep: RP-232630->RP- 233244; / WI rapporteur name: Wael Boukley Hasan, Vodafone
- 1614: 6/9/23: FCD:09/09/2023->23/09/2023; WID: RP-230791->RP-231476; Stat Rep: ->RP-231747; Rapporteur: Vodafone->Wael Boukley Hasan, Vodafone; Rap eMail: ->Wael.boukleyhasan@vodafone.com; ; 21/9/23: FCD:23/09/2023->12/12/2023; Stat Rep: RP-231747->RP-232630; ; 8/12/23: Compl:0%->100%; Stat Rep: RP-232630->RP- 233244; / WI rapporteur name: Wael Boukley Hasan, Vodafone
- 1615: 6/10/23: WID:RP-230805->RP-232677; 2/1/24: WID:RP-232677->RP-233999 / WI rapporteur name: Vodafone
- 1616: ; 7/6/23: Compl:0%->40%; 6/9/23: Compl:40%->60%; WID: RP-230805->RP-231486; Stat Rep: ->RP-231924; Rapporteur: Vodafone->Diogo Martins, Vodafone; Rap eMail: ->diogo.martins@vodafone.com; ; 8/12/23: Compl:60%->100%; Stat Rep: RP-231924->RP-233039; ; 14/...; 13/6/24: Stat Rep: RP-240385->RP-241057; / WI rapporteur name: Diogo Martins, Vodafone
- 1617: ; 7/6/23: CD:06/06/2024->06/06/2023; 6/9/23: FCD:06/06/2023->06/06/2024; WID: RP-230805->RP-231486; Stat Rep: ->RP-231924; Rapporteur: Vodafone->Diogo Martins, Vodafone; Rap eMail: ->diogo.martins@vodafone.com; ; 8/12/23: Stat Rep: RP-231924->RP-233039...; 13/6/24: Compl:25%->100%; Stat Rep: RP-240385->RP-241057; / WI rapporteur name: Diogo Martins, Vodafone
- 1618: 2/1/24: WID:RP-232691->RP-233950 / WI rapporteur name: Nokia
- 1619: 8/12/23: Compl:0%->100%; Stat Rep: ->RP-233181; Rapporteur: Nokia->Petri Vasenkari, Nokia; Rap eMail: ->petri.j.vasenkari@nokia.com; / WI rapporteur name: Petri Vasenkari, Nokia
- 1620: 8/12/23: FCD:06/06/2024->12/12/2023; Compl:0%->100%; Stat Rep: ->RP-233181; Rapporteur: Nokia->Petri Vasenkari, Nokia; Rap eMail: ->petri.j.vasenkari@nokia.com; / WI rapporteur name: Petri Vasenkari, Nokia

| ID | WBS | Task | Duration | Start | Finish | Complete | Remaining | Total slack | Constraint | Resources | Work | Actual work | Acronym | PCG approved | WI rapporteur name | Release | TSG approved | WI rapporteur e-mail | Status Report | TSG stopped | Impacted TSs and TRs |
| --- | --- | --- | --- | --- | --- | --- | --- | --- | --- | --- | --- | --- | --- | --- | --- | --- | --- | --- | --- | --- | --- |
| 1621 | 729 | **Enhancement for 700/800/900MHz band combinations for NR** | 291.88d | 2023-03-06 A | 2023-12-12 A | 100% |  |  |  | R4 | 4872h | 4872h | NR_700800900_combo_enh | 50 | CATT | Rel-18 | 99 |  |  |  |  |
| 1622 | 729.1 | Core part: Enhancement for 700/800/900MHz band combinations for NR | 203d | 2023-03-06 A | 2023-12-12 A | 100% |  |  | finish no earlier than 2023-12-12 | R4 | 1624h | 1624h | NR_700800900_combo_enh-Core | 50 | Shan Huiping, CATT | Rel-18 | 99 | shanhuiping@catt.cn | RP-233005 |  |  |
| 1623 | 729.2 | Stopped - Perf. part: Enhancement for 700/800/900MHz band combinations for NR | 203d | 2023-03-06 A | 2023-12-12 A | 100% |  |  | finish no earlier than 2023-12-12 | R4 | 1624h | 1624h | NR_700800900_combo_enh-Perf | 50 | Shan Huiping, CATT | Rel-18 | 99 | shanhuiping@catt.cn | RP-231833 | 102 |  |
| 1624 | 730 | **Introduction of NR TDD band in 1670-1675 MHz (n54)** | 84.75d | 2022-12-12 A | 2023-03-03 A | 100% |  |  |  |  | 960h | 960h | NR_TDD_n54 | 50 | Ligado Networks | Rel-18 | 98 |  |  |  |  |
| 1625 | 730.1 | Core part: Introduction of NR TDD band in 1670-1675 MHz (n54) | 60d | 2022-12-12 A | 2023-03-03 A | 100% |  |  | finish no earlier than 2023-03-03 | R4 | 480h | 480h | NR_TDD_n54-Core | 50 | Ojas Choksi, Ligado Networks | Rel-18 | 98 | ojas.choksi@ligado.com | RP-230061 |  |  |
| 1626 | 730.2 | Perf. part: Introduction of NR TDD band in 1670-1675 MHz (n54) | 60d | 2022-12-12 A | 2023-03-03 A | 100% |  |  | finish no earlier than 2023-03-03 | R4 | 480h | 480h | NR_TDD_n54-Perf | 50 | Ojas Choksi, Ligado Networks | Rel-18 | 98 | ojas.choksi@ligado.com | RP-230061 |  |  |
| 1627 | 731 | **Introduction of 900 MHz NR band in the US** | 262d | 2022-12-13 A | 2023-08-22 | 25% | 196.5d | 38700.8d |  |  | 4192h |  | NR_900MHz_US | 50 | Anterix | Rel-18 | 98 |  |  |  |  |
| 1628 | 731.1 | Core Part: Introduction of 900 MHz NR band in the US | 262d | 2022-12-13 A | 2023-08-22 | 25% | 196.5d | 38700.8d | finish no earlier than 2023-12-12 | R4 | 2096h |  | NR_900MHz_US-Core | 50 | Gene Fong, Qualcomm Incorporated | Rel-18 | 98 | gfong@qti.qualcomm.com | RP-231956 |  |  |
| 1629 | 731.2 | Perf. part: Introduction of 900 MHz NR band in the US | 262d | 2022-12-13 A | 2023-08-22 | 25% | 196.5d | 38700.8d | finish no earlier than 2023-12-12 | R4 | 2096h |  | NR_900MHz_US-Perf | 50 | Gene Fong, Qualcomm Incorporated | Rel-18 | 98 | gfong@qti.qualcomm.com | RP-231956 |  |  |
| 1630 | 732 | **Rel-18 NR Inter-band Carrier Aggregation/Dual Connectivity for 2 bands DL with x bands UL (x=1,2)** | 748.38d | 2022-06-15 A | 2024-06-06 A | 100% |  |  |  |  | 7752h | 7752h | NR_CADC_R18_2BDL_xBUL | 49 | ZTE | Rel-18 | 96 |  |  |  |  |
| 1631 | 732.1 | Core part: Rel-18 NR Inter-band Carrier Aggregation/Dual Connectivity for 2 bands DL with x bands UL (x=1,2) | 520d | 2022-06-15 A | 2024-06-06 A | 100% |  |  | finish no earlier than 2024-06-06 | R4 | 4160h | 4160h | NR_CADC_R18_2BDL_xBUL-Core | 49 | Wubin, Zhou, ZTE | Rel-18 | 96 | zhou.wubin@zte.com.cn | RP-241223 |  | 38.718-02-01 |
| 1632 | 732.2 | Stopped - Perf. part: Rel-18 NR Inter-band Carrier Aggregation/Dual Connectivity for 2 bands DL with x bands UL (x=1,2) | 449d | 2022-06-15 A | 2024-03-01 A | 100% |  |  | finish no earlier than 2024-03-01 | R4 | 3592h | 3592h | NR_CADC_R18_2BDL_xBUL-Perf | 49 | Wubin, Zhou, ZTE | Rel-18 | 96 | zhou.wubin@zte.com.cn | RP-241223 |  |  |
| 1633 | 733 | **Rel-18 NR Inter-band Carrier Aggregation/Dual Connectivity for 3 bands DL with x bands UL (x=1,2)** | 748.38d | 2022-06-15 A | 2024-06-06 A | 100% |  |  |  |  | 8312h | 8312h | NR_CADC_R18_3BDL_xBUL | 49 | ZTE | Rel-18 | 96 |  |  |  |  |
| 1634 | 733.1 | Core part: Rel-18 NR Inter-band Carrier Aggregation/Dual Connectivity for 3 bands DL with x bands UL (x=1,2) | 520d | 2022-06-15 A | 2024-06-06 A | 100% |  |  | finish no earlier than 2024-06-06 | R4 | 4160h | 4160h | NR_CADC_R18_3BDL_xBUL-Core | 49 | Zhifeng Ma, ZTE | Rel-18 | 96 | ma.zhifeng@zte.com.cn | RP-241090 |  | 38.718-03-01 |
| 1635 | 733.2 | Perf. part: Rel-18 NR Inter-band Carrier Aggregation/Dual Connectivity for 3 bands DL with x bands UL (x=1,2) | 519d | 2022-06-16 A | 2024-06-06 A | 100% |  |  | finish no earlier than 2024-06-06 | R4 | 4152h | 4152h | NR_CADC_R18_3BDL_xBUL-Perf | 49 | Zhifeng Ma, ZTE | Rel-18 | 96 | ma.zhifeng@zte.com.cn | RP-241090 |  |  |
| 1636 | 734 | **High Power UE support for NR bands n100 and n101 for Rail Mobile Radio (RMR) in Europe** | 390d | 2022-12-01 | 2023-12-12 |  |  | 38584.9d |  |  | 3120h |  | NR_RAIL_HPUE_n100_n101 | 49 | Union Internationale Chemins de Fer (UIC) | Rel-18 | 96 |  |  |  |  |
| 1637 | 734.1 | Core part: High Power UE support for NR bands n100 and n101 for Rail Mobile Radio (RMR) in Europe | 390d | 2022-12-01 | 2023-12-12 |  |  | 38584.9d | finish no earlier than 2023-12-12 | R4 | 3120h |  | NR_RAIL_HPUE_n100_n101-Core | 49 | Union Internationale Chemins de Fer (UIC) | Rel-18 | 96 |  | RP-222544 |  |  |
| 1638 | 735 | **Rel-18 NR intra band Carrier Aggregation for xCC DL/yCC UL including contiguous and non-contiguous spectrum (x>=y)** | 748.38d | 2022-06-15 A | 2024-06-06 A | 100% |  |  |  |  | 7752h | 7752h | NR_CA_R18_Intra | 49 | Ericsson | Rel-18 | 96 |  |  |  |  |
| 1639 | 735.1 | Core part: Rel-18 NR intra band Carrier Aggregation for xCC DL/yCC UL including contiguous and non-contiguous spectrum (x>=y) | 520d | 2022-06-15 A | 2024-06-06 A | 100% |  |  | finish no earlier than 2024-06-06 | R4 | 4160h | 4160h | NR_CA_R18_Intra-Core | 49 | Per Lindell, Ericsson | Rel-18 | 96 | per.lindell@ericsson.com | RP-241139 |  | 38.718-01-01 |
| 1640 | 735.2 | Stopped - Perf. part: Rel-18 NR intra band Carrier Aggregation for xCC DL/yCC UL including contiguous and non-contiguous spectrum (x>=y) | 449d | 2022-06-15 A | 2024-03-01 A | 100% |  |  | finish no earlier than 2024-03-01 | R4 | 3592h | 3592h | NR_CA_R18_Intra-Perf | 49 | Per Lindell, Ericsson | Rel-18 | 96 | per.lindell@ericsson.com | RP-241139 | 102 |  |
| 1641 | 736 | **Rel-18 NR inter-band Carrier Aggregation/Dual Connectivity for y bands DL (y=4, 5, 6) with x bands UL (x=1, 2)** | 748.38d | 2022-06-15 A | 2024-06-06 A | 100% |  |  |  |  | 8320h | 8320h | NR_CADC_R18_yBDL_xBUL | 49 | Ericsson | Rel-18 | 96 |  |  |  |  |
| 1642 | 736.1 | Core part: Rel-18 NR inter-band Carrier Aggregation/Dual Connectivity for y bands DL (y=4, 5, 6) with x bands UL (x=1, 2) | 520d | 2022-06-15 A | 2024-06-06 A | 100% |  |  | finish no earlier than 2024-06-06 | R4 | 4160h | 4160h | NR_CADC_R18_yBDL_xBUL-Core | 49 | Reihaneh Malekafzaliardakani, Ericsson | Rel-18 | 96 | reihaneh.malekafzaliardakani@ericsson.com | RP-241328 |  |  |
| 1643 | 736.2 | Perf. part: Rel-18 NR inter-band Carrier Aggregation/Dual Connectivity for y bands DL (y=4, 5, 6) with x bands UL (x=1, 2) | 520d | 2022-06-15 A | 2024-06-06 A | 100% |  |  | finish no earlier than 2024-06-06 | R4 | 4160h | 4160h | NR_CADC_R18_yBDL_xBUL-Perf | 49 | Reihaneh Malekafzaliardakani, Ericsson | Rel-18 | 96 | reihaneh.malekafzaliardakani@ericsson.com | RP-241328 |  |  |
| 1644 | 737 | **APT 600MHz NR band** | 271.25d | 2022-06-15 A | 2023-03-03 A | 100% |  |  |  |  | 3008h | 3008h | NR_600MHz_APT | 49 | Spark NZ Ltd | Rel-18 | 96 |  |  |  |  |
| 1645 | 737.1 | Core part: APT 600MHz NR band | 188d | 2022-06-15 A | 2023-03-03 A | 100% |  |  | finish no earlier than 2023-03-03 | R4 | 1504h | 1504h | NR_600MHz_APT-Core | 49 | Mansoor Shafi, Spark New Zealand | Rel-18 | 96 | Mansoor.shafi@spark.co.nz | RP-230053 |  | 38.892 |
| 1646 | 737.2 | Perf. part: APT 600MHz NR band | 188d | 2022-06-15 A | 2023-03-03 A | 100% |  |  | finish no earlier than 2023-03-03 | R4 | 1504h | 1504h | NR_600MHz_APT-Perf | 49 | Mansoor Shafi, Spark New Zealand | Rel-18 | 96 | Mansoor.shafi@spark.co.nz | RP-230053 |  |  |

Notes:
- 1621: 6/10/23: WID:RP-230764->RP-232680; 2/1/24: WID:RP-232680->RP-233991
- 1622: ; 7/6/23: Compl:0%->50%; 6/9/23: Compl:50%->80%; WID: RP-230764->RP-231450; Stat Rep: ->RP-231833; Rapporteur: CATT->Shan Huiping, CATT; Rap eMail: ->shanhuiping@catt.cn; ; 8/12/23: Compl:80%->100%; Stat Rep: RP-231833->RP-233005;
- 1623: 6/9/23: WID: RP-230764->RP-231450; Stat Rep: ->RP-231833; Rapporteur: CATT->Shan Huiping, CATT; Rap eMail: ->shanhuiping@catt.cn¦01/24: stopped at 0% at RAN#102
- 1624: 29/3/23: WID:RP-223514->RP-230062
- 1625: 17/3/23: FCD:06/06/2023->03/03/2023; Compl:0%->100%; Stat Rep: ->RP-230061; Rapporteur: Ligado Networks->Ojas Choksi, Ligado Networks; Rap eMail: ->ojas.choksi@ligado.com;
- 1626: 17/3/23: FCD:06/06/2023->03/03/2023; Compl:0%->100%; Stat Rep: ->RP-230061; Rapporteur: Ligado Networks->Ojas Choksi, Ligado Networks; Rap eMail: ->ojas.choksi@ligado.com;
- 1627: 29/3/23: WID:RP-223529->RP-230723; 2/1/24: WID:RP-230723->RP-234044
- 1628: 17/3/23: Compl:0%->5%; Stat Rep: ->RP-230348; Rapporteur: Anterix->Emil Olbrich, Anterix; Rap eMail: ->eolbrich@anterix.com; ; 21/9/23: Compl:5%->25%; Stat Rep: RP-230348->RP-231956; Rapporteur: Emil Olbrich, Anterix->Gene Fong, Qualcomm Incorporated; Rap eMail: eolbrich@anterix.com->gfong@qti.qualcomm.com;
- 1629: 17/3/23: Stat Rep: ->RP-230348; Rapporteur: Anterix->Emil Olbrich, Anterix; Rap eMail: ->eolbrich@anterix.com; ; 21/9/23: Compl:0%->25%; Stat Rep: RP-230348->RP-231956; Rapporteur: Emil Olbrich, Anterix->Gene Fong, Qualcomm Incorporated; Rap eMail: eolbrich@anterix.com->gfong@qti.qualcomm.com;
- 1630: 23/9/22: WID:RP-221876->RP-222079; 9/1/23: WID:RP-222079->RP-222904; 29/3/23: WID:RP-222904->RP-230133; 6/10/23: WID:RP-230133->RP-231840; 2/1/24: WID:RP-231840->RP-232920; 2/4/24: WID:RP-232920->RP-240761; 23/7/24: WID:RP-240761->RP-241222
- 1631: 9/9/22: Comp...; 23/9/22: 38.718-02-01 added;; 9/12/22: FCD:23/12/2022->01/12/2023; Compl:5%->20%; Stat Rep: ->RP-222905; Rapporteur: ZTE->Wubin, Zhou, ZTE; Rap eMail: ->zhou.wubin@zte.com.cn; 17/3/23: FCD:30/11/2023->12/12/2023; Compl:2.....; 13/6/24: Compl:90%->100%; Stat Rep: RP-240247->RP-241223;
- 1632: 9/9/22: Comp...; 9/12/22: FCD:23/12/2022->01/12/2023; Compl:5%->20%; Stat Rep: ->RP-222905; Rapporteur: ZTE->Wubin, Zhou, ZTE; Rap eMail: ->zhou.wubin@zte.com.cn; 17/3/23: FCD:30/11/2023->12/12/2023; Compl:20%->40%; Stat Rep: RP-222905->.....; 23/7/24: 85%->100
- 1633: 23/9/22: WID:RP-221877->RP-222092; 9/1/23: WID:RP-222092->RP-222834; 29/3/23: WID:RP-222834->RP-230084; 6/10/23: WID:RP-230084->RP-231860; 2/1/24: WID:RP-231860->RP-233231; 2/4/24: WID:RP-233231->RP-240166; 23/7/24: WID:RP-240166->RP-241089
- 1634: 9/9/22: Comp...; 23/9/22: 38.718-03-01 added;; 9/12/22: FCD:23/12/2022->01/12/2023; Compl:10%->15%; Stat Rep: ->RP-222835; Rapporteur: ZTE->Zhifeng Ma, ZTE; Rap eMail: ->ma.zhifeng@zte.com.cn; 17/3/23: FCD:30/11/2023->12/12/2023; Compl:1.....; 13/6/24: Compl:90%->100%; Stat Rep: RP-240167->RP-241090;
- 1635: 9/9/22: CD:1...; 9/12/22: FCD:23/12/2022->01/12/2023; Stat Rep: ->RP-222835; Rapporteur: ZTE->Zhifeng Ma, ZTE; Rap eMail: ->ma.zhifeng@zte.com.cn; 17/3/23: Compl:0%->40%; Stat Rep: RP-222835->RP-230085; ...; 6/9/23: Compl:60%->75%; WID: RP...; 13/6/24: Compl:90%->100%; Stat Rep: RP-240167->RP-241090;
- 1638: 23/9/22: WID:RP-221835->RP-222105; 9/1/23: WID:RP-222105->RP-222846; 29/3/23: WID:RP-222846->RP-230067; 6/10/23: WID:RP-230067->RP-231623; 2/1/24: WID:RP-231623->RP-233990; 2/4/24: WID:RP-233990->RP-240238; 23/7/24: WID:RP-240238->RP-241140
- 1639: 9/9/22: CD:1...; 23/9/22: 38.718-01-01 added;; 9/12/22: FCD:23/12/2022->01/12/2023; Compl:0%->71%; Stat Rep: ->RP-222845; Rapporteur: Ericsson->Per Lindell, Ericsson; Rap eMail: ->per.lindell@ericsson.com; 17/3/23: FCD:30/11/2023->12/12/.....; 13/6/24: Compl:91%->100%; Stat Rep: RP-240237->RP-241139;
- 1640: 9/9/22: CD:1...; 9/12/22: FCD:23/12/2022->01/12/2023; Compl:0%->71%; Stat Rep: ->RP-222845; Rapporteur: Ericsson->Per Lindell, Ericsson; Rap eMail: ->per.lindell@ericsson.com; 17/3/23: FCD:30/11/2023->12/12/2023; Compl:71%->57%; Stat Rep.....; 13/6/24: FCD:12/12/2023->01/03/2024; Compl:91%->100%; Stat Rep: RP-240237->RP-241139;
- 1641: 23/9/22: WID:RP-221838->RP-222318; 9/1/23: WID:RP-222318->RP-223438; 29/3/23: WID:RP-223438->RP-230421; 6/10/23: WID:RP-230421->RP-231738; 2/1/24: WID:RP-231738->RP-233696; 2/4/24: WID:RP-233696->RP-240501; 23/7/24: WID:RP-240501->RP-241327
- 1642: 9/9/22: Comp...; 9/12/22: FCD:23/12/2022->01/12/2023; Compl:25%->29%; Stat Rep: ->RP-222911; Rapporteur: Ericsson->Reihaneh Malekafzaliardakani, Ericsson; Rap eMail: ->reihaneh.malekafzaliardakani@ericsson.com; 17/3/23: FCD:30/11/2023->1.....; 13/6/24: Compl:60%->100%; Stat Rep: RP-240502->RP-241328;
- 1643: 9/9/22: Comp...; 9/12/22: FCD:23/12/2022->01/12/2023; Compl:25%->29%; Stat Rep: ->RP-222911; Rapporteur: Ericsson->Reihaneh Malekafzaliardakani, Ericsson; Rap eMail: ->reihaneh.malekafzaliardakani@ericsson.com; 17/3/23: FCD:30/11/2023->1.....; 13/6/24: Compl:60%->100%; Stat Rep: RP-240502->RP-241328;
- 1644: 9/1/23: WID:RP-221778->RP-223265; 29/3/23: WID:RP-223265->RP-230060
- 1645: 9/9/22: Comp...; 23/9/22: 38.892 added;; 9/12/22: FCD:22/12/2022->01/03/2023; Compl:10%->95%; Stat Rep: ->RP-222803; Rapporteur: Spark NZ Ltd->Mansoor Shafi, Spark New Zealand; Rap eMail: ->Mansoor.shafi@spark.co.nz; 17/3/23: Compl:95%->...
- 1646: 9/9/22: Comp...; 9/12/22: FCD:23/03/2023->01/03/2023; Compl:10%->60%; Stat Rep: ->RP-222803; Rapporteur: Spark NZ Ltd->Mansoor Shafi, Spark New Zealand; Rap eMail: ->Mansoor.shafi@spark.co.nz; 17/3/23: Compl:60%->100%; WID: RP-223265->RP...

| ID | WBS | Task | Type | Duration | Start | Finish | Complete | Remaining | Actual finish | Total slack | Constraint | Resources | Work | Actual work | Acronym | PCG approved | Release | TSG approved | TSG stopped | Status Report | Impacted TSs and TRs |
| --- | --- | --- | --- | --- | --- | --- | --- | --- | --- | --- | --- | --- | --- | --- | --- | --- | --- | --- | --- | --- | --- |
| 1647 | 738 | **Stopped - Introduction of additional 6GHz NR licensed bands** |  | 564.38d | 2022-06-16 A | 2023-12-12 A | 100% |  |  |  |  |  | 6240h | 6240h | NR_6GHz_add_bands | 49 | Rel-18 | 96 | 102 |  |  |
| 1648 | 738.1 | Stopped - Core part: Introduction of additional 6GHz NR licensed bands |  | 390d | 2022-06-16 A | 2023-12-12 A | 100% |  |  |  | finish no earlier than 2023-12-12 | R4 | 3120h | 3120h | NR_6GHz_add_bands-Core | 49 | Rel-18 | 96 | 102 | RP-233184 |  |
| 1649 | 738.2 | Stopped - Perf. part: Introduction of additional 6GHz NR licensed bands |  | 390d | 2022-06-16 A | 2023-12-12 A | 100% |  |  |  | finish no earlier than 2023-12-12 | R4 | 3120h | 3120h | NR_6GHz_add_bands-Perf | 49 | Rel-18 | 96 | 102 | RP-233184 |  |
| 1650 | 739 | **Additional NR bands for UL-MIMO in Rel-18** |  | 944.12d | 2022-06-15 A | 2024-12-12 | 100% |  | 2025-06-06 |  |  |  | 13228h | 13228h | NR_bands_UL_MIMO_R18 | 49 | Rel-18 | 96 |  |  |  |
| 1651 | 739.1 | Core part: Additional NR bands for UL-MIMO in Rel-18 |  | 449d | 2022-06-15 A | 2024-03-01 A | 100% |  |  |  | finish no earlier than 2024-03-01 | R4 | 3592h | 3592h | NR_bands_UL_MIMO_R18-Core | 49 | Rel-18 | 96 |  | RP-240421 |  |
| 1652 | 739.2 | stopped - Perf. part: Additional NR bands for UL-MIMO in Rel-18 |  | 449d | 2022-06-15 A | 2024-03-01 A | 100% |  |  |  | finish no earlier than 2024-03-01 | R4 | 3592h | 3592h | NR_bands_UL_MIMO_R18-Perf | 49 | Rel-18 | 96 | 102 | RP-233198 |  |
| 1653 | 739.3 | UE Conformance - Additional NR bands for UL-MIMO in Rel-18 |  | 755.5d | 2023-06-08 A | 2025-06-06 A | 100% |  |  |  | finish no earlier than 2025-06-06 | R5 | 6044h | 6044h | NR_bands_UL_MIMO_R18-UEConTest | 51 | Rel-18 | 100 |  | RP-251509 |  |
| 1654 | 740 | **Enhancements of NR shared spectrum bands** |  | 369.75d | 2022-06-15 A | 2023-06-06 | 99% | 1.84d |  | 38780.5d |  |  | 4080h | 3544h | NR_unlic_enh | 49 | Rel-18 | 96 |  |  |  |
| 1655 | 740.1 | Core part: Enhancements of NR shared spectrum bands |  | 255d | 2022-06-15 A | 2023-06-06 A | 100% |  |  |  | finish no earlier than 2023-06-06 | R4 | 2040h | 2040h | NR_unlic_enh-Core | 49 | Rel-18 | 96 |  | RP-230729 |  |
| 1656 | 740.2 | Perf. part: Enhancements of NR shared spectrum bands |  | 255d | 2022-06-15 A | 2023-02-16 | 99% | 2.55d |  | 38895.2d | finish no earlier than 2023-06-06 | R4 | 2040h | 1504h | NR_unlic_enh-Perf | 49 | Rel-18 | 96 |  | RP-230729 |  |
| 1657 | 741 | **Introduction of LTE TDD band in 1670-1675 MHz** |  | 660.62d | 2022-03-15 A | 2023-12-12 A | 100% |  |  |  |  |  | 4640h | 4640h | LTE_TDD_1670_1675MHz | 48 | Rel-18 | 95 |  |  |  |
| 1658 | 741.1 | Core part: Introduction of LTE TDD band in 1670-1675 MHz |  | 188d | 2022-03-15 A | 2022-12-01 A | 100% |  |  |  | finish no earlier than 2022-12-01 | R4 | 1504h | 1504h | LTE_TDD_1670_1675MHz-Core | 48 | Rel-18 | 95 |  | RP-222830 |  |
| 1659 | 741.2 | Perf. part: Introduction of LTE TDD band in 1670-1675 MHz |  | 188d | 2022-03-15 A | 2022-12-01 A | 100% |  |  |  | finish no earlier than 2022-12-01 | R4 | 1504h | 1504h | LTE_TDD_1670_1675MHz-Perf | 48 | Rel-18 | 95 |  | RP-222830 |  |
| 1660 | 741.3 | UE Conformance - Introduction of LTE TDD band in 1670 – 1675 MHz |  | 204d | 2023-03-03 A | 2023-12-12 A | 100% |  |  |  | finish no earlier than 2023-12-12 | R5 | 1632h | 1632h | LTE_TDD_1670_1675MHz-UEConTest | 50 | Rel-18 | 99 |  | RP-232784 |  |
| 1661 | 742 | Study on UE support of regionally-defined subsets of an NR band |  | 188d | 2022-06-15 A | 2023-03-03 A | 100% |  |  |  | finish no earlier than 2023-03-03 | RP | 1504h | 1504h | FS_NR_subset_band_support | 49 | Rel-18 | 96 |  | RP-230340 | 38.893 |
| 1662 | 743 | UE Conformance - New Rel-18 NR licensed bands and extension of existing NR bands |  | 399d | 2023-06-08 A | 2024-12-12 A | 100% |  |  |  | finish no earlier than 2024-12-12 | R5 | 3192h | 3192h | NR_lic_bands_BW_R18-UEConTest | 51 | Rel-18 | 100 |  | RP-243088 |  |
| 1663 | 744 | Rel-18 Other NR and LTE | milestone | 0d? | 2019-03-07 | 2019-03-07 |  |  |  | 40388.9d |  |  |  |  |  |  | Rel-18 |  |  |  |  |
| 1664 | 745 | **Rel-18 basket WI 3Tx NR inter-band UL Carrier Aggregation (CA) and EN-DC** |  | 281.38d | 2023-09-09 A | 2024-06-06 A | 100% |  |  |  |  | R4 | 3152h | 3152h | R18_3Tx_NR_CA_ENDC | 51 | Rel-18 | 101 |  |  |  |
| 1665 | 745.1 | Core pat: Rel-18 basket WI 3Tx NR inter-band UL Carrier Aggregation (CA) and EN-DC |  | 197d | 2023-09-09 A | 2024-06-06 A | 100% |  |  |  | finish no earlier than 2024-06-06 | R4 | 1576h | 1576h | R18_3Tx_NR_CA_ENDC-Core | 51 | Rel-18 | 101 |  | RP-241150 | 38.88 |
| 1666 | 746 | **Rel-18 High power UE (power class m with 1<m<3) for a single FR1 band in UL of Dual Connectivity (DC) combinations of x bands (x=1,2,3, 4 for y=1 or x=1, 2 for y=2) LTE inter-band CA (xDL/1UL) and y bands NR inter-band CA (yDL/1UL)** |  | 656.12d | 2022-09-12 A | 2024-06-06 A | 100% |  |  |  |  |  | 6280h | 6280h | HPUE_FR1_DC_LTE_NR_R18 | 49 | Rel-18 | 97 |  |  |  |
| 1667 | 746.1 | Core part: Rel-18 High power UE (power class m with 1<m<3) for a single FR1 band in UL of Dual Connectivity (DC) combinations of x bands (x=1,2,3, 4 for y=1 or x=1, 2 for y=2) LTE inter-band CA (xDL/1UL) and y bands NR inter-band CA (yDL/1UL) |  | 457d | 2022-09-12 A | 2024-06-06 A | 100% |  |  |  | finish no earlier than 2024-06-06 | R4 | 3656h | 3656h | HPUE_FR1_DC_LTE_NR_R18-Core | 49 | Rel-18 | 97 |  | RP-241143 | 38.898 |
| 1668 | 746.2 | Stopped - Perf. part: Rel-18 High power UE (power class m with 1<m<3) for a single FR1 band in UL of Dual Connectivity (DC) combinations of x bands (x=1,2,3, 4 for y=1 or x=1, 2 for y=2) LTE inter-band CA (xDL/1UL) and y bands NR inter-band CA (yDL/1UL) |  | 328d | 2022-09-12 A | 2023-12-12 A | 100% |  |  |  | finish no earlier than 2024-03-01 | R4 | 2624h | 2624h | HPUE_FR1_DC_LTE_NR_R18-Perf | 49 | Rel-18 | 97 | 102 | RP-240240 |  |
| 1669 | 747 | UE Conformance - Rel-18 High Power UE for NR CA and DC; and NR and LTE DC Configurations; |  | 1035.25d | 2023-06-08 A | 2026-03-03 | 98% | 20.7d |  | 37744.2d | finish no earlier than 2026-03-03 | R5 | 8282h |  | HPUE_NR_CADC_NR_LTE_DC_R18-UEConTest | 51 | Rel-18 | 100 |  | RP-253465 |  |
| 1670 | 748 | **High-power UE operation for fixed-wireless/vehicle-mounted use cases in LTE bands and NR bands** |  | 655d | 2022-06-15 A | 2024-12-12 A | 100% |  |  |  |  |  | 7352h | 7352h | LTE_NR_HPUE_FWVM_R18 | 49 | Rel-18 | 96 |  |  |  |
| 1671 | 748.1 | Core part: High-power UE operation for fixed-wireless/vehicle-mounted use cases in LTE bands and NR bands |  | 520d | 2022-06-15 A | 2024-06-06 A | 100% |  |  |  | finish no earlier than 2024-06-06 | R4 | 4160h | 4160h | LTE_NR_HPUE_FWVM_R18-Core | 49 | Rel-18 | 96 |  | RP-240942 | 37.829 |
| 1672 | 748.2 | UE Conformance - High-power UE operation for fixed-wireless/vehicle-mounted use cases in LTE bands and NR bands in Rel-18 |  | 399d | 2023-06-08 A | 2024-12-12 A | 100% |  |  |  | finish no earlier than 2024-12-12 | R5 | 3192h | 3192h | LTE_NR_HPUE_FWVM_R18-UEConTest | 51 | Rel-18 | 100 |  | RP-242836 |  |
| 1673 | 749 | UE Conformance - Rel-18 NR CA and DC; and NR and LTE DC Configurations |  | 1132.5d | 2023-06-08 A | 2026-06-05 | 76% | 271.8d |  | 37647d | finish no earlier than 2026-06-05 | R5 | 9060h |  | NR_CADC_NR_LTE_DC_R18-UEConTest | 51 | Rel-18 | 100 |  | RP-253427 |  |

Notes:
- 1647: 23/9/22: WID:RP-221845->RP-22249801/24: stopped at 0% at RAN#102 / WI rapporteur name: Huawei
- 1648: 9/9/22: CD:1…; 9/12/22: FCD:23/12/2022->01/12/2023; WID: RP-221845->RP-222498; Stat Rep: ->RP-223341; Rapporteur: Huawei->Liehai Liu, Dominique Everaere, Iwajlo Angelow, Fei Xue, Huawei, Ericsson, Nokia, ZTE Corporation¦01/24: stopped at 0% at RAN#102 / WI rapporteur name: Liehai Liu, Dominique Everaere, Iwajlo Angelow, Fei Xue, Huawei, Ericsson, Nokia, ZTE Corporation / WI rapporteur e-mail: liuliehai@huawei.com, dominique.everaere@ericsson.com, iwajlo.angelow@nokia.com, xue.fei25@zte.com.cn
- 1649: 9/9/22: CD:1...; 9/12/22: FCD:23/12/2022->01/12/2023; WID: RP-221845->RP-222498; Stat Rep: ->RP-223341; Rapporteur: Huawei->Liehai Liu, Dominique Everaere, Iwajlo Angelow, Fei Xue, Huawei, Ericsson, Nokia, ZTE Corporation; Rap eMail: ->liu...; 8/12/23: Stat Rep: RP-232364->RP-233184¦01/24: stopped at 0% / WI rapporteur name: Liehai Liu, Dominique Everaere, Iwajlo Angelow, Fei Xue, Huawei, Ericsson, Nokia, ZTE Corporation / WI rapporteur e-mail: liuliehai@huawei.com, dominique.everaere@ericsson.com, iwajlo.angelow@nokia.com, xue.fei25@zte.com.cn
- 1650: 23/9/22: WID:RP-221844->RP-222509; 9/1/23: WID:RP-222509->RP-223516; 6/10/23: WID:RP-223516->RP-232374; 2/1/24: WID:RP-232374->RP-234040; 2/4/24: WID:RP-234040->RP-240422 / WI rapporteur name: Huawei
- 1651: 9/9/22: Comp...; 9/12/22: FCD:23/12/2022->01/12/2023; Compl:10%->15%; Stat Rep: ->RP-223351; Rapporteur: Huawei->Xiang Gao, Huawei; Rap eMail: ->gaoxiang74@huawei.com; 17/3/23: FCD:30/11/2023->12/12/2023; Compl:15%->25%; Stat Rep: RP-223.....; 14/3/24: Compl:90%->100%; Stat Rep: RP-233198->RP-240421; / WI rapporteur name: Xiang Gao, Huawei / WI rapporteur e-mail: gaoxiang74@huawei.com
- 1652: 9/9/22: CD:1...; 9/12/22: FCD:23/12/2022->01/12/2023; Compl:0%->15%; Stat Rep: ->RP-223351; Rapporteur: Huawei->Xiang Gao, Huawei; Rap eMail: ->gaoxiang74@huawei.com; 17/3/23: FCD:30/11/2023->12/12/2023; Compl:15%->25%; Stat Rep: RP-2233.....; 8/12/23: FCD:12/12/2023->01/03/2024; Compl:70%->90%; Stat Rep: RP-232373->RP-233198¦01/24: stopped at 90% at RAN#102 / WI rapporteur name: Xiang Gao, Huawei / WI rapporteur e-mail: gaoxiang74@huawei.com
- 1653: 6/9/23: Compl:0%->49%; Stat Rep: ->RP-231550; Rapporteur: China Unicom->Shi，Yu, China Unicom; Rap eMail: ->shiyu19@chinaunicom.cn; ; 8/12/23: Stat Rep: RP-231550->RP-232771; ; 2/1/24: WID:RP-230868->RP-232772; 14/3/24: FCD:05/06/2024->12/12/2024; Stat ...; / WI rapporteur name: Shi，Yu, China Unicom / WI rapporteur e-mail: shiyu19@chinaunicom.cn
- 1654: 23/9/22: WID:RP-221813->RP-222174; 29/3/23: WID:RP-222174->RP-230730 / WI rapporteur name: Apple
- 1655: 9/9/22: Comp...; 9/12/22: FCD:23/03/2023->01/03/2023; Compl:15%->50%; Stat Rep: ->RP-223194; Rapporteur: Apple->Daniel Popp, Apple Inc.; Rap eMail: ->d_popp@apple.com; 17/3/23: FCD:03/03/2023->08/09/2023; Compl:50%->85%; Stat Rep: RP-223... / WI rapporteur name: Daniel Popp, Apple Inc. / WI rapporteur e-mail: d_popp@apple.com
- 1656: 9/12/22: FCD:15/03/2023->01/03/2023; Compl:0%->50%; Stat Rep: RP-222175->RP-223194; Rapporteur: Apple->Daniel Popp, Apple Inc.; Rap eMail: ->d_popp@apple.com; 17/3/23: Compl:50%->100%; Stat Rep: RP-223194->RP-230152; 31/3/23: FCD:03/03/2023->06/06... / WI rapporteur name: Daniel Popp, Apple Inc. / WI rapporteur e-mail: d_popp@apple.com
- 1657: 9/1/23: WID:RP-220971->RP-222831 / WI rapporteur name: Ligado Networks
- 1658: ; 6/6/22: Compl:0%->15% ; 6/6 ; 20/6/22: Rapporteur: Ligado Networks->Ojas Choksi, Ligado Networks; Rap eMail: ->ojas.choksi@ligado.com ...; 9/12/22: FCD:22/12/2022->01/12/2022; Compl:50%->100%; Stat Rep: RP-221061->RP-222830; 9/1/23: 100%->100 / WI rapporteur name: Ojas Choksi, Ligado Networks / WI rapporteur e-mail: ojas.choksi@ligado.com
- 1659: ; 6/6/22: CD:15/12/2022->22/12/2022; 6/6/22: Stat Rep: ->RP-221061; 20/6/22: Rapporteur: Ligado Networks->Ojas Choksi, Ligado Networks; Rap eMail: ->ojas.choksi@ligado.com; 9/12/22: FCD:22/12/2022->01/12/2022; Compl:0%->100%; Stat Rep: RP-221061->RP... / WI rapporteur name: Ojas Choksi, Ligado Networks / WI rapporteur e-mail: ojas.choksi@ligado.com
- 1660: ; 7/6/23: Compl:0%->83%; 7/6/23: CD:09/09/2023->...; 6/9/23: Compl:83%->99%; WID: RP-230063->RP-230907; Stat Rep: ->RP-231546; Rapporteur: Ligado Networks->Ojas Choksi, Ligado Networks; Rap eMail: ->ojas.choksi@ligado.com; ; 6/10/23: WID:RP-230907->RP...; 2/1/24: WID:RP-231545->RP-232783 / WI rapporteur name: Ojas Choksi, Ligado Networks / WI rapporteur e-mail: ojas.choksi@ligado.com
- 1661: 23/9/22: FCD:15/12/2022->12/20; 23/9/22: 0%->40; 23/9/22: WID:RP-221872->RP-222220; 23/9/22: 38.893 added;; 9/1/23: WID:RP-222220->RP-223556; 29/3/23: FCD:12/12/2023->03/23; 29/3/23: 40%->100; 31/3/23: Stat Rep: RP-222222->RP-230340; Rapporteur: Qualcomm->Gene Fong, Qualcomm Incorporated; Rap eMail: ->gfong@qti.qualcomm.com; / WI rapporteur name: Gene Fong, Qualcomm Incorporated / WI rapporteur e-mail: gfong@qti.qualcomm.com
- 1662: 6/9/23: FCD:06/06/2025->06/06/2024; Compl:0%->5%; Stat Rep: ->RP-232360; Rapporteur: Huawei->Yuxin Hao, Huawei Technologies. Co., Ltd.; Rap eMail: ->haoyuxin@huawei.com; ; 6/10/23: WID:RP-231249->RP-232361; 8/12/23: FCD:06/06/2024->06/06/2025; Stat Rep...; 24/1/25: 99%->100 / WI rapporteur name: Yuxin Hao, Huawei Technologies. Co., Ltd. / WI rapporteur e-mail: haoyuxin@huawei.com
- 1663: -
- 1664: 2/1/24: WID:RP-232674->RP-232941; 2/4/24: WID:RP-232941->RP-240307; 23/7/24: WID:RP-240307->RP-241149 / WI rapporteur name: Oppo
- 1665: 8/12/23: FCD:12/12/2023->01/03/2024; Compl:0%->30%; Stat Rep: ->RP-232940; Rapporteur: Oppo->Jinqiang Xing, OPPO; Rap eMail: ->xingjinqiang@oppo.com; ; 4/1/24: 38.880 added;; 14/3/24: FCD:01/03/2024->06/06/2024; Compl:30%->70%; Stat Rep: RP-232940->RP...; 13/6/24: Compl:70%->100%; Stat Rep: RP-240308->RP-241150; / WI rapporteur name: Jinqiang Xing, OPPO / WI rapporteur e-mail: xingjinqiang@oppo.com
- 1666: 9/1/23: WID:RP-222660->RP-222848; 29/3/23: WID:RP-222848->RP-230069; 6/10/23: WID:RP-230069->RP-231625; 2/1/24: WID:RP-231625->RP-233977; 2/4/24: WID:RP-233977->RP-240241; 23/7/24: WID:RP-240241->RP-241144 / WI rapporteur name: Ericsson
- 1667: 9/12/22: FCD:12/12/2023->01/12/2023; Compl:0%->14%; Stat Rep: ->RP-222847; Rapporteur: Ericsson->Per Lindell, Ericsson; Rap eMail: ->per.lindell@ericsson.com; 17/3/23: FCD:30/11/2023->12/12/2023; Compl:14%->19%; Stat Rep: RP-222847->RP-230068; 17/...;...; 13/6/24: Compl:75%->100%; Stat Rep: RP-240240->RP-241143; / WI rapporteur name: Per Lindell, Ericsson / WI rapporteur e-mail: per.lindell@ericsson.com
- 1668: 9/12/22: FCD:12/12/2023->01/12/2023; Compl:0%->14%; Stat Rep: ->RP-222847; Rapporteur: Ericsson->Per Lindell, Ericsson; Rap eMail: ->per.lindell@ericsson.com; 17/3/23: FCD:30/11/2023->12/12/2023; Compl:14%->19%; Stat Rep: RP-222847->RP-230068; ;...; 6...; 23/7/24: 79%->100 / WI rapporteur name: Per Lindell, Ericsson / WI rapporteur e-mail: per.lindell@ericsson.com
- 1669: 6/9/23: FCD:06/06/2025->06/06/2024; Compl:0%->5%; Stat Rep: ->RP-232259; Rapporteur: China Telecom->Lei GAO, China Telecom; Rap eMail: ->gaol8@chinatelecom.cn; ; 8/12/23: FCD:06/06/2024->06/06/2025; Compl:5%->15%; Stat Rep: RP-232259->RP-233565; ; 14/3...; 3/12/25: FCD:Fri 12/12/25->Tue 03/03/26; Compl:95%->98%; Stat Rep: RP-252545->RP-253465; / WI rapporteur name: Lei GAO, China Telecom / WI rapporteur e-mail: gaol8@chinatelecom.cn
- 1670: 19/10/22: acronym corrected; 9/1/23: WID:RP-221841->RP-223424; 6/10/23: WID:RP-223424->RP-231615; 2/1/24: WID:RP-231615->RP-233180; 2/4/24: WID:RP-233180->RP-240361; 23/7/24: WID:RP-240361->RP-240941 / WI rapporteur name: Nokia
- 1671: 9/9/22: Comp...; 23/9/22: 37.829 added;; 9/12/22: FCD:23/12/2022->01/12/2023; Compl:10%->30%; WID: RP-222058->RP-221841; Stat Rep: ->RP-222825; Rapporteur: Nokia->Petri Vasenkari, Nokia; Rap eMail: ->petri.j.vasenkari@nokia.com; 17/3/23:.....; 13/6/24: Compl:80%->100%; WID: RP-233180->RP-240361; Stat Rep: RP-240362->RP-240942; / WI rapporteur name: Petri Vasenkari, Nokia / WI rapporteur e-mail: petri.j.vasenkari@nokia.com
- 1672: 6/9/23: Compl:0%->18%; Stat Rep: ->RP-231612; Rapporteur: Nokia->Tuomo S yn j kangas, Nokia; Rap eMail: ->tuomo.saynajakangas@nokia.com; ; 6/10/23: WID:RP-231429->RP-231613; 8/12/23: WID: RP-231615->RP-231613; Stat Rep: RP-231612->RP-232856; ; 14/3/24:...; 24/1/25: 99%->100 / WI rapporteur name: Tuomo S yn j kangas, Nokia / WI rapporteur e-mail: tuomo.saynajakangas@nokia.com
- 1673: 6/9/23: FCD:06/06/2025->06/06/2024; Compl:0%->5%; Stat Rep: ->RP-232359; Rapporteur: Huawei->Yuxin Hao, Huawei Technologies. Co., Ltd.; Rap eMail: ->haoyuxin@huawei.com; ; 8/12/23: FCD:06/06/2024->06/06/2025; Stat Rep: RP-232359->RP-233767; ; 14/3/24: ...; 3/12/25: FCD:Fri 12/12/25->Fri 05/06/26; Stat Rep: RP-252645->RP-253427; / WI rapporteur name: Chunying GU, Huawei Technologies. Co., Ltd. / WI rapporteur e-mail: guchunying@huawei.com

| ID | WBS | Task | Duration | Start | Finish | Complete | Remaining | Total slack | Constraint | Resources | Work | Actual work | Acronym | PCG approved | WI rapporteur name | Release | TSG approved | WI rapporteur e-mail | Status Report | Impacted TSs and TRs | TSG stopped |
| --- | --- | --- | --- | --- | --- | --- | --- | --- | --- | --- | --- | --- | --- | --- | --- | --- | --- | --- | --- | --- | --- |
| 1674 | 750 | **4Rx handheld UE for low NR bands (<1GHz) and/or 3Tx for NR inter-band UL Carrier Aggregation (CA) and EN-DC** | 377.88d | 2022-12-13 A | 2023-12-12 A | 100% |  |  |  |  | 2096h | 2096h | 4Rx_low_NR_band_handheld_3Tx_NR_CA_ENDC | 50 | Oppo | Rel-18 | 98 |  |  |  |  |
| 1675 | 750.1 | Core part: 4Rx handheld UE for low NR bands (<1GHz) and/or 3Tx for NR inter-band UL Carrier Aggregation (CA) and EN-DC | 262d | 2022-12-13 A | 2023-12-12 A | 100% |  |  | finish no earlier than 2023-12-12 | R4 | 2096h | 2096h | 4Rx_low_NR_band_handheld_3Tx_NR_CA_ENDC-Core | 50 | Jinqiang Xing, OPPO | Rel-18 | 98 | xingjinqiang@oppo.com | RP-232937 |  |  |
| 1676 | 751 | UE Conformance - 4Rx handheld UE for low NR bands (<1GHz) and/or 3Tx for NR inter-band UL Carrier Aggregation (CA) and EN-DC | 462.62d | 2023-12-13 A | 2025-03-03 A | 100% |  |  | finish no earlier than 2025-03-03 | R5 | 3701h | 3701h | 4Rx_low_NR_band_handheld_3Tx_NR_CA_ENDC-UEConTest | 52 | Yaping ZHANG, Huawei | Rel-18 | 102 | zhangyaping13@huawei.com | RP-250446 |  |  |
| 1677 | 752 | **Simultaneous Rx/Tx band combinations for NR CA/DC, NR SUL and LTE/NR DC in Rel-18** | 526d | 2022-09-08 A | 2024-09-09 A | 100% |  |  |  |  | 7880h | 7880h | LTE_NR_Simult_RxTx_R18 | 49 | Huawei | Rel-18 | 97 |  |  |  |  |
| 1678 | 752.1 | Core part: Simultaneous Rx/Tx band combinations for NR CA/DC, NR SUL and LTE/NR DC in Rel-18 | 459d | 2022-09-08 A | 2024-06-06 A | 100% |  |  | finish no earlier than 2024-06-06 | R4 | 3672h | 3672h | LTE_NR_Simult_RxTx_R18-Core | 49 | Dan Hu, Huawei | Rel-18 | 97 | hudan11@huawei.com | RP-241250 | 38.894 |  |
| 1679 | 752.2 | Stopped - Perf. part: Simultaneous Rx/Tx band combinations for NR CA/DC, NR SUL and LTE/NR DC in Rel-18 | 388d | 2022-09-08 A | 2024-03-01 A | 100% |  |  | finish no earlier than 2024-03-01 | R4 | 3104h | 3104h | LTE_NR_Simult_RxTx_R18-Perf | 49 | Dan Hu, Huawei | Rel-18 | 97 | hudan11@huawei.com | RP-233201 |  | 102 |
| 1680 | 752.3 | UE Conformance - Simultaneous Rx/Tx band combinations for NR CA/DC, NR SUL and LTE/NR DC in Rel-18 | 138d | 2024-03-03 A | 2024-09-09 A | 100% |  |  | finish no earlier than 2024-09-24 | R5 | 1104h | 1104h | LTE_NR_Simult_RxTx_R18-UEConTest | 52 | Huawei | Rel-18 | 103 |  | RP-242076 |  |  |
| 1681 | 753 | **Enhancement of UE TRP (Total Radiated Power) and TRS (Total Radiated Sensitivity) requirements and test methodologies for FR1 (NR SA and EN-DC)** | 1038.25d | 2022-09-08 A | 2025-06-06 A | 100% |  |  |  |  | 12031h | 12031h | NR_FR1_TRP_TRS_enh | 49 | Vivo | Rel-18 | 97 |  |  |  |  |
| 1682 | 753.1 | Core part: Enhancement of UE TRP and TRS requirements and test methodologies for FR1 (NR SA and EN-DC) | 601d | 2022-09-08 A | 2024-12-23 A | 100% |  |  | finish no earlier than 2024-12-23 | R4 | 4808h | 4808h | NR_FR1_TRP_TRS_enh-Core | 49 | Wang, Ruixin, vivo | Rel-18 | 97 | ruixin.wang@vivo.com | RP-241829 | 38.87 |  |
| 1683 | 753.2 | Perf. Part: Enhancement of UE TRP and TRS requirements and test methodologies for FR1 (NR SA and EN-DC) | 524d | 2022-09-12 A | 2024-09-09 A | 100% |  |  | finish no earlier than 2024-09-24 | R4 | 4192h | 4192h | NR_FR1_TRP_TRS_enh-Perf | 49 | Wang, Ruixin, vivo | Rel-18 | 97 | ruixin.wang@vivo.com | RP-241829 |  |  |
| 1684 | 753.3 | UE Conformance - Enhancement of UE TRP (Total Radiated Power) and TRS (Total Radiated Sensitivity) requirements and test methodologies for FR1 (NR SA and EN-DC) | 378.88d | 2024-06-06 A | 2025-06-06 A | 100% |  |  | finish no earlier than 2025-06-06 | R5 | 3031h | 3031h | NR_FR1_TRP_TRS_enh-UEConTest | 53 | Apple | Rel-18 | 104 |  | RP-251178 |  |  |
| 1685 | 754 | **Rel-18 single SUL band combinations for SA NR supplementary uplink (SUL), NSA NR SUL, NSA NR SUL with UL sharing from the UE perspective (ULSUP)** | 748.38d | 2022-06-15 A | 2024-06-06 A | 100% |  |  |  |  | 7752h | 7752h | NR_SUL_combos_R18 | 49 | Huawei | Rel-18 | 96 |  |  |  |  |
| 1686 | 754.1 | Core part: Rel-18 single SUL band combinations for SA NR supplementary uplink (SUL), NSA NR SUL, NSA NR SUL with UL sharing from the UE perspective (ULSUP) | 520d | 2022-06-15 A | 2024-06-06 A | 100% |  |  | finish no earlier than 2024-06-06 | R4 | 4160h | 4160h | NR_SUL_combos_R18-Core | 49 | Zhang, Peng, Huawei | Rel-18 | 96 | zhangpeng169@huawei.com | RP-241247 | 37.718-00-00 |  |
| 1687 | 754.2 | Stopped - Perf. Part: Rel-18 single SUL band combinations for SA NR supplementary uplink (SUL), NSA NR SUL, NSA NR SUL with UL sharing from the UE perspective (ULSUP) | 449d | 2022-06-15 A | 2024-03-01 A | 100% |  |  | finish no earlier than 2024-03-01 | R4 | 3592h | 3592h | NR_SUL_combos_R18-Perf | 49 | Zhang, Peng, Huawei | Rel-18 | 96 | zhangpeng169@huawei.com | RP-241247 |  |  |
| 1688 | 755 | **Rel-18 Dual Connectivity (DC) of 1 band LTE (1DL/1UL) and 1 NR band (1DL/1UL)** | 748.38d | 2022-06-15 A | 2024-06-06 A | 100% |  |  |  |  | 8312h | 8312h | DC_R18_1BLTE_1BNR_2DL2UL | 49 | CHTTL | Rel-18 | 96 |  |  |  |  |
| 1689 | 755.1 | Core part: Rel-18 Dual Connectivity (DC) of 1 band LTE (1DL/1UL) and 1 NR band (1DL/1UL) | 520d | 2022-06-15 A | 2024-06-06 A | 100% |  |  | finish no earlier than 2024-06-06 | R4 | 4160h | 4160h | DC_R18_1BLTE_1BNR_2DL2UL-Core | 49 | Bo-Han Hsieh (Tank), CHTTL | Rel-18 | 96 | pohanhsieh@cht.com.tw | RP-241219 | 37.718-11-11 |  |
| 1690 | 755.2 | Perf. part: Rel-18 Dual Connectivity (DC) of 1 band LTE (1DL/1UL) and 1 NR band (1DL/1UL) | 519d | 2022-06-16 A | 2024-06-06 A | 100% |  |  | finish no earlier than 2024-06-06 | R4 | 4152h | 4152h | DC_R18_1BLTE_1BNR_2DL2UL-Perf | 49 | Bo-Han Hsieh (Tank), CHTTL | Rel-18 | 96 | pohanhsieh@cht.com.tw | RP-241219 |  |  |
| 1691 | 756 | **Rel-18 Dual Connectivity (DC) of x LTE bands and y NR bands with z bands DL and 3 bands UL (x=1, 2, 3, 4; y=1, 2; 3<=z<=6)** | 748.38d | 2022-06-15 A | 2024-06-06 | 87% | 96.36d | 38401.9d |  |  | 7288h | 4160h | DC_R18_xBLTE_yBNR_zDL3UL | 49 | Samsung | Rel-18 | 96 |  |  |  |  |
| 1692 | 756.1 | Core part: Rel-18 Dual Connectivity (DC) of x LTE bands and y NR bands with z bands DL and 3 bands UL (x=1, 2, 3, 4; y=1, 2; 3<=z<=6) | 520d | 2022-06-15 A | 2024-06-06 A | 100% |  |  | finish no earlier than 2024-06-06 | R4 | 4160h | 4160h | DC_R18_xBLTE_yBNR_zDL3UL-Core | 49 | Yuanyuan Zhang, Samsung | Rel-18 | 96 | Tina55.zhang@samsung.com | RP-241273 |  |  |
| 1693 | 756.2 | Perf. part: Rel-18 Dual Connectivity (DC) of x LTE bands and y NR bands with z bands DL and 3 bands UL (x=1, 2, 3, 4; y=1, 2; 3<=z<=6) | 391d | 2022-06-15 A | 2023-06-27 | 70% | 117.3d | 38759.2d | finish no earlier than 2023-12-12 | R4 | 3128h |  | DC_R18_xBLTE_yBNR_zDL3UL-Perf | 49 | Yuanyuan Zhang, Samsung | Rel-18 | 96 | Tina55.zhang@samsung.com | RP-241273 |  |  |
| 1694 | 757 | **Rel-18 Dual Connectivity (DC) of x bands (x=1,2,3,4) LTE inter-band CA (xDL/1UL) and 2 bands NR inter-band CA (2DL/1UL)** | 748.38d | 2022-06-15 A | 2024-06-06 A | 100% |  |  |  |  | 7752h | 7752h | DC_R18_xBLTE_2BNR_yDL2UL | 49 | LG Electronics | Rel-18 | 96 |  |  |  |  |
| 1695 | 757.1 | Core part: Rel-18 Dual Connectivity (DC) of x bands (x=1,2,3,4) LTE inter-band CA (xDL/1UL) and 2 bands NR inter-band CA (2DL/1UL) | 520d | 2022-06-15 A | 2024-06-06 A | 100% |  |  | finish no earlier than 2024-06-06 | R4 | 4160h | 4160h | DC_R18_xBLTE_2BNR_yDL2UL-Core | 49 | Sang-Wook Lee, LG Electronics | Rel-18 | 96 | sangwook1.lee@lge.com | RP-241053 | 37.718-11-21 |  |
| 1696 | 757.2 | Stopped - Perf. Part: Rel-18 Dual Connectivity (DC) of x bands (x=1,2,3,4) LTE inter-band CA (xDL/1UL) and 2 bands NR inter-band CA (2DL/1UL) | 449d | 2022-06-15 A | 2024-03-01 A | 100% |  |  | finish no earlier than 2024-06-06 | R4 | 3592h | 3592h | DC_R18_xBLTE_2BNR_yDL2UL-Perf | 49 | Sang-Wook Lee, LG Electronics | Rel-18 | 96 | sangwook1.lee@lge.com | RP-241053 |  |  |
| 1697 | 758 | **Rel-18 Dual Connectivity (DC) of 2 bands LTE inter-band CA (2DL/1UL) and 1 NR band (1DL/1UL)** | 748.38d | 2022-06-15 A | 2024-06-06 A | 100% |  |  |  |  | 7752h | 7752h | DC_R18_2BLTE_1BNR_3DL2UL | 49 | Huawei | Rel-18 | 96 |  |  |  |  |
| 1698 | 758.1 | Core part: Rel-18 Dual Connectivity (DC) of 2 bands LTE inter-band CA (2DL/1UL) and 1 NR band (1DL/1UL) | 520d | 2022-06-15 A | 2024-06-06 A | 100% |  |  | finish no earlier than 2024-06-06 | R4 | 4160h | 4160h | DC_R18_2BLTE_1BNR_3DL2UL-Core | 49 | Liehai Liu, Huawei | Rel-18 | 96 | liuliehai@huawei.com | RP-241244 | 37.718-21-11 |  |
| 1699 | 758.2 | Stopped - Perf. part: Rel-18 Dual Connectivity (DC) of 2 bands LTE inter-band CA (2DL/1UL) and 1 NR band (1DL/1UL) | 449d | 2022-06-15 A | 2024-03-01 A | 100% |  |  | finish no earlier than 2024-03-01 | R4 | 3592h | 3592h | DC_R18_2BLTE_1BNR_3DL2UL-Perf | 49 | Liehai Liu, Huawei | Rel-18 | 96 | liuliehai@huawei.com | RP-233192 |  | 102 |

Notes:
- 1674: 29/3/23: WID:RP-223517->RP-230161; 6/10/23: WID:RP-230161->RP-231719; 2/1/24: WID:RP-231719->RP-234046
- 1675: 17/3/23: Compl:0%->10%; Stat Rep: ->RP-230160; Rapporteur: Oppo->Jinqiang Xing, OPPO; Rap eMail: ->xingjinqiang@oppo.com; ; 29/6/23: 10%->70; 6/9/23: Compl:70%->85%; WID: RP-230161->RP-231013; Stat Rep: RP-231012->RP-231718; ; 8/12/23: Compl:85%->100%; Stat Rep: RP-231718->RP-232937;
- 1676: 14/3/24: Compl:0%->7%; Stat Rep: ->RP-240289; Rapporteur: Huawei->Yaping ZHANG, Huawei; Rap eMail: ->zhangyaping13@huawei.com; 2/4/24: corrected: rel-19->Rel-18; 13/6/24: Compl:7%->26%; Stat Rep: RP-240289->RP-241376; ; 4/9/24: FCD:06/06/2025->25/06/2025;; 3/4/25: WID:RP-233771->RP-250447
- 1677: 9/1/23: WID:RP-222648->RP-223354; 2/1/24: WID:RP-223354->RP-234002; 2/4/24: WID:RP-234002->RP-240425; 23/7/24: WID:RP-240425->RP-241251
- 1678: 9/12/22: Acronym:LTE_NR_Simult_RxTx_R18-Core->LTE_NR _Simult_RxTx_R18-Core; FCD:10/12/2023->01/12/2023; Compl:0%->20%; Stat Rep: ->RP-223353; Rapporteur: Huawei->Dan Hu, Huawei; Rap eMail: ->hudan11@huawei.com; 17/3/23: FCD:30/11/2023->12/12/2023; C.....; 13/6/24: Compl:90%->100%; Stat Rep: RP-240423->RP-241250;
- 1679: 9/12/22: Acronym:LTE_NR_Simult_RxTx_R18-Perf->LTE_NR _Simult_RxTx_R18-Perf; FCD:10/12/2023->01/12/2023; Compl:0%->20%; Stat Rep: ->RP-223353; Rapporteur: Huawei->Dan Hu, Huawei; Rap eMail: ->hudan11@huawei.com; 17/3/23: FCD:30/11/2023->12/12/2023; C.....; 2/1/24: Stopped at 85% at RAN#102
- 1680: 13/6/24: Compl:0%->58%; Stat Rep: ->RP-241379; ; 4/9/24: FCD:06/06/2025->24/09/2024; Compl:58%->100%; Stat Rep: RP-241379->RP-242076; ; 26/9/24: WID:RP-240292->RP-242077
- 1681: 9/1/23: WID:RP-222669->RP-223112; 2/1/24: WID:RP-223112->RP-234064
- 1682: 9/12/22: FCD:10/12/2023->01/12/2023; Compl:0%->15%; Stat Rep: ->RP-223111; Rapporteur: Vivo->Wang, Ruixin, vivo; Rap eMail: ->ruixin.wang@vivo.com; 17/3/23: FCD:30/11/2023->12/12/2023; Compl:15%->30%; Stat Rep: RP-223111->RP-230375; 17/3/23: 38.87...;...; 4/9/24: FCD:12/12/2023->23/12/2024; Stat Rep: RP-241046->RP-241829;
- 1683: 9/12/22: FCD:10/06/2024->01/06/2024; Stat Rep: ->RP-223111; Rapporteur: Vivo->Wang, Ruixin, vivo; Rap eMail: ->ruixin.wang@vivo.com; 17/3/23: Compl:0%->5%; Stat Rep: RP-223111->RP-230375; ;...; 6/9/23: FCD:06/06/2023->06/06/2024; Compl:20%->30%; Stat ...; 26/9/24: WID:RP-234064->RP-242327
- 1684: 4/9/24: FCD:06/06/2025->25/06/2025; Compl:0%->5%; Stat Rep: ->RP-241899; ; 6/12/24: Compl:5%->30%; Stat Rep: RP-241899->RP-242480; ; 24/1/25: WID:RP-241503->RP-242602; 6/3/25: FCD:14/02/2025->06/06/2025; Compl:30%->70%; WID: RP-242602->RP-241503; Stat Re; 18/7/25: WID:RP-241503->RP-251502
- 1685: 23/9/22: WID:RP-221839->RP-222507; 9/1/23: WID:RP-222507->RP-223537; 29/3/23: WID:RP-223537->RP-230475; 6/10/23: WID:RP-230475->RP-232372; 2/1/24: WID:RP-232372->RP-233197; 2/4/24: WID:RP-233197->RP-240420; 23/7/24: WID:RP-240420->RP-241248
- 1686: 9/9/22: Comp...; 23/9/22: 37.718-00-00 added;; 9/12/22: FCD:23/12/2022->01/12/2023; Compl:10%->20%; Stat Rep: ->RP-223349; Rapporteur: Huawei->Zhang, Peng, Huawei; Rap eMail: ->zhangpeng169@huawei.com; 17/3/23: FCD:30/11/2023->12/12/2023.....; 13/6/24: Compl:90%->100%; Stat Rep: RP-240418->RP-241247;
- 1687: 9/9/22: Comp...; 9/12/22: FCD:23/12/2022->01/12/2023; Compl:10%->20%; Stat Rep: ->RP-223349; Rapporteur: Huawei->Zhang, Peng, Huawei; Rap eMail: ->zhangpeng169@huawei.com; 17/3/23: FCD:30/11/2023->12/12/2023; Compl:20%->40%; Stat Rep: RP.....; 23/7/24: 80%->100
- 1688: 23/9/22: WID:RP-221264->RP-222091; 9/1/23: WID:RP-222091->RP-223078; 29/3/23: WID:RP-223078->RP-230338; 6/10/23: WID:RP-230338->RP-232302; 2/1/24: WID:RP-232302->RP-233242; 2/4/24: WID:RP-233242->RP-240482; 23/7/24: WID:RP-240482->RP-241233
- 1689: 9/9/22: Comp...; 23/9/22: 37.718-11-11 added;; 9/12/22: FCD:23/12/2022->01/12/2023; Compl:5%->15%; WID: RP-222091->RP-222091 Revised WID: Rel-18 Dual Connectivity (DC) of 1 band LTE (1DL/1UL) and 1 NR band (1DL/1UL); Stat Rep: ->RP-223077;...; 13/6/24: Compl:90%->100%; Stat Rep: RP-240481->RP-241219;
- 1690: 9/9/22: CD:1...; 9/12/22: FCD:23/12/2022->01/12/2023; WID: RP-222091->RP-222091 Revised WID: Rel-18 Dual Connectivity (DC) of 1 band LTE (1DL/1UL) and 1 NR band (1DL/1UL); Stat Rep: ->RP-223077; Rapporteur: CHTTL->Bo-Han Hsieh (Tank), CHTT...; 13/6/24: Compl:50%->100%; Stat Rep: RP-240481->RP-241219;
- 1691: 23/9/22: WID:RP-221400->RP-222237; 2/1/24: WID:RP-222237->RP-233989; 2/4/24: WID:RP-233989->RP-240374; 23/7/24: WID:RP-240374->RP-241274
- 1692: 9/9/22: Comp...; 9/12/22: FCD:23/12/2022->01/12/2023; Compl:5%->15%; Stat Rep: ->RP-222924; Rapporteur: Samsung->Yuanyuan Zhang, Samsung; Rap eMail: ->Tina55.zhang@samsung.com; 17/3/23: FCD:30/11/2023->12/12/2023; Compl:15%->30%; Stat Re.....; 13/6/24: Compl:85%->100%; Stat Rep: RP-240373->RP-241273;
- 1693: 9/9/22: Comp...; 9/12/22: FCD:23/12/2022->01/12/2023; Compl:5%->15%; Stat Rep: ->RP-222924; Rapporteur: Samsung->Yuanyuan Zhang, Samsung; Rap eMail: ->Tina55.zhang@samsung.com; 17/3/23: FCD:30/11/2023->12/12/2023; Compl:15%->30%; Stat Re.....; 13/6/24: FCD:01/03/2024->12/12/2023; Stat Rep: RP-240373->RP-241273;
- 1694: 23/9/22: WID:RP-221800->RP-221944; 9/1/23: WID:RP-221944->RP-222840; 29/3/23: WID:RP-222840->RP-230725; 6/10/23: WID:RP-230725->RP-231723; 2/1/24: WID:RP-231723->RP-233488; 2/4/24: WID:RP-233488->RP-240758; 23/7/24: WID:RP-240758->RP-241052
- 1695: 9/9/22: Comp...; 23/9/22: 37.718-11-21 added;; 9/12/22: FCD:23/12/2022->01/12/2023; Compl:5%->15%; Stat Rep: ->RP-222841; Rapporteur: LG Electronics->Sang-Wook Lee, LG Electronics; Rap eMail: ->sangwook1.lee@lge.com; 17/3/23: FCD:30/11/2.....; 13/6/24: Compl:85%->100%; Stat Rep: RP-240325->RP-241053;
- 1696: 9/9/22: Comp...; 9/12/22: FCD:23/12/2022->01/12/2023; Compl:5%->15%; Stat Rep: ->RP-222841; Rapporteur: LG Electronics->Sang-Wook Lee, LG Electronics; Rap eMail: ->sangwook1.lee@lge.com; 17/3/23: FCD:30/11/2023->12/12/2023; Compl:15%->30.....; 23/7/24: 80%->100
- 1697: 23/9/22: WID:RP-221832->RP-222505; 9/1/23: WID:RP-222505->RP-223348; 29/3/23: WID:RP-223348->RP-230473; 6/10/23: WID:RP-230473->RP-232370; 2/1/24: WID:RP-232370->RP-233987; 2/4/24: WID:RP-233987->RP-240417; 23/7/24: WID:RP-240417->RP-241245
- 1698: 9/9/22: Comp...; 23/9/22: 37.718-21-11 added;; 9/12/22: FCD:23/12/2022->01/12/2023; Compl:10%->30%; Stat Rep: ->RP-223347; Rapporteur: Huawei->Liehai Liu, Huawei; Rap eMail: ->liuliehai@huawei.com; 17/3/23: FCD:30/11/2023->12/12/2023; Co.....; 13/6/24: Compl:90%->100%; Stat Rep: RP-240415->RP-241244;
- 1699: 9/9/22: Comp…; 9/12/22: FCD:23/12/2022->01/12/2023; Compl:10%->30%; Stat Rep: ->RP-223347; Rapporteur: Huawei->Liehai Liu, Huawei; Rap eMail: ->liuliehai@huawei.com; 17/3/23: FCD:30/11/2023->12/12/2023; Compl:30%->50%¦01/24: stopped at 85% at RAN#102

| ID | WBS | Task | Type | Duration | Start | Finish | Complete | Remaining | Total slack | Constraint | Resources | Work | Actual work | Acronym | PCG approved | WI rapporteur name | Release | TSG approved | WI rapporteur e-mail | Status Report | Impacted TSs and TRs | TSG stopped |
| --- | --- | --- | --- | --- | --- | --- | --- | --- | --- | --- | --- | --- | --- | --- | --- | --- | --- | --- | --- | --- | --- | --- |
| 1700 | 759 | **Rel-18 Dual Connectivity (DC) of x bands (x=3,4,5) LTE inter-band CA (xDL/1UL) and 1 NR band (1DL/1UL)** |  | 748.38d | 2022-06-15 A | 2024-06-06 A | 100% |  |  |  |  | 7752h | 7752h | DC_R18_xBLTE_1BNR_yDL2UL | 49 | Nokia | Rel-18 | 96 |  |  |  |  |
| 1701 | 759.1 | Core part: Rel-18 Dual Connectivity (DC) of x bands (x=3,4,5) LTE inter-band CA (xDL/1UL) and 1 NR band (1DL/1UL) |  | 520d | 2022-06-15 A | 2024-06-06 A | 100% |  |  | finish no earlier than 2024-06-06 | R4 | 4160h | 4160h | DC_R18_xBLTE_1BNR_yDL2UL-Core | 49 | Johannes Hejselbaek, Nokia | Rel-18 | 96 | johannes.hejselbaek@nokia.com | RP-241165 |  |  |
| 1702 | 759.2 | Perf. part: Rel-18 Dual Connectivity (DC) of x bands (x=3,4,5) LTE inter-band CA (xDL/1UL) and 1 NR band (1DL/1UL) |  | 449d | 2022-06-15 A | 2024-03-01 A | 100% |  |  | finish no earlier than 2024-03-01 | R4 | 3592h | 3592h | DC_R18_xBLTE_1BNR_yDL2UL-Perf | 49 | Johannes Hejselbaek, Nokia | Rel-18 | 96 | johannes.hejselbaek@nokia.com | RP-240382 |  |  |
| 1703 | 760 | **Rel-18 Dual Connectivity (DC) of x bands (x=1,2,3) LTE inter-band CA (xDL/1UL) and y bands (3<=y<=5 and x+y <= 6) NR inter-band CA (yDL/1UL)** |  | 748.38d | 2022-06-15 A | 2024-06-06 A | 100% |  |  |  |  | 7752h | 7752h | DC_R18_xBLTE_yBNR_zDL2UL | 49 | ZTE | Rel-18 | 96 |  |  |  |  |
| 1704 | 760.1 | Core part: Rel-18 Dual Connectivity (DC) of x bands (x=1,2,3) LTE inter-band CA (xDL/1UL) and y bands (3<=y<=5 and x+y <= 6) NR inter-band CA (yDL/1UL) |  | 520d | 2022-06-15 A | 2024-06-06 A | 100% |  |  | finish no earlier than 2024-06-06 | R4 | 4160h | 4160h | DC_R18_xBLTE_yBNR_zDL2UL-Core | 49 | Wubin Zhou, ZTE | Rel-18 | 96 | Zhou.wubin@zte.com.cn | RP-24xxxx |  |  |
| 1705 | 760.2 | Stopped - Perf. part: Rel-18 Dual Connectivity (DC) of x bands (x=1,2,3) LTE inter-band CA (xDL/1UL) and y bands (3<=y<=5 and x+y <= 6) NR inter-band CA (yDL/1UL) |  | 449d | 2022-06-15 A | 2024-03-01 A | 100% |  |  | finish no earlier than 2024-03-01 | R4 | 3592h | 3592h | DC_R18_xBLTE_yBNR_zDL2UL-Perf | 49 | Wubin Zhou, ZTE | Rel-18 | 96 | Zhou.wubin@zte.com.cn | RP-24xxxx |  |  |
| 1706 | 761 | **Rel-18 band combinations for concurrent operation of NR/LTE Uu bands/band combinations and one NR/LTE V2X PC5 band** |  | 565.38d | 2022-06-15 A | 2023-12-12 A | 100% |  |  |  |  | 6256h | 6256h | NR_LTE_V2X_PC5_combos_R18 | 49 | CATT | Rel-18 | 96 |  |  |  |  |
| 1707 | 761.1 | Core part: Rel-18 band combinations for concurrent operation of NR/LTE Uu bands/band combinations and one NR/LTE V2X PC5 band |  | 391d | 2022-06-15 A | 2023-12-12 A | 100% |  |  | finish no earlier than 2023-12-12 | R4 | 3128h | 3128h | NR_LTE_V2X_PC5_combos_R18-Core | 49 | Qiuge Guo, CATT | Rel-18 | 96 | guoqiuge@catt.cn | RP-233006 | 37.878 |  |
| 1708 | 761.2 | Perf. part: Rel-18 band combinations for concurrent operation of NR/LTE Uu bands/band combinations and one NR/LTE V2X PC5 band |  | 391d | 2022-06-15 A | 2023-12-12 A | 100% |  |  | finish no earlier than 2023-12-12 | R4 | 3128h | 3128h | NR_LTE_V2X_PC5_combos_R18-Perf | 49 | Qiuge Guo, CATT | Rel-18 | 96 | guoqiuge@catt.cn | RP-233006 |  |  |
| 1709 | 762 | **Rel-18 downlink interruption for NR and EN-DC band combinations at dynamic Tx Switching in Uplink** |  | 1126.25d | 2022-06-15 A | 2025-06-06 A | 100% |  |  |  |  | 8499h | 8499h | DL_intrpt_combos_TxSW_R18 | 49 | China Telecom | Rel-18 | 96 | LTE, NR |  |  |  |
| 1710 | 762.1 | Core part: Rel-18 downlink interruption for NR and EN-DC band combinations at dynamic Tx Switching in Uplink |  | 391d | 2022-06-15 A | 2023-12-12 A | 100% |  |  | finish no earlier than 2023-12-12 | R4 | 3128h | 3128h | DL_intrpt_combos_TxSW_R18-Core | 49 | Liu, Bo, China Telecom | Rel-18 | 96 | liubo1@chinatelecom.cn | RP-233587 | 37.877 |  |
| 1711 | 762.2 | Perf. part: Rel-18 downlink interruption for NR and EN-DC band combinations at dynamic Tx Switching in Uplink |  | 391d | 2022-06-15 A | 2023-12-12 A | 100% |  |  | finish no earlier than 2023-12-12 | R4 | 3128h | 3128h | DL_intrpt_combos_TxSW_R18-Perf | 49 | Liu, Bo, China Telecom | Rel-18 | 96 | liubo1@chinatelecom.cn | RP-233587 |  |  |
| 1712 | 762.3 | UE Conformance - Rel-18 downlink interruption for NR and EN-DC band combinations at dynamic Tx Switching in Uplink |  | 280.38d | 2024-09-09 A | 2025-06-06 A | 100% |  |  | finish no earlier than 2025-06-06 | R5 | 2243h | 2243h | DL_intrpt_combos_TxSW_R18-UEConTest | 53 | China Telecom | Rel-18 | 105 |  | RP-251464 |  |  |
| 1713 | 763 | Rel-18 Other LTE-only | milestone | 0d? | 2019-03-07 | 2019-03-07 |  |  | 40388.9d |  |  |  |  |  |  |  | Rel-18 |  |  |  |  |  |
| 1714 | 764 | **Rel-18 LTE-Advanced Carrier Aggregation for x bands (2<=x<= 6) DL with y bands (y=1, 2) UL** |  | 748.38d | 2022-06-15 A | 2024-06-06 A | 100% |  |  |  |  | 7752h | 7752h | LTE_CA_R18_xBDL_yBUL | 49 | Huawei | Rel-18 | 96 | LTE |  |  |  |
| 1715 | 764.1 | Core part: Rel-18 LTE-Advanced Carrier Aggregation for x bands (2<=x<= 6) DL with y bands (y=1, 2) UL |  | 520d | 2022-06-15 A | 2024-06-06 A | 100% |  |  | finish no earlier than 2024-06-06 | R4 | 4160h | 4160h | LTE_CA_R18_xBDL_yBUL-Core | 49 | Mohammad Abdi Abyaneh, Huawei- HiSilicon | Rel-18 | 96 | Mohammad.abdi.abyaneh@huawei.com | RP-241241 | 36.718-02-01 |  |
| 1716 | 764.2 | Stopped - Perf. part: Rel-18 LTE-Advanced Carrier Aggregation for x bands (2<=x<= 6) DL with y bands (y=1, 2) UL |  | 449d | 2022-06-15 A | 2024-03-01 A | 100% |  |  | finish no earlier than 2024-03-01 | R4 | 3592h | 3592h | LTE_CA_R18_xBDL_yBUL-Perf | 49 | Mohammad Abdi Abyaneh, Huawei- HiSilicon | Rel-18 | 96 | Mohammad.abdi.abyaneh@huawei.com | RP-233189 |  | 102 |
| 1717 | 765 | **LTE intra-band contiguous Carrier Aggregation for band 8** |  | 197.75d | 2022-06-15 A | 2022-12-22 A | 100% |  |  |  | R4 | 2192h | 2192h | LTE_CA_intra_B8 | 49 | China Mobile | Rel-18 | 96 | LTE |  |  |  |
| 1718 | 765.1 | Core part: LTE intra-band contiguous Carrier Aggregation for band 8 |  | 137d | 2022-06-15 A | 2022-12-22 A | 100% |  |  | finish no earlier than 2022-12-22 | R4 | 1096h | 1096h | LTE_CA_intra_B8-Core | 49 | China Mobile | Rel-18 | 96 | LTE |  |  |  |
| 1719 | 766 | UE Conformance - Rel-18 LTE CA Configurations |  | 477.38d | 2025-06-06 A | 2026-09-09 | 10% | 429.64d | 37547.6d | finish no earlier than 2026-09-09 | R5 | 3819h |  | LTE_CA_R18-UEConTest | 55 | China Telecom | Rel-18 | 108 |  | RP-253470 |  |  |
| 1720 | 767 | **High Power UE (Power Class 2) for LTE FDD Band 14** |  | 181.12d | 2023-09-09 A | 2024-03-01 A | 100% |  |  |  | R4 | 3024h | 3024h | HPUE_LTE_FDD_B14 | 51 | AT&T | Rel-18 | 101 |  |  |  |  |
| 1721 | 767.1 | Core part: High Power UE (Power Class 2) for LTE FDD Band 14 |  | 126d | 2023-09-09 A | 2024-03-01 A | 100% |  |  | finish no earlier than 2024-03-01 | R4 | 1008h | 1008h | HPUE_LTE_FDD_B14-Core | 51 | Borsato, Ron | Rel-18 | 101 | ronald.borsato@att.com | RP-240075 | 36.77 |  |
| 1722 | 767.2 | Perf. part: High Power UE (Power Class 2) for LTE FDD Band 14 |  | 126d | 2023-09-09 A | 2024-03-01 A | 100% |  |  | finish no earlier than 2024-03-01 | R4 | 1008h | 1008h | HPUE_LTE_FDD_B14-Perf | 51 | Borsato, Ron | Rel-18 | 101 | ronald.borsato@att.com | RP-240075 |  |  |
| 1723 | 768 | **Additional LTE bands for UE categories M1/M2/NB1/NB2 in Rel-18** |  | 377.88d | 2022-12-13 A | 2023-12-12 A | 100% |  |  |  |  | 4192h | 4192h | LTE_bands_R18_M1_M2_NB1_NB2 | 50 | Ericsson | Rel-18 | 98 |  |  |  |  |
| 1724 | 768.1 | Core part: Additional LTE bands for UE categories M1/M2/NB1/NB2 in Rel-18 |  | 262d | 2022-12-13 A | 2023-12-12 A | 100% |  |  | finish no earlier than 2023-12-12 | R4 | 2096h | 2096h | LTE_bands_R18_M1_M2_NB1_NB2-Core | 50 | Chunhui Zhang, Ericsson | Rel-18 | 98 | Chunhui.Zhang@ericsson.com | RP- 232891 |  |  |
| 1725 | 768.2 | Perf. part: Additional LTE bands for UE categories M1/M2/NB1/NB2 in Rel-18 |  | 262d | 2022-12-13 A | 2023-12-12 A | 100% |  |  | finish no earlier than 2023-12-12 | R4 | 2096h | 2096h | LTE_bands_R18_M1_M2_NB1_NB2-Perf | 50 | Chunhui Zhang, Ericsson | Rel-18 | 98 | Chunhui.Zhang@ericsson.com | RP- 232891 |  |  |

Notes:
- 1700: 23/9/22: WID:RP-221833->RP-222312; 9/1/23: WID:RP-222312->RP-222876; 29/3/23: WID:RP-222876->RP-230090; 6/10/23: WID:RP-230090->RP-232248; 2/1/24: WID:RP-232248->RP-233988; 2/4/24: WID:RP-233988->RP-240384; 23/7/24: WID:RP-240384->RP-241166
- 1701: 9/9/22: Comp...; 9/12/22: FCD:23/12/2022->01/12/2023; Compl:5%->15%; Stat Rep: ->RP-222875; Rapporteur: Nokia->Johannes Hejselbaek, Nokia; Rap eMail: ->johannes.hejselbaek@nokia.com; 17/3/23: FCD:30/11/2023->12/12/2023; Compl:15%->25%; S.....; 13/6/24: Compl:90%->100%; Stat Rep: RP-240382->RP-241165;
- 1702: 9/9/22: Comp...; 9/12/22: FCD:23/12/2022->01/12/2023; Stat Rep: ->RP-222875; Rapporteur: Nokia->Johannes Hejselbaek, Nokia; Rap eMail: ->johannes.hejselbaek@nokia.com; 17/3/23: FCD:30/11/2023->12/12/2023; Compl:5%->10%; Stat Rep: RP-2228.....; 14/3/24: Compl:80%->100%; Stat Rep: RP-233648->RP-240382;
- 1703: 23/9/22: WID:RP-221834->RP-222094; 9/1/23: WID:RP-222094->RP-222906; 29/3/23: WID:RP-222906->RP-230135; 6/10/23: WID:RP-230135->RP-231842; 2/1/24: WID:RP-231842->RP-232923; 2/4/24: WID:RP-232923->RP-240760; 23/7/24: WID:RP-240760->RP-241225
- 1704: 9/9/22: Comp...; 9/12/22: FCD:23/12/2022->01/12/2023; Compl:5%->20%; Stat Rep: ->RP-222907; Rapporteur: ZTE->Aijun Cao, ZTE; Rap eMail: ->Cao.aijun@zte.com.cn; 17/3/23: FCD:30/11/2023->12/12/2023; Compl:20%->40%; Stat Rep: RP-222907->RP-.....; 13/6/24: Compl:90%->100%; Stat Rep: RP-240250->RP-24xxxx;
- 1705: 9/9/22: Comp...; 9/12/22: FCD:23/12/2022->01/12/2023; Compl:5%->20%; Stat Rep: ->RP-222907; Rapporteur: ZTE->Aijun Cao, ZTE; Rap eMail: ->Cao.aijun@zte.com.cn; 17/3/23: FCD:30/11/2023->12/12/2023; Compl:20%->40%; Stat Rep: RP-222907->RP-.....; 23/7/24: 85%->100
- 1706: 23/9/22: WID:RP-221879->RP-222385; 29/3/23: WID:RP-222385->RP-230390
- 1707: 9/9/22: Comp...; 23/9/22: 37.878 added;; 17/3/23: FCD:23/12/2022->12/12/2023; Compl:5%->50%; Stat Rep: ->RP-230389; Rapporteur: CATT->Qiuge Guo, CATT; Rap eMail: ->guoqiuge@catt.cn; ; 6/9/23: Stat Rep: RP-230389->RP-231834; ; 8/12/23: Compl:50%->100%; Stat Rep: RP-231834->RP-233006;
- 1708: 9/9/22: CD:1...; 9/12/22: Acronym:NR_LTE_V2X_PC5_combos_R18-Perf->NR_LTE_V2X_PC5_combos_R18-Core; FCD:23/12/2022->01/12/2023; Compl:0%->50%; Stat Rep: ->RP-223146; Rapporteur: CATT->Qiuge Guo, CATT; Rap eMail: ->guoqiuge@catt.cn; 17/3/23.....; 8/12/23: Compl:0%->100%; Stat Rep: RP-231834->RP-233006;
- 1709: 23/9/22: WID:RP-221843->RP-222288; 2/1/24: WID:RP-222288->RP-233588
- 1710: 9/9/22: Comp...; 23/9/22: 37.877 added;; 17/3/23: FCD:23/12/2022->12/12/2023; Compl:10%->99%; WID: RP-222288->RP-221843 RP-222288; Stat Rep: ->RP-230319; Rapporteur: China Telecom->Liu, Bo, China Telecom; Rap eMail: LTE, NR->liubo1@chinate...; 8/12/23: Compl:99%->100%; Stat Rep: RP-232269->RP-233587;
- 1711: 9/9/22: CD:1...; 9/12/22: Acronym:DL_intrpt_combos_TxSW_R18-Perf->DL_intrpt_combos_TxSW_R18-Core; FCD:23/12/2022->01/12/2023; Compl:0%->20%; WID: RP-222288->RP-221843 RP-222288; Stat Rep: ->RP-222939; Rapporteur: China Telecom->Liu, Bo, Ch...; 8/12/23: Compl:0%->100%; Stat Rep: RP-232269->RP-233587;
- 1712: 6/12/24: Compl:0%->67%; Stat Rep: ->RP-242853; ; 6/3/25: FCD:24/07/2025->12/12/2025; Compl:67%->69%; Stat Rep: RP-242853->RP-250380; ; 6/6/25: FCD:Fri 12/12/25->Fri 06/06/25; Compl:69%->100%; Stat Rep: RP-250380->RP-251464; ; 18/7/25: WID:RP-242001->RP-251465
- 1713: -
- 1714: 23/9/22: WID:RP-221831->RP-222503; 9/1/23: WID:RP-222503->RP-223489; 29/3/23: WID:RP-223489->RP-230471; 6/10/23: WID:RP-230471->RP-232368; 2/1/24: WID:RP-232368->RP-233927; 2/4/24: WID:RP-233927->RP-240414; 23/7/24: WID:RP-240414->RP-241242
- 1715: 9/9/22: Comp...; 23/9/22: 36.718-02-01 added;; 9/12/22: FCD:23/12/2022->01/12/2023; Compl:20%->35%; Stat Rep: ->RP-223345; Rapporteur: Huawei->Mohammad Abdi Abyaneh, Huawei; Rap eMail: LTE->Mohammad.abdi.abyaneh@huawei.com; 17/3/23: FCD:.....; 13/6/24: Compl:55%->100%; Stat Rep: RP-240412->RP-241241;
- 1716: 9/9/22: Comp...; 9/12/22: FCD:23/12/2022->01/12/2023; Compl:20%->35%; Stat Rep: ->RP-223345; Rapporteur: Huawei->Mohammad Abdi Abyaneh, Huawei; Rap eMail: LTE->Mohammad.abdi.abyaneh@huawei.com; 17/3/23: FCD:30/11/2023->12/12/2023; Stat R.....; 2/1/24: Stopped at 43% at RAN#102
- 1718: 9/9/22: Comp...; 9/1/23: 99%->100
- 1719: tested: REL-18 WI LTE_CA_R18_xBDL_yBUL-Core; compare: LTE_CA_R17, LTE_CA_R16, LTE_CA_R15, LTE_CA_R14 ; 11/9/25: FCD:Wed 09/09/26->Tue 08/09/26; Compl:0%->5%; Stat Rep: ->RP-252550; ; 3/12/25: Compl:5%->10%; Stat Rep: RP-252550->RP-253470;
- 1720: 2/1/24: WID:RP-232676->RP-232946
- 1721: 8/12/23: FCD:12/12/2023->01/03/2024; Compl:0%->50%; Stat Rep: ->RP-232945; Rapporteur: AT&T->Borsato, Ron; Rap eMail: ->ronald.borsato@att.com; ; 4/1/24: 36.770 added;; 14/3/24: Compl:50%->100%; Stat Rep: RP-232945->RP-240075; List of Impacted TS & TR updated;
- 1722: 8/12/23: FCD:12/12/2023->01/03/2024; Compl:0%->80%; Stat Rep: ->RP-232945; Rapporteur: AT&T->Borsato, Ron; Rap eMail: ->ronald.borsato@att.com; ; 14/3/24: Compl:80%->100%; Stat Rep: RP-232945->RP-240075;
- 1723: 2/1/24: WID:RP-222824->RP-232892
- 1724: 17/3/23: Compl:0%->99%; Stat Rep: ->RP-230462; Rapporteur: Ericsson->Chunhui Zhang, Ericsson; Rap eMail: ->Chunhui.Zhang@ericsson.com; ; 6/9/23: Stat Rep: RP-230462->RP-231880; ; 8/12/23: Compl:99%->100%; Stat Rep: RP-231880->RP- 232891;
- 1725: 17/3/23: Compl:0%->99%; Stat Rep: ->RP-230462; Rapporteur: Ericsson->Chunhui Zhang, Ericsson; Rap eMail: ->Chunhui.Zhang@ericsson.com; ; 6/9/23: Stat Rep: RP-230462->RP-231880; ; 8/12/23: Compl:99%->100%; Stat Rep: RP-231880->RP- 232891;

| ID | WBS | Task | Type | Duration | Start | Finish | Complete | Remaining | Total slack | Constraint | Resources | Work | Actual work | Acronym | PCG approved | Release | TSG approved | Status Report |
| --- | --- | --- | --- | --- | --- | --- | --- | --- | --- | --- | --- | --- | --- | --- | --- | --- | --- | --- |
| 1726 | 769 | **Introduction of 900 MHz LTE band in the US** |  | 841.5d | 2022-12-12 A | 2025-03-03 | 86% | 115.95d |  |  |  | 6636h | 5620h | LTE_900MHz_US | 50 | Rel-18 | 98 |  |
| 1727 | 769.1 | Core part: Introduction of 900 MHz LTE band in the US |  | 127d | 2022-12-12 A | 2023-06-06 A | 100% |  |  | finish no earlier than 2023-06-06 | R4 | 1016h | 1016h | LTE_900MHz_US-Core | 50 | Rel-18 | 98 | RP-231218 |
| 1728 | 769.2 | Perf. part: Introduction of 900 MHz LTE band in the US |  | 127d | 2022-12-12 A | 2023-04-13 | 10% | 114.3d | 38836.8d | finish no earlier than 2023-06-06 | R4 | 1016h |  | LTE_900MHz_US-Perf | 50 | Rel-18 | 98 | RP-231218 |
| 1729 | 769.3 | UE Conformance - Introduction of 900 MHz LTE band in the US |  | 575.5d | 2024-03-03 A | 2025-09-09 A | 100% |  |  | finish no earlier than 2025-09-09 | R5 | 4604h | 4604h | LTE_900MHz_US-UEConTest | 52 | Rel-18 | 103 | RP-251937 |
| 1730 | 770 | **Maximum Power Reduction Requirements (MPR) for LTE intra-band Carrier Aggregation (CA) with a Component Carrier (CC) gap larger than 35 MHz** |  | 84.75d | 2022-12-12 A | 2023-03-03 A | 100% |  |  |  |  | 480h | 480h | LTE_intra_CA_MPR_35MHz_gap | 50 | Rel-18 | 98 |  |
| 1731 | 770.1 | Core part: Maximum Power Reduction Requirements (MPR) for LTE intra-band Carrier Aggregation (CA) with a Component Carrier (CC) gap larger than 35 MHz |  | 60d | 2022-12-12 A | 2023-03-03 A | 100% |  |  | finish no earlier than 2023-03-03 | R4 | 480h | 480h | LTE_intra_CA_MPR_35MHz_gap-Core | 50 | Rel-18 | 98 | RP-230480 |
| 1732 | 771 | **Introduction of 600MHz US LTE band with 1.4 and 3MHz channel bandwidths** |  | 204d | 2023-05-29 A | 2023-12-12 |  | 204d | 38584.9d |  | R4 | 4896h | 1632h | LTE600_US_lowCBW | 50 | Rel-18 | 99 |  |
| 1733 | 771.1 | Core part: Introduction of 600MHz US LTE band with 1.4 and 3MHz channel bandwidths |  | 204d | 2023-05-29 | 2023-12-12 |  |  | 38584.9d | finish no earlier than 2023-12-12 | R4 | 1632h |  | LTE600_US_lowCBW-Core | 50 | Rel-18 | 99 |  |
| 1734 | 771.2 | Perf. part: Introduction of 600MHz US LTE band with 1.4 and 3MHz channel bandwidths |  | 204d | 2023-05-29 | 2023-12-12 |  |  | 38584.9d | finish no earlier than 2023-12-12 | R4 | 1632h |  | LTE600_US_lowCBW-Perf | 50 | Rel-18 | 99 |  |
| 1735 | 772 | Rel-18 RAN Studies | milestone | 0d? | 2017-12-15 A | 2017-12-15 | 34% | 0d? | 40851.9d |  |  |  |  |  |  | Rel-18 |  |  |
| 1736 | 773 | Study on enhancement for sub-1GHz NR band combinations |  | 136d | 2023-03-03 A | 2023-09-08 A | 100% |  |  | finish no earlier than 2023-09-08 | R4 | 1088h | 1088h | FS_NR_sub1GHz_combo_enh | 50 | Rel-18 | 99 | RP-232661 |
| 1737 | 774 | Study on self-evaluation towards the IMT-2020 submission of the 3GPP Satellite Radio Interface Technology |  | 204d | 2023-03-03 A | 2023-12-12 A | 100% |  |  | finish no earlier than 2023-12-12 | RP | 1632h | 1632h | FS_IMT2020_SAT_eval | 50 | Rel-18 | 99 | RP-231944 |
| 1738 | 775 | Study on Ambient IoT (Internet of Things) in RAN |  | 262d | 2022-09-08 A | 2023-09-08 A | 100% |  |  | finish no earlier than 2023-09-08 | RP | 2096h | 2096h | FS_Ambient_IoT_RAN | 49 | Rel-18 | 97 | RP-232403 |
| 1739 | 776 | Study on simplification of band combination specification for NR and LTE |  | 457d | 2022-03-15 A | 2023-12-12 A | 100% |  |  | finish no earlier than 2023-12-12 | R4 | 3656h | 3656h | FS_SimBC | 48 | Rel-18 | 95 | RP-233234 |
| 1740 | 777 | Study on NR frequency range 2 (FR2) Over-the-Air (OTA) testing enhancements |  | 457d | 2022-03-15 A | 2023-12-12 A | 100% |  |  | finish no earlier than 2023-12-12 | R4 | 3656h | 3656h | FS_NR_FR2_OTA_enh | 48 | Rel-18 | 95 | RP-233170 |
| 1741 | 778 | Study on NR base station (BS) RF requirement evolution |  | 321d | 2022-03-15 A | 2023-06-06 A | 100% |  |  | finish no earlier than 2023-06-06 | R4 | 2568h | 2568h | FS_NR_BS_RF_evo | 48 | Rel-18 | 95 | RP-230469 |
| 1742 | 779 | Study on enhancement for 700/800/900MHz band combinations for NR |  | 262d | 2022-03-03 A | 2023-03-03 A | 100% |  |  | start no earlier than 2022-03-03 | R4 | 2096h | 2096h | FS_NR_700800900_combo_enh | 48 | Rel-18 | 95 | RP-230388 |
| 1743 | 780 | Study on enhanced test methods for FR2 NR UEs |  | 720d | 2019-09-19 A | 2022-06-22 A | 100% |  |  | finish no earlier than 2022-06-22 | R4 | 5760h | 5760h | FS_FR2_enhTestMethods | 43 | Rel-18 | 85 | RP-221575 |
| 1744 | 781 | Study on efficient utilization of licensed spectrum that is not aligned with existing NR channel bandwidths |  | 643d | 2020-09-17 A | 2023-03-03 A | 100% |  |  | finish no earlier than 2023-03-03 | R4 | 5144h | 5144h | FS_NR_eff_BW_util | 45 | Rel-18 | 89 | RP-230579 |
| 1745 | 782 | Rel-18 Network automation | milestone | 0d? | 2016-03-15 A | 2016-03-15 A | 100% |  |  | start no earlier than 2016-03-15 |  |  |  |  |  | Rel-18 |  |  |
| 1746 | 783 | **Enablers for Network Automation for 5G phase 3** |  | 833.5d | 2021-12-20 A | 2024-03-03 A | 100% |  |  |  |  | 10264h | 10264h | eNA_Ph3 | 50 | Rel-18 | 99 |  |
| 1747 | 783.1 | Study on Enablers for Network Automation for 5G - phase 3 |  | 256d | 2021-12-20 A | 2022-12-12 A | 100% |  |  | finish no earlier than 2022-12-12 | S2 | 2048h | 2048h | FS_eNA_Ph3 | 48 | Rel-18 | 94 |  |
| 1748 | 783.2 | Study on security aspects of enablers for Network Automation for 5G - phase 3 |  | 257d | 2022-03-10 A | 2023-03-03 A | 100% |  |  | finish no earlier than 2023-03-03 | S3 | 2056h | 2056h | FS_eNA_SEC_Ph3 | 48 | Rel-18 | 95 |  |
| 1749 | 783.3 | Security aspects of enablers for Network Automation for 5G - phase 3 |  | 128d | 2023-03-16 A | 2023-09-09 A | 100% |  |  | finish no earlier than 2023-09-09 | S3 | 1024h | 1024h | eNA_Ph3_SEC | 50 | Rel-18 | 99 |  |
| 1750 | 783.4 | (stage 2 of eNA_Ph3) Enablers for Network Automation for 5G phase 3 |  | 128d | 2022-12-09 A | 2023-06-06 A | 100% |  |  | finish no earlier than 2023-06-06 | S2 | 1024h | 1024h | eNA_Ph3 | 50 | Rel-18 | 98 |  |
| 1751 | 783.5 | CT3 aspects of eNA_Ph3 |  | 257d | 2023-03-13 A | 2024-03-03 A | 100% |  |  | finish no earlier than 2024-03-03 | C3 | 2056h | 2056h | eNA_Ph3 | 50 | Rel-18 | 99 |  |
| 1752 | 783.6 | CT4 aspects of eNA_Ph3 |  | 257d | 2023-03-13 A | 2024-03-03 A | 100% |  |  | finish no earlier than 2024-03-03 | C4 | 2056h | 2056h | eNA_Ph3 | 50 | Rel-18 | 99 |  |
| 1753 | 784 | Enhancement of Network Automation Enablers |  | 460.75d | 2022-12-15 A | 2024-03-03 A | 100% |  |  | finish no earlier than 2024-03-03 | C3 | 2552h | 2552h | eNetAE | 49 | Rel-18 | 96 |  |
| 1754 | 785 | Rel-18 other Studies | milestone | 0d? | 2016-03-15 A | 2016-03-15 A | 100% |  |  | start no earlier than 2016-03-15 |  |  |  |  |  | Rel-18 |  |  |
| 1755 | 786 | Guidelines for Extra-territorial 5G Systems |  | 526d | 2019-12-06 A | 2021-12-10 A | 100% |  |  | finish no earlier than 2021-12-12 | S1 | 4208h | 4208h | FS_5GET | 44 | Rel-18 | 86 |  |
| 1756 | 787 | Study on NRF API enhancements to avoid signalling and storing of redundant data |  | 333d | 2022-06-02 A | 2023-09-09 A | 100% |  |  | finish no earlier than 2023-09-09 | C4 | 2664h | 2664h | FS_NRFe | 49 | Rel-18 | 96 |  |
| 1757 | 788 | Rel-18 Management-only Features | milestone | 0d? | 2016-03-15 A | 2016-03-15 A | 100% |  |  | start no earlier than 2016-03-15 |  |  |  |  |  | Rel-18 |  |  |
| 1758 | 789 | Management of cloud-native Virtualized Network Functions |  | 178d | 2023-06-30 A | 2024-03-03 A | 100% |  |  | finish no earlier than 2024-03-03 | S5 | 1424h | 1424h | MCVNF | 51 | Rel-18 | 100 |  |
| 1759 | 790 | Charging enhancement for Network Slice based wholesale in roaming |  | 27d | 2023-05-01 A | 2023-06-06 A | 100% |  |  | start no earlier than 2023-05-01 | S5 | 216h | 216h | CHNSWO | 51 | Rel-18 | 100 |  |
| 1760 | 791 | Network and Service Operations for Energy Utilities |  | 194d | 2023-06-08 A | 2024-03-03 A | 100% |  |  | finish no earlier than 2024-03-03 | S5 | 1552h | 1552h | NSOEU | 51 | Rel-18 | 100 |  |
| 1761 | 792 | Study on CHF Segmentation |  | 322d | 2022-12-12 A | 2024-03-03 A | 100% |  |  | finish no earlier than 2024-03-03 | S5 | 2576h | 2576h | FS_CHFSeg | 50 | Rel-18 | 98 |  |
| 1762 | 793 | Management of Trace/MDT phase 2 |  | 322d | 2022-12-12 A | 2024-03-03 A | 100% |  |  | finish no earlier than 2024-03-03 | S5 | 2576h | 2576h | 5GMDT_Ph2 | 50 | Rel-18 | 98 |  |
| 1763 | 794 | Enhancements of EE for 5G Phase 2 |  | 525d | 2021-12-10 A | 2023-12-12 A | 100% |  |  | finish no earlier than 2023-12-12 | S5 | 4200h | 4200h | EE5GPLUS_Ph2 | 48 | Rel-18 | 94 |  |
| 1764 | 795 | Security Assurance Specification for Management Function (MnF) |  | 262d | 2021-12-10 A | 2022-12-09 A | 100% |  |  | finish no earlier than 2022-12-12 | S3 | 2096h | 2096h | SCAS_5G_MF | 48 | Rel-18 | 94 |  |
| 1765 | 796 | Multimedia Messaging Service Charging using service-based interface |  | 138d | 2022-06-02 A | 2022-12-12 A | 100% |  |  | finish no earlier than 2022-12-12 | S5 | 1104h | 1104h | MMS_CH_SBI | 49 | Rel-18 | 96 |  |
| 1766 | 797 | 5G performance measurements and KPIs phase 3 |  | 459d | 2022-06-02 A | 2024-03-03 A | 100% |  |  | finish no earlier than 2024-03-03 | S5 | 3672h | 3672h | PM_KPI_5G_Ph3 | 49 | Rel-18 | 96 |  |
| 1767 | 798 | Enhancement of QoE Measurement Collection |  | 972d | 2020-03-25 A | 2023-12-12 A | 100% |  |  | finish no earlier than 2023-12-12 | S5 | 7776h | 7776h | eQoE | 44 | Rel-18 | 87 |  |
| 1768 | 799 | Enhanced Edge Computing Management |  | 519d | 2022-03-10 A | 2024-03-03 A | 100% |  |  | finish no earlier than 2024-03-03 | S5 | 4152h | 4152h | eECM | 48 | Rel-18 | 95 |  |
| 1769 | 800 | Study on access control for management service |  | 256d | 2020-09-16 A | 2021-09-08 A | 100% |  |  | finish no earlier than 2021-09-08 | S5 | 2048h | 2048h | FS_MNSAC | 45 | Rel-17 | 89 |  |
| 1770 | 801 | Access control for management service |  | 649d | 2021-09-10 A | 2024-03-03 A | 100% |  |  | finish no earlier than 2024-03-03 | S5 | 5192h | 5192h | MSAC | 47 | Rel-18 | 93 |  |
| 1771 | 802 | Network slice provisioning enhancement |  | 590d | 2021-09-10 A | 2023-12-12 A | 100% |  |  | finish no earlier than 2023-12-12 | S5 | 4720h | 4720h | eNETSLICE_PRO | 48 | Rel-18 | 94 |  |
| 1772 | 803 | Study on YANG PUSH |  | 388d | 2020-09-16 A | 2022-03-10 A | 100% |  |  | finish no earlier than 2022-03-12 | S5 | 3104h | 3104h | FS_YANG | 45 | Rel-18 | 89 |  |
| 1773 | 804 | Study on Continuous integration continuous delivery support for 3GPP NFs. |  | 257d | 2021-03-18 A | 2022-03-11 A | 100% |  |  | finish no earlier than 2022-03-12 | S5 | 2056h | 2056h | FS_CICDNS | 46 | Rel-18 | 91 |  |
| 1774 | 805 | Study on Enhancement of service-based management architecture |  | 580d | 2021-03-18 A | 2023-06-06 A | 100% |  |  | finish no earlier than 2023-06-06 | S5 | 4640h | 4640h | FS_eSBMA | 46 | Rel-18 | 91 |  |
| 1775 | 806 | Service based management architecture |  | 254d | 2023-03-16 A | 2024-03-03 A | 100% |  |  | finish no earlier than 2024-03-03 | S5 | 2032h | 2032h | eSBMA | 50 | Rel-18 | 99 |  |
| 1776 | 807 | Study on Enhancement of the management aspects related to NWDAF |  | 387d | 2021-12-13 A | 2023-06-06 A | 100% |  |  | finish no earlier than 2023-06-06 | S5 | 3096h | 3096h | FS_MANWDAF | 48 | Rel-18 | 94 |  |
| 1777 | 808 | Management Aspects related to NWDAF |  | 195d | 2023-03-16 A | 2023-12-12 A | 100% |  |  | finish no earlier than 2023-12-12 | S5 | 1560h | 1560h | MANWDAF | 50 | Rel-18 | 99 |  |
| 1778 | 809 | Study on enhancement of management of non-public networks |  | 320d | 2021-12-13 A | 2023-03-03 A | 100% |  |  | finish no earlier than 2023-03-03 | S5 | 2560h | 2560h | FS_OAM_eNPN | 48 | Rel-18 | 94 |  |
| 1779 | 810 | Study on new aspects of EE for 5G networks Phase 2 |  | 387d | 2021-12-13 A | 2023-06-06 A | 100% |  |  | finish no earlier than 2023-06-06 | S5 | 3096h | 3096h | FS_EE5G_Ph2 | 48 | Rel-18 | 94 |  |
| 1780 | 811 | Study on Deterministic Communication Service Assurance |  | 582d | 2021-12-13 A | 2024-03-03 A | 100% |  |  | finish no earlier than 2024-03-03 | S5 | 4656h | 4656h | FS_DCSA | 48 | Rel-18 | 94 |  |
| 1781 | 812 | Study on evaluation of autonomous network levels |  | 582d | 2021-12-13 A | 2024-03-03 A | 100% |  |  | finish no earlier than 2024-03-03 | S5 | 4656h | 4656h | FS_ANLEVA | 48 | Rel-18 | 94 |  |
| 1782 | 813 | Study on enhancement of autonomous network levels |  | 523d | 2021-12-13 A | 2023-12-12 A | 100% |  |  | finish no earlier than 2023-12-12 | S5 | 4184h | 4184h | FS_eANL | 48 | Rel-18 | 94 |  |
| 1783 | 814 | Study on enhanced intent driven management services for mobile networks |  | 387d | 2021-12-13 A | 2023-06-06 A | 100% |  |  | finish no earlier than 2023-06-06 | S5 | 3096h | 3096h | FS_eIDMS_MN | 48 | Rel-18 | 94 |  |
| 1784 | 815 | Study on Basic SBMA enabler enhancements |  | 324d | 2022-03-10 A | 2023-06-06 A | 100% |  |  | finish no earlier than 2023-06-06 | S5 | 2592h | 2592h | FS_eSBMAe | 48 | Rel-18 | 95 |  |
| 1785 | 816 | Study on alignment with ETSI MEC for Edge computing management |  | 324d | 2022-03-10 A | 2023-06-06 A | 100% |  |  | finish no earlier than 2023-06-06 | S5 | 2592h | 2592h | FS_MEC_ECM | 48 | Rel-18 | 95 |  |
| 1786 | 817 | Study on Management Aspect of 5GLAN |  | 257d | 2022-03-10 A | 2023-03-03 A | 100% |  |  | finish no earlier than 2023-03-03 | S5 | 2056h | 2056h | FS_5GLAN_Mgt | 48 | Rel-18 | 95 |  |
| 1787 | 818 | Management Aspect of 5GLAN |  | 195d | 2023-03-16 A | 2023-12-12 A | 100% |  |  | finish no earlier than 2023-12-12 | S5 | 1560h | 1560h | 5GLAN_Mgt | 50 | Rel-18 | 99 |  |
| 1788 | 819 | Study on Management of Cloud Native Virtualized Network Functions |  | 324d | 2022-03-10 A | 2023-06-06 A | 100% |  |  | finish no earlier than 2023-06-06 | S5 | 2592h | 2592h | FS_MCVNF | 48 | Rel-18 | 95 |  |
| 1789 | 820 | Study on Management Aspects of 5G MOCN Network Sharing Phase2 |  | 324d | 2022-03-10 A | 2023-06-06 A | 100% |  |  | finish no earlier than 2023-06-06 | S5 | 2592h | 2592h | FS_MANS_ph2 | 48 | Rel-18 | 95 |  |
| 1790 | 821 | Management Aspects of 5G Network Sharing Phase2 |  | 194d | 2023-06-08 A | 2024-03-03 A | 100% |  |  | finish no earlier than 2024-03-03 | S5 | 1552h | 1552h | MANS_ph2 | 51 | Rel-18 | 100 |  |
| 1791 | 822 | Study on Management of Trace/MDT phase 2 |  | 324d | 2022-03-10 A | 2023-06-06 A | 100% |  |  | finish no earlier than 2023-06-06 | S5 | 2592h | 2592h | FS_5GMDT_Ph2 | 48 | Rel-18 | 95 |  |
| 1792 | 823 | Study on Fault Supervision Evolution |  | 519d | 2022-03-10 A | 2024-03-03 A | 100% |  |  | finish no earlier than 2024-03-03 | S5 | 4152h | 4152h | FS_FSEV | 48 | Rel-18 | 95 |  |
| 1793 | 824 | Study on measurement data collection to support RAN intelligence |  | 138d | 2022-06-02 A | 2022-12-12 A | 100% |  |  | finish no earlier than 2022-12-12 | S5 | 1104h | 1104h | FS_MEDACO_RAN | 49 | Rel-18 | 96 |  |
| 1794 | 825 | Study on Nchf charging services phase 2 |  | 654d | 2021-06-11 A | 2023-12-12 A | 100% |  |  | finish no earlier than 2023-12-12 | S5 | 5232h | 5232h | FS_NCHF_Ph2 | 47 | Rel-18 | 92 |  |
| 1795 | 826 | CHF Distributed Availability |  | 128d | 2023-03-16 A | 2023-09-09 A | 100% |  |  | finish no earlier than 2023-09-09 | S5 | 1024h | 1024h | DIST_CH | 50 | Rel-18 | 99 |  |

Notes:
- 1726: 29/3/23: WID:RP-223530->RP-230722 / WI rapporteur name: Anterix
- 1727: 17/3/23: Compl:0%->20%; Stat Rep: ->RP-230264; Rapporteur: Anterix->Emil Olbrich, Anterix; Rap eMail: ->eolbrich@anterix.com; ; 29/6/23: 20%->100 / WI rapporteur name: Emil Olbrich, Anterix / WI rapporteur e-mail: eolbrich@anterix.com
- 1728: 17/3/23: Compl:0%->10%; Stat Rep: ->RP-230264; Rapporteur: Anterix->Emil Olbrich, Anterix; Rap eMail: ->eolbrich@anterix.com; / WI rapporteur name: Emil Olbrich, Anterix / WI rapporteur e-mail: eolbrich@anterix.com
- 1729: 13/6/24: Compl:0%->85%; Stat Rep: ->RP-240915; ; 4/9/24: FCD:03/03/2025->25/03/2025; Stat Rep: RP-240915->RP-241747; ; 6/12/24: Stat Rep: RP-241747->RP-242838; ; 6/3/25: FCD:12/11/2024->06/06/2025; Stat Rep: RP-242838->RP-250081; ; 6/6/25: FCD:Fri 06/06/2; 29/9/25: WID:RP-240096->RP-251938 / WI rapporteur name: Nokia
- 1730: 29/3/23: WID:RP-223511->RP-230705 / WI rapporteur name: Huawei
- 1731: 17/3/23: FCD:06/06/2023->03/03/2023; Compl:0%->100%; Stat Rep: ->RP-230480; Rapporteur: Huawei->Mohammad Abdi Abyaneh, Huawei, HiSilicon; Rap eMail: ->Mohammad.abdi.abyaneh@huawei.com; / WI rapporteur name: Mohammad Abdi Abyaneh, Huawei, HiSilicon / WI rapporteur e-mail: Mohammad.abdi.abyaneh@huawei.com
- 1732: WI rapporteur name: T-Mobile USA
- 1733: ; 7/6/23: CD:06/06/2023->12/12/2023 / WI rapporteur name: T-Mobile USA
- 1734: ; 7/6/23: CD:09/09/2023->12/12/2023 / WI rapporteur name: T-Mobile USA
- 1735: -
- 1736: ; 7/6/23: Compl:0%->86%; 7/6/23: CD:06/06/2023->09/09/2023; 6/9/23: FCD:09/09/2023->12/12/2023; Compl:86%->80%; WID: RP-230789->RP-231141; Stat Rep: ->RP-232378; Rapporteur: Huawei->Zhang, Peng, Huawei; Rap eMail: ->zhangpeng169@huawei.com; ; 21/9/23: FCD:12/12/2023->08/09/2023; Compl:80%->100%; Stat Rep: RP-232378->RP-232661; / WI rapporteur name: Zhang, Peng, Huawei / WI rapporteur e-mail: zhangpeng169@huawei.com
- 1737: 29/6/23: 0%->20; 21/9/23: Compl:20%->40%; WID: RP-230736->RP-231945; Stat Rep: RP-231291->RP-231944; Rapporteur: Asbjörn Grövlen, Ericsson->Asbj rn Gr vlen, Ericsson; ; 21/9/23: 37.911 added;; 2/1/24: 40%->100 / Impacted TSs and TRs: 37.911 / WI rapporteur name: Asbj rn Gr vlen, Ericsson / WI rapporteur e-mail: asbjorn.grovlen@ericsson.com
- 1738: 9/1/23: WID:RP-222685->RP-223396; 17/3/23: 38.848 added;; 31/3/23: Compl:0%->50%; WID: RP-223396->RP-222685; Stat Rep: ->RP-230669; Rapporteur: Huawei->Matthew Webb, Huawei; Rap eMail: ->matthew.webb@huawei.com; ; 29/6/23: 50%->60; 29/6/23: FCD:06/06/...; 6/10/23: 100%->100 / Impacted TSs and TRs: 38.848 / WI rapporteur name: Matthew Webb, Huawei / WI rapporteur e-mail: matthew.webb@huawei.com
- 1739: TR 37.8xx; LTE only combos will not be considered ; 20/6/22: FCD:15/06/2023->23/06/2022; Stat Rep: ->RP-221266 / 1769; Rapporteur: ZTE->Zhifeng Ma, ZTE Corporation; Rap eMail: ->ma.zhifeng@zte.com.cn12/7/22: WID:RP-220956->RP-221790; 13/7/22: FCD:...;...; 8/12/23: Compl:95%->100%; Stat Rep: RP-231862->RP-233234; / Impacted TSs and TRs: 38.846 / WI rapporteur name: Zhifeng Ma, ZTE Corporation / WI rapporteur e-mail: ma.zhifeng@zte.com.cn
- 1740: compare REL-16 SI FS_NR_test_methods and REL-17 SI FS_FR2_enhTestMethods; TR 38.3xx ; 6/6/22: CD:15/12/2023->23/12/2022; 6/6/22: Stat Rep: ->RP-221391; 20/6/22: Rapporteur: Qualcomm->Bin Han, Qualcomm Incorporated; Rap eMail: ->binhan@qti.qualcomm.com...; 2/1/24: WID:RP-230814->RP-233171 / Impacted TSs and TRs: 38.871 / WI rapporteur name: Bin Han, Qualcomm Incorporated / WI rapporteur e-mail: binhan@qti.qualcomm.com
- 1741: for NR FR2 mmWave BSs; TR 38.8xx 6/6/22: CD:15/06/2023->23/06/20226/6/22: Stat Rep: ->RP-221530; 20/6/22: Rapporteur: Huawei->Richard Kybett, Huawei; Rap eMail: ->Richard.kybett@huawei.com13/7/22: FCD:23/06/2022->06/20; 13/7/22: 38.877 added;;...; 23/...; ; ; ; ; ; ; ; ; ; ; ; ; ; ; ; ; ; ; ; ; ; ; 7/6/23: Compl:80%->100% / Impacted TSs and TRs: 38.877 / WI rapporteur name: Liehai Liu, Huawei / WI rapporteur e-mail: liuliehai@huawei.com
- 1742: TR 38.8xx ; 6/6/22: CD:08/06/2021->23/03/2023; 6/6/22: Stat Rep: ->RP-221460; 20/6/22: Rapporteur: CATT->Yuexia Song, CATT; Rap eMail: ->songyuexia@catt.cn12/7/22: WID:RP-221016->RP-221464; 13/7/22: 38.872 added ; ;...; 23/9/22: WID:RP-221464->RP-2225...; 17/3/23: FCD:28/02/2023->03/03/2023; Compl:80%->100%; Stat Rep: RP-223145->RP-230388; / Impacted TSs and TRs: 38.872 / WI rapporteur name: Huiping Shan, CATT / WI rapporteur e-mail: shanhuiping@catt.cn
- 1743: TR 38.8XX; 14/1/20: WID:RP-192322->RP-192430; 28/7/20: WID:RP-192430->RP-201110; 25/9/20: WID:RP-201110->RP-201862; 7/4/21: WID:RP-201862->RP-210633; 2/7/21: WID:RP-210633->RP-211600; ; 04/22: Rel-17->Rel-18 ; ; 20/6/22: Rapporteur: Apple->Anatoliy ...; 12/7/22: WID:RP-211600->RP-221574 / WI rapporteur name: Anatoliy IOFFE, Ruixin WANG, Aida Vera LOPEZ, Apple Inc., vivo, Intel Corporation / WI rapporteur e-mail: aioffe@apple.com, ruixin.wang@vivo.com, aida.l.vera.lopez@intel.com
- 1744: TR 38.8xx ; 6/1/21: WID:RP-202103->RP-202339; 7/4/21: WID:RP-202339->RP-210706; 2/7/21: WID:RP-210706->RP-211468; 13/9/21: Compl:0%->50%; ; 6/1/22: WID:RP_211468->RP-213657 ; 5/4/22: WID:RP-213657->RP-220461; 04/22: Rel-17->Rel-18; ; 20/6/22: Rappor...; 17/3/23: FCD:28/02/2023->03/03/2023; Compl:85%->100%; Stat Rep: RP- 223273->RP-230579; / Impacted TSs and TRs: 38.844 / WI rapporteur name: Esther Sienkiewicz, Ericsson / WI rapporteur e-mail: esther dot sienkiewicz at ericsson dot com
- 1745: -
- 1746: 10/12/22: 0%->25 / Impacted TSs and TRs: 23.501; 23.502; 23.503; 23.288 / WI rapporteur name: Aihua Li, China Mobile / WI rapporteur e-mail: liaihua@chinamobile
- 1747: 21/1/22: 23.700-81 added;; 21/1/22: 23.700-85 added;; 12/3/22: 0%->13; 4/6/22: 13%->50; 21/6/22: WID:SP-211650->SP-220678; 12/9/22: 50%->75; 12/9/22: FCD:12/09/2022->12/22; 10/12/22: 75%->100 / Impacted TSs and TRs: 23.700-81; 23.700-85 / WI rapporteur name: Aihua Li, China Mobile / WI rapporteur e-mail: liaihua@chinamobile.com
- 1748: 4/6/22: 0%->10; 13/7/22: 33.738 added;; 12/9/22: 10%->35; 11/12/22: 35%->60; 17/3/23: 60%->80; 8/6/23: 80%->95; 15/3/24: 95%->100 / Impacted TSs and TRs: 33.738 / WI rapporteur name: Chang Liu, China Mobile / WI rapporteur e-mail: liuchangyjy@chinamobile.com
- 1749: ; 8/6/23: 0%->65; 15/3/24: 65%->100 / Impacted TSs and TRs: 33.501 / WI rapporteur name: Chang Liu, China Mobile / WI rapporteur e-mail: liuchangyjy@chinamobile.com
- 1750: 10/12/22: 0%->25; 15/3/23: 13%->65; 15/3/23: WID:SP-221345->SP-230110; 8/6/23: 65%->100 / Impacted TSs and TRs: 23.501; 23.502; 23.503; 23.288 / WI rapporteur name: Aihua Li, China Mobile / WI rapporteur e-mail: liaihua@chinamobile
- 1751: ; 6/6/23: Compl:15%->65% / Impacted TSs and TRs: 29.507.29.508.29.122.29.513.29.517.29.519.29.520.29.522.29.523.29.525.29.551.29.552.29.574.29.575.29.576.29.591.29.503.29.504.29.505.29.510.29.515.29.518.29.564.29.571 / WI rapporteur name: Zhennning Huang, China Mobile / WI rapporteur e-mail: huangzhenning@chinamobile.com
- 1752: ; 6/6/23: Compl:5%->30% / Impacted TSs and TRs: 29.507.29.508.29.122.29.513.29.517.29.519.29.520.29.522.29.523.29.525.29.551.29.552.29.574.29.575.29.576.29.591.29.503.29.504.29.505.29.510.29.515.29.518.29.564.29.571 / WI rapporteur name: Zhennning Huang, China Mobile / WI rapporteur e-mail: huangzhenning@chinamobile.com
- 1753: ; 6/6/23: Compl:70%->90%; 6/6/23: CD:12/12/2023->03/03/2024; ;... / Impacted TSs and TRs: 29.517; 29.520; 29.522; 29.552; 29.574; 29.575; 29.576; 29.591 / WI rapporteur name: Xuefei Zhang, Huawei / WI rapporteur e-mail: summer.xuefei@huawei.com
- 1754: -
- 1755: 12/9/20: 0%->20; 5/12/20: 20%->40; 19/3/21: FCD:11/09/2020->12/21; 19/3/21: 40%->50; 11/6/21: 50%->60; 13/9/21: 60%->80; 10/12/21: 80%->100 / WI rapporteur name: Cyril MICHEL,Thales / WI rapporteur e-mail: cyril.michel@thalesaleniaspace.com
- 1756: 13/7/22: 29.831 added;; 6/6/23: Compl:50%->60%; 30/6/23: WID:CP-221088->CP-231022 / Impacted TSs and TRs: 29.xxx; 29.831 / WI rapporteur name: Wiehe, Ulrich, Nokia / WI rapporteur e-mail: Ulrich.wiehe@nokia.com
- 1757: -
- 1758: ; 7/9/23: 0%->30; 8/12/23: 30%->95; 14/3/24: 95%->100 / Impacted TSs and TRs: 28.531; 28.533; 28.526 / WI rapporteur name: China Mobile Guangjing Cao / WI rapporteur e-mail: caoguangjing@chinamobile.com
- 1759: ; 8/12/23: 0%->100 / Impacted TSs and TRs: 32.240; 32.255; 32.256; 32.291; 32.298 / WI rapporteur name: Maryse Gardella, MATRIXX Software, / WI rapporteur e-mail: Maryse dot Gardella at Matrixx dot com
- 1760: ; 30/6/23: 28.318 added;; 7/9/23: 0%->30; 8/12/23: 30%->60; 4/1/24: 28.879 added;; 14/3/24: 60%->100 / Impacted TSs and TRs: 28.552; 28.554; 28.622 ; 28.318; 28.879 / WI rapporteur name: Erik Guttman , Samsung; / WI rapporteur e-mail: <erik.guttman@samsung.com
- 1761: 17/3/23: 0%->5; 17/3/23: 28.840 added;; 8/6/23: 5%->12; 7/9/23: 12%->18; 8/12/23: 18%->55; 8/12/23: FCD:09/09/2023->/2024; 14/3/24: 55%->100 / Impacted TSs and TRs: 28.840 / WI rapporteur name: João Rodrigues, Nokia / WI rapporteur e-mail: joao.a.rodrigues@nokia.com
- 1762: ; 8/6/23: 0%->; 30/6/23: WID:SP-221163->SP-230777; 7/9/23: 0%->40; 7/9/23: FCD:12/12/2023->/24; 8/12/23: 40%->90; 14/3/24: 90%->100 / Impacted TSs and TRs: 28.621; 28.622; 28.623; 32.421; 32.422; 32.423 / WI rapporteur name: Swaminathan, Sivaramakrishnan, Nokia / WI rapporteur e-mail: sivaramakrishnan<dot>swaminathan<at>nokia<dot>com
- 1763: ; 12/9/22: 0%->10; 12/9/22: FCD:10/03/2023->06/23; 11/12/22: 10%->25; 17/3/23: 25%->30; 17/3/23: FCD:06/06/2023->12/23; 8/6/23: 30%->35; 7/9/23: 35%->55; 8/12/23: 55%->100 / Impacted TSs and TRs: 28.310; 28.552; 28.554; 28.541 / WI rapporteur name: Cornily Jean-Michel, Huawei / WI rapporteur e-mail: jean.michel.cornily@huawei.com
- 1764: ; 7/1/22: 33.526 added;; 12/3/22: 0%->10; 4/6/22: 10%->30; 12/9/22: 30%->60; 11/12/22: 60%->75; 17/3/23: 75%->85; 8/6/23: 85%->95; 7/9/23: 95%->100 / Impacted TSs and TRs: 33.926 ; 33.526 / WI rapporteur name: Noamen Ben Henda, Huawei Technologies Co., Ltd. / WI rapporteur e-mail: noamen.ben.henda@huawei.com
- 1765: ; 17/8/22: WID:SP-220486->SP-220689; 12/9/22: 0%->25; 12/9/22: FCD:12/09/2022->12/22; 11/12/22: 25%->100 / Impacted TSs and TRs: 32.240; 32.270; 32.290; 32.291; 32.298 / WI rapporteur name: Törnkvist, Robert, Ericsson AB / WI rapporteur e-mail: robert(dot)tornkvist(at)Ericson(dot)com
- 1766: ; 17/8/22: WID:SP-220489->SP-220690; 12/9/22: 0%->15; 11/12/22: 15%->50; 17/3/23: 50%->60; 8/6/23: 60%->70; 8/6/23: 70%->; 7/9/23: 70%->80; 8/12/23: 80%->99; 8/12/23: FCD:12/12/2023->/2024; 3/1/24: WID:SP-220690->SP-231710; 4/1/24: 28.558 added;; 14/3...; 2/4/24: WID:SP-231710->SP-240271 / Impacted TSs and TRs: 28.552; 32.425; 28.554; 28.550 ; 28.558 / WI rapporteur name: Chen, Xiumin, China Telecom / WI rapporteur e-mail: (chenxiumin<at>chinatelecom<dot>cn)
- 1767: ; 5/12/20: 0%->5; 21/3/21: 5%->15; 11/6/21: 15%->20; 13/9/21: 20%->40; 13/9/21: FCD:Thu 16/09/->03/22; 13/12/21: 40%->60; 12/3/22: 60%->90; 4/6/22: 90%->95; 4/6/22: FCD:11/03/2022->12/22; Rel-17->Rel-18; 12/9/22: 95%->70; 12/9/22: FCD:12/12/2022->12/2...; 8/6/23: 100%-> / Impacted TSs and TRs: 28.307; 28.308; 28.309; 28.404; 28.405; 28.406; 28.622; 28.623; 28.533 / WI rapporteur name: Bagher Zadeh, Ericsson / WI rapporteur e-mail: Bagher Zadeh <at>ericsson<dot>ericsson
- 1768: ; 4/6/22: 0%->10; 12/9/22: 10%->35; 11/12/22: 35%->50; 17/3/23: 50%->50; 17/3/23: FCD:03/03/2023->12/23; 17/3/23: FCD:12/12/2023->/23; 17/3/23: 50%->100; 30/6/23: WID:SP-220154->SP-230775; 8/12/23: 100%->70; 8/12/23: FCD:03/03/2023->/2024; 14/3/24: 70%->100 / Impacted TSs and TRs: 28.541; 28.538; 28.552; 28.554; 28.531; 28.532 / WI rapporteur name: Deepanshu Gautam, Samsung / WI rapporteur e-mail: deepanshu<dot>g<at>samsung<dot>com
- 1769: 25/9/20: WID:SP-200764->SP-200853; 5/12/20: 0%->5; 21/3/21: 5%->35; 21/3/21: FCD:12/03/2021->09/21; 11/6/21: 35%->80; 11/6/21: FCD:Wed 08/09/->09/21; 13/9/21: 80%->100 / WI rapporteur name: Jing Ping, Nokia / WI rapporteur e-mail: jing.ping@nokia-sbell.com
- 1770: ; 12/3/22: 0%->60; 4/6/22: 60%->67; 4/6/22: FCD:10/12/2021->12/22; Rel-17->Rel-18; 11/12/22: 67%->68; 11/12/22: FCD:12/12/2022->12/23; 17/3/23: 68%->69; 8/6/23: 69%->72; 7/9/23: 72%->73; 8/12/23: 73%->75; 8/12/23: FCD:12/12/2023->/2024; 3/1/24: WID:SP...; 14/3/24: 75%->100 / Impacted TSs and TRs: 28.319 / WI rapporteur name: Clifton Fernandes, Nokia / WI rapporteur e-mail: Clifton.fernandes@nokia.com
- 1771: ; 12/3/22: 0%->50; 4/6/22: 50%->85; 4/6/22: FCD:11/03/2022->09/22; Rel=-17->Rel-18; 12/9/22: 85%->85; 12/9/22: FCD:12/09/2022->12/12/22; 11/12/22: 85%->90; 11/12/22: FCD:12/12/2022->/23; 17/3/23: 90%->90; 17/3/23: FCD:03/03/2023->12/23; 7/9/23: 90%->100 / Impacted TSs and TRs: 28.531; 28.541 / WI rapporteur name: Deepanshu Gautam , Samsung / WI rapporteur e-mail: deepanshu<dot>g<at>samsung<dot>com
- 1772: 5/12/20: 0%->5; 21/3/21: 5%->10; 21/3/21: FCD:12/03/2021->09/21; 11/6/21: 10%->10; 13/9/21: FCD:Wed 08/09/->12/21; 13/12/21: FCD:Fri 10/12/->03/22; 12/3/22: Rel-17->Rel-18; 8/12/23: 10%->100 / WI rapporteur name: Lengyel, Balazs, Ericsson / WI rapporteur e-mail: balazs.lengyel@ericsson.com
- 1773: ; 11/6/21: 0%->15; 13/9/21: 15%->30; 13/9/21: FCD:Fri 10/09/->12/21; 13/12/21: 30%->75; 13/12/21: FCD:Fri 10/12/->03/22; 7/1/22: 28.901 added;12/3/22: Rel-17->Rel-18; 4/6/22: 75%->100 / Impacted TSs and TRs: New ; 28.901 / WI rapporteur name: Vaishnavi, Ishan, Lenovo / WI rapporteur e-mail: ivaishnavi@lenovo.com
- 1774: ; 11/6/21: 0%->10; 13/9/21: 10%->15; 13/12/21: 15%->45; 13/12/21: FCD:Fri 10/12/->03/22; 12/3/22: Rel-17->Rel-18; 4/6/22: 45%->60; 12/9/22: 60%->75; 12/9/22: FCD:11/03/2022->03/23; 11/12/22: 75%->80; 17/3/23: 80%->85; 17/3/23: FCD:03/03/2023->/23; 8/6/23: 85%->100 / Impacted TSs and TRs: New / WI rapporteur name: Lan Zou, Huawei / WI rapporteur e-mail: zoulan@huawei.com
- 1775: ; 31/3/23: 28.111 added;; 30/6/23: WID:SP-230174->SP-230776; 7/9/23: 0%->10; 21/9/23: 32.161 added;; 8/12/23: 10%->55; 8/12/23: FCD:12/12/2023->/2024; 3/1/24: WID:SP-230776->SP-231443; 4/1/24: 28.871 added;; 14/3/24: 55%->100 / Impacted TSs and TRs: 32.404; 28.622; 28.623; 32.300; 28.532; 28.545; 28.532; 28.532; 28.532; 28.158; 28.532 ; 28.111; 32.161; 28.871 / WI rapporteur name: Zhang Kai, Huawei / WI rapporteur e-mail: kai.zhangkai@huawei.com
- 1776: 7/1/22: 28.864 added;; 4/6/22: 0%->30; 12/9/22: 30%->65; 11/12/22: 65%->75; 11/12/22: FCD:12/12/2022->/23; 8/6/23: 75%->; 8/6/23: FCD:03/03/2023->/23; 8/6/23: 75%->100 / Impacted TSs and TRs: 28.864 / WI rapporteur name: ZHAO, Song, China Telecom / WI rapporteur e-mail: zhaosong1@chinatelecom.cn
- 1777: ; 8/6/23: 0%->50; 7/9/23: 50%->75; 8/12/23: 75%->100; 4/1/24: 28.877 added; / Impacted TSs and TRs: 28.541; 28.552; 28.554 ; 28.877 / WI rapporteur name: Niu, Yuxia, China Telecom / WI rapporteur e-mail: niuyx@chinatelecom.cn
- 1778: 7/1/22: 28.907 added;; 4/6/22: 0%->40; 12/9/22: 40%->80; 11/12/22: 80%->90; 11/12/22: FCD:12/12/2022->/23; 16/3/23: WID:SP-211436->SP-230185; 17/3/23: 90%->100 / Impacted TSs and TRs: 28.907 / WI rapporteur name: ZHANG, Kai, Huawei / WI rapporteur e-mail: kai.zhangkai@huawei.com
- 1779: 7/1/22: 28.913 added;; 4/6/22: 0%->10; 12/9/22: 10%->25; 11/12/22: 25%->50; 17/3/23: 50%->50; 8/6/23: 50%->100 / Impacted TSs and TRs: 28.913 / WI rapporteur name: Cornily Jean-Michel, Orange / WI rapporteur e-mail: jean.michel.cornily@huawei.com
- 1780: 7/1/22: 28.865 added;; 4/6/22: 0%->30; 12/9/22: 30%->32; 12/9/22: FCD:12/12/2023->12/22; 11/12/22: FCD:12/12/2022->/23; 17/3/23: 32%->45; 17/3/23: FCD:03/03/2023->/23; 8/6/23: 45%->60; 8/6/23: FCD:06/06/2023->/24; 7/9/23: 60%->; 8/12/23: 60%->92; 14/3/...; 2/4/24: WID:SP-211442->SP-240269 / Impacted TSs and TRs: 28.865 / WI rapporteur name: <Zhang>, <Jian>, <Huawei> / WI rapporteur e-mail: justincn.zhang@huawei.com
- 1781: 7/1/22: 28.909 added;; 4/6/22: 0%->10; 11/12/22: 10%->10; 8/6/23: 10%->60; 8/6/23: FCD:10/03/2023->12/24; 7/9/23: 60%->70; 7/9/23: FCD:12/12/2024->/24; 8/12/23: 70%->80; 14/3/24: 80%->100 / Impacted TSs and TRs: 28.909 / WI rapporteur name: Cao Xi, China Mobile / WI rapporteur e-mail: caoxi@chinamobile.com
- 1782: 7/1/22: 28.910 added;; 4/6/22: 0%->25; 12/9/22: 25%->30; 12/9/22: FCD:12/09/2022->12/22; 11/12/22: 30%->30; 11/12/22: FCD:12/12/2022->/23; 8/6/23: 30%->75; 8/6/23: FCD:03/03/2023->12/23; 7/9/23: 75%->85; 8/12/23: 85%->100 / Impacted TSs and TRs: 28.910 / WI rapporteur name: Cao Xi, China Mobile / WI rapporteur e-mail: caoxi@chinamobile.com
- 1783: 7/1/22: 28.912 added;; 4/6/22: 0%->40; 12/9/22: 40%->80; 12/9/22: FCD:12/09/2022->12/22; 11/12/22: 80%->90; 11/12/22: FCD:12/12/2022->/23; 8/6/23: 90%->; 8/6/23: FCD:03/03/2023->/23; 8/6/23: 90%->100 / Impacted TSs and TRs: 28.912 / WI rapporteur name: Xu Ruiyue, Huawei / WI rapporteur e-mail: Xuruiyue@huawei.com
- 1784: 5/4/22: 28.831 added;; 4/6/22: 0%->10; 12/9/22: 10%->25; 11/12/22: 25%->35; 11/12/22: FCD:12/12/2022->/23; 17/3/23: 35%->70; 8/6/23: 70%->100; 30/6/23: WID:SP-220145->SP-230774 / Impacted TSs and TRs: 28.831 / WI rapporteur name: Pollakowski, Olaf, Nokia / WI rapporteur e-mail: olaf.pollakowski@nokia.com
- 1785: 5/4/22: 28.903 added;; 4/6/22: 0%->15; 12/9/22: 15%->50; 12/9/22: FCD:12/09/2022->03/23; 17/3/23: 50%->70; 17/3/23: FCD:03/03/2023->/23; 8/6/23: 70%->100 / Impacted TSs and TRs: 28.903 / WI rapporteur name: Shitao Li, Huawei / WI rapporteur e-mail: lishitao<at>huawei<dot>com
- 1786: 5/4/22: 28.833 added;; 4/6/22: 0%->25; 12/9/22: 25%->65; 12/9/22: FCD:12/12/2022->03/23; 11/12/22: 65%->98; 17/3/23: 98%->100; 8/6/23: 100%-> / Impacted TSs and TRs: 28.833 / WI rapporteur name: Xiaowen Sun, CMCC / WI rapporteur e-mail: sunxiaowen@chinamobile.com
- 1787: ; 8/6/23: 0%->45; 7/9/23: 45%->90; 8/12/23: 90%->100 / Impacted TSs and TRs: 28.541; 28.552; 28.554 / WI rapporteur name: Yushuang Hu, CMCC, / WI rapporteur e-mail: huyushuang@chinamobile.com
- 1788: 5/4/22: 28.834 added;; 4/6/22: 0%->5; 12/9/22: 5%->30; 11/12/22: 30%->70; 17/3/23: 70%->95; 17/3/23: FCD:03/03/2023->/23; 8/6/23: 95%->100; 4/1/24: 28.869 added; / Impacted TSs and TRs: 28.834; 28.869 / WI rapporteur name: China Mobile Guangjing Cao / WI rapporteur e-mail: caoguangjing@chinamobile.com
- 1789: 5/4/22: 28.835 added;; 4/6/22: 0%->30; 12/9/22: 30%->75; 12/9/22: FCD:12/09/2022->03/23; 11/12/22: 75%->90; 17/3/23: 90%->94; 17/3/23: FCD:03/03/2023->/23; 8/6/23: 94%->100; 4/1/24: 28.878 added; / Impacted TSs and TRs: 28.835; 28.878 / WI rapporteur name: Zhaoning Wang, ChinaUnicom / WI rapporteur e-mail: wangzn18@chinaunicom.cn
- 1790: ; 7/9/23: 0%->30; 8/12/23: 30%->60; 14/3/24: 60%->100 / Impacted TSs and TRs: 32.130; 28.541; 28.552 / WI rapporteur name: Wang Zhaoning, China Unicom, / WI rapporteur e-mail: wangzn18@chinaunicom.cn,
- 1791: 5/4/22: 28.837 added;; 4/6/22: 0%->15; 12/9/22: 15%->25; 12/9/22: FCD:12/12/2022->03/23; 11/12/22: 25%->35; 11/12/22: FCD:10/03/2023->/23; 17/3/23: 35%->60; 8/6/23: 60%->100; 30/6/23: WID:SP-220152->SP-230773 / Impacted TSs and TRs: 28.837 / WI rapporteur name: Sivaramaskrishnan Swaminathan, Nokia / WI rapporteur e-mail: sivaramakrishnan.swaminathan@nokia.com
- 1792: 5/4/22: 28.830 added;; 4/6/22: 0%->10; 12/9/22: 10%->20; 8/6/23: 20%->; 8/6/23: 20%->30; 8/6/23: FCD:03/03/2023->/24; 7/9/23: 30%->40; 8/12/23: 40%->65; 14/3/24: 65%->100 / Impacted TSs and TRs: 28.830 / WI rapporteur name: Deng LingLi (China Mobile)
- 1793: 12/9/22: 0%->10; 11/12/22: 10%->100; 8/6/23: 100%-> / WI rapporteur name: Chou, Joey, Intel / WI rapporteur e-mail: joey<dot>chou<at>intel<dot>com
- 1794: 12/3/22: 0%->40; 4/6/22: 40%->60; 4/6/22: FCD:11/03/2022->03/23; 21/6/22: 60%->100. 13/7/22: moved Rel-17->Rel-18, as per Gerald e-mail 21/06/22, 15:03; 12/9/22: 100%->70; 11/12/22: 70%->94; 11/12/22: 94%->75; 17/3/23: 75%->98; 17/3/23: 98%->88; 8/6/23...; 8/12/23: 96%->100 / WI rapporteur name: Tornkvist, Robert, Ericsson AB / WI rapporteur e-mail: robert(dot)tornkvist(at)Ericsson(dot)com
- 1795: ; 8/12/23: 0%->100 / Impacted TSs and TRs: 32.240; 32.290 / WI rapporteur name: João Rodrigues, Nokia / WI rapporteur e-mail: joao.a.rodrigues@nokia.com

| ID | WBS | Task | Type | Duration | Start | Finish | Complete | Remaining | Total slack | Constraint | Resources | Work | Actual work | Acronym | PCG approved | WI rapporteur name | WI rapporteur e-mail | Release | TSG approved |
| --- | --- | --- | --- | --- | --- | --- | --- | --- | --- | --- | --- | --- | --- | --- | --- | --- | --- | --- | --- |
| 1796 | 827 | Study on 5G roaming charging architecture for wholesale and retail scenarios |  | 587d | 2021-06-11 A | 2023-09-09 A | 100% |  |  | finish no earlier than 2023-09-09 | S5 | 4696h | 4696h | FS_CHROAM | 47 | Tornkvist, Robert, Ericsson AB | robert(dot)tornkvist(at)Ericsson(dot)com | Rel-18 | 92 |
| 1797 | 828 | Charging for roaming and additional actor using CHF to CHF interface |  | 130d | 2023-09-06 A | 2024-03-03 A | 100% |  |  | finish no earlier than 2024-03-03 | S5 | 1040h | 1040h | CHRACHF | 51 | Törnkvist, Robert, Ericsson AB | robert(dot)tornkvist(at)Ericsson(dot)com | Rel-18 | 101 |
| 1798 | 829 | Methodology for deprecation |  | 130d | 2022-09-12 A | 2023-03-10 A | 100% |  |  | finish no earlier than 2023-03-12 | S5 | 1040h | 1040h | OAM_MetDep | 49 | Lengyel, Balázs, Ericsson | balazs.lengyel@ericsson.com | Rel-18 | 97 |
| 1799 | 830 | Study on Data management phase 2 |  | 387d | 2022-09-12 A | 2024-03-03 A | 100% |  |  | finish no earlier than 2024-03-03 | S5 | 3096h | 3096h | FS_MADCOL_ph2 | 49 | Pollakowski, Olaf, Nokia | olaf.pollakowski@nokia.com | Rel-18 | 97 |
| 1800 | 831 | Study on Time Sensitive Networking (TSN) Charging |  | 328d | 2022-09-12 A | 2023-12-12 A | 100% |  |  | finish no earlier than 2023-12-12 | S5 | 2624h | 2624h | FS_TSNCH | 49 | CHEN SHAN, Huawei | chenshan@huawei.com | Rel-18 | 97 |
| 1801 | 832 | Charging Aspects of TSN |  | 130d | 2023-09-06 A | 2024-03-03 A | 100% |  |  | finish no earlier than 2024-03-03 | S5 | 1040h | 1040h | TSN_CH | 51 | Deng, Yimeng, Huawei, | dengyimeng at huawei dot com | Rel-18 | 101 |
| 1802 | 833 | Charging Aspects for NSSAA |  | 254d | 2023-03-16 A | 2024-03-03 A | 100% |  |  | finish no earlier than 2024-03-03 | S5 | 2032h | 2032h | NSSAA_CH | 50 | Gerald Görmer, MATRIXX Software | Gerald dot Goermer at Matrixx dot com | Rel-18 | 99 |
| 1803 | 834 | Management Aspects of NTN |  | 195d | 2023-03-16 A | 2023-12-12 A | 100% |  |  | finish no earlier than 2023-12-12 | S5 | 1560h | 1560h | OAM_NTN | 50 | Sun Mingrui, China Unicom | sunmr19@chinaunicom.cn | Rel-18 | 99 |
| 1804 | 835 | Management of non-public networks phase 2 |  | 254d | 2023-03-16 A | 2024-03-03 A | 100% |  |  | finish no earlier than 2024-03-03 | S5 | 2032h | 2032h | OAM_NPN_Ph2 | 50 | ZHANG, Kai, Huawei | kai.zhangkai@huawei.com | Rel-18 | 99 |
| 1805 | 836 | Rel-18 service-based aspects | milestone | 0d? | 2016-03-15 A | 2016-03-15 A | 100% |  |  | start no earlier than 2016-03-15 |  |  |  |  |  |  |  | Rel-18 |  |
| 1806 | 837 | Study on Standardising Automated Certificate Management in SBA |  | 452d | 2021-06-11 A | 2023-03-03 A | 100% |  |  | finish no earlier than 2023-03-03 | S3 | 3616h | 3616h | FS_ACM_SBA | 47 | BT, Niraj Rathod | Niraj.rathod@bt.com | Rel-18 | 92 |
| 1807 | 838 | Automated certificate management in SBA |  | 128d | 2023-03-16 A | 2023-09-09 A | 100% |  |  | finish no earlier than 2023-09-09 | S3 | 1024h | 1024h | ACM_SBA | 50 | Peinado, German, Nokia | german.peinado@nokia.com | Rel-18 | 99 |
| 1808 | 839 | Security Aspects of the 5G Service Based Architecture Phase 2 |  | 61d | 2022-12-09 A | 2023-03-03 A | 100% |  |  | finish no earlier than 2023-03-03 | S3 | 488h | 488h | 5G_eSBA_Ph2 | 50 | Anja Jerichow, Nokia | anja.jerichow@nokia.com | Rel-18 | 98 |
| 1809 | 840 | **Service Based Interface Protocol Improvements Release 18** |  | 577.88d | 2022-06-03 A | 2023-12-12 A | 100% |  |  |  |  | 6384h | 6384h | SBIProtoc18 | 49 | Wang Rong, China Mobile, wangrongyjy@chinamobile.com |  | Rel-18 | 96 |
| 1810 | 840.1 | CT4 aspects of SBIProtoc18 |  | 399d | 2022-06-03 A | 2023-12-12 A | 100% |  |  | finish no earlier than 2023-12-12 | C4 | 3192h | 3192h | SBIProtoc18 | 49 | Wang Rong, China Mobile, wangrongyjy@chinamobile.com |  | Rel-18 | 96 |
| 1811 | 840.2 | CT3 aspects of SBIProtoc18 |  | 399d | 2022-06-03 A | 2023-12-12 A | 100% |  |  | finish no earlier than 2023-12-12 | C3 | 3192h | 3192h | SBIProtoc18 | 49 | Wang Rong, China Mobile, wangrongyjy@chinamobile.com |  | Rel-18 | 96 |
| 1812 | 841 | Study on GBA_U Based APIs |  | 196d | 2022-06-03 A | 2023-03-03 A | 100% |  |  | finish no earlier than 2023-03-03 | C6 | 1568h | 1568h | FS_GBA_U_API | 49 | Huo Weijing, China Mobile | huoweijing@chinamobile.com | Rel-18 | 96 |
| 1813 | 842 | GBA_U Based APIs |  | 195d | 2023-06-07 A | 2024-03-03 A | 100% |  |  | finish no earlier than 2024-03-03 | C6 | 1560h | 1560h | GBA_U_APIs | 51 | Huo Weijing(China Mobile) | huoweijing@chinamobile.com | Rel-18 | 100 |
| 1814 | 843 | Study on IETF QUIC Transport for Service Based Interfaces | milestone | 0d? | 2023-12-12 A | 2023-12-12 A | 100% |  |  | finish no earlier than 2022-03-12 | C4 |  |  | FS_QUIC | 41 | Qi Caixia, Huawei | caixia.qi@huawei.com | Rel-18 | 80 |
| 1815 | 844 | Rel-18 other aspects | milestone | 0d? | 2016-03-15 A | 2016-03-15 A | 100% |  |  | start no earlier than 2016-03-15 |  |  |  |  |  |  |  | Rel-18 |  |
| 1816 | 845 | (Small) Technical Enhancements and Improvements for Rel-18 |  | 517d | 2021-03-12 A | 2022-07-24 |  | 517d | 39109.6d | finish no earlier than 2023-03-03 |  |  |  | TEI18 | 47 |  |  | Rel-18 | 92 |
| 1817 | 846 | Lawful Interception Rel-18 |  | 653d | 2021-03-12 A | 2022-12-02 | 96% | 26.12d | 38973.6d | finish no earlier than 2023-09-09 | S3LI | 5224h |  | LI18 | 47 | Koen Jaspers, PIDS | kbj@xs4all.nl | Rel-18 | 92 |
| 1818 | 847 | Limbo: code to be used for not-approved CRs related to never-approved WIDs |  | 1d | 2019-03-07 | 2019-03-07 |  |  | 40387.9d |  |  |  |  | Limbo | 48 |  |  |  | 95 |
| 1819 | 848 | Test - (Small) Technical Enhancements and Improvements for Rel-18 |  | 312d | 2022-01-05 A | 2023-03-16 A | 100% |  |  | finish no earlier than 2023-03-16 | R5 | 2496h | 2496h | TEI18_Test | 50 |  |  | Rel-18 | 99 |
| 1820 | 849 | Update of conformance test specifications to Rel-18 |  | 733.75d | 2023-06-29 A | 2025-06-06 A | 100% |  |  | finish no earlier than 2025-06-06 | C6 | 5870h | 5870h | UEConTest_R18 | 47 | Arne Marquordt, COMPRION GmbH | amarquordt@comprion.com | Rel-18 | 92 |
| 1821 | 850 | --- RELEASE 17 --- | milestone | 0d? | 2016-03-15 A | 2016-03-15 A | 100% |  |  | start no earlier than 2016-03-15 |  |  |  |  |  |  |  | Rel-17 |  |
| 1822 | 851 | Rel-17 on Use of 5G by different sectors ("verticals") | milestone, manual | 0d | 2016-06-09 A | 2016-06-09 A | 100% |  |  | finish no earlier than 2016-06-09 |  |  |  |  |  |  |  | Rel-17 |  |

Notes:
- 1796: 13/9/21: 0%->10; 12/3/22: 10%->50; 4/6/22: 50%->100; 4/6/22: FCD:11/03/2022->03/23; 4/6/22: 100%->75; 4/6/22: 0%->75; 21/6/22: 75%->100 13/7/22: moved Rel-17->Rel-18, as per Gerald e-mail 21/06/22, 15:03; 12/9/22: 100%->85; 11/12/22: 85%->90; 17/3/23: ...; 7/9/23: 99%->100
- 1797: ; 8/12/23: 0%->40; 14/3/24: 40%->100 / Impacted TSs and TRs: 32.240; 32.255; 32.256; 32.290; 32.291; 32.298
- 1798: ; 11/12/22: 0%->95; 17/3/23: 95%->100 / Impacted TSs and TRs: 32.156; 32.160
- 1799: ; 23/9/22: 28.842 added;; 11/12/22: 0%->5; 11/12/22: FCD:12/06/2023->/23; 17/3/23: 5%->10; 8/6/23: 10%->25; 8/6/23: FCD:06/06/2023->/24; 7/9/23: 25%->45; 8/12/23: 45%->80; 4/1/24: 28.873 added;; 14/3/24: 80%->100 / Impacted TSs and TRs: ; 28.842; 28.873
- 1800: 23/9/22: 28.839 added;; 11/12/22: 0%->10; 17/3/23: 10%->25; 8/6/23: 25%->70; 8/6/23: FCD:06/06/2023->12/23; 7/9/23: 70%->100 / Impacted TSs and TRs: 28.839
- 1801: ; 21/9/23: 32.282 added;; 8/12/23: 0%->60; 14/3/24: 60%->100; 2/4/24: WID:SP-231151->SP-240268 / Impacted TSs and TRs: 32.240; 32.254; 32.255; 32.291; 32.298; 32.297 ; 32.282
- 1802: ; 31/3/23: 28.204 added;; 8/6/23: 0%->10; 7/9/23: 10%->40; 8/12/23: 40%->80; 14/3/24: 80%->100 / Impacted TSs and TRs: 32.240; 32.290; 32.291; 32.298; 32.297 ; 28.204
- 1803: ; 7/9/23: 0%->30; 8/12/23: 30%->100 / Impacted TSs and TRs: 28.541; 28.552; 28.554; 28.658
- 1804: ; 8/6/23: 0%->10; 7/9/23: 10%->40; 8/12/23: 40%->65; 8/12/23: FCD:12/12/2023->/2024; 14/3/24: 65%->100 / Impacted TSs and TRs: 28.557; 28.541; 28.531; 28.533; 28.552
- 1805: -
- 1806: Was previously listed under Rel-18 but according to SA#92 report, it is Rel-17; 1/10/21: 33.876 added;; 10/3/22: WID:SP-210419->SP-220195. Rel-17->Rel-18; 12/3/22: 0%->5; 12/3/22: FCD:10/06/2022->9/22; 4/6/22: 5%->35; 12/9/22: 35%->60; 17/3/23: 60%->90...; 8/6/23: 90%->100 / Impacted TSs and TRs: 33.876
- 1807: ; 8/6/23: 0%->35; 30/6/23: WID:SP-230150->SP-230768; 7/9/23: 35%->100 / Impacted TSs and TRs: 33.310
- 1808: ; 8/6/23: 0%->95; 15/3/24: 95%->100 / Impacted TSs and TRs: 33.501
- 1809: Impacted TSs and TRs: 29.507; 29.508; 29.512; 29.514; 29.517; 29.519; 29.520; 29.521; 29.523; 29.525; 29.534; 29.535; 29.537; 29.551; 29.554; 29.557; 29.565; 29.574; 29.575; 29.576; 29.580; 29.591; 29.594; 29.675
- 1810: ; 6/6/23: Compl:25%->50% / Impacted TSs and TRs: 29.500; 29.501; 29.502; 29.503; 29.504; 29.505; 29.509; 29.510; 29.511; 29.515; 29.518; 29.524; 29.531; 29.532; 29.536; 29.540; 29.541; 29.542; 29.544; 29.550; 29.555; 29.556; 29.559; 29.562; 29.563; 29.564; 29.571; 29.572; 29.573; 29.577; 29.578; 29.579;
- 1811: ; 9/6/23: 30%->60 / Impacted TSs and TRs: 29.507; 29.508; 29.512; 29.514; 29.517; 29.519; 29.520; 29.521; 29.523; 29.525; 29.534; 29.535; 29.537; 29.551; 29.554; 29.557; 29.565; 29.574; 29.575; 29.576; 29.580; 29.591; 29.594; 29.675
- 1812: 13/7/22: 31.822 added / Impacted TSs and TRs: 31.121 ; 31.822
- 1813: ; 30/6/23: 31.122 added; / Impacted TSs and TRs: 31.102; 31.130; 31.116 ; 31.122
- 1814: 6/8/18: 29.893 added;¦10/9/18: 0%->40¦10/12/18: FCD:03/19->06/19¦10/12/18: WID:CP-181194->CP-183245¦14/3/19: 50%->75; 31/5/19: 75%->80. 02/07/20: moved Rel-16->Rel-17; 13/9/20: FCD:12/06/2019->09/21; 13/9/21: FCD:Wed 08/09/->03/22; 12/3/22:rel-17->18 / Impacted TSs and TRs: New; 29.893
- 1815: -
- 1817: 10/9/21: WID:SP-210300->SP-210830; 4/6/22: 0%->5; 12/9/22: 5%->15; 11/12/22: 15%->20; 16/3/23: FCD:03/03/2023->/2023; 16/3/23: WID:SP-210830->SP-230241. Rapporteur changed from Alex Leadbeater; 31/3/23: 33.928 added;; 5/9/24: 20%->90; 5/12/24: 90%->96 / Impacted TSs and TRs: 33.128;33.127;33.126;33.108;33.107 ; 33.928
- 1818: "Dummy" is a temporary code for CRs related to not-yet-approved WIDs. If a WID ended up not being approved at pleanry, then all related CRs have to be changed from "Dummy" to "Limbo"
- 1819: 8/6/23: 0%->100
- 1821: -
- 1822: -

| ID | WBS | Task | Duration | Start | Finish | Complete | Constraint | Resources | Work | Actual work | Acronym | PCG approved | WI rapporteur name | WI rapporteur e-mail | Release | TSG approved | TSG stopped |
| --- | --- | --- | --- | --- | --- | --- | --- | --- | --- | --- | --- | --- | --- | --- | --- | --- | --- |
| 1823 | 852 | **Enhancements for cyber-physical control applications in vertical domains** | 291d | 2019-03-07 A | 2019-12-12 A | 100% |  |  | 2135h | 2135h | eCAV | 43 | Bahr, Michael, Siemens AG | bahr et siemens dod com | Rel-17 | 84 |  |
| 1824 | 852.1 | Study on eCAV | 130.88d | 2019-03-07 A | 2019-09-05 A | 100% |  | S1 | 1047h | 1047h | FS_eCAV | 42 | Michael Bahr, Siemens AG | bahr et siemens dod com | Rel-17 | 83 |  |
| 1825 | 852.2 | Stage 1 of eCAV | 136d | 2019-06-06 A | 2019-12-12 A | 100% | finish no earlier than 2019-12-12 | S1 | 1088h | 1088h | eCAV | 43 | Bahr, Michael, Siemens AG | bahr et siemens dod com | Rel-17 | 84 |  |
| 1826 | 853 | Study on enhanced support of Non-Public Networks | 462d | 2019-06-06 A | 2021-03-12 A | 100% | finish no earlier than 2021-03-12 | S2 | 3696h | 3696h | FS_eNPN | 43 | Peter Hedman | peter . hedman @ ericsson . com | Rel-17 | 84 |  |
| 1827 | 854 | **Enhanced support of Non-Public Networks** | 754.88d | 2020-06-12 A | 2022-06-10 A | 100% |  |  | 16080h | 16080h | eNPN | 46 | Hedman, Peter, Ericsson | peter dot hedman at ericsson dot com | Rel-17 | 90 |  |
| 1828 | 854.1 | Stage 2 for eNPN | 200d | 2020-12-03 A | 2021-09-08 A | 100% | finish no earlier than 2021-09-08 | S2 | 1600h | 1600h | eNPN | 46 | Hedman, Peter, Ericsson | peter dot hedman at ericsson dot com | Rel-17 | 90 |  |
| 1829 | 854.2 | **CT aspects of eNPN** | 371.62d | 2021-03-18 A | 2022-03-11 A | 100% |  | ct | 8224h | 8224h | eNPN | 46 | Sedlacek, Ivo, Ericsson | ivo <dot> sedlacek <at> ericsson <dot> com | Rel-17 | 91 |  |
| 1830 | 854.2.1 | CT1 aspects of eNPN | 257d | 2021-03-18 A | 2022-03-11 A | 100% | finish no earlier than 2022-03-12 | C1 | 2056h | 2056h | eNPN | 46 | Sedlacek, Ivo, Ericsson | ivo <dot> sedlacek <at> ericsson <dot> com | Rel-17 | 91 |  |
| 1831 | 854.2.2 | CT3 aspects of eNPN | 257d | 2021-03-18 A | 2022-03-11 A | 100% | finish no earlier than 2022-03-12 | C3 | 2056h | 2056h | eNPN | 46 | Sedlacek, Ivo, Ericsson | ivo <dot> sedlacek <at> ericsson <dot> com | Rel-17 | 91 |  |
| 1832 | 854.2.3 | CT4 aspects of eNPN | 257d | 2021-03-18 A | 2022-03-11 A | 100% | finish no earlier than 2022-03-12 | C4 | 2056h | 2056h | eNPN | 46 | Sedlacek, Ivo, Ericsson | ivo <dot> sedlacek <at> ericsson <dot> com | Rel-17 | 91 |  |
| 1833 | 854.3 | Security Aspects of eNPN | 261d | 2021-06-11 A | 2022-06-10 A | 100% | finish no earlier than 2022-06-12 | S3 | 2088h | 2088h | eNPN | 47 | Jost, Christine, Ericsson | christine.jost@ericsson.com | Rel-17 | 92 |  |
| 1834 | 854.4 | Study on enhanced security support for Non-Public Networks | 521d | 2020-06-12 A | 2022-06-10 A | 100% | finish no earlier than 2022-06-12 | S3 | 4168h | 4168h | FS_eNPN_SEC | 45 | Normann, Henrik, Ericsson | henrik.normann@ericsson.com | Rel-17 | 88 |  |
| 1835 | 855 | **Audio-Visual Service Production** | 574.75d? | 2018-06-06 A | 2019-12-12 A | 100% |  |  | 3216h | 3216h | AVPROD | 43 | Wagdin, Ian, BBC | ian.wagdin@bbc.co.uk | Rel-17 | 84 |  |
| 1836 | 855.1 | Study on AVPROD | 266d? | 2018-06-06 A | 2019-06-12 A | 100% | finish no earlier than 2019-06-12 | S1 | 2128h | 2128h | FS_AVPROD | 41 | Roland Beutler, EBU | Roland.Beutler@swr.de | Rel-17 | 80 |  |
| 1837 | 855.2 | Stage 1 of AVPROD | 136d | 2019-06-06 A | 2019-12-12 A | 100% | finish no earlier than 2019-12-12 | S1 | 1088h | 1088h | AVPROD | 43 | Wagdin, Ian, BBC | ian.wagdin@bbc.co.uk | Rel-17 | 84 |  |
| 1838 | 856 | Study on Media Production over 5G NPN | 322d | 2021-03-18 A | 2022-06-10 A | 100% | finish no earlier than 2022-06-12 | S4 | 2576h | 2576h | FS_NPN4AVProd | 46 | Lohmar, Thorsten, Ericsson | Thorsten.Lohmar@ericsson.com | Rel-17 | 91 |  |
| 1839 | 857 | Study on application layer support for Factories of the Future in 5G network | 592d? | 2019-03-07 A | 2021-06-11 A | 100% | finish no earlier than 2021-06-12 | S6 | 4736h | 4736h | FS_FFAPP | 42 | Shao Weixiang, ZTE Corporation | shao.weixiang@zte.com.cn | Rel-17 | 82 |  |
| 1840 | 858 | Stopped - Study on enhancement of support for 5G LAN-type service | 201d | 2019-06-06 A | 2020-03-12 A | 100% | finish no earlier than 2020-03-12 | S2 | 1608h | 1608h | FS_5GLAN_enh | 43 | Runze Zhou, Huawei | zhourunze@huawei.com | Rel-17 | 84 | 96 |
| 1841 | 859 | Study on Charging Aspect of 5G LAN-type Services | 266d | 2020-12-04 A | 2021-12-10 A | 100% | finish no earlier than 2021-12-12 | S5 | 2128h | 2128h | FS_5GLAN_CH | 46 | CHEN SHAN, Huawei | chenshan@huawei.com | Rel-17 | 90 |  |
| 1842 | 860 | Charging Aspects of 5G LAN VN Group | 131d | 2021-12-10 A | 2022-06-10 A | 100% | finish no earlier than 2022-06-12 | S5 | 1048h | 1048h | 5GLAN_CH | 48 | CHEN SHAN, Huawei | chenshan@huawei.com | Rel-17 | 94 |  |
| 1843 | 861 | Complete Gap Analysis for Railways Mobile Communication System | 136d | 2019-06-06 A | 2019-12-12 A | 100% | finish no earlier than 2019-12-12 | S1 | 1088h | 1088h | MONASTERYEND | 43 | Gach, Guillaume, UIC | ext.gach@uic.org | Rel-17 | 84 |  |
| 1844 | 862 | **Enhancements to Application Architecture for the Mobile Communication System for Railways Phase 2** | 1045.88d | 2019-06-06 A | 2022-03-11 A | 100% |  |  | 5760h | 5760h | eMONASTERY2 | 43 | Oettl, Martin, Nokia | martin(dot)oettl(at)nokia(dot)com | Rel-17 | 84 |  |
| 1845 | 862.1 | Stage 2 of eMONASTERY2 | 332d | 2019-06-06 A | 2020-09-11 A | 100% | finish no earlier than 2020-09-12 | S6 | 2656h | 2656h | eMONASTERY2 | 43 | Oettl, Martin, Nokia | martin(dot)oettl(at)nokia(dot)com | Rel-17 | 84 |  |
| 1846 | 862.2 | Stage 3 of eMONASTERY2 | 388d | 2020-09-16 A | 2022-03-11 A | 100% | finish no earlier than 2022-03-12 | C1 | 3104h | 3104h | eMONASTERY2 | 45 | Gkatzikis, Lazaros, Nokia(Nokia) | lazaros(dot)gkatzikis(at)nokia(dot)com | Rel-17 | 89 |  |
| 1847 | 863 | Study on Future Railway Mobile Communication System3 | 136d | 2019-06-06 A | 2019-12-12 A | 100% | finish no earlier than 2019-12-12 | S1 | 1088h | 1088h | FS_FRMCS3 | 43 | Gach, Guillaume, UIC, | ext.gach@uic.org | Rel-17 | 84 |  |

Notes:
- 1823: Impacted TSs and TRs: 22.104; 22.261
- 1824: 14/3/19: 0%->5; 31/5/19: 5%->60; 13/9/19: 60%->85; 6/12/19: 85%->95; 26/6/20: 95%->100 / Impacted TSs and TRs: New
- 1825: 31/5/19: 0%->10; 13/9/19: 10%->80; 20/9/19: WID:SP-190310->SP-190945; 6/12/19: 80%->95; 12/12/19: WID:SP-190945->SP-191043; 26/6/20: 95%->100 / Impacted TSs and TRs: 22.104; 22.261
- 1826: 8/10/19: 23.700-07 added;; 6/12/19: 0%->15; 25/3/20: WID:SP-190453->SP-200094; 25/3/20: FCD:12/03/2020->06/20; 25/3/20: 15%->35; 26/6/20: FCD:15/06/2020->09/20; 26/6/20: 35%->55; 12/9/20: 55%->75; 12/9/20: FCD:15/09/2020->12/20; 5/12/20: 75%->90; 5/12 / Impacted TSs and TRs: New ; 23.700-07
- 1827: Impacted TSs and TRs: 23.501; 23.502; 23.503; 23.228; 23.167
- 1828: 19/3/21: 0%->20; 14/6/21: 20%->85; 14/6/21: FCD:Fri 11/06/->09/21; 13/9/21: 85%->95; 10/12/21: 95%->97; 12/3/22: 97%->100 / Impacted TSs and TRs: 23.501; 23.502; 23.503; 23.228; 23.167
- 1829: ; 10/9/21: WID:CP-210139->CP-212103 / Impacted TSs and TRs: 23.003; 23.122; 24.008; 24.167; 24.229; 24.368; 24.501; 24.526; 27.007; 29.503; 29.505; 29.509; 29.513; 29.522; 29.525; 29.561
- 1830: ; 11/6/21: 0%->20; 13/9/21: 20%->40; 13/12/21: 40%->65; 12/3/22: 65%->93; 4/6/22: 93%->99; 20/6/22: Compl:99%->100%
- 1831: ; 13/9/21: 0%->45; 13/12/21: 45%->75; 13/12/21: WID:CP-212103->CP-213072; 12/3/22: 75%->100
- 1832: ; 11/6/21: 0%->30; 13/9/21: 30%->40; 13/12/21: 40%->80; 12/3/22: 80%->98; 4/6/22: 98%->100
- 1833: ; 13/9/21: 0%->50; 13/12/21: 50%->90; 12/3/22: 90%->95; 12/3/22: FCD:10/12/2021->6/22; 4/6/22: 95%->100 / Impacted TSs and TRs: 33.501
- 1834: 28/7/20: 33.857 added;; 12/9/20: 0%->10; 5/12/20: 10%->35; 5/12/20: FCD:11/12/2020->03/20; 19/3/21: 35%->65; 19/3/21: FCD:12/03/2021->06/21; 11/6/21: 65%->75; 11/6/21: FCD:Fri 11/06/->12/21; 13/9/21: 75%->90; 12/3/22: 90%->90; 12/3/22: FCD:10/12/2021-> / Impacted TSs and TRs: 33.857
- 1835: Impacted TSs and TRs: 22.261
- 1836: 6/8/18: 22.827 added;¦10/9/18: 0%->10¦4/12/18: 10%->50¦14/12/18: WID:SP-180340->SP-181015¦14/12/18: FCD:03/19->06/19¦14/3/19: 50%->80; 31/5/19: 80%->95; 13/9/19: 95%->100 / Impacted TSs and TRs: 22.827
- 1837: 13/9/19: 0%->80; 6/12/19: 80%->100; 12/12/19: WID:SP-190304->SP-191041 / Impacted TSs and TRs: 22.261
- 1838: ; 9/4/21: 26.805 added;; 11/6/21: 0%->15; 13/9/21: 15%->30; 13/12/21: 30%->60; 12/3/22: 60%->80; 12/3/22: FCD:11/03/2022->6/22; 4/6/22: 80%->100 / Impacted TSs and TRs: New 26.805
- 1839: 14/3/19: 0%->5; 31/5/19: 5%->15; 13/9/19: 15%->20; 13/9/19: FCD:12/03/2020->09/20; 20/9/19: WID:SP-181139->SP-190724; 6/12/19: 20%->40; 26/3/20: 40%->50; 25/6/20: WID:SP-190724->; 28/6/20: 50%->60; 13/9/20: 60%->70; 13/9/20: WID:->SP-200836; 13/9/20: F / Impacted TSs and TRs: new
- 1840: 20/9/19: WID:SP-190454->SP-190626; 8/10/19: 23.762 added;; 22/3/22: Stopped at 0% (Puneet: deprioritized as part of the Rel-17 prioritization exercise) / Impacted TSs and TRs: New ; 23.762
- 1841: 21/3/21: 0%->10; 2/7/21: 28.822 added;; 13/9/21: 10%->60; 13/9/21: FCD:Fri 11/06/->12/21; 12/3/22: 60%->100 / Impacted TSs and TRs: 28.822
- 1842: ; 12/3/22: 0%->35; 22/3/22: WID:SP-211430->SP-220291; 4/6/22: 35%->100 / Impacted TSs and TRs: 32.240; 32.255; 32.291; 32.298
- 1843: 31/5/19: 0%->20; 13/9/19: 20%->80; 6/12/19: 80%->100 / Impacted TSs and TRs: 22.280; 22.281; 22.282; 22.179; 22.289
- 1844: 13/9/19: 0%->70; 6/12/19: 70%->50; 6/12/19: FCD:10/12/2019->03/20; 6/12/19: WID:SP-190565->SP-191104; 26/3/20: 50%->60; 26/3/20: FCD:12/03/2020->09/20; 28/6/20: 60%->85 / Impacted TSs and TRs: 23.280; 23.379; 23.281; 23.282; 23.283
- 1845: 13/9/19: 0%->70; 6/12/19: 70%->50; 6/12/19: FCD:10/12/2019->03/20; 6/12/19: WID:SP-190565->SP-191104; 26/3/20: 50%->60; 26/3/20: FCD:12/03/2020->09/20; 28/6/20: 60%->85; 13/9/20: 85%->100 / Impacted TSs and TRs: 23.280; 23.379; 23.281; 23.282; 23.283
- 1846: ; 5/12/20: 0%->10; 21/3/21: 10%->30; 11/6/21: 30%->50; 13/9/21: 50%->55; 13/9/21: FCD:Wed 08/09/->03/22; 13/12/21: 55%->70; 12/3/22: 70%->80; 4/6/22: 80%->98 / Impacted TSs and TRs: 24.379 ; 24.282 ; 24.481 ; 24.483 ; 24.484 ; 24.582
- 1847: 31/5/19: 0%->40; 13/9/19: 40%->80; 6/12/19: 80%->100; 25/6/20: WID:SP-190321->SP-200578 / Impacted TSs and TRs: 22.989

| ID | WBS | Task | Type | Duration | Start | Finish | Complete | Constraint | Resources | Work | Actual work | Acronym | PCG approved | Impacted TSs and TRs | WI rapporteur name | WI rapporteur e-mail | Release | TSG approved | Status Report |
| --- | --- | --- | --- | --- | --- | --- | --- | --- | --- | --- | --- | --- | --- | --- | --- | --- | --- | --- | --- |
| 1848 | 864 | **Asset Tracking for 5G** |  | 479.5d? | 2018-09-06 A | 2019-12-12 A | 100% |  |  | 2104h | 2104h | ATRAC | 43 | 22.261 | Thierry Berisot, NOVAMINT | tberisot@novamint.com | Rel-17 | 85 |  |
| 1849 | 864.1 | Study on ATRAC |  | 202d? | 2018-09-06 A | 2019-06-14 A | 100% | finish no earlier than 2019-06-14 | S1 | 1616h | 1616h | FS_5G_ATRAC | 41 | 22.836 | Thierry Berisot, NOVAMINT | tberisot@novamint.com | Rel-17 | 81 |  |
| 1850 | 864.2 | Stage 1 of ATRAC |  | 61d | 2019-09-19 A | 2019-12-12 A | 100% | finish no earlier than 2019-12-12 | S1 | 488h | 488h | ATRAC | 43 | 22.261 | Thierry Berisot, NOVAMINT | tberisot@novamint.com | Rel-17 | 85 |  |
| 1851 | 865 | **Enhancement to the 5GC LoCation Services-Phase 2** |  | 742.38d | 2020-03-25 A | 2022-03-11 A | 100% |  |  | 11272h | 11272h | 5G_eLCS_ph2 | 44 | 23.273 | Ming Ai, CATT | aiming@catt.cn | Rel-17 | 87 |  |
| 1852 | 865.1 | Stage 2 of 5G_eLCS_ph2 |  | 381d | 2020-03-25 A | 2021-09-08 A | 100% | finish no earlier than 2021-09-08 | S2 | 3048h | 3048h | 5G_eLCS_ph2 | 44 | 23.273 | Ming Ai, CATT | aiming@catt.cn | Rel-17 | 87 |  |
| 1853 | 865.2 | **CT aspects of 5G_eLCS_ph2** |  | 371.62d | 2021-03-18 A | 2022-03-11 A | 100% |  | ct | 8224h | 8224h | 5G_eLCS_ph2 | 46 |  | Chenxi Bao, CATT | baochenxi@catt.cn | Rel-17 | 91 |  |
| 1854 | 865.2.1 | CT1 aspects of 5G_eLCS_ph2 |  | 257d | 2021-03-18 A | 2022-03-11 A | 100% | finish no earlier than 2022-03-12 | C1 | 2056h | 2056h | 5G_eLCS_ph2 | 46 | 24.501; 24.571; 27.007 | Chenxi Bao, CATT | baochenxi@catt.cn | Rel-17 | 91 |  |
| 1855 | 865.2.2 | CT3 aspects of 5G_eLCS_ph2 |  | 257d | 2021-03-18 A | 2022-03-11 A | 100% | finish no earlier than 2022-03-12 | C3 | 2056h | 2056h | 5G_eLCS_ph2 | 46 | 29.522; 29.122 | Chenxi Bao, CATT | baochenxi@catt.cn | Rel-17 | 91 |  |
| 1856 | 865.2.3 | CT4 aspects of 5G_eLCS_ph2 |  | 257d | 2021-03-18 A | 2022-03-11 A | 100% | finish no earlier than 2022-03-12 | C4 | 2056h | 2056h | 5G_eLCS_ph2 | 46 | 29.515; 29.572; 24.080; 29.518; 29.503; 29.571 | Chenxi Bao, CATT | baochenxi@catt.cn | Rel-17 | 91 |  |
| 1857 | 866 | **RAN aspects of NR positioning enhancements** |  | 1510d | 2019-03-07 A | 2024-12-12 A | 100% |  |  | 13720h | 13720h | NR_pos_enh | 46 |  | Intel |  | Rel-17 | 90 |  |
| 1858 | 866.1 | Study on NR positioning enhancements |  | 325d | 2019-03-07 A | 2020-06-03 A | 100% |  | R1 | 2600h | 2600h | FS_NR_pos_enh | 44 |  | CATT |  | Rel-17 | 86 |  |
| 1859 | 866.2 | Core part: NR positioning enhancements |  | 332d | 2020-12-14 A | 2022-03-22 A | 100% | finish no earlier than 2022-03-22 | R1 | 2656h | 2656h | NR_pos_enh-Core | 46 |  | Yi GUO, Intel Corporation | yi.guo@intel.com | Rel-17 | 90 | RP-221586 |
| 1860 | 866.3 | Perf. part: NR positioning enhancements |  | 464d | 2020-12-14 A | 2022-09-22 A | 100% | finish no earlier than 2022-09-22 | R1 | 3712h | 3712h | NR_pos_enh-Perf | 46 |  | Yi GUO, Intel Corporation | yi.guo@intel.com | Rel-17 | 90 | RP-221586 |
| 1861 | 866.4 | UE Conformance - NR Positioning Enhancements |  | 594d | 2022-09-08 A | 2024-12-12 A | 100% | finish no earlier than 2024-12-12 | R5 | 4752h | 4752h | NR_pos_enh-UEConTest | 49 |  | Xiaoyang TIAN, CATT | tianxiaoyang@catt.cn | Rel-17 | 97 | RP-243119 |
| 1862 | 867 | **Communication Service Requirements for Critical Medical Applications** |  | 479.5d? | 2018-09-06 A | 2019-12-12 A | 100% |  |  | 3224h | 3224h | CMED | 43 | 22.261; 22.104 | Lagrange, Mathieu, b<>com | mathieu.lagrange@b-com.com | Rel-17 | 84 |  |
| 1863 | 867.1 | Study on CMED |  | 267d? | 2018-09-06 A | 2019-09-13 A | 100% | finish no earlier than 2019-09-13 | S1 | 2136h | 2136h | FS_CMED | 41 | 22.826 | Mathieu Lagrange, b<>com | mathieu.lagrange@b-com.com | Rel-17 | 81 |  |
| 1864 | 867.2 | Stage 1 of CMED |  | 136d | 2019-06-06 A | 2019-12-12 A | 100% | finish no earlier than 2019-12-12 | S1 | 1088h | 1088h | CMED | 43 | 22.261; 22.104 | Lagrange, Mathieu, b<>com | mathieu.lagrange@b-com.com | Rel-17 | 84 |  |
| 1865 | 868 | Rel-17 drone/UAS/UAV/EAV | milestone, manual | 0d | 2016-06-09 A | 2016-06-09 A | 100% | finish no earlier than 2016-06-09 |  |  |  |  |  |  |  |  | Rel-17 |  |  |
| 1866 | 869 | **5G Enhancement for UAVs** |  | 480.5d? | 2018-09-06 A | 2019-12-13 A | 100% |  |  | 3744h | 3744h | EAV | 43 | 22.125; 22.261 | Qun Wei, China Unicom | weiqun5@chinaunicom.cn | Rel-17 | 84 |  |
| 1867 | 869.1 | Study on EAV |  | 332d? | 2018-09-06 A | 2019-12-13 A | 100% | finish no earlier than 2019-12-13 | S1 | 2656h | 2656h | FS_EAV | 41 | 22.829 | Qun Wei, China Unicom | weiqun5@chinaunicom.cn | Rel-17 | 81 |  |
| 1868 | 869.2 | Stage 1 of EAV |  | 136d | 2019-06-06 A | 2019-12-12 A | 100% | finish no earlier than 2019-12-12 | S1 | 1088h | 1088h | EAV | 43 | 26.118; 26.247¦22.125 | Qun Wei, China Unicom | weiqun5@chinaunicom.cn | Rel-17 | 84 |  |
| 1869 | 870 | Study on supporting Uncrewed Aerial Systems Connectivity, Identification, and Tracking |  | 529d | 2018-12-06 A | 2020-12-15 A | 100% | finish no earlier than 2020-12-15 | S2 | 4232h | 4232h | FS_ID_UAS_SA2 | 42 |  | Qualcomm Incorporated, Stefano Faccin | sfaccin@qti.qualcomm.com | Rel-17 | 82 |  |
| 1870 | 871 | Study on application layer support for Uncrewed Aerial System (UAS) |  | 592d | 2018-12-06 A | 2021-03-12 A | 100% | finish no earlier than 2021-03-12 | S6 | 4736h | 4736h | FS_UASAPP | 42 | new 23.755 | Niranth Amogh, Huawei | namogh@huawei.com | Rel-17 | 82 |  |
| 1871 | 872 | **Application layer support for Uncrewed Aerial System (UAS)** |  | 479.38d | 2020-12-04 A | 2022-03-11 A | 100% |  |  | 4224h | 4224h | UASAPP | 46 |  | Niranth Amogh, Huawei Telecommunications India | namogh@huawei.com | Rel-17 | 90 |  |
| 1872 | 872.1 | Stage 2 of Application layer support for Uncrewed Aerial System (UAS) |  | 136d | 2020-12-04 A | 2021-06-11 A | 100% | finish no earlier than 2021-06-12 | S6 | 1088h | 1088h | UASAPP | 46 | 23.434 ; new 23.255 | Niranth Amogh, Huawei Telecommunications India | namogh@huawei.com | Rel-17 | 90 |  |
| 1873 | 872.2 | CT1 Aspects of Application Layer Support for Uncrewed Aerial Systems (UAS) |  | 196d | 2021-06-11 A | 2022-03-11 A | 100% | finish no earlier than 2022-03-12 | C1 | 1568h | 1568h | UASAPP | 47 | 24.548;24.545;27.007 ; 24.257 | Lin Shu, Huawei, | shulin@huawei.com | Rel-17 | 92 |  |
| 1874 | 872.3 | CT3 Aspects of Application Layer Support for Uncrewed Aerial Systems (UAS) |  | 196d | 2021-06-11 A | 2022-03-11 A | 100% | finish no earlier than 2022-03-12 | C3 | 1568h | 1568h | UASAPP | 47 | 29.549 ; 29.257 | Lin Shu, Huawei | shulin@huawei.com | Rel-17 | 92 |  |
| 1875 | 873 | Study on security aspects of Uncrewed Aerial Systems (UAS) |  | 391d | 2020-06-12 A | 2021-12-10 A | 100% | finish no earlier than 2021-12-12 | S3 | 3128h | 3128h | FS_UAS_SEC | 45 | 33.854 | Adrian Escott, Qualcomm Incorporated | aescott@qti.qualcomm.com | Rel-17 | 88 |  |

Notes:
- 1849: 4/12/18: 0%->15¦14/3/19: 15%->45; 31/5/19: 45%->50; 13/9/19: 50%->100
- 1850: ; 13/9/19: 0%->95; 6/12/19: 95%->100
- 1851: 5/12/20: 0%->20; 5/12/20: FCD:17/09/2020->06/20
- 1852: 5/12/20: 0%->20; 5/12/20: FCD:17/09/2020->06/20; 19/3/21: 20%->40; 11/6/21: 40%->70; 11/6/21: FCD:Fri 11/06/->09/21; 13/9/21: 70%->95; 10/12/21: 95%->100
- 1853: 11/6/21: WID:CP-210075->CP-211090
- 1854: 13/12/21: 0%->50; 12/3/22: 50%->98; 20/6/22: Compl:98%->100%
- 1855: 13/9/21: 0%->10; 13/12/21: 10%->60; 12/3/22: 60%->100
- 1856: 11/6/21: 0%->20; 13/9/21: 20%->35; 13/12/21: 35%->75; 12/3/22: 75%->98; 4/6/22: 98%->100; 20/6/22: Compl:99%->100%
- 1857: follow-up WI of REL-17 SI FS_NR_pos_enh (not yet completed at RAN #90e) ; 7/4/21: WID:RP-202900->RP-210903
- 1858: affects: NR. compare REL-16 NR_pos WI; TR 38.8xx; 26/3/20: WID:RP-193237->RP-200218; 28/7/20: WID:RP-200218->RP-200928; 25/9/20: WID:RP-200928->RP-202094; 7/4/21: 0%->100
- 1859: follow-up WI of REL-17 SI FS_NR_pos_enh (not yet completed at RAN #90e) ; 20/6/22: FCD:12/03/2022->22/03/2022; Compl:0%->100%; Stat Rep: ->RP-221586; Rapporteur: Intel->Yi GUO, Intel Corporation; Rap eMail: ->yi.guo@intel.com;
- 1860: follow-up WI of REL-17 SI FS_NR_pos_enh ; 20/6/22: WG: R4->R1; FCD:08/09/2022->22/09/2022; Compl:0%->40%; Stat Rep: ->RP-221586; Rapporteur: Intel->Yi GUO, Intel Corporation; Rap eMail: ->yi.guo@intel.com ; ;...; 23/9/22: 100%->100
- 1861: 9/12/22: FCD:10/06/2024->31/05/2024; Compl:0%->5%; Stat Rep: ->RP-223137; Rapporteur: CATT->Xiaoyang TIAN, CATT; Rap eMail: ->tianxiaoyang@catt.cn; 17/3/23: Compl:5%->7%; Stat Rep: RP-223137->RP-230394; ...; 6/9/23: FCD:06/06/2023->06/06/2024; Compl:1...; 24/1/25: 99%->100
- 1863: 4/12/18: 0%->15¦14/3/19: 15%->65; 31/5/19: 65%->90; 6/12/19: 90%->100
- 1864: 13/9/19: 0%->80; 6/12/19: 80%->100
- 1865: 06/21: "unmanned" changed to "uncrewed" as per SA#91 discussions
- 1867: -; 31/5/19: 70%->90; 13/9/19: 90%->100
- 1868: 26.118¦26.247 ; 13/9/19: 0%->80; 6/12/19: 80%->100
- 1869: 25/3/20: WID:SP-181114->SP-200097; 25/3/20: 0%->25; 26/6/20: FCD:12/03/2020->09/20; 26/6/20: 25%->50; 12/9/20: 50%->70; 12/9/20: FCD:15/09/2020->12/20; 5/12/20: 70%->100
- 1870: 31/5/19: 0%->10; 13/9/19: 10%->25; 6/12/19: 25%->35; 6/12/19: FCD:13/12/2019->03/20; 25/3/20: WID:SP-181252->SP-200111; 25/3/20: FCD:12/03/2020->09/20; 28/6/20: 35%->45; 13/9/20: 45%->55; 5/12/20: 55%->75; 5/12/20: FCD:11/09/2020->03/20; 21/3/21: 75%->100
- 1871: 23.434 ; 21/3/21: 0%->25
- 1872: 21/3/21: 0%->25; 11/6/21: 25%->100; 2/7/21: 23.255 added;
- 1873: ; 2/7/21: 24.257 added;; 13/9/21: 0%->40; 13/12/21: 40%->80; 12/3/22: 80%->100
- 1874: ; 11/6/21: 0%->5; 2/7/21: 29.257 added;; 13/9/21: 5%->30; 13/12/21: 30%->75; 13/12/21: WID:CP-211111->CP-213076; 12/3/22: 75%->100; 12/3/22: WID:CP-213076->CP-220303
- 1875: 12/9/20: 0%->15; 12/9/20: FCD:15/01/2021->03/21; 5/12/20: 15%->30; 19/3/21: FCD:12/03/2021->06/21; 19/3/21: 30%->65; 11/6/21: 65%->90; 11/6/21: FCD:Fri 11/06/->12/21; 13/12/21: 90%->90; 31/3/23: 90%->100

| ID | WBS | Task | Type | Duration | Start | Finish | Complete | Actual finish | Constraint | Resources | Work | Actual work | Acronym | PCG approved | WI rapporteur name | WI rapporteur e-mail | Release | TSG approved | Status Report |
| --- | --- | --- | --- | --- | --- | --- | --- | --- | --- | --- | --- | --- | --- | --- | --- | --- | --- | --- | --- |
| 1876 | 874 | **Remote Identification of Uncrewed Aerial Systems** |  | 2371.25d? | 2018-09-06 A | 2024-12-12 A | 100% |  |  |  | 15712h | 15712h | ID_UAS | 41 | Eddy HALL, Qualcomm incorporated | edhall@qti.qualcomm.com | Rel-17 | 81 |  |
| 1877 | 874.1 | Stage 1 of Remote Identification of Uncrewed Aerial Systems |  | 72d? | 2018-09-06 A | 2018-12-14 A | 100% |  | finish no earlier than 2018-12-14 | S1 | 576h | 576h | ID_UAS | 41 | Eddy HALL, Qualcomm incorporated | edhall@qti.qualcomm.com | Rel-17 | 81 |  |
| 1878 | 874.2 | (Stage 2 of) Support of Uncrewed Aerial Systems Connectivity, Identification, and Tracking |  | 200d | 2020-12-03 A | 2021-09-08 A | 100% |  | finish no earlier than 2021-09-08 | S2 | 1600h | 1600h | ID_UAS | 46 | Faccin, Stefano, Qualcomm Incorporated | sfaccin@qti.qualcomm.com | Rel-17 | 90 |  |
| 1879 | 874.3 | **CT aspects for ID_UAS** |  | 371.62d | 2021-03-18 A | 2022-03-11 A | 100% |  |  | ct | 8224h | 8224h | ID_UAS | 46 | Sunghoon Kim, Qualcomm Incorporated | sunghoon@qti.qualcomm.com | Rel-17 | 91 |  |
| 1880 | 874.3.1 | CT1 aspects for ID_UAS |  | 257d | 2021-03-18 A | 2022-03-11 A | 100% |  | finish no earlier than 2022-03-12 | C1 | 2056h | 2056h | ID_UAS | 46 | Sunghoon Kim, Qualcomm Incorporated | sunghoon@qti.qualcomm.com | Rel-17 | 91 |  |
| 1881 | 874.3.2 | CT3 aspects for ID_UAS |  | 257d | 2021-03-18 A | 2022-03-11 A | 100% |  | finish no earlier than 2022-03-12 | C3 | 2056h | 2056h | ID_UAS | 46 | Sunghoon Kim, Qualcomm Incorporated | sunghoon@qti.qualcomm.com | Rel-17 | 91 |  |
| 1882 | 874.3.3 | CT4 aspects for ID_UAS |  | 257d | 2021-03-18 A | 2022-03-11 A | 100% |  | finish no earlier than 2022-03-12 | C4 | 2056h | 2056h | ID_UAS | 46 | Sunghoon Kim, Qualcomm Incorporated | sunghoon@qti.qualcomm.com | Rel-17 | 91 |  |
| 1883 | 874.4 | Security aspects of Uncrewed Aerial Systems |  | 196d | 2021-06-11 A | 2022-03-11 A | 100% |  | finish no earlier than 2022-03-12 | S3 | 1568h | 1568h | ID_UAS | 47 | Escott, Adrian, Qualcomm Incorporated | aescott@qti.qualcomm.com | Rel-17 | 92 |  |
| 1884 | 874.5 | UE Conformance - Support of Uncrewed Aerial Systems Connectivity, Identification, and Tracking |  | 468d | 2023-03-03 A | 2024-12-12 A | 100% |  | finish no earlier than 2024-12-12 | R5 | 3744h | 3744h | ID_UAS-UEConTest | 50 | Yogesh Tugnawat, Qualcomm | yogesht[at]qti.qualcomm.com | Rel-17 | 99 | RP-241126 |
| 1885 | 875 | Rel-17 Satellite/Non-Terrestrial (NTN) related | milestone, manual | 0d | 2016-06-09 A | 2016-06-09 A | 100% |  | finish no earlier than 2016-06-09 |  |  |  |  |  |  |  | Rel-17 |  |  |
| 1886 | 876 | **Integration of satellite components in the 5G architecture** |  | 1423.88d? | 2018-06-06 A | 2022-03-11 A | 100% |  |  |  | 20968h | 20968h | 5GSAT_ARCH | 44 | Cyril MICHEL, thales | cyril.michel@thalesaleniaspace.com | Rel-17 | 86 |  |
| 1887 | 876.1 | Stage 1 of 5GSAT |  | 73d? | 2018-06-06 A | 2018-09-14 A | 100% |  | finish no earlier than 2018-09-14 | S1 | 584h | 584h | 5GSAT | 41 | MICHEL, Cyril, Thales | cyril.michel@thalesaleniaspace.com | Rel-17 | 80 |  |
| 1888 | 876.2 | Study on architecture aspects for using satellite access in 5G |  | 537d? | 2018-06-06 A | 2020-06-25 A | 100% |  | finish no earlier than 2020-06-25 | S2 | 4296h | 4296h | FS_5GSAT_ARCH | 41 | MICHEL, Cyril | cyril.michel@thalesaleniaspace.com | Rel-17 | 80 |  |
| 1889 | 876.3 | (Stage 2 of) Integration of satellite components in the 5G architecture |  | 459d | 2019-12-06 A | 2021-09-08 A | 100% |  | finish no earlier than 2021-09-08 | S2 | 3672h | 3672h | 5GSAT_ARCH | 44 | Cyril MICHEL, thales | cyril.michel@thalesaleniaspace.com | Rel-17 | 86 |  |
| 1890 | 876.4 | **CT aspects of 5GC architecture for satellite networks** |  | 561.12d | 2020-09-16 A | 2022-03-11 A | 100% |  |  | ct | 12416h | 12416h | 5GSAT_ARCH-CT | 45 | Catovic, Amer, Qualcomm Incorporated | amerc@qti.qualcomm.com | Rel-17 | 89 |  |
| 1891 | 876.4.1 | CT1 aspects of 5GC architecture for satellite networks |  | 388d | 2020-09-16 A | 2022-03-11 A | 100% |  | finish no earlier than 2022-03-12 | C1 | 3104h | 3104h | 5GSAT_ARCH-CT | 45 | Catovic, Amer, Qualcomm Incorporated | amerc@qti.qualcomm.com | Rel-17 | 89 |  |
| 1892 | 876.4.2 | CT3 aspects of 5GC architecture for satellite networks |  | 258d | 2020-09-16 A | 2021-09-10 A | 100% |  | finish no earlier than 2021-09-12 | C3 | 2064h | 2064h | 5GSAT_ARCH-CT | 45 | Catovic, Amer, Qualcomm Incorporated | amerc@qti.qualcomm.com | Rel-17 | 89 |  |
| 1893 | 876.4.3 | CT4 aspects of 5GC architecture for satellite networks |  | 388d | 2020-09-16 A | 2022-03-11 A | 100% |  | finish no earlier than 2022-03-12 | C4 | 3104h | 3104h | 5GSAT_ARCH-CT | 45 | Catovic, Amer, Qualcomm Incorporated | amerc@qti.qualcomm.com | Rel-17 | 89 |  |
| 1894 | 876.4.4 | CT6 aspects of 5GC architecture for satellite networks |  | 130d | 2021-09-13 A | 2022-03-11 A | 100% |  | start no earlier than 2021-09-13 | C6 | 1040h | 1040h | 5GSAT_ARCH-CT | 47 | Catovic, Amer, Qualcomm Incorporated | amerc@qti.qualcomm.com | Rel-17 | 93 |  |
| 1895 | 877 | **Solutions for NR to support non-terrestrial networks (NTN)** |  | 1888.5d | 2019-12-16 A | 2024-12-12 | 100% | 2025-12-12 |  |  | 22472h | 22472h | NR_NTN_solutions | 44 | Thales |  | Rel-17 | 86 |  |
| 1896 | 877.1 | Core part: Solutions for NR for NTN |  | 646d | 2019-12-16 A | 2022-06-06 A | 100% |  | finish no earlier than 2022-06-06 | R4 | 5168h | 5168h | NR_NTN_solutions-Core | 44 | Nicolas Chuberre, Thales | nicolas.chuberre@thalesaleniaspace.com | Rel-17 | 86 | RP-230115 |
| 1897 | 877.2 | Perf. Part: Solutions for NR for NTN |  | 841d | 2019-12-16 A | 2023-03-03 A | 100% |  | finish no earlier than 2023-03-03 | R4 | 6728h | 6728h | NR_NTN_solutions-Perf | 44 | Nicolas Chuberre, Thales | nicolas.chuberre@thalesaleniaspace.com | Rel-17 | 86 | RP-230115 |
| 1898 | 877.3 | UE Conformance - Solutions for NR to support non-terrestrial networks (NTN) plus CT aspects |  | 1322d | 2022-06-15 A | 2025-12-12 A | 100% |  | finish no earlier than 2025-12-12 | R5 | 10576h | 10576h | NR_NTN_solutions_plus_CT-UEConTest | 49 | Vijay Balasubramanian, Qualcomm | vijayb[at]qti.qualcomm.com | Rel-17 | 96 | RP-253369 |
| 1899 | 878 | **NB-IoT/eMTC support for Non-Terrestrial Networks** |  | 1026d | 2021-06-15 A | 2024-03-01 A | 100% |  |  | R1 | 14080h | 14080h | LTE_NBIOT_eMTC_NTN | 47 | MediaTek |  | Rel-17 | 92 |  |
| 1900 | 878.1 | Core part: NB-IoT/eMTC support for Non-Terrestrial Networks |  | 267d | 2021-06-15 A | 2022-06-22 A | 100% |  | finish no earlier than 2022-06-22 | R1 | 2136h | 2136h | LTE_NBIOT_eMTC_NTN-Core | 47 | Gilles Charbit, MediaTek | Gilles.charbit@mediatek.com | Rel-17 | 92 | RP-221546 |
| 1901 | 878.2 | UE Conformance - NB-IoT/eMTC support for Non-Terrestrial Networks (NTN) including EPS aspects |  | 449d | 2022-06-15 A | 2024-03-01 A | 100% |  | finish no earlier than 2024-03-01 | R5 | 3592h | 3592h | LTE_NBIOT_eMTC_NTN_plus_EPS-UEConTest | 49 | Daiwei Zhou, MediaTek Inc. | daiwei.zhou@mediatek.com | Rel-17 | 96 | RP-240442 |
| 1902 | 878.3 | Architecture support for NB-IoT/eMTC Non-Terrestrial Networks in EPS |  | 66d | 2021-09-10 A | 2021-12-10 A | 100% |  | finish no earlier than 2021-12-12 | S2 | 528h | 528h | IoT_SAT_ARCH_EPS | 47 | SEBIRE, Guillaume, MediaTek Inc. | guillaume dot sebire at mediatek dot com | Rel-17 | 93 |  |
| 1903 | 878.4 | CT1 aspects of NB-IoT/eMTC Non-Terrestrial Networks in EPS |  | 67d | 2021-12-13 A | 2022-03-15 A | 100% |  | finish no earlier than 2022-03-15 | C1 | 536h | 536h | IoT_SAT_ARCH_EPS | 48 | NIEMI, Marko, MediaTek Inc., | marko.niemi at mediatek dot com | Rel-17 | 94 |  |
| 1904 | 878.5 | CT3 aspects of NB-IoT/eMTC Non-Terrestrial Networks in EPS |  | 67d | 2021-12-13 A | 2022-03-15 A | 100% |  | start no earlier than 2021-12-13 | C3 | 536h | 536h | IoT_SAT_ARCH_EPS | 48 | NIEMI, Marko, MediaTek Inc., | marko.niemi at mediatek dot com | Rel-17 | 95 |  |
| 1905 | 878.6 | CT4 aspects of NB-IoT/eMTC Non-Terrestrial Networks in EPS |  | 67d | 2021-12-13 A | 2022-03-15 A | 100% |  | start no earlier than 2021-12-13 | C4 | 536h | 536h | IoT_SAT_ARCH_EPS | 48 | NIEMI, Marko, MediaTek Inc., | marko.niemi at mediatek dot com | Rel-17 | 95 |  |
| 1906 | 878.7 | CT6 aspects of NB-IoT/eMTC Non-Terrestrial Networks in EPS |  | 67d | 2021-12-13 A | 2022-03-15 A | 100% |  | start no earlier than 2021-12-13 | C6 | 536h | 536h | IoT_SAT_ARCH_EPS | 48 | NIEMI, Marko, MediaTek Inc., | marko.niemi at mediatek dot com | Rel-17 | 95 |  |
| 1907 | 879 | Study on management and orchestration aspects with integrated satellite components in a 5G network |  | 526.88d | 2019-03-07 A | 2021-03-12 A | 100% |  | finish no earlier than 2021-03-12 | S5 | 4215h | 4215h | FS_5GSAT_MO | 42 | Floris Drijver, TNO | floris.drijver@tno.nl | Rel-17 | 83 |  |
| 1908 | 880 | Study on NB-IoT/eMTC support for NTN |  | 392d | 2019-12-16 A | 2021-06-15 A | 100% |  | finish no earlier than 2021-06-15 | R1 | 3136h | 3136h | FS_LTE_NBIOT_eMTC_NTN | 44 | MediaTek |  | Rel-17 | 86 |  |
| 1909 | 881 | Rel-17 IoT related | milestone, manual | 0d | 2016-06-09 A | 2016-06-09 A | 100% |  | finish no earlier than 2016-06-09 |  |  |  |  |  |  |  | Rel-17 |  |  |
| 1910 | 882 | Study on enhanced support of Industrial IoT |  | 387d | 2019-09-19 A | 2021-03-12 A | 100% |  | finish no earlier than 2021-03-12 | S2 | 3096h | 3096h | FS_IIoT | 43 | Nokia, Devaki Chandramouli, | devaki.chandramouli@nokia.com | Rel-17 | 85 |  |
| 1911 | 883 | Study on security for enhanced support of Industrial IoT |  | 261d | 2020-06-12 A | 2021-06-11 A | 100% |  | finish no earlier than 2021-06-12 | S3 | 2088h | 2088h | FS_IIoT_SEC | 45 | Nokia, Anja Jerichow | anja.jerichow@nokia.com | Rel-17 | 88 |  |
| 1912 | 884 | Security for enhanced support of Industrial IoT |  | 6d | 2021-06-11 A | 2021-06-18 A | 100% |  | finish no earlier than 2021-06-20 | S3 | 48h | 48h | IIoT_SEC | 47 | Nokia, Anja Jerichow | anja.jerichow@nokia.com | Rel-17 | 92 |  |

Notes:
- 1877: 10/9/18: 0%->5¦4/12/18: 5%->100. Initially Rel-16 / Impacted TSs and TRs: 22.125
- 1878: 19/3/21: 0%->15; 14/6/21: 15%->80; 14/6/21: FCD:Fri 11/06/->09/21; 13/9/21: 80%->98; 10/12/21: 98%->100 / Impacted TSs and TRs: 23.501; 23.502; 23.503; 23.401
- 1879: ; 11/6/21: WID:CP-210287->CP-211112 / Impacted TSs and TRs: 24.501; 24.301; 24.008; 27.007; 29.502; 29.503; 29.504; 29.505; 29.510; 29.518; 29.571; 29.274; 29.522; 29.122; 29.512; 29.513; 29.514; 29.561; 29.519
- 1880: ; 11/6/21: 0%->20; 13/9/21: 20%->30; 13/12/21: 30%->70; 12/3/22: 70%->100
- 1881: ; 2/7/21: 29.255 added;; 2/7/21: 29.257 added;; 13/9/21: 0%->20; 13/12/21: 20%->80; 12/3/22: 80%->100 / Impacted TSs and TRs: 29.255; 29.257
- 1882: ; 11/6/21: 0%->20; 13/9/21: 20%->30; 13/12/21: 30%->80; 12/3/22: 80%->100
- 1883: 1/10/21: 33.256 added;; 13/12/21: 0%->50; 13/12/21: FCD:Fri 10/12/->03/22; 12/3/22: 50%->100 / Impacted TSs and TRs: 33.256
- 1884: ; 7/6/23: Compl:0%->6%; 7/6/23: CD:12/12/2024->12/12/2023; 6/9/23: Compl:6%->40%; Stat Rep: ->RP-231997; Rapporteur: Qualcomm->Yogesh Tugnawat, Qualcomm; Rap eMail: ->yogesht[at]qti.qualcomm.com; ; 14/3/24: FCD:12/12/2023->12/12/2024; Compl:40%->95%; ...; 23/7/24: WID:RP-230716->RP-241591
- 1885: -
- 1886: Impacted TSs and TRs: 23.501; 23.502; 23.503
- 1887: 10/9/18: 0%->95¦4/12/18: 95%->100. 09/20: moved to Rel-17 since St 2 and 3 are Rel-17 / Impacted TSs and TRs: 22.261
- 1888: 10/9/18: 0%->15¦10/9/18: FCD:06/19->03/19¦7/12/18: 15%->35¦14/12/18: WID:SP-180505->SP-181253¦14/12/18: FCD:03/19->09/19¦14/3/19: 35%->50; 5/6/19: 50%->60; 13/9/19: 60%->70. Moved to R17.; 6/12/19: 70%->85; 26/6/20: FCD:12/09/2019->06/20; 26/6/20: 85%- / Impacted TSs and TRs: New
- 1889: 12/9/20: 0%->10; 12/9/20: FCD:11/09/2020->03/21; 5/12/20: 10%->50; 19/3/21: FCD:12/03/2021->06/21; 19/3/21: 50%->75; 11/6/21: 75%->98; 11/6/21: FCD:Fri 11/06/->09/21; 13/9/21: 98%->99; 10/12/21: 99%->100 / Impacted TSs and TRs: 23.501; 23.502; 23.503
- 1890: ; 25/9/20: WID:CP-202189->CP-202244; 5/12/20: 0%->20; 21/3/21: 20%->25; 11/6/21: WID:CP-202244->CP-210149 / Impacted TSs and TRs: 23.122; 24.501; 24.008; 24.301
- 1891: ; 25/9/20: WID:CP-202189->CP-202244; 5/12/20: 0%->20; 21/3/21: 20%->25; 11/6/21: 25%->80; 13/9/21: 80%->60; 13/12/21: 60%->75; 12/3/22: FCD:10/09/2021->3/22; 12/3/22: 75%->85; 4/6/22: 85%->100 / Impacted TSs and TRs: 23.122; 24.501; 24.008; 24.301
- 1892: ; 25/9/20: WID:CP-202189->CP-202244; 5/12/20: 0%->20; 21/3/21: 20%->25; 11/6/21: 25%->80; 11/6/21: 0%->60; 13/9/21: 60%->80; 13/12/21: 80%->95; 12/3/22: 95%->100 / Impacted TSs and TRs: 23.122; 24.501; 24.008; 24.301
- 1893: ; 25/9/20: WID:CP-202189->CP-202244; 5/12/20: 0%->20; 21/3/21: 20%->25; 11/6/21: 0%->80; 13/9/21: FCD:Fri 10/09/->03/22; 13/12/21: 80%->90; 12/3/22: 90%->100 / Impacted TSs and TRs: 23.122; 24.501; 24.008; 24.301
- 1894: CT6 aspects introduced as per CT6 report in CP-212127; 12/3/22: 0%->96; 4/6/22: 96%->97
- 1895: affects: NR. Follow-up WI of REL-16 SI FS_NR_NTN_solutions; 28/7/20: WID:RP-193234->RP-201256; 6/1/21: WID:RP-201256->RP-202908; 7/4/21: WID:RP-202908->RP-210908; 1/10/21: 38.108 & 38.181 added;; 5/4/22: WID:RP-210908->RP-220208 / Impacted TSs and TRs: 38.108; 38.181
- 1896: affects: NR. follow-up WI of REL-16 SI FS_NR_NTN_solutions; 1/10/21: 38.863 added;; 7/1/22: 38.101-5 added ; ; 6/6/22: Compl:90%->0% ; 20/6/22: Compl:0%->100%; Stat Rep: RP-221168->RP-221168 / 1745; Rapporteur: Thales->Nicolas Chuberre, Thales; Rap e...; 17/3/23: WID:RP-222556->RP-221169 / Impacted TSs and TRs: 38.863; 38.101-5
- 1897: affects: NR.; ; 20/6/22: WG: R4->R2; FCD:12/09/2022->22/12/2022; Compl:40%->20%; WID: RP-220208->RP-213691; Stat Rep: RP-220132->RP-221168 / 1745; Rapporteur: Thales->Nicolas Chuberre, Thales; Rap eMail: ->nicolas.chuberre@thalesaleniaspace.com; ;...;...; 17/3/23: FCD:28/02/2023->03/03/2023; Compl:98%->100%; Stat Rep: RP-222739->RP-230115;
- 1898: 9/9/22: Comp...; 23/9/22: WID:RP-221241->RP-222537; 9/12/22: FCD:23/12/2022->01/12/2023; Compl:5%->13%; WID: RP-222537->RP-221241; Stat Rep: ->RP-223386; Rapporteur: Qualcomm->Vijay Balasubramanian, Qualcomm; Rap eMail: ->vijayb[at]qti.qual...; 3/12/25: Compl:97%->100%; Stat Rep: RP-252040->RP-253369; / Impacted TSs and TRs: 38.521-5
- 1899: follow-up WI of REL-17 SI FS_LTE_NBIOT_eMTC_NTN; no Perf. part
- 1900: follow-up WI of REL-17 SI FS_LTE_NBIOT_eMTC_NTN; no Perf. part ; 20/6/22: Release: Rel-17->Rel-18; Rapporteur: MediaTek->Gilles Charbit, MediaTek; Rap eMail: ->Gilles.charbit@mediatek.com;
- 1901: 9/9/22: Comp...; 9/12/22: FCD:23/09/2022->01/09/2023; Compl:45%->95%; Stat Rep: ->RP-223229; Rapporteur: MediaTek->Daiwei Zhou, MediaTek Inc.; Rap eMail: ->daiwei.zhou@mediatek.com; 17/3/23: FCD:09/09/2023->08/09/2023; Compl:95%->96%; Sta.....; 14/3/24: Compl:99%->100%; Stat Rep: RP-233249->RP-240442;
- 1902: ; 7/1/22: WID:SP-211124->SP-211306; 7/1/22: 0%->95; 12/3/22: 95%->100 / Impacted TSs and TRs: 23.203; 23.271; 23.401; 23.682
- 1903: ; 12/3/22: 0%->20; 4/6/22: 20%->80;; 20/6/22: FCD:13/12/2021->15/03/2022Compl:80%->95% / Impacted TSs and TRs: 23.122; 23.008; 24.008; 24.301; 27.007; 29.212; 29.272; 29.274; 31.102; 31.111
- 1904: ; 12/3/22: 0%->20; 12/3/22: 0%->100 / Impacted TSs and TRs: 23.122; 23.008; 24.008; 24.301; 27.007; 29.212; 29.272; 29.274; 31.102; 31.111
- 1905: ; 12/3/22: 0%->20; 12/3/22: 0%->100 / Impacted TSs and TRs: 23.122; 23.008; 24.008; 24.301; 27.007; 29.212; 29.272; 29.274; 31.102; 31.111
- 1906: ; 12/3/22: 0%->20; 4/6/22: 0%->80 / Impacted TSs and TRs: 23.122; 23.008; 24.008; 24.301; 27.007; 29.212; 29.272; 29.274; 31.102; 31.111
- 1907: 31/5/19: 0%->10; 31/5/19: 0%->10; 13/9/19: 10%->30; 26/3/20: 30%->60; 26/3/20: FCD:05/12/2019->06/20; 28/6/20: 60%->65; 13/9/20: 65%->70; 13/9/20: FCD:12/06/2020->12/20; 5/12/20: 70%->90; 5/12/20: FCD:15/12/2020->03/20; 21/3/21: 90%->100 / Impacted TSs and TRs: New
- 1908: affects: LTE. connecting LTE NB-IoT and LTE eMTC to NTN of NR; TR 36.7xx; 25/9/20: 36.763 added;; 6/1/21: WID:RP-193235->RP-202689; 2/7/21: 0%->100 / Impacted TSs and TRs: 36.763
- 1909: -
- 1910: ; 8/10/19: 23.700-20 added;; 6/12/19: 0%->20; 25/3/20: WID:SP-190932->SP-200298; 25/3/20: FCD:12/03/2020->06/20; 25/3/20: 20%->40; 26/6/20: FCD:15/06/2020->09/20; 26/6/20: 40%->55; 12/9/20: 55%->75; 12/9/20: FCD:15/09/2020->12/20; 5/12/20: 75%->95; 5 / Impacted TSs and TRs: New ; 23.700-20
- 1911: 28/7/20: 33.851 added;; 12/9/20: 0%->15; 5/12/20: 15%->60; 5/12/20: FCD:11/12/2020->06/20; 19/3/21: 60%->90; 11/6/21: 90%->100 / Impacted TSs and TRs: 33.851
- 1912: ; 24/3/22: 0%->100 / Impacted TSs and TRs: 33.501

| ID | WBS | Task | Type | Duration | Start | Finish | Complete | Actual finish | Constraint | Resources | Work | Actual work | Acronym | PCG approved | WI rapporteur name | WI rapporteur e-mail | Release | TSG approved | Status Report |
| --- | --- | --- | --- | --- | --- | --- | --- | --- | --- | --- | --- | --- | --- | --- | --- | --- | --- | --- | --- |
| 1913 | 885 | **Support of Enhanced Industrial IIoT** |  | 480.38d | 2020-12-03 A | 2022-03-11 A | 100% |  |  |  | 9824h | 9824h | IIoT | 46 | Devaki Chandramouli, Nokia | Devaki.chandramouli@nokia.com | Rel-17 | 90 |  |
| 1914 | 885.1 | Stage 2 for IIoT |  | 200d | 2020-12-03 A | 2021-09-08 A | 100% |  | finish no earlier than 2021-09-08 | S2 | 1600h | 1600h | IIoT | 46 | Devaki Chandramouli, Nokia | Devaki.chandramouli@nokia.com | Rel-17 | 90 |  |
| 1915 | 885.2 | **CT aspects of support of enhanced Industrial IoT** |  | 371.62d | 2021-03-18 A | 2022-03-11 A | 100% |  |  | ct | 8224h | 8224h | IIoT | 46 | Won, Sung Hwan, Nokia | sung.won@nokia.com | Rel-17 | 91 |  |
| 1916 | 885.2.1 | CT1 aspects of support of enhanced Industrial IoT |  | 257d | 2021-03-18 A | 2022-03-11 A | 100% |  | finish no earlier than 2022-03-12 | C1 | 2056h | 2056h | IIoT | 46 | Won, Sung Hwan, Nokia | sung.won@nokia.com | Rel-17 | 91 |  |
| 1917 | 885.2.2 | CT3 aspects of support of enhanced Industrial IoT |  | 257d | 2021-03-18 A | 2022-03-11 A | 100% |  | finish no earlier than 2022-03-12 | C3 | 2056h | 2056h | IIoT | 46 | Won, Sung Hwan, Nokia | sung.won@nokia.com | Rel-17 | 91 |  |
| 1918 | 885.2.3 | CT4 aspects of support of enhanced Industrial IoT |  | 257d | 2021-03-18 A | 2022-03-11 A | 100% |  | finish no earlier than 2022-03-12 | C4 | 2056h | 2056h | IIoT | 46 | Won, Sung Hwan, Nokia | sung.won@nokia.com | Rel-17 | 91 |  |
| 1919 | 886 | Charging enhancements for 5G CIoT |  | 131d | 2021-12-10 A | 2022-06-10 A | 100% |  | finish no earlier than 2022-06-12 | S5 | 1048h | 1048h | 5G_CIoT_CH | 48 | Zhu, Lei, Huawei | Lei.zhu@huawei.com | Rel-17 | 94 |  |
| 1920 | 887 | **Additional enhancements for NB-IoT and LTE-MTC** |  | 1342.12d | 2019-03-07 A | 2022-09-22 A | 100% |  |  |  | 7936h | 7936h | NB_IOTenh4_LTE_eMTC6 | 44 | Huawei |  | Rel-17 | 86 |  |
| 1921 | 887.1 | Core part: Additional enhancements for NB-IoT and LTE-MTC |  | 66d | 2021-12-21 A | 2022-03-22 A | 100% |  | finish no earlier than 2022-03-22 | R1 | 528h | 528h | NB_IOTenh4_LTE_eMTC6-Core | 44 | Yubo YANG Emre YAVUZ, Huawei Ericsson | yangyubo1@huawei.com emre.yavuz@ericsson.com | Rel-17 | 86 | RP-221499 |
| 1922 | 887.2 | Perf. part: Additional enhancements for NB-IoT and LTE-MTC |  | 926d | 2019-03-07 A | 2022-09-22 A | 100% |  | start no earlier than 2019-03-07 | R1 | 7408h | 7408h | NB_IOTenh4_LTE_eMTC6-Perf | 44 | Yubo YANG Emre YAVUZ, Huawei Ericsson | yangyubo1@huawei.com emre.yavuz@ericsson.com | Rel-17 | 86 | RP-221499 |
| 1923 | 888 | **NR small data transmissions in INACTIVE state** |  | 1308d | 2019-12-16 A | 2024-12-12 A | 100% |  |  |  | 16288h | 16288h | NR_SmallData_INACTIVE | 44 | ZTE |  | Rel-17 | 86 |  |
| 1924 | 888.1 | Core part: NR small data transmissions in INACTIVE state |  | 592d | 2019-12-16 A | 2022-03-22 A | 100% |  | finish no earlier than 2022-03-22 | R2 | 4736h | 4736h | NR_SmallData_INACTIVE-Core | 44 | Eswar Vutukuri, ZTE Corporation | eswar.vutukuri@zte.com.cn | Rel-17 | 86 | RP-221309 |
| 1925 | 888.2 | Perf. part: NR small data transmissions in INACTIVE state |  | 789d | 2019-12-16 A | 2022-12-21 A | 100% |  | finish no earlier than 2022-12-22 | R2 | 6312h | 6312h | NR_SmallData_INACTIVE-Perf | 44 | Eswar Vutukuri, ZTE Corporation | eswar.vutukuri@zte.com.cn | Rel-17 | 86 | RP-221309 |
| 1926 | 888.3 | UE Conformance - NR small data transmissions in INACTIVE state |  | 655d | 2022-06-15 A | 2024-12-12 A | 100% |  | finish no earlier than 2024-12-12 | R5 | 5240h | 5240h | NR_SmallData_INACTIVE-UEConTest | 49 | Yogesh Tugnawat, Qualcomm | yogesht[at]qti.qualcomm.com | Rel-17 | 96 | RP-242497 |
| 1927 | 889 | **Enhanced Industrial Internet of Things (IoT) and ultra-reliable and low latency communication (URLLC) support for NR** |  | 1509.75d | 2019-12-16 A | 2023-12-12 A | 100% |  |  |  | 12896h | 12896h | NR_IIOT_URLLC_enh | 44 | Nokia |  | Rel-17 | 86 |  |
| 1928 | 889.1 | Core part: Enhanced IoT and URLLC support for NR |  | 577d | 2019-12-16 A | 2022-03-01 A | 100% |  | finish no earlier than 2022-03-22 | R2 | 4616h | 4616h | NR_IIOT_URLLC_enh-Core | 44 | Chunli Wu, Nokia | Chunli.wu@nokia-sbell.com | Rel-17 | 86 | RP-223027 |
| 1929 | 889.2 | Perf. Part: Enhanced IoT and URLLC support for NR |  | 644d | 2020-06-15 A | 2022-12-01 A | 100% |  | finish no earlier than 2022-12-01 | R2 | 5152h | 5152h | NR_IIOT_URLLC_enh-Perf | 44 | Chunli Wu, Nokia | Chunli.wu@nokia-sbell.com | Rel-17 | 86 | RP-223027 |
| 1930 | 889.3 | UE Conformance - Enhanced Industrial Internet of Things (IoT) and ultra-reliable and low latency communication (URLLC) support for NR |  | 391d | 2022-06-15 A | 2023-12-12 A | 100% |  | finish no earlier than 2023-12-12 | R5 | 3128h | 3128h | NR_IIOT_URLLC_enh-UEConTest | 49 | Matti Kangas, Nokia, Nokia Shanghai Bell | matti.kangas@nokia.com | Rel-17 | 96 | RP-232885 |
| 1931 | 890 | Rel-17 V2V/D2D/Sidelink related | milestone, manual | 0d | 2016-06-09 A | 2016-06-09 A | 100% |  | finish no earlier than 2016-06-09 |  |  |  |  |  |  |  | Rel-17 |  |  |
| 1932 | 891 | **NR Sidelink enhancement** |  | 1972.38d | 2019-12-16 A | 2025-03-03 | 100% | 2025-09-09 |  |  | 20270h | 20270h | NR_SL_enh | 44 | LG Electronics |  | Rel-17 | 86 |  |
| 1933 | 891.1 | Core part: NR Sidelink enhancement |  | 585d | 2019-12-16 A | 2022-03-11 A | 100% |  | finish no earlier than 2022-03-22 | R1 | 4680h | 4680h | NR_SL_enh-Core | 44 | LG Electronics |  | Rel-17 | 86 | RP-220520 |
| 1934 | 891.2 | Perf. part: NR Sidelink enhancement |  | 724d | 2019-12-16 A | 2022-09-22 A | 100% |  | finish no earlier than 2022-09-22 | R4 | 5792h | 5792h | NR_SL_enh-Perf | 44 | Seungmin Lee, LG Electronics | Edison.lee@lge.com | Rel-17 | 86 | RP-221186 |
| 1935 | 891.3 | UE Conformance - NR Sidelink enhancement |  | 1224.75d | 2022-06-15 A | 2025-09-09 A | 100% |  | finish no earlier than 2025-09-09 | R5 | 9798h | 9798h | NR_SL_enh-UEConTest | 49 | Xiaozhong CHEN, CATT | chenxiaozhong@catt.cn | Rel-17 | 96 | RP-252720 |
| 1936 | 892 | Study on NR Sidelink relay |  | 197d | 2019-12-16 A | 2020-09-15 A | 100% |  | finish no earlier than 2020-09-15 | R2 | 1576h | 1576h | FS_NR_SL_relay | 44 | OPPO |  | Rel-17 | 86 |  |
| 1937 | 893 | Study on enhancements to application layer support for V2X services |  | 267d | 2019-06-06 A | 2020-06-12 A | 100% |  | finish no earlier than 2020-06-12 | S6 | 2136h | 2136h | FS_eV2XAPP | 43 | Niranth Amogh, Huawei Telecommunications India | namogh@huawei.com | Rel-17 | 84 |  |

Notes:
- 1914: 19/3/21: 0%->35; 11/6/21: 35%->90; 11/6/21: FCD:Fri 11/06/->09/21; 13/9/21: 90%->100 / Impacted TSs and TRs: 23.501; 23.502; 23.503
- 1915: ; 10/9/21: WID:CP-211114->CP-212100 / Impacted TSs and TRs: 24.501; 24.519; 24.535; 29.512; 29.513; 29.514; 29.519; 29.522; 29.591; 29.244
- 1916: ; 11/6/21: 0%->65; 2/7/21: 24.539 added;; 13/9/21: 65%->90; 13/12/21: 90%->95; 12/3/22: 95%->100 / Impacted TSs and TRs: 24.539
- 1917: ; 11/6/21: 0%->45; 11/6/21: WID:CP-210279->CP-211114; 13/9/21: 45%->65; 1/10/21: 29.565 added;; 13/12/21: 65%->85; 12/3/22: 85%->98; 4/6/22: 98%->100 / Impacted TSs and TRs: 29.565
- 1918: ; 11/6/21: 0%->60; 13/9/21: 60%->90; 13/12/21: 90%->95; 12/3/22: 95%->100
- 1919: ; 12/3/22: 0%->60; 4/6/22: 60%->100 / Impacted TSs and TRs: 32.255; 32.291; 32.298
- 1920: affects: LTE. compare NB_IOT, LTE_MTCe2_L1 in REL-13,NB_IOTenh, LTE_feMTC in REL-14, WTC; 28/7/20: WID:RP-193264->RP-201306; 2/7/21: WID:RP-201306->RP-211340; 5/4/22: WID:RP-211340->RP-220529
- 1921: affects: LTE. compare NB_IOT, LTE_MTCe2_L1 in REL-13,NB_IOTenh, LTE_feMTC in REL-14, WTC; 13/9/21: Com ; 20/6/22: Rapporteur: Huawei->Yubo YANG Emre YAVUZ, Huawei Ericsson; Rap eMail: ->yangyubo1@huawei.com emre.yavuz@ericsson.com20/6/22: 1...
- 1922: affects: LTE.; 13/9/21: CD:Wed 15/12/21->Wed 22/09/21 ; 22/3/22: Compl:0%->30% ; 20/6/22: WG: R4->R1; Rapporteur: Huawei->Yubo YANG Emre YAVUZ, Huawei Ericsson; Rap eMail: ->yangyubo1@huawei.com emre.yavuz@ericsson.com20/6/22: 0%->70; 20/6/22...
- 1923: affects: NR.; 28/7/20: WID:RP-193252->RP-201305; 7/4/21: WID:RP-201305->RP-210870; 29/9/21: WID:RP-210870->RP-212594; 23/9/22: WID:RP-212594->RP-222364
- 1924: affects: NR.; 13/9/21: Compl:0%->50%; 13/9/21: CD:Tue 15/06/21->Tue 22/03/22; ; 20/6/22: Rapporteur: ZTE->Eswar Vutukuri, ZTE Corporation; Rap eMail: ->eswar.vutukuri@zte.com.cn;
- 1925: affects: NR.; 13/9/21: CD:Wed 15/12/21->Wed 22/09/21; 13/9/21: Stat Rep: ->RP-211871; 22/3/22: CD:22/09/2021->12/09/2022; 22/3/22: Stat Rep: RP-211871->RP-220153 20/6/22: WG: R4->R2; Rapporteur: ZTE->Eswar Vutukuri, ZTE Corporation; Rap eMail: ->es...; 9/1/23: 70%->100
- 1926: 9/9/22: Comp...; 9/12/22: FCD:23/12/2022->01/12/2023; Compl:15%->30%; Stat Rep: ->RP-223385; Rapporteur: Qualcomm->Yogesh Tugnawat, Qualcomm; Rap eMail: ->yogesht[at]qti.qualcomm.com; 17/3/23: FCD:30/11/2023->12/12/2023; Compl:30%->75%; S.....; 24/1/25: 99%->100
- 1927: affects: NR. no Perf. part; compare REL-16 WI NR_IIOT and NR_L1enh_URLLC; 7/4/21: WID:RP-201310->RP-210854; 5/4/22: WID:RP-210854->RP-220152
- 1928: affects: NR. no Perf. part; compare REL-16 WI NR_IIOT and NR_L1enh_URLLC; 28/7/20: WID:RP-193233->RP-201310; 13/9/21: Compl:0%->55% ; ; 20/6/22: Rapporteur: Nokia->Chunli Wu, Nokia; Rap eMail: ->Chunli.wu@nokia-sbell.com; 9/12/22: FCD:22/03/2022->...
- 1929: ; 13/9/21: CD:Tue 15/03/22->Wed 22/09/21; 13/9/21: Stat Rep: ->RP-211938; 22/3/22: CD:22/09/2021->12/09/2022; 22/3/22: Stat Rep: RP-211938->RP-220151 20/6/22: WG: R4->R2; Rapporteur: Nokia->Chunli Wu, Nokia; Rap eMail: ->Chunli.wu@nokia-sbell.com; ...; 9/12/22: FCD:22/12/2022->01/12/2022; Compl:85%->100%; Stat Rep: RP-221198->RP-223027;
- 1930: 9/9/22: Comp...; 9/12/22: FCD:23/06/2023->01/06/2023; Stat Rep: ->RP-223013; Rapporteur: Nokia->Matti Kangas, Nokia, Nokia Shanghai Bell; Rap eMail: ->matti.kangas@nokia.com; 31/3/23: Compl:5%->74%; Stat Rep: RP-223013->RP-230700; ;...; 6/9...; 8/12/23: Compl:82%->100%; Stat Rep: RP-231544->RP-232885;
- 1931: -
- 1932: affects: NR. compare REL-16 WI 5G_V2X_NRSL; 28/7/20: WID:RP-193257->RP-201385; 25/9/20: WID:RP-201385->RP-201516; 6/1/21: WID:RP-201516->RP-202846
- 1933: affects: NR. compare REL-16 WI 5G_V2X_NRSL; 13/9/21: Compl:0%->63%; ;
- 1934: affects: NR.; 13/9/21: CD:Wed 15/12/21->Wed 22/09/21; ; 22/3/22: Compl:0%->10%; 22/3/22: CD:22/09/2021->12/09/2022 20/6/22: FCD:12/09/2022->22/09/2022; Compl:10%->95%; Stat Rep: RP-220520->RP-221186; Rapporteur: LG Electronics->Seungmin Lee, LG El...; 23/9/22: 100%->100
- 1935: 9/9/22: Comp...; 9/12/22: FCD:23/09/2022->01/09/2023; Stat Rep: ->RP-223140; Rapporteur: CATT->Xiaozhong CHEN, CATT; Rap eMail: ->chenxiaozhong@catt.cn; 17/3/23: FCD:09/09/2023->08/09/2023; Stat Rep: RP-223140->RP-230396; ...; 6/9/23: FCD:0...; 29/9/25: WID:RP-221448->RP-252719
- 1936: affects: NR. TR 38.8xx; 25/9/20: WID:RP-193253->RP-201474; 6/1/21: WID:RP-201474->RP-202208; 7/4/21: 0%->100
- 1937: 13/9/19: 0%->25; 8/10/19: 23.764 added;; 6/12/19: 25%->35; 25/3/20: WID:SP-190477->SP-200110; 25/3/20: FCD:12/03/2020->06/20; 26/3/20: 35%->50; 28/6/20: 50%->75; 13/9/20: 75%->95; 22/3/22: 95%->100 / Impacted TSs and TRs: 23.764

| ID | WBS | Task | Type | Duration | Start | Finish | Complete | Constraint | Resources | Work | Actual work | Acronym | PCG approved | Impacted TSs and TRs | WI rapporteur name | WI rapporteur e-mail | Release | TSG approved | Status Report |
| --- | --- | --- | --- | --- | --- | --- | --- | --- | --- | --- | --- | --- | --- | --- | --- | --- | --- | --- | --- |
| 1938 | 894 | **Enhanced application layer support for V2X services** |  | 561.12d | 2020-09-16 A | 2022-03-11 A | 100% |  |  | 7728h | 7728h | eV2XAPP | 45 | 23.286; 23.434 | Niranth Amogh, Huawei Telecommunications India | namogh@huawei.com | Rel-17 | 89 |  |
| 1939 | 894.1 | Stage 2 of eV2XAPP |  | 195d | 2020-09-16 A | 2021-06-15 A | 100% | finish no earlier than 2021-06-15 | S6 | 1560h | 1560h | eV2XAPP | 45 | 23.286; 23.434 | Niranth Amogh, Huawei Telecommunications India | namogh@huawei.com | Rel-17 | 89 |  |
| 1940 | 894.2 | **CT aspects of eV2XAPP** |  | 371.62d | 2021-03-18 A | 2022-03-11 A | 100% |  | ct | 6168h | 6168h | eV2XAPP | 46 | 24.486; 24.544; 24.545; 24.546; 24.547; 24.548; 29.549 | Herrero Veron, Christian (Huawei) |  | Rel-17 | 91 |  |
| 1941 | 894.2.1 | CT1 aspects of eV2XAPP |  | 257d | 2021-03-18 A | 2022-03-11 A | 100% | finish no earlier than 2022-03-12 | C1 | 2056h | 2056h | eV2XAPP | 46 |  | Herrero Veron, Christian (Huawei) |  | Rel-17 | 91 |  |
| 1942 | 894.2.2 | CT3 aspects of eV2XAPP |  | 257d | 2021-03-18 A | 2022-03-11 A | 100% | finish no earlier than 2022-03-12 | C3 | 2056h | 2056h | eV2XAPP | 46 |  | Herrero Veron, Christian (Huawei) |  | Rel-17 | 91 |  |
| 1943 | 895 | **Support of advanced V2X services - Phase 2** |  | 937.12d | 2019-09-19 A | 2022-03-11 A | 100% |  |  | 8800h | 8800h | eV2XARC_Ph2 | 46 | 23.287 | LaeYoung Kim, LG Electronics | laeyoung.kim@lge.com | Rel-17 | 91 |  |
| 1944 | 895.1 | Study on V2X services – Phase 2 |  | 387d | 2019-09-19 A | 2021-03-12 A | 100% | finish no earlier than 2021-03-12 | S2 | 3096h | 3096h | FS_eV2XARC_Ph2 | 43 | New | LaeYoung Kim, LG Electronics | laeyoung.kim@lge.com | Rel-17 | 85 |  |
| 1945 | 895.2 | Stage 2 of eV2XARC_Ph2 |  | 125d | 2021-03-18 A | 2021-09-08 A | 100% | finish no earlier than 2021-09-08 | S2 | 1000h | 1000h | eV2XARC_Ph2 | 46 | 23.287 | LaeYoung Kim, LG Electronics | laeyoung.kim@lge.com | Rel-17 | 91 |  |
| 1946 | 895.3 | CT1 aspects of eV2XARC_Ph2 |  | 196d | 2021-06-11 A | 2022-03-11 A | 100% | finish no earlier than 2022-03-12 | C1 | 1568h | 1568h | eV2XARC_Ph2 | 47 | 24.588;24.587 | Herrero Veron, Christian (Huawei) | Christian.Herrero at huawei.com | Rel-17 | 92 |  |
| 1947 | 895.4 | Deleted- CT3 aspects of eV2XARC_Ph2 |  | 196d | 2021-06-11 A | 2022-03-11 A | 100% | finish no earlier than 2022-03-12 | C3 | 1568h | 1568h | eV2XARC_Ph2 | 47 | 31.102;29.522;29.525;29.519 | Herrero Veron, Christian (Huawei) | Christian.Herrero at huawei.com | Rel-17 | 92 |  |
| 1948 | 895.5 | CT6 aspects of eV2XARC_Ph2 |  | 196d | 2021-06-11 A | 2022-03-11 A | 100% | finish no earlier than 2022-03-12 | C6 | 1568h | 1568h | eV2XARC_Ph2 | 47 | 31.102 | Herrero Veron, Christian (Huawei) | Christian.Herrero at huawei.com | Rel-17 | 92 |  |
| 1949 | 896 | Rel-17 NR enhancements | milestone, manual | 0d | 2016-06-09 A | 2016-06-09 A | 100% |  |  |  |  |  |  | 26.234; 26.247 |  |  | Rel-17 |  |  |
| 1950 | 897 | **UE RF requirements for Transparent Tx Diversity (TxD) for NR** |  | 859.25d | 2021-06-15 A | 2023-09-22 A | 100% |  | R4 | 10936h | 10936h | NR_RF_TxD | 47 |  | Qualcomm |  | Rel-17 | 92 |  |
| 1951 | 897.1 | Core part: UE RF requirements for Transparent Tx Diversity (TxD) for NR |  | 194d | 2021-06-15 A | 2022-03-11 A | 100% | finish no earlier than 2022-03-22 | R4 | 1552h | 1552h | NR_RF_TxD-Core | 47 | 38.837 | Qualcomm |  | Rel-17 | 92 | RP-220467 |
| 1952 | 897.2 | Perf. part: UE RF requirements for Transparent Tx Diversity (TxD) for NR |  | 194d | 2021-06-15 A | 2022-03-11 A | 100% | finish no earlier than 2022-03-22 | R4 | 1552h | 1552h | NR_RF_TxD-Perf | 47 |  | Qualcomm |  | Rel-17 | 92 | RP-220467 |
| 1953 | 897.3 | UE Conformance - UE RF requirements for Transparent Tx Diversity (TxD) for NR |  | 466d | 2021-12-13 A | 2023-09-22 A | 100% | finish no earlier than 2023-09-22 | R5 | 3728h | 3728h | NR_RF_TxD-UEConTest | 48 |  | Yaping ZHANG, Huawei | zhangyaping13@huawei.com | Rel-17 | 94 | RP-232351 |
| 1954 | 898 | **Further enhancements on MIMO for NR** |  | 1240d | 2019-12-16 A | 2024-09-09 A | 100% |  |  | 15624h | 15624h | NR_feMIMO | 44 |  | Samsung |  | Rel-17 | 86 |  |
| 1955 | 898.1 | Core part: Further enhancements on MIMO for NR |  | 592d | 2019-12-16 A | 2022-03-22 A | 100% | finish no earlier than 2022-03-22 | R1 | 4736h | 4736h | NR_FeMIMO-Core | 44 |  | Eko Onggosanusi, Samsung | eko.o@samsung.com | Rel-17 | 86 | RP-221403 |
| 1956 | 898.2 | Perf. part: Further enhancements on MIMO for NR |  | 774d | 2019-12-16 A | 2022-12-01 A | 100% | finish no earlier than 2022-12-01 | R1 | 6192h | 6192h | NR_feMIMO-Perf | 44 |  | Eko Onggosanusi, Samsung | eko.o@samsung.com | Rel-17 | 86 | RP-222928 |
| 1957 | 898.3 | UE Conformance - Further enhancements on MIMO for NR |  | 587d | 2022-06-15 A | 2024-09-09 A | 100% | finish no earlier than 2024-09-24 | R5 | 4696h | 4696h | NR_feMIMO-UEConTest | 49 |  | Runsen Tang, Samsung | runsen.tang@samsung.com | Rel-17 | 96 | RP-241980 |
| 1958 | 899 | **NR Dynamic spectrum sharing (DSS)** |  | 857.38d | 2019-12-16 A | 2022-03-22 A | 100% |  |  | 4736h | 4736h | NR_DSS | 44 |  | Ericsson |  | Rel-17 | 86 |  |
| 1959 | 899.1 | Core part: NR DSS |  | 592d | 2019-12-16 A | 2022-03-22 A | 100% | finish no earlier than 2022-03-22 | R1 | 4736h | 4736h | NR_DSS-Core | 44 |  | Ravikiran Nory | ravikiran.nory@ericsson.com | Rel-17 | 86 | RP-220463 |
| 1960 | 900 | **UE power saving enhancements for NR** |  | 1592.5d | 2019-12-16 A | 2024-03-01 A | 100% |  |  | 19232h | 19232h | NR_UE_pow_sav_enh | 44 |  | MediaTek |  | Rel-17 | 86 |  |
| 1961 | 900.1 | Core part: UE power saving enhancements for NR |  | 592d | 2019-12-16 A | 2022-03-22 A | 100% | finish no earlier than 2022-03-22 | R2 | 4736h | 4736h | NR_UE_pow_sav_enh-Core | 44 |  | Weide Wu / Dapeng Li | weide.wu@mediatek.com / dapeng@zte.com.cn | Rel-17 | 86 | RP-221542 |
| 1962 | 900.2 | Perf. part: UE power saving enhancements for NR |  | 724d | 2019-12-16 A | 2022-09-22 A | 100% | finish no earlier than 2022-09-22 | R2 | 5792h | 5792h | NR_UE_pow_sav_enh-Perf | 44 |  | Weide Wu / Dapeng Li | weide.wu@mediatek.com / dapeng@zte.com.cn | Rel-17 | 86 | RP-221542 |
| 1963 | 900.3 | UE Conformance Test Aspects -UE Power Saving in NR |  | 639d | 2020-06-22 A | 2022-12-01 A | 100% | finish no earlier than 2022-12-01 | R5 | 5112h | 5112h | NR_UE_pow_sav-UEConTest | 45 |  | Huiying ZHANG, CATT | zhanghuiying@catt.cn | Rel-16 | 88 | RP-223138 |
| 1964 | 900.4 | UE Conformance - UE power saving enhancements for NR |  | 449d | 2022-06-15 A | 2024-03-01 A | 100% | finish no earlier than 2024-03-01 | R5 | 3592h | 3592h | NR_UE_pow_sav_enh_plus_CT-UEConTest | 49 |  | Eniko Sokondar, Vijay Balasubramanian, MediaTek, Qualcomm | eniko.sokondar[at]mediatek.com, vijayb[at]qti.qualcomm.com | Rel-17 | 96 | RP-233246 |

Notes:
- 1938: ; 5/12/20: 0%->35; 10/2/21: FCD:12/03/2021->06/21
- 1939: ; 5/12/20: 0%->35; 10/2/21: FCD:12/03/2021->06/21; 21/3/21: 35%->55; 11/6/21: 55%->100
- 1940: ; 11/6/21: WID:CP-210273->CP-211109
- 1941: ; 11/6/21: 0%->35; 13/9/21: 35%->65; 13/12/21: 65%->85; 12/3/22: 85%->100
- 1942: ; 11/6/21: 0%->50; 13/12/21: 50%->90; 12/3/22: 90%->100
- 1944: ; 26/6/20: FCD:12/06/2020->09/20; 26/6/20: 0%->25; 12/9/20: 25%->70; 12/9/20: FCD:15/09/2020->12/20; 5/12/20: 70%->86; 5/12/20: FCD:15/12/2020->03/20; 19/3/21: 86%->100
- 1945: ; 14/6/21: 0%->70; 14/6/21: FCD:Fri 11/06/->09/21; 13/9/21: 70%->95; 10/12/21: 95%->100
- 1946: ; 13/9/21: 0%->45; 13/12/21: 45%->90; 12/3/22: 90%->100
- 1947: 03/22: No task for CT3; 22/3/22: 0%->100
- 1948: ; 4/6/22: 0%->100
- 1950: TR38.8xx; impact on REL-15/16? ; 29/9/21: WID:RP-211597->RP-211940
- 1951: TR38.8xx; impact on REL-15/16? ; 13/9/21: Compl:0%->50%; 13/9/21: CD:Tue 15/03/22->Tue 22/03/22 ; 1/10/21: 38.837 added ;
- 1952: ; 13/9/21: Compl:0%->10%; 13/9/21: CD:Tue 15/03/22->Tue 22/03/22 ; ;
- 1953: tested: REL-17 WI NR_RF_TxD; 22/3/22: Compl:0%->5%; 22/3/22: Stat Rep: ->RP-220420 6/6/22: Compl:5%->23% 20/6/22: Rapporteur: Huawei->Chunying GU, Huawei; Rap eMail: ->guchunying@huawei.com12/7/22: WID:RP-213229->RP-221491 ...; 9/12/22: FCD:22/12/202...; 6/9/23: FCD:09/09/2023->22/09/2023; Compl:99%->100%; WID: RP-213229->RP-231240; Stat Rep: RP-230432->RP-232351; Rapporteur: Yaping Zhang, Huawei->Yaping ZHANG, Huawei;
- 1954: affects: NR. compare REL-16 WI NR_eMIMO; 25/9/20: WID:RP-193133->RP-202024; 2/7/21: WID:RP-202024->RP-211586; 29/9/21: WID:RP-211586->RP-212535
- 1955: affects: NR. compare REL-16 WI NR_eMIMO; 13/9/21: Compl:0%->70%; 13/9/21: CD:Tue 15/06/21->Tue 22/03/22; 13/9/21: Stat Rep: ->RP-211788 ; 20/6/22: Acronym:NR_feMIMO-Core->NR_FeMIMO-Core; Rapporteur: Samsung->Eko Onggosanusi, Samsung; Rap eMail: ...
- 1956: affects: NR.; 13/9/21: CD:Wed 15/12/21->Wed 22/09/21; 13/9/21: Stat Rep: ->RP-211788; 22/3/22: Compl:0%->25%; 20/6/22: Acronym:NR_feMIMO-Perf->NR_FeMIMO-Perf; WG: R4->R1; Rapporteur: Samsung->Eko Onggosanusi, Samsung; Rap eMail: ->eko.o@samsung.c...;...; 9/1/23: 100%->100; Acronym reverted to NR_feMIMO-Perf
- 1957: 9/9/22: Comp...; 9/12/22: FCD:23/12/2022->01/12/2023; Stat Rep: ->R5-226804; Rapporteur: Samsung->Runsen Tang, Samsung; Rap eMail: ->runsen.tang@samsung.com; 17/3/23: FCD:30/11/2023->12/12/2023; Compl:5%->10%; Stat Rep: R5-226804->RP-2301.....; 26/9/24: WID:RP-221401->RP-241983
- 1958: affects: NR. no Perf. part; 2/7/21: WID:RP-193260->RP-211345
- 1959: affects: NR. no Perf. part; 20/6/22: FCD:15/03/2021->22/03/2022; Compl:0%->100%; Stat Rep: ->RP-220463; Rapporteur: Ericsson->Ravikiran Nory; Rap eMail: ->ravikiran.nory@ericsson.com;
- 1960: affects: NR. compare REL-16 WI NR_UE_pow_sav; 26/3/20: WID:RP-193239->RP-200494; 30/6/20: WID:RP-200494->RP-193239; 28/7/20: WID:RP-193239->RP-200938; 29/9/21: WID:RP-200938->RP-212630; 5/4/22: WID:RP-212630->RP-220748; 12/7/22: WID:RP-220748->RP-221543
- 1961: affects: NR. compare REL-16 WI NR_UE_pow_sav; ; 20/6/22: FCD:11/03/2022->22/03/2023; Stat Rep: RP-220747->RP-221542; Rapporteur: MediaTek->Weide Wu / Dapeng Li; Rap eMail: ->weide.wu@mediatek.com / dapeng@zte.com.cn;
- 1962: affects: NR.; ; 20/6/22: WG: R4->R2; FCD:12/09/2022->22/09/2022; Compl:35%->65%; Stat Rep: RP-220747->RP-221542; Rapporteur: MediaTek->Weide Wu / Dapeng Li; Rap eMail: ->weide.wu@mediatek.com / dapeng@zte.com.cn9/9/22: 65%->100; 23/9/22: 100%->100
- 1963: 8/10/20: 0%->5; 6/1/21: WID:RP-200930->RP-202726; 8/4/21: 5%->39; 2/7/21: FCD:Mon 21/06/->09/21; 2/7/21: 39%->52; 6/1/22: WID:RP-202726->RP-213291; 20/6/22: Rapporteur: CATT->Huiying ZHANG, CATT; Rap eMail: ->zhanghuiying@catt.cn ; ...; 9/12/22: FCD...; 9/1/23: 100%->100
- 1964: 9/9/22: Comp...; 9/12/22: FCD:23/12/2022->01/12/2023; Compl:3%->20%; Stat Rep: ->RP-223228; Rapporteur: MediaTek->Eniko Sokondar, Vijay Balasubramanian, MediaTek, Qualcomm; Rap eMail: ->eniko.sokondar[at]mediatek.com, vijayb[at]qti.qualcomm...; 2/4/24: 97%->100

| ID | WBS | Task | Duration | Start | Finish | Complete | Constraint | Resources | Work | Actual work | Acronym | PCG approved | Release | TSG approved | Status Report | Impacted TSs and TRs |
| --- | --- | --- | --- | --- | --- | --- | --- | --- | --- | --- | --- | --- | --- | --- | --- | --- |
| 1965 | 901 | **Further Multi-RAT Dual-Connectivity enhancements** | 1692.75d | 2019-12-16 A | 2024-06-06 A | 100% |  |  | 13136h | 13136h | LTE_NR_DC_enh2 | 44 | Rel-17 | 86 |  |  |
| 1966 | 901.1 | Core part: Further Multi-RAT Dual-Connectivity enhancements | 585d | 2019-12-16 A | 2022-03-11 A | 100% | finish no earlier than 2022-03-12 | R2 | 4680h | 4680h | LTE_NR_DC_enh2-Core | 44 | Rel-17 | 86 | RP-220409 |  |
| 1967 | 901.2 | Perf. part: Further Multi-RAT Dual-Connectivity enhancements | 724d | 2019-12-16 A | 2022-09-22 A | 100% | finish no earlier than 2022-09-22 | R4 | 5792h | 5792h | LTE_NR_DC_enh2-Perf | 44 | Rel-17 | 86 | RP-220409 |  |
| 1968 | 901.3 | UE Conformance - Further Multi-RAT Dual-Connectivity enhancement | 333d | 2023-03-03 A | 2024-06-06 A | 100% | finish no earlier than 2024-06-06 | R5 | 2664h | 2664h | LTE_NR_DC_enh2-UEConTest | 50 | Rel-17 | 99 | RP-241372 |  |
| 1969 | 902 | **Enhancements to Integrated Access and Backhaul (IAB) for NR** | 1337.88d | 2019-03-11 A | 2022-09-22 A | 100% |  |  | 16816h | 16816h | NR_IAB_enh | 44 | Rel-17 | 86 |  |  |
| 1970 | 902.1 | Core part: Enhancements to IAB for NR | 658d | 2019-12-16 A | 2022-06-22 A | 100% | finish no earlier than 2022-06-22 | R2 | 5264h | 5264h | NR_IAB_enh-Core | 44 | Rel-17 | 86 | RP-221176 |  |
| 1971 | 902.2 | Perf. part: Enhancements to IAB for NR | 724d | 2019-12-16 A | 2022-09-22 A | 100% | finish no earlier than 2022-09-22 | R2 | 5792h | 5792h | NR_IAB_enh-Perf | 44 | Rel-17 | 86 | RP-221176 |  |
| 1972 | 902.3 | Study on Security for NR_IAB | 720d | 2019-03-11 A | 2021-12-10 A | 100% | finish no earlier than 2021-12-12 | S3 | 5760h | 5760h | FS_NR_IAB_Sec | 42 | Rel-17 | 83 |  | 33.824 |
| 1973 | 903 | **Enhanced eNB(s) architecture evolution for E-UTRAN and NG-RAN** | 843.88d | 2019-12-16 A | 2022-03-09 A | 100% |  |  | 4664h | 4664h | LTE_NR_arch_evo_enh | 44 | Rel-17 | 86 |  | 37.483; 37.482; 37.481; 37.480; 37.480; |
| 1974 | 903.1 | Core part: LTE_NR_arch_evo_enh | 583d | 2019-12-16 A | 2022-03-09 A | 100% | finish no earlier than 2022-03-09 | R3 | 4664h | 4664h | LTE_NR_arch_evo_enh-Core | 44 | Rel-17 | 86 | RP-220557 |  |
| 1975 | 904 | **Further enhancement on NR demodulation performance** | 1044d | 2020-09-15 A | 2024-09-09 A | 100% |  |  | 10016h | 10016h | NR_demod_enh2 | 45 | Rel-17 | 89 |  |  |
| 1976 | 904.1 | Core part: Further enhancement on NR demodulation performance | 137d | 2021-12-14 A | 2022-06-22 A | 100% | finish no earlier than 2022-06-22 | R4 | 1096h | 1096h | NR_demod_enh2-Core | 48 | Rel-17 | 94 | RP-221284 |  |
| 1977 | 904.2 | Perf. part: NR_demod_enh2 | 528d | 2020-09-15 A | 2022-09-22 A | 100% | finish no earlier than 2022-09-22 | R4 | 4224h | 4224h | NR_demod_enh2-Perf | 45 | Rel-17 | 89 | RP-221284 | 38.833 |
| 1978 | 904.3 | UE Conformance - Further enhancement on NR demodulation performance | 587d | 2022-06-15 A | 2024-09-09 A | 100% | finish no earlier than 2024-09-24 | R5 | 4696h | 4696h | NR_demod_enh2-UEConTest | 49 | Rel-17 | 96 | RP-241993 |  |
| 1979 | 905 | **Introduction of DL 1024QAM for NR frequency range 1 (FR1)** | 1226d | 2020-09-15 A | 2023-12-12 A | 100% |  |  | 9992h | 9992h | NR_DL1024QAM_FR1 | 45 | Rel-17 | 89 |  |  |
| 1980 | 905.1 | Core part: Introduction of DL 1024QAM for NR FR1 | 396d | 2020-09-15 A | 2022-03-22 A | 100% | finish no earlier than 2022-03-22 | R4 | 3168h | 3168h | NR_DL1024QAM_FR1-Core | 45 | Rel-17 | 89 | RP-220190 |  |
| 1981 | 905.2 | Perf. part: Introduction of DL 1024QAM for NR FR1 | 462d | 2020-09-15 A | 2022-06-22 A | 100% | finish no earlier than 2022-06-22 | R4 | 3696h | 3696h | NR_DL1024QAM_FR1-Perf | 45 | Rel-17 | 89 | RP-221226 /1771 |  |
| 1982 | 905.3 | UE Conformance - Introduction of DL 1024QAM for NR FR1 | 391d | 2022-06-15 A | 2023-12-12 A | 100% | finish no earlier than 2023-12-12 | R5 | 3128h | 3128h | NR_DL1024QAM_FR1-UEConTest | 49 | Rel-17 | 96 | RP-233873 |  |
| 1983 | 906 | **NR RRM further enhancement** | 764.12d | 2020-09-15 A | 2022-09-22 A | 100% |  |  | 7392h | 7392h | NR_RRM_enh2 | 45 | Rel-17 | 89 |  |  |
| 1984 | 906.1 | Core part: Further RRM enhancement for NR and MR-DC | 396d | 2020-09-15 A | 2022-03-22 A | 100% | finish no earlier than 2022-03-22 | R4 | 3168h | 3168h | NR_RRM_enh2-Core | 45 | Rel-17 | 89 | RP-221699 |  |
| 1985 | 906.2 | Perf. part: Further RRM enhancement for NR and MR-DC | 528d | 2020-09-15 A | 2022-09-22 A | 100% | finish no earlier than 2023-03-22 | R4 | 4224h | 4224h | NR_RRM_enh2-Perf | 45 | Rel-17 | 89 | RP-221699 |  |
| 1986 | 907 | **Enhanced NR support for high speed train scenario for frequency range 1 (FR1)** | 1030.38d | 2020-09-15 A | 2023-06-06 A | 100% |  |  | 9432h | 9432h | NR_HST_FR1_enh | 45 | Rel-17 | 89 |  |  |
| 1987 | 907.1 | Core part: Enhanced NR support for high speed train scenario for FR1 | 396d | 2020-09-15 A | 2022-03-22 A | 100% | finish no earlier than 2022-03-22 | R4 | 3168h | 3168h | NR_HST_FR1_enh-Core | 45 | Rel-17 | 89 | RP-221353 |  |
| 1988 | 907.2 | Perf. part: Enhanced NR support for high speed train scenario for FR1 | 528d | 2020-09-15 A | 2022-09-22 A | 100% | finish no earlier than 2022-09-22 | R4 | 4224h | 4224h | NR_HST_FR1_enh-Perf | 45 | Rel-17 | 89 | RP-221353 |  |
| 1989 | 907.3 | UE Conformance - Enhanced NR support for high speed train scenario for frequency range 1 (FR1) | 255d | 2022-06-15 A | 2023-06-06 A | 100% | finish no earlier than 2023-06-06 | R5 | 2040h | 2040h | NR_HST_FR1_enh-UEConTest | 49 | Rel-17 | 96 | RP-230283 |  |

Notes:
- 1965: affects: LTE, NR. compare REL-16 WI LTE_NR_DC_CA_enh; 28/7/20: WID:RP-193249->RP-201040 / WI rapporteur name: Huawei
- 1966: affects: LTE, NR. compare REL-16 WI LTE_NR_DC_CA_enh; / WI rapporteur name: Huawei
- 1967: affects: LTE, NR.; 22/3/22: CD:15/12/2021->12/09/2022; 22/3/22: Stat Rep: ->RP-220409; 20/6/22: WG: R4->R2; FCD:12/09/2022->22/09/2022; Compl:0%->30%; Stat Rep: RP-220409->RP-221500; Rapporteur: Huawei->David Lecompte, Huawei; Rap eMail: ->david.lecomp...9/9/22: Compl:30%->100%9/9/22: CD:12/09/2022->22/09/2022 / WI rapporteur name: Matti Kangas / WI rapporteur e-mail: matti.kangas@nokia.com
- 1968: ; 7/6/23: Compl:0%->5%; 6/9/23: Compl:5%->46%; Stat Rep: ->RP-232355; Rapporteur: Huawei->Yaping ZHANG, Huawei; Rap eMail: ->zhangyaping13@huawei.com; ; 8/12/23: FCD:03/03/2024->01/03/2024; Compl:46%->94%; Stat Rep: RP-232355->RP-233763; ; 2/1/24: WID...; 13/6/24: Compl:94%->100%; WID: RP-230436->RP-233764; Stat Rep: RP-240281->RP-241372; / WI rapporteur name: Yaping ZHANG, Huawei / WI rapporteur e-mail: zhangyaping13@huawei.com
- 1969: affects: NR. compare REL-16 WI NR_IAB; 28/7/20: WID:RP-193251->RP-201293; 7/4/21: WID:RP-201293->RP-210758; 2/7/21: WID:RP-210758->RP-211548; 6/1/22: WID:RP-211548->RP-213668; 12/7/22: WID:RP-213668->RP-221177 / WI rapporteur name: Qualcomm
- 1970: affects: NR. compare REL-16 WI NR_IAB; 13/9/21: Compl:0%->41%; 13/9/21: CD:Tue 15/06/21->Tue 22/03/22; 13/9/21: Stat Rep: ->RP-211767 ; 20/6/22: Rapporteur: Qualcomm->Georg Hampel, Qualcomm Incorporated; Rap eMail: ->ghampel@qti.qualcomm.com; / WI rapporteur name: Georg Hampel, Qualcomm Incorporated / WI rapporteur e-mail: ghampel@qti.qualcomm.com
- 1971: affects: NR.; 13/9/21: CD:Wed 15/12/21->Wed 22/09/21; 13/9/21: Stat Rep: ->RP-211767; 22/3/22: Compl:0%->20%; 22/3/2 20/6/22: WG: R4->R2; Rapporteur: Qualcomm->Georg Hampel, Qualcomm Incorporated; Rap eMail: ->ghampel@qti.qualcomm.com9/9/22: ... / WI rapporteur name: Georg Hampel, Qualcomm Incorporated / WI rapporteur e-mail: ghampel@qti.qualcomm.com
- 1972: 31/5/19: 0%->20; 13/9/19: 20%->50; 13/9/19: FCD:09/09/2019->12/20; 26/6/20: FCD:12/12/2019->12/20; 12/9/20: 50%->75; 5/12/20: FCD:15/12/2020->03/20; 5/12/20: WID:SP-190106->SP-201016, Rel-16->17; 9/4/21: FCD:12/03/2021->06/21; 11/6/21: 75%->78; 11/6/21 / WI rapporteur name: Rajavelsamy Rajadurai, Samsung, / WI rapporteur e-mail: rajvel{@]samsung.com
- 1973: affects: LTE, NR. No Perf. Part; compare REL-16 WI LTE_NR_arch_evo; 2/7/21: WID:RP-193181->RP-211409; 6/1/22: WID:RP-211409->RP-213667; 7/1/22: 37.483 added;; 7/1/22: 37.480 added; / WI rapporteur name: China Unicom
- 1974: affects: LTE, NR. no Perf. part; compare REL-16 WI LTE_NR_arch_evo; 6/1/22: WID:RP-211409->RP-213667; 20/6/22: FCD:15/12/2020->22/03/2023; Compl:0%->100%; Stat Rep: ->RP-220557; Rapporteur: China Unicom->Gen Cao; Rap eMail: ->caogen@chinaunicom.cn2... / WI rapporteur name: Gen Cao / WI rapporteur e-mail: caogen@chinaunicom.cn
- 1975: demodulation aspects were introduced in REL-15 WI NR_newRAT and enhanced in REL-16 WI NR_perf_enh-Perf; no Core part ; 6/1/21: WID:RP-202000->RP-202828; 7/4/21: WID:RP-202828->RP-210920; 2/7/21: WID:RP-210920->RP-211135; 29/9/21: WID:RP-211135->RP-2126 ; 12/7/22: WID:RP-213656->RP-221285 / WI rapporteur name: China Telecom
- 1976: ; 20/6/22: Rapporteur: China Telecom->Shan YANG, Tricia LI, Dmitry BELOV, China Telecom, Huawei, Intel Corporation; Rap eMail: ->yangshan@chinatelecom.cn, tricia.li@huawei.com, dmitry.belov@intel.com; / WI rapporteur name: Shan YANG, Tricia LI, Dmitry BELOV, China Telecom, Huawei, Intel Corporation / WI rapporteur e-mail: yangshan@chinatelecom.cn, tricia.li@huawei.com, dmitry.belov@intel.com
- 1977: demodulation aspects were introduced in REL-15 WI NR_newRAT and enhanced in REL-16 WI NR_perf_enh-Perf; no Core part ; 2/7/21: 38.833 added;; 13/9/21: Compl:0%->45%; 13/9/21: C ; 6/1/22: WID:RP-212636->RP-213656 20/6/22: FCD:10/06/2022->22/09/2022;... / WI rapporteur name: Shan YANG, Tricia LI, Dmitry BELOV, China Telecom, Huawei, Intel Corporation / WI rapporteur e-mail: yangshan@chinatelecom.cn, tricia.li@huawei.com, dmitry.belov@intel.com
- 1978: 9/9/22: Comp...; 9/12/22: FCD:23/12/2022->01/12/2023; Stat Rep: ->RP-222947; Rapporteur: ChinaTelecom->Wu Jingzhou, Balasubramanian Vijay, China Telecom, Qualcomm Inc; Rap eMail: ->wujingzhou@chinatelecom.cn, vijayb@qti.qualcomm.com; 17/3.....; 26/9/24: WID:RP-233586->RP-241994 / WI rapporteur name: Wu Jingzhou, Balasubramanian Vijay, China Telecom, Qualcomm Inc / WI rapporteur e-mail: wujingzhou@chinatelecom.cn, vijayb@qti.qualcomm.com
- 1979: ; 6/1/21: WID:RP-202044->RP-202886; 6/1/22: WID:RP-202886->RP-213654 / WI rapporteur name: Ericsson
- 1980: ; 20/6/22: FCD:08/09/2021->22/03/2022; Compl:0%->100%; Stat Rep: ->RP-220190; Rapporteur: Ericsson->Yi GUO; Rap eMail: ->yi.guo@intel.com; / WI rapporteur name: Yi GUO / WI rapporteur e-mail: yi.guo@intel.com
- 1981: ; 13/9/21: Compl:0%->90%; 13/9/21: CD:Sat 12/03/22->Tue 21/12/21; 13/9/21: Stat Rep: ->RP-211770; ; 20/6/22: FCD:11/03/2022->22/06/2022; Stat Rep: RP-220190->RP-221226 /1771; Rapporteur: Ericsson->Wanuga, Kevin (RAN1); Uesaka, Kazuyoshi (RAN4), Nokia, Ericsson; Rap eMail: ->kevin (dot) wanuga (at) nokia (dot) com; kazuyoshi (dot) uesaka (at) ericsson (dot) com; / WI rapporteur name: Wanuga, Kevin (RAN1); Uesaka, Kazuyoshi (RAN4), Nokia, Ericsson / WI rapporteur e-mail: kevin (dot) wanuga (at) nokia (dot) com; kazuyoshi (dot) uesaka (at) ericsson (dot) com
- 1982: 9/9/22: Comp...; 9/12/22: FCD:23/03/2023->01/03/2023; Compl:5%->34%; Stat Rep: ->RP-223384; Rapporteur: Qualcomm->Vijay Balasubramanian, Qualcomm; Rap eMail: ->vijayb[at]qti.qualcomm.com; 17/3/23: FCD:03/03/2023->08/09/2023; Stat Rep: RP-.....; 8/12/23: Compl:90%->100%; Stat Rep: RP-232015->RP-233873; / WI rapporteur name: Vijay Balasubramanian, Qualcomm / WI rapporteur e-mail: vijayb[at]qti.qualcomm.com
- 1983: LTE impacts? ; 6/1/21: WID:RP-202053->RP-202874; 6/1/22: WID:RP-202874->RP-213067 / WI rapporteur name: Apple
- 1984: LTE impacts? ; 4/6/22: 0%->100; 20/6/22: FCD:08/09/2021->22/03/2023; Stat Rep: ->RP-221699; Rapporteur: Apple->Jie Cui, Apple Corporation; Rap eMail: ->jie_cui@apple.com; / WI rapporteur name: Jie Cui, Apple Corporation / WI rapporteur e-mail: jie_cui@apple.com
- 1985: LTE impacts? ; 13/9/21: Compl:0%->60%; 13/9/21: CD:Sat 12/03/22->Tue 22/03/22 ; ; 20/6/22: FCD:22/03/2023->22/09/2022; Compl:100%->50%; Rapporteur: Apple->Jie Cui, Apple Corporation; Rap eMail: ->jie_cui@apple.com 9/9... / WI rapporteur name: Jie Cui, Apple Corporation / WI rapporteur e-mail: jie_cui@apple.com
- 1986: follow-up WI of REL-16 WI NR_HST ; 6/1/21: WID:RP-202106->RP-202335; 7/4/21: WID:RP-202335->RP-210833 / WI rapporteur name: CMCC
- 1987: follow-up WI of REL-16 WI NR_HST ; 13/9/21: Compl:0%->70%; 13/9/ ; ; 20/6/22: Rapporteur: CMCC->Jingjing Chen, CMCC; Rap eMail: ->chenjingjing@chinamobile.com; / WI rapporteur name: Jingjing Chen, CMCC / WI rapporteur e-mail: chenjingjing@chinamobile.com
- 1988: follow-up WI of REL-16 WI NR_HST ; 13/9/21: Compl:0%->50%; 1 ; 22/3/22: Compl:50%->70%; 20/6/22: Rapporteur: CMCC->Jingjing Chen, CMCC; Rap eMail: ->chenjingjing@chinamobile.com ; 9/9/22: Compl:85%->100% / WI rapporteur name: Jingjing Chen, CMCC / WI rapporteur e-mail: chenjingjing@chinamobile.com
- 1989: 9/9/22: Comp...; 9/12/22: FCD:23/06/2023->01/06/2023; Compl:23%->62%; Stat Rep: ->RP-223063; Rapporteur: CMCC->Dan SONG, CMCC; Rap eMail: ->songdan@chinamobile.com; 17/3/23: Compl:62%->71%; Stat Rep: RP-223063->RP-230283; ... / WI rapporteur name: Dan SONG, CMCC / WI rapporteur e-mail: songdan@chinamobile.com

| ID | WBS | Task | Type | Duration | Start | Finish | Complete | Actual finish | Constraint | Resources | Work | Actual work | Acronym | PCG approved | Impacted TSs and TRs | Release | TSG approved | WI rapporteur e-mail | Status Report |
| --- | --- | --- | --- | --- | --- | --- | --- | --- | --- | --- | --- | --- | --- | --- | --- | --- | --- | --- | --- |
| 1990 | 908 | **Further enhancements of NR RF requirements for frequency range 2 (FR2)** |  | 1308.75d | 2020-09-15 A | 2024-03-01 A | 100% |  |  |  | 11024h | 11024h | NR_RF_FR2_req_enh2 | 45 | 38.851 | Rel-17 | 89 |  |  |
| 1991 | 908.1 | Core part: NR_RF_FR2_req_enh2 |  | 462d | 2020-09-15 A | 2022-06-22 A | 100% |  | finish no earlier than 2022-06-22 | R4 | 3696h | 3696h | NR_RF_FR2_req_enh2-Core | 45 |  | Rel-17 | 89 | Petri.j.vasenkari@nokia.com | RP-221205 |
| 1992 | 908.2 | Perf. part: NR_RF_FR2_req_enh2 |  | 528d | 2020-09-15 A | 2022-09-22 A | 100% |  | finish no earlier than 2022-09-22 | R4 | 4224h | 4224h | NR_RF_FR2_req_enh2-Perf | 45 |  | Rel-17 | 89 | Petri.j.vasenkari@nokia.com | RP-221205 |
| 1993 | 908.3 | UE Conformance - Further enhancements of NR RF requirements for frequency range 2 (FR2) |  | 388d | 2022-09-08 A | 2024-03-01 A | 100% |  | finish no earlier than 2024-03-01 | R5 | 3104h | 3104h | NR_RF_FR2_req_enh2-UEConTest | 49 |  | Rel-17 | 97 | tuomo.saynajakangas@nokia.com ashwin_mohan@apple.com | RP-240092 |
| 1994 | 909 | **NR support for high speed train scenario in frequency range 2 (FR2)** |  | 1604.75d | 2020-09-15 A | 2024-12-12 | 100% | 2025-12-12 |  |  | 17968h | 17968h | NR_HST_FR2 | 45 |  | Rel-17 | 89 |  |  |
| 1995 | 909.1 | Core part: NR support for high speed train scenario in FR2 |  | 396d | 2020-09-15 A | 2022-03-22 A | 100% |  | finish no earlier than 2022-03-22 | R4 | 3168h | 3168h | NR_HST_FR2-Core | 45 |  | Rel-17 | 89 | h0809.wang@samsung.com | RP-221404 |
| 1996 | 909.2 | Perf. Part: NR support for high speed train scenario in FR2 |  | 528d | 2020-09-15 A | 2022-09-22 A | 100% |  | finish no earlier than 2022-09-22 | R4 | 4224h | 4224h | NR_HST_FR2-Perf | 45 |  | Rel-17 | 89 | h0809.wang@samsung.com | RP-221404 |
| 1997 | 909.3 | UE Conformance - NR support for high speed train scenario in frequency range 2 (FR2) |  | 1322d | 2022-06-15 A | 2025-12-12 A | 100% |  | finish no earlier than 2025-12-12 | R5 | 10576h | 10576h | NR_HST_FR2-UEConTest | 49 |  | Rel-17 | 96 | runsen.tang@samsung.com | RP-253314 |
| 1998 | 910 | **NR measurement gap enhancements** |  | 1409d | 2020-09-15 A | 2024-06-06 A | 100% |  |  |  | 10512h | 10512h | NR_MG_enh | 45 |  | Rel-17 | 89 |  |  |
| 1999 | 910.1 | Core part: NR and MR-DC measurement gap enhancements |  | 396d | 2020-09-15 A | 2022-03-22 A | 100% |  | finish no earlier than 2022-03-22 | R4 | 3168h | 3168h | NR_MG_enh-Core | 45 |  | Rel-17 | 89 | ato.yu@mediatek.com, rui.huang@intel.com | RP-221549 |
| 2000 | 910.2 | Perf. part: NR and MR-DC measurement gap enhancements |  | 528d | 2020-09-15 A | 2022-09-22 A | 100% |  | finish no earlier than 2023-03-22 | R4 | 4224h | 4224h | NR_MG_enh-Perf | 45 |  | Rel-17 | 89 | ato.yu@mediatek.com, rui.huang@intel.com | RP-221549 |
| 2001 | 910.3 | UE Conformance - NR and MR-DC measurement gap enhancements |  | 390d | 2022-12-14 A | 2024-06-06 A | 100% |  | finish no earlier than 2024-06-06 | R5 | 3120h | 3120h | NR_MG_enh-UEConTest | 50 |  | Rel-17 | 98 | daiwei.zhou@mediatek.com | RP-241346 |
| 2002 | 911 | **RF requirements enhancement for NR frequency range 1 (FR1)** |  | 1308.75d | 2020-09-15 A | 2024-03-01 A | 100% |  |  |  | 10984h | 10984h | NR_RF_FR1_enh | 45 |  | Rel-17 | 89 |  |  |
| 2003 | 911.1 | Core part: RF requirements enhancement for NR FR1 |  | 396d | 2020-09-15 A | 2022-03-22 A | 100% |  | finish no earlier than 2022-03-22 | R4 | 3168h | 3168h | NR_RF_FR1_enh-Core | 45 |  | Rel-17 | 89 | leo.liuye@huawei.com | RP-221501 |
| 2004 | 911.2 | Perf. part: RF requirements enhancement for NR FR1 |  | 528d | 2020-09-15 A | 2022-09-22 A | 100% |  | finish no earlier than 2022-09-22 | R4 | 4224h | 4224h | NR_RF_FR1_enh-Perf | 45 |  | Rel-17 | 89 | leo.liuye@huawei.com | RP-221501 |
| 2005 | 911.3 | UE Conformance - RF requirements enhancement for NR frequency range 1 (FR1) |  | 449d | 2022-06-15 A | 2024-03-01 A | 100% |  | finish no earlier than 2024-03-01 | R5 | 3592h | 3592h | NR_RF_FR1_enh-UEConTest | 49 |  | Rel-17 | 96 | guchunying@huawei.com | RP-240280 |
| 2006 | 912 | **4Rx support for NR band n8** |  | 294d | 2021-12-13 A | 2022-09-22 A | 100% |  |  | R4 | 3248h | 3248h | NR_4Rx_Bn8_FWA | 48 |  | Rel-17 | 94 |  |  |
| 2007 | 912.1 | Core part: 4Rx support for NR band n8 |  | 65d | 2021-12-13 A | 2022-03-11 A | 100% |  | start no earlier than 2021-12-12 | R4 | 520h | 520h | NR_4Rx_Bn8_FWA-Core | 48 |  | Rel-17 | 94 |  | RP-220394 |
| 2008 | 912.2 | Perf. part: 4Rx support for NR band n8 |  | 65d | 2021-12-13 A | 2022-03-11 A | 100% |  | start no earlier than 2021-12-12 | R4 | 520h | 520h | NR_4Rx_Bn8_FWA-Perf | 48 |  | Rel-17 | 94 |  | RP-220394 |
| 2009 | 912.3 | UE Conformance - 4Rx support for NR band n8 |  | 72d | 2022-06-15 A | 2022-09-22 A | 100% |  | finish no earlier than 2022-09-22 | R5 | 576h | 576h | NR_4Rx_Bn8_FWA-UEConTest | 49 |  | Rel-17 | 96 |  |  |
| 2010 | 913 | Rel-17 Self-Organizing (SON)/Autonomous Networks | milestone, manual | 0d | 2016-06-09 A | 2016-06-09 A | 100% |  | finish no earlier than 2016-06-09 |  |  |  |  |  | 26.234; 26.247 | Rel-17 |  |  |  |
| 2011 | 914 | **Enhancement of data collection for SON (Self-Organising Networks)/MDT (Minimization of Drive Tests) in NR and EN-DC** |  | 857.38d | 2019-12-16 A | 2022-03-22 A | 100% |  |  |  | 4736h | 4736h | NR_ENDC_SON_MDT_enh | 44 |  | Rel-17 | 86 |  |  |
| 2012 | 914.1 | Core part: Enhancement of data collection for SON (Self-Organising Networks)/MDT (Minimization of Drive Tests) in NR standalone and MR-DC (Multi-Radio Dual Connectivity) |  | 592d | 2019-12-16 A | 2022-03-22 A | 100% |  | finish no earlier than 2022-03-22 | R3 | 4736h | 4736h | NR_ENDC_SON_MDT_enh-Core | 44 |  | Rel-17 | 86 | liuliang@chinamobile.com, angelo.centonza@ericsson.com | RP-220820 |
| 2013 | 915 | Plug and connect support for management of Network Functions |  | 257d | 2021-03-18 A | 2022-03-11 A | 100% |  | finish no earlier than 2022-03-12 | S5 | 2056h | 2056h | PACMAN | 46 | 28.313 | Rel-17 | 91 | Per.elmdahl@ericsson.com |  |
| 2014 | 916 | Enhancements of Self-Organizing Networks (SON) for 5G networks |  | 513d | 2020-03-25 A | 2022-03-11 A | 100% |  | finish no earlier than 2022-03-12 | S5 | 4104h | 4104h | eSON_5G | 44 | 28.313; 28.552; 28.541; 28.545 | Rel-17 | 87 | joey<dot>chou<at>intel<dot>com |  |
| 2015 | 917 | Study on autonomous network levels |  | 258d | 2019-09-19 A | 2020-09-14 A | 100% |  | finish no earlier than 2020-09-14 | S5 | 2064h | 2064h | FS_ANL | 43 | New ; 28.810 | Rel-17 | 85 | caoxi@chinamobile.com |  |
| 2016 | 918 | Autonomous network levels |  | 391d | 2020-06-12 A | 2021-12-10 A | 100% |  | finish no earlier than 2021-12-12 | S5 | 3128h | 3128h | ANL | 45 |  | Rel-17 | 88 | caoxi@chinamobile.com |  |
| 2017 | 919 | Rel-17 Multicast-broadcast Services (MBS) and Mission Critical (MC) | milestone, manual | 0d | 2016-06-09 A | 2016-06-09 A | 100% |  | finish no earlier than 2016-06-09 |  |  |  |  |  | 26.234; 26.247 | Rel-17 |  |  |  |
| 2018 | 920 | Study on Multicast Architecture Enhancements for 5G Media Streaming |  | 318d | 2020-03-25 A | 2021-06-11 A | 100% |  | finish no earlier than 2021-06-12 | S4 | 2544h | 2544h | FS_5GMS_Multicast | 44 | new | Rel-17 | 87 | peng.tan@telus.com |  |
| 2019 | 921 | Study on location enhancements for mission critical services |  | 390d? | 2018-09-14 A | 2020-03-12 A | 100% |  | finish no earlier than 2020-03-12 | S6 | 3120h | 3120h | FS_enhMCLoc | 41 | 23.744 | Rel-17 | 81 | dom.lazara@motorolasolutions.com |  |
| 2020 | 922 | Study on Security Aspects of Enhancements for 5G Multicast-Broadcast Services |  | 391d | 2020-06-12 A | 2021-12-10 A | 100% |  | finish no earlier than 2021-12-12 | S3 | 3128h | 3128h | FS_5MBS_SEC | 45 | 33.850 | Rel-17 | 88 | guolonghua@huawei.com |  |
| 2021 | 923 | Study on Mission Critical services over 5G multicast-broadcast system |  | 126d | 2019-09-19 A | 2020-03-12 A | 100% |  | finish no earlier than 2020-03-12 | S6 | 1008h | 1008h | FS_MC5MBS | 43 | New ; 23.774; 33.524 | Rel-17 | 85 |  |  |

Notes:
- 1990: compare REL-16 WI NR_RF_FR2_req_enh ; 6/1/21: WID:RP-202107->RP-202409; 7/4/21: WID:RP-202409->RP-210914; 2/7/21: WID:RP-210914->RP-211538; 2/7/21: 38.851 added;; 29/9/21: WID:RP-211538->RP-212092; 6/1/22: WID:RP-212092->RP-213666; 5/4/22: WID:RP-21366 ; 12/7/22: WID:RP-220968->RP-221784 / WI rapporteur name: Nokia
- 1991: compare REL-16 WI NR_RF_FR2_req_enh ; 13/9/21: Compl:0%->55%; ; 22/3/22: Compl:55%->75%; 20/6/22: Rapporteur: Nokia->Vasenkari, Petri, Nokia; Rap eMail: ->Petri.j.vasenkari@nokia.com; / WI rapporteur name: Vasenkari, Petri, Nokia
- 1992: compare REL-16 WI NR_RF_FR2_req_enh ; 13/9/21: Compl:0%->25%; ; 22/3/22: CD:22/06/2022->10/06/2022 ; 20/6/22: Rapporteur: Nokia->Vasenkari, Petri, Nokia; Rap eMail: ->Petri.j.vasenkari@nokia.com 9/9/22: Compl:80%... / WI rapporteur name: Vasenkari, Petri, Nokia
- 1993: 9/12/22: FCD:10/12/2023->01/12/2023; Compl:0%->6%; Stat Rep: ->RP-222732; Rapporteur: Nokia->Tuomo S yn j kangas, Ashwin Mohan, Nokia, Apple; Rap eMail: ->tuomo.saynajakangas@nokia.com ashwin_mohan@apple.com; 17/3/23: FCD:30/11/2023->12/12/2023; Com.....; 2/4/24: WID:RP-221932->RP-240751 / WI rapporteur name: Tuomo S yn j kangas, Ashwin Mohan, Nokia, Apple
- 1994: follow-up WI of REL-16 WI NR_HST; TR 38.8xx ; 6/1/21: WID:RP-202118->RP-202538; 7/4/21: WID:RP-202538->RP-210800 / WI rapporteur name: Samsung
- 1995: follow-up WI of REL-16 WI NR_HST; TR 38.8xx ; 13/9/21: Compl:0%->50%; ; 20/6/22: Rapporteur: Samsung->WANG, He (Jackson), Samsung; Rap eMail: ->h0809.wang@samsung.com; / WI rapporteur name: WANG, He (Jackson), Samsung
- 1996: follow-up WI of REL-16 WI NR_HST ; 13/9/21: Compl:0%->20% ; 22/3/22: Compl:20%->50%; 20/6/22: Rapporteur: Samsung->WANG, He (Jackson), Samsung; Rap eMail: ->h0809.wang@samsung.com ; 9/9/22: Compl:80%->100% / WI rapporteur name: WANG, He (Jackson), Samsung
- 1997: 9/9/22: Comp...; 9/12/22: FCD:23/12/2022->01/12/2023; Stat Rep: ->R5-226806; Rapporteur: Samsung->Runsen Tang, Samsung; Rap eMail: ->runsen.tang@samsung.com; 17/3/23: FCD:30/11/2023->12/12/2023; Compl:7%->18%; Stat Rep: R5-226806->RP-2301.....; 7/1/26: WID:RP-251017->RP-253315 / WI rapporteur name: Runsen Tang, Samsung
- 1998: measurement gaps were introduced for NR in REL-15 WI NR_newRAT ; 6/1/21: WID:RP-202119->RP-202658; 7/4/21: WID:RP-202658->RP-210679; 2/7/21: WID:RP-210679->RP-211591; 6/1/22: WID:RP-211591->RP-213658 / WI rapporteur name: MediaTek
- 1999: measurement gaps were introduced for NR in REL-15 WI NR_newRAT ; 20/6/22: FCD:08/09/2021->22/03/2023; Compl:0%->100%; WID: RP-213658->RP-220772; Stat Rep: ->RP-221549; Rapporteur: MediaTek->Ato (Tsang-Wei) YU, Rui HUANG, MediaTek Inc., Intel Corporation; Rap eMail: ->ato.yu@mediatek.com, rui.huang@intel.com; / WI rapporteur name: Ato (Tsang-Wei) YU, Rui HUANG, MediaTek Inc., Intel Corporation
- 2000: measurement gaps were introduced for NR in REL-15 WI NR_newRAT ; 20/6/22: FCD:22/03/2023->22/09/2022; Compl:100%->40%; Rapporteur: MediaTek->Ato (Tsang-Wei) YU, Rui HUANG, MediaTek Inc., Intel Corporation; Rap eMail: ->ato.yu@mediatek.com, rui.... / WI rapporteur name: Ato (Tsang-Wei) YU, Rui HUANG, MediaTek Inc., Intel Corporation
- 2001: 17/3/23: FCD:03/03/2024->01/03/2024; Compl:0%->31%; Stat Rep: ->RP-230638; Rapporteur: MediaTek->Daiwei Zhou, MediaTek Inc.; Rap eMail: ->daiwei.zhou@mediatek.com; ;...; 6/9/23: Compl:55%->63%; Stat Rep: RP-230638->RP-232306; ; 8/12/23: FCD:03/03/2024...; 13/6/24: Compl:95%->100%; Stat Rep: RP-240441->RP-241346; / WI rapporteur name: Daiwei Zhou, MediaTek Inc.
- 2002: compare REL-16 WI NR_RF_FR1 ; 6/1/21: WID:RP-202088->RP-202799; 7/4/21: WID:RP-202799->RP-210899; 29/9/21: WID:RP-210899->RP-212527; 5/4/22: WID:RP-212527->RP-220681 / WI rapporteur name: Huawei
- 2003: compare REL-16 WI NR_RF_FR1 ; 13/9/21: Compl:0%->60%; ; 22/3/22: Compl:60%->90%; 20/6/22: Rapporteur: Huawei->Liu Ye, Huawei, HiSilicon; Rap eMail: ->leo.liuye@huawei.com; / WI rapporteur name: Liu Ye, Huawei, HiSilicon
- 2004: compare REL-16 WI NR_RF_FR1 ; 13/9/21: CD:Sat 11/12/21->Wed 22/09/21; ; 22/3/22: CD:22/09/2021->12/09/2022; 22/3/22: Stat Rep: RP-212170->RP-220680 ; 20/6/22: Rapporteur: Huawei->Liu Ye, Huawei, HiSilicon; Rap eMail: ->leo.liuye@huawei.com12/7/22... / WI rapporteur name: Liu Ye, Huawei, HiSilicon
- 2005: 9/9/22: Comp...; 9/12/22: FCD:23/12/2022->01/12/2023; Stat Rep: ->RP-223222; Rapporteur: Huawei->Chunying GU, Huawei; Rap eMail: ->guchunying@huawei.com; 17/3/23: FCD:30/11/2023->12/12/2023; Compl:11%->20%; Stat Rep: RP-223222->RP-230702;.....; 14/3/24: FCD:05/06/2024->01/03/2024; Compl:50%->100%; Stat Rep: RP-233762->RP-240280; / WI rapporteur name: Chunying GU, Huawei
- 2006: 5/4/22: WID:RP-213659->RP-220395 / WI rapporteur name: CHTTL
- 2007: ; / WI rapporteur name: CHTTL
- 2008: ; / WI rapporteur name: CHTTL
- 2009: 9/9/22: Comp...; 23/9/22: WID:RP-221159->RP-222137 / WI rapporteur name: ChinaUnicom
- 2011: affects: LTE, NR. no Perf. part; compare REL-16 SI FS_LTE_NR_data_collect and REL-16 WI NR_SON_MDT-Core; includes EN-DC and MR-DC changes and therefore LTE changes; 6/1/22: WID:RP-193255->RP-213574; 5/4/22: WID:RP-213574->RP-220821 / WI rapporteur name: CMCC
- 2012: affects: LTE, NR. no Perf. part; compare REL-16 SI FS_LTE_NR_data_collect and REL-16 WI NR_SON_MDT-Core; includes EN-DC and MR-DC changes and therefore LTE changes; 28/7/20: WID:RP-193255->RP-201281; ; 6/1/22: WID:RP-193255->RP-213574; 20/6/22: Compl:65%->100%; WID: RP-220821->RP-213574; Stat Rep: RP-211998->RP-220820; Rapporteur: CMCC->Liang LIU, AngeloCentonza; Rap eMail: ->liuliang@chinamobile.com, angelo.centonza@ericsson.com; / WI rapporteur name: Liang LIU, AngeloCentonza
- 2013: ; 11/6/21: 0%->10; 13/9/21: 10%->20; 13/12/21: 20%->70; 13/12/21: FCD:Fri 10/06/->03/22; 12/3/22: 70%->100 / WI rapporteur name: Per Elmdahl, Ericsson
- 2014: ; 13/9/20: 0%->2; 5/12/20: 2%->5; 21/3/21: 5%->15; 11/6/21: 15%->35; 11/6/21: FCD:Thu 17/06/->12/21; 13/9/21: 35%->70; 13/12/21: 70%->90; 13/12/21: FCD:Fri 10/12/->03/22; 21/6/22: 90%->100 / WI rapporteur name: Joey Chou, Intel
- 2015: ; 8/10/19: 28.810 added;; 26/3/20: 0%->50; 26/3/20: FCD:12/03/2020->06/20; 28/6/20: 50%->85; 13/9/20: 85%->100; 13/9/20: FCD:12/06/2020->09/20. 9/4/21: Rel-16->Rel-17 / WI rapporteur name: China Mobile
- 2016: 28.533; 28.313; 28.535; 28.809; 28.312; 28.541 ; 13/9/20: 0%->5; 13/9/20: FCD:11/12/2020->06/21; 5/12/20: 5%->30; 21/3/21: 30%->50; 11/6/21: 50%->70; 13/9/21: 70%->71; 13/9/21: FCD:Fri 11/06/->12/21; 13/12/21: 71%->100 / WI rapporteur name: Cao, Xi, China Mobile
- 2018: 10/6/20: 0%->5; 5/12/20: 5%->25; 5/12/20: FCD:17/12/2020->06/20; 21/3/21: 25%->60; 11/6/21: 60%->100 / WI rapporteur name: Peng Tan, Telus
- 2019: 7/12/18: 0%->20¦14/3/19: 20%->45¦14/3/19: FCD:03/19->09/19; 31/5/19: 45%->60; 13/9/19: 60%->70; 13/9/19: FCD:12/09/2019->03/20; 20/9/19: WID:SP-180921->SP-190725; 6/12/19: 70%->75; 28/6/20: 75%->90. Moved from Rel-16; 5/12/20: 90%->100 / WI rapporteur name: Dom Lazara, Motorola Solutions
- 2020: 28/7/20: 33.850 added;; 12/9/20: 0%->15; 5/12/20: 15%->30; 19/3/21: 30%->60; 19/3/21: FCD:25/03/2021->06/21; 11/6/21: 60%->75; 11/6/21: FCD:Fri 11/06/->12/21; 13/9/21: 75%->85; 12/3/22: 85%->100 / WI rapporteur name: Longhua Guo, Huawei Technologies
- 2021: ; 13/9/19: 0%->20; 8/10/19: 23.774 added;; 8/10/19: 33.524 added;; 6/12/19: 20%->55; 26/3/20: 55%->100 / WI rapporteur name: Val Oprescu, AT&T

| ID | WBS | Task | Type | Duration | Start | Finish | Complete | Constraint | Resources | Work | Actual work | Acronym | PCG approved | WI rapporteur name | WI rapporteur e-mail | Release | TSG approved | Status Report |
| --- | --- | --- | --- | --- | --- | --- | --- | --- | --- | --- | --- | --- | --- | --- | --- | --- | --- | --- |
| 2022 | 924 | **Multicast-broadcast services in 5G** |  | 1888.88d | 2019-03-07 A | 2024-03-03 A | 100% |  |  | 15743h | 15743h | 5MBS | 46 | Meng Li, Huawei | raymond.limeng@huawei.com | Rel-17 | 90 |  |
| 2023 | 924.1 | Study on Architectural enhancements for 5MBS |  | 526.88d | 2019-03-07 A | 2021-03-12 A | 100% | finish no earlier than 2021-03-12 | S2 | 4215h | 4215h | FS_5MBS | 42 | Meng Li, Huawei | raymond.limeng@huawei.com | Rel-17 | 83 |  |
| 2024 | 924.2 | Stage 2 for 5MBS |  | 202d | 2020-12-03 A | 2021-09-10 A | 100% | finish no earlier than 2021-09-12 | S2 | 1616h | 1616h | 5MBS | 46 | Meng Li, Huawei | raymond.limeng@huawei.com | Rel-17 | 90 |  |
| 2025 | 924.3 | CT1 aspects of 5MBS |  | 196d | 2021-06-11 A | 2022-03-11 A | 100% | finish no earlier than 2022-03-12 | C1 | 1568h | 1568h | 5MBS | 47 | Gulbani, Giorgi, Huawei | giorgi.gulbani@huawei.com | Rel-17 | 92 |  |
| 2026 | 924.4 | CT3 aspects of 5MBS |  | 196d | 2021-06-11 A | 2022-03-11 A | 100% | finish no earlier than 2022-03-12 | C3 | 1568h | 1568h | 5MBS | 47 | Gulbani, Giorgi, Huawei | giorgi.gulbani@huawei.com | Rel-17 | 92 |  |
| 2027 | 924.5 | CT4 aspect of 5MBS |  | 196d | 2021-06-11 A | 2022-03-11 A | 100% | finish no earlier than 2022-03-12 | C4 | 1568h | 1568h | 5MBS | 46 | Gulbani, Giorgi, Huawei | giorgi.gulbani@huawei.com | Rel-17 | 91 |  |
| 2028 | 924.6 | CT6 aspects of 5MBS |  | 196d | 2021-06-11 A | 2022-03-11 A | 100% | finish no earlier than 2022-03-12 | C6 | 1568h | 1568h | 5MBS | 49 | Gulbani, Giorgi, Huawei | giorgi.gulbani@huawei.com | Rel-17 | 96 |  |
| 2029 | 924.7 | Security Aspects of Enhancements for 5G Multicast-Broadcast Services |  | 261d | 2021-06-11 A | 2022-06-10 A | 100% | finish no earlier than 2022-06-12 | S3 | 2088h | 2088h | 5MBS | 47 | Longhua Guo, Huawei Technologies | guolonghua@huawei.com | Rel-17 | 92 |  |
| 2030 | 924.8 | Charging Aspects for SMF and MB-SMF to Support 5G Multicast-broadcast Services |  | 194d | 2023-06-08 A | 2024-03-03 A | 100% | finish no earlier than 2024-03-03 | S5 | 1552h | 1552h | 5MBS_CH | 51 | Dong, Jia, China Mobile, | dongjia at chinamobile dot com | Rel-18 | 100 |  |
| 2031 | 925 | Broadcast / Multicast requirements supporting Mission Critical Services in 5G |  | 74d | 2019-09-02 A | 2019-12-12 A | 100% | finish no earlier than 2019-12-12 | S1 | 592h | 592h | 5MBS_eMC | 43 | Toobe, Jens, BDBOS | jens.toobe at bdbos.bmi.bund.de | Rel-17 | 85 |  |
| 2032 | 926 | 5G Multicast-Broadcast Protocols |  | 131d | 2021-12-10 A | 2022-06-10 A | 100% | finish no earlier than 2022-06-12 | S4 | 1048h | 1048h | 5MBP3 | 48 | Thomas Stockhammer, Qualcomm Incorporated | tsto@QTI.QUALCOMM.COM | Rel-17 | 94 |  |
| 2033 | 927 | **NR multicast and broadcast services** |  | 1509.75d | 2019-12-16 A | 2023-12-12 A | 100% |  | R2 | 15568h | 15568h | NR_MBS | 44 | Huawei |  | Rel-17 | 86 |  |
| 2034 | 927.1 | Core part: NR multicast and broadcast services |  | 585d | 2019-12-16 A | 2022-03-11 A | 100% | finish no earlier than 2022-03-12 | R2 | 4680h | 4680h | NR_MBS-Core | 44 | Huawei |  | Rel-17 | 86 | RP-220407 |
| 2035 | 927.2 | UE Conformance - NR Multicast and Broadcast Services including CT and SA aspects |  | 457d | 2022-03-15 A | 2023-12-12 A | 100% | finish no earlier than 2023-12-12 | R5 | 3656h | 3656h | NR_MBS_5MBS_5MBUSA-UEConTest | 48 | Ya Zhao, Huawei Technologies. Co., Ltd | zhaoya@hisilicon.com | Rel-17 | 95 | RP-233760 |
| 2036 | 928 | **Mission Critical Services over 5GS** |  | 561.12d | 2020-09-16 A | 2022-03-11 A | 100% |  |  | 3128h | 3128h | MCOver5GS | 45 | Wendler, Ingo, UIC | ingo.wendler@sbb.ch | Rel-17 | 89 |  |
| 2037 | 928.1 | Stage 2 of MCOver5GS |  | 195d | 2020-09-16 A | 2021-06-15 A | 100% | finish no earlier than 2021-06-15 | S6 | 1560h | 1560h | MCOver5GS | 45 | Wendler, Ingo, UIC | ingo.wendler@sbb.ch | Rel-17 | 89 |  |
| 2038 | 928.2 | CT1 aspects of MCOver5GS |  | 196d | 2021-06-11 A | 2022-03-11 A | 100% | finish no earlier than 2022-03-12 | C1 | 1568h | 1568h | MCOver5GS | 47 | Gkatzikis, Lazaros, Nokia | lazaros(dot)gkatzikis(at)nokia(dot)com | Rel-17 | 92 |  |
| 2039 | 929 | **Mission Critical Data** |  | 856.38d | 2019-12-06 A | 2022-03-11 A | 100% |  |  | 6808h | 6808h | eMCData3 | 44 | Shih, Jerry, AT&T | jerry.shih@att.com | Rel-17 | 86 |  |
| 2040 | 929.1 | Stage 2 of MCData3 |  | 398d | 2019-12-06 A | 2021-06-15 A | 100% | finish no earlier than 2021-06-15 | S6 | 3184h | 3184h | eMCData3 | 44 | Shih, Jerry, AT&T | jerry.shih@att.com | Rel-17 | 86 |  |
| 2041 | 929.2 | CT aspects of eMCData3 |  | 453d | 2020-06-17 A | 2022-03-11 A | 100% | finish no earlier than 2022-03-12 | C1 | 3624h | 3624h | eMCData3 | 45 |  |  | Rel-17 | 89 |  |
| 2042 | 930 | Mission Critical system migration and interconnection |  | 847d | 2018-12-13 A | 2022-03-11 A | 100% | finish no earlier than 2022-03-12 | C1 | 6776h | 6776h | MCSMI_CT | 42 | Dom Lazara, Motorola Solutions | dom.lazara@motorolasolutions.com | Rel-17 | 82 |  |
| 2043 | 931 | CT aspects of Enhanced Mission Critical Communication Interworking with Land Mobile Radio Systems |  | 256d | 2020-09-16 A | 2021-09-08 A | 100% | finish no earlier than 2021-09-08 | C1 | 2048h | 2048h | eMCCI_CT | 45 | Mike Dolan, FirstNet | michael.dolan@firstnet.gov | Rel-17 | 89 |  |
| 2044 | 932 | Rel-17 Edge computing | milestone, manual | 0d | 2016-06-09 A | 2016-06-09 A | 100% | finish no earlier than 2016-06-09 |  |  |  |  |  |  |  | Rel-17 |  |  |
| 2045 | 933 | **Architecture for enabling Edge Applications** |  | 1231.38d | 2019-03-07 A | 2022-06-07 A | 100% |  |  | 13159.1h | 13159.1h | EDGEAPP | 44 | Basavaraj (Basu) Pattan, Samsung | basavarajjp@samsung.com | Rel-17 | 86 |  |
| 2046 | 933.1 | Study on Application Architecture for enabling Edge Applications |  | 195.88d | 2019-03-07 A | 2019-12-05 A | 100% |  | S6 | 1567h | 1567h | FS_EDGEAPP | 42 | Basavaraj (Basu) Pattan, Samsung | basavarajjp@samsung.com | Rel-17 | 83 |  |
| 2047 | 933.2 | Architecture for enabling Edge Applications |  | 398d | 2019-12-06 A | 2021-06-15 A | 100% | finish no earlier than 2021-06-15 | S6 | 3184h | 3184h | EDGEAPP | 44 | Basavaraj (Basu) Pattan, Samsung | basavarajjp@samsung.com | Rel-17 | 86 |  |

Notes:
- 2022: 23.501; 23.502; 23.503
- 2023: 7/6/19: WID:SP-190253->SP-190442; 20/9/19: WID:SP-190442->SP-190625; 6/12/19: 0%->15; 25/3/20: WID:SP-190625->SP-200092; 25/3/20: 15%->35; 26/6/20: FCD:12/06/2020->09/20; 26/6/20: 35%->50; 12/9/20: 50%->65; 12/9/20: FCD:15/09/2020->12/20; 13/9/20: WID: / Impacted TSs and TRs: 23.757
- 2024: 23.501; 23.502; 23.503 ; 19/3/21: 0%->20; 14/6/21: 20%->75; 13/9/21: 75%->85; 10/12/21: 85%->95; 12/3/22: 95%->99; 4/6/22: 99%->100
- 2025: ; 13/9/21: 0%->45; 13/12/21: 45%->80; 12/3/22: 80%->95; 22/3/22: 24.575 added;; 22/3/22: WID:CP-212022->CP-220402; 4/6/22: 95%->97 / Impacted TSs and TRs: 24.501 ; 24.575
- 2026: ; 13/12/21: 0%->40; 13/12/21: WID:CP-212022->CP-213078; 12/3/22: WID:CP-213078->CP-220099; 12/3/22: 40%->65; 22/3/22: 29.580 added;; 4/6/22: 65%->85; 4/6/22: WID:CP-220402->CP-221084; 20/6/22: WID: eSEALCP-221084->CP-220402 / Impacted TSs and TRs: 29.561;29.525;29.522;29.521;29.520;29.519;29.514;29.513;29.512;29.508 ; 29.580
- 2027: UID in 91xx range but presented to CT#92; 2/7/21: 29.532 added;; 10/9/21: WID:CP-211093->CP-212022; 13/9/21: 0%->15; 13/12/21: 15%->75; 7/1/22: 29.537 added;; 12/3/22: 75%->80; 22/3/22: 29.581 added;; 20/6/22: Compl:80%->99% / Impacted TSs and TRs: 29.571;29.518;29.510;29.503;29.502;29.281;29.244;23.003 ; 29.532; 29.537; 29.581
- 2029: ; 12/3/22: 0%->95; 12/3/22: FCD:10/12/2021->6/22; 4/6/22: 95%->100 / Impacted TSs and TRs: 33.501
- 2030: ; 7/9/23: 0%->20; 7/9/23: 20%->30; 8/12/23: 30%->65; 3/1/24: WID:SP-230623->SP-231712; 14/3/24: 65%->100 / Impacted TSs and TRs: 32.240; 32.255; 32.298; 32.291; 33.279; 33.290
- 2031: ; 13/9/19: 0%->80; 20/9/19: FCD:19/09/2019->12/19; 6/12/19: 80%->100 / Impacted TSs and TRs: 22.261
- 2032: ; 12/3/22: 0%->40; 12/3/22: FCD:15/03/2022->6/22; 4/6/22: 40%->100 / Impacted TSs and TRs: 26.346; 26.347; 26.512
- 2033: affects: NR. no Perf. part; 5/4/22: WID:RP-193248->RP-220428
- 2034: affects: NR. no Perf. part; 28/7/20: WID:RP-193248->RP-201038 ;
- 2035: tested: REL-17 WI NR_MBS-Core, SA/CT REL-17 WI 5MBS, SA4 REL-17 WI 5MBUSA ; 6/6/22: Compl:0%->5% ; 20/6/22: Rapporteur: Huawei->Ya Zhao, Huawei Technologies. Co., Ltd; Rap eMail: ->zhaoya@hisilicon.com ...; 9/12/22: FCD:23/06/2023->01/06/2023; Compl...; 8/12/23: Compl:90%->100%; Stat Rep: RP-232352->RP-233760;
- 2036: 25/9/20: 23.289 added;; 5/12/20: 0%->30; 5/12/20: FCD:11/12/2020->03/20; 10/2/21: FCD:12/03/2021->06/21; 21/3/21: 30%->65 / Impacted TSs and TRs: 23.289
- 2037: 25/9/20: 23.289 added;; 5/12/20: 0%->30; 5/12/20: FCD:11/12/2020->03/20; 10/2/21: FCD:12/03/2021->06/21; 21/3/21: 30%->65; 11/6/21: 65%->100 / Impacted TSs and TRs: 23.289
- 2038: ; 13/12/21: 0%->25; 12/3/22: 25%->40; 4/6/22: 40%->100 / Impacted TSs and TRs: 24.582;24.581;24.484;24.483;24.481;24.380;24.379;24.282;24.281
- 2039: ; 26/3/20: 0%->15; 28/6/20: 15%->45; 13/9/20: 45%->70 / Impacted TSs and TRs: 23.280; 23.282
- 2040: ; 26/3/20: 0%->15; 28/6/20: 15%->45; 13/9/20: 45%->70; 5/12/20: 70%->85; 10/2/21: FCD:11/09/2020->06/21; 21/3/21: 85%->90; 11/6/21: 90%->100 / Impacted TSs and TRs: 23.280; 23.282
- 2041: 5/12/20: 0%->10; 21/3/21: 10%->40; 11/6/21: 40%->45; 13/9/21: 45%->50; 13/12/21: 50%->65; 12/3/22: FCD:15/09/2021->3/22; 12/3/22: 65%->97; 4/6/22: 97%->100
- 2042: ¦18/3/19: FCD:019->12/19¦18/3/19: WID:CP-183244->CP-190143; 13/9/19: 0%->5. 1/7/20: Rel-16->Rel-17 (comments during CT#88e presentation); 13/9/21: 5%->10; 13/12/21: 10%->30; 12/3/22: 30%->90; 12/3/22: FCD:12/12/2019->3/22; 4/6/22: 90%->100 / Impacted TSs and TRs: 24.379; 24.380; 24.282; 24.481; 24.483; 24.484; 24.482
- 2043: 5/12/20: 0%->60; 13/9/21: 60%->65 / Impacted TSs and TRs: 29.379; 29.380; 29.582
- 2044: Impacted TSs and TRs: 26.234; 26.247
- 2045: 25/3/20: WID:SP-191105->SP-200109; 26/3/20: 0%->20 / Impacted TSs and TRs: 23.222; 23.558
- 2046: 31/5/19: 0%->35; 13/9/19: 35%->70; 6/12/19: 70%->95; 26/3/20: 95%->100 / Impacted TSs and TRs: New
- 2047: 25/3/20: WID:SP-191105->SP-200109; 26/3/20: 0%->20; 28/6/20: 20%->50; 13/9/20: 50%->70; 13/9/20: WID:SP-200109->SP-200834; 13/9/20: FCD:11/09/2020->12/20; 25/9/20: WID:SP-200834->SP-200886; 5/12/20: 70%->85; 10/2/21: FCD:11/12/2020->06/21; 21/3/21: 85% / Impacted TSs and TRs: 23.222; 23.558

| ID | WBS | Task | Type | Duration | Start | Finish | Complete | Constraint | Resources | Work | Actual work | Acronym | PCG approved | WI rapporteur name | WI rapporteur e-mail | Release | TSG approved | Impacted TSs and TRs |
| --- | --- | --- | --- | --- | --- | --- | --- | --- | --- | --- | --- | --- | --- | --- | --- | --- | --- | --- |
| 2048 | 933.3 | **CT aspects for Enabling Edge Applications** |  | 567.38d | 2020-12-07 A | 2022-06-07 A | 100% |  |  | 8408.08h | 8408.08h | EDGEAPP | 46 | Narendranath Durga Tangudu | n.tangudu@samsung.com | Rel-17 | 90 |  |
| 2049 | 933.3.1 | CT1 aspects for EDGEAPP |  | 330d | 2020-12-07 A | 2022-03-11 A | 100% | finish no earlier than 2022-03-12 | C1 | 2640h | 2640h | EDGEAPP | 46 | Narendranath Durga Tangudu | n.tangudu@samsung.com | Rel-17 | 90 |  |
| 2050 | 933.3.2 | CT3 aspects for EDGEAPP |  | 330d | 2020-12-07 A | 2022-03-11 A | 100% | finish no earlier than 2022-03-12 | C3 | 2640h | 2640h | EDGEAPP | 46 | Narendranath Durga Tangudu | n.tangudu@samsung.com | Rel-17 | 90 |  |
| 2051 | 933.3.3 | CT4 aspects for EDGEAPP |  | 391.01d | 2020-12-07 A | 2022-06-07 A | 100% | finish no earlier than 2022-06-07 | C4 | 3128.08h | 3128.08h | EDGEAPP | 46 | Narendranath Durga Tangudu | n.tangudu@samsung.com | Rel-17 | 90 |  |
| 2052 | 934 | Study on enhancement of support for Edge Computing in 5GC |  | 463.88d | 2019-03-07 A | 2020-12-15 A | 100% | finish no earlier than 2020-12-15 | S2 | 3711h | 3711h | FS_enh_EC | 42 | Hui Ni, Huawei | Hui.ni@huawei.com | Rel-17 | 83 | New |
| 2053 | 935 | **Enhancement of support for Edge Computing in 5G Core network** |  | 480.38d | 2020-12-03 A | 2022-03-11 A | 100% |  |  | 10872h | 10872h | eEDGE_5GC | 46 | Hui Ni, Huawei Technologies | hui.ni@huawei.com | Rel-17 | 90 |  |
| 2054 | 935.1 | Stage 2 of eEDGE_5GC |  | 200d | 2020-12-03 A | 2021-09-08 A | 100% | finish no earlier than 2021-09-08 | S2 | 1600h | 1600h | eEDGE_5GC | 46 | Hui Ni, Huawei Technologies | hui.ni@huawei.com | Rel-17 | 90 |  |
| 2055 | 935.2 | **CT aspects of 5G eEDGE** |  | 371.62d | 2021-03-18 A | 2022-03-11 A | 100% |  | ct | 8224h | 8224h | eEDGE_5GC | 46 | Qi Caixia, Huawei | caixia.qi@huawei.com | Rel-17 | 91 |  |
| 2056 | 935.2.1 | CT1 aspects of 5G eEDGE |  | 257d | 2021-03-18 A | 2022-03-11 A | 100% | finish no earlier than 2022-03-12 | C1 | 2056h | 2056h | eEDGE_5GC | 46 | Qi Caixia, Huawei | caixia.qi@huawei.com | Rel-17 | 91 | 24.008; 24.501; 24.526; 27.007 |
| 2057 | 935.2.2 | CT3 aspects of 5G eEDGE |  | 257d | 2021-03-18 A | 2022-03-11 A | 100% | finish no earlier than 2022-03-12 | C3 | 2056h | 2056h | eEDGE_5GC | 46 | Qi Caixia, Huawei | caixia.qi@huawei.com | Rel-17 | 91 | 29.508; 29.512; 29.514; 29.513; 29.522; 29.519; 29.561 |
| 2058 | 935.2.3 | CT4 aspects of 5G eEDGE |  | 257d | 2021-03-18 A | 2022-03-11 A | 100% | finish no earlier than 2022-03-12 | C4 | 2056h | 2056h | eEDGE_5GC | 46 | Qi Caixia, Huawei | caixia.qi@huawei.com | Rel-17 | 91 | 29.244; 29.510; 29.502; 29.503; 29.505; 29.571; 29.564 |
| 2059 | 935.3 | Security Aspects of Enhancements of Support for Edge Computing in 5GC |  | 131d | 2021-06-11 A | 2021-12-10 A | 100% | finish no earlier than 2021-12-12 | S3 | 1048h | 1048h | eEDGE_5GC | 47 | Bo Zhang, Huawei Technologies | zhangbo6@huawei.com | Rel-17 | 92 | 33.501 ; 33.558 |
| 2060 | 936 | Edge Computing Management |  | 196d | 2021-06-11 A | 2022-03-11 A | 100% | finish no earlier than 2022-03-12 | S5 | 1568h | 1568h | ECM | 47 | Deepanshu Gautam, Samsung | deepanshu<dot>g<at>samsung<dot>com | Rel-17 | 92 | 28.532;28.531;28.554;28.552;28.541 |
| 2061 | 937 | Study on Security Aspects of Enhancement of Support for Edge Computing in 5GC |  | 391d | 2020-06-12 A | 2021-12-10 A | 100% | finish no earlier than 2021-12-12 | S3 | 3128h | 3128h | FS_eEDGE_Sec | 45 | Bo Zhang, Huawei Technologies | zhangbo6@huawei.com | Rel-17 | 88 | 33.839 |
| 2062 | 938 | Edge Extensions to 5GMS Stage 3 |  | 131d | 2021-12-10 A | 2022-06-10 A | 100% | finish no earlier than 2022-06-12 | S4 | 1048h | 1048h | 5GMS_EDGE_3 | 48 | Bouazizi, Imed, Qualcomm Inc. | bouazizi@qti.qualcomm.com | Rel-17 | 94 | 26.512; |
| 2063 | 939 | **Charging aspects of Edge Computing** |  | 647.12d | 2020-06-25 A | 2022-03-11 A | 100% |  | S5 | 7680h | 7680h | EDGE_CH | 47 | Yao, Yizhi, Intel | yizhi<dot>yao<at>intel<dot>com | Rel-17 | 93 | 32.240; 32.291; 32.298; 32.297 ; 32.257 |
| 2064 | 939.1 | Study on charging aspects of Edge Computing |  | 382d | 2020-06-25 A | 2021-12-10 A | 100% | finish no earlier than 2021-12-12 | S5 | 3056h | 3056h | FS_EDGE_CH | 45 | Yizhi Yao, Intel | yizhi<dot>yao<at>intel<dot>com | Rel-17 | 88 | 28.815 |
| 2065 | 939.2 | Charging aspects of Edge Computing |  | 131d | 2021-09-10 A | 2022-03-11 A | 100% | finish no earlier than 2022-03-12 | S5 | 1048h | 1048h | EDGE_CH | 47 | Yao, Yizhi, Intel | yizhi<dot>yao<at>intel<dot>com | Rel-17 | 93 | 32.240; 32.291; 32.298; 32.297 |
| 2066 | 940 | Study on enhancements of edge computing management |  | 381d | 2020-03-25 A | 2021-09-08 A | 100% | finish no earlier than 2021-09-08 | S5 | 3048h | 3048h | FS_eEDGE_Mgt | 44 | Joey Chou, Intel | joey<dot>chou<at>intel<dot>com | Rel-17 | 87 | New |
| 2067 | 941 | Rel-17 Slicing | milestone, manual | 0d | 2016-06-09 A | 2016-06-09 A | 100% | finish no earlier than 2016-06-09 |  |  |  |  |  |  |  | Rel-17 |  | 26.234; 26.247 |
| 2068 | 942 | **Rel-17 Enhancements of 3GPP Northbound Interfaces and Application Layer APIs** |  | 283.62d | 2021-06-11 A | 2022-03-11 A | 100% |  |  | 4704h | 4704h | NBI17 | 47 | Abdessamad El Moatamid, Huawei | abdessamad.el.moatamid@huawei.com | Rel-17 | 92 |  |
| 2069 | 942.1 | CT1 aspects of NBI17 |  | 196d | 2021-06-11 A | 2022-03-11 A | 100% | finish no earlier than 2022-03-12 | C1 | 1568h | 1568h | NBI17 | 47 | Abdessamad El Moatamid, Huawei | abdessamad.el.moatamid@huawei.com | Rel-17 | 92 | 24.558 |
| 2070 | 942.2 | CT3 aspects of NBI17 |  | 196d | 2021-06-11 A | 2022-03-11 A | 100% | finish no earlier than 2023-03-12 | C3 | 1568h | 1568h | NBI17 | 47 | Abdessamad El Moatamid, Huawei | abdessamad.el.moatamid@huawei.com | Rel-17 | 92 | 29.558;29.549;29.522;29.486;29.343;29.222;29.122;29.116 |
| 2071 | 942.3 | CT4 aspects of NBI17 |  | 196d | 2021-06-11 A | 2022-03-11 A | 100% | finish no earlier than 2022-03-12 | C4 | 1568h | 1568h | NBI17 | 47 | Abdessamad El Moatamid, Huawei | abdessamad.el.moatamid@huawei.com | Rel-17 | 92 | 29.518;29.503;29.272;29.336;29.571 |
| 2072 | 943 | Enhancement of 5G PCC related services in Rel-17 |  | 196d | 2021-06-11 A | 2022-03-11 A | 100% | finish no earlier than 2022-03-12 | C3 | 1568h | 1568h | en5GPccSer17 | 47 | Xiaoyun Zhou, Huawei | zhouxiaoyun8@huawei.com | Rel-17 | 92 | 29.214;29.519;29.594;29.521;29.514;29.513;29.512 |

Notes:
- 2048: 29.222 ; 11/6/21: WID:CP-203106->CP-211196
- 2049: 29.222 ; 21/3/21: 0%->5; 11/6/21: 5%->30; 13/9/21: 30%->55; 13/12/21: 55%->68; 12/3/22: FCD:10/09/2021->3/22; 12/3/22: 68%->85; 4/6/22: 85%->99; 4/6/22: WID:CP-211196->CP-221106
- 2050: 29.222 ; 21/3/21: 0%->20; 11/6/21: FCD:Fri 10/09/->12/21; 11/6/21: 20%->50; 13/9/21: 50%->60; 13/12/21: 60%->75; 12/3/22: FCD:10/12/2021->3/22; 12/3/22: 75%->90
- 2051: CT4 chair input (07/06/2022); 3/8/22: 0%->100
- 2052: 6/12/19: 0%->20; 25/3/20: WID:SP-190185->SP-200093; 25/3/20: FCD:05/03/2020->06/20; 25/3/20: 20%->40; 26/6/20: FCD:15/06/2020->09/20; 26/6/20: 40%->60; 12/9/20: 60%->70; 12/9/20: FCD:11/09/2020->12/20; 5/12/20: 70%->100
- 2053: 23.501; 23.502; 23.503
- 2054: 23.501; 23.502; 23.503 ; 19/3/21: 0%->35; 11/6/21: 35%->75; 11/6/21: FCD:Fri 11/06/->09/21; 13/9/21: 75%->95; 10/12/21: 95%->100
- 2055: 10/9/21: WID:CP-211092->CP-212021
- 2056: 11/6/21: 0%->40; 13/9/21: 40%->65; 13/12/21: 65%->85; 12/3/22: 85%->95; 4/6/22: 95%->100
- 2057: 11/6/21: 0%->40; 11/6/21: WID:CP-210284->CP-211092; 13/9/21: 40%->65; 13/12/21: 65%->85; 12/3/22: 85%->100
- 2058: 11/6/21: 0%->25; 13/9/21: 25%->45; 1/10/21: 29.564 added;; 13/12/21: 45%->80; 12/3/22: 80%->98; 4/6/22: 98%->100
- 2059: ; 13/9/21: 0%->30; 1/10/21: 33.558 added;; 13/12/21: 30%->50; 12/3/22: 50%->100
- 2060: ; 13/9/21: 0%->10; 13/12/21: 10%->50; 12/3/22: 50%->90; 4/6/22: 90%->100
- 2061: 12/9/20: 0%->15; 5/12/20: 15%->50; 19/3/21: FCD:25/03/2021->06/21; 19/3/21: 50%->60; 11/6/21: 60%->75; 11/6/21: FCD:Fri 11/06/->12/21; 13/9/21: 75%->85; 12/3/22: 85%->100
- 2062: ; 12/3/22: 0%->60; 12/3/22: FCD:11/03/2022->6/22; 4/6/22: 60%->100
- 2063: ; 22/3/22: 32.257 added;
- 2064: 5/12/20: 0%->30; 21/3/21: 30%->60; 21/3/21: FCD:19/03/2021->09/21; 13/9/21: 60%->90; 13/9/21: FCD:Wed 08/09/->12/21; 21/6/22: 90%->100
- 2065: ; 12/3/22: 0%->70; 4/6/22: 70%->100
- 2066: 13/9/20: 0%->15; 5/12/20: 15%->25; 5/12/20: FCD:17/12/2020->03/20; 21/3/21: 25%->75; 11/6/21: 75%->90; 11/6/21: FCD:Fri 12/03/->09/21; 13/9/21: 90%->100
- 2068: 01/22: Rapp changed from yanyali@huawei.com ; 28/4/22: WID:CP-211197->CP-220058
- 2069: ; 13/9/21: 0%->85; 13/12/21: 85%->95; 12/3/22: 95%->99; 4/6/22: 99%->100; 20/6/22: WID: CP-220058->CP-211197
- 2070: ; 11/6/21: 0%->35; 13/9/21: 35%->65; 13/12/21: 65%->85; 13/12/21: WID:CP-211197->CP-213262; 12/3/22: 85%->100; 12/3/22: FCD:10/03/2023->3/22
- 2071: ; 12/3/22: 0%->100
- 2072: ; 11/6/21: 0%->20; 13/9/21: 20%->35; 13/12/21: 35%->70; 12/3/22: 70%->100

| ID | WBS | Task | Type | Duration | Start | Finish | Complete | Constraint | Resources | Work | Actual work | Acronym | PCG approved | WI rapporteur name | WI rapporteur e-mail | Release | TSG approved | Impacted TSs and TRs | Status Report |
| --- | --- | --- | --- | --- | --- | --- | --- | --- | --- | --- | --- | --- | --- | --- | --- | --- | --- | --- | --- |
| 2073 | 944 | **Enhancement of Network Slicing Phase 2** |  | 1405.38d | 2019-09-19 A | 2023-06-06 A | 100% |  |  | 18064h | 18064h | eNS_Ph2 | 46 | ZTE, Jinguo Zhu | Zhu dot Jinguo at zte dot com dot cn | Rel-17 | 90 |  |  |
| 2074 | 944.1 | Study on Enhancement of Network Slicing Phase 2 |  | 387d | 2019-09-19 A | 2021-03-12 A | 100% | finish no earlier than 2021-03-12 | S2 | 3096h | 3096h | FS_eNS_Ph2 | 43 | So, Tricci, ZTE | tso@ztetx.com | Rel-17 | 85 | New ; 23.700-40 |  |
| 2075 | 944.2 | Stage 2 for Enhancement of Network Slicing Phase 2 |  | 200d | 2020-12-03 A | 2021-09-08 A | 100% | finish no earlier than 2021-09-08 | S2 | 1600h | 1600h | eNS_Ph2 | 46 | ZTE, Jinguo Zhu | Zhu dot Jinguo at zte dot com dot cn | Rel-17 | 90 |  |  |
| 2076 | 944.3 | **Stage 3 for Enhancement of Network Slicing Phase 2** |  | 839.88d | 2021-03-18 A | 2023-06-06 A | 100% |  | ct | 13368h | 13368h | eNS_Ph2 | 46 | Hannah Wang, ZTE | wang.menghan@zte.com.cn | Rel-17 | 91 |  |  |
| 2077 | 944.3.1 | CT1 aspects of eNS_Ph2 |  | 257d | 2021-03-18 A | 2022-03-11 A | 100% | finish no earlier than 2022-03-12 | C1 | 2056h | 2056h | eNS_Ph2 | 46 | Hannah Wang, ZTE | wang.menghan@zte.com.cn | Rel-17 | 91 | 24.501 |  |
| 2078 | 944.3.2 | CT3 aspects of eNS_Ph2 |  | 257d | 2021-03-18 A | 2022-03-11 A | 100% | finish no earlier than 2022-03-12 | C3 | 2056h | 2056h | eNS_Ph2 | 46 | Hannah Wang, ZTE | wang.menghan@zte.com.cn | Rel-17 | 91 | 29.522 |  |
| 2079 | 944.3.3 | CT4 aspects of eNS_Ph2 |  | 257d | 2021-03-18 A | 2022-03-11 A | 100% | finish no earlier than 2022-03-12 | C4 | 2056h | 2056h | eNS_Ph2 | 46 | Hannah Wang, ZTE | wang.menghan@zte.com.cn | Rel-17 | 91 | 29.510; 29.518; 29.502; 29.524 |  |
| 2080 | 944.3.4 | UE Conformance - Enhancement of Network Slicing Phase 2 |  | 321d | 2022-03-15 A | 2023-06-06 A | 100% | finish no earlier than 2023-06-06 | R5 | 2568h | 2568h | eNS_Ph2-UEConTest | 48 | Danni Song, Xiaozhong Chen, CMCC, CATT | songdan@chinamobile.com, chenxiaozhong@catt.cn | Rel-17 | 95 |  | RP-230286 |
| 2081 | 945 | **Enhancement of RAN slicing for NR** |  | 1720d | 2019-03-07 A | 2023-09-22 A | 100% |  | R2 | 10744h | 10744h | NR_slice | 46 | CMCC |  | Rel-17 | 91 |  |  |
| 2082 | 945.1 | Core part: Enhancement of RAN slicing for NR |  | 334d | 2021-03-12 A | 2022-06-22 A | 100% | finish no earlier than 2022-06-22 | R2 | 2672h | 2672h | NR_slice-Core | 46 | Ningyu Chen, CMCC | chenningyu@chinamobile.com | Rel-17 | 91 |  | RP-221375 |
| 2083 | 945.2 | UE Conformance - Enhancement of RAN slicing for NR |  | 334d | 2022-06-15 A | 2023-09-22 A | 100% | finish no earlier than 2023-09-22 | R5 | 2672h | 2672h | NR_slice-UEConTest | 49 | Danni Song, CMCC | songdan@chinamobile.com | Rel-17 | 96 |  | RP-232242 |
| 2084 | 945.3 | CT1 aspects of enhancement of RAN Slicing for NR |  | 12d | 2022-06-03 A | 2022-06-20 A | 100% | finish no earlier than 2022-06-20 | C1 | 96h | 96h | NRslice | 49 | Chen Xu, China Mobile | chenxu@chinamobile.com | Rel-17 | 96 | 24.501; 29.531; 29.571 |  |
| 2085 | 945.4 | CT4 aspects on enhancement of RAN slicing for NR |  | 1d | 2019-03-07 A | 2019-03-07 A | 100% | finish no earlier than 2019-03-07 | C4 | 8h | 8h | NRslice | 49 | Chen Xu, China Mobile | chenxu@chinamobile.com | Rel-17 | 96 | 24.501; 29.531; 29.571 |  |
| 2086 | 946 | Study on network slice management enhancement |  | 526d | 2019-12-06 A | 2021-12-10 A | 100% | finish no earlier than 2021-12-12 | S5 | 4208h | 4208h | FS_NSMEN | 44 | Brendan Hassett, Huawei Technologies Sweden AB, | brendan.t.hassett@huawei.com | Rel-17 | 86 |  |  |
| 2087 | 947 | Network Slice charging based on 5G Data Connectivity |  | 2d | 2022-03-10 A | 2022-03-11 A | 100% | finish no earlier than 2022-03-12 | S5 | 16h | 16h | NETSLICE_DC_CH | 48 | MATRIXX Software, Gerald Görmer | Gerald dot Goermer at Matrixx dot com | Rel-17 | 95 | 32.255 |  |
| 2088 | 948 | Rel-17 Multi-(U)SIM | milestone, manual | 0d | 2016-06-09 A | 2016-06-09 A | 100% | finish no earlier than 2016-06-09 |  |  |  |  |  |  |  | Rel-17 |  | 26.234; 26.247 |  |
| 2089 | 949 | **Support for Multi-USIM Devices** |  | 1140.12d? | 2019-03-07 A | 2022-03-11 A | 100% |  |  | 16247h | 16247h | MUSIM | 43 | Liao, Ellen C, Intel | ellen.c.liao@intel.com | Rel-17 | 84 | 22.261; 22.278; 22.101 |  |
| 2090 | 949.1 | Study on MUSIM |  | 130.88d? | 2019-03-07 A | 2019-09-06 A | 100% | finish no later than 2019-09-12 | S1 | 1047.04h | 1047.04h | FS_MUSIM | 42 | Liao, Ellen C, Intel | ellen.c.liao@intel.com | Rel-17 | 83 | New |  |
| 2091 | 949.2 | Stage 1 of MUSIM |  | 136d | 2019-06-06 A | 2019-12-12 A | 100% | finish no earlier than 2019-12-12 | S1 | 1088h | 1088h | MUSIM | 43 | Liao, Ellen C, Intel | ellen.c.liao@intel.com | Rel-17 | 84 | 22.261; 22.278; 22.101 |  |
| 2092 | 949.3 | Study on Stage 2 (System Enablers) for MUSIM |  | 527d | 2019-03-07 A | 2021-03-12 A | 100% | finish no earlier than 2021-03-12 | S2 | 4216h | 4216h | FS_MUSIM | 42 | Sašo Stojanovski, Intel | saso stojanovski intel com) | Rel-17 | 82 | 23.761 |  |
| 2093 | 949.4 | System enablers for Multi-USIM devices |  | 200d | 2020-12-03 A | 2021-09-08 A | 100% | finish no earlier than 2021-09-08 | S2 | 1600h | 1600h | MUSIM | 46 | Sašo Stojanovski, Intel | saso stojanovski intel com | Rel-17 | 90 |  |  |
| 2094 | 949.5 | **CT aspects of MUSIM** |  | 371.62d | 2021-03-18 A | 2022-03-11 A | 100% |  | ct | 6168h | 6168h | MUSIM | 46 | Thomas Luetzenkirchen, Intel | thomas.luetzenkirchen@intel.com | Rel-17 | 91 | 24.501; 24.301; 27.007; 29.274 |  |
| 2095 | 949.5.1 | CT1 aspects of Enabling Multi-USIM Devices |  | 257d | 2021-03-18 A | 2022-03-11 A | 100% | finish no earlier than 2022-03-12 | C1 | 2056h | 2056h | MUSIM | 46 | Thomas Luetzenkirchen, Intel | thomas.luetzenkirchen@intel.com | Rel-17 | 91 |  |  |
| 2096 | 949.5.2 | CT4 aspects of Enabling Multi-USIM Devices |  | 257d | 2021-03-18 A | 2022-03-11 A | 100% | finish no earlier than 2022-03-12 | C4 | 2056h | 2056h | MUSIM | 46 | Thomas Luetzenkirchen, Intel | thomas.luetzenkirchen@intel.com | Rel-17 | 91 |  |  |
| 2097 | 949.6 | Study on the security of the system enablers for devices having multiple Universal Subscriber Identity Modules (USIM) |  | 266d | 2020-12-04 A | 2021-12-10 A | 100% | finish no earlier than 2021-12-12 | S3 | 2128h | 2128h | FS_MUSIM_SEC | 46 | Abhijeet Kolekar, Intel Corporation | abhijeet.kolekar@intel.com | Rel-17 | 90 | 33.873 |  |

Notes:
- 2073: 23.501; 23.502; 23.503
- 2074: ; 8/10/19: 23.700-40 added;; 6/12/19: 0%->15; 25/3/20: 15%->35; 26/6/20: FCD:12/03/2020->09/20; 26/6/20: 35%->55; 12/9/20: 55%->75; 12/9/20: FCD:15/09/2020->12/20; 5/12/20: 75%->90; 5/12/20: FCD:15/12/2020->03/20; 19/3/21: 90%->100
- 2075: 23.501; 23.502; 23.503 ; 19/3/21: 0%->5; 14/6/21: 5%->85; 14/6/21: FCD:Fri 11/06/->09/21; 13/9/21: 85%->97; 10/12/21: 97%->99; 22/3/22: 99%->100
- 2076: 1/10/21: WID:CP-210288->CP-211091
- 2077: 11/6/21: 0%->30; 13/9/21: 30%->45; 13/12/21: 45%->80; 12/3/22: 80%->100
- 2078: 11/6/21: 0%->30; 13/9/21: 30%->40; 13/12/21: 40%->80; 12/3/22: 80%->96; 4/6/22: 96%->100
- 2079: 11/6/21: 0%->30; 13/9/21: 30%->45; 1/10/21: WID:CP-210288->CP-211091; 13/12/21: 45%->80; 12/3/22: 80%->100
- 2080: tested: SA/CT REL-17 WI eNS_Ph2 (note: This WI is not testing NR_slice-Core) 6/6/22: Compl:0%->10% ; ; 20/6/22: Rapporteur: CMCC->Luting Kong, Xiaozhong Chen, CMCC, CATT; Rap eMail: ->kongluting@chinamobile.com, chenxiaozhong@catt.cn ; ;...; 9/12/22:...; ; ; ; ; ; ; ; ; ; ; ; ; ; ; ; ; ; ; ; ; 7/6/23: Compl:87%->100%
- 2081: follow-up WI of RAN2 REL-17 SI FS_NR_slice; no Perf. part ; 2/7/21: WID:RP-210912->RP-211290; 29/9/21: WID:RP-211290->RP-212534; 12/7/22: WID:RP-212534->RP-221377
- 2082: follow-up WI of RAN2 REL-17 SI FS_NR_slice; no Perf. part ; 20/6/22: FCD:12/03/2022->22/06/2022; Compl:0%->100%; Stat Rep: ->RP-221375; Rapporteur: CMCC->Ningyu Chen, CMCC; Rap eMail: ->chenningyu@chinamobile.com;
- 2083: 9/9/22: Comp...; 23/9/22: WID:RP-221364->RP-222118; 9/12/22: FCD:22/09/2022->01/09/2023; Compl:12%->13%; Stat Rep: ->RP-223068; Rapporteur: CMCC->Danni Song, CMCC; Rap eMail: ->songdan@chinamobile.com; 9/1/23: WID:RP-222118->RP-223067; 17...; 6/9/23: FCD:09/09/2023->22/09/2023; Compl:91%->100%; Stat Rep: RP-230287->RP-232242;
- 2084: ; 4/6/22: 0%->100
- 2085: ; 4/6/22: 0%->100; 3/8/22: 99%->100
- 2086: 13/9/20: 0%->5; 13/9/20: WID:SP-191192->SP-200766; 5/12/20: 5%->20; 21/3/21: 20%->40; 11/6/21: 40%->80; 11/6/21: FCD:Fri 11/06/->09/21; 13/9/21: 80%->90; 13/9/21: FCD:Wed 08/09/->12/21; 13/12/21: 90%->100
- 2087: ; 12/3/22: 0%->100
- 2090: 14/3/19: 0%->5; 31/5/19: 5%->95; 13/9/19: 95%->98; 6/12/19: 98%->100
- 2091: 13/9/19: 0%->50; 6/12/19: 50%->100
- 2092: 21/3/19: WID:SP-181251->SP-190248; 6/12/19: 0%->29; 25/3/20: WID:SP-190248->SP-200297; 25/3/20: 29%->45; 26/6/20: FCD:11/06/2020->09/20; 26/6/20: 45%->60; 12/9/20: 60%->80; 12/9/20: FCD:15/09/2020->12/20; 5/12/20: 80%->90; 5/12/20: FCD:15/12/2020->03/2
- 2093: 23.501; 23.502; 23.401; 23.228 ; 19/3/21: 0%->20; 13/6/21: WID:SP-200978->SP-210091; 14/6/21: 20%->90; 14/6/21: FCD:Fri 11/06/->09/21; 13/9/21: 90%->98; 10/12/21: 98%->100
- 2094: ; 10/9/21: WID:CP-210280->CP-212102; 01/22: rapporteur changed from Vivek Gupta
- 2095: ; 11/6/21: 0%->40; 13/9/21: 40%->65; 13/12/21: 65%->90; 12/3/22: 90%->100
- 2096: ; 11/6/21: 0%->40; 13/12/21: 40%->90; 12/3/22: 90%->100
- 2097: 5/12/20: 0%->10; 10/2/21: 33.873 added;; 19/3/21: 10%->35; 19/3/21: FCD:12/03/2021->06/21; 11/6/21: 35%->96; 11/6/21: FCD:Fri 11/06/->12/21; 13/9/21: 96%->100

| ID | WBS | Task | Type | Duration | Start | Finish | Complete | Constraint | Resources | Work | Actual work | Acronym | PCG approved | WI rapporteur name | Release | TSG approved | WI rapporteur e-mail | Status Report | Impacted TSs and TRs |
| --- | --- | --- | --- | --- | --- | --- | --- | --- | --- | --- | --- | --- | --- | --- | --- | --- | --- | --- | --- |
| 2098 | 950 | **Support for Multi-SIM devices for LTE/NR** |  | 1433d | 2019-12-09 A | 2023-09-22 A | 100% |  |  | 7976h | 7976h | LTE_NR_MUSIM | 44 | Vivo | Rel-17 | 86 |  |  |  |
| 2099 | 950.1 | Core part: Support for Multi-SIM devices for LTE/NR |  | 597d | 2019-12-09 A | 2022-03-22 A | 100% | finish no earlier than 2022-03-22 | R2 | 4776h | 4776h | LTE_NR_MUSIM-Core | 44 | Xiaodong Yang | Rel-17 | 86 | Yangxiaodong5g@vivo.com | RP-220603 |  |
| 2100 | 950.2 | UE Conformance - Multi-SIM devices for LTE/NR |  | 400d | 2022-03-15 A | 2023-09-22 A | 100% | finish no earlier than 2023-09-22 | R5 | 3200h | 3200h | LTE_NR_MUSIM_plus_CT1-UEConTest | 48 | Jing Zhao, China telecom | Rel-17 | 95 | Zhaoj16@chinatelecom.cn | RP-231824 |  |
| 2101 | 951 | Rel-17 other cross-TSG Features | milestone, manual | 0d | 2016-06-09 A | 2016-06-09 A | 100% | finish no earlier than 2016-06-09 |  |  |  |  |  |  | Rel-17 |  |  |  | 26.234; 26.247 |
| 2102 | 952 | **Support of the 5GMSG Service** |  | 951.75d | 2019-06-06 A | 2021-12-10 A | 100% |  |  | 6288h | 6288h | FS_5GMARCH | 43 | Liu, Yue, China Mobile | Rel-17 | 84 | liuyueyjy@chinamobile.com |  | 23.700-24 |
| 2103 | 952.1 | Study on support of the 5GMSG Service |  | 397d | 2019-06-06 A | 2020-12-11 A | 100% | finish no earlier than 2020-12-12 | S6 | 3176h | 3176h | FS_5GMARCH | 43 | Liu, Yue, China Mobile | Rel-17 | 84 | liuyueyjy@chinamobile.com |  | 23.700-24 |
| 2104 | 952.2 | Study on security aspects of the 5GMSG Service (St1 in Rel16) |  | 323d | 2020-09-16 A | 2021-12-10 A | 100% | finish no earlier than 2021-12-12 | S3 | 2584h | 2584h | FS_SEC_5GMSG | 45 | Xiaoting Huang, China Mobile | Rel-17 | 89 | huangxiaoting@chinamobile.com |  | 33.862 |
| 2105 | 952.3 | Security aspects of the 5GMSG Service |  | 66d | 2021-09-10 A | 2021-12-10 A | 100% | finish no earlier than 2021-12-12 | S3 | 528h | 528h | 5GMSG | 47 | Xiaoting Huang, China Mobile | Rel-17 | 93 | huangxiaoting@chinamobile.com |  | 33.501 |
| 2106 | 953 | **Application Architecture for MSGin5G Service** |  | 561.12d | 2020-09-16 A | 2022-03-11 A | 100% |  |  | 4704h | 4704h | 5GMARCH | 45 | Liu, Yue, China Mobile | Rel-17 | 89 | liuyueyjy@chinamobile.com |  | 23.554 |
| 2107 | 953.1 | Application Architecture for MSGin5G Service |  | 195d | 2020-09-16 A | 2021-06-15 A | 100% | finish no earlier than 2021-06-15 | S6 | 1560h | 1560h | 5GMARCH | 45 | Liu, Yue, China Mobile | Rel-17 | 89 | liuyueyjy@chinamobile.com |  | 23.554 |
| 2108 | 953.2 | **CT aspects for enabling MSGin5G Service** |  | 189.38d | 2021-09-10 A | 2022-03-11 A | 100% |  | ct | 3144h | 3144h | 5GMARCH | 47 | Liu, Yue, China Mobile | Rel-17 | 93 | liuyueyjy@chinamobile.com |  | 29.222 |
| 2109 | 953.2.1 | CT1 aspects for enabling MSGin5G Service |  | 131d | 2021-09-10 A | 2022-03-11 A | 100% | finish no earlier than 2022-03-12 | C1 | 1048h | 1048h | 5GMARCH | 47 | Liu, Yue, China Mobile | Rel-17 | 93 | liuyueyjy@chinamobile.com |  | 24.538 |
| 2110 | 953.2.2 | CT3 aspects for enabling MSGin5G Service |  | 131d | 2021-09-10 A | 2022-03-11 A | 100% | finish no earlier than 2022-03-12 | C3 | 1048h | 1048h | 5GMARCH | 47 | Liu, Yue, China Mobile | Rel-17 | 93 | liuyueyjy@chinamobile.com |  | 29.538 |
| 2111 | 954 | **IMS voice service support and network usability guarantee for UE s E-UTRA capability disabled scenario in SA 5GS** |  | 1016.5d | 2021-09-29 A | 2024-06-06 A | 100% |  | ct | 9640h | 9640h | ING_5GS | 47 | Mingxue Li, China Telecom | Rel-17 | 93 | limx36@chinatelecom.cn |  |  |
| 2112 | 954.1 | CT1 aspects of ING_5GS |  | 118d | 2021-09-29 A | 2022-03-11 A | 100% | finish no earlier than 2022-03-12 | C1 | 944h | 944h | ING_5GS | 47 | Mingxue Li, China Telecom | Rel-17 | 93 | limx36@chinatelecom.cn |  | 24.301; 24.368; 24.501 |
| 2113 | 954.2 | CT6 aspects of ING_5GS |  | 118d | 2021-09-29 A | 2022-03-11 A | 100% | finish no earlier than 2022-03-12 | C6 | 944h | 944h | ING_5GS | 47 | Mingxue Li, China Telecom | Rel-17 | 93 | limx36@chinatelecom.cn |  | 31.102 |
| 2114 | 954.3 | UE Conformance - ING_5GS |  | 264d | 2023-06-08 A | 2024-06-06 A | 100% | finish no earlier than 2024-06-06 | R5 | 2112h | 2112h | ING_5GS-UEConTest | 51 | Jing Zhao, China telecom | Rel-17 | 100 | Zhaoj16@chinatelecom.cn | RP-240910 |  |
| 2115 | 955 | **User Consent for 3GPP services** |  | 654.38d | 2020-09-16 A | 2022-06-09 A | 100% |  |  | 5192h | 5192h | UC3S | 45 | Rong Wu, Huawei Technologies | Rel-17 | 89 | raina.wu@huawei.com |  | 33.867 |
| 2116 | 955.1 | Study on User Consent for 3GPP services |  | 453d | 2020-09-16 A | 2022-06-09 A | 100% | finish no earlier than 2022-06-12 | S3 | 3624h | 3624h | FS_UC3S | 45 | Rong Wu, Huawei Technologies | Rel-17 | 89 | raina.wu@huawei.com |  | 33.867 |
| 2117 | 955.2 | Security aspects on User Consent for 3GPP services |  | 196d | 2021-09-10 A | 2022-06-09 A | 100% | finish no earlier than 2022-06-12 | S3 | 1568h | 1568h | UC3S_SEC | 47 | Rong Wu, Huawei Technologies | Rel-17 | 93 | Raina.wu@huawei.com |  | 33.501 |
| 2118 | 956 | User Plane Integrity Protection for LTE |  | 192d | 2021-03-18 A | 2021-12-10 A | 100% | finish no earlier than 2021-12-12 | S3 | 1536h | 1536h | UPIP_SEC_LTE | 46 | Evans, Tim, Vodafone | Rel-17 | 91 | tim.evans1@vodafone.com |  | 33.401; 33.501 |
| 2119 | 957 | **User Plane Integrity Protection support for EPC connected architectures** |  | 838.62d | 2021-12-13 A | 2024-03-01 A | 100% |  | R3 | 8328h | 8328h | UPIP_SEC_LTE-RAN | 48 | Vodafone | Rel-17 | 94 |  |  |  |
| 2120 | 957.1 | Core part: User Plane Integrity Protection support for EPC connected architectures |  | 72d | 2021-12-13 A | 2022-03-22 A | 100% | start no earlier than 2021-12-12 | R3 | 576h | 576h | UPIP_SEC_LTE-RAN-Core | 48 | Vodafone | Rel-17 | 94 |  |  |  |
| 2121 | 957.2 | UE Conformance - User Plane Integrity Protection support for EPC connected architectures (incl. CT/SA aspects) |  | 388d | 2022-09-08 A | 2024-03-01 A | 100% | finish no earlier than 2024-03-01 | R5 | 3104h | 3104h | UPIP_SEC_LTE-RAN-UEConTest | 49 | Petra RAUER, Vodafone | Rel-17 | 97 | Petra[dot]Rauer[at]Vodafone[dot]com | RP-240047 |  |
| 2122 | 958 | Start of Pause of Charging via User Plane |  | 62d | 2021-03-18 A | 2021-06-11 A | 100% | finish no earlier than 2021-06-12 | C4 | 496h | 496h | SPOCUP | 46 | YONG, YANG, Ericsson, frank | Rel-17 | 91 | yong.yang@ericsson.com |  | 29.244; 29.060; 29.281; 29.274; 29.502 |
| 2123 | 959 | NPN support of PWS | milestone | 0d | 2021-06-12 A | 2021-06-12 A | 100% | finish no earlier than 2021-06-12 | S1 |  |  | NPN_PWS | 47 | Francesco Pica, Qualcomm | Rel-17 | 92 | fpica <at> qti.qualcomm.com |  | 22.261 |

Notes:
- 2098: 28/7/20: WID:RP-193263->RP-201309. 6/1/21: WID:RP-193263->RP-202895; 7/4/21: WID:RP-202895->RP-210316; 2/7/21: WID:RP-210316->RP-211561; 29/9/21: WID:RP-211561->RP-212610; 6/1/22: WID:RP-212610->RP-213679
- 2099: 20/6/22: FCD:17/06/2021->22/03/2023; Compl:0%->100%; Stat Rep: ->RP-220603; Rapporteur: Vivo->Xiaodong Yang; Rap eMail: ->Yangxiaodong5g@vivo.com20/6/22: 0%->100
- 2100: tested: REL-17 WI LTE_NR_MUSIM-Core and REL-17 CT1 WI MUSIM 6/6/22: Compl:0%->5% 6/6/ ; 20/6/22: Rapporteur: China Telecom->Jing Zhao, China telecom; Rap eMail: ->Zhaoj16@chinatelecom.cn12/7/22: WID:RP-220127->RP-221193; 23/9/22: 5%->25; 23/9/22: FCD:...; 6/9/23: FCD:09/09/2023->22/09/2023; Compl:99%->100%; Stat Rep: RP-230076->RP-231824;
- 2102: 13/9/19: 0%->20; 8/10/19: 23.700-24 added;; 6/12/19: 20%->35; 26/3/20: 35%->40; 28/6/20: 40%->50; 13/9/20: 50%->65; 13/9/20: WID:SP-190559->SP-200835; 13/9/20: FCD:12/06/2020->12/20; 5/12/20: 65%->80; 21/3/21: 80%->95; 11/6/21: 95%->100
- 2103: 13/9/19: 0%->20; 8/10/19: 23.700-24 added;; 6/12/19: 20%->35; 26/3/20: 35%->40; 28/6/20: 40%->50; 13/9/20: 50%->65; 13/9/20: WID:SP-190559->SP-200835; 13/9/20: FCD:12/06/2020->12/20; 5/12/20: 65%->80; 21/3/21: 80%->95; 11/6/21: 95%->100
- 2104: 25/9/20: WID:SP-200717->SP-200878; 5/12/20: 0%->10; 19/3/21: 10%->40; 11/6/21: 40%->45; 11/6/21: FCD:Fri 11/06/->12/21; 13/9/21: 45%->75; 12/3/22: 75%->100
- 2105: ; 12/3/22: 0%->100
- 2106: Stage 1 in Rel-16, UID 810014
- 2107: 25/9/20: 23.554 added;; 5/12/20: 0%->5; 10/2/21: FCD:12/03/2021->06/21; 21/3/21: 5%->25; 11/6/21: 25%->75; 13/9/21: 75%->90; 13/12/21: 90%->100
- 2109: ; 1/10/21: 24.538 added;; 13/12/21: 0%->30; 12/3/22: 30%->75; 4/6/22: 75%->100
- 2110: ; 1/10/21: 29.538 added;; 13/12/21: 0%->30; 12/3/22: 30%->100
- 2112: 13/12/21: 0%->85; 12/3/22: 85%->100
- 2113: 12/3/22: 0%->100; 4/6/22: 100%->
- 2114: 6/9/23: FCD:06/06/2024->03/03/2024; Compl:0%->5%; Stat Rep: ->RP-231826; Rapporteur: China Telecom->Jing Zhao, China telecom; Rap eMail: ->Zhaoj16@chinatelecom.cn; ; 14/3/24: FCD:03/03/2024->06/06/2024; Compl:5%->74%; Stat Rep: RP-231826->RP-240115; ; ...; 13/6/24: Compl:74%->100%; WID: RP-240049->RP-230873; Stat Rep: RP-240115->RP-240910;
- 2115: 5/12/20: 0%->5; 19/3/21: 5%->40; 19/3/21: FCD:12/03/2021->06/21; 11/6/21: 40%->50; 11/6/21: FCD:Fri 11/06/->12/21
- 2116: 5/12/20: 0%->5; 19/3/21: 5%->40; 19/3/21: FCD:12/03/2021->06/21; 11/6/21: 40%->50; 11/6/21: FCD:Fri 11/06/->12/21; 13/9/21: 50%->80; 12/3/22: 80%->95; 12/3/22: FCD:10/12/2021->6/22; 31/3/23: 95%->100
- 2117: ; 13/12/21: 0%->85; 12/3/22: 85%->95; 12/3/22: FCD:10/12/2021->6/22; 31/3/23: 95%->100
- 2118: ; 11/6/21: 0%->85; 11/6/21: FCD:Fri 11/06/->12/21; 13/12/21: 85%->100
- 2119: no Perf. part; UPIP_SEC_LTE is an SA3 REL-17 WI; WI is addressing LTE and LTE link in EN-DC case; 29/3/23: WID:RP-213669->RP-230070
- 2120: no Perf. part; UPIP_SEC_LTE is an SA3 REL-17 WI; WI is addressing LTE and LTE link in EN-DC case; 4/6/22: 0%->100
- 2121: 17/3/23: FCD:09/09/2023->08/09/2023; Compl:0%->5%; Stat Rep: ->RP-230071; Rapporteur: Vodafone->Petra RAUER, Vodafone; Rap eMail: ->Petra[dot]Rauer[at]Vodafone[dot]com; ...; 6/9/23: FCD:09/09/2023->12/12/2023; Compl:28%->62%; Stat Rep: RP-230071->RP-2...; 2/4/24: WID:RP-230070->RP-240048
- 2122: ; 21/3/21: 0%->85; 11/6/21: 85%->100
- 2123: 11/3/22: 0%->100

| ID | WBS | Task | Duration | Start | Finish | Complete | Constraint | Resources | Work | Actual work | Acronym | PCG approved | WI rapporteur name | WI rapporteur e-mail | Release | TSG approved |
| --- | --- | --- | --- | --- | --- | --- | --- | --- | --- | --- | --- | --- | --- | --- | --- | --- |
| 2124 | 960 | **Enhancements of 3GPP profiles for cryptographic algorithms and security protocols** | 371.62d | 2021-03-18 A | 2022-03-11 A | 100% |  |  | 3120h | 3120h | eCryptPr | 46 | Pinar Comak, Ericsson | pinar.comak@ericsson.com | Rel-17 | 91 |
| 2125 | 960.1 | Stage 2 for eCryptPr | 192d | 2021-03-18 A | 2021-12-10 A | 100% | finish no earlier than 2021-12-12 | S3 | 1536h | 1536h | eCryptPr | 46 | Pinar Comak, Ericsson | pinar.comak@ericsson.com | Rel-17 | 91 |
| 2126 | 960.2 | Stage 3 CT1 for eCryptPr | 66d | 2021-12-10 A | 2022-03-11 A | 100% | finish no earlier than 2022-03-12 | C1 | 528h | 528h | eCryptPr | 48 | Biondic, Nevenka, Ericsson | nevenka.biondic@ericsson.com | Rel-17 | 94 |
| 2127 | 960.3 | Stage 3 CT3 for eCryptPr | 66d | 2021-12-10 A | 2022-03-11 A | 100% | finish no earlier than 2022-03-12 | C3 | 528h | 528h | eCryptPr | 48 | Biondic, Nevenka, Ericsson | nevenka.biondic@ericsson.com | Rel-17 | 94 |
| 2128 | 960.4 | Stage 3 CT4 for eCryptPr | 66d | 2021-12-10 A | 2022-03-11 A | 100% | finish no earlier than 2022-03-12 | C4 | 528h | 528h | eCryptPr | 48 | Biondic, Nevenka, Ericsson | nevenka.biondic@ericsson.com | Rel-17 | 94 |
| 2129 | 961 | **AKMA TLS protocol profiles** | 377.88d | 2021-06-11 A | 2022-06-10 A | 100% |  | S3 | 4192h | 4192h | AKMA_TLS | 47 | Escott, Adrian, Qualcomm Incorporated | aescott@qti.qualcomm.com | Rel-17 | 92 |
| 2130 | 961.1 | Security aspects of AKMA_TLS | 261d | 2021-06-11 A | 2022-06-10 A | 100% | finish no earlier than 2022-06-12 | S3 | 2088h | 2088h | AKMA_TLS | 47 | Escott, Adrian, Qualcomm Incorporated | aescott@qti.qualcomm.com | Rel-17 | 92 |
| 2131 | 961.2 | CT aspects of AKMA_TLS | 2d | 2022-03-10 A | 2022-03-11 A | 100% | finish no earlier than 2022-03-12 | C1 | 16h | 16h | AKMA_TLS | 48 | Chaponniere, Lena, Qualcomm Incorporated | lguellec@qti.qualcomm.com | Rel-17 | 95 |
| 2132 | 962 | Restoration of PDN Connections in PGW-C/SMF Set | 10d | 2020-12-07 A | 2020-12-18 A | 100% | finish no earlier than 2020-12-18 | C4 | 80h | 80h | RPCPSET | 46 | LANDAIS, Bruno, Nokia | bruno.landais@nokia.com | Rel-17 | 90 |
| 2133 | 963 | Enhancement of Inter-PLMN Roaming | 330d | 2020-12-07 A | 2022-03-11 A | 100% | finish no earlier than 2022-03-12 | C4 | 2640h | 2640h | EoIPR | 46 | Caixia Qi, Huawei | Caixia.qi@huawei.com | Rel-17 | 90 |
| 2134 | 964 | **Reliable Data Service Serialization Indication** | 951.75d | 2019-03-07 A | 2021-09-10 A | 100% |  |  | 15936h | 15936h | RDSSI | 43 | Starsinic, Michael, Convida Wireless LLC | starsinic.michael@convidawireless.com | Rel-17 | 84 |
| 2135 | 964.1 | Stage 2 of RDSSI | 21d | 2019-05-09 A | 2019-06-06 A | 100% | finish no earlier than 2019-06-06 | S2 | 168h | 168h | RDSSI | 43 | Starsinic, Michael, Convida Wireless LLC | starsinic.michael@convidawireless.com | Rel-17 | 84 |
| 2136 | 964.2 | **CT aspects of RDSSI** | 951.75d | 2019-03-07 A | 2021-09-10 A | 100% |  | C1 | 15768h | 15768h | RDSSI | 46 | Vivek Gupta, Intel | vivek.g.gupta@intel.com | Rel-17 | 90 |
| 2137 | 964.2.1 | CT1 aspects of RDSSI | 657d | 2019-03-07 A | 2021-09-10 A | 100% | finish no earlier than 2021-09-10 | C1 | 5256h | 5256h | RDSSI | 49 | Vivek Gupta, Intel | vivek.g.gupta@intel.com | Rel-17 | 97 |
| 2138 | 964.2.2 | CT3 aspects of RDSSI | 657d | 2019-03-07 A | 2021-09-10 A | 100% | finish no earlier than 2021-09-10 | C3 | 5256h | 5256h | RDSSI | 49 | Vivek Gupta, Intel | vivek.g.gupta@intel.com | Rel-17 | 97 |
| 2139 | 965 | Adapting BEST for use in 5G networks | 266d | 2020-12-04 A | 2021-12-10 A | 100% | finish no earlier than 2021-12-12 | S3 | 2128h | 2128h | BEST_5G | 46 | Keesmaat, Iko, KPN | iko.keesmaat@tno.nl | Rel-17 | 90 |
| 2140 | 966 | **Enhanced Service Enabler Architecture Layer for Verticals** | 479.38d | 2020-12-04 A | 2022-03-11 A | 100% |  |  | 4248h | 4248h | eSEAL | 47 | Basavaraj (Basu) Pattan, Samsung | basavarajjp@samsung.com | Rel-17 | 92 |
| 2141 | 966.1 | Stage 2 of eSEAL | 138d | 2020-12-04 A | 2021-06-15 A | 100% | finish no earlier than 2021-06-15 | S6 | 1104h | 1104h | eSEAL | 46 | Basavaraj (Basu) Pattan, Samsung | basavarajjp@samsung.com | Rel-17 | 90 |
| 2142 | 966.2 | CT1 aspects of eSEAL | 196d | 2021-06-11 A | 2022-03-11 A | 100% | finish no earlier than 2022-03-12 | C1 | 1568h | 1568h | eSEAL | 47 | Sapan Shah (Samsung Electronics) | sapan.shah@samsung.com | Rel-17 | 92 |
| 2143 | 966.3 | CT3 aspects of eSEAL | 196d | 2021-06-11 A | 2022-03-11 A | 100% | finish no earlier than 2022-03-12 | C3 | 1568h | 1568h | eSEAL | 47 | Sapan Shah (Samsung Electronics) | sapan.shah@samsung.com | Rel-17 | 92 |
| 2144 | 966.4 | Security for eSEAL | 1d | 2021-12-10 A | 2021-12-10 A | 100% | finish no earlier than 2021-12-12 | S3 | 8h | 8h | eSEAL | 48 | Rajavelsamy Rajadurai, Samsung | rajvel@samsung.com | Rel-17 | 94 |
| 2145 | 967 | **Access Traffic Steering, Switch and Splitting support in the 5G system architecture; Phase 2** | 1987d | 2019-03-07 A | 2024-06-06 A | 100% |  |  | 14600h | 14600h | ATSSS_Ph2 | 46 | Apostolis Salkintzis, Lenovo | y1026c@lenovo.com | Rel-17 | 90 |
| 2146 | 967.1 | Study on ATSSS_Ph2 | 464d | 2019-03-07 A | 2020-12-15 A | 100% | finish no earlier than 2020-12-15 | S2 | 3712h | 3712h | FS_ATSSS_Ph2 | 43 | So, Tricci, ZTE | tso@ztetx.com | Rel-17 | 84 |
| 2147 | 967.2 | Stage 2 of ATSSS_Ph2 | 137d | 2020-12-03 A | 2021-06-11 A | 100% | finish no earlier than 2021-06-12 | S2 | 1096h | 1096h | ATSSS_Ph2 | 46 | Apostolis Salkintzis, Lenovo | y1026c@lenovo.com | Rel-17 | 90 |

Notes:
- 2124: ; 11/6/21: 0%->35; 11/6/21: FCD:Fri 10/09/->12/21; 13/9/21: 35%->85 / Impacted TSs and TRs: 33.141; 33.203; 33.210; 33.220; 33.222; 33.310; 33.328; 33.501
- 2125: ; 11/6/21: 0%->35; 11/6/21: FCD:Fri 10/09/->12/21; 13/9/21: 35%->85; 13/12/21: 85%->95; 12/3/22: 95%->100 / Impacted TSs and TRs: 33.141; 33.203; 33.210; 33.220; 33.222; 33.310; 33.328; 33.501
- 2126: ; 12/3/22: 0%->97; 4/6/22: 97%->100 / Impacted TSs and TRs: 24.109; 24.141; 24.229; 24.259; 24.424; 24.481; 24.482; 24.486; 24.545; 24.547; 24.548; 24.623
- 2127: ; 12/3/22: 0%->100 / Impacted TSs and TRs: 29.079; 29.116; 29.122; 29.155; 29.201; 29.222; 29.486; 29.517; 29.522; 29.549
- 2128: ; 7/1/22: 0%->60; 12/3/22: 60%->90; 4/6/22: 90%->100 / Impacted TSs and TRs: 23.008; 29.228; 29.229; 29.240; 23.333; 23.334; 29.334; 29.335
- 2129: ; 13/12/21: 0%->95; 13/12/21: FCD:Fri 10/09/->12/21; 4/6/22: 95%->100; 12/9/22: 100%-> / Impacted TSs and TRs: 33.535
- 2130: ; 13/12/21: 0%->95; 13/12/21: FCD:Fri 10/09/->12/21; 12/3/22: FCD:15/12/2021->6/22; 4/6/22: 100%->100 / Impacted TSs and TRs: 33.535
- 2131: ; 12/3/22: 0%->80; 4/6/22: 100%->100 / Impacted TSs and TRs: 24.109
- 2132: 23.007; 29.274; 29.303; 23.003 ; 5/12/20: 0%->100; 5/12/20: 0%->100
- 2133: 29.510; 29.531; 29.573 ; 21/3/21: 0%->30; 11/6/21: 30%->35; 13/12/21: 35%->80; 13/12/21: FCD:Fri 10/09/->03/22; 12/3/22: 80%->100
- 2134: Impacted TSs and TRs: 23.682; 23.501; 23.502
- 2135: 6/6/19: 0%->100. 9/4/21: Rel-16->Rel-17 / Impacted TSs and TRs: 23.682; 23.501; 23.502
- 2136: 24.250; 29.122 ; 21/3/21: 0%->100
- 2137: 23/9/22: 99%->100
- 2138: 23/9/22: 99%->100
- 2139: 33.163 ; 19/3/21: 0%->40; 11/6/21: 40%->70; 11/6/21: FCD:Fri 11/06/->12/21; 13/9/21: 70%->85; 13/12/21: 85%->100
- 2140: 23.434 ; 5/12/20: 0%->10; 10/2/21: FCD:11/06/2021->06/21; 21/3/21: 10%->35
- 2141: 23.434 ; 5/12/20: 0%->10; 10/2/21: FCD:11/06/2021->06/21; 21/3/21: 10%->35; 11/6/21: 35%->80; 13/9/21: 80%->100
- 2142: ; 2/7/21: 24.549 added;; 10/9/21: WID:CP-211117->CP-212098; 13/9/21: 0%->20; 13/12/21: 20%->60; 12/3/22: 60%->92; 4/6/22: 92%->99 / Impacted TSs and TRs: 29.549;24.548;24.547;24.546;24.545 ; 24.549
- 2143: ; 10/9/21: WID:CP-211117->CP-212098; 13/9/21: 0%->10; 13/12/21: 10%->40; 12/3/22: 40%->96; 4/6/22: 96%->100 / Impacted TSs and TRs: 29.549
- 2144: ; 24/3/22: 0%->100 / Impacted TSs and TRs: 33.434
- 2145: 23.501; 23.502; 23.503
- 2146: 25/3/20: WID:SP-190558->SP-200095; 26/3/20: 0%->15; 26/6/20: FCD:18/06/2020->09/20; 26/6/20: 15%->35; 12/9/20: 35%->70; 12/9/20: FCD:15/09/2020->12/20; 5/12/20: 70%->95; 19/3/21: 95%->100 / Impacted TSs and TRs: New 23.700-93
- 2147: 23.501; 23.502; 23.503 ; 19/3/21: 0%->55; 14/6/21: 55%->97; 13/9/21: 97%->100

| ID | WBS | Task | Duration | Start | Finish | Complete | Constraint | Resources | Work | Actual work | Acronym | PCG approved | WI rapporteur name | WI rapporteur e-mail | Release | TSG approved | Status Report |
| --- | --- | --- | --- | --- | --- | --- | --- | --- | --- | --- | --- | --- | --- | --- | --- | --- | --- |
| 2148 | 967.3 | **CT aspects of ATSSS_Ph2** | 371.62d | 2021-03-18 A | 2022-03-11 A | 100% |  | ct | 8224h | 8224h | ATSSS_Ph2 | 46 | ZHOU Xingyue (Joy), ZTE | zhou.xingyue@zte.com.cn | Rel-17 | 91 |  |
| 2149 | 967.3.1 | CT1 aspects of ATSSS_Ph2 | 257d | 2021-03-18 A | 2022-03-11 A | 100% | finish no earlier than 2022-03-12 | C1 | 2056h | 2056h | ATSSS_Ph2 | 46 | ZHOU Xingyue (Joy), ZTE | zhou.xingyue@zte.com.cn | Rel-17 | 91 |  |
| 2150 | 967.3.2 | CT3 aspects of ATSSS_Ph2 | 257d | 2021-03-18 A | 2022-03-11 A | 100% | finish no earlier than 2022-03-12 | C3 | 2056h | 2056h | ATSSS_Ph2 | 46 | ZHOU Xingyue (Joy), ZTE | zhou.xingyue@zte.com.cn | Rel-17 | 91 |  |
| 2151 | 967.3.3 | CT4 aspects of ATSSS_Ph2 | 257d | 2021-03-18 A | 2022-03-11 A | 100% | finish no earlier than 2022-03-12 | C4 | 2056h | 2056h | ATSSS_Ph2 | 46 | ZHOU Xingyue (Joy), ZTE | zhou.xingyue@zte.com.cn | Rel-17 | 91 |  |
| 2152 | 967.4 | UE Conformance - ATSSS_Ph2 | 196d | 2023-09-11 A | 2024-06-06 A | 100% | finish no earlier than 2024-06-06 | R5 | 1568h | 1568h | ATSSS_Ph2-UEConTest | 51 | China Telecom |  | Rel-17 | 101 | RP-240911 |
| 2153 | 968 | **Enablers for Network Automation for 5G - phase 2** | 1045.88d | 2019-06-06 A | 2022-03-11 A | 100% |  |  | 14568h | 14568h | eNA_Ph2 | 46 | TBD |  | Rel-17 | 90 |  |
| 2154 | 968.1 | Study on Enablers for Network Automation for 5G - phase 2 | 399d | 2019-06-06 A | 2020-12-15 A | 100% | finish no earlier than 2020-12-15 | S2 | 3192h | 3192h | FS_eNA_Ph2 | 43 | Xiaobo Wu, Huawei Technologies | wuxiaobo@huawei.com | Rel-17 | 84 |  |
| 2155 | 968.2 | Study on security aspects of enablers for Network Automation (eNA) for 5GS Phase 2 | 388d | 2020-09-16 A | 2022-03-11 A | 100% | finish no earlier than 2022-03-12 | S3 | 3104h | 3104h | FS_eNA_SEC | 45 | Xiaoting Huang, China Mobile | huangxiaoting@chinamobile.com | Rel-17 | 89 |  |
| 2156 | 968.3 | Stage 2 of eNA_Ph2 | 200d | 2020-12-03 A | 2021-09-08 A | 100% | finish no earlier than 2021-09-08 | S2 | 1600h | 1600h | eNA_Ph2 | 46 | TBD |  | Rel-17 | 90 |  |
| 2157 | 968.4 | **CT aspects of eNA_Ph2** | 370.62d | 2021-03-19 A | 2022-03-11 A | 100% |  | ct | 6144h | 6144h | eNA_Ph2 | 46 | Huang Zhenning (China Mobile) | huangzhenning (at) chinamobile (dot) com | Rel-17 | 91 |  |
| 2158 | 968.4.1 | CT3 aspects of eNA_Ph2 | 256d | 2021-03-19 A | 2022-03-11 A | 100% | finish no earlier than 2022-03-12 | C3 | 2048h | 2048h | eNA_Ph2 | 46 | Huang Zhenning (China Mobile) | huangzhenning (at) chinamobile (dot) com | Rel-17 | 91 |  |
| 2159 | 968.4.2 | CT4 aspects of eNA_Ph2 | 256d | 2021-03-19 A | 2022-03-11 A | 100% | finish no earlier than 2022-03-12 | C4 | 2048h | 2048h | eNA_Ph2 | 46 | Huang Zhenning (China Mobile) | huangzhenning (at) chinamobile (dot) com | Rel-17 | 91 |  |
| 2160 | 968.5 | Security aspects of eNA_Ph2 | 66d | 2021-09-10 A | 2021-12-10 A | 100% | finish no earlier than 2021-12-12 | S3 | 528h | 528h | eNA_Ph2 | 47 | Chang Liu, China Mobile | liuchangyjy@chinamobile.com | Rel-17 | 93 |  |
| 2161 | 969 | **Proximity based Services in 5GS** | 1234.38d | 2019-03-07 A | 2022-06-10 A | 100% |  |  | 25463h | 25463h | 5G_ProSe | 45 | TBD |  | Rel-17 | 88 |  |
| 2162 | 969.1 | Study on System enhancement for Proximity based Services in 5GS | 526.88d | 2019-03-07 A | 2021-03-12 A | 100% | finish no earlier than 2021-03-12 | S2 | 4215h | 4215h | FS_5G_ProSe | 42 | Qiang Deng, CATT | dengqiang1@catt.cn | Rel-17 | 83 |  |
| 2163 | 969.2 | Stage 2 for Proximity based Services in 5GS | 200d | 2020-12-03 A | 2021-09-08 A | 100% | finish no earlier than 2021-09-08 | S2 | 1600h | 1600h | 5G_ProSe | 46 | Qiang Deng, CATT | dengqiang1@catt.cn | Rel-17 | 90 |  |
| 2164 | 969.3 | **CT aspects of proximity based services in 5GS** | 371.62d | 2021-03-18 A | 2022-03-11 A | 100% |  | ct | 10280h | 10280h | 5G_ProSe | 46 | Yong Jiang, CATT | jiangyong@catt.cn | Rel-17 | 91 |  |
| 2165 | 969.3.1 | CT1 aspects of 5G_ProSe | 257d | 2021-03-18 A | 2022-03-11 A | 100% | finish no earlier than 2022-03-12 | C1 | 2056h | 2056h | 5G_ProSe | 46 | Yong Jiang, CATT | jiangyong@catt.cn | Rel-17 | 91 |  |
| 2166 | 969.3.2 | CT3 aspects of 5G_ProSe | 257d | 2021-03-18 A | 2022-03-11 A | 100% | finish no earlier than 2022-03-12 | C3 | 2056h | 2056h | 5G_ProSe | 46 | Yong Jiang, CATT | jiangyong@catt.cn | Rel-17 | 91 |  |
| 2167 | 969.3.3 | CT4 aspects of 5G_ProSe | 257d | 2021-03-18 A | 2022-03-11 A | 100% | finish no earlier than 2022-03-12 | C4 | 2056h | 2056h | 5G_ProSe | 46 | Yong Jiang, CATT | jiangyong@catt.cn | Rel-17 | 91 |  |
| 2168 | 969.3.4 | CT6 aspects of 5G_ProSe | 257d | 2021-03-18 A | 2022-03-11 A | 100% | finish no earlier than 2022-03-12 | C6 | 2056h | 2056h | 5G_ProSe | 47 | Yong Jiang, CATT | jiangyong@catt.cn | Rel-17 | 92 |  |
| 2169 | 969.4 | Study on charging aspects of Proximity-based Services in 5GS | 323d | 2020-09-16 A | 2021-12-10 A | 100% | finish no earlier than 2021-12-12 | S5 | 2584h | 2584h | FS_5G_Prose_CH | 45 | Shu, Min, CATT | shumin@catt.cn | Rel-17 | 89 |  |
| 2170 | 969.5 | Charging aspects of Proximity-based Services in 5GS | 131d | 2021-12-10 A | 2022-06-10 A | 100% | finish no earlier than 2022-06-12 | S5 | 1048h | 1048h | 5G_ProSe | 48 | Shu, Min, CATT | shumin<at>catt<dot>cn | Rel-17 | 94 |  |
| 2171 | 969.6 | Study on Security Aspects of Enhancement for Proximity Based Services in 5GS | 521d | 2020-06-12 A | 2022-06-10 A | 100% | finish no earlier than 2022-06-12 | S3 | 4168h | 4168h | FS_5G_ProSe_Sec | 45 | Wei Zhou, CATT | zhouwei@catt.cn | Rel-17 | 88 |  |
| 2172 | 969.7 | Security Aspects of Proximity based Services in 5GS | 196d | 2021-09-10 A | 2022-06-09 A | 100% | finish no earlier than 2022-06-12 | S3 | 1568h | 1568h | 5G_ProSe | 47 | Wei Zhou, CATT | zhouwei@catt.cn | Rel-17 | 93 |  |

Notes:
- 2149: 11/6/21: 0%->60; 13/9/21: 60%->80; 13/12/21: 80%->95; 12/3/22: 95%->96; 4/6/22: 96%->100 / Impacted TSs and TRs: 24.193; 24.301; 24.501
- 2150: 11/6/21: 0%->50; 13/9/21: 50%->80; 13/12/21: 80%->100 / Impacted TSs and TRs: 29.512
- 2151: 11/6/21: 0%->5; 14/6/21: 5%->50; 13/9/21: 50%->60; 13/12/21: 60%->90; 12/3/22: 90%->100 / Impacted TSs and TRs: 29.244; 29.502; 29.518
- 2152: 13/6/24: FCD:09/09/2024->06/06/2024; Compl:0%->100%; Stat Rep: ->RP-240911; ; 23/7/24: WID:RP-231827->RP-240912
- 2153: 23.501; 23.502; 23.503; 23.288
- 2154: 8/10/19: 23.700-91 added;; 6/12/19: 0%->15; 25/3/20: WID:SP-190557->SP-200098; 25/3/20: FCD:12/03/2020->06/20; 25/3/20: 15%->32; 26/6/20: FCD:15/06/2020->09/20; 26/6/20: 32%->55; 12/9/20: 55%->70; 12/9/20: FCD:15/09/2020->12/20; 5/12/20: 70%->97; 19/3 / Impacted TSs and TRs: New ; 23.700-91
- 2155: 5/12/20: 0%->10; 19/3/21: 10%->40; 11/6/21: 40%->50; 11/6/21: FCD:Fri 11/06/->12/21; 13/9/21: 50%->75; 12/3/22: 75%->100; 12/3/22: FCD:10/12/2021->3/22 / Impacted TSs and TRs: 33.866
- 2156: 23.501; 23.502; 23.503; 23.288 ; 19/3/21: 0%->40; 14/6/21: 40%->90; 14/6/21: FCD:Fri 11/06/->09/21; 13/9/21: 90%->99; 10/12/21: 99%->100
- 2157: ; 11/6/21: WID:CP-210290->CP-211191 / Impacted TSs and TRs: 29.503; 29.508; 29.510; 29.513; 29.514; 29.517; 29.518; 29.520; 29.522; 29.523; 29.554; 29.571; 29.591
- 2158: ; 11/6/21: 0%->20; 2/7/21: 29.576 added;; 2/7/21: 29.575 added;; 2/7/21: 29.574 added;; 13/9/21: 20%->30; 13/12/21: 30%->65; 13/12/21: WID:CP-211191->CP-213261; 12/3/22: 65%->96; 4/6/22: 96%->100 / Impacted TSs and TRs: 29.576; 29.575; 29.574
- 2159: ; 11/6/21: 0%->5; 14/6/21: 5%->60; 13/9/21: 60%->80; 13/12/21: 80%->90; 12/3/22: 90%->100
- 2160: ; 13/12/21: 0%->90; 12/3/22: 90%->100 / Impacted TSs and TRs: 33.501
- 2162: 7/6/19: WID:SP-190186->SP-190443; 8/10/19: 23.752 added;; 6/12/19: 0%->30; 25/3/20: 30%->55; 26/6/20: FCD:12/06/2020->09/20; 26/6/20: 55%->65; 12/9/20: 65%->70; 12/9/20: FCD:15/09/2020->12/20; 5/12/20: 70%->90; 5/12/20: FCD:15/12/2020->03/20; 19/3/21: / Impacted TSs and TRs: 23.752; 23.752
- 2163: 19/3/21: 0%->30; 11/6/21: 30%->85; 11/6/21: FCD:Fri 11/06/->09/21; 13/9/21: 85%->98; 10/12/21: 98%->99; 12/3/22: 99%->100
- 2164: ; 11/6/21: WID:CP-210292->CP-211110; 10/9/21: WID:CP-211110->CP-212105; 13/7/22: 29.533 added; / Impacted TSs and TRs: 23.122; 24.501; 27.007; 29.513; 29.519; 29.522; 29.525; 23.008; 29.502; 29.503; 29.505; 29.510; 29.518; 29.527; 29.571; 31.102 ; 29.533
- 2165: ; 11/6/21: 0%->50; 13/9/21: 50%->65; 13/12/21: 65%->75; 12/3/22: 75%->85; 4/6/22: 85%->96
- 2166: ; 11/6/21: 0%->35; 2/7/21: 29.557 added;; 13/9/21: 35%->65; 13/12/21: 65%->95; 12/3/22: 95%->100 / Impacted TSs and TRs: 29.557
- 2167: ; 11/6/21: 0%->25; 13/9/21: 25%->45; 13/12/21: 45%->80; 22/3/22: 29.559 added;; 4/6/22: 80%->90 / Impacted TSs and TRs: 29.559
- 2168: 2/7/21: added ; 13/12/21: 0%->50; 12/3/22: 50%->60; 4/6/22: 60%->60
- 2169: 25/9/20: 32.846 added;; 5/12/20: 0%->15; 21/3/21: 15%->40; 13/9/21: 40%->80; 13/9/21: FCD:Wed 08/09/->12/21; 21/6/22: 80%->100 / Impacted TSs and TRs: 32.846
- 2170: ; 12/3/22: 0%->40; 4/6/22: 40%->100 / Impacted TSs and TRs: 32.277; 32.240; 32.290; 32.291; 32.298
- 2171: 28/7/20: 33.847 added;; 12/9/20: 0%->15; 5/12/20: 15%->45; 5/12/20: FCD:15/12/2020->06/20; 19/3/21: 45%->60; 9/4/21: 60%->65; 11/6/21: 65%->75; 11/6/21: FCD:Fri 11/06/->12/21; 13/9/21: 75%->85; 12/3/22: 85%->85; 12/3/22: FCD:10/12/2021->06/22; 4/6/22: / Impacted TSs and TRs: 33.847
- 2172: ; 13/12/21: 0%->45; 13/12/21: FCD:Fri 10/12/->03/22; 12/3/22: 45%->65; 12/3/22: FCD:11/03/2022->6/22; 22/3/22: 33.503 added;; 4/6/22: 65%->92; 12/9/22: 92%->83; 31/3/23: 83%->100 / Impacted TSs and TRs: New ; 33.503

| ID | WBS | Task | Duration | Start | Finish | Complete | Constraint | Resources | Work | Actual work | Acronym | PCG approved | WI rapporteur name | Release | TSG approved | Impacted TSs and TRs | WI rapporteur e-mail | Status Report | TSG stopped |
| --- | --- | --- | --- | --- | --- | --- | --- | --- | --- | --- | --- | --- | --- | --- | --- | --- | --- | --- | --- |
| 2173 | 970 | **NR Sidelink Relay** | 1798.38d | 2021-03-12 A | 2025-12-12 A | 100% |  |  | 15920h | 15920h | NR_SL_relay | 46 | OPPO | Rel-17 | 91 |  |  |  |  |
| 2174 | 970.1 | Core part: NR Sidelink Relay | 268d | 2021-03-12 A | 2022-03-22 A | 100% | finish no earlier than 2022-03-22 | R2 | 2144h | 2144h | NR_SL_relay-Core | 46 | Qianxi Lu, Xueyan Huang | Rel-17 | 91 | 38.351 | qianxi.lu@oppo.com, huangxueyan@chinamoblie.com | RP-220210 |  |
| 2175 | 970.2 | Perf. part: NR Sidelink Relay | 400d | 2021-03-12 A | 2022-09-22 A | 100% | finish no earlier than 2022-09-22 | R4 | 3200h | 3200h | NR_SL_relay-Perf | 46 | Qianxi Lu, Xueyan Huang, OPPO, CMCC | Rel-17 | 91 |  | qianxi.lu@oppo.com, huangxueyan@chinamoblie.com | RP-221187 / 1770 |  |
| 2176 | 970.3 | UE Conformance - NR Sidelink Relay | 1322d | 2022-06-15 A | 2025-12-12 A | 100% | finish no earlier than 2025-12-12 | R5 | 10576h | 10576h | NR_SL_relay-UEConTest | 49 | Xiaozhong CHEN, CATT | Rel-17 | 96 |  | chenxiaozhong@catt.cn | RP-253449 |  |
| 2177 | 971 | **Authentication and key management for applications based on 3GPP credential in 5G** | 937.12d | 2019-09-19 A | 2022-03-11 A | 100% |  |  | 13952h | 13952h | AKMA | 43 | Xiaoting Huang, China Mobile | Rel-17 | 85 | New ; 33.535 | huangxiaoting@chinamobile.com |  |  |
| 2178 | 971.1 | SA3 aspects of AKMA | 192d | 2019-09-19 A | 2020-06-12 A | 100% | finish no earlier than 2020-06-12 | S3 | 1536h | 1536h | AKMA | 43 | Xiaoting Huang, China Mobile | Rel-17 | 85 | New ; 33.535 | huangxiaoting@chinamobile.com |  |  |
| 2179 | 971.2 | **CT aspects of AKMA** | 561.12d | 2020-09-16 A | 2022-03-11 A | 100% |  | ct | 12416h | 12416h | AKMA-CT | 45 | Huang Zhenning (China Mobile) | Rel-17 | 89 |  | huangzhenning (at) chinamobile (dot) com |  |  |
| 2180 | 971.2.1 | CT1 aspects of AKMA | 388d | 2020-09-16 A | 2022-03-11 A | 100% | finish no earlier than 2022-03-12 | C1 | 3104h | 3104h | AKMA-CT | 45 | Huang Zhenning (China Mobile) | Rel-17 | 89 | 24.501 | huangzhenning (at) chinamobile (dot) com |  |  |
| 2181 | 971.2.2 | CT3 aspects of AKMA | 388d | 2020-09-16 A | 2022-03-11 A | 100% | finish no earlier than 2022-03-12 | C3 | 3104h | 3104h | AKMA-CT | 45 | Huang Zhenning (China Mobile) | Rel-17 | 89 | 29.522 | huangzhenning (at) chinamobile (dot) com |  |  |
| 2182 | 971.2.3 | CT4 aspects of AKMA | 388d | 2020-09-16 A | 2022-03-11 A | 100% | finish no earlier than 2022-03-12 | C4 | 3104h | 3104h | AKMA-CT | 45 | Huang Zhenning (China Mobile) | Rel-17 | 89 | 29.503; 29.510; 29.571 | huangzhenning (at) chinamobile (dot) com |  |  |
| 2183 | 972 | **Enhancement of Private Network support for NG-RAN** | 1505.5d | 2020-09-17 A | 2024-09-09 A | 100% |  | R3 | 16120h | 16120h | NG_RAN_PRN_enh | 45 | China Telecom | Rel-17 | 89 |  |  |  |  |
| 2184 | 972.1 | Core part: Enhancement of Private Network support for NG-RAN | 387d | 2020-09-17 A | 2022-03-11 A | 100% | finish no earlier than 2022-03-22 | R3 | 3096h | 3096h | NG_RAN_PRN_enh-Core | 45 | China Telecom | Rel-17 | 89 |  |  | RP-220561 |  |
| 2185 | 972.2 | UE Conformance - Enhancement of Private Network support for NG-RAN including CT aspects | 587d | 2022-06-15 A | 2024-09-09 A | 100% | finish no earlier than 2024-09-24 | R5 | 4696h | 4696h | NG_RAN_PRN_enh_plus_CT-UEConTest | 49 | Lei GAO, Yogesh Tugnawat, China Telecom, Qualcomm | Rel-17 | 96 |  | gaol8@chinatelecom.cn, yogesht@qti.qualcomm.com | RP-242006 |  |
| 2186 | 973 | **Multimedia Priority Service (MPS) Phase 2** | 1603.12d? | 2017-12-15 A | 2022-03-11 A | 100% |  |  | 23112h | 23112h | MPS2 | 43 | Singh, Ray P; Perspecta Labs | Rel-17 | 84 | 22.953; 22.153 | rsingh@perspectalabs.com |  |  |
| 2187 | 973.1 | Study on MPS2 | 455d? | 2017-12-15 A | 2019-09-12 A | 100% | finish no earlier than 2019-09-12 | S1 | 3640h | 3640h | FS_MPS2 | 40 | Singh, Ray P; Vencore Labs | Rel-17 | 78 | 22.854 | rsingh@vencorelabs.com |  |  |
| 2188 | 973.2 | Stopped - Study on MPS2, Stage 2 | 192d | 2019-09-19 A | 2020-06-12 A | 100% | finish no earlier than 2020-06-12 | S2 | 1536h | 1536h | FS_MPS2_St2 | 43 | Don Lukacs; Perspecta Labs | Rel-17 | 85 | New ; 23.775 | dlukacs@perspectalabs.com |  | 96 |
| 2189 | 973.3 | Stage 1 of MPS2 | 136d | 2019-06-06 A | 2019-12-12 A | 100% | finish no earlier than 2019-12-12 | S1 | 1088h | 1088h | MPS2 | 43 | Singh, Ray P; Perspecta Labs | Rel-17 | 84 | 22.953; 22.153 | rsingh@perspectalabs.com |  |  |
| 2190 | 973.4 | Stage 2 of MPS2 | 318d | 2020-03-25 A | 2021-06-11 A | 100% | finish no earlier than 2021-06-12 | S2 | 2544h | 2544h | MPS2 | 44 | Streijl, Robert, Perspecta Labs | Rel-17 | 87 |  | rstreijl@perspectalabs.com |  |  |
| 2191 | 973.5 | **Stage 3 of MPS2** | 647.12d | 2020-06-25 A | 2022-03-11 A | 100% |  | ct | 14304h | 14304h | MPS2 | 45 | Peter Monnes, Perspecta Labs | Rel-17 | 88 |  | pmonnes@perspectalabs.com |  |  |
| 2192 | 973.5.1 | CT1 aspects of MPS2 | 447d | 2020-06-25 A | 2022-03-11 A | 100% | finish no earlier than 2022-03-12 | C1 | 3576h | 3576h | MPS2 | 45 | Peter Monnes, Perspecta Labs | Rel-17 | 88 |  | pmonnes@perspectalabs.com |  |  |
| 2193 | 973.5.2 | CT3 aspects of MPS2 | 447d | 2020-06-25 A | 2022-03-11 A | 100% | finish no earlier than 2022-03-12 | C3 | 3576h | 3576h | MPS2 | 45 | Peter Monnes, Perspecta Labs | Rel-17 | 88 |  | pmonnes@perspectalabs.com |  |  |
| 2194 | 973.5.3 | CT4 aspects of MPS2 | 447d | 2020-06-25 A | 2022-03-11 A | 100% | finish no earlier than 2022-03-12 | C4 | 3576h | 3576h | MPS2 | 45 | Peter Monnes, Perspecta Labs | Rel-17 | 88 |  | pmonnes@perspectalabs.com |  |  |
| 2195 | 974 | Mission critical security enhancements phase 2 | 323d | 2020-09-16 A | 2021-12-10 A | 100% | finish no earlier than 2021-12-12 | S3 | 2584h | 2584h | MCXSec2 | 45 | Woodward, Tim, Motorola Solutions, Inc, | Rel-17 | 89 | 33.180 | tim.woodward@motorolasolutions.com |  |  |
| 2196 | 975 | **PAP/CHAP protocols usage in 5GS** | 372.75d | 2020-09-16 A | 2021-09-10 A | 100% |  | ct | 5152h | 5152h | PAP_CHAP | 45 | Mingxue Li, China Telecom | Rel-17 | 89 |  | limx36@chinatelecom.cn |  |  |
| 2197 | 975.1 | CT1 aspects of PAP/CHAP protocols usage in 5GS | 258d | 2020-09-16 A | 2021-09-10 A | 100% | finish no earlier than 2021-09-12 | C1 | 2064h | 2064h | PAP_CHAP | 45 | Mingxue Li, China Telecom | Rel-17 | 89 |  | limx36@chinatelecom.cn |  |  |
| 2198 | 975.2 | CT3 aspects of PAP/CHAP protocols usage in 5GS | 128d | 2020-09-16 A | 2021-03-12 A | 100% | finish no earlier than 2021-03-12 | C3 | 1024h | 1024h | PAP_CHAP | 45 | Mingxue Li, China Telecom | Rel-17 | 89 |  | limx36@chinatelecom.cn |  |  |

Notes:
- 2173: follow-up WI of RAN2 REL-17 SI FS_NR_SL_relay ; 2/7/21: WID:RP-210904->RP-211050; 29/9/21: WID:RP-211050->RP-212601
- 2174: follow-up WI of RAN2 REL-17 SI FS_NR_SL_relay ; 2/7/21: 38.351 added;; 20/6/22: FCD:12/03/2022->22/03/2022; Compl:0%->100%; WID: RP-211050->RP-212819; Stat Rep: ->RP-220210; Rapporteur: OPPO->Qianxi Lu, Xueyan Huang; Rap eMail: ->qianxi.lu@oppo.com, huangxueyan@chinamoblie.com;
- 2175: follow-up WI of RAN2 REL-17 SI FS_NR_SL_relay ; 13/9/21: Compl:0%->55%; 13/9/21: CD:Thu 08/09/22->Tue 22/03/22; 13/9/21: Stat Rep: ->RP-211779 20/6/22: FCD:22/03/2022->22/09/2022; Compl:100%->95%; Stat Rep: RP-220210->RP-221187 / 1770; Rapporteur:...
- 2176: 9/9/22: Comp...; 23/9/22: WID:RP-221447->RP-222378; 9/12/22: FCD:23/09/2022->01/09/2023; WID: RP-222378->RP-221447; Stat Rep: ->RP-223141; Rapporteur: CATT->Xiaozhong CHEN, CATT; Rap eMail: ->chenxiaozhong@catt.cn; 17/3/23: FCD:09/09/2023.....; 3/12/25: Compl:95%->100%; Stat Rep: RP-252722->RP-253449;
- 2177: ; 8/10/19: 33.535 added; 6/12/19: 0%->20; 25/3/20: 20%->60; 25/3/20: FCD:12/03/2020->06/20; 26/6/20: 60%->95; 25/09/20: Rel-16->Rel-17
- 2178: ; 8/10/19: 33.535 added; 6/12/19: 0%->20; 25/3/20: 20%->60; 25/3/20: FCD:12/03/2020->06/20; 26/6/20: 60%->95; 12/9/20: 95%->96; 25/09/20: Rel-16->Rel-17; 5/12/20: 96%->97; 19/3/21: 97%->98; 12/3/22: 98%->100
- 2179: 25/9/20: WID:CP-202047->CP-202240; 25/9/20: WID:CP-202240->CP-202254
- 2180: 21/3/21: 0%->95; 13/9/21: 95%->96; 13/12/21: 96%->97; 12/3/22: FCD:12/03/2021->3/22; 12/3/22: 97%->100
- 2181: 5/12/20: 0%->15; 21/3/21: 15%->95; 11/6/21: 95%->97; 13/9/21: 97%->95; 13/9/21: FCD:Fri 12/03/->03/22; 13/12/21: 95%->99; 12/3/22: 99%->100
- 2182: 13/9/20: FCD:12/03/2021->09/21; 5/12/20: 0%->20; 21/3/21: 20%->95; 13/9/21: FCD:Wed 08/09/->03/22; 12/3/22: 95%->100
- 2183: follow-up WI of REL-16 WI NG_RAN_PRN-Core which was completed in June 20; no Perf. part; related SA2 SI? ; 6/1/21: WID:RP-202051->RP-202363; 29/9/21: WID:RP-202363->RP-212585
- 2184: follow-up WI of REL-16 WI NG_RAN_PRN-Core which was completed in June 20; no Perf. part; related SA2 SI? ; 13/9/21: Compl:0%->50%; 13/9/21: CD:Thu 17/06/21->Tue 22/03/22; 13/9/21: ;
- 2185: 9/9/22: Comp...; 9/12/22: FCD:23/12/2022->01/12/2023; Stat Rep: ->RP-222942; Rapporteur: ChinaTelecom->Lei GAO, Yogesh Tugnawat, China Telecom, Qualcomm; Rap eMail: ->gaol8@chinatelecom.cn, yogesht@qti.qualcomm.com; 17/3/23: FCD:30/11/202.....; 26/9/24: WID:RP-221300->RP-242005
- 2187: 16/3/18: 0%->10¦7/6/18: 10%->30¦10/9/18: 30%->50¦4/12/18: 50%->65¦12/12/18: FCD:03/19->09/19. Rel-16->Rel-17¦14/3/19: 65%->80; 31/5/19: 80%->90; 7/6/19: WID:SP-170996->SP-190315; 17/8/20: 90%->100
- 2188: ; 8/10/19: 23.775 added;; 22/3/22: 0%->100. Puneet: finally no study phase needed.
- 2189: 13/9/19: 0%->85; 6/12/19: 85%->100
- 2190: 25/9/20: WID:SP-200083->SP-200519; 5/12/20: FCD:16/12/2020->06/20; 5/12/20: 0%->20; 19/3/21: 20%->98; 11/6/21: 98%->99; 12/3/22: 99%->100
- 2191: 24.229; 29.212; 29.213; 29.214; 29.512; 29.513; 29.514; 29.328
- 2192: 24.229; 2/7/20: FCD:16/12/2020->03/21; 13/9/20: 0%->50; 5/12/20: 50%->75; 21/3/21: 75%->80; 13/9/21: 80%->90; 13/12/21: 90%->95; 12/3/22: FCD:15/03/2021->3/22; 12/3/22: 95%->100
- 2193: 29.212; 29.213; 29.214; 29.512; 29.513; 29.514; 2/7/20: FCD:20/09/2021->03/21; 11/6/21: 0%->70; 13/9/21: 70%->95; 12/3/22: FCD:15/03/2021->3/22; 12/3/22: 95%->100
- 2194: 29.328 ; 2/7/20: FCD:20/09/2021->03/21; 11/6/21: 0%->70; 13/9/21: FCD:Mon 15/03/->03/22; 7/1/22: 70%->95; 12/3/22: 95%->100
- 2195: ; 12/9/20: FCD:12/03/2021->06/21; 12/9/20: 0%->10; 25/9/20: WID:SP-200718->SP-200879; 5/12/20: 10%->100; 19/3/21: 100%->25; 11/6/21: 25%->80; 11/6/21: FCD:Fri 11/06/->12/21; 13/9/21: 80%->82; 13/12/21: 82%->100
- 2196: 24.501; 29.561 ; 12/3/22: 99%->100
- 2197: 24.501; 5/12/20: 0%->90; 5/12/20: FCD:12/03/2021->09/20; 21/3/21: 90%->95; 11/6/21: 95%->100
- 2198: 29.561; 5/12/20: 0%->75; 21/3/21: 75%->95; 21/3/21: WID:CP-202251->CP-210188; 11/6/21: 95%->100

| ID | WBS | Task | Duration | Start | Finish | Complete | Constraint | Resources | Work | Actual work | Acronym | PCG approved | WI rapporteur name | WI rapporteur e-mail | Release | TSG approved | Impacted TSs and TRs | Status Report | TSG stopped |
| --- | --- | --- | --- | --- | --- | --- | --- | --- | --- | --- | --- | --- | --- | --- | --- | --- | --- | --- | --- |
| 2199 | 976 | **Service-based support for SMS in 5GC** | 561.12d | 2020-09-16 A | 2022-03-11 A | 100% |  |  | 6208h | 6208h | SMS_SBI | 45 | HAOUARI, Wafa, Orange | wafa.haouari@orange.com | Rel-17 | 89 |  |  |  |
| 2200 | 976.1 | CT1 aspects of SMS_SBI | 388d | 2020-09-16 A | 2022-03-11 A | 100% | finish no earlier than 2022-03-12 | C1 | 3104h | 3104h | SMS_SBI | 45 | HAOUARI, Wafa, Orange | wafa.haouari@orange.com | Rel-17 | 89 | 23.040 |  |  |
| 2201 | 976.2 | CT4 aspects of SMS_SBI | 388d | 2020-09-16 A | 2022-03-11 A | 100% | finish no earlier than 2022-03-12 | C4 | 3104h | 3104h | SMS_SBI | 45 | HAOUARI, Wafa, Orange | wafa.haouari@orange.com | Rel-17 | 89 | 29.503; 29.540; 29.571; 23.540; 29.577; 29.579; 29.578 |  |  |
| 2202 | 977 | **Enhanced Relays for Energy eFficiency and Extensive Coverage** | 479.5d? | 2018-09-06 A | 2019-12-12 A | 100% |  |  | 2704h | 2704h | REFEC | 43 | Norp, Toon, KPN | toon.norp@tno.nl | Rel-17 | 84 | 22.261 |  |  |
| 2203 | 977.1 | Study on REFEC | 202d? | 2018-09-06 A | 2019-06-14 A | 100% | finish no earlier than 2019-06-14 | S1 | 1616h | 1616h | FS_REFEC | 41 | Jose Luis Almodovar Chico, KPN | jose.almodovarchico@tno.nl | Rel-17 | 81 | 22.866 |  |  |
| 2204 | 977.2 | Stage 1 of REFEC | 136d | 2019-06-06 A | 2019-12-12 A | 100% | finish no earlier than 2019-12-12 | S1 | 1088h | 1088h | REFEC | 43 | Norp, Toon, KPN | toon.norp@tno.nl | Rel-17 | 84 | 22.261 |  |  |
| 2205 | 978 | **Network Controlled Interactive Service** | 574.75d? | 2018-06-06 A | 2019-12-12 A | 100% |  |  | 2704h | 2704h | NCIS | 43 | Ning YANG, oppo | yangning@oppo.com | Rel-17 | 84 | 22.261 |  |  |
| 2206 | 978.1 | Study on NCIS | 202d? | 2018-06-06 A | 2019-03-14 A | 100% | finish no earlier than 2019-03-14 | S1 | 1616h | 1616h | FS_NCIS | 41 | YANG Ning, Oppo | yangning@oppo.com | Rel-17 | 80 | 22.842 |  |  |
| 2207 | 978.2 | Stage 1 of NCIS | 136d | 2019-06-06 A | 2019-12-12 A | 100% | finish no earlier than 2019-12-12 | S1 | 1088h | 1088h | NCIS | 43 | Ning YANG, oppo | yangning@oppo.com | Rel-17 | 84 | 22.261 |  |  |
| 2208 | 979 | 5G System Enhancement for Advanced Interactive Services | 527d | 2019-06-06 A | 2021-06-11 A | 100% | finish no earlier than 2021-06-12 | S2 | 4216h | 4216h | 5G_AIS | 43 | Lei Yixue, Tencent | yixuelei@tencent.com | Rel-17 | 84 | 23.501; 23.502; 23.503 |  |  |
| 2209 | 980 | Points for 8K VR 360 Video over 5G | 193d | 2020-09-16 A | 2021-06-11 A | 100% | finish no earlier than 2021-06-12 | S4 | 1544h | 1544h | 8K_VR_5G | 45 | Ozgur Oyman, Company: Intel | ozgur.oyman@intel.com | Rel-17 | 89 | 26.118; 26.511; 26.925 |  |  |
| 2210 | 981 | **Multi-Device and multi-identity Enhancements (MuDE)** | 483.5d | 2019-09-02 A | 2020-12-11 A | 100% |  |  | 1088h | 1088h | MuDE | 43 | Adrian.buckley@vivo.com |  | Rel-17 | 85 | 22.173 |  |  |
| 2211 | 981.1 | Stage 1 of MuDE | 14d | 2019-09-02 A | 2019-09-19 A | 100% | finish no earlier than 2019-09-19 | S1 | 112h | 112h | MuDE | 43 | Adrian.buckley@vivo.com |  | Rel-17 | 85 | 22.173 |  |  |
| 2212 | 981.2 | Stage 3 of MuDE | 122d | 2020-06-25 A | 2020-12-11 A | 100% | finish no earlier than 2020-12-12 | C1 | 976h | 976h | MuDe | 45 | Adrian Buckley | adrian.buckley@vivo.com | Rel-17 | 88 |  |  |  |
| 2213 | 982 | **Best Practice of Packet Forwarding Control Protocol (PFCP)** | 647.12d | 2020-06-25 A | 2022-03-11 A | 100% |  | ct | 10728h | 10728h | BEPoP | 45 | Song Yue, China Mobile | songyue@chinamobile.com | Rel-17 | 88 | 29.820 |  |  |
| 2214 | 982.1 | CT3 aspects of BEPoP | 447d | 2020-06-25 A | 2022-03-11 A | 100% | finish no earlier than 2022-03-12 | C3 | 3576h | 3576h | BEPoP | 45 | Song Yue, China Mobile | songyue@chinamobile.com | Rel-17 | 88 | 29.820 |  |  |
| 2215 | 982.2 | CT4 aspects of BEPoP | 447d | 2020-06-25 A | 2022-03-11 A | 100% | finish no earlier than 2022-03-12 | C4 | 3576h | 3576h | BEPoP | 45 | Song Yue, China Mobile | songyue@chinamobile.com | Rel-17 | 88 | 29.820 |  |  |
| 2216 | 983 | Extension for headset interface tests of UE | 317d | 2020-06-25 A | 2021-09-10 A | 100% | start no earlier than 2020-06-25 | S4 | 2536h | 2536h | HInT | 45 | Jan Reimes, HEAD acoustics GmbH, | jan.reimes@head-acoustics.com | Rel-17 | 88 |  |  |  |
| 2217 | 984 | MC services support on IOPS mode of operation | 332d | 2019-06-06 A | 2020-09-11 A | 100% | finish no earlier than 2020-09-12 | S6 | 2656h | 2656h | MCIOPS | 43 | Camilo.solano@ericsson.com | 23.280; 23.379; 23.281; 23.282 | Rel-17 | 84 | 23.180 | Camilo Solano, Ericsson |  |
| 2218 | 985 | Stopped - Supporting Flexible Local Area Data Network | 332d | 2019-06-06 A | 2020-09-11 A | 100% | finish no earlier than 2020-09-11 | S2 | 2656h | 2656h | FLADN | 43 | LG Electronics, Hyunsook Kim | hyuns.kim@lge.com | Rel-17 | 84 | 23.501; 23.502 |  | 95 |
| 2219 | 986 | Support of Immersive Teleconferencing and Telepresence for Remote Terminals | 846.88d | 2018-12-13 A | 2022-03-11 A | 100% | finish no earlier than 2022-03-12 | S4 | 6775h | 6775h | ITT4RT | 42 | Ozgur Oyman, Intel | Ozgur.Oyman@Intel.com | Rel-17 | 82 | 26.114; 26.223; 26.962; 26.862 |  |  |
| 2220 | 987 | Handsets Featuring Non-Traditional Earpieces | 591d | 2019-12-06 A | 2022-03-11 A | 100% | finish no earlier than 2022-03-12 | S4 | 4728h | 4728h | HaNTE | 44 | Schevciw, Andre, Qualcomm Incorporated | aschevci@qti.qualcomm.com | Rel-17 | 86 | 26.131; 26.132; 26.801 |  |  |
| 2221 | 988 | **5GMS AF Event Exposure** | 377.88d | 2021-06-11 A | 2022-06-10 A | 100% |  | S4 | 4240h | 4240h | EVEX | 47 | Lo, Charles, Qualcomm Inc., | clo@qti.qualcomm.com | Rel-17 | 92 | 26.512;26.501 ; 26.531; 26.532 |  |  |
| 2222 | 988.1 | Stage 2 of EVEX | 261d | 2021-06-11 A | 2022-06-10 A | 100% | finish no earlier than 2022-06-12 | S4 | 2088h | 2088h | EVEX | 47 | Lo, Charles, Qualcomm Inc., | clo@qti.qualcomm.com | Rel-17 | 92 | 26.512;26.501 ; 26.531; 26.532 |  |  |
| 2223 | 988.2 | Stage 3 (CT3) of EVEX | 8d | 2022-06-01 A | 2022-06-10 A | 100% | finish no earlier than 2022-06-10 | C3 | 64h | 64h | EVEX | 49 | Waqar Zia, Qualcomm Incorporated | wzia@qti.qualcomm.com | Rel-17 | 96 | 29.522; 29.517; 29.591 |  |  |
| 2224 | 989 | Edge Extensions to the 5G Media Streaming Architecture | 64d | 2021-06-11 A | 2021-09-08 A | 100% | start no earlier than 2021-06-11 | S4 | 512h | 512h | 5GMS_EDGE | 47 | Bouazizi, Imed, Qualcomm Inc. | bouazizi@qti.qualcomm.com | Rel-17 | 92 | 26.501 |  |  |
| 2225 | 990 | 5G Multicast-Broadcast User Service Architecture and related 5GMS Extensions | 196d | 2021-06-11 A | 2022-03-11 A | 100% | finish no earlier than 2022-03-12 | S4 | 1568h | 1568h | 5MBUSA | 47 | TAN, PENG, TELUS | peng.tan@telus.com | Rel-17 | 92 | 26.501 ; 26.502 |  |  |
| 2226 | 991 | 8K Television over 5G | 196d | 2021-06-11 A | 2022-03-11 A | 100% | start no earlier than 2021-06-11 | S4 | 1568h | 1568h | 8K_TV_5G | 47 | Thomas Stockhammer | tsto@qti.qualcomm.com | Rel-17 | 92 | 26.955;26.925;26.511;26.116 |  |  |
| 2227 | 992 | Verification-modified Calling Name Display | 11d? | 2019-03-07 A | 2019-03-21 A | 100% | finish no earlier than 2019-03-21 | S1 | 88h | 88h | VMOD_DISPLAY | 42 | Hala Mowafy, Ericsson | Hala.Mowafy@ericsson.com | Rel-17 | 83 | 22.173 |  |  |
| 2228 | 993 | Enhanced Calling Name Service Analytics Interworking | 14d | 2019-09-02 A | 2019-09-19 A | 100% | finish no earlier than 2019-09-19 | S1 | 112h | 112h | eCNAM_An | 43 | Hala.Mowafy@ericsson.com |  | Rel-17 | 85 | 22.173 |  |  |

Notes:
- 2199: 25/9/20: WID:CP-202028->CP-202242; 10/9/21: WID:CP-202242->CP-212023
- 2200: 12/3/22: FCD:12/03/2021->3/22; 12/3/22: 0%->100
- 2201: 13/9/20: FCD:12/03/2021->09/21; 5/12/20: 0%->15; 21/3/21: 15%->25; 11/6/21: 25%->35; 13/9/21: FCD:Wed 08/09/->03/22; 13/9/21: 35%->40; 1/10/21: 23.540 added;; 13/12/21: 40%->45; 12/3/22: 45%->65; 22/3/22: 29.577 added;; 22/3/22: 29.579 added;; 22/3/22: ; 3/8/22: 99%->90
- 2203: 4/12/18: 0%->20¦14/3/19: 20%->40; 31/5/19: 40%->60; 13/9/19: 60%->95; 6/12/19: 95%->100
- 2204: 13/9/19: 0%->90; 6/12/19: 90%->100
- 2206: 6/8/18: 22.842 added;¦10/9/18: 0%->25¦4/12/18: 25%->60¦14/3/19: 60%->85; 31/5/19: 85%->100
- 2207: 13/9/19: 0%->85; 6/12/19: 80%->100; 12/12/19: WID:SP-190303->SP-191039
- 2208: 5/12/20: 0%->10; 5/12/20: FCD:10/09/2020->06/20; 19/3/21: 10%->40; 11/6/21: 40%->100
- 2209: ; 5/12/20: 0%->25; 21/3/21: 25%->85; 21/3/21: FCD:12/03/2021->06/21; 11/6/21: 85%->100
- 2210: ; 13/9/19: 0%->100
- 2211: ; 13/9/19: 0%->100
- 2212: 24.174 ; 13/9/20: 0%->15; 21/3/21: 15%->40; 11/6/21: 40%->100
- 2213: 29.244; 29.510 ; 2/7/20: 0%->5; 13/9/20: 5%->10; 25/9/20: 29.820 added;; 5/12/20: 10%->20; 21/3/21: 20%->30; 11/6/21: WID:CP-201076->CP-210074; 10/9/21: WID:CP-210074->CP-212024
- 2214: 29.244; 29.510 ; 2/7/20: 0%->5; 13/9/20: 5%->10; 25/9/20: 29.820 added;; 5/12/20: 10%->20; 21/3/21: 20%->30; 11/6/21: 0%->60; 10/9/21: FCD:Wed 15/09/->03/22; 13/9/21: 60%->85; 12/3/22: 85%->100
- 2215: 29.244; 29.510 ; 2/7/20: 0%->5; 13/9/20: 5%->10; 25/9/20: 29.820 added;; 5/12/20: 10%->20; 21/3/21: 20%->30; 11/6/21: 30%->45; 10/9/21: FCD:Wed 15/09/->03/22; 13/9/21: 45%->55; 13/12/21: 55%->80; 12/3/22: 80%->100
- 2216: 26.131; 26.132 ; 12/9/20: 0%->10; 5/12/20: 10%->25; 21/3/21: 25%->50; 11/6/21: 50%->70; 13/9/21: 70%->75; 13/12/21: 75%->100
- 2217: 13/9/19: 0%->10; 20/9/19: WID:SP-190480->SP-190944; 8/10/19: 23.180 added;; 6/12/19: 10%->40; 26/3/20: FCD:12/03/2020->09/20; 26/3/20: 40%->50; 28/6/20: 50%->75; 13/9/20: 75%->95; 5/12/20: 95%->100
- 2218: 21/1/22: stopped at 0%; 21/1/22: 0%->100
- 2219: 7/3/19: 0%->5%; 31/5/19: 0%->10; 13/9/19: 10%->20; 6/12/19: 20%->25; 25/3/20: 25%->35; 10/6/20: 35%->45; 26/6/20: 45%->45; 12/9/20: 45%->50; 5/12/20: 50%->55; 5/12/20: FCD:18/12/2020->06/20; 21/3/21: 55%->60; 11/6/21: 60%->75; 11/6/21: FCD:Fri 11/06/->
- 2220: 25/3/20: 0%->5; 20/4/20: FCD:12/03/2020->09/20. Study in Rel-16; 10/6/20: 5%->25; 26/6/20: 25%->25; 12/9/20: 25%->35; 12/9/20: FCD:15/09/2020->12/20; 5/12/20: 35%->35; 5/12/20: FCD:15/12/2020->03/20; 21/3/21: 35%->50; 21/3/21: FCD:12/03/2021->09/21; 11
- 2221: ; 13/9/21: 0%->10; 1/10/21: 26.531 & 26.532 added;; 13/12/21: 10%->40; 12/3/22: 40%->60; 12/3/22: FCD:11/03/2022->6/22
- 2222: ; 13/9/21: 0%->10; 1/10/21: 26.531 & 26.532 added;; 13/12/21: 10%->40; 12/3/22: 40%->60; 12/3/22: FCD:11/03/2022->6/22; 4/6/22: 60%->100
- 2224: ; 13/9/21: 0%->30; 13/12/21: 30%->100
- 2225: ; 13/9/21: 0%->5; 1/10/21: 26.502 added;; 13/12/21: 5%->60; 12/3/22: FCD:10/06/2022->3/22; 12/3/22: 60%->100
- 2226: ; 13/9/21: 0%->40; 13/12/21: 40%->60; 12/3/22: 60%->100
- 2227: 14/3/19: 0%->100
- 2228: ; 13/9/19: 0%->100

| ID | WBS | Task | Duration | Start | Finish | Complete | Constraint | Resources | Work | Actual work | Acronym | PCG approved | WI rapporteur name | WI rapporteur e-mail | Release | TSG approved | Status Report |
| --- | --- | --- | --- | --- | --- | --- | --- | --- | --- | --- | --- | --- | --- | --- | --- | --- | --- |
| 2229 | 994 | **Enhancement for the 5G Control Plane Steering of Roaming for UE in Connected mode** | 1324.38d | 2019-09-02 A | 2023-03-03 A | 100% |  |  | 15504h | 15504h | eCPSOR_CON | 43 | Minokuchi, Atsushi, NTT DOCOMO | minokuchi at nttdocomo dot com | Rel-17 | 85 |  |
| 2230 | 994.1 | Stage 1 of eCPSOR_CON | 470d | 2019-09-02 A | 2021-06-18 A | 100% | finish no earlier than 2021-06-20 | S1 | 3760h | 3760h | eCPSOR_CON | 43 | Minokuchi, Atsushi, NTT DOCOMO | minokuchi at nttdocomo dot com | Rel-17 | 85 |  |
| 2231 | 994.2 | Stage 3 (CT1) of eCPSOR_CON | 447d | 2020-06-25 A | 2022-03-11 A | 100% | finish no earlier than 2022-03-12 | C1 | 3576h | 3576h | eCPSOR_CON | 45 | Al-Bakri Ban, NTT DOCOMO | ban.albakri@meadowcom.com | Rel-17 | 88 |  |
| 2232 | 994.3 | Stage 3 (CT4) of eCPSOR_CON | 447d | 2020-06-25 A | 2022-03-11 A | 100% | finish no earlier than 2022-03-11 | C4 | 3576h | 3576h | eCPSOR_CON | 46 | Al-Bakri Ban, NTT DOCOMO | ban.albakri@meadowcom.com | Rel-17 | 90 |  |
| 2233 | 994.4 | Stage 3 (CT6) of eCPSOR_CON | 447d | 2020-06-25 A | 2022-03-11 A | 100% | finish no earlier than 2022-03-12 | C6 | 3576h | 3576h | eCPSOR_CON | 47 | Al-Bakri Ban, NTT DOCOMO | ban.albakri@meadowcom.com | Rel-17 | 92 |  |
| 2234 | 994.5 | UE Conformance - Enhancement for the 5G Control Plane Steering of Roaming for UE in Connected mode | 127d | 2022-09-08 A | 2023-03-03 A | 100% | finish no earlier than 2023-03-03 | R5 | 1016h | 1016h | eCPSOR_CON-UEConTest | 49 | Masahiro Takano, NTT DOCOMO, INC | masahiro[dot]takano[dot]ru[at]nttdocomo[dot]com | Rel-17 | 97 | RP-230359 |
| 2235 | 995 | **Integration of Generic Bootstrapping Architecture (GBA) into 5GC** | 1423.88d | 2018-06-06 A | 2022-03-11 A | 100% |  |  | 14571.4h | 14571.4h | GBA_5G | 43 | Vlasios Tsiatsis, Ericsson | vlasios.tsiatsis@ericsson.com | Rel-17 | 85 |  |
| 2236 | 995.1 | Security aspects of Integration of GBA into 5GC | 582d | 2019-09-19 A | 2021-12-10 A | 100% | finish no earlier than 2021-12-12 | S3 | 4656h | 4656h | GBA_5G | 43 | Vlasios Tsiatsis, Ericsson | vlasios.tsiatsis@ericsson.com | Rel-17 | 85 |  |
| 2237 | 995.2 | CT aspects of Integration of GBA into SBA | 257d | 2021-03-18 A | 2022-03-11 A | 100% | finish no earlier than 2022-03-12 | C4 | 2056h | 2056h | GBA_5G | 46 | de Gregorio, Jesús (Ericsson) | jesus.de.gregorio@ericsson.com | Rel-17 | 91 |  |
| 2238 | 995.3 | Integration of Generic Bootstrapping Architecture (GBA) into 5GC | 982.42d | 2018-06-06 A | 2022-03-11 A | 100% | finish no earlier than 2022-03-12 | S3 | 7859.36h | 7859.36h | GBA_5G | 43 | Vlasios Tsiatsis, Ericsson | vlasios.tsiatsis@ericsson.com | Rel-17 | 85 |  |
| 2239 | 996 | **Support for Minimization of service Interruption** | 1140.12d | 2019-03-07 A | 2022-03-11 A | 100% |  |  | 6615h | 6615h | MINT | 43 | SungDuck Chun; LG Electronics | sungduck.chun@lge.com | Rel-17 | 85 |  |
| 2240 | 996.1 | Study on MINT | 130.88d | 2019-03-07 A | 2019-09-05 A | 100% |  | S1 | 1047h | 1047h | FS_MINT | 42 | SungDuck Chun; LG Electronics | sungduck.chun@lge.com | Rel-17 | 83 |  |
| 2241 | 996.2 | Stage 1 of MINT | 65d | 2019-09-13 A | 2019-12-12 A | 100% | finish no earlier than 2019-12-12 | S1 | 520h | 520h | MINT | 43 | SungDuck Chun; LG Electronics | sungduck.chun@lge.com | Rel-17 | 85 |  |
| 2242 | 996.3 | Stage 2 of MINT | 87d | 2021-08-12 A | 2021-12-10 A | 100% | finish no earlier than 2021-12-12 | S2 | 696h | 696h | MINT | 47 | Hyunsook Kim, LG Electronics | hyuns.kim@lge.com | Rel-17 | 92 |  |
| 2243 | 996.4 | Study on the CT aspects of Support for Minimization of service Interruption | 70d | 2020-12-07 A | 2021-03-12 A | 100% | finish no earlier than 2021-03-12 | C1 | 560h | 560h | FS_MINT-CT | 46 | Sang Min Park, LG Electronics | sangmin2.park@lge.com | Rel-17 | 90 |  |
| 2244 | 996.5 | **Stage 3 of MINT** | 169.62d | 2021-09-29 A | 2022-03-11 A | 100% |  | ct | 3776h | 3776h | MINT | 47 | Hyunsook Kim, LG Electronics | hyuns.kim@lge.com | Rel-17 | 93 |  |
| 2245 | 996.5.1 | CT1 aspects of MINT | 118d | 2021-09-29 A | 2022-03-11 A | 100% | finish no earlier than 2022-03-12 | C1 | 944h | 944h | MINT | 47 | Hyunsook Kim, LG Electronics | hyuns.kim@lge.com | Rel-17 | 93 |  |
| 2246 | 996.5.2 | CT4 aspects of MINT | 118d | 2021-09-29 A | 2022-03-11 A | 100% | finish no earlier than 2022-03-12 | C4 | 944h | 944h | MINT | 47 | Hyunsook Kim, LG Electronics | hyuns.kim@lge.com | Rel-17 | 93 |  |
| 2247 | 996.5.3 | CT6 aspects of MINT | 118d | 2021-09-29 A | 2022-03-11 A | 100% | finish no earlier than 2022-03-12 | C6 | 944h | 944h | MINT | 47 | Hyunsook Kim, LG Electronics | hyuns.kim@lge.com | Rel-17 | 93 |  |
| 2248 | 996.6 | Security Aspects of MINT | 2d | 2022-03-10 A | 2022-03-11 A | 100% | finish no earlier than 2022-03-12 | S3 | 16h | 16h | MINT | 48 | Dongjoo Kim, LG Electronics | dongjoo7.kim@lge.com | Rel-17 | 95 |  |
| 2249 | 997 | IMS emergency support for Stand-alone Non-Public Network (SNPN) | 6d | 2019-12-06 A | 2019-12-13 A | 100% | finish no earlier than 2019-12-13 | S1 | 48h | 48h | IESNPN | 44 | Wong, Curt; | curt.wong@charter.com | Rel-17 | 86 |  |
| 2250 | 998 | Management of non-public networks (NPN) | 513d | 2020-03-25 A | 2022-03-11 A | 100% | finish no earlier than 2022-03-12 | S5 | 4104h | 4104h | OAM_NPN | 44 | ZHANG, Kai, Huawei | kai.zhangkai@huawei.com | Rel-17 | 87 |  |
| 2251 | 999 | Assurance Specification for IMS | 396d | 2019-12-06 A | 2021-06-11 A | 100% | finish no earlier than 2021-06-12 | S3 | 3168h | 3168h | SCAS_IMS | 44 | Bo Zhang, Huawei Technologies | zhangbo6@huawei.com | Rel-17 | 86 |  |
| 2252 | 1000 | **Security Assurance Specification for 5G (eSCAS_5G)** | 836.62d | 2020-03-25 A | 2022-06-10 A | 100% |  | S3 | 23168h | 23168h | eSCAS_5G | 44 | Rong Wu, Huawei Technologies Co. | Raina.wu@huawei.com | Rel-17 | 87 |  |
| 2253 | 1000.1 | eSCAS_5G for Network Slice-Specific Authentication and Authorization Function (NSSAAF) | 323d | 2020-09-16 A | 2021-12-10 A | 100% | finish no earlier than 2021-12-12 | S3 | 2584h | 2584h | SCAS_5G_NSSAAF | 45 | Rong Wu, Huawei Technologies Co., Ltd. | Raina.wu@huawei.com | Rel-17 | 89 |  |
| 2254 | 1000.2 | eSCAS_5G for Non-3GPP InterWorking Function | 448d | 2020-03-25 A | 2021-12-10 A | 100% | finish no earlier than 2021-12-12 | S3 | 3584h | 3584h | SCAS_5G_N3IWF | 44 | Feng Gao, China Unicom | gaofeng149@chinaunicom.cn | Rel-17 | 87 |  |
| 2255 | 1000.3 | eSCAS_5G for 5G NWDAF | 578d | 2020-03-25 A | 2022-06-10 A | 100% | finish no earlier than 2022-06-12 | S3 | 4624h | 4624h | SCAS_5G_NWDAF | 44 | QI Minpeng, China Mobile | qiminpeng@chinamobile.com | Rel-17 | 87 |  |
| 2256 | 1000.4 | eSCAS_5G for Service Communication Proxy | 578d | 2020-03-25 A | 2022-06-09 A | 100% | finish no earlier than 2022-06-12 | S3 | 4624h | 4624h | SCAS_5G_SECOP | 44 | Wei Lu, Nokia | wei.lu@nokia-sbell.com | Rel-17 | 87 |  |
| 2257 | 1000.5 | eSCAS_5Gfor Inter PLMN UP Security | 391d | 2020-06-12 A | 2021-12-10 A | 100% | finish no earlier than 2021-12-12 | S3 | 3128h | 3128h | SCAS_5G_IPUPS | 45 | Jin PENG, ZTE Corporation | peng.jin1@zte.com.cn | Rel-17 | 88 |  |

Notes:
- 2229: ; 13/9/19: 0%->100; 13/6/21: WID:SP-190941->CP-210148 / Impacted TSs and TRs: 22.261
- 2230: ; 13/9/19: 0%->100; 5/12/20: 100%->10; 5/12/20: FCD:19/09/2019->06/20; 11/3/22: 10%->100 / Impacted TSs and TRs: 22.261
- 2231: 23.122; 24.501; 29.503; 29.505; 29.550; 29.509; 29.571; 31.102; 31.111 ; 13/9/20: 0%->5; 13/9/20: WID:CP-201166->CP-202186; 21/3/21: 5%->35; 11/6/21: 35%->50; 13/9/21: 50%->70; 13/9/21: FCD:Fri 18/06/->03/22; 13/12/21: 70%->92; 12/3/22: 92%->100
- 2232: 23.122; 24.501; 29.503; 29.505; 29.550; 29.509; 29.571; 31.102; 31.111 ; 13/9/20: 0%->5; 13/9/20: WID:CP-201166->CP-202186; 5/12/20: 0%->5; 21/3/21: 5%->5; 11/6/21: 5%->10; 13/12/21: 10%->70; 13/12/21: FCD:Fri 18/06/->03/22; 12/3/22: 70%->100
- 2233: 23.122; 24.501; 29.503; 29.505; 29.550; 29.509; 29.571; 31.102; 31.111 ; 13/9/20: 0%->5; 13/9/20: WID:CP-201166->CP-202186; 5/12/20: 0%->5; 21/3/21: 5%->5; 11/6/21: 5%->10; 13/9/21: 0%->70; 13/9/21: FCD:Fri 18/06/->03/22; 12/3/22: 70%->100; 4/6/22: 100
- 2234: 9/12/22: FCD:08/09/2023->01/09/2023; Compl:0%->80%; Stat Rep: ->RP-223159; Rapporteur: NTT DOCOMO->Masahiro Takano, NTT DOCOMO, INC; Rap eMail: ->masahiro[dot]takano[dot]ru[at]nttdocomo[dot]com; 17/3/23: FCD:09/09/2023->03/03/2023; Compl:80%->100%; ...
- 2235: 26/6/20: FCD:12/06/2020->09/20; 26/6/20: 0%->5; 12/9/20: 5%->50; 12/9/20: FCD:15/09/2020->12/20; 5/12/20: 50%->55; 5/12/20: FCD:15/12/2020->03/20 / Impacted TSs and TRs: 33.220; 33.222; 33.223; 33.501
- 2236: 26/6/20: FCD:12/06/2020->09/20; 26/6/20: 0%->5; 12/9/20: 5%->50; 12/9/20: FCD:15/09/2020->12/20; 5/12/20: 50%->55; 5/12/20: FCD:15/12/2020->03/20; 19/3/21: FCD:12/03/2021->09/21; 11/6/21: FCD:Wed 08/09/->12/21; 13/9/21: 55%->80; 13/12/21: 80%->100 / Impacted TSs and TRs: 33.220; 33.222; 33.223; 33.501
- 2237: ; 21/3/21: 0%->5; 11/6/21: 5%->15; 13/9/21: 15%->60; 13/12/21: 60%->80; 12/3/22: 80%->100 / Impacted TSs and TRs: 29.503; 29.505; 29.510; 29.562; 29.571
- 2238: 26/6/20: FCD:12/06/2020->09/20; 26/6/20: 0%->5; 12/9/20: 5%->50; 12/9/20: FCD:15/09/2020->12/20; 5/12/20: 50%->55; 5/12/20: FCD:15/12/2020->03/20; 24/3/22: 0%->100 / Impacted TSs and TRs: 33.220; 33.222; 33.223; 33.501
- 2239: Impacted TSs and TRs: 22.011; 22.261
- 2240: 31/5/19: 0%->65; 13/9/19: 65%->100 / Impacted TSs and TRs: New
- 2241: 13/9/19: 0%->80; 6/12/19: 80%->100 / Impacted TSs and TRs: 22.011; 22.261
- 2242: 13/9/21: 0%->50; 10/12/21: 50%->90; 12/3/22: 90%->98; 4/6/22: 98%->100 / Impacted TSs and TRs: 23.501; 23.502
- 2243: 21/3/21: 0%->60; 11/6/21: 60%->95; 13/9/21: 95%->100
- 2244: Impacted TSs and TRs: 23.122; 24.501; 31.102; 31.111
- 2245: ; 13/12/21: 0%->50; 12/3/22: 50%->85; 4/6/22: 85%->100 / Impacted TSs and TRs: 23.122; 24.501; 31.102; 31.111
- 2246: ; 12/3/22: 0%->80; 20/6/22: Compl:80%->100% / Impacted TSs and TRs: 23.122; 24.501; 31.102; 31.111
- 2247: ; 12/3/22: 0%->100; 4/6/22: 100%->100 / Impacted TSs and TRs: 23.122; 24.501; 31.102; 31.111
- 2248: ; 22/3/22: 0%->100 / Impacted TSs and TRs: 33.501
- 2249: 6/12/19: 0%->100 / Impacted TSs and TRs: 22.101; 22.261; 22.228
- 2250: ; 13/9/20: 0%->5; 5/12/20: 5%->15; 21/3/21: 15%->35; 11/6/21: 35%->50; 11/6/21: FCD:Wed 16/06/->12/21; 13/9/21: 50%->70; 13/12/21: 70%->85; 13/12/21: FCD:Fri 10/12/->03/22; 12/3/22: 85%->100 / Impacted TSs and TRs: 28.541; 28.531; 28.533; 28.552; 28.554
- 2251: ; 26/6/20: 0%->15; 12/9/20: 15%->40; 5/12/20: 40%->60; 5/12/20: FCD:11/12/2020->03/20; 19/3/21: 60%->80; 19/3/21: FCD:12/03/2021->06/21; 11/6/21: 80%->90; 13/12/21: 90%->100 / Impacted TSs and TRs: 33.926
- 2252: 26/6/20: 0%->5 / Impacted TSs and TRs: 33.926; 33.117; 33.511; 33.512; 33.513; 33.514; 33.515; 33.516; 33.517; 33.518; 33.519
- 2253: 5/12/20: 0%->5; 19/3/21: 5%->40; 9/4/21: 40%->60; 11/6/21: 60%->45; 11/6/21: FCD:Fri 11/06/->12/21; 13/9/21: 45%->100 / Impacted TSs and TRs: 33.926; 33.326
- 2254: 26/6/20: 0%->10; 19/3/21: 10%->20; 19/3/21: FCD:17/03/2021->06/21; 9/4/21: 20%->60; 11/6/21: 60%->20; 11/6/21: FCD:Fri 11/06/->12/21; 13/12/21: 20%->100 / Impacted TSs and TRs: 33.926; 33.520
- 2255: 26/6/20: 0%->10; 5/12/20: 10%->60; 19/3/21: 60%->70; 19/3/21: FCD:17/03/2021->06/21; 11/6/21: 70%->85; 11/6/21: FCD:Fri 11/06/->12/21; 11/6/21: 85%->; 13/9/21: 85%->90; 12/3/22: FCD:10/12/2021->06/22; 4/6/22: 90%->100 / Impacted TSs and TRs: 33.521; 33.926
- 2256: 26/6/20: 0%->10; 12/9/20: 10%->20; 19/3/21: FCD:17/03/2021->06/21; 9/4/21: 20%->60; 11/6/21: 60%->70; 11/6/21: FCD:Fri 11/06/->12/21; 13/12/21: 70%->95; 12/3/22: 95%->95; 12/3/22: FCD:10/12/2021->06/22; 31/3/23: 95%->100 / Impacted TSs and TRs: 33.522; 33.926
- 2257: 33.926; 33.513 ; 12/9/20: 0%->20; 19/3/21: 20%->70; 11/6/21: 70%->90; 11/6/21: FCD:Fri 11/06/->12/21; 13/9/21: 90%->100

| ID | WBS | Task | Duration | Start | Finish | Complete | Constraint | Resources | Work | Actual work | Acronym | PCG approved | WI rapporteur name | WI rapporteur e-mail | Release | TSG approved | Status Report |
| --- | --- | --- | --- | --- | --- | --- | --- | --- | --- | --- | --- | --- | --- | --- | --- | --- | --- |
| 2258 | 1001 | **Enhanced Mission Critical Push-to-talk architecture phase 3** | 552d | 2020-03-25 A | 2021-09-08 A | 100% |  |  | 4624h | 4624h | enh3MCPTT | 44 | Dom Lazara; Motorola Solutions | Dom.Lazara@motorolasolutions.com | Rel-17 | 87 |  |
| 2259 | 1001.1 | Stage 2 aspects of enh3MCPTT | 320d | 2020-03-25 A | 2021-06-15 A | 100% | finish no earlier than 2021-06-15 | S6 | 2560h | 2560h | enh3MCPTT | 44 | Dom Lazara; Motorola Solutions | Dom.Lazara@motorolasolutions.com | Rel-17 | 87 |  |
| 2260 | 1001.2 | Stage 3 aspects of enh3MCPTT | 258d | 2020-09-14 A | 2021-09-08 A | 100% | finish no earlier than 2021-09-08 | C1 | 2064h | 2064h | enh3MCPTT-CT | 44 |  |  | Rel-17 | 87 |  |
| 2261 | 1002 | Protocol enhancements for Mission Critical Services | 381d | 2020-09-25 A | 2022-03-11 A | 100% | finish no earlier than 2022-03-12 | C1 | 3048h | 3048h | MCProtoc17 | 45 | AXELL, Jörgen | jorgen.axell@ericsson.com | Rel-17 | 88 |  |
| 2262 | 1003 | UE Conformance - Protocol enhancements for Mission Critical Services (MCPTT, MCVideo, MCData) for Rel-17 | 476.12d | 2024-09-09 A | 2025-12-12 A | 100% | finish no earlier than 2025-12-12 | R5 | 3809h | 3809h | MCProtoc17_enh3MCPTT_eMCData3_MCOver5GS-UEConTest | 53 | Ericsson |  | Rel-17 | 105 | RP-253305 |
| 2263 | 1004 | IMS Charging in 5G System Architecture | 657d | 2019-06-06 A | 2021-12-10 A | 100% | finish no earlier than 2021-12-12 | S5 | 5256h | 5256h | 5GSIMSCH | 43 | Jahangir, Zeeshan, T-Mobile USA | Zeeshan.jahangir@t-mobile.com | Rel-17 | 84 |  |
| 2264 | 1005 | Study on User Plane Integrity Protection | 587d | 2018-12-13 A | 2021-03-12 A | 100% | finish no earlier than 2021-03-12 | S3 | 4696h | 4696h | FS_UP_IP_Sec | 42 | Evans, Tim, Vodafone | tim.evans1@vodafone.com | Rel-17 | 82 |  |
| 2265 | 1006 | Enhancements to User Plane Integrity Protection Support in 5GS | 128d | 2020-09-16 A | 2021-03-12 A | 100% | finish no earlier than 2021-03-12 | S3 | 1024h | 1024h | eUPIP_SEC | 45 | Anand Palanigounder, Qualcomm Incorporated | apg@qti.qualcomm.com | Rel-17 | 89 |  |
| 2266 | 1007 | **Non-Seamless WLAN offload in 5GS** | 301.12d | 2021-05-25 A | 2022-03-11 A | 100% |  | S3 | 2864h | 2864h | NSWO_5G | 48 | Ranganathan Mavureddi Dhanasekaran, Nokia | ranganathan.mavureddi_dhanasekaran@nokia-bell-labs.com | Rel-17 | 95 |  |
| 2267 | 1007.1 | Study on non-seamless WLAN Offload in 5GS using 3GPP credentials | 77d | 2021-05-25 A | 2021-09-08 A | 100% | finish no earlier than 2021-09-08 | S3 | 616h | 616h | FS_NSWO_5G | 46 | Nair, Suresh, Nokia | suresh.p.nair@nokia.com | Rel-17 | 91 |  |
| 2268 | 1007.2 | Security aspects of NSWO | 66d | 2021-12-10 A | 2022-03-11 A | 100% | finish no earlier than 2022-03-12 | S3 | 528h | 528h | NSWO_5G | 48 | Ranganathan Mavureddi Dhanasekaran, Nokia | ranganathan.mavureddi_dhanasekaran@nokia-bell-labs.com | Rel-17 | 94 |  |
| 2269 | 1007.3 | CT1 aspects of NSWO | 2d | 2022-03-10 A | 2022-03-11 A | 100% | finish no earlier than 2022-03-12 | C1 | 16h | 16h | NSWO_5G | 48 | Wiehe, Ulrich, Nokia | ulrich.wiehe@nokia.com | Rel-17 | 95 |  |
| 2270 | 1007.4 | CT4 aspects of NSWO | 2d | 2022-03-10 A | 2022-03-11 A | 100% | finish no earlier than 2022-03-12 | C4 | 16h | 16h | NSWO_5G | 48 | Wiehe, Ulrich, Nokia | ulrich.wiehe@nokia.com | Rel-17 | 95 |  |
| 2271 | 1007.5 | CT6 aspects of NSWO | 2d | 2022-03-10 A | 2022-03-11 A | 100% | finish no earlier than 2022-03-12 | C6 | 16h | 16h | NSWO_5G | 48 | Wiehe, Ulrich, Nokia | ulrich.wiehe@nokia.com | Rel-17 | 95 |  |
| 2272 | 1008 | **Lawful Interception Rel-17** | 946.38d | 2019-12-10 A | 2022-06-10 A | 100% |  | S3 | 20944h | 20944h | LI17 | 44 | Alex Leadbeater, BT | alex.leadbeater@bt.com | Rel-17 | 86 |  |
| 2273 | 1008.1 | Lawful Interception Rel-17 general aspects | 654d | 2019-12-10 A | 2022-06-10 A | 100% | finish no earlier than 2022-06-12 | S3 | 5232h | 5232h | LI17 | 44 | Alex Leadbeater, BT | alex.leadbeater@bt.com | Rel-17 | 86 |  |
| 2274 | 1008.2 | (IETF) PASSporT Extension for Rich Call Data (draft-ietf-stir-passport-rcd) | 655d | 2019-12-10 A | 2022-06-10 A | 100% | finish no earlier than 2022-06-10 | S3-IETF | 5240h | 5240h | LI17 | 50 | Lionel Morand, Orange | lionel.morand@orange.com | Rel-17 | 99 |  |
| 2275 | 1008.3 | (IETF) Messaging Use Cases and Extensions for STIR (draft-ietf-stir-messaging) | 655d | 2019-12-10 A | 2022-06-10 A | 100% | finish no earlier than 2022-06-10 | S3-IETF | 5240h | 5240h | LI17 | 50 | Lionel Morand, Orange | lionel.morand@orange.com | Rel-17 | 99 |  |
| 2276 | 1009 | **(Small) Technical Enhancements and Improvements for Rel-17** | 756.88d | 2020-03-11 A | 2022-03-11 A | 100% |  |  | 39464h | 39464h | TEI17 | 43 |  |  | Rel-17 | 85 |  |
| 2277 | 1009.1 | **IMS Optimization for HSS Group ID in an SBA environment (St. 2)** | 756.88d | 2020-03-11 A | 2022-03-11 A | 100% |  | S2 | 8832h | 8832h | TEI17_IMSGID | 44 | Foti, George, Ericsson | George.foti@ericsson.com | Rel-17 | 87 |  |
| 2278 | 1009.1.1 | Stage 2 for TEI17_IMSGID | 58d | 2020-03-25 A | 2020-06-12 A | 100% | finish no earlier than 2020-06-12 | S2 | 464h | 464h | TEI17_IMSGID | 44 | Foti, George, Ericsson | George.foti@ericsson.com | Rel-17 | 87 |  |
| 2279 | 1009.1.2 | Stage 3 for TEI17_IMSGID | 523d | 2020-03-11 A | 2022-03-11 A | 100% |  | C1 | 4184h | 4184h | TEI17_IMSGID | 48 | Axell, Jörgen, Ericsson | Jorgen.Axell@ericsson.com | Rel-17 | 94 |  |
| 2280 | 1009.2 | **Same PCF Selection For AMF and SMF** | 552d | 2020-03-25 A | 2021-09-08 A | 100% |  |  | 2960h | 2960h | TEI17_SPSFAS | 45 | Heng, Nie, China Telecom | nieheng@chinatelecom.cn | Rel-17 | 88 |  |
| 2281 | 1009.2.1 | Stage 2 for TEI17_SPSFAS | 58d | 2020-03-25 A | 2020-06-12 A | 100% | finish no earlier than 2020-06-12 | S2 | 464h | 464h | TEI17_SPSFAS | 45 | Heng, Nie, China Telecom | nieheng@chinatelecom.cn | Rel-17 | 88 |  |

Notes:
- 2258: ; 28/6/20: 0%->20 / Impacted TSs and TRs: 23.379; 23.280; 23.281; 23.282; 23.283
- 2259: ; 28/6/20: 0%->20; 13/9/20: 20%->35; 5/12/20: 35%->45; 10/2/21: FCD:17/09/2020->06/21; 21/3/21: 45%->60; 11/6/21: 60%->100 / Impacted TSs and TRs: 23.379; 23.280; 23.281; 23.282; 23.283
- 2260: ; 28/6/20: 0%->20; 13/9/20: 20%->35; 5/12/20: 35%->45; 5/12/20: 0%->45; 11/6/21: 45%->48; 13/12/21: 48%->100 / Impacted TSs and TRs: 23.379; 23.280; 23.281; 23.282; 23.283
- 2261: 24.229; 24.281; 24.282; 24.379; 24.380; 24.481; 24.482; 24.483; 24.484; 24.581; 24.582; 29.379; 29.380; 29.582 ; 13/9/20: 0%->10; 25/9/20: WID:CP-201164->CP-202193; 5/12/20: 10%->30; 21/3/21: 30%->40; 11/6/21: 40%->50; 13/9/21: 50%->70; 13/12/21: 70%->
- 2262: 6/12/24: Compl:0%->16%; Stat Rep: ->RP-242642; ; 24/1/25: WID:RP-241755->RP-242768; 6/3/25: FCD:24/07/2025->12/12/2025; Compl:16%->23%; Stat Rep: RP-242642->RP-250286; ; 3/4/25: WID:RP-242768->RP-250287; 6/6/25: Compl:23%->47%; WID: RP-250287->RP-242768;; 3/12/25: Compl:66%->100%; Stat Rep: RP-252157->RP-253305;
- 2263: 13/9/19: 0%->10; 6/12/19: 10%->30; 25/03/20: Rel-16->Rel-17; 5/12/20: 30%->40; 5/12/20: FCD:12/03/2020->03/20; 21/3/21: 40%->60; 13/9/21: 60%->80; 13/9/21: FCD:Fri 12/03/->12/21; 12/3/22: 80%->100 / Impacted TSs and TRs: 32.240; 32.260; 32.275; 32.281; 32.290; 32.291; 32.298; 32.297
- 2264: 20/3/19: 0%->15¦20/3/19: 0%->15; 31/5/19: 15%->25; 13/9/19: 25%->50; 13/9/19: FCD:19/09/2019->12/20; 6/12/19: 50%->65; 6/12/19: FCD:12/12/2019->03/20; 25/03/20: Rel-16->Rel-17; 26/6/20: FCD:12/03/2020->12/20; 26/6/20: 65%->75; 12/9/20: 75%->85; 5/12/20
- 2265: ; 5/12/20: 0%->80; 5/12/20: FCD:17/12/2020->03/20; 19/3/21: 80%->100 / Impacted TSs and TRs: 33.501
- 2266: Impacted TSs and TRs: 33.501
- 2267: 11/6/21: 0%->25; 13/9/21: 25%->70; 1/10/21: 33.881 added;; 4/6/22: 70%->100 / Impacted TSs and TRs: 33.881
- 2268: ; 12/3/22: FCD:12/12/2021->3/22; 12/3/22: 0%->100 / Impacted TSs and TRs: 33.501
- 2269: ; 22/3/22: 0%->100 / Impacted TSs and TRs: 24.302; 24.368; 24.501; 24.502; 29.503; 29.509; 29.273; 29.510; 31.102; 31.111; 31.101
- 2270: ; 12/3/22: 0%->98; 4/6/22: 98%->100 / Impacted TSs and TRs: 24.302; 24.368; 24.501; 24.502; 29.503; 29.509; 29.273; 29.510; 31.102; 31.111; 31.101
- 2271: ; 12/3/22: 0%->100; 4/6/22: 100%-> / Impacted TSs and TRs: 24.302; 24.368; 24.501; 24.502; 29.503; 29.509; 29.273; 29.510; 31.102; 31.111; 31.101
- 2272: 19/3/21: FCD:12/06/2021->03/22; 19/3/21: 0%->5; 11/6/21: 5%->20; 13/9/21: 20%->87; 12/3/22: 87%->98; 12/3/22: FCD:11/03/2022->06/22; 4/6/22: 98%->100 / Impacted TSs and TRs: 33.107; 33.108; 33.126; 33.127; 33.128
- 2273: 19/3/21: FCD:12/06/2021->03/22; 19/3/21: 0%->5; 11/6/21: 5%->20; 13/9/21: 20%->87; 12/3/22: 87%->98; 12/3/22: FCD:11/03/2022->06/22; 4/6/22: 98%->100 / Impacted TSs and TRs: 33.107; 33.108; 33.126; 33.127; 33.128
- 2277: 19/3/21: 0%->100 / Impacted TSs and TRs: 23.228
- 2278: 19/3/21: 0%->100 / Impacted TSs and TRs: 23.228
- 2279: ; 12/3/22: 70%->100 / Impacted TSs and TRs: 24.229
- 2281: 23.501, 23.502 ; 19/3/21: 0%->100

| ID | WBS | Task | Duration | Start | Finish | Complete | Constraint | Resources | Work | Actual work | Acronym | PCG approved | WI rapporteur name | WI rapporteur e-mail | Release | TSG approved |
| --- | --- | --- | --- | --- | --- | --- | --- | --- | --- | --- | --- | --- | --- | --- | --- | --- |
| 2282 | 1009.2.2 | **CT aspects on TEI17_SPSFAS** | 181.25d | 2021-03-18 A | 2021-09-08 A | 100% |  | ct | 2496h | 2496h | TEI17_SPSFAS | 46 | Yue Sun, China Telecom | suny20@chinatelecom.cn | Rel-17 | 91 |
| 2283 | 1009.2.2.1 | CT3 aspects on TEI17_SPSFAS | 125d | 2021-03-18 A | 2021-09-08 A | 100% | finish no earlier than 2021-09-08 | C3 | 1000h | 1000h | TEI17_SPSFAS | 46 | Yue Sun, China Telecom | suny20@chinatelecom.cn | Rel-17 | 91 |
| 2284 | 1009.2.2.2 | CT4 aspects on TEI17_SPSFAS | 62d | 2021-03-18 A | 2021-06-11 A | 100% | finish no earlier than 2021-06-12 | C4 | 496h | 496h | TEI17_SPSFAS | 46 | Yue Sun, China Telecom | suny20@chinatelecom.cn | Rel-17 | 91 |
| 2285 | 1009.3 | **System enhancement for Redundant PDU Session** | 742.38d | 2020-03-25 A | 2022-03-11 A | 100% |  |  | 4656h | 4656h | TEI17_SE_RPS | 45 | Devaki Chandramouli | devaki.chandraouli@nokia.com | Rel-17 | 88 |
| 2286 | 1009.3.1 | Stage 2 for TEI17_SE_RPS | 58d | 2020-03-25 A | 2020-06-12 A | 100% | finish no earlier than 2020-06-12 | S2 | 464h | 464h | TEI17_SE_RPS | 45 | Devaki Chandramouli | devaki.chandraouli@nokia.com | Rel-17 | 88 |
| 2287 | 1009.3.2 | **CT aspects of TEI17_SE_RPS** | 189.38d | 2021-09-10 A | 2022-03-11 A | 100% |  | ct | 4192h | 4192h | TEI17_SE_RPS | 47 | WON, Sung Hwan, Nokia | sung.won@nokia.com | Rel-17 | 93 |
| 2288 | 1009.3.2.1 | CT1 aspects of TEI17_SE_RPS | 131d | 2021-09-10 A | 2022-03-11 A | 100% | finish no earlier than 2022-03-12 | C1 | 1048h | 1048h | TEI17_SE_RPS | 47 | WON, Sung Hwan, Nokia | sung.won@nokia.com | Rel-17 | 93 |
| 2289 | 1009.3.2.2 | CT3 aspects of TEI17_SE_RPS | 131d | 2021-09-10 A | 2022-03-11 A | 100% | finish no earlier than 2022-03-12 | C3 | 1048h | 1048h | TEI17_SE_RPS | 47 | WON, Sung Hwan, Nokia | sung.won@nokia.com | Rel-17 | 93 |
| 2290 | 1009.3.2.3 | CT4 aspects of TEI17_SE_RPS | 131d | 2021-09-10 A | 2022-03-11 A | 100% | finish no earlier than 2022-03-12 | C4 | 1048h | 1048h | TEI17_SE_RPS | 47 | WON, Sung Hwan, Nokia | sung.won@nokia.com | Rel-17 | 93 |
| 2291 | 1009.4 | **Support for Signed Attestation for Priority and Emergency Sessions** | 554d | 2020-03-25 A | 2021-09-10 A | 100% |  |  | 3488h | 3488h | TEI17_SAPES | 44 | Foti, George, Ericsson | George.foti@ericsson.com | Rel-17 | 87 |
| 2292 | 1009.4.1 | Stage 2 for TEI17_SAPES | 58d | 2020-03-25 A | 2020-06-12 A | 100% | finish no earlier than 2020-06-12 | S2 | 464h | 464h | TEI17_SAPES | 44 | Foti, George, Ericsson | George.foti@ericsson.com | Rel-17 | 87 |
| 2293 | 1009.4.2 | **CT aspects on TEI17_SAPES** | 182.25d | 2021-03-19 A | 2021-09-10 A | 100% |  | ct | 3024h | 3024h | TEI17_SAPES | 46 | Axell, Jörgen, Ericsson | Jorgen.Axell@ericsson.com | Rel-17 | 91 |
| 2294 | 1009.4.2.1 | CT1 aspects on TEI17_SAPES | 126d | 2021-03-19 A | 2021-09-10 A | 100% | finish no earlier than 2021-09-12 | C1 | 1008h | 1008h | TEI17_SAPES | 46 | Axell, Jörgen, Ericsson | Jorgen.Axell@ericsson.com | Rel-17 | 91 |
| 2295 | 1009.4.2.2 | CT3 aspects on TEI17_SAPES | 126d | 2021-03-19 A | 2021-09-10 A | 100% | finish no earlier than 2021-09-12 | C3 | 1008h | 1008h | TEI17_SAPES | 46 | Axell, Jörgen, Ericsson | Jorgen.Axell@ericsson.com | Rel-17 | 91 |
| 2296 | 1009.5 | **Dynamically Changing AM Policies in the 5GC** | 756.88d | 2020-03-11 A | 2022-03-11 A | 100% |  |  | 6760h | 6760h | TEI17_DCAMP | 44 | Pancorbo, Belen (Ericsson) |  | Rel-17 | 87 |
| 2297 | 1009.5.1 | Stage 2 for TEI17_DCAMP | 77d | 2020-03-11 A | 2020-06-25 A | 100% | finish no earlier than 2020-06-25 | S2 | 616h | 616h | TEI17_DCAMP | 44 | Pancorbo, Belen (Ericsson) |  | Rel-17 | 87 |
| 2298 | 1009.5.2 | **CT aspects on TEI17_DCAMP** | 370.62d | 2021-03-19 A | 2022-03-11 A | 100% |  | ct | 6144h | 6144h | TEI17_DCAMP | 46 | Garcia Azorero, Fuencisla. Ericsson | fuencisla.garcia@ericsson.com | Rel-17 | 91 |
| 2299 | 1009.5.2.1 | CT3 aspects on TEI17_DCAMP | 256d | 2021-03-19 A | 2022-03-11 A | 100% | finish no earlier than 2022-03-12 | C3 | 2048h | 2048h | TEI17_DCAMP | 46 | Garcia Azorero, Fuencisla. Ericsson | fuencisla.garcia@ericsson.com | Rel-17 | 91 |
| 2300 | 1009.5.2.2 | CT4 aspects on TEI17_DCAMP | 256d | 2021-03-19 A | 2022-03-11 A | 100% | finish no earlier than 2022-03-12 | C4 | 2048h | 2048h | TEI17_DCAMP | 46 | Garcia Azorero, Fuencisla. Ericsson | fuencisla.garcia@ericsson.com | Rel-17 | 91 |
| 2301 | 1009.6 | IP address pool information from UDM | 77d | 2020-03-11 A | 2020-06-25 A | 100% | finish no earlier than 2020-06-25 | S2 | 616h | 616h | TEI17_IPU | 44 | Stefan Rommer | stefan . rommer @ ericsson . com | Rel-17 | 87 |
| 2302 | 1009.7 | **Dynamic management of group-based event monitoring** | 756.88d | 2020-03-11 A | 2022-03-11 A | 100% |  |  | 6760h | 6760h | TEI17_GEM | 44 | Qian XB Chen, Ericsson | Qian.XB.Chen@ericsson.com | Rel-17 | 87 |
| 2303 | 1009.7.1 | Stage 2 for TEI17_GEM | 77d | 2020-03-11 A | 2020-06-25 A | 100% | finish no earlier than 2020-06-25 | S2 | 616h | 616h | TEI17_GEM | 44 | Qian XB Chen, Ericsson | Qian.XB.Chen@ericsson.com | Rel-17 | 87 |
| 2304 | 1009.7.2 | **CT aspects on TEI17_GEM** | 370.62d | 2021-03-19 A | 2022-03-11 A | 100% |  | ct | 6144h | 6144h | TEI17_GEM | 46 | Maria Tianmei, Liang, Ericsson | maría.liang@ericsson.com | Rel-17 | 91 |
| 2305 | 1009.7.2.1 | CT3 aspects on TEI17_GEM | 256d | 2021-03-19 A | 2022-03-11 A | 100% | finish no earlier than 2022-03-12 | C3 | 2048h | 2048h | TEI17_GEM | 46 | Maria Tianmei, Liang, Ericsson | maría.liang@ericsson.com | Rel-17 | 91 |
| 2306 | 1009.7.2.2 | CT4 aspects on TEI17_GEM | 256d | 2021-03-19 A | 2022-03-11 A | 100% | finish no earlier than 2022-03-12 | C4 | 2048h | 2048h | TEI17_GEM | 46 | Maria Tianmei, Liang, Ericsson | maría.liang@ericsson.com | Rel-17 | 91 |

Notes:
- 2283: 11/6/21: 0%->98; 11/6/21: FCD:Fri 11/06/->09/21; 11/6/21: WID:CP-210071->CP-211184; 13/9/21: 98%->100 / Impacted TSs and TRs: 29.513
- 2284: 11/6/21: 0%->80; 13/9/21: 80%->100 / Impacted TSs and TRs: 29.502; 29.503; 29.504
- 2285: ; 11/6/21: 0%->100 / Impacted TSs and TRs: 23.501; 23.502
- 2286: ; 11/6/21: 0%->100 / Impacted TSs and TRs: 23.501; 23.502
- 2287: Impacted TSs and TRs: 24.501; 24.526; 27.007; 29.513; 29.525; 29.561; 29.502
- 2288: ; 13/12/21: 0%->100 / Impacted TSs and TRs: 24.501; 24.526; 27.007
- 2289: ; 13/12/21: 0%->50; 12/3/22: 50%->100 / Impacted TSs and TRs: 29.513; 29.525; 29.561
- 2290: ; 13/12/21: 0%->100 / Impacted TSs and TRs: 29.502
- 2292: 19/3/21: 0%->100 / Impacted TSs and TRs: 23.228; 23.167
- 2293: Impacted TSs and TRs: 24.229; 29.165
- 2294: ; 11/6/21: 0%->100
- 2295: ; 11/6/21: 0%->100
- 2297: 19/3/21: 0%->100 / Impacted TSs and TRs: 23.501; 23.502; 23.503
- 2298: ; 11/6/21: WID:CP-210291->CP-211192; 10/9/21: WID:CP-211192->CP-212163 / Impacted TSs and TRs: 29.513; 29.507; 29.512; 29.519; 29.521; 29.523; 29.514; 29.504; 29.510; 29.522; 29.571
- 2299: ; 11/6/21: 0%->30; 13/9/21: 30%->50; 13/12/21: 50%->75; 12/3/22: 75%->100
- 2300: ; 13/12/21: 0%->70; 12/3/22: 70%->100
- 2301: 19/3/21: 0%->100
- 2303: 11/6/21: 0%->100 / Impacted TSs and TRs: 23.682
- 2304: ; 11/6/21: WID:CP-210185->CP-211195; 10/9/21: WID:CP-211195->CP-212165 / Impacted TSs and TRs: 29.122 29.336
- 2305: ; 11/6/21: 0%->35; 13/9/21: 35%->80; 13/12/21: 80%->90; 12/3/22: 90%->100
- 2306: ; 13/9/21: 0%->80; 7/1/22: 80%->90; 12/3/22: 90%->100

| ID | WBS | Task | Duration | Start | Finish | Complete | Constraint | Resources | Work | Actual work | Acronym | PCG approved | WI rapporteur name | WI rapporteur e-mail | Release | TSG approved | Status Report |
| --- | --- | --- | --- | --- | --- | --- | --- | --- | --- | --- | --- | --- | --- | --- | --- | --- | --- |
| 2307 | 1009.8 | **Support of different slices over different Non 3GPP access** | 481.5d | 2020-03-11 A | 2021-06-18 A | 100% |  |  | 712h | 712h | TEI17_N3SLICE | 44 | Laurent Thiebaut, Nokia | Laurent.thiebaut@nokia.com | Rel-17 | 87 |  |
| 2308 | 1009.8.1 | Stage 2 for TEI17_N3SLICE | 77d | 2020-03-11 A | 2020-06-25 A | 100% | finish no earlier than 2020-06-25 | S2 | 616h | 616h | TEI17_N3SLICE | 44 | Laurent Thiebaut, Nokia | Laurent.thiebaut@nokia.com | Rel-17 | 87 |  |
| 2309 | 1009.8.2 | CT1 aspects of TEI17_N3SLICE | 6d | 2021-06-11 A | 2021-06-18 A | 100% | finish no earlier than 2021-06-20 | C1 | 48h | 48h | TEI17_N3SLICE | 47 | LANDAIS, Bruno, Nokia | bruno.landais@nokia.com | Rel-17 | 92 |  |
| 2310 | 1009.8.3 | CT4 aspects of TEI17_N3SLICE | 6d | 2021-06-11 A | 2021-06-18 A | 100% | finish no earlier than 2021-06-20 | C4 | 48h | 48h | TEI17_N3SLICE | 47 | LANDAIS, Bruno, Nokia | bruno.landais@nokia.com | Rel-17 | 92 |  |
| 2311 | 1009.9 | **N7/N40 Interfaces Enhancements to Support GERAN and UTRAN** | 568.5d | 2020-03-11 A | 2021-09-10 A | 100% |  |  | 4680h | 4680h | TEI17_NIESGU | 44 | Aihua, Li, China Mobile | liaihua@ chinamobile.com | Rel-17 | 87 |  |
| 2312 | 1009.9.1 | Stage 2 for TEI17_NIESGU | 77d | 2020-03-11 A | 2020-06-25 A | 100% | finish no earlier than 2020-06-25 | S2 | 616h | 616h | TEI17_NIESGU | 44 | Aihua, Li, China Mobile | liaihua@ chinamobile.com | Rel-17 | 87 |  |
| 2313 | 1009.9.2 | SA5 aspects of N40 Interface Enhancements to Support GERAN and UTRAN | 256d | 2020-09-16 A | 2021-09-08 A | 100% | finish no earlier than 2021-09-08 | S5 | 2048h | 2048h | TEI17_NIESGU | 45 | Dong, Jia, China Mobile | dongjia@chinamobile.com | Rel-17 | 89 |  |
| 2314 | 1009.9.3 | CT3 aspects of N7 Interfaces Enhancements to Support GERAN and UTRAN | 126d | 2021-03-19 A | 2021-09-10 A | 100% | finish no earlier than 2021-09-12 | C3 | 1008h | 1008h | TEI17_NIESGU | 46 | Huang Zhenning (China Mobile) | huangzhenning (at) chinamobile (dot) com | Rel-17 | 91 |  |
| 2315 | 1009.9.4 | CT4 aspects of N7 Interfaces Enhancements to Support GERAN and UTRAN | 126d | 2021-03-19 A | 2021-09-10 A | 100% | finish no earlier than 2021-09-12 | C4 | 1008h | 1008h | TEI17_NIESGU | 47 | Huang Zhenning (China Mobile) | huangzhenning (at) chinamobile (dot) com | Rel-17 | 92 |  |
| 2316 | 1010 | (Small) Test Technical Enhancements and Improvements for Rel-17 | 73d | 2021-12-10 A | 2022-03-22 A | 100% | finish no earlier than 2022-03-22 | R5 | 584h | 584h | TEI17_Test | 48 |  |  | Rel-17 | 95 |  |
| 2317 | 1011 | **Stage-3 5GS NAS protocol development 17** | 647.12d | 2020-06-25 A | 2022-03-11 A | 100% |  | C1 | 9736h | 9736h | 5GProtoc17 | 45 | Sedlacek, Ivo, Ericsson | ivo <dot> sedlacek <at> ericsson <dot> com | Rel-17 | 88 |  |
| 2318 | 1011.1 | Stage-3 5GS NAS protocol development 17 general aspects | 447d | 2020-06-25 A | 2022-03-11 A | 100% | finish no earlier than 2022-03-12 | C1 | 3576h | 3576h | 5GProtoc17 | 45 | Sedlacek, Ivo, Ericsson | ivo <dot> sedlacek <at> ericsson <dot> com | Rel-17 | 88 |  |
| 2319 | 1011.2 | Stage-3 5GS NAS protocol development 17 non-IETF aspects | 323d | 2020-06-25 A | 2021-09-20 A | 100% | finish no earlier than 2021-09-20 | C1 | 2584h | 2584h | 5GProtoc17-non3GPP | 45 | Sedlacek, Ivo, Ericsson | ivo <dot> sedlacek <at> ericsson <dot> com | Rel-17 | 88 |  |
| 2320 | 1012 | **Stage-3 SAE Protocol Development** | 647.12d | 2020-06-25 A | 2022-03-11 A | 100% |  | C1 | 12320h | 12320h | SAES17 | 45 | Aghili, Behrouz, InterDigital Communications | behrouz.aghili@interdigital.com | Rel-17 | 88 |  |
| 2321 | 1012.1 | Stage-3 SAE Protocol Development general aspects | 447d | 2020-06-25 A | 2022-03-11 A | 100% | finish no earlier than 2022-03-12 | C1 | 3576h | 3576h | SAES17 | 45 | Aghili, Behrouz, InterDigital Communications | behrouz.aghili@interdigital.com | Rel-17 | 88 |  |
| 2322 | 1012.2 | Stage-3 SAE Protocol Development CSFB aspects | 323d | 2020-06-25 A | 2021-09-20 A | 100% | finish no earlier than 2021-09-20 | C1 | 2584h | 2584h | SAES17-CSFB | 45 | Aghili, Behrouz, InterDigital Communications | behrouz.aghili@interdigital.com | Rel-17 | 88 |  |
| 2323 | 1012.3 | Stage-3 SAE Protocol Development non 3GPP aspects | 323d | 2020-06-25 A | 2021-09-20 A | 100% | finish no earlier than 2021-09-20 | C1 | 2584h | 2584h | SAES17-non3GPP | 45 | Aghili, Behrouz, InterDigital Communications | behrouz.aghili@interdigital.com | Rel-17 | 88 |  |
| 2324 | 1013 | **IMS Stage-3 IETF Protocol Alignment** | 1494d | 2020-06-25 A | 2024-06-06 A | 100% |  | ct | 17544h | 17544h | IMSProtoc17 | 45 | Gkatzikis, Lazaros(Nokia) | lazaros(dot)gkatzikis(at)nokia(dot)com | Rel-17 | 88 |  |
| 2325 | 1013.1 | CT1 aspects of IMS Stage-3 IETF Protocol Alignment | 447d | 2020-06-25 A | 2022-03-11 A | 100% | finish no earlier than 2022-03-12 | C1 | 3576h | 3576h | IMSProtoc17 | 45 | Gkatzikis, Lazaros(Nokia) | lazaros(dot)gkatzikis(at)nokia(dot)com | Rel-17 | 88 |  |
| 2326 | 1013.2 | CT3 aspects of IMS Stage-3 IETF Protocol Alignment | 447d | 2020-06-25 A | 2022-03-11 A | 100% | finish no earlier than 2022-03-12 | C3 | 3576h | 3576h | IMSProtoc17 | 45 | Gkatzikis, Lazaros(Nokia) | lazaros(dot)gkatzikis(at)nokia(dot)com | Rel-17 | 88 |  |
| 2327 | 1013.3 | STOPPED - UE Conformance - IMS Data Channel | 265d | 2023-06-07 A | 2024-06-06 A | 100% | finish no earlier than 2024-06-06 | R5 | 2120h | 2120h | IMSProtoc17_dataCH-UEContest | 51 | Zhaobing Yang, Huawei Technologies. Co., Ltd | yangzhaobing@huawei.com | Rel-17 | 100 | RP-241373 |
| 2328 | 1014 | Packet Flow Description (PFD) management enhancement | 252d | 2020-06-25 A | 2021-06-11 A | 100% | finish no earlier than 2021-06-12 | C3 | 2016h | 2016h | pfdManEnh | 45 | Xiaoyun Zhou, Huawei | zhouxiaoyun8@huawei.com | Rel-17 | 88 |  |
| 2329 | 1015 | **Service Based Interface Protocol Improvements Release 17** | 647.12d | 2020-06-25 A | 2022-03-11 A | 100% |  |  | 7152h | 7152h | SBIProtoc17 | 45 | Song Yue, China Mobile | songyue@chinamobile.com | Rel-17 | 88 |  |
| 2330 | 1015.1 | CT3 aspects of SBIProtoc17 | 447d | 2020-06-25 A | 2022-03-11 A | 100% | finish no earlier than 2022-03-12 | C3 | 3576h | 3576h | SBIProtoc17 | 45 | Song Yue, China Mobile | songyue@chinamobile.com | Rel-17 | 88 |  |
| 2331 | 1015.2 | CT4 aspects of SBIProtoc17 | 447d | 2020-06-25 A | 2022-03-11 A | 100% | finish no earlier than 2022-03-11 | C4 | 3576h | 3576h | SBIProtoc17 | 45 | Song Yue, China Mobile | songyue@chinamobile.com | Rel-17 | 88 |  |
| 2332 | 1016 | Study on restoration of profiles related to UDR | 330d | 2020-12-07 A | 2022-03-11 A | 100% | finish no earlier than 2022-03-12 | C4 | 2640h | 2640h | FS_ReP_UDR | 46 | Ishikawa, Hiroshi, NTT DOCOMO | hiroshi.ishikawa.ev (at) nttdocomo.com | Rel-17 | 90 |  |

Notes:
- 2307: 19/3/21: 0%->100 / Impacted TSs and TRs: 23.501; 23.502
- 2308: 19/3/21: 0%->100 / Impacted TSs and TRs: 23.501; 23.502
- 2309: ; 11/6/21: 0%->100; 1/10/21: 0%->100 / Impacted TSs and TRs: 24.501;29.571;29.510
- 2310: ; 11/6/21: 0%->100 / Impacted TSs and TRs: 24.501;29.571;29.510
- 2312: 11/6/21: 0%->100 / Impacted TSs and TRs: 23.060; 23.401; 23.503; 23.203
- 2313: 25/09/20: acronym: "NIESGU"->"TEI17_NIESGU"; 25/9/20: WID:SP-200768->SP-200854; 5/12/20: FCD:11/06/2021->09/20; 5/12/20: 0%->5; 21/3/21: 5%->10; 13/9/21: 10%->100 / Impacted TSs and TRs: 32.240; 32.251; 32.255; 32.290; 32.291; 32.298
- 2314: ; 11/6/21: 0%->90; 11/6/21: WID:CP-210186->CP-211194; 13/9/21: 90%->100 / Impacted TSs and TRs: 29.512; 29.513
- 2315: 2/7/21: added; 13/9/21: 0%->100 / Impacted TSs and TRs: 29.512; 29.513
- 2316: Added as per Ingo's request on 02/04/22
- 2317: Impacted TSs and TRs: 23.040; 23.041; 23.122; 24.007; 24.008; 24.011; 24.173; 24.229; 24.301; 24.302; 24.305; 24.341; 24.368; 24.501; 24.502; 24.526; 27.007
- 2318: 23.040; 23.041; 23.122; 24.007; 24.008; 24.011; 24.173; 24.229; 24.301; 24.302; 24.305; 24.341; 24.368; 24.501; 24.502; 24.526; 27.007 ; 13/9/20: 0%->10; 5/12/20: 10%->30; 21/3/21: 30%->40; 11/6/21: 40%->50; 13/9/21: 50%->70; 13/9/21: FCD:Mon 20/09/->0
- 2319: 1/10/21: 0%->70; 23/9/22: 70%->100 / Impacted TSs and TRs: 23.040; 23.041; 23.122; 24.007; 24.008; 24.011; 24.173; 24.229; 24.301; 24.302; 24.305; 24.341; 24.368; 24.501; 24.502; 24.526; 27.007
- 2321: 13/9/20: 0%->10; 5/12/20: 10%->30; 21/3/21: 30%->40; 11/6/21: 40%->50; 13/9/21: 50%->65; 13/12/21: 65%->90; 12/3/22: FCD:20/09/2021->3/22; 12/3/22: 90%->100 / Impacted TSs and TRs: 23.122; 24.008; 24.167; 24.229; 24.301; 24.302; 24.303; 24.304; 24.305; 24.312; 29.018; 29.118; 24.368 ;
- 2322: 22/3/22: 0%->100 / Impacted TSs and TRs: 23.122; 24.008; 24.167; 24.229; 24.301; 24.302; 24.303; 24.304; 24.305; 24.312; 29.018; 29.118; 24.368
- 2323: 22/3/22: 0%->100 / Impacted TSs and TRs: 23.122; 24.008; 24.167; 24.229; 24.301; 24.302; 24.303; 24.304; 24.305; 24.312; 29.018; 29.118; 24.368
- 2324: 13/9/20: 0%->10; 13/9/20: 10%->15; 5/12/20: 15%->30; 21/3/21: 30%->20 / Impacted TSs and TRs: 23.218; 24.229; 24.930; 29.163; 29.165; 29.292 ;
- 2325: 11/6/21: 20%->40; 13/9/21: 40%->60; 13/12/21: 60%->80; 12/3/22: FCD:10/09/2021->3/22; 12/3/22: 80%->100 / Impacted TSs and TRs: 23.218; 24.229; 24.930; 29.163; 29.165; 29.292 ; 13/9/20: 0%->10; 13/9/20: 10%->15; 5/12/20: 15%->30; 21/3/21: 30%->20
- 2326: 11/6/21: 0%->60; 13/9/21: 60%->70; 13/12/21: 70%->85; 12/3/22: 85%->100; 12/3/22: FCD:10/09/2021->3/22 / Impacted TSs and TRs: 23.218; 24.229; 24.930; 29.163; 29.165; 29.292 ; 13/9/20: 0%->10; 13/9/20: 10%->15; 5/12/20: 15%->30; 21/3/21: 30%->20
- 2327: 6/9/23: FCD:12/12/2023->22/09/2023; Compl:0%->5%; Stat Rep: ->RP-232356; Rapporteur: HiSilicon->Zhaobing Yang, Huawei Technologies. Co., Ltd; Rap eMail: ->yangzhaobing@hisilicon.com; ; 6/10/23: WID:RP-231246->RP-232357; 8/12/23: FCD:22/09/2023->09/09/2...; 13/6/24: FCD:09/09/2024->06/06/2024; Stat Rep: RP-240282->RP-241373;
- 2328: 13/9/20: 0%->25; 5/12/20: 25%->60; 21/3/21: 60%->98; 21/3/21: FCD:11/12/2020->06/21; 21/3/21: WID:CP-201208->CP-210183; 11/6/21: 98%->100 / Impacted TSs and TRs: 29.251; 29.551
- 2330: 13/9/20: 0%->15; 5/12/20: 15%->30; 21/3/21: 30%->50; 11/6/21: 50%->65; 11/6/21: WID:CP-201075->CP-211088; 13/9/21: 65%->75; 13/12/21: 75%->85; 12/3/22: FCD:20/09/2021->3/22; 12/3/22: 85%->100 / Impacted TSs and TRs: 29.507; 29.508; 29.512; 29.514; 29.519; 29.520; 29.521; 29.522; 29.523; 29.525; 29.551; 29.554; 29.554; 29.591; 29.594; 29.122; 29.222; 29.486; 29.517; 29.549; 29.675;
- 2331: 13/9/20: 0%->10; 5/12/20: 10%->20; 21/3/21: 20%->30; 11/6/21: 30%->50; 13/9/21: 50%->60; 13/12/21: 60%->80; 13/12/21: FCD:Mon 20/09/->03/22; 12/3/22: 80%->100 / Impacted TSs and TRs: 29.500; 29.501; 29.502; 29.503; 29.504; 29.505; 29.509; 29.510; 29.511; 29.515; 29.518; 29.531; 29.540; 29.541; 29.542; 29.544; 29.550; 29.562; 29.563; 29.571; 29.572; 29.573; 29.598;
- 2332: 21/3/21: 0%->20; 11/6/21: 20%->40; 13/9/21: FCD:Fri 10/09/->12/21; 13/9/21: 40%->60; 1/10/21: WID:CP-203019->CP-203271; 13/12/21: 60%->95; 12/3/22: FCD:10/12/2021->3/22; 12/3/22: 95%->100

| ID | WBS | Task | Type | Duration | Start | Finish | Complete | Constraint | Resources | Work | Actual work | Acronym | PCG approved | WI rapporteur name | WI rapporteur e-mail | Release | TSG approved |
| --- | --- | --- | --- | --- | --- | --- | --- | --- | --- | --- | --- | --- | --- | --- | --- | --- | --- |
| 2333 | 1017 | **Restoration of Profiles related to UDR** |  | 1147.38d | 2019-03-07 A | 2022-03-18 A | 100% |  | C4 | 19008h | 19008h | ReP_UDR | 48 | Ishikawa, Hiroshi, NTT DOCOMO | hiroshi.ishikawa.ev (at) nttdocomo.com | Rel-17 | 94 |
| 2334 | 1017.1 | CT3 aspects of ReP_UDR |  | 792d | 2019-03-07 A | 2022-03-18 A | 100% | finish no earlier than 2022-03-18 | C3 | 6336h | 6336h | ReP_UDR | 49 | Ishikawa, Hiroshi, NTT DOCOMO | hiroshi.ishikawa.ev (at) nttdocomo.com | Rel-17 | 97 |
| 2335 | 1017.2 | CT4 aspects of ReP_UDR |  | 792d | 2019-03-07 A | 2022-03-18 A | 100% | finish no earlier than 2022-03-18 | C4 | 6336h | 6336h | ReP_UDR | 49 | Ishikawa, Hiroshi, NTT DOCOMO | hiroshi.ishikawa.ev (at) nttdocomo.com | Rel-17 | 97 |
| 2336 | 1018 | Multi-device enhancements for device transfers |  | 131d | 2021-12-10 A | 2022-06-10 A | 100% | finish no earlier than 2022-06-12 | C1 | 1048h | 1048h | MuDTran | 48 | Axell, Jörgen, Ericsson | Jorgen.Axell@ericsson.com | Rel-17 | 94 |
| 2337 | 1019 | Enhancement on the GTP-U entity restart |  | 66d | 2021-12-10 A | 2022-03-11 A | 100% | finish no earlier than 2022-03-12 | C4 | 528h | 528h | EGTPUR | 48 | YONG, YANG, Ericsson | frank.yong.yang@ericsson.com | Rel-17 | 94 |
| 2338 | 1020 | Study on authentication enhancements in 5GS |  | 782d | 2018-12-13 A | 2021-12-10 A | 100% | finish no earlier than 2021-12-12 | S3 | 6256h | 6256h | FS_AUTH_ENH | 42 | Tsiatsis, Vlasios, | vlasios.tsiatsis@ericsson.com | Rel-17 | 82 |
| 2339 | 1021 | Authentication enhancements in 5GS |  | 66d | 2021-12-10 A | 2022-03-11 A | 100% | finish no earlier than 2022-03-12 | S3 | 528h | 528h | AUTH_ENH | 48 | Tsiatsis, Vlasios, Ericsson | vlasios.tsiatsis@ericsson.com | Rel-17 | 94 |
| 2340 | 1022 | Repository for the 3GPP Allocated Port Numbers for New 3GPP Interfaces |  | 2d | 2022-03-10 A | 2022-03-11 A | 100% | finish no earlier than 2022-03-12 | C4 | 16h | 16h | PortAl | 48 | Giorgi Gulbani, Huawei | giorgi.gulbani@huawei.com | Rel-17 | 95 |
| 2341 | 1023 | Modifying PASSporT signing and verification for Spoofed calls |  | 2d | 2022-03-10 A | 2022-03-11 A | 100% | finish no earlier than 2022-03-12 | C1 | 16h | 16h | SPECTRE_Ph3 | 48 | Politz, Ken, Neustar | ken.politz@team.neustar | Rel-17 | 95 |
| 2342 | 1024 | Update of conformance test specifications to Rel-17 |  | 782d | 2021-06-14 A | 2024-06-06 A | 100% |  | C6 | 6256h | 6256h | UEConTest_R17 | 47 | Arne Marquordt, COMPRION GmbH | amarquordt@comprion.com | Rel-17 | 92 |
| 2343 | 1025 | Rel-17 Management-only Features | milestone, manual | 0d | 2016-06-09 A | 2016-06-09 A | 100% | finish no earlier than 2016-06-09 |  |  |  |  |  |  |  | Rel-17 |  |
| 2344 | 1026 | Management Aspects of 5G Network Sharing |  | 331d | 2020-12-04 A | 2022-03-11 A | 100% | finish no earlier than 2022-03-12 | S5 | 2648h | 2648h | MANS | 46 | Mingrui Sun, China Unicom | sunmr19@chinaunicom.cn | Rel-17 | 90 |
| 2345 | 1027 | Study on Management Aspects of 5G Network Sharing |  | 131d | 2021-06-11 A | 2021-12-10 A | 100% | finish no earlier than 2021-12-12 | S5 | 1048h | 1048h | FS_MANS | 47 | Mingrui Sun, China Unicom | sunmr19@chinaunicom.cn | Rel-17 | 92 |
| 2346 | 1028 | File Management |  | 257d | 2021-03-18 A | 2022-03-11 A | 100% | finish no earlier than 2022-03-12 | S5 | 2056h | 2056h | FIMA | 46 | Pollakowski, Olaf, Nokia | olaf.pollakowski@nokia.com | Rel-17 | 91 |
| 2347 | 1029 | **Improved support for NSA in the service-based management architecture** |  | 189.38d | 2021-09-10 A | 2022-03-11 A | 100% |  | S5 | 2096h | 2096h | NSA_SBMA | 46 | Lan Zou, Huawei | zoulan@huawei.com | Rel-17 | 91 |
| 2348 | 1029.1 | Improved support for NSA in the service-based management architecture |  | 131d | 2021-09-10 A | 2022-03-11 A | 100% | finish no earlier than 2022-03-12 | S5 | 1048h | 1048h | NSA_SBMA | 47 | Lan Zou, Huawei | zoulan@huawei.com | Rel-17 | 93 |
| 2349 | 1030 | Enhancement of Handover Optimization |  | 447d | 2020-06-25 A | 2022-03-11 A | 100% | finish no earlier than 2022-03-12 | S5 | 3576h | 3576h | E_HOO | 45 | Elmdahl, Per, Ericsson | per dot Elmdahl at Ericsson dot com | Rel-17 | 88 |
| 2350 | 1031 | Management data collection control and discovery |  | 447d | 2020-06-25 A | 2022-03-11 A | 100% | finish no earlier than 2022-03-12 | S5 | 3576h | 3576h | MADCOL | 45 | Pollakowski, Olaf, Nokia | olaf.pollakowski@nokia.com | Rel-17 | 88 |
| 2351 | 1032 | Management of the enhanced tenant concept |  | 384d | 2020-06-26 A | 2021-12-15 A | 100% | start no earlier than 2020-06-26 | S5 | 3072h | 3072h | eMEMTANE | 45 | Zhu, Lei, Huawei | lei.zhu@huawei.com | Rel-17 | 88 |
| 2352 | 1033 | Enhancements of 5G performance measurements and KPIs |  | 456d | 2020-06-12 A | 2022-03-11 A | 100% | finish no earlier than 2022-03-12 | S5 | 3648h | 3648h | ePM_KPI_5G | 45 | Yizhi Yao, Intel | yizhi<dot>yao<at>intel<dot>com | Rel-17 | 88 |
| 2353 | 1034 | Intent driven management service for mobile network |  | 917d? | 2018-09-06 A | 2022-03-11 A | 100% | finish no earlier than 2022-03-12 | S5 | 7336h | 7336h | IDMS_MN | 41 | Zou Lan, Huawei | zoulan@huawei.com | Rel-17 | 81 |
| 2354 | 1035 | Discovery of management services in 5G |  | 847d | 2018-12-13 A | 2022-03-11 A | 100% | finish no earlier than 2022-03-12 | S5 | 6776h | 6776h | 5GDMS | 42 | Brendan Hassett, Huawei Technologies Sweden AB | brendan.t.hassett@huawei.com | Rel-17 | 82 |
| 2355 | 1036 | Network policy managementfor 5G mobile networks |  | 591d | 2019-12-06 A | 2022-03-11 A | 100% | finish no earlier than 2022-03-12 | S5 | 4728h | 4728h | NPM | 44 | China Mobile Shasha Guo | guoshasha@chinamobile.com | Rel-17 | 86 |
| 2356 | 1037 | Study on enhancement of Management Data Analytics Service |  | 387d | 2019-09-19 A | 2021-03-12 A | 100% | finish no earlier than 2021-03-12 | S5 | 3096h | 3096h | FS_eMDAS | 43 | Yao, Yizhi, Intel | yizhi.yao@intel.com | Rel-17 | 85 |
| 2357 | 1038 | Enhancements of Management Data Analytics Service |  | 192d | 2021-03-18 A | 2021-12-10 A | 100% | finish no earlier than 2021-12-12 | S5 | 1536h | 1536h | eMDAS | 46 | Yao, Yizhi, Intel | yizhi<dot>yao<at>intel<dot>com | Rel-17 | 91 |
| 2358 | 1039 | Enhancements on EE for 5G networks |  | 448d | 2020-03-25 A | 2021-12-10 A | 100% | finish no earlier than 2021-12-12 | S5 | 3584h | 3584h | EE5GPLUS | 44 | Jean-Michel CORNILY, ORANGE | jeanmichel.cornily@orange.com | Rel-17 | 87 |
| 2359 | 1040 | Study on new aspects of EE for 5G networks |  | 448d | 2020-03-25 A | 2021-12-10 A | 100% | finish no earlier than 2021-12-12 | S5 | 3584h | 3584h | FS_EE5G | 44 | Jean-Michel CORNILY, ORANGE | jeanmichel.cornily@orange.com | Rel-17 | 87 |
| 2360 | 1041 | Enhancement on Management Aspects of 5G Service-Level Agreement |  | 513d | 2020-03-25 A | 2022-03-11 A | 100% | finish no earlier than 2022-03-12 | S5 | 4104h | 4104h | EMA5SLA | 44 | SHI, Xiaonan, CMCC | shixiaonan@chinamobile.com | Rel-17 | 87 |
| 2361 | 1042 | Management of MDT enhancement in 5G |  | 513d | 2020-03-25 A | 2022-03-11 A | 100% | finish no earlier than 2022-03-12 | S5 | 4104h | 4104h | e_5GMDT | 44 | Ayani, Zhulia, Ericsson | zhulia.Ayani@ericsson.com | Rel-17 | 87 |
| 2362 | 1043 | Additional NRM features |  | 548d | 2020-02-05 A | 2022-03-11 A | 100% | finish no earlier than 2022-03-12 | S5 | 4384h | 4384h | adNRM | 44 | Sean Sun, Nokia | sean.sun@nokia-sbell.com | Rel-17 | 87 |
| 2363 | 1044 | Enhanced Closed loop SLS Assurance |  | 513d | 2020-03-25 A | 2022-03-11 A | 100% | finish no earlier than 2022-03-12 | S5 | 4104h | 4104h | eCOSLA | 44 | Groenendijk, Jan, Ericsson | jan.groenendijk@ericsson.com | Rel-17 | 87 |
| 2364 | 1045 | 5G Charging for Local breakout roaming of data connectivity |  | 67d | 2022-03-10 A | 2022-06-10 A | 100% | finish no earlier than 2022-06-12 | S5 | 536h | 536h | CHROAM | 48 | Ericsson, Robert Törnkvist | robert dot tornkvist at ericsson dot com | Rel-17 | 95 |
| 2365 | 1046 | Rel-17 Other NR-only improvements | milestone, manual | 0d | 2016-06-09 A | 2016-06-09 A | 100% |  |  |  |  |  |  |  |  | Rel-17 |  |
| 2366 | 1047 | Study on NR QoE (Quality of Experience) management and optimizations for diverse services |  | 197d | 2019-12-16 A | 2020-09-15 A | 100% | finish no earlier than 2020-09-15 | R3 | 1576h | 1576h | FS_NR_QoE | 44 | China Unicom |  | Rel-17 | 86 |

Notes:
- 2333: ; 12/3/22: 0%->100; 12/3/22: WID:CP-213070->CP-220100 / Impacted TSs and TRs: 23.527; 29.503; 29.505; 29.510; 29.519
- 2334: Impacted TSs and TRs: 23.527; 29.503; 29.505; 29.510; 29.519
- 2335: Impacted TSs and TRs: 23.527; 29.503; 29.505; 29.510; 29.519
- 2336: ; 12/3/22: 0%->90; 22/3/22: WID:CP-213080->CP-220352; 22/3/22: FCD:11/03/2022->06/22; 4/6/22: 90%->100 / Impacted TSs and TRs: 24.174; 24.175; 24.229
- 2337: ; 12/3/22: 0%->100 / Impacted TSs and TRs: 23.007; 23.527; 29.060; 29.244; 29.281
- 2338: 07/19: Rel corrected, was wrongly allocated to Rel-17¦20/3/19: 0%->5; 13/9/19: 5%->15; 13/9/19: FCD:19/09/2019->12/20; 19/9/19: WID:S3-183745->SP-190713; 6/12/19: 15%->40; 6/12/19: FCD:12/12/2019->03/20; 25/03/20: Rel-16->Rel-17; 26/6/20: FCD:12/03/202 / Impacted TSs and TRs: new
- 2339: ; 24/3/22: 0%->100 / Impacted TSs and TRs: 33.102
- 2340: ; 12/3/22: 0%->100 / Impacted TSs and TRs: 29.941
- 2341: ; 4/6/22: 0%->35; 20/6/22: Compl:35%->100% / Impacted TSs and TRs: 24.229
- 2342: Tests eV2XARC_Ph2;eCPSOR_CON;5G_ProSe;5GSAT_ARCH-CT;ING_5GS;MINT;NSWO_5G;ARCH_NR_REDCAP;IoT_SAT_ARCH_EPS / Impacted TSs and TRs: 31.121; 31.124
- 2343: Impacted TSs and TRs: 26.234; 26.247
- 2344: 32.130; 28.541; 28.552; 28.554 ; 21/3/21: 0%->20; 11/6/21: 20%->25; 13/9/21: 25%->30; 13/9/21: FCD:Fri 10/09/->03/22; 13/12/21: 30%->60; 12/3/22: 60%->100
- 2345: ; 13/9/21: 0%->5; 13/12/21: 5%->100 / Impacted TSs and TRs: New
- 2346: ; 11/6/21: 0%->25; 13/9/21: 25%->60; 13/12/21: 60%->75; 13/12/21: FCD:Fri 10/12/->03/22; 12/3/22: 75%->100 / Impacted TSs and TRs: 28.537; 28.622; 28.623; 28.532
- 2347: Impacted TSs and TRs: 28.623; 28.622; 28.659; 28.663
- 2348: ; 13/12/21: 0%->20; 12/3/22: 20%->100 / Impacted TSs and TRs: 28.623; 28.622; 28.659; 28.663
- 2349: 28.552; 28.313; 28.541 ; 5/12/20: 0%->5; 21/3/21: 5%->10; 21/3/21: FCD:18/06/2021->03/22; 11/6/21: 10%->30; 13/9/21: 30%->40; 13/12/21: 40%->90; 12/3/22: 90%->100
- 2350: 28.533; 28.532; 28.622; 28.623 ; 5/12/20: 0%->5; 21/3/21: 5%->25; 11/6/21: 25%->30; 13/9/21: 30%->35; 13/9/21: FCD:Wed 22/09/->03/22; 13/12/21: 35%->40; 12/3/22: 40%->45; 4/6/22: 45%->100
- 2351: 28.531; 28.532; 28.533; 28.541 ; 5/12/20: 0%->5; 11/6/21: 5%->15; 13/9/21: 15%->20; 12/3/22: 20%->100; 22/3/22: WID:SP-200463->SP-220293
- 2352: 28.552; 32.425; 28.554; 32.426; 32.450; 32.451; 32.455 ; 13/9/20: 0%->10; 5/12/20: 10%->20; 21/3/21: 20%->40; 11/6/21: 40%->50; 13/9/21: 50%->60; 13/9/21: FCD:Fri 10/09/->03/22; 13/12/21: 60%->80; 12/3/22: 80%->100
- 2353: 7/12/18: 0%->20¦14/3/19: 20%->30; 31/5/19: 30%->35; 13/9/19: 35%->45; 13/9/19: FCD:14/06/2019->03/20; 26/3/20: 45%->55; 26/3/20: FCD:12/03/2020->03/21; Rel-16->Rel-17; 13/9/20: FCD:12/03/2021->09/21; 5/12/20: 55%->65; 21/3/21: 65%->70; 11/6/21: FCD:Wed / Impacted TSs and TRs: New
- 2354: ¦14/3/19: 0%->25; 31/5/19: 25%->35; 13/9/19: 35%->65; 13/9/19: FCD:19/06/2019->12/20; 26/3/20: 65%->80; 28/6/20: 80%->90. 09/20: moved from Rel-16; 13/9/20: WID:SP-181072->SP-200770; 13/9/20: FCD:12/12/2019->09/21; 25/9/20: 90%->50; 21/3/21: 50%->70; / Impacted TSs and TRs: 28.533; 28.532; 28.531
- 2355: ; 13/9/20: 0%->55; 13/9/20: FCD:11/12/2020->06/21; 5/12/20: 55%->60; 21/3/21: 60%->65; 21/3/21: FCD:11/06/2021->03/22. 9/4/21: corrected from Rel-16 to Rel-17; 11/6/21: 65%->75; 13/9/21: 75%->78; 13/12/21: 78%->100 / Impacted TSs and TRs: 28.532; 28.541
- 2356: ; 20/9/19: WID:SP-190783->SP-190930; 8/10/19: 28.809 added;; 26/3/20: 0%->30; 28/6/20: 30%->50; 13/9/20: 50%->70; 13/9/20: FCD:11/09/2020->03/21; 5/12/20: 70%->90; 21/3/21: 90%->100 / Impacted TSs and TRs: New ; 28.809
- 2357: ; 13/9/21: 0%->10; 13/9/21: FCD:Fri 10/12/->12/21; 13/12/21: 10%->45. UID was at 0, corrected; 12/3/22: 45%->65; 4/6/22: 65%->100 / Impacted TSs and TRs: 28.552; 32.425; 28.554; 28.541; 28.622; 28.623; 28.533; 28.105
- 2358: ; 13/9/20: FCD:16/06/2021->09/21; 5/12/20: 0%->10; 21/3/21: 10%->30; 11/6/21: 30%->55; 11/6/21: FCD:Wed 08/09/->12/21; 13/9/21: 55%->70; 13/12/21: 70%->100 / Impacted TSs and TRs: 28.310; 28.552; 28.554; 28.541
- 2359: 28/6/20: 0%->10; 13/9/20: 10%->25; 13/9/20: FCD:16/06/2021->09/21; 5/12/20: 25%->45; 21/3/21: 45%->70; 11/6/21: 70%->75; 11/6/21: FCD:Wed 08/09/->12/21; 13/9/21: 75%->80; 13/12/21: 80%->100
- 2360: ; 13/9/20: 0%->5; 5/12/20: 5%->40; 21/3/21: 40%->60; 21/3/21: FCD:18/03/2021->06/21; 11/6/21: 60%->65; 11/6/21: FCD:Fri 11/06/->12/21; 10/9/21: WID:SP-200190->SP-210860; 13/9/21: 65%->70; 13/12/21: 70%->85; 13/12/21: FCD:Fri 10/12/->03/22; 12/3/22: 85 / Impacted TSs and TRs: 28.541; 28.531
- 2361: ; 13/9/20: 0%->20; 5/12/20: 20%->50; 5/12/20: FCD:17/12/2020->06/20; 21/3/21: 50%->70; 21/3/21: FCD:11/06/2021->12/21; 11/6/21: 70%->75; 13/9/21: 75%->85; 13/12/21: 85%->95; 13/12/21: FCD:Fri 10/12/->03/22; 12/3/22: 95%->100 / Impacted TSs and TRs: 32.421; 32.422; 32.423; 28.622; 28.623; 28.523
- 2362: ; 10/6/20: FCD:19/03/2020->06/20; 5/12/20: 0%->5; 21/3/21: 5%->15; 11/6/21: 15%->30; 13/9/21: 30%->50; 13/9/21: FCD:Tue 15/06/->12/21; 13/12/21: 50%->80; 13/12/21: FCD:Fri 10/12/->03/22; 01/22: rapporteur change from Jing Ping; 12/3/22: 80%->100 / Impacted TSs and TRs: 28.540; 28.541; 28.622; 28.623
- 2363: 13/9/20: 0%->5; 5/12/20: 5%->10; 5/12/20: FCD:11/12/2020->03/20; 21/3/21: 10%->30; 11/6/21: 30%->50; 11/6/21: FCD:Fri 12/03/->09/21; 13/9/21: 50%->60; 13/9/21: FCD:Wed 08/09/->03/22; 13/12/21: 60%->80; 12/3/22: 80%->90; 4/6/22: 90%->100; 4/1/24: 28.867 added; / Impacted TSs and TRs: 28.535; 28.536; 28.533; 28.541; 28.546; 28.552; 28.553 ; 28.867
- 2364: 12/3/22: FCD:12/03/2022->6/22; 12/3/22: 0%->5; 4/6/22: 5%->100 / Impacted TSs and TRs: 32.240; 32.255; 32.290; 32.291; 32.298
- 2365: Impacted TSs and TRs: 26.234; 26.247
- 2366: affects: NR.; 25/9/20: 38.890 added;; 7/4/21: 0%->100 / Impacted TSs and TRs: 38.890

| ID | WBS | Task | Duration | Start | Finish | Complete | Remaining | Total slack | Constraint | Resources | Work | Actual work | Acronym | PCG approved | Release | TSG approved | Status Report | Impacted TSs and TRs | TSG stopped |
| --- | --- | --- | --- | --- | --- | --- | --- | --- | --- | --- | --- | --- | --- | --- | --- | --- | --- | --- | --- |
| 2367 | 1048 | **NR QoE magement and optimizations for diverse services** | 966d | 2021-01-01 A | 2024-09-09 A | 100% |  |  |  |  | 6752h | 6752h | NR_QoE | 46 | Rel-17 | 91 |  |  |  |
| 2368 | 1048.1 | Core part: NR QoE management and optimizations for diverse services | 318d | 2021-01-01 A | 2022-03-22 A | 100% |  |  | finish no earlier than 2022-03-22 | R3 | 2544h | 2544h | NR_QoE-Core | 46 | Rel-17 | 91 | RP-220554 |  |  |
| 2369 | 1048.2 | UE Conformance - NR QoE management and optimizations for diverse services | 526d | 2022-09-08 A | 2024-09-09 A | 100% |  |  | finish no earlier than 2024-09-24 | R5 | 4208h | 4208h | NR_QoE-UEConTest | 49 | Rel-17 | 97 | RP-241753 |  |  |
| 2370 | 1049 | **Rel-17 Power Class 2 UE for NR inter-band CA with or without SUL configurations with x (16>=x>2) bands DL and y (y=1, 2) bands UL** | 1602.62d | 2021-03-12 A | 2025-06-06 | 57% | 685.46d |  |  |  | 14404h | 5344h | NR_UE_PC2_R17_CADC_SUL_xBDL_yBUL | 46 | Rel-17 | 91 |  |  |  |
| 2371 | 1049.1 | Core part: NR_UE_PC2_R17_CADC_SUL_xBDL_yBUL | 334d | 2021-03-12 A | 2022-06-22 A | 100% |  |  | finish no earlier than 2022-06-22 | R4 | 2672h | 2672h | NR_UE_PC2_R17_CADC_SUL_xBDL_yBUL-Core | 46 | Rel-17 | 91 | RP-221515 | 38.842; 38.541 |  |
| 2372 | 1049.2 | Stopped - Perf. part: NR_UE_PC2_R17_CADC_SUL_xBDL_yBUL | 334d | 2021-03-12 A | 2022-06-22 A | 100% |  |  | finish no earlier than 2022-06-22 | R4 | 2672h | 2672h | NR_UE_PC2_R17_CADC_SUL_xBDL_yBUL-Perf | 46 | Rel-17 | 91 | RP-221515 |  | 96 |
| 2373 | 1049.3 | UE Conformance - Rel-17 Power Class 2 UE for NR inter-band CA/DC with or without SUL configurations with x (6>=x>2) bands DL and y (y=1, 2) bands UL | 1132.5d | 2023-06-08 A | 2026-06-05 | 32% | 770.1d | 37647d | finish no earlier than 2026-06-05 | R5 | 9060h |  | NR_UE_PC2_R17_CADC_SUL_xBDL_yBUL-UEConTest | 51 | Rel-17 | 100 | RP-253425 |  |  |
| 2374 | 1050 | **Introduction of UE TRP (Total Radiated Power) and TRS (Total Radiated Sensitivity) requirements and test methodologies for FR1 (NR SA and EN-DC)** | 1041.75d | 2021-03-12 A | 2023-12-12 A | 100% |  |  |  |  | 8472h | 8472h | NR_FR1_TRP_TRS | 46 | Rel-17 | 91 |  | 38.161 |  |
| 2375 | 1050.1 | Core part: NR_FR1_TRP_TRS | 268d | 2021-03-12 A | 2022-03-22 A | 100% |  |  | finish no earlier than 2022-03-22 | R4 | 2144h | 2144h | NR_FR1_TRP_TRS-Core | 46 | Rel-17 | 91 | RP-221276 | 38.834 |  |
| 2376 | 1050.2 | Perf. part: NR_FR1_TRP_TRS | 400d | 2021-03-12 A | 2022-09-22 A | 100% |  |  | finish no earlier than 2022-09-22 | R4 | 3200h | 3200h | NR_FR1_TRP_TRS-Perf | 46 | Rel-17 | 91 | RP-221276 |  |  |
| 2377 | 1050.3 | UE Conformance - Introduction of UE TRP (Total Radiated Power) and TRS (Total Radiated Sensitivity) requirements and test methodologies for FR1 (NR SA and EN-DC) | 391d | 2022-06-15 A | 2023-12-12 A | 100% |  |  | finish no earlier than 2023-12-12 | R5 | 3128h | 3128h | NR_FR1_TRP_TRS-UEConTest | 49 | Rel-17 | 96 | RP-233311 | 38.561 |  |
| 2378 | 1051 | **High power UE (power class 1.5) for NR band n79** | 652.38d | 2021-03-12 A | 2022-12-01 A | 100% |  |  |  |  | 4584h | 4584h | NR_UE_PC1_5_n79 | 46 | Rel-17 | 91 |  |  |  |
| 2379 | 1051.1 | Core part: NR_UE_PC1_5_n79 | 129d | 2021-03-12 A | 2021-09-08 A | 100% |  |  | finish no earlier than 2021-09-08 | R4 | 1032h | 1032h | NR_UE_PC1_5_n79-Core | 46 | Rel-17 | 91 |  |  |  |
| 2380 | 1051.2 | Perf. part: NR_UE_PC1_5_n79 | 129d | 2021-03-12 A | 2021-09-08 A | 100% |  |  | finish no earlier than 2021-09-08 | R4 | 1032h | 1032h | NR_UE_PC1_5_n79-Perf | 46 | Rel-17 | 91 |  |  |  |
| 2381 | 1051.3 | UE Conformance - High power UE (power class 1.5) for NR band n79 | 315d | 2021-09-17 A | 2022-12-01 A | 100% |  |  | finish no earlier than 2022-12-01 | R5 | 2520h | 2520h | NR_UE_PC1_5_n79-UEConTest | 47 | Rel-17 | 93 | RP-223061 |  |  |
| 2382 | 1052 | **High power UE (power class 2) for NR band n34** | 484.62d | 2021-03-12 A | 2022-06-22 A | 100% |  |  |  |  | 3656h | 3656h | NR_UE_PC2_n34 | 46 | Rel-17 | 91 |  |  |  |
| 2383 | 1052.1 | Core part: NR_UE_PC2_n34 | 129d | 2021-03-12 A | 2021-09-08 A | 100% |  |  | finish no earlier than 2021-09-08 | R4 | 1032h | 1032h | NR_UE_PC2_n34-Core | 46 | Rel-17 | 91 |  |  |  |
| 2384 | 1052.2 | Perf. part: NR_UE_PC2_n34 | 129d | 2021-03-12 A | 2021-09-08 A | 100% |  |  | finish no earlier than 2021-09-08 | R4 | 1032h | 1032h | NR_UE_PC2_n34-Perf | 46 | Rel-17 | 91 |  |  |  |
| 2385 | 1052.3 | UE Conformance - High power UE (power class 2) for NR band n34 | 199d | 2021-09-17 A | 2022-06-22 A | 100% |  |  | finish no earlier than 2022-09-12 | R5 | 1592h | 1592h | NR_UE_PC2_n34-UEConTest | 47 | Rel-17 | 93 | RP-221357 |  |  |
| 2386 | 1053 | **High power UE (power class 2) for NR band n39** | 957.75d | 2021-03-12 A | 2023-09-22 A | 100% |  |  |  |  | 6288h | 6288h | NR_UE_PC2_n39 | 46 | Rel-17 | 91 |  |  |  |
| 2387 | 1053.1 | Core part: NR_UE_PC2_n39 | 129d | 2021-03-12 A | 2021-09-08 A | 100% |  |  | finish no earlier than 2021-09-08 | R4 | 1032h | 1032h | NR_UE_PC2_n39-Core | 46 | Rel-17 | 91 |  |  |  |
| 2388 | 1053.2 | Perf. part: NR_UE_PC2_n39 | 129d | 2021-03-12 A | 2021-09-08 A | 100% |  |  | finish no earlier than 2021-09-08 | R4 | 1032h | 1032h | NR_UE_PC2_n39-Perf | 46 | Rel-17 | 91 |  |  |  |
| 2389 | 1053.3 | UE Conformance - High power UE (power class 2) for NR band n39 | 528d | 2021-09-17 A | 2023-09-22 A | 100% |  |  | finish no earlier than 2023-09-22 | R5 | 4224h | 4224h | NR_UE_PC2_n39-UEConTest | 47 | Rel-17 | 93 | RP-232243 |  |  |
| 2390 | 1054 | **Introduction of FR2 FWA (Fixed Wireless Access) UE with maximum TRP of 23dBm for band n259** | 187.5d | 2021-03-12 A | 2021-09-08 A | 100% |  |  |  |  | 2064h | 2064h | NR_FR2_FWA_Bn259 | 46 | Rel-17 | 91 |  |  |  |
| 2391 | 1054.1 | Core part: NR_FR2_FWA_Bn259 | 129d | 2021-03-12 A | 2021-09-08 A | 100% |  |  | finish no earlier than 2021-09-08 | R4 | 1032h | 1032h | NR_FR2_FWA_Bn259-Core | 46 | Rel-17 | 91 |  |  |  |
| 2392 | 1054.2 | Perf. part: NR_FR2_FWA_Bn259 | 129d | 2021-03-12 A | 2021-09-08 A | 100% |  |  | finish no earlier than 2021-09-08 | R4 | 1032h | 1032h | NR_FR2_FWA_Bn259-Perf | 46 | Rel-17 | 91 |  |  |  |

Notes:
- 2367: follow-up WI of RAN3 REL-17 SI FS_NR_QoE; no Perf. part ; 2/7/21: WID:RP-210913->RP-211406 / WI rapporteur name: China Unicom
- 2368: follow-up WI of RAN3 REL-17 SI FS_NR_QoE; no Perf. part ; 20/6/22: FCD:31/12/2021->22/03/2022; Compl:0%->100%; Stat Rep: ->RP-220554; Rapporteur: China Unicom->Gen Cao; Rap eMail: ->caogen@chinauincom.cn; / WI rapporteur name: Gen Cao / WI rapporteur e-mail: caogen@chinauincom.cn
- 2369: 9/12/22: FCD:08/09/2023->01/09/2023; Compl:0%->5%; Stat Rep: ->RP-222818; Rapporteur: Ericsson->Bo J NSSON, Ericsson; Rap eMail: ->Bo[dot]jonsson[at]ericsson[dot]com; 17/3/23: FCD:09/09/2023->08/09/2023; Stat Rep: RP-222818->RP-230267; ;...; 6/9/23: C...; 26/9/24: WID:RP-222102->RP-241754 / WI rapporteur name: Bo J NSSON, Ericsson / WI rapporteur e-mail: Bo[dot]jonsson[at]ericsson[dot]com
- 2370: basket WI; TR 38.8xx ; 2/7/21: WID:RP-210543->RP-211378; 29/9/21: WID:RP-211378->RP-212182; 6/1/22: WID:RP-212182->RP-213650; 5/4/22: WID:RP-213650->RP-220701; 12/7/22: WID:RP-220701->RP-221516 / WI rapporteur name: Huawei
- 2371: basket WI; TR 38.8xx ; 2/7/21: 38.842 added;; 13/9/21: Compl:0%->5% ; 22/3/22: Compl:5%->78% ; 20/6/22: Rapporteur: Huawei->Wang, Jin, Huawei; Rap eMail: ->jinwang@huawei.com; / WI rapporteur name: Wang, Jin, Huawei / WI rapporteur e-mail: jinwang@huawei.com
- 2372: ; 13/9/21: CD:Sat 12/03/22->Tue 22/03/22 ; 22/3/22: CD:22/03/2022->12/06/2022; 22/3/22: Stat Rep: RP-212181->RP-220699 ; 6/6/22: CD:12/06/2022->22/06/2022 ; 20/6/22:Stopped at 0%; Rapporteur: Huawei->Wang, Jin, Huawei; Rap eMail: ->jinwang@huawei.com; / WI rapporteur name: Wang, Jin, Huawei / WI rapporteur e-mail: jinwang@huawei.com
- 2373: 6/9/23: FCD:06/06/2025->06/06/2024; Compl:0%->9%; Stat Rep: ->RP-232358; Rapporteur: Huawei->Yuxin Hao, Huawei Technologies. Co., Ltd.; Rap eMail: ->haoyuxin@huawei.com; ; 8/12/23: FCD:06/06/2024->06/06/2025; Stat Rep: RP-232358->RP-233766; ; 14/3/24: ...; 3/12/25: FCD:Fri 12/12/25->Fri 05/06/26; Compl:31%->32%; WID: RP-251484->RP-250443; Stat Rep: RP-252643->RP-253425; / WI rapporteur name: Yuxin Hao, Huawei Technologies. Co., Ltd. / WI rapporteur e-mail: haoyuxin@huawei.com
- 2374: compare LTE_UTRA_TRP_TRS; related to OTA; TR 38.8xx ; 2/7/21: WID:RP-210807->RP-211158; 29/9/21: WID:RP-211158->RP-212030; 1/10/21: 38.161 added;; / WI rapporteur name: Vivo
- 2375: compare LTE_UTRA_TRP_TRS; related to OTA; TR 38.8xx ; 2/7/21: 38.834 added ; 20/6/22: Rapporteur: Vivo->Wang, Ruixin; Liu, Qifei; Shaozhe, vivo, OPPO, CMCC; Rap eMail: ->ruixin.wang@vivo.com liuqifei@oppo.com shaozhe@CHINAMOBILE.COM; / WI rapporteur name: Wang, Ruixin; Liu, Qifei; Shaozhe, vivo, OPPO, CMCC / WI rapporteur e-mail: ruixin.wang@vivo.com liuqifei@oppo.com shaozhe@CHINAMOBILE.COM
- 2376: compare LTE_UTRA_TRP_TRS; related to OTA; TS 38.1yy ; 22/3/22: Compl:0%->20%; 22/3/22: CD:08/09/2022->12/09/2022 20/6/22: Rapporteur: Vivo->Wang, Ruixin; Liu, Qifei; Shaozhe, vivo, OPPO, CMCC; Rap eMail: ->ruixin.wang@vivo.com liuqifei@oppo.com s...; 23/9/22: WID:RP-221785->RP-222269 / WI rapporteur name: Wang, Ruixin; Liu, Qifei; Shaozhe, vivo, OPPO, CMCC / WI rapporteur e-mail: ruixin.wang@vivo.com liuqifei@oppo.com shaozhe@CHINAMOBILE.COM
- 2377: 9/9/22: Comp...; 23/9/22: 38.561 added;; 9/12/22: FCD:23/12/2022->01/12/2023; Compl:5%->9%; Stat Rep: ->RP-223197; Rapporteur: Apple->Ashwin Mohan, Jose Fortes, Ruixin Wang, Apple, Rohde and Schwarz, Vivo; Rap eMail: ->ashwin_mohan[at]apple...; 8/12/23: Compl:55%->100%; Stat Rep: RP-231968->RP-233311; / WI rapporteur name: Ashwin Mohan, Jose Fortes, Ruixin Wang, Apple, Rohde and Schwarz, Vivo / WI rapporteur e-mail: ashwin_mohan[at]apple.com, Jose.Fortes[at]rohde-schwarz.com,ruixin.wang[at]vivo.com
- 2378: WI rapporteur name: CMCC
- 2379: ; 29/9/21: 0%->100 / WI rapporteur name: CMCC
- 2380: ; 29/9/21: 0%->100 / WI rapporteur name: CMCC
- 2381: tested: REL-17 WI NR_UE_PC1_5_n79-Core ; 6/1/22: WID:RP-211979->RP-213033; 22/3/22: Compl:0%->57% ; 20/6/22: Rapporteur: CMCC->Dan SONG, CMCC; Rap eMail: ->songdan@chinamobile.com ; ;...; 9/12/22: FCD:23/03/2023->01/12/2022; Compl:84%->100%; Stat R...; 9/1/23: 100%->100 / WI rapporteur name: Dan SONG, CMCC / WI rapporteur e-mail: songdan@chinamobile.com
- 2382: WI rapporteur name: CMCC
- 2383: ; 2/7/21: 0%->100 / WI rapporteur name: CMCC
- 2384: ; 2/7/21: 0%->100 / WI rapporteur name: CMCC
- 2385: tested: REL-17 WI NR_UE_PC2_n34-Core ; 6/1/22: WID:RP-211980->RP-213034; 22/3/22: Compl:0%->53% ; 20/6/22: FCD:12/09/2022->22/06/2022; Rapporteur: CMCC->Dan SONG, CMCC; Rap eMail: ->songdan@chinamobile.com12/7/22: WID:RP-211980->RP-221760 / WI rapporteur name: Dan SONG, CMCC / WI rapporteur e-mail: songdan@chinamobile.com
- 2386: WI rapporteur name: CMCC
- 2387: ; 29/9/21: 0%->100 / WI rapporteur name: CMCC
- 2388: ; 29/9/21: 0%->100 / WI rapporteur name: CMCC
- 2389: tested: REL-17 WI NR_UE_PC2_n39-Core ; 6/1/22: WID:RP-211981->RP-213035; 22/3/22: Compl:0%->47% ; 20/6/22: Rapporteur: CMCC->Dan SONG, CMCC; Rap eMail: ->songdan@chinamobile.com ...; 23/9/22: WID:RP-211981->RP-222651; 9/12/22: FCD:23/03/2023->01/0...; 6/9/23: FCD:09/09/2023->22/09/2023; Compl:99%->100%; Stat Rep: RP-230282->RP-232243; / WI rapporteur name: Dan SONG, CMCC / WI rapporteur e-mail: songdan@chinamobile.com
- 2390: compare REL-17 WI NR_FR2_FWA_Bn257_Bn258 / WI rapporteur name: SoftBank Corp., KDDI, NTT DOCOMO, Rakuten Mobile, Qualcomm
- 2391: compare REL-17 WI NR_FR2_FWA_Bn257_Bn258 ; 29/9/21: 0%->100 / WI rapporteur name: SoftBank Corp., KDDI, NTT DOCOMO, Rakuten Mobile, Qualcomm
- 2392: compare REL-17 WI NR_FR2_FWA_Bn257_Bn258 ; 6/1/22: 0%->100 / WI rapporteur name: SoftBank Corp., KDDI, NTT DOCOMO, Rakuten Mobile, Qualcomm

| ID | WBS | Task | Duration | Start | Finish | Complete | Remaining | Total slack | Constraint | Resources | Work | Actual work | Acronym | PCG approved | WI rapporteur name | Release | TSG approved | Status Report | WI rapporteur e-mail | Impacted TSs and TRs |
| --- | --- | --- | --- | --- | --- | --- | --- | --- | --- | --- | --- | --- | --- | --- | --- | --- | --- | --- | --- | --- |
| 2393 | 1055 | **NR Uplink Data Compression (UDC)** | 846.12d | 2021-03-12 A | 2023-06-06 A | 100% |  |  |  |  | 4128h | 4128h | NR_UDC | 46 | CATT | Rel-17 | 91 |  |  |  |
| 2394 | 1055.1 | Core part: NR_UDC | 261d | 2021-03-12 A | 2022-03-11 A | 100% |  |  | finish no earlier than 2022-03-12 | R2 | 2088h | 2088h | NR_UDC-Core | 46 | CATT | Rel-17 | 91 | RP-220141 |  |  |
| 2395 | 1055.2 | UE Conformance - NR Uplink Data Compression (UDC) | 255d | 2022-06-15 A | 2023-06-06 A | 100% |  |  | finish no earlier than 2023-06-06 | R5 | 2040h | 2040h | NR_UDC-UEConTest | 49 | Huiying ZHANG, CATT | Rel-17 | 96 | RP-230395 | zhanghuiying@catt.cn |  |
| 2396 | 1056 | Study on optimizations of pi/2 BPSK uplink power in NR | 261d | 2021-03-12 A | 2022-03-11 A | 100% |  |  | finish no earlier than 2022-03-12 | R4 | 2088h | 2088h | FS_NR_Opt_pi2BPSK | 46 | Huawei | Rel-17 | 91 | RP-220136 |  | 38.868 |
| 2397 | 1057 | Study on band combination handling in RAN4 | 261d | 2021-03-12 A | 2022-03-11 A | 100% |  |  | finish no earlier than 2022-03-22 | R4 | 2088h | 2088h | FS_NR_ENDC_combo_rules | 46 | ZTE | Rel-17 | 91 | RP-220164 |  | 38.862 |
| 2398 | 1058 | **Multiple Input Multiple Output (MIMO) Over-the-Air (OTA) requirements for NR UEs** | 1314d | 2020-06-22 A | 2023-12-12 A | 100% |  |  |  |  | 11536h | 11536h | NR_MIMO_OTA | 45 | CAICT | Rel-17 | 88 |  |  |  |
| 2399 | 1058.1 | Core part: NR_MIMO_OTA | 523d | 2020-06-22 A | 2022-06-22 A | 100% |  |  | finish no earlier than 2022-06-22 | R4 | 4184h | 4184h | NR_MIMO_OTA-Core | 45 | Zhu, Siting; Xing, Jinqiang, CAICT, OPPO | Rel-17 | 88 | RP-221382 | zhusiting@caict.ac.cn xingjinqiang@oppo.com | 38.151 |
| 2400 | 1058.2 | Perf. Part: NR_MIMO_OTA | 589d | 2020-06-22 A | 2022-09-22 A | 100% |  |  | finish no earlier than 2022-09-22 | R4 | 4712h | 4712h | NR_MIMO_OTA-Perf | 45 | Zhu, Siting; Xing, Jinqiang, CAICT, OPPO | Rel-17 | 88 | RP-222634 | zhusiting@caict.ac.cn xingjinqiang@oppo.com |  |
| 2401 | 1058.3 | UE Conformance - Multiple Input Multiple Output (MIMO) Over-the-Air (OTA) requirements for NR UEs | 330d | 2022-09-08 A | 2023-12-12 A | 100% |  |  | finish no earlier than 2023-12-12 | R5 | 2640h | 2640h | NR_MIMO_OTA-UEConTest | 49 | Istvan Szini, Apple | Rel-17 | 97 | RP-233312 | Istvan@apple.com | 38.551 |
| 2402 | 1059 | **Introduction of FR2 FWA (Fixed Wireless Access) UE with maximum TRP (Total Radiated Power) of 23dBm for band n257 and n258** | 1785d | 2020-03-25 A | 2024-12-12 | 78% | 397.89d |  |  |  | 17385h | 3032h | NR_FR2_FWA_Bn257_Bn258 | 44 | Softbank | Rel-17 | 87 |  |  |  |
| 2403 | 1059.1 | Core part: NR_FR2_FWA_Bn257_Bn258 | 125d | 2020-03-25 A | 2020-09-15 A | 100% |  |  | finish no earlier than 2020-09-15 | R4 | 1000h | 1000h | NR_FR2_FWA_Bn257_Bn258-Core | 44 | Softbank | Rel-17 | 87 |  |  |  |
| 2404 | 1059.2 | Perf. Part: NR_FR2_FWA_Bn257_Bn258 | 254d | 2020-03-25 A | 2021-03-15 A | 100% |  |  | finish no earlier than 2021-03-15 | R4 | 2032h | 2032h | NR_FR2_FWA_Bn257_Bn258-Perf | 44 | Softbank | Rel-17 | 87 |  |  |  |
| 2405 | 1059.3 | UE Conformance - Introduction of FR2 FWA (Fixed Wireless Access) UE with maximum TRP (Total Radiated Power) of 23dBm for band n257 and n258 | 1794.12d | 2022-03-15 A | 2026-12-11 | 73% | 484.41d | 37451.4d | finish no earlier than 2026-12-11 | R5 | 14353h |  | NR_FR2_FWA_Bn257_Bn258-UEConTest | 48 | Yuxin Hao, Huawei Technologies. Co., Ltd. | Rel-17 | 95 | RP-253426 | haoyuxin@huawei.com |  |
| 2406 | 1060 | **Adding channel bandwidth support to existing NR bands** | 756.88d | 2020-06-22 A | 2022-06-22 A | 100% |  |  |  |  | 4184h | 4184h | NR_bands_R17_BWs | 45 | Ericsson | Rel-17 | 88 |  |  |  |
| 2407 | 1060.1 | Core part: NR_bands_R17_BWs | 523d | 2020-06-22 A | 2022-06-22 A | 100% |  |  | finish no earlier than 2022-06-22 | R4 | 4184h | 4184h | NR_bands_R17_BWs-Core | 45 | Dominique Everaere, Ericsson | Rel-17 | 88 | RP-221213 | dominique.everaere@ericsson.com |  |
| 2408 | 1061 | **Introduction of channel bandwidths 35MHz and 45MHz for NR FR1** | 379d | 2020-03-19 A | 2021-03-19 A | 100% |  |  |  |  | 4192h | 4192h | NR_FR1_35MHz_45MHz_BW | 45 | Huawei | Rel-17 | 88 |  |  |  |
| 2409 | 1061.1 | Core part: NR_FR1_35MHz_45MHz_BW | 262d | 2020-03-19 A | 2021-03-19 A | 100% |  |  | finish no earlier than 2021-03-19 | R4 | 2096h | 2096h | NR_FR1_35MHz_45MHz_BW-Core | 45 | Huawei | Rel-17 | 88 |  |  |  |
| 2410 | 1061.2 | Perf. Part: NR_FR1_35MHz_45MHz_BW | 262d | 2020-03-19 A | 2021-03-19 A | 100% |  |  | finish no earlier than 2021-03-19 | R4 | 2096h | 2096h | NR_FR1_35MHz_45MHz_BW-Perf | 45 | Huawei | Rel-17 | 88 |  |  |  |
| 2411 | 1062 | **SAR schemes for UE power class 2 (PC2) for NR inter-band Carrier Aggregation and supplemental uplink (SUL) configurations with 2 bands UL** | 950.62d | 2020-03-19 A | 2022-09-22 A | 100% |  |  |  |  | 10000h | 10000h | NR_SAR_PC2_interB_SUL_2BUL | 45 | China Telecom | Rel-17 | 88 |  |  |  |
| 2412 | 1062.1 | Core part: NR_SAR_PC2_interB_SUL_2BUL | 394d | 2020-03-19 A | 2021-09-21 A | 100% |  |  | finish no earlier than 2021-09-21 | R4 | 3152h | 3152h | NR_SAR_PC2_interB_SUL_2BUL-Core | 45 | China Telecom | Rel-17 | 88 | RP-211830 |  |  |
| 2413 | 1062.2 | Perf. Part: NR_SAR_PC2_interB_SUL_2BUL | 523d | 2020-03-19 A | 2022-03-21 A | 100% |  |  | finish no earlier than 2022-03-21 | R4 | 4184h | 4184h | NR_SAR_PC2_interB_SUL_2BUL-Perf | 45 | China Telecom | Rel-17 | 88 | RP-211830 |  |  |
| 2414 | 1062.3 | UE Conformance - SAR schemes for UE power class 2 (PC2) for NR inter-band Carrier Aggregation and supplemental uplink (SUL) configurations with 2 bands UL | 333d | 2021-06-15 A | 2022-09-22 A | 100% |  |  | finish no earlier than 2022-09-22 | R5 | 2664h | 2664h | NR_SAR_PC2_interB_SUL_2BUL-UEConTest | 47 | Jingzhou Wu, China Telecom | Rel-17 | 92 | RP-221295 | wujingzhou@chinatelecom.cn |  |
| 2415 | 1063 | **NR coverage enhancements** | 1886.75d | 2019-03-07 A | 2024-03-01 A | 100% |  |  |  |  | 13552h | 13552h | NR_cov_enh | 46 | China Telecom | Rel-17 | 90 |  |  |  |
| 2416 | 1063.1 | Study on on NR coverage enhancements | 325d | 2019-03-07 A | 2020-06-03 A | 100% |  |  |  | R1 | 2600h | 2600h | FS_NR_cov_enh | 44 | China Telecom | Rel-17 | 86 |  |  |  |
| 2417 | 1063.2 | Core part: NR_cov_enh | 325d | 2020-12-14 A | 2022-03-11 A | 100% |  |  | finish no earlier than 2022-03-22 | R1 | 2600h | 2600h | NR_cov_enh-Core | 46 | China Telecom | Rel-17 | 90 | RP-220563 |  |  |
| 2418 | 1063.3 | Perf. part: NR_cov_enh | 529d | 2020-12-14 A | 2022-12-21 A | 100% |  |  | finish no earlier than 2022-12-22 | R1 | 4232h | 4232h | NR_cov_enh-Perf | 46 | Jianchi Zhu, China Telecom | Rel-17 | 90 | RP-221283 / 1817 | zhujc@chinatelecom.cn |  |
| 2419 | 1063.4 | UE Conformance - NR coverage enhancements | 515d | 2022-03-15 A | 2024-03-01 A | 100% |  |  | finish no earlier than 2024-03-01 | R5 | 4120h | 4120h | NR_cov_enh-UEConTest | 48 | Jingzhou Wu, China Telecom | Rel-17 | 95 | RP-240340 | wujingzhou@chinatelecom.cn |  |

Notes:
- 2393: no Perf. part; compare RAN2 REL-15 WI LTE_UDC-Core ; 2/7/21: WID:RP-210909->RP-211203; 5/4/22: WID:RP-211203->RP-220140
- 2394: no Perf. Part; compare RAN2 REL-15 WI LTE_UDC-Core ; ;…; 5/4/22: WID:RP-211203->RP-220140
- 2395: 9/9/22: Comp...; 9/12/22: FCD:23/06/2023->01/06/2023; Compl:7%->33%; Stat Rep: ->RP-223139; Rapporteur: CATT->Huiying ZHANG, CATT; Rap eMail: ->zhanghuiying@catt.cn; 17/3/23: Compl:33%->67%; Stat Rep: RP-223139->RP-230395; ;...
- 2396: ; 1/10/21: 38.868 added;; 6/1/22: WID:RP-210910->RP-213535 ;
- 2397: TR 38.8XX; to collect agreements on rules and guidelines of specifying band combinations covering NR CA, NR DC and EN-DC ; 2/7/21: WID:RP-210773->RP-211146; 2/7/21: 38.862 added;13/9/21: Compl:0%->50%13/9/21: CD:Sat 12/03/22->Tue 22/03/2213/9/21: Stat
- 2398: 25/9/20: WID:RP-201302->RP-201800; 6/1/22: WID:RP-201800->RP-213101
- 2399: 25/9/20: 38.151 added;; 13/9/21: Compl:0%->83%; ; 20/6/22: Rapporteur: CAICT->Zhu, Siting; Xing, Jinqiang, CAICT, OPPO; Rap eMail: ->zhusiting@caict.ac.cn xingjinqiang@oppo.com;
- 2400: ; 13/9/21: Compl:0%->20%; 13/9/21: CD:Wed 15 ; 22/3/22: Compl:20%->35%; ; 6/6/22: Compl:35%->55% 20/6/22: Rapporteur: CAICT->Zhu, Siting; Xing, Jinqiang, CAICT, OPPO; Rap eMail: ->zhusiting@caict.ac.cn xingjinqiang@oppo.com 9/...; 23/9/22: 90%->100; 23/9/22: WID:RP-213101->RP-222348
- 2401: 19/10/22: 38.551 added;; 9/12/22: FCD:10/12/2023->01/12/2023; Compl:0%->5%; Stat Rep: ->RP-223198; Rapporteur: Apple->Istvan Szini, Apple; Rap eMail: ->Istvan@apple.com; 17/3/23: FCD:30/11/2023->12/12/2023; Compl:5%->8%; Stat Rep: RP-223198->RP-2301.....; 8/12/23: Compl:50%->100%; Stat Rep: RP-231969->RP-233312;
- 2402: affects: NR. TR 38.8xx; 28/7/20: WID:RP-200503->RP-201215; 25/9/20: WID:RP-201215->RP-201598; 6/1/21: WID:RP-201598->RP-202565
- 2403: affects: NR. TR 38.8xx; 7/4/21: 0%->100
- 2404: affects: NR. TR 38.8xx; 7/4/21: 0%->100
- 2405: tested: REL-17 WI NR_FR2_FWA_Bn257_Bn258-Core 6/6/22: Compl:0%->5% 6/6/22 ; 20/6/22: Rapporteur: Huawei->Yuxin Hao, Huawei Technologies. Co., Ltd.; Rap eMail: ->haoyuxin@huawei.com; 9/12/22: FCD:23/12/2022->01/12/2023; Stat Rep: RP-221492->RP-223221.....; 3/12/25: FCD:Fri 12/12/25->Fri 11/12/26; Stat Rep: RP-252644->RP-253426;
- 2406: 25/9/20: WID:RP-201294->RP-202062; 6/1/21: WID:RP-202062->RP-202277; 7/4/21: WID:RP-202277->RP-210917; 2/7/21: WID:RP-210917->RP-211599; 29/9/21: WID:RP-211599->RP-212531; 6/1/22: WID:RP-212531->RP-213248; 5/4/22: WID:RP-213248->RP-220160; 12/7/22: WID:RP-220160->RP-221212
- 2407: ; 13/9/21: Compl:0%->50%; 13/9/21: CD:Wed 15/09/21->Tue 22/03/22; ; 22/3/22: Compl:50%->80%; 20/6/22: Rapporteur: Ericsson->Dominique Everaere, Ericsson; Rap eMail: ->dominique.everaere@ericsson.com;
- 2408: 25/9/20: WID:RP-201321->RP-201722; 6/1/21: WID:RP-201722->RP-202607; 7/4/21: WID:RP-202607->RP-210722; 2/7/21: WID:RP-210722->RP-211386
- 2409: 29/9/21: 0%->100
- 2410: 29/9/21: 0%->100
- 2411: 25/9/20: WID:RP-201337->RP-201584; 2/7/21: WID:RP-201584->RP-211494; 29/9/21: WID:RP-211494->RP-212530
- 2412: 25/9/20: WID:RP-201337->RP-201584; 13/9/21: Compl:0%->100%; 13/9/21: CD:Fri 19/03/21->Tue 21/09/21; 13/9/21: WID: RP-211494->RP-201337 RP-201584 RP-211494; ; 29/9/21: 100%->100
- 2413: 7/4/21: 0%->100; 13/9/21: CD:Fri 19/03/21->Mon 21/03/22; 13/9/21: WID: RP-211494->RP-201337 RP-201584 RP-211494; 13/9/21: Stat Rep: ->RP-211830
- 2414: tested: REL-17 WI NR_SAR_PC2_interB_SUL_2BUL-Core ; 13/9/21: Compl:0%->5%; 13/9/21: CD:Tue 15/03/22->Tue 22/03/22; 13/9/ ; 22/3/22: Compl:5%->23% ; 20/6/22: Rapporteur: China Telecom->Jingzhou Wu, China Telecom; Rap eMail: ->wujingzhou@chinateleco...
- 2415: follow-up WI of REL-17 SI FS_NR_cov_enh ; 7/4/21: WID:RP-202928->RP-210855; 2/7/21: WID:RP-210855->RP-211566
- 2416: affects: NR. TR 38.8xx; 28/7/20: WID:RP-193240->RP-200861; 6/1/21: 0%->100
- 2417: follow-up WI of REL-17 SI FS_NR_cov_enh ; 13/9/21: Compl:0%->60%; 13/9/21: CD:Sat 12/03/22->Tue 22/03/22; 13/9/21: Stat Rep: ->RP-211826 ;
- 2418: follow-up WI of REL-17 SI FS_NR_cov_enh ; 13/9/21: CD:Thu 08/09/22->Wed 22/09/21; 13/9/21: Stat Rep: ->RP-211826; 22/3/22: Compl:0%->35% 20/6/22: WG: R4->R1; FCD:12/09/2022->22/09/2022; Compl:35%->60%; Stat Rep: RP-220563->RP-221283 / 1817; Rappor...; 9/1/23: 90%->100
- 2419: tested: REL-17 WI NR_cov_enh-Core ; 6/6/22: Compl:0%->5% ; 6/6/22: CD:15/06/2023->23/ ; 20/6/22: Rapporteur: China Telecom->Jingzhou Wu, China Telecom; Rap eMail: ->wujingzhou@chinatelecom.cn12/7/22: WID:RP-220576->RP-221298 ; ;...; 9/12/22: FCD:23/06...; 2/4/24: WID:RP-221298->RP-240341

| ID | WBS | Task | Duration | Start | Finish | Complete | Constraint | Resources | Work | Actual work | Acronym | PCG approved | WI rapporteur name | Release | TSG approved | WI rapporteur e-mail | Status Report | Impacted TSs and TRs |
| --- | --- | --- | --- | --- | --- | --- | --- | --- | --- | --- | --- | --- | --- | --- | --- | --- | --- | --- |
| 2420 | 1064 | **Support of reduced capability NR devices** | 1592.5d | 2019-12-16 A | 2024-03-01 A | 100% |  |  | 16264.2h | 16264.2h | NR_redcap | 46 | Ericsson | Rel-17 | 90 |  |  |  |
| 2421 | 1064.1 | Study on support of reduced capability NR devices | 131d | 2019-12-16 A | 2020-06-15 A | 100% | finish no earlier than 2020-06-15 | R1 | 1048h | 1048h | FS_NR_redcap | 44 | Ericsson | Rel-17 | 86 |  |  |  |
| 2422 | 1064.2 | Core part: NR_redcap | 398d | 2020-12-14 A | 2022-06-22 A | 100% | finish no earlier than 2022-06-22 | R1 | 3184h | 3184h | NR_redcap-Core | 46 | Johan BERGMAN, Ericsson | Rel-17 | 90 | johan.bergman@ericsson.com | RP-221162 |  |
| 2423 | 1064.3 | Perf. part: NR_redcap | 529d | 2020-12-14 A | 2022-12-22 A | 100% | finish no earlier than 2022-12-22 | R1 | 4232h | 4232h | NR_redcap-Perf | 46 | Johan BERGMAN, Ericsson | Rel-17 | 90 | johan.bergman@ericsson.com | RP-221162 |  |
| 2424 | 1064.4 | UE Conformance - Support of reduced capability NR devices | 515d | 2022-03-15 A | 2024-03-01 A | 100% | finish no earlier than 2024-03-01 | R5 | 4120h | 4120h | NR_redcap_plus_ARCH-UEConTest | 48 | Shi，Yu, China Unicom | Rel-17 | 95 | shiyu19@chinaunicom.cn | RP-240050 |  |
| 2425 | 1064.5 | Architecture Enhancement for NR Reduced Capability Devices | 66d | 2021-09-10 A | 2021-12-10 A | 100% | finish no earlier than 2021-12-12 | S2 | 528h | 528h | ARCH_NR_REDCAP | 47 | Aihua Li, China Mobile | Rel-17 | 93 | liaihua@chinamobile.com |  | 23.501; 23.502 |
| 2426 | 1064.6 | CT1 aspects of NR_redcap | 66d | 2021-12-10 A | 2022-03-11 A | 100% | finish no earlier than 2022-03-12 | C1 | 528h | 528h | ARCH_NR_REDCAP | 48 | Chen Xu, China Mobile | Rel-17 | 94 | chenxu@chinamobile.com |  | 24.501; 23.122; 24.008; 24.368 |
| 2427 | 1064.7 | CT3 aspects of NR_redcap | 65.02d | 2021-12-10 A | 2022-03-11 A | 100% | finish no earlier than 2022-03-11 | C3 | 520.16h | 520.16h | ARCH_NR_REDCAP | 48 | Chen Xu, China Mobile | Rel-17 | 95 | chenxu@chinamobile.com |  | 24.501; 23.122; 24.008; 24.368 |
| 2428 | 1064.8 | CT4 aspects of NR_redcap | 66d | 2021-12-10 A | 2022-03-11 A | 100% | finish no earlier than 2022-03-12 | C4 | 528h | 528h | ARCH_NR_REDCAP | 48 | Chen Xu, China Mobile | Rel-17 | 94 | chenxu@chinamobile.com |  | 29.571; 29.502; 29.540; 29.518; 23.008 |
| 2429 | 1064.9 | CT6 aspects of NR_redcap | 66d | 2021-12-10 A | 2022-03-11 A | 100% | finish no earlier than 2022-03-12 | C6 | 528h | 528h | ARCH_NR_REDCAP | 48 | Chen Xu, China Mobile | Rel-17 | 95 | chenxu@chinamobile.com |  | 29.571; 29.502; 29.540; 29.518; 23.008 |
| 2430 | 1064.10 | Charging aspects of Architecture Enhancement for NR Reduced Capability Devices | 131d | 2021-12-10 A | 2022-06-10 A | 100% | finish no earlier than 2022-06-12 | S5 | 1048h | 1048h | ARCH_NR_REDCAP | 48 | Dong, Jia, China Mobile | Rel-17 | 94 | dongjia@chinamobile.com |  | 32.255; 32.298; 32.291 |
| 2431 | 1065 | **Additional NR bands for UL-MIMO power class 3 (PC3) in Rel-17** | 937.12d | 2020-12-14 A | 2023-06-06 A | 100% |  |  | 9464h | 9464h | NR_bands_UL_MIMO_PC3_R17 | 46 | Huawei | Rel-17 | 90 |  |  |  |
| 2432 | 1065.1 | Core part: NR_bands_UL_MIMO_PC3_R17 | 398d | 2020-12-14 A | 2022-06-22 A | 100% | finish no earlier than 2022-06-22 | R4 | 3184h | 3184h | NR_bands_UL_MIMO_PC3_R17-Core | 46 | Liu Ye, Huawei | Rel-17 | 90 | leo.liuye@huawei.com | RP-221517 |  |
| 2433 | 1065.2 | Perf. part: NR_bands_UL_MIMO_PC3_R17 | 398d | 2020-12-14 A | 2022-06-22 A | 100% | finish no earlier than 2022-06-22 | R4 | 3184h | 3184h | NR_bands_UL_MIMO_PC3_R17-Perf | 46 | Liu Ye, Huawei | Rel-17 | 90 | leo.liuye@huawei.com | RP-221517 |  |
| 2434 | 1065.3 | UE Conformance - Additional NR bands for UL-MIMO in Rel-17 | 387d | 2021-12-13 A | 2023-06-06 A | 100% | finish no earlier than 2023-06-06 | R5 | 3096h | 3096h | NR_bands_UL_MIMO_PC3_R17-UEConTest | 48 | Yuxin Hao, Huawei Technologies. Co., Ltd. | Rel-17 | 94 | haoyuxin@huawei.com | RP-230431 |  |
| 2435 | 1066 | Introduction of bandwidth combination set 4 (BCS4) for NR | 860d | 2019-03-07 A | 2022-06-22 A | 100% | finish no earlier than 2022-06-22 | R4 | 6880h | 6880h | NR_BCS4-Core | 46 | Per Lindell, Ericsson | Rel-17 | 90 | per.lindell@ericsson.com | RP-221317 |  |
| 2436 | 1067 | **Downlink interruption for NR and EN-DC band combinations to conduct dynamic Tx Switching in Uplink** | 1215.5d | 2020-12-14 A | 2024-03-01 A | 100% |  |  | 7760h | 7760h | DL_intrpt_combos_TxSW_R17 | 46 | China Telecom | Rel-17 | 90 |  |  | 37.867 |
| 2437 | 1067.1 | Core part: DL_intrpt_combos_TxSW_R17 | 325d | 2020-12-14 A | 2022-03-11 A | 100% | finish no earlier than 2022-03-22 | R4 | 2600h | 2600h | DL_intrpt_combos_TxSW_R17-Core | 46 | China Telecom | Rel-17 | 90 |  | RP-220570 |  |
| 2438 | 1067.2 | Perf. part: DL_intrpt_combos_TxSW_R17 | 325d | 2020-12-14 A | 2022-03-11 A | 100% | finish no earlier than 2022-03-22 | R4 | 2600h | 2600h | DL_intrpt_combos_TxSW_R17-Perf | 46 | China Telecom | Rel-17 | 90 |  | RP-220570 |  |
| 2439 | 1067.3 | UE Conformance - Downlink interruption for NR and EN-DC band combinations to conduct dynamic Tx Switching in Uplink | 320d | 2022-12-13 A | 2024-03-01 A | 100% | finish no earlier than 2024-03-01 | R5 | 2560h | 2560h | DL_intrpt_combos_TxSW_R17-UEConTest | 50 | Jingzhou Wu, China Telecom | Rel-17 | 98 | wujingzhou@chinatelecom.cn | RP-240342 |  |
| 2440 | 1068 | **High-power UE (power class 1.5) operation in NR bands n77 and n78** | 743.38d | 2020-12-14 A | 2022-12-01 A | 100% |  |  | 4136h | 4136h | HPUE_PC1_5_n77_n78 | 46 | Qualcomm | Rel-17 | 90 |  |  |  |
| 2441 | 1068.1 | Core part: HPUE_PC1_5_n77_n78 | 202d | 2020-12-14 A | 2021-09-21 A | 100% | finish no earlier than 2021-09-21 | R4 | 1616h | 1616h | HPUE_PC1_5_n77_n78-Core | 46 | Qualcomm | Rel-17 | 90 |  | RP-212049 |  |
| 2442 | 1068.2 | UE Conformance - High-power UE (power class 1.5) operation in NR bands n77 and n78 | 315d | 2021-09-17 A | 2022-12-01 A | 100% | finish no earlier than 2022-12-01 | R5 | 2520h | 2520h | HPUE_PC1_5_n77_n78-UEConTest | 47 | Jinwen MA, Tuomo Saynajakangas, Verizon, Nokia | Rel-17 | 93 | jinwen.ma@verizonwireless.com, tuomo.saynajakangas@nokia.com | RP-223280 |  |
| 2443 | 1069 | **NR repeaters** | 764.12d | 2020-12-14 A | 2022-12-21 A | 100% |  |  | 5296h | 5296h | NR_repeaters | 46 | Qualcomm | Rel-17 | 90 |  |  |  |
| 2444 | 1069.1 | Core part: HPUE_PC1_5_n77_n78 | 332d | 2020-12-14 A | 2022-03-22 A | 100% | finish no earlier than 2022-03-22 | R4 | 2656h | 2656h | NR_repeaters-Core | 46 | Valentin Gheorghiu | Rel-17 | 90 | vgheorgh@qti.qualcomm.com | RP-221566 | 38.114; 38.106 |
| 2445 | 1069.2 | Perf. part: NR repeaters | 330d | 2021-09-17 A | 2022-12-21 A | 100% | finish no earlier than 2022-12-22 | R4 | 2640h | 2640h | NR_repeaters-Perf | 47 | Valentin Gheorghiu | Rel-17 | 93 | vgheorgh@qti.qualcomm.com | RP-221566 | 38.115-2; 38.115-1 |

Notes:
- 2420: follow-up WI of REL-17 SI FS_NR_redcap (not yet completed at RAN #90e) ; 7/4/21: WID:RP-202933->RP-210918; 2/7/21: WID:RP-210918->RP-211574; 5/4/22: WID:RP-211574->RP-220966
- 2421: affects: NR. TR 38.8xx; 28/7/20: WID:RP-193238->RP-201386; 25/9/20: WID:RP-201386->RP-201677; 6/1/21: WID:RP-201677->RP-202704; 7/4/21: 0%->100
- 2422: follow-up WI of REL-17 SI FS_NR_redcap (not yet completed at RAN #90e) ; 22/ 20/6/22: Rapporteur: Ericsson->Johan BERGMAN, Ericsson; Rap eMail: ->johan.bergman@ericsson.com;
- 2423: follow-up WI of REL-17 SI FS_NR_redcap ; 22/3/22: Compl:0%->25%; 22/3/22: CD:08/09/2022- 6/6/22: Compl ; 20/6/22: WG: R4->R1; Rapporteur: Ericsson->Johan BERGMAN, Ericsson; Rap eMail: ->johan.bergman@ericsson.com ...; 9/12/22: 75%->100; 9/1/23: 100%...; 9/1/23: 100%->100
- 2424: tested: REL-17 WI NR_redcap-Core and CT1 REL-17 WI ARCH_NR_REDCAP 6/6/22: Compl:0%->13% ; 20/6/22: Rapporteur: China Unicom->Shi，Yu, China Unicom; Rap eMail: ->shiyu19@chinaunicom.cn ...; 23/9/22: WID:RP-222830->RP-222136; 9/12/22: FCD:23/06/2023->...; 2/4/24: WID:RP-232770->RP-240053
- 2425: ; 10/12/21: 0%->100
- 2426: 12/3/22: 0%->98; 12/3/22: FCD:10/06/2022->3/22; 4/6/22: 98%->100
- 2427: 12/3/22: 0%->98; 12/3/22: FCD:10/06/2022->3/22; 12/3/22: WID:CP-213081->CP-220304; 12/3/22: 0%->100; 4/6/22: WID:CP-220304->CP-221265
- 2428: 12/3/22: 20%->98; 12/3/22: FCD:10/06/2022->3/22; 4/6/22: 98%->100
- 2429: 12/3/22: 20%->98; 12/3/22: FCD:10/06/2022->3/22; 12/3/22: 0%->100; 4/6/22: 100%->
- 2430: ; 12/3/22: 0%->35; 4/6/22: 35%->100
- 2431: basket WI ; 7/4/21: WID:RP-202819->RP-210557; 2/7/21: WID:RP-210557->RP-211380; 29/9/21: WID:RP-211380->RP-212184; 6/1/22: WID:RP-212184->RP-213137; 5/4/22: WID:RP-213137->RP-220704; 12/7/22: WID:RP-220704->RP-221518
- 2432: basket WI ; 13/9/21: Compl:0%->70%; 20/6/22: WID: ->RP-213136; Rapporteur: Huawei->Liu Ye, Huawei; Rap eMail: ->leo.liuye@huawei.com;
- 2433: basket WI ; 13/9/21: CD:Sun 12/06/22->Tue 22/03/22; ; 20/6/22: WID: ->RP-213136; Rapporteur: Huawei->Liu Ye, Huawei; Rap eMail: ->leo.liuye@huawei.com;
- 2434: tested: REL-17 WI NR_bands_UL_MIMO_PC3_R17; 22/3/22: Compl:0%->8%; 22/3/22: Stat Rep: ->RP-220419; 5/4/22: WID:RP-213227->RP-220745 ; 6/6/22: CD:12/09/2022->22 ; 20/6/22: Rapporteur: Huawei->Yuxin Hao, Huawei Technologies. Co., Ltd.; Rap eMail: ->haoyu...; ; ; ; ; ; ; ; ; ; ; ; ; ; ; ; ; ; ; ; ; ; ; ; ; ; ; ; ; ; ; ; ; ; ; ; ; ; ; ; ; ; ; ; ; ; ; ; ; ; ; ; ; ; ; ; ; ; ; ; ; ; ; ; ; ; 7/6/23: Compl:73%->100%
- 2435: no Perf. part ; 20/6/22: FCD:03/06/2020->22/06/2022; Compl:0%->100%; Stat Rep: ->RP-221317; Rapporteur: Ericsson->Per Lindell, Ericsson; Rap eMail: ->per.lindell@ericsson.com;
- 2436: basket WI; TR 37.8xx ; 7/4/21: WID:RP-202885->RP-210478; 2/7/21: 37.867 added;
- 2437: basket WI; TR 37.8xx ; 13/9/21: Compl:0%->60%; 13/9/21: CD:Sat 12/03/22->Tue 22/03/22; 13/9/21: WID: RP-210478->RP-202885 RP-210478 ; ;
- 2438: basket WI ; 13/9/21: CD:Sat 12/03/22->Tue 22/03/22; 13/9/21: WID: RP-210478->RP-202885 RP-210478; 13/9/21: Stat Rep: ->RP-211833 ;
- 2439: 17/3/23: FCD:12/12/2023->06/06/2023; Compl:0%->5%; Stat Rep: ->RP-230318; Rapporteur: China Telecom->Jingzhou Wu, China Telecom; Rap eMail: ->wujingzhou@chinatelecom.cn; 31/3/23: FCD:06/06/2023->12/12/2023; Stat Rep: RP-230318->RP-230715; ...; 6/9/23:...; 2/4/24: WID:RP-222948->RP-240785
- 2440: no Perf. part
- 2441: no Perf. part ; 13/9/21: Compl:0%->100% ; 29/9/21: 100%->100
- 2442: tested: REL-17 WI HPUE_PC1_5_n77_n78-Core ; 22/3/22: Compl:0%->50%; ; 6/6/22: Compl:50%->61%20/6/22: Rapporteur: Verizon->Jinwen MA, Tuomo Saynajakangas, Verizon, Nokia; Rap eMail: ->jinwen.ma@verizonwireless.com, tuomo.saynajakangas@nokia.com; ...;...; 9/1/23: 100%->100
- 2443: no Perf. part ; 7/4/21: WID:RP-202927->RP-210818; 29/9/21: WID:RP-210818->RP-212129; 6/1/22: WID:RP-212129->RP-213514
- 2444: no Perf. part ; 2/7/21: 38.114 added;; 2/7/21: 38.106 added;; 20/6/22: FCD:12/12/2021->22/03/2023; Compl:0%->100%; WID: RP-213514->RP-212129; Stat Rep: ->RP-221566; Rapporteur: Qualcomm->Valentin Gheorghiu; Rap eMail: ->vgheorgh@qti.qualcomm.com;
- 2445: Core part (UID=900170) started in Dec.20 while Perf. Part (UID=930250) started in 17/09/21 via revised WID RP-212129; TS 38.1??-1, TS 38.1??-2 ; 7/1/22: 38.115-2 and 38.115-1 added;; 20/6/22: FCD:17/09/2022->22/09/2022; Compl:0%->30%; WID: RP-213514->R...; 9/1/23: 80%->100

| ID | WBS | Task | Type | Duration | Start | Finish | Complete | Constraint | Resources | Work | Actual work | Acronym | PCG approved | WI rapporteur name | Release | TSG approved | WI rapporteur e-mail | Status Report | Impacted TSs and TRs | TSG stopped |
| --- | --- | --- | --- | --- | --- | --- | --- | --- | --- | --- | --- | --- | --- | --- | --- | --- | --- | --- | --- | --- |
| 2446 | 1070 | **Increasing UE power high limit for CA and DC** |  | 762d | 2021-09-17 A | 2023-09-22 A | 100% |  | R4 | 7448h | 7448h | Power_Limit_CA_DC | 47 | Qualcomm | Rel-17 | 93 |  |  |  |  |
| 2447 | 1070.1 | Core part: Increasing UE power high limit for CA and DC |  | 199d | 2021-09-17 A | 2022-06-22 A | 100% | finish no earlier than 2022-06-22 | R4 | 1592h | 1592h | Power_Limit_CA_DC-Core | 47 | Gene Fong, Qualcomm Incorporated | Rel-17 | 93 | gfong@qti.qualcomm.com | RP-221588 |  |  |
| 2448 | 1070.2 | UE Conformance - Increasing UE power high limit for CA and DC |  | 205d | 2022-12-13 A | 2023-09-22 A | 100% | finish no earlier than 2023-09-22 | R5 | 1640h | 1640h | Power_Limit_CA_DC-UEConTest | 50 | Kevin Wang / Jingzhou wu, Qualcomm / China Telecom | Rel-17 | 98 | kevinw@qti.qualcomm.com /wujingzhou@chinatelecom.cn | RP-232018 |  |  |
| 2449 | 1071 | **Introduction of upper 700MHz A block E-UTRA band for the US** |  | 456.62d | 2021-09-17 A | 2022-12-01 A | 100% |  | R4 | 5512h | 5512h | LTE_upper_700MHz_A | 47 | Puloli | Rel-17 | 93 |  |  |  |  |
| 2450 | 1071.1 | Core part: Introduction of upper 700MHz A block E-UTRA band for the US |  | 126d | 2021-09-17 A | 2022-03-11 A | 100% | finish no earlier than 2022-03-15 | R4 | 1008h | 1008h | LTE_upper_700MHz_A-Core | 47 | Puloli | Rel-17 | 93 |  | RP- 220404 | 36.779 |  |
| 2451 | 1071.2 | Perf. part: Introduction of upper 700MHz A block E-UTRA band for the US |  | 126d | 2021-09-17 A | 2022-03-11 A | 100% | finish no earlier than 2022-03-15 | R4 | 1008h | 1008h | LTE_upper_700MHz_A-Perf | 47 | Puloli | Rel-17 | 93 |  | RP- 220404 |  |  |
| 2452 | 1071.3 | UE Conformance - Introduction of upper 700MHz A block E-UTRA band for the US (band 103) |  | 122d | 2022-06-15 A | 2022-12-01 A | 100% | finish no earlier than 2022-12-01 | R5 | 976h | 976h | LTE_upper_700MHz_A-UEConTest | 49 | Heng Pan, Puloli | Rel-17 | 96 | heng.pan@puloli.com | RP-222802 |  |  |
| 2453 | 1072 | **High power UE (power class 2) for one NR FDD band** |  | 456.62d | 2021-09-17 A | 2022-12-01 A | 100% |  | R4 | 5512h | 5512h | NR_PC2_UE_FDD | 47 | China Unicom | Rel-17 | 93 |  |  |  |  |
| 2454 | 1072.1 | Core part: High power UE (power class 2) for one NR FDD band |  | 126d | 2021-09-17 A | 2022-03-11 A | 100% | finish no earlier than 2022-03-15 | R4 | 1008h | 1008h | NR_PC2_UE_FDD-Core | 47 | China Unicom | Rel-17 | 93 |  | RP-220381 |  |  |
| 2455 | 1072.2 | Perf. part: High power UE (power class 2) for one NR FDD band |  | 126d | 2021-09-17 A | 2022-03-11 A | 100% | finish no earlier than 2022-03-15 | R4 | 1008h | 1008h | NR_PC2_UE_FDD-Perf | 47 | China Unicom | Rel-17 | 93 |  | RP-220381 |  |  |
| 2456 | 1072.3 | UE Conformance - High power UE (power class 2) for one NR FDD band |  | 122d | 2022-06-15 A | 2022-12-01 A | 100% | finish no earlier than 2022-12-01 | R5 | 976h | 976h | NR_PC2_UE_FDD-UEConTest | 49 | Shi，Yu, China Unicom | Rel-17 | 96 | shiyu19@chinaunicom.cn | RP-222808 |  |  |
| 2457 | 1073 | **Rel-17 NR Carrier Aggregation** |  | 0d | 2016-06-09 A | 2016-06-09 A | 100% |  |  |  |  |  |  |  | Rel-17 |  |  |  | 26.234; 26.247 |  |
| 2458 | 1073.1 | Rel-17 NR intra band Carrier Aggregation (itrabCA) | milestone, manual | 0d | 2016-06-09 A | 2016-06-09 A | 100% |  |  |  |  |  |  |  | Rel-17 |  |  |  | 26.234; 26.247 |  |
| 2459 | 1074 | **NR itrabCA for xCC DL/yCC UL including contiguous and non-contiguous spectrum (x>=y)** |  | 2283.5d | 2016-06-09 A | 2022-06-22 A | 100% |  |  | 8368h | 8368h | NR_CA_R17_Intra | 45 | Ericsson | Rel-17 | 88 |  |  |  |  |
| 2460 | 1074.1 | Core part: NR_CA_R17_Intra |  | 523d | 2020-06-22 A | 2022-06-22 A | 100% | finish no earlier than 2022-06-22 | R4 | 4184h | 4184h | NR_CA_R17_Intra-Core | 45 | Per Lindell, Ericsson | Rel-17 | 88 | per.lindell@ericsson.com | RP-221314 |  |  |
| 2461 | 1074.2 | Perf. Part: NR_CA_R17_Intra |  | 523d | 2020-06-22 A | 2022-06-22 A | 100% | finish no earlier than 2022-06-22 | R4 | 4184h | 4184h | NR_CA_R17_Intra-Perf | 45 | Per Lindell, Ericsson | Rel-17 | 88 | per.lindell@ericsson.com | RP-221314 |  |  |
| 2462 | 1074.3 | Rel-17 NR inter band Carrier Aggregation (iterbCA) | milestone, manual | 0d | 2016-06-09 A | 2016-06-09 A | 100% |  |  |  |  |  |  |  | Rel-17 |  |  |  | 26.234; 26.247 |  |
| 2463 | 1075 | **High power UE for NR TDD intra-band Carrier Aggregation in frequency range FR1** |  | 515.62d | 2021-02-10 A | 2022-06-22 A | 100% |  |  | 5632h | 5632h | NR_intra_HPUE_R17 | 46 | Huawei | Rel-17 | 90 |  |  |  |  |
| 2464 | 1075.1 | Core part: NR_intra_HPUE_R17 |  | 356d | 2021-02-10 A | 2022-06-22 A | 100% | finish no earlier than 2022-06-22 | R4 | 2848h | 2848h | NR_intra_HPUE_R17-Core | 46 | Lingyu Kong, Huawei, HiSilicon | Rel-17 | 90 | konglingyu4@hisilicon.com | RP-221513 / 1773 |  |  |
| 2465 | 1075.2 | Stopped - Perf. Part: NR_intra_HPUE_R17 |  | 348d | 2021-02-10 A | 2022-06-10 A | 100% | finish no earlier than 2022-06-12 | R4 | 2784h | 2784h | NR_intra_HPUE_R17-Perf | 46 | Huawei | Rel-17 | 90 |  | RP-220696 |  | 96 |
| 2466 | 1076 | **NR iterbCA/Dual Connectivity for 2 bands DL with x bands UL (x=1,2)** |  | 756.88d | 2020-06-22 A | 2022-06-22 A | 100% |  |  | 8368h | 8368h | NR_CADC_R17_2BDL_xBUL | 45 | ZTE | Rel-17 | 88 |  |  |  |  |
| 2467 | 1076.1 | Core part: NR_CADC_R17_2BDL_xBUL |  | 523d | 2020-06-22 A | 2022-06-22 A | 100% | finish no earlier than 2022-06-22 | R4 | 4184h | 4184h | NR_CADC_R17_2BDL_xBUL-Core | 45 | Aijun Cao, ZTE | Rel-17 | 88 | cao.aijun@zte.com.cn | RP-221251 |  |  |
| 2468 | 1076.2 | Perf. part: NR_CADC_R17_2BDL_xBUL |  | 523d | 2020-06-22 A | 2022-06-22 A | 100% | finish no earlier than 2022-06-22 | R4 | 4184h | 4184h | NR_CADC_R17_2BDL_xBUL-Perf | 45 | Aijun Cao, ZTE | Rel-17 | 88 | cao.aijun@zte.com.cn | RP-221251 |  |  |
| 2469 | 1077 | **NR iterbCA for 3 bands DL with 1 band UL** |  | 756.88d | 2020-06-22 A | 2022-06-22 A | 100% |  |  | 8368h | 8368h | NR_CA_R17_3BDL_1BUL | 45 | CATT | Rel-17 | 88 |  |  |  |  |
| 2470 | 1077.1 | Core part: NR_CA_R17_3BDL_1BUL |  | 523d | 2020-06-22 A | 2022-06-22 A | 100% | finish no earlier than 2022-06-22 | R4 | 4184h | 4184h | NR_CA_R17_3BDL_1BUL-Core | 45 | Yuexia Song, CATT | Rel-17 | 88 | songyuexia@catt.cn | RP-221462 |  |  |
| 2471 | 1077.2 | Perf. part: NR_CA_R17_3BDL_1BUL |  | 523d | 2020-06-22 A | 2022-06-22 A | 100% | finish no earlier than 2022-06-22 | R4 | 4184h | 4184h | NR_CA_R17_3BDL_1BUL-Perf | 45 | Yuexia Song, CATT | Rel-17 | 88 | songyuexia@catt.cn | RP-221462 |  |  |

Notes:
- 2446: no Perf. part ; 12/7/22: WID:RP-212622->RP-221302
- 2447: no Perf. Part ; 22/3/22: Compl:0%->75%; … 20/6/22: WID: RP-212622->RP-221302; Stat Rep: RP-220514->RP-221588; Rapporteur: Qualcomm->Gene Fong, Qualcomm Incorporated; Rap eMail: ->gfong@qti.qualcomm.com;
- 2448: 17/3/23: FCD:09/09/2023->08/09/2023; Compl:0%->52%; Stat Rep: ->RP-230101; Rapporteur: Qualcomm->Kevin Wang / Jingzhou wu, Qualcomm / China Telecom; Rap eMail: ->kevinw@qti.qualcomm.com /wujingzhou@chinatelecom.cn; ...; 6/9/23: FCD:09/09/2023->22/09/2023; Compl:85%->100%; Stat Rep: RP-230101->RP-232018;
- 2449: specs in [ ]; TR 36.8xx ; 6/1/22: WID:RP-212618->RP-212917
- 2450: specs in [ ]; TR 36.8xx ; 7/1/22: 36.779 added ;
- 2451: specs in [ ] ;
- 2452: 9/9/22: Comp...; 9/12/22: FCD:22/12/2022->01/12/2022; Compl:72%->100%; Stat Rep: ->RP-222802; Rapporteur: Puloli->Heng Pan, Puloli; Rap eMail: ->heng.pan@puloli.com; 9/1/23: 100%->100
- 2453: follow-up WI of SI FS_NR_PC2_UE_FDD; for NR bands n1 and n3
- 2454: follow-up WI of SI FS_NR_PC2_UE_FDD; for NR bands n1 and n3 ;
- 2455: follow-up WI of SI FS_NR_PC2_UE_FDD ;
- 2456: 9/9/22: Comp...; 9/12/22: FCD:23/12/2022->01/12/2022; Compl:67%->100%; WID: RP-221158->RP-222809; Stat Rep: ->RP-222808; Rapporteur: ChinaUnicom->Shi，Yu, China Unicom; Rap eMail: ->shiyu19@chinaunicom.cn; 9/1/23: 100%->100
- 2459: 25/9/20: WID:RP-200663->RP-201571; 6/1/21: WID:RP-201571->RP-202187; 7/4/21: WID:RP-202187->RP-210210; 2/7/21: WID:RP-210210->RP-211585; 29/9/21: WID:RP-211585->RP-211757; 6/1/22: WID:RP-211757->RP-212900; 5/4/22: WID:RP-212900->RP-220825; 12/7/22: WID:RP-220825->RP-221319
- 2460: 13/9/21: Compl:0%->24%13/9/21: CD:Wed 15/09/21->Tue 22/03/2213/9/21: Stat Rep: ->RP-211752 ; 20/6/22: Rapporteur: Ericsson->Per Lindell, Ericsson; Rap eMail: ->per.lindell@ericsson.com;
- 2461: 13/9/21: Compl:0%->24%13/9/21: CD:Wed 15/09/21->Tue 22/03/2213/9/21: Stat Rep: ->RP-211752 ; 20/6/22: Rapporteur: Ericsson->Per Lindell, Ericsson; Rap eMail: ->per.lindell@ericsson.com;
- 2463: 7/4/21: WID:RP-202818->RP-210555; 29/9/21: WID:RP-210555->RP-212180; 6/1/22: WID:RP-212180->RP-213133; 5/4/22: WID:RP-213133->RP-220930; 12/7/22: WID:RP-220930->RP-221774
- 2464: ; 13/9/21: Compl:0%->5% ; 22/3/22: Compl:5%->10%; 22/3/22: CD:22/03/2022->10/06/2022 ; 20/6/22: Stat Rep: RP-221513->RP-221513 / 1773; Rapporteur: Huawei->Lingyu Kong, Huawei, HiSilicon; Rap eMail: ->konglingyu4@hisilicon.com;
- 2465: ; 13/9/21: CD:Thu 09/12/21->Wed 22/06/22; ; 22/3/22: CD:22/06/2022->12/06/2022; 22/3/22: WID: RP-213133->RP-213132; 22/3/22: Stat Rep: RP-212179->RP-220696. 12/7/22: stopped at 0%. 0%->100
- 2466: 25/9/20: WID:RP-200672->RP-201539; 6/1/21: WID:RP-201539->RP-202199; 7/4/21: WID:RP-202199->RP-210495; 2/7/21: WID:RP-210495->RP-211058; 29/9/21: WID:RP-211058->RP-212511; 6/1/22: WID:RP-212511->RP-212887; 5/4/22: WID:RP-212887->RP-220144; 12/7/22: WID:RP-220144->RP-221250
- 2467: ; 20/6/22: Rapporteur: ZTE->Aijun Cao, ZTE; Rap eMail: ->cao.aijun@zte.com.cn;
- 2468: ; 20/6/22: Rapporteur: ZTE->Aijun Cao, ZTE; Rap eMail: ->cao.aijun@zte.com.cn;
- 2469: 25/9/20: WID:RP-200922->RP-201787; 6/1/21: WID:RP-201787->RP-202720; 7/4/21: WID:RP-202720->RP-210901; 2/7/21: WID:RP-210901->RP-211215; 29/9/21: WID:RP-211215->RP-212239; 6/1/22: WID:RP-212239->RP-213299; 5/4/22: WID:RP-213299->RP-220738; 12/7/22: WID:RP-220738->RP-221772
- 2470: ; 22/3/22: Compl:0%->95%; 20/6/22: Rapporteur: CATT->Yuexia Song, CATT; Rap eMail: ->songyuexia@catt.cn;
- 2471: ; 22/3/22: CD:15/09/2021->12/06/2022; 22/3/22: Stat Rep: ->RP-220737 ; 20/6/22: Rapporteur: CATT->Yuexia Song, CATT; Rap eMail: ->songyuexia@catt.cn;

| ID | WBS | Task | Type | Duration | Start | Finish | Complete | Actual finish | Constraint | Resources | Work | Actual work | Acronym | PCG approved | WI rapporteur name | Release | TSG approved | WI rapporteur e-mail | Status Report | Impacted TSs and TRs |
| --- | --- | --- | --- | --- | --- | --- | --- | --- | --- | --- | --- | --- | --- | --- | --- | --- | --- | --- | --- | --- |
| 2472 | 1078 | **NR iterbCA/Dual Connectivity for 3 bands DL with 2 bands UL** |  | 756.88d | 2020-06-22 A | 2022-06-22 A | 100% |  |  |  | 8368h | 8368h | NR_CADC_R17_3BDL_2BUL | 45 | ZTE | Rel-17 | 88 |  |  |  |
| 2473 | 1078.1 | Core part: NR_CADC_R17_3BDL_2BUL |  | 523d | 2020-06-22 A | 2022-06-22 A | 100% |  | finish no earlier than 2022-06-22 | R4 | 4184h | 4184h | NR_CADC_R17_3BDL_2BUL-Core | 45 | Aijun Cao, ZTE | Rel-17 | 88 | cao.aijun@zte.com.cn | RP-221254 |  |
| 2474 | 1078.2 | Perf. part: NR_CADC_R17_3BDL_2BUL |  | 523d | 2020-06-22 A | 2022-06-22 A | 100% |  | finish no earlier than 2022-06-22 | R4 | 4184h | 4184h | NR_CADC_R17_3BDL_2BUL-Perf | 45 | Aijun Cao, ZTE | Rel-17 | 88 | cao.aijun@zte.com.cn | RP-221254 |  |
| 2475 | 1079 | **NR iterbCA for 4 bands DL with 1 band UL** |  | 756.88d | 2020-06-22 A | 2022-06-22 A | 100% |  |  |  | 8368h | 8368h | NR_CA_R17_4BDL_1BUL | 45 | Ericsson | Rel-17 | 88 |  |  |  |
| 2476 | 1079.1 | Core part: NR_CA_R17_4BDL_1BUL |  | 523d | 2020-06-22 A | 2022-06-22 A | 100% |  | finish no earlier than 2022-06-22 | R4 | 4184h | 4184h | NR_CA_R17_4BDL_1BUL-Core | 45 | Per Lindell, Ericsson | Rel-17 | 88 | per.lindell@ericsson.com | RP-221316 |  |
| 2477 | 1079.2 | Perf. part: NR_CA_R17_4BDL_1BUL |  | 523d | 2020-06-22 A | 2022-06-22 A | 100% |  | finish no earlier than 2022-06-22 | R4 | 4184h | 4184h | NR_CA_R17_4BDL_1BUL-Perf | 45 | Per Lindell, Ericsson | Rel-17 | 88 | per.lindell@ericsson.com | RP-221316 |  |
| 2478 | 1080 | **NR iterbCA/Dual connectivity for DL 4 bands and 2UL bands** |  | 756.88d | 2020-06-22 A | 2022-06-22 A | 100% |  |  |  | 8368h | 8368h | NR_CADC_R17_4BDL_2BUL | 45 | Samsung | Rel-17 | 88 |  |  |  |
| 2479 | 1080.1 | Core part: NR_CADC_R17_4BDL_2BUL |  | 523d | 2020-06-22 A | 2022-06-22 A | 100% |  | finish no earlier than 2022-06-22 | R4 | 4184h | 4184h | NR_CADC_R17_4BDL_2BUL-Core | 45 | Yue Wu, Samsung | Rel-17 | 88 | yue.wu@samsung.com | RP-221397 |  |
| 2480 | 1080.2 | Perf. part: NR_CADC_R17_4BDL_2BUL |  | 523d | 2020-06-22 A | 2022-06-22 A | 100% |  | finish no earlier than 2022-06-22 | R4 | 4184h | 4184h | NR_CADC_R17_4BDL_2BUL-Perf | 45 | Yue Wu, Samsung | Rel-17 | 88 | yue.wu@samsung.com | RP-221397 |  |
| 2481 | 1081 | **NR iterbCA for 5 bands DL with x bands UL (x=1, 2)** |  | 756.88d | 2020-06-22 A | 2022-06-22 A | 100% |  |  |  | 8368h | 8368h | NR_CADC_R17_5BDL_xBUL | 45 | Huawei | Rel-17 | 88 |  |  |  |
| 2482 | 1081.1 | Core part: NR_CADC_R17_5BDL_xBUL |  | 523d | 2020-06-22 A | 2022-06-22 A | 100% |  | finish no earlier than 2022-06-22 | R4 | 4184h | 4184h | NR_CADC_R17_5BDL_xBUL-Core | 45 | Zhang, Peng, Huawei | Rel-17 | 88 | zhangpeng169@huawei.com | RP-221509 |  |
| 2483 | 1081.2 | Perf. part: NR_CADC_R17_5BDL_xBUL |  | 523d | 2020-06-22 A | 2022-06-22 A | 100% |  | finish no earlier than 2022-06-22 | R4 | 4184h | 4184h | NR_CADC_R17_5BDL_xBUL-Perf | 45 | Zhang, Peng, Huawei | Rel-17 | 88 | zhangpeng169@huawei.com | RP-221509 |  |
| 2484 | 1082 | **Rel-17 High power UE for NR inter-band Carrier Aggregation with 2 bands downlink and x bands uplink (x=1,2)** |  | 1224d | 2020-09-17 A | 2023-12-12 A | 100% |  |  |  | 12584h | 12584h | NR_PC2_CA_R17_2BDL_2BUL | 45 | China Telecom | Rel-17 | 89 |  |  | 38.841 |
| 2485 | 1082.1 | Core part: NR_PC2_CA_R17_2BDL_2BUL |  | 460d | 2020-09-17 A | 2022-06-22 A | 100% |  | finish no earlier than 2022-06-22 | R4 | 3680h | 3680h | NR_PC2_CA_R17_2BDL_2BUL-Core | 45 | Liu, Bo, China Telecom | Rel-17 | 89 | liubo1@chinatelecom.cn | RP-221301 |  |
| 2486 | 1082.2 | Perf. part: NR_PC2_CA_R17_2BDL_2BUL |  | 460d | 2020-09-17 A | 2022-06-22 A | 100% |  | finish no earlier than 2022-06-22 | R4 | 3680h | 3680h | NR_PC2_CA_R17_2BDL_2BUL-Perf | 45 | Liu, Bo, China Telecom | Rel-17 | 89 | liubo1@chinatelecom.cn | RP-221301 |  |
| 2487 | 1082.3 | UE Conformance - Rel-17 High power UE for NR inter-band Carrier Aggregation with 2 bands downlink and x bands uplink (x=1,2) |  | 653d | 2021-06-15 A | 2023-12-12 A | 100% |  | finish no earlier than 2023-12-12 | R5 | 5224h | 5224h | NR_PC2_CA_R17_2BDL_2BUL-UEConTest | 47 | Jingzhou Wu, Dan Song, China Telecom, China Mobile | Rel-17 | 92 | wujingzhou@chinatelecom.cn, songdan@chinamobile.com | RP-233580 |  |
| 2488 | 1083 | Rel-17 NR and LTE | manual | 125d | 2020-03-25 A | 2020-09-15 A | 100% |  |  |  |  |  |  |  |  | Rel-17 |  |  |  | 26.234; 26.247 |
| 2489 | 1084 | **LTE/NR spectrum sharing in Band 34/n34 and Band 39/n39** |  | 0d | 2019-03-07 A | 2019-03-07 | 100% | 2022-03-11 |  | R4 | 1576h | 1576h | DSS_LTE_B34_NR_Bn34_LTE_B39_NR_Bn39 | 47 | CMCC | Rel-17 | 92 |  | RP-211995 |  |
| 2490 | 1084.1 | Core part: LTE/NR spectrum sharing in Band 34/n34 and Band 39/n39 |  | 132d | 2021-06-15 A | 2021-12-15 A | 100% |  | finish no earlier than 2021-12-15 | R4 | 1056h | 1056h | DSS_LTE_B34_NR_Bn34_LTE_B39_NR_Bn39-Core | 47 | CMCC | Rel-17 | 92 |  |  |  |
| 2491 | 1084.2 | UE Conformance - LTE/NR spectrum sharing in Band 34/n34 and Band 39/n39 |  | 65d | 2021-12-13 A | 2022-03-11 A | 100% |  | finish no earlier than 2022-12-12 | R5 | 520h | 520h | DSS_LTE_B34_NR_Bn34_LTE_B39_NR_Bn39-UEConTest | 48 | CMCC | Rel-17 | 94 |  | RP-220625 |  |
| 2492 | 1085 | **High-power UE operation for fixed-wireless/vehicle-mounted use cases in LTE bands and NR bands** |  | 386.12d | 2021-06-15 A | 2022-06-22 A | 100% |  |  | R4 | 5880h | 5880h | LTE_NR_HPUE_FWVM | 47 | Nokia | Rel-17 | 92 |  |  |  |
| 2493 | 1085.1 | Core part: High-power UE operation for fixed-wireless/vehicle-mounted use cases in LTE bands and NR bands |  | 267d | 2021-06-15 A | 2022-06-22 A | 100% |  | finish no earlier than 2022-06-22 | R4 | 2136h | 2136h | LTE_NR_HPUE_FWVM-Core | 47 | Vasenkari, Petri, Nokia | Rel-17 | 92 | Petri.j.vasenkari@nokia.com | RP-221199 / 1775 | 37.828; 37.828 |
| 2494 | 1085.2 | Perf. Part: High-power UE operation for fixed-wireless/vehicle-mounted use cases in LTE bands and NR bands |  | 201d | 2021-09-15 A | 2022-06-22 A | 100% |  | finish no earlier than 2022-06-22 | R4 | 1608h | 1608h | LTE_NR_HPUE_FWVM-Perf | 47 | Vasenkari, Petri, Nokia | Rel-17 | 92 | Petri.j.vasenkari@nokia.com | RP-221199 / 1775 |  |
| 2495 | 1086 | **Rel-17 Dual Connectivity (DC) of x bands (x=1,2) LTE inter-band CA (xDL1UL) and 4 bands NR inter-band CA (4DL1UL)** |  | 386.12d | 2021-06-15 A | 2022-06-22 A | 100% |  |  | R4 | 6408h | 6408h | DC_R17_xBLTE_4BNR_yDL2UL | 47 | Huawei | Rel-17 | 92 |  |  |  |
| 2496 | 1086.1 | Core part: Rel-17 Dual Connectivity (DC) of x bands (x=1,2) LTE inter-band CA (xDL1UL) and 4 bands NR inter-band CA (4DL1UL) |  | 267d | 2021-06-15 A | 2022-06-22 A | 100% |  | finish no earlier than 2022-06-22 | R4 | 2136h | 2136h | DC_R17_xBLTE_4BNR_yDL2UL-Core | 47 | Zhang, Peng, Huawei | Rel-17 | 92 | zhangpeng169@huawei.com | RP-221523 |  |
| 2497 | 1086.2 | Perf. part: Rel-17 Dual Connectivity (DC) of x bands (x=1,2) LTE inter-band CA (xDL1UL) and 4 bands NR inter-band CA (4DL1UL) |  | 267d | 2021-06-15 A | 2022-06-22 A | 100% |  | finish no earlier than 2022-06-22 | R4 | 2136h | 2136h | DC_R17_xBLTE_4BNR_yDL2UL-Perf | 47 | Zhang, Peng, Huawei | Rel-17 | 92 | zhangpeng169@huawei.com | RP-221523 |  |

Notes:
- 2472: 25/9/20: WID:RP-201374->RP-201541; 6/1/21: WID:RP-201541->RP-202201; 7/4/21: WID:RP-202201->RP-210497; 2/7/21: WID:RP-210497->RP-211060; 29/9/21: WID:RP-211060->RP-212512; 6/1/22: WID:RP-212512->RP-212889; 5/4/22: WID:RP-212889->RP-220146; 12/7/22: WID:RP-220146->RP-221253
- 2473: ; 20/6/22: Rapporteur: ZTE->Aijun Cao, ZTE; Rap eMail: ->cao.aijun@zte.com.cn;
- 2474: ; 20/6/22: Rapporteur: ZTE->Aijun Cao, ZTE; Rap eMail: ->cao.aijun@zte.com.cn;
- 2475: 25/9/20: WID:RP-200665->RP-201573; 6/1/21: WID:RP-201573->RP-202189; 7/4/21: WID:RP-202189->RP-210760; 2/7/21: WID:RP-210760->RP-211171; 29/9/21: WID:RP-211171->RP-211759; 6/1/22: WID:RP-211759->RP-212902; 5/4/22: WID:RP-212902->RP-220827; 12/7/22: WID:RP-220827->RP-221321
- 2476: 13/9/21: Compl:0%->45%13/9/21: CD:Wed 15/09/21->Tue 22/03/2213/9/21: Stat Rep: ->RP-211754 ; 20/6/22: Rapporteur: Ericsson->Per Lindell, Ericsson; Rap eMail: ->per.lindell@ericsson.com;
- 2477: 13/9/21: Compl:0%->45%13/9/21: CD:Wed 15/09/21->Tue 22/03/2213/9/21: Stat Rep: ->RP-211754 ; 20/6/22: Rapporteur: Ericsson->Per Lindell, Ericsson; Rap eMail: ->per.lindell@ericsson.com;
- 2478: 25/9/20: WID:RP-200869->RP-201640; 6/1/21: WID:RP-201640->RP-202544; 7/4/21: WID:RP-202544->RP-210802; 2/7/21: WID:RP-210802->RP-211194; 29/9/21: WID:RP-211194->RP-212110; 6/1/22: WID:RP-212110->RP-213111; 5/4/22: WID:RP-213111->RP-220676; 12/7/22: WID:RP-220676->RP-221396
- 2479: 20/6/22: FCD:15/09/2021->22/06/2022; Compl:0%->100%; Stat Rep: ->RP-221397; Rapporteur: Samsung->Yue Wu, Samsung; Rap eMail: ->yue.wu@samsung.com;
- 2480: ; 13/9/21: Compl:0%->70%; ; 22/3/22: Compl:70%->90%; 20/6/22: Rapporteur: Samsung->Yue Wu, Samsung; Rap eMail: ->yue.wu@samsung.com;
- 2481: 25/9/20: WID:RP-201027->RP-201724; 6/1/21: WID:RP-201724->RP-202609; 7/4/21: WID:RP-202609->RP-210561; 2/7/21: WID:RP-210561->RP-211373; 29/9/21: WID:RP-211373->RP-212176; 6/1/22: WID:RP-212176->RP-213129; 5/4/22: WID:RP-213129->RP-220692; 12/7/22: WID:RP-220692->RP-221510
- 2482: ; 13/9/21: Compl:0%->15%; ; 22/3/22: Compl:15%->40%; 22/3/22: 20/6/22: Rapporteur: Huawei->Zhang, Peng, Huawei; Rap eMail: ->zhangpeng169@huawei.com;
- 2483: ; 13/9/21: Compl:0%->15%; ; 22/3/22: Compl:15%->40%; 22/3 20/6/22: Rapporteur: Huawei->Zhang, Peng, Huawei; Rap eMail: ->zhangpeng169@huawei.com;
- 2484: basket WI; related to generic WI NR_SAR_PC2_interB_SUL_2BUL-Core; TR 38.8xx ; 6/1/21: WID:RP-202102->RP-202373; 7/4/21: WID:RP-202373->RP-210476; 2/7/21: WID:RP-210476->RP-211131; 2/7/21: 38.841 added;; 29/9/21: WID:RP-211131->RP-211831; 6/1/22: WID:RP ; 12/7/22: WID:RP-220567->RP-221866
- 2485: basket WI; related to generic WI NR_SAR_PC2_interB_SUL_2BUL-Core; TR 38.8xx ; 13/9/21: Compl:0%->70%; 13/9/21: CD:Fri 17/12/21->Tue 22/03/22; 13/9/21: WID: RP-211 ; 20/6/22: WID: RP-202102 RP-202373 RP-210476 RP-211131 RP-211831 RP_213649 RP-220...
- 2486: basket WI ; 13/9/21: CD:Fri 17/12/21->Tue 22/03/22; 13/9/21: WID: RP-211131->RP-202102 RP-202373 RP-210476 RP-211131; 13/9/21: Stat Rep: ->RP-211832; 22/3/22: CD:22/03/2022->12/06/2022; 22/3/22: WID: RP-213649->RP_213649; 22/3/22: Stat Rep: RP-211832- ; 20/6/22: WID: RP-202102 RP-202373 RP-210476 RP-211131 RP-211831 RP_213649 RP-220567->RP-220567; Rapporteur: China Telecom->Liu, Bo, China Telecom; Rap eMail: ->liubo1@chinatelecom.cn;
- 2487: tested: REL-17 WI NR_PC2_CA_R17_2BDL_2BUL-Core ; 13/9/21: Compl:0%->15%; 13/9/21: CD:Tue 15/03/22->Tue 22/03/22; 1 ; 22/3/22: Compl:15%->18%; 20/6/22: Rapporteur: China Telecom->Jingzhou Wu, China Telecom; Rap eMail: ->wujingzhou@chinatelecom.cn...;...; 2/1/24: WID:RP-211140->RP-233581
- 2489: compare REL-17 WI NR_DSS; no Perf. part ; 13/9/21: Compl:0%->100% ;
- 2490: compare REL-17 WI NR_DSS; no Perf. part ; 29/9/21: WID:RP-211509->RP-211996
- 2491: tested: REL-17 WI DSS_LTE_B34_NR_Bn34_LTE_B39_NR_Bn39-Core;
- 2492: this is not a basket WI ; 29/9/21: WID:RP-211571->RP-212533; 6/1/22: WID:RP-212533->RP-213106; 5/4/22: WID:RP-213106->RP-220767; 12/7/22: WID:RP-220767->RP-221795
- 2493: this is not a basket WI ; 13/9/21: CD:Tue 15/03/22->Tue 22/03/22; …; 7/1/22: 37.828 and 37.828 added;; 22/3/22: Compl:0%->50% ; 20/6/22: Compl:50%->100%; Stat Rep: RP-221199->RP-221199 / 1775; Rapporteur: Nokia->Vasenkari, Petri, Nokia; Rap eMail...
- 2494: this is not a basket WI ; 13/9/21: CD:Wed 15/06/22->Wed 22/06/22; ; 22/3/22: Compl:0%->50% ; 20/6/22: FCD:22/09/2022->22/06/2022; Stat Rep: RP-221199->RP-221199 / 1775; Rapporteur: Nokia->Vasenkari, Petri, Nokia; Rap eMail: ->Petri.j.vasenkari@n...
- 2495: basket WI; TR 37.717-11-41 ; 29/9/21: WID:RP-211592->RP-212606; 6/1/22: WID:RP-212606->RP-213142; 5/4/22: WID:RP-213142->RP-220712; 12/7/22: WID:RP-220712->RP-221524
- 2496: basket WI; TR 37.717-11-41 ; 20/6/22: FCD:15/03/2022->22/06/2022; Compl:0%->100%; Stat Rep: ->RP-221523; Rapporteur: Huawei->Zhang, Peng, Huawei; Rap eMail: ->zhangpeng169@huawei.com;
- 2497: basket WI ; 22/3/22: Compl:0%->15%; 22/3/22: CD:15/03/2022->10/06/2022; 20/6/22: Rapporteur: Huawei->Zhang, Peng, Huawei; Rap eMail: ->zhangpeng169@huawei.com;

| ID | WBS | Task | Type | Duration | Start | Finish | Complete | Remaining | Total slack | Constraint | Resources | Work | Actual work | Acronym | PCG approved | WI rapporteur name | Release | TSG approved | TSG stopped | WI rapporteur e-mail | Status Report | Impacted TSs and TRs |
| --- | --- | --- | --- | --- | --- | --- | --- | --- | --- | --- | --- | --- | --- | --- | --- | --- | --- | --- | --- | --- | --- | --- |
| 2498 | 1087 | **Addition of MSD (Maximum Sensitivity Degradation) for inter-band EN-DC combinations (1 band LTE+1 band NR FR1) due to added channel bandwidths** |  | 0d | 2021-03-25 A | 2021-03-25 |  | 0d | 39613.1d |  | R4 |  |  | ENDC_R17_1BLTE_1BNR_MSD | 46 | Huawei, HiSilicon | Rel-17 | 91 |  |  |  |  |
| 2499 | 1087.1 | Core part: ENDC_R17_1BLTE_1BNR_MSD | milestone | 0d | 2021-03-25 A | 2021-03-25 | 99% | 0d | 39613.1d | finish no earlier than 2022-03-25 | R4 |  |  | ENDC_R17_1BLTE_1BNR_MSD-Core | 46 | Huawei, HiSilicon | Rel-17 | 91 |  |  |  |  |
| 2500 | 1087.2 | Stopped - Perf. Part: ENDC_R17_1BLTE_1BNR_MSD | milestone | 0d | 2021-03-25 A | 2021-03-25 | 99% | 0d | 39613.1d | finish no earlier than 2022-03-25 | R4 |  |  | ENDC_R17_1BLTE_1BNR_MSD-Perf | 47 | Huawei, HiSilicon | Rel-17 | 93 | 96 |  |  |  |
| 2501 | 1088 | **Rel-17 Power Class 2 for EN-DC with x LTE bands + y NR band(s) in DL and with 1 LTE band +1 TDD NR band in UL (either x= 2, 3, y=1 or x=1, 2, y=2)** |  | 916d | 2021-03-12 A | 2024-09-09 A | 100% |  |  |  |  | 11592h | 11592h | ENDC_PC2_R17_xLTE_yNR | 46 | Ericsson | Rel-17 | 91 |  |  |  |  |
| 2502 | 1088.1 | Core part: ENDC_PC2_R17_xLTE_yNR |  | 334d | 2021-03-12 A | 2022-06-22 A | 100% |  |  | finish no earlier than 2022-06-22 | R4 | 2672h | 2672h | ENDC_PC2_R17_xLTE_yNR-Core | 46 | Per Lindell, Ericsson | Rel-17 | 91 |  | per.lindell@ericsson.com | RP-221318 |  |
| 2503 | 1088.2 | Perf. Part: ENDC_PC2_R17_xLTE_yNR |  | 334d | 2021-03-12 A | 2022-06-22 A | 100% |  |  | finish no earlier than 2022-06-22 | R4 | 2672h | 2672h | ENDC_PC2_R17_xLTE_yNR-Perf | 46 | Per Lindell, Ericsson | Rel-17 | 91 |  | per.lindell@ericsson.com | RP-221318 |  |
| 2504 | 1088.3 | UE Conformance - Power Class 2 for EN-DC with x LTE bands + y NR band(s) in DL and with 1 LTE band +1 TDD NR band in UL (either x= 2, 3, y=1 or x=1, 2, y=2) |  | 781d | 2021-09-17 A | 2024-09-09 A | 100% |  |  | finish no earlier than 2024-09-24 | R5 | 6248h | 6248h | ENDC_PC2_R17_xLTE_yNR-UEConTest | 47 | Kuba KOLODZIEJ, Ericsson | Rel-17 | 93 |  | Kuba[dot]kolodziej[at]ericsson[dot]com | RP-242229 |  |
| 2505 | 1089 | **Simultaneous Rx/Tx band combinations for NR CA/DC, NR SUL and LTE/NR DC** |  | 484.62d | 2021-03-12 A | 2022-06-22 A | 100% |  |  |  |  | 5344h | 5344h | LTE_NR_Simult_RxTx | 46 | Huawei | Rel-17 | 91 |  |  |  |  |
| 2506 | 1089.1 | Core part: LTE_NR_Simult_RxTx |  | 334d | 2021-03-12 A | 2022-06-22 A | 100% |  |  | finish no earlier than 2022-06-22 | R4 | 2672h | 2672h | LTE_NR_Simult_RxTx-Core | 46 | Liu Ye, Huawei | Rel-17 | 91 |  | leo.liuye@huawei.com | RP-221520 | 38.839 |
| 2507 | 1089.2 | Stopped - Perf. part: LTE_NR_Simult_RxTx |  | 334d | 2021-03-12 A | 2022-06-22 A | 100% |  |  | finish no earlier than 2022-06-22 | R4 | 2672h | 2672h | LTE_NR_Simult_RxTx-Perf | 46 | Liu Ye, Huawei | Rel-17 | 91 | 96 | leo.liuye@huawei.com | RP-221520 |  |
| 2508 | 1090 | **Rel-17 Dual Connectivity (DC) of 5 bands LTE inter-band CA (5DL/1UL) and 1 NR band (1DL/1UL)** |  | 560.12d | 2020-09-17 A | 2022-03-11 A | 100% |  |  |  |  | 6192h | 6192h | DC_R17_5BLTE_1BNR_6DL2UL | 45 | Samsung | Rel-17 | 89 |  |  |  |  |
| 2509 | 1090.1 | Core part: DC_R17_5BLTE_1BNR_6DL2UL |  | 387d | 2020-09-17 A | 2022-03-11 A | 100% |  |  | finish no earlier than 2022-03-22 | R4 | 3096h | 3096h | DC_R17_5BLTE_1BNR_6DL2UL-Core | 45 | Samsung | Rel-17 | 89 |  |  | RP-220673 |  |
| 2510 | 1090.2 | Perf. part: DC_R17_5BLTE_1BNR_6DL2UL |  | 387d | 2020-09-17 A | 2022-03-11 A | 100% |  |  | finish no earlier than 2022-03-22 | R4 | 3096h | 3096h | DC_R17_5BLTE_1BNR_6DL2UL-Perf | 45 | Samsung | Rel-17 | 89 |  |  | RP-220673 |  |
| 2511 | 1091 | **Rel-17 Dual Connectivity (DC) of x bands (x=2, 3, 4) LTE inter-band CA (xDL/1UL) and 1 NR FR1 band (1DL/1UL) and 1 NR FR2 band (1DL/1UL)** |  | 560.12d | 2020-09-17 A | 2022-03-11 A | 100% |  |  |  |  | 6192h | 6192h | DC_R17_xBLTE_2BNR_yDL3UL | 45 | Samsung | Rel-17 | 89 |  |  |  |  |
| 2512 | 1091.1 | Core part: DC_R17_xBLTE_2BNR_yDL3UL |  | 387d | 2020-09-17 A | 2022-03-11 A | 100% |  |  | finish no earlier than 2022-03-22 | R4 | 3096h | 3096h | DC_R17_xBLTE_2BNR_yDL3UL-Core | 45 | Samsung | Rel-17 | 89 |  |  | RP-220675 |  |
| 2513 | 1091.2 | Perf. part: DC_R17_xBLTE_2BNR_yDL3UL |  | 387d | 2020-09-17 A | 2022-03-11 A | 100% |  |  | finish no earlier than 2022-03-22 | R4 | 3096h | 3096h | DC_R17_xBLTE_2BNR_yDL3UL-Perf | 45 | Samsung | Rel-17 | 89 |  |  | RP-220675 |  |
| 2514 | 1092 | **Band combinations for concurrent operation of NR/LTE Uu bands/band combinations and one NR/LTE V2X PC5 band** |  | 756.88d | 2020-06-22 A | 2022-06-22 A | 100% |  |  |  |  | 8368h | 8368h | NR_LTE_V2X_PC5_combos | 45 | CATT | Rel-17 | 88 |  |  |  | 37.875 |
| 2515 | 1092.1 | Core part: NR_LTE_V2X_PC5_combos |  | 523d | 2020-06-22 A | 2022-06-22 A | 100% |  |  | finish no earlier than 2022-06-22 | R4 | 4184h | 4184h | NR_LTE_V2X_PC5_combos-Core | 45 | Yuan Gao, CATT | Rel-17 | 88 |  | gaoyuan@catt.cn | RP-221461 | 37.875 |
| 2516 | 1092.2 | Perf. part: NR_LTE_V2X_PC5_combos |  | 523d | 2020-06-22 A | 2022-06-22 A | 100% |  |  | finish no earlier than 2022-06-22 | R4 | 4184h | 4184h | NR_LTE_V2X_PC5_combos-Perf | 45 | Yuan Gao, CATT | Rel-17 | 88 |  | gaoyuan@catt.cn | RP-221461 | 37.875 |
| 2517 | 1093 | **High power UE (power class 2) for EN-DC with 1 LTE band + 1 NR TDD band** |  | 1118.38d | 2020-06-22 A | 2023-06-06 A | 100% |  |  |  |  | 13040h | 13040h | ENDC_UE_PC2_R17_NR_TDD | 45 | China Unicom | Rel-17 | 88 |  |  |  |  |
| 2518 | 1093.1 | Core part: ENDC_UE_PC2_R17_NR_TDD |  | 523d | 2020-06-22 A | 2022-06-22 A | 100% |  |  | finish no earlier than 2022-06-22 | R4 | 4184h | 4184h | ENDC_UE_PC2_R17_NR_TDD-Core | 45 | Basaier Jialade, China Unicom | Rel-17 | 88 |  | basejld@chinaunicom.cn | RP-221228 |  |
| 2519 | 1093.2 | Perf. part: ENDC_UE_PC2_R17_NR_TDD |  | 523d | 2020-06-22 A | 2022-06-22 A | 100% |  |  | finish no earlier than 2022-06-22 | R4 | 4184h | 4184h | ENDC_UE_PC2_R17_NR_TDD-Perf | 45 | Basaier Jialade, China Unicom | Rel-17 | 88 |  | basejld@chinaunicom.cn | RP-221228 |  |
| 2520 | 1093.3 | UE Conformance - ENDC_UE_PC2_R17_NR_TDD |  | 584d | 2021-03-12 A | 2023-06-06 A | 100% |  |  | finish no earlier than 2023-06-06 | R5 | 4672h | 4672h | ENDC_UE_PC2_R17_NR_TDD-UEConTest | 46 | Shi，Yu, China Unicom | Rel-17 | 91 |  | shiyu19@chinaunicom.cn | RP-230698 |  |
| 2521 | 1094 | **LTE/NR spectrum sharing in Band 38/n38** |  | 94.25d | 2020-06-17 A | 2020-09-15 A | 100% |  |  |  |  | 520h | 520h | DSS_LTE_B38_NR_Bn38 | 45 | Vodafone | Rel-17 | 88 |  |  |  |  |
| 2522 | 1094.1 | Core part: DSS_LTE_B38_NR_Bn38 |  | 65d | 2020-06-17 A | 2020-09-15 A | 100% |  |  | finish no earlier than 2020-09-15 | R4 | 520h | 520h | DSS_LTE_B38_NR_Bn38-Core | 45 | Vodafone | Rel-17 | 88 |  |  |  |  |

Notes:
- 2498: basket WI; addition of MSD requirement for cases where new channel bandwidths were added; no Perf. Part; 2/7/21: WID:RP-210891->RP-211384; 29/9/21: WID:RP-211384->RP-212187; 6/1/22: WID:RP-212187->RP-213140; 5/4/22: WID:RP-213140->RP-220709
- 2499: 20/6/22: WG: ->R4; FCD:25/03/2022->22/03/2023; Compl:0%->100%; WID: RP-220709->RP-213140; Stat Rep: ->RP-220858; Rapporteur: Huawei, HiSilicon->Zhang, Peng; Rap eMail: ->zhangpeng169@huawei.com20/6/22: 0%->100
- 2500: 4/6/22: Stopped at 70%. This Perf. part is not needed
- 2501: basket WI; compare REL-16 WI ENDC_UE_PC2_TDD_TDD and REL-16 WI ENDC_UE_PC2_FDD_TDD; TR 37.8xx ; 2/7/21: WID:RP-210816->RP-211172; 29/9/21: WID:RP-211172->RP-211760; 6/1/22: WID:RP-211760->RP-213467; 5/4/22: WID:RP-213467->RP-220828; 12/7/22: WID:RP-220828->RP-221322
- 2502: basket WI; compare REL-16 WI ENDC_UE_PC2_TDD_TDD and REL-16 WI ENDC_UE_PC2_FDD_TDD; TR 37.8xx ; 2/7/21: 37.827 added; ; 20/6/22: Rapporteur: Ericsson->Per Lindell, Ericsson; Rap eMail: ->per.lindell@ericsson.com; List of Impacted TS & TR updated;
- 2503: compare REL-16 WI ENDC_UE_PC2_TDD_TDD and REL-16 WI ENDC_UE_PC2_FDD_TDD ; 20/6/22: Rapporteur: Ericsson->Per Lindell, Ericsson; Rap eMail: ->per.lindell@ericsson.com;
- 2504: tested: REL-17 WI ENDC_PC2_R17_xLTE_yNR ; 22/3/22: Compl:0%->5%; 22/3/22: CD:15/12/2022->12/12/2022; 22/3/22 6/6/22: CD:12/12/2022->22/12/2022 ; ; 20/6/22: Rapporteur: Ericsson->Leif MATTISSON, Ericsson; Rap eMail: ->Leif[dot]mattisson[at]ericsson[d...; 4/9/24: FCD:09/09/2024->24/09/2024; Compl:6%->100%; WID: RP-240074->RP-230082; Stat Rep: RP-240945->RP-242229;
- 2505: ; 2/7/21: WID:RP-210890->RP-211382; 5/4/22: WID:RP-211382->RP-220707; 12/7/22: WID:RP-220707->RP-221521
- 2506: ; 13/9/21: Compl:0%->70% ; 1/10/21: 38.839 added; ; 20/6/22: Rapporteur: Huawei->Liu Ye, Huawei; Rap eMail: ->leo.liuye@huawei.com;
- 2507: ; 13/9/21: Compl:0%->70% ; 6/6/22: Compl:70%->0%6/6/22: CD:22/03/2022->22/06/20226/6/22: WID: RP-220707->RP-2113826/6/22: Stat Rep: RP-212185->RP-221520; 20/6/22: Compl:0%->100%; Rapporteur: Huawei->Liu Ye, Huawei; Rap eMail: ->leo.liuye@huawei.com; Sto
- 2508: basket WI; TR 37.717-51-11 ; 6/1/21: WID:RP-201642->RP-202540; 7/4/21: WID:RP-202540->RP-210801; 2/7/21: WID:RP-210801->RP-211195; 6/1/22: WID:RP-211195->RP-213112; 5/4/22: WID:RP-213112->RP-220672
- 2509: basket WI; TR 37.717-51-11 ; 13/9/21: Compl:0%->70% ; ;
- 2510: basket WI ; 13/9/21: Compl:0%->70%; ;
- 2511: basket WI; TR 37.717-21-22 ; 6/1/21: WID:RP-201643->RP-202542; 5/4/22: WID:RP-202542->RP-220674
- 2512: basket WI; TR 37.717-21-22 ; 13/9/21: Compl:0%->70% ; ;
- 2513: basket WI ; 13/9/21: Compl:0%->70%; ;
- 2514: 25/9/20: WID:RP-200924->RP-201789; 25/9/20: 37.875 added;; 7/4/21: WID:RP-201789->RP-210588; 6/1/22: WID:RP-210588->RP-213297
- 2515: 25/9/20: 37.875 added;; 22/3/22: Compl:0%->95%; 20/6/22: Rapporteur: CATT->Yuan Gao, CATT; Rap eMail: ->gaoyuan@catt.cn;
- 2516: 25/9/20: 37.875 added;; 22/3/22: Compl:0%->9 20/6/22: Rapporteur: CATT->Yuan Gao, CATT; Rap eMail: ->gaoyuan@catt.cn;
- 2517: 25/9/20: WID:RP-201328->RP-202079; 6/1/21: WID:RP-202079->RP-202838; 7/4/21: WID:RP-202838->RP-210327; 2/7/21: WID:RP-210327->RP-211073; 29/9/21: WID:RP-211073->RP-211853; 5/4/22: WID:RP-211853->RP-220388; 12/7/22: WID:RP-220388->RP-221227
- 2518: ; 13/9/21: Compl:0%->40%; 13/9/21: CD:Wed 15/09/21->Tue 22/03/22; 13/9/21: Stat Rep: ->RP-211852; 22/3/2 20/6/22: Rapporteur: China Unicom->Basaier Jialade, China Unicom; Rap eMail: ->basejld@chinaunicom.cn;
- 2519: ; 13/9/21: Compl:0%->40%; 13/9/21: CD:Wed 15/09/21->Tue 22/03/22; 13/9/21: Stat Rep: ->RP-211852; 22/3 20/6/22: Rapporteur: China Unicom->Basaier Jialade, China Unicom; Rap eMail: ->basejld@chinaunicom.cn;
- 2520: tested: REL-17 basket WI ENDC_UE_PC2_R17_NR_TDD-Core ; 2/7/21: WID:RP-210401->RP-211420; 2/7/21: 0%->10 ; ; 6/6/22: Com ; 20/6/22: Rapporteur: China Unicom->Shi，Yu, China Unicom; Rap eMail: ->shiyu19@chinaunicom.cn ; ;...; 9/12/22: FCD:23/03/2023->01...; ; ; ; ; ; ; ; ; ; ; ; ; ; ; ; ; ; ; ; 7/6/23: Compl:55%->100%
- 2522: 25/9/20: 0%->100

| ID | WBS | Task | Duration | Start | Finish | Complete | Constraint | Resources | Work | Actual work | Acronym | PCG approved | WI rapporteur name | Release | TSG approved | WI rapporteur e-mail | Status Report |
| --- | --- | --- | --- | --- | --- | --- | --- | --- | --- | --- | --- | --- | --- | --- | --- | --- | --- |
| 2523 | 1095 | **LTE/NR spectrum sharing in Band 40/n40** | 94.25d | 2020-06-17 A | 2020-09-15 A | 100% |  |  | 1040h | 1040h | DSS_LTE_B40_NR_Bn40 | 45 | Reliance Jio | Rel-17 | 88 |  |  |
| 2524 | 1095.1 | Core part: DSS_LTE_B40_NR_Bn40 | 65d | 2020-06-17 A | 2020-09-15 A | 100% | finish no earlier than 2020-09-15 | R4 | 520h | 520h | DSS_LTE_B40_NR_Bn40-Core | 45 | Reliance Jio | Rel-17 | 88 |  |  |
| 2525 | 1095.2 | Perf. part: DSS_LTE_B40_NR_Bn40 | 65d | 2020-06-17 A | 2020-09-15 A | 100% | finish no earlier than 2020-09-15 | R4 | 520h | 520h | DSS_LTE_B40_NR_Bn40-Perf | 45 | Reliance Jio | Rel-17 | 88 |  |  |
| 2526 | 1096 | **Dual Connectivity (DC) of 1 LTE band (1DL/1UL) and 1 NR band (1DL/1UL)** | 756.88d | 2020-06-22 A | 2022-06-22 A | 100% |  |  | 8368h | 8368h | DC_R17_1BLTE_1BNR_2DL2UL | 45 | CHTTL | Rel-17 | 88 |  |  |
| 2527 | 1096.1 | Core part: DC_R17_1BLTE_1BNR_2DL2UL | 523d | 2020-06-22 A | 2022-06-22 A | 100% | finish no earlier than 2022-06-22 | R4 | 4184h | 4184h | DC_R17_1BLTE_1BNR_2DL2UL-Core | 45 | Bo-Han Hsieh (Tank), CHTTL | Rel-17 | 88 | pohanhsieh@cht.com.tw | RP-221256 |
| 2528 | 1096.2 | Perf. part: DC_R17_1BLTE_1BNR_2DL2UL | 523d | 2020-06-22 A | 2022-06-22 A | 100% | finish no earlier than 2022-06-22 | R4 | 4184h | 4184h | DC_R17_1BLTE_1BNR_2DL2UL-Perf | 45 | Bo-Han Hsieh (Tank), CHTTL | Rel-17 | 88 | pohanhsieh@cht.com.tw | RP-221256 |
| 2529 | 1097 | **Dual Connectivity (DC) of 2 bands LTE inter-band CA (2DL/1UL) and 1 NR band (1DL/1UL)** | 756.88d | 2020-06-22 A | 2022-06-22 A | 100% |  |  | 7872h | 7872h | DC_R17_2BLTE_1BNR_3DL2UL | 45 | Huawei | Rel-17 | 88 |  |  |
| 2530 | 1097.1 | Core part: DC_R17_2BLTE_1BNR_3DL2UL | 523d | 2020-06-22 A | 2022-06-22 A | 100% | finish no earlier than 2022-06-22 | R4 | 4184h | 4184h | DC_R17_2BLTE_1BNR_3DL2UL-Core | 45 | Liehai Liu, Huawei | Rel-17 | 88 | liuliehai@huawei.com | RP-221507 |
| 2531 | 1097.2 | Perf. part: DC_R17_2BLTE_1BNR_3DL2UL | 461d | 2020-09-16 A | 2022-06-22 A | 100% | finish no earlier than 2022-06-22 | R4 | 3688h | 3688h | DC_R17_2BLTE_1BNR_3DL2UL-Perf | 45 | Liehai Liu, Huawei | Rel-17 | 89 | liuliehai@huawei.com | RP-221507 |
| 2532 | 1098 | **Dual Connectivity (DC) of 3 bands LTE inter-band CA (3DL/1UL) and 1 NR band (1DL/1UL)** | 756.88d | 2020-06-22 A | 2022-06-22 A | 100% |  |  | 8368h | 8368h | DC_R17_3BLTE_1BNR_4DL2UL | 45 | Ericsson | Rel-17 | 88 |  |  |
| 2533 | 1098.1 | Core part: DC_R17_3BLTE_1BNR_4DL2UL | 523d | 2020-06-22 A | 2022-06-22 A | 100% | finish no earlier than 2022-06-22 | R4 | 4184h | 4184h | DC_R17_3BLTE_1BNR_4DL2UL-Core | 45 | Per Lindell, Ericsson | Rel-17 | 88 | per.lindell@ericsson.com | RP-221315 |
| 2534 | 1098.2 | Perf. part: DC_R17_3BLTE_1BNR_4DL2UL | 523d | 2020-06-22 A | 2022-06-22 A | 100% | finish no earlier than 2022-06-22 | R4 | 4184h | 4184h | DC_R17_3BLTE_1BNR_4DL2UL-Perf | 45 | Per Lindell, Ericsson | Rel-17 | 88 | per.lindell@ericsson.com | RP-221315 |
| 2535 | 1099 | **Dual Connectivity (DC) of 4 bands LTE inter-band CA (4DL/1UL) and 1 NR band (1DL/1UL)** | 756.88d | 2020-06-22 A | 2022-06-22 A | 100% |  |  | 8368h | 8368h | DC_R17_4BLTE_1BNR_5DL2UL | 45 | Nokia | Rel-17 | 88 |  |  |
| 2536 | 1099.1 | Core part: DC_R17_4BLTE_1BNR_5DL2UL | 523d | 2020-06-22 A | 2022-06-22 A | 100% | finish no earlier than 2022-06-22 | R4 | 4184h | 4184h | DC_R17_4BLTE_1BNR_5DL2UL-Core | 45 | Johannes Hejselbaek, Nokia | Rel-17 | 88 | johannes.hejselbaek@nokia.com | RP-221072 |
| 2537 | 1099.2 | Perf. part: DC_R17_4BLTE_1BNR_5DL2UL | 523d | 2020-06-22 A | 2022-06-22 A | 100% | finish no earlier than 2022-06-22 | R4 | 4184h | 4184h | DC_R17_4BLTE_1BNR_5DL2UL-Perf | 45 | Johannes Hejselbaek, Nokia | Rel-17 | 88 | johannes.hejselbaek@nokia.com | RP-221072 |
| 2538 | 1100 | **Dual Connectivity (DC) of x bands (x=1,2,3,4) LTE inter-band CA (xDL/1UL) and 2 bands NR inter-band CA (2DL/1UL)** | 756.88d | 2020-06-22 A | 2022-06-22 A | 100% |  |  | 8368h | 8368h | DC_R17_xBLTE_2BNR_yDL2UL | 45 | LG Electronics | Rel-17 | 88 |  |  |
| 2539 | 1100.1 | Core part: DC_R17_xBLTE_2BNR_yDL2UL | 523d | 2020-06-22 A | 2022-06-22 A | 100% | finish no earlier than 2022-06-22 | R4 | 4184h | 4184h | DC_R17_xBLTE_2BNR_yDL2UL-Core | 45 | Sang-Wook Lee, LG Electronics | Rel-17 | 88 | sangwook1.lee@lge.com | RP-221183 |
| 2540 | 1100.2 | Perf. part: DC_R17_xBLTE_2BNR_yDL2UL | 523d | 2020-06-22 A | 2022-06-22 A | 100% | finish no earlier than 2022-06-22 | R4 | 4184h | 4184h | DC_R17_xBLTE_2BNR_yDL2UL-Perf | 45 | Sang-Wook Lee, LG Electronics | Rel-17 | 88 | sangwook1.lee@lge.com | RP-221183 |
| 2541 | 1101 | **Dual Connectivity (DC) of x bands (x=1,2) LTE inter-band CA (xDL/xUL) and y bands (y=3-x) NR inter-band CA (yDL/yUL)** | 756.88d | 2020-06-22 A | 2022-06-22 A | 100% |  |  | 8368h | 8368h | DC_R17_xBLTE_yBNR_3DL3UL | 45 | ZTE | Rel-17 | 88 |  |  |
| 2542 | 1101.1 | Core part: DC_R17_xBLTE_yBNR_3DL3UL | 523d | 2020-06-22 A | 2022-06-22 A | 100% | finish no earlier than 2022-06-22 | R4 | 4184h | 4184h | DC_R17_xBLTE_yBNR_3DL3UL-Core | 45 | Wubin Zhou, ZTE | Rel-17 | 88 | zhou.wubin@zte.com.cn | RP-221233 |
| 2543 | 1101.2 | Perf. part: DC_R17_xBLTE_yBNR_3DL3UL | 523d | 2020-06-22 A | 2022-06-22 A | 100% | finish no earlier than 2022-06-22 | R4 | 4184h | 4184h | DC_R17_xBLTE_yBNR_3DL3UL-Perf | 45 | Wubin Zhou, ZTE | Rel-17 | 88 | zhou.wubin@zte.com.cn | RP-221233 |
| 2544 | 1102 | **Dual Connectivity (DC) of x bands (x=1,2,3) LTE inter-band CA (xDL/1UL) and 3 bands NR inter-band CA (3DL/1UL)** | 756.88d | 2020-06-22 A | 2022-06-22 A | 100% |  |  | 8368h | 8368h | DC_R17_xBLTE_3BNR_yDL2UL | 45 | ZTE | Rel-17 | 88 |  |  |
| 2545 | 1102.1 | Core part: DC_R17_xBLTE_3BNR_yDL2UL | 523d | 2020-06-22 A | 2022-06-22 A | 100% | finish no earlier than 2022-06-22 | R4 | 4184h | 4184h | DC_R17_xBLTE_3BNR_yDL2UL-Core | 45 | Wubin Zhou, ZTE | Rel-17 | 88 | zhou.wubin@zte.com.cn | RP-221236 |
| 2546 | 1102.2 | Perf. part: DC_R17_xBLTE_3BNR_yDL2UL | 523d | 2020-06-22 A | 2022-06-22 A | 100% | finish no earlier than 2022-06-22 | R4 | 4184h | 4184h | DC_R17_xBLTE_3BNR_yDL2UL-Perf | 45 | Wubin Zhou, ZTE | Rel-17 | 88 | zhou.wubin@zte.com.cn | RP-221236 |

Notes:
- 2523: 25/9/20: WID:RP-201362->RP-202084
- 2524: 6/1/21: 0%->100
- 2525: 25/9/20: 0%->100
- 2526: 25/9/20: WID:RP-201368->RP-201553; 6/1/21: WID:RP-201553->RP-202545; 7/4/21: WID:RP-202545->RP-210204; 2/7/21: WID:RP-210204->RP-211162; 29/9/21: WID:RP-211162->RP-212096; 6/1/22: WID:RP-212096->RP-213060; 5/4/22: WID:RP-213060->RP-220398; 12/7/22: WID:RP-220398->RP-221257
- 2527: ; 13/9/21: Compl:0%->75%; ; 22/3/22: Compl:75%->90%; 20/6/22: Rapporteur: CHTTL->Bo-Han Hsieh (Tank), CHTTL; Rap eMail: ->pohanhsieh@cht.com.tw;
- 2528: ; 13/9/21: CD:Wed 15/09/21->Tue 22/03/22; ; 22/3/22: Compl:0%->90%; ; 20/6/22: Rapporteur: CHTTL->Bo-Han Hsieh (Tank), CHTTL; Rap eMail: ->pohanhsieh@cht.com.tw;
- 2529: 25/9/20: WID:RP-201369->RP-202060; 6/1/21: WID:RP-202060->RP-202613; 7/4/21: WID:RP-202613->RP-210559; 2/7/21: WID:RP-210559->RP-211371; 29/9/21: WID:RP-211371->RP-212174; 6/1/22: WID:RP-212174->RP-213127; 5/4/22: WID:RP-213127->RP-220689; 12/7/22: WID:RP-220689->RP-221508
- 2530: ; 13/9/21: Compl:0%->60%; ; 22/3/22: Compl:60%->85%; 20/6/22: Rapporteur: Huawei->Liehai Liu, Huawei; Rap eMail: ->liuliehai@huawei.com;
- 2531: 20/6/22: FCD:15/09/2021->22/06/2022; Compl:0%->100%; Stat Rep: ->RP-221507; Rapporteur: Huawei->Liehai Liu, Huawei; Rap eMail: ->liuliehai@huawei.com;
- 2532: 25/9/20: WID:RP-201370->RP-201572; 6/1/21: WID:RP-201572->RP-202188; 7/4/21: WID:RP-202188->RP-210211; 2/7/21: WID:RP-210211->RP-211170; 29/9/21: WID:RP-211170->RP-211758; 6/1/22: WID:RP-211758->RP-212901; 5/4/22: WID:RP-212901->RP-220826; 12/7/22: WID:RP-220826->RP-221320
- 2533: 13/9/21: Compl:0%->74%13/9/21: CD:Wed 15/09/21->Tue 22/03/2213/9/21: Stat Rep: ->RP-211753 ; 20/6/22: Rapporteur: Ericsson->Per Lindell, Ericsson; Rap eMail: ->per.lindell@ericsson.com;
- 2534: 13/9/21: Compl:0%->74%13/9/21: CD:Wed 15/09/21->Tue 22/03/2213/9/21: Stat Rep: ->RP-211753 ; 20/6/22: Rapporteur: Ericsson->Per Lindell, Ericsson; Rap eMail: ->per.lindell@ericsson.com;
- 2535: 25/9/20: WID:RP-201371->RP-201483; 6/1/21: WID:RP-201483->RP-202590; 7/4/21: WID:RP-202590->RP-210766; 2/7/21: WID:RP-210766->RP-211319; 29/9/21: WID:RP-211319->RP-212532; 6/1/22: WID:RP-212532->RP-213251; 5/4/22: WID:RP-213251->RP-220999; 12/7/22: WID:RP-220999->RP-221073
- 2536: ; 13/9/21: Compl:0%->60%; 13/9/21: CD:Wed 15/09/21->Tue 22/03/22; 13/9/21: Stat Rep: ->RP-211820; 20/6/22: Stat Rep: RP-221151->RP-221072; Rapporteur: Nokia->Johannes Hejselbaek, Nokia; Rap eMail: ->johannes.hejselbaek@nokia.com;
- 2537: ; 13/9/21: Compl:0%->60%; 13/9/21: CD:Wed 15/09/21->Tue 22/03/22; 13/9/21: Stat Rep: ->RP-211820; 20/6/22: Stat Rep: RP-221151->RP-221072; Rapporteur: Nokia->Johannes Hejselbaek, Nokia; Rap eMail: ->johannes.hejselbaek@nokia.com;
- 2538: 25/9/20: WID:RP-201372->RP-201477; 6/1/21: WID:RP-201477->RP-202292; 7/4/21: WID:RP-202292->RP-210202; 2/7/21: WID:RP-210202->RP-211043; 29/9/21: WID:RP-211043->RP-211750; 6/1/22: WID:RP-211750->RP-212876; 5/4/22: WID:RP-212876->RP-220302; 12/7/22: WID:RP-220302->RP-221182
- 2539: 13/9/21: Compl:0%->80%13/9/21: CD:Wed 15/09/21->Tue 22/03/2213/9/21: Stat Rep: ->RP-211751; 20/6/22: Rapporteur: LG Electronics->Sang-Wook Lee, LG Electronics; Rap eMail: ->sangwook1.lee@lge.com;
- 2540: 13/9/21: Compl:0%->80%13/9/21: CD:Wed 15/09/21->Tue 22/03/2213/9/21: Stat Rep: ->RP-211751; 20/6/22: Rapporteur: LG Electronics->Sang-Wook Lee, LG Electronics; Rap eMail: ->sangwook1.lee@lge.com;
- 2541: 25/9/20: WID:RP-201373->RP-201710; 6/1/21: WID:RP-201710->RP-202192; 7/4/21: WID:RP-202192->RP-210344; 2/7/21: WID:RP-210344->RP-211054; 29/9/21: WID:RP-211054->RP-211803; 6/1/22: WID:RP-211803->RP-212883; 5/4/22: WID:RP-212883->RP-220202; 12/7/22: WID:RP-220202->RP-221232
- 2542: ; 6/6/22: Compl:0%->100% ; 20/6/22: Rapporteur: ZTE->Wubin Zhou, ZTE; Rap eMail: ->zhou.wubin@zte.com.cn;
- 2543: ; 6/6/22: Compl:0%->100% ; 20/6/22: Rapporteur: ZTE->Wubin Zhou, ZTE; Rap eMail: ->zhou.wubin@zte.com.cn;
- 2544: 25/9/20: WID:RP-200715->RP-201712; 6/1/21: WID:RP-201712->RP-202194; 7/4/21: WID:RP-202194->RP-210346; 2/7/21: WID:RP-210346->RP-211056; 29/9/21: WID:RP-211056->RP-211805; 6/1/22: WID:RP-211805->RP-212885; 5/4/22: WID:RP-212885->RP-220205; 12/7/22: WID:RP-220205->RP-221235
- 2545: 6/6/22: Compl:0%->100%; ; 20/6/22: Rapporteur: ZTE->Wubin Zhou, ZTE; Rap eMail: ->zhou.wubin@zte.com.cn;
- 2546: 6/6/22: Compl:0%->100%; ; 20/6/22: Rapporteur: ZTE->Wubin Zhou, ZTE; Rap eMail: ->zhou.wubin@zte.com.cn;

| ID | WBS | Task | Type | Duration | Start | Finish | Complete | Remaining | Actual finish | Total slack | Constraint | Resources | Work | Actual work | Acronym | PCG approved | Release | TSG approved | WI rapporteur e-mail | Status Report | Impacted TSs and TRs |
| --- | --- | --- | --- | --- | --- | --- | --- | --- | --- | --- | --- | --- | --- | --- | --- | --- | --- | --- | --- | --- | --- |
| 2547 | 1103 | **band combinations for SA NR supplementary uplink (SUL), NSA NR SUL, NSA NR SUL with UL sharing from the UE perspective (ULSUP)** |  | 756.88d | 2020-06-22 A | 2022-06-22 A | 100% |  |  |  |  |  | 8368h | 8368h | NR_SUL_combos_R17 | 45 | Rel-17 | 88 |  |  |  |
| 2548 | 1103.1 | Core part: NR_SUL_combos_R17 |  | 523d | 2020-06-22 A | 2022-06-22 A | 100% |  |  |  | finish no earlier than 2022-06-22 | R4 | 4184h | 4184h | NR_SUL_combos_R17-Core | 45 | Rel-17 | 88 | zhangpeng169@huawei.com | RP-221511 |  |
| 2549 | 1103.2 | Perf. part: NR_SUL_combos_R17 |  | 523d | 2020-06-22 A | 2022-06-22 A | 100% |  |  |  | finish no earlier than 2022-06-22 | R4 | 4184h | 4184h | NR_SUL_combos_R17-Perf | 45 | Rel-17 | 88 | zhangpeng169@huawei.com | RP-221511 |  |
| 2550 | 1104 | UE Conformance - Rel-17 NR CA and DC; and NR and LTE DC Configurations |  | 2070.62d | 2020-12-14 A | 2026-06-05 | 11% | 1842.86d |  | 37647d | finish no earlier than 2026-06-05 | R5 | 16565h |  | NR_CADC_NR_LTE_DC_R17-UEConTest | 46 | Rel-17 | 90 | haoyuxin@huawei.com | RP-253424 |  |
| 2551 | 1105 | Rel-17 NR new/modified bands | milestone, manual | 0d | 2016-06-09 A | 2016-06-09 A | 100% |  |  |  |  |  |  |  |  |  | Rel-17 |  |  |  | 26.234; 26.247 |
| 2552 | 1106 | **Introduction of 900MHz NR band for Europe for Rail Mobile Radio (RMR)** |  | 579.88d | 2021-03-12 A | 2022-09-22 A | 100% |  |  |  |  |  | 5872h | 5872h | NR_RAIL_EU_900MHz | 46 | Rel-17 | 91 |  |  |  |
| 2553 | 1106.1 | Core part: NR_RAIL_EU_900MHz |  | 400d | 2021-03-12 A | 2022-09-22 A | 100% |  |  |  | finish no earlier than 2023-03-22 | R4 | 3200h | 3200h | NR_RAIL_EU_900MHz-Core | 46 | Rel-17 | 91 | ingo dot wendler at sbb dot ch | RP-221071/1071/1808/1816 | 38.853 |
| 2554 | 1106.2 | Perf. part: NR_RAIL_EU_900MHz |  | 334d | 2021-03-12 A | 2022-06-22 A | 100% |  |  |  | finish no earlier than 2023-03-22 | R4 | 2672h | 2672h | NR_RAIL_EU_900MHz-Perf | 46 | Rel-17 | 91 | ingo dot wendler at sbb dot ch | RP-221071/1071/1808/1816 |  |
| 2555 | 1107 | **Introduction of 1900MHz NR TDD band for Europe for Rail Mobile Radio (RMR)** |  | 377.88d | 2021-03-12 A | 2022-03-11 A | 100% |  |  |  |  |  | 4176h | 4176h | NR_RAIL_EU_1900MHz_TDD | 46 | Rel-17 | 91 |  |  |  |
| 2556 | 1107.1 | Core part: NR_RAIL_EU_1900MHz_TDD |  | 261d | 2021-03-12 A | 2022-03-11 A | 100% |  |  |  | finish no earlier than 2022-03-12 | R4 | 2088h | 2088h | NR_RAIL_EU_1900MHz_TDD-Core | 46 | Rel-17 | 91 |  | RP-220148 | 38.852 |
| 2557 | 1107.2 | Perf. part: NR_RAIL_EU_1900MHz_TDD |  | 261d | 2021-03-12 A | 2022-03-11 A | 100% |  |  |  | finish no earlier than 2022-03-12 | R4 | 2088h | 2088h | NR_RAIL_EU_1900MHz_TDD-Perf | 46 | Rel-17 | 91 |  | RP-220148 |  |
| 2558 | 1108 | **Extending current NR operation to 71GHz** |  | 1215.62d | 2019-12-16 A | 2023-03-03 A | 100% |  |  |  |  | R1 | 19248h | 19248h | NR_ext_to_71GHz | 44 | Rel-17 | 86 |  |  |  |
| 2559 | 1108.1 | Core part: Extending current NR operation to 71GHz |  | 724d | 2019-12-16 A | 2022-09-22 A | 100% |  |  |  | finish no earlier than 2022-09-22 | R1 | 5792h | 5792h | NR_ext_to_71GHz-Core | 44 | Rel-17 | 86 | jingsun@qti.qualcomm.com; aida.l.vera.lopez@intel.com | RP-222655 |  |
| 2560 | 1108.2 | Perf. part: Extending current NR operation to 71GHz |  | 841d | 2019-12-16 A | 2023-03-03 A | 100% |  |  |  | finish no earlier than 2023-03-03 | R1 | 6728h | 6728h | NR_ext_to_71GHz-Perf | 44 | Rel-17 | 86 | jingsun@qti.qualcomm.com; aida.l.vera.lopez@intel.com | RP-230662 |  |
| 2561 | 1109 | Study on supporting NR from 52.6 GHz to 71 GHz |  | 131d | 2019-12-16 A | 2020-06-15 A | 100% |  |  |  | finish no earlier than 2020-06-15 | R1 | 1048h | 1048h | FS_NR_52_to_71GHz | 44 | Rel-17 | 86 |  |  |  |
| 2562 | 1110 | Study on IMT parameters for 6.425-7.025GHz, 7.025-7.125GHz and 10.0-10.5GHz |  | 190d | 2020-03-25 A | 2020-12-15 A | 100% |  |  |  | finish no earlier than 2020-12-15 | R4 | 1520h | 1520h | FS_NR_IMT_param | 44 | Rel-17 | 87 |  |  |  |
| 2563 | 1111 | **Introduction of NR band n13** |  | 181.25d | 2020-03-25 A | 2020-09-15 A | 100% |  |  |  |  | R4 | 3000h | 3000h | NR_n13 | 44 | Rel-17 | 87 |  |  |  |
| 2564 | 1111.1 | Core part: Introduction of NR band n13 |  | 125d | 2020-03-25 A | 2020-09-15 A | 100% |  |  |  | finish no earlier than 2020-09-15 | R4 | 1000h | 1000h | NR_n13-Core | 44 | Rel-17 | 87 |  |  |  |
| 2565 | 1111.2 | Perf. part: Introduction of NR band n13 |  | 125d | 2020-03-25 A | 2020-09-15 A | 100% |  |  |  | finish no earlier than 2020-09-15 | R4 | 1000h | 1000h | NR_n13-Perf | 44 | Rel-17 | 87 |  |  |  |
| 2566 | 1112 | **Introduction of NR 47GHz band** |  | 0d | 2019-03-07 A | 2019-03-07 | 100% |  | 2021-03-19 |  |  | R4 | 4192h | 4192h | NR_47GHz_band | 45 | Rel-17 | 88 |  | RP-211772 |  |
| 2567 | 1112.1 | Core part: Introduction of NR 47GHz band |  | 262d | 2020-03-19 A | 2021-03-19 A | 100% |  |  |  | finish no earlier than 2021-03-19 | R4 | 2096h | 2096h | NR_47GHz_band-Core | 45 | Rel-17 | 88 |  |  |  |
| 2568 | 1112.2 | Perf. part: Introduction of NR 47GHz band |  | 262d | 2020-03-19 A | 2021-03-19 A | 100% |  |  |  | finish no earlier than 2021-03-19 | R4 | 2096h | 2096h | NR_47GHz_band-Perf | 45 | Rel-17 | 88 |  |  |  |
| 2569 | 1113 | **Introduction of NR band 24** |  | 379d | 2020-03-19 A | 2021-03-19 A | 100% |  |  |  |  | R4 | 6288h | 6288h | NR_band_n24 | 45 | Rel-17 | 88 |  |  |  |
| 2570 | 1113.1 | Core part: Introduction of NR band 24 |  | 262d | 2020-03-19 A | 2021-03-19 A | 100% |  |  |  | finish no earlier than 2021-03-19 | R4 | 2096h | 2096h | NR_band_n24-Core | 45 | Rel-17 | 88 |  |  |  |
| 2571 | 1113.2 | Perf. part: Introduction of NR band 24 |  | 262d | 2020-03-19 A | 2021-03-19 A | 100% |  |  |  | finish no earlier than 2021-03-19 | R4 | 2096h | 2096h | NR_band_n24-Perf | 45 | Rel-17 | 88 |  |  |  |

Notes:
- 2547: 25/9/20: WID:RP-201026->RP-201726; 6/1/21: WID:RP-201726->RP-202611; 7/4/21: WID:RP-202611->RP-210563; 2/7/21: WID:RP-210563->RP-211375; 29/9/21: WID:RP-211375->RP-212178; 6/1/22: WID:RP-212178->RP-213131; 5/4/22: WID:RP-213131->RP-220695; 12/7/22: WID:RP-220695->RP-221512 / WI rapporteur name: Huawei
- 2548: ; 13/9/21: Compl:0%->60%; ; 22/3/22: Compl:60%->80%; 20/6/22: Rapporteur: Huawei->Zhang, Peng, Huawei; Rap eMail: ->zhangpeng169@huawei.com; / WI rapporteur name: Zhang, Peng, Huawei
- 2549: ; 13/9/21: Compl:0%->60%; ; 22/3/22: Compl:60%->80%; 20/6/22: Rapporteur: Huawei->Zhang, Peng, Huawei; Rap eMail: ->zhangpeng169@huawei.com; / WI rapporteur name: Zhang, Peng, Huawei
- 2550: tested: REL-17 basket WIs: NR_CA_R17_Intra, NR_CADC_R17_2BDL_xBUL, NR_CA_R17_3BDL_1BUL, NR_CADC_R17_3BDL_2BUL, NR_CA_R17_4BDL_1BUL, NR_CADC_R17_4BDL_2BUL, NR_CADC_R17_5BDL_xBUL, NR_SUL_combos_R17, DC_R17_1BLTE_1BNR_2DL2UL, DC_R17_2BLTE_1BNR_3DL2UL, DC_...; 3/12/25: FCD:Fri 12/12/25->Fri 05/06/26; Stat Rep: RP-252642->RP-253424; / WI rapporteur name: Yuxin Hao, Huawei Technologies. Co., Ltd.
- 2552: FDD: UL: 874.4-880MHz, DL: 919.4-925MHz ; 2/7/21: WID:RP-210878->RP-211495; 12/7/22: WID:RP-211495->RP-221768 / WI rapporteur name: Union Internationale Chemins de Fer (UIC)
- 2553: FDD: UL: 874.4-880MHz, DL: 919.4-925MHz ; 1/10/21: 38.853 added;; 22/3/22: Compl:0 20/6/22: FCD:22/03/2023->22/09/2022; Compl:100%->95%; Stat Rep: RP-221071->RP-221071/1071/1808/1816; Rapporteur: Union Internationale Chemins de Fer (UIC)->Ingo Wen... / WI rapporteur name: Ingo Wendler, UIC
- 2554: ; 22/3/22: Compl:0%->90% ; 20/6/22: FCD:22/03/2023->22/06/2022; Stat Rep: RP-221071->RP-221071/1071/1808/1816; Rapporteur: Union Internationale Chemins de Fer (UIC)->Ingo Wendler, UIC; Rap eMail: ->ingo dot wendler at sbb dot ch; / WI rapporteur name: Ingo Wendler, UIC
- 2555: TDD: UL: 1900-1910MHz, DL: 1900 MHz 1910 MHz ; 2/7/21: WID:RP-210879->RP-211542 / WI rapporteur name: Union Internationale Chemins de Fer (UIC)
- 2556: TDD: UL: 1900-1910MHz, DL: 1900 MHz 1910 MHz ; 1/10/21: 38.852 added ; / WI rapporteur name: Union Internationale Chemins de Fer (UIC)
- 2557: ; / WI rapporteur name: Union Internationale Chemins de Fer (UIC)
- 2558: affects: NR.; 25/9/20: WID:RP-193229->RP-201845; 6/1/21: WID:RP-201845->RP-202925; 7/4/21: WID:RP-202925->RP-210862; 2/7/21: WID:RP-210862->RP-211584; 29/9/21: WID:RP-211584->RP-212637; 6/1/22: WID:RP-212637->RP-213540; 23/9/22: WID:RP-213540->RP-222656 / WI rapporteur name: Qualcomm
- 2559: affects: NR.; 13/9/21: Compl:0%->45%; ; 22/3/22: Compl:45%->90%; 20/6/22: Stat Rep: RP-221349->RP-221349 / 1749; Rapporteur: Qualcomm->Jing Sun (RAN1); Aida Vera Lopez (RAN4), Qualcomm; Intel Corporation; Rap eMail: ->jingsun@qti.qualcomm.com; ...; 23/9/22: 100%->100 / WI rapporteur name: Jing Sun (RAN1); Aida Vera Lopez (RAN4), Qualcomm; Intel Corporation
- 2560: affects: NR.; 13/9/21: CD:Wed 15/09/21->Wed 22/06/22; ; 22/3/22: Compl:0%->25%; 22/3/22: 6/6/22: CD:12/09/2022->22/12/2022 ; 20/6/22: WG: R4->R1; Stat Rep: RP-221349->RP-221349 / 1749; Rapporteur: Qualcomm->Jing Sun (RAN1); Aida Vera Lopez (RAN4), ...; 17/3/23: FCD:28/02/2023->03/03/2023; Compl:85%->100%; Stat Rep: RP-223126->RP-230662; Rapporteur: Jing Sun (RAN1); Aida Vera Lopez (RAN4), Qualcomm; Intel Corporation->Jing Sun (RAN1); Aida Vera Lopez (RAN4), Qualcomm Incorporated; Intel Corporation; / WI rapporteur name: Jing Sun (RAN1); Aida Vera Lopez (RAN4), Qualcomm Incorporated; Intel Corporation
- 2561: affects: NR. TR 38.8xx; 28/7/20: WID:RP-193259->RP-200902; 25/9/20: WID:RP-200902->RP-201838; 7/4/21: 0%->100 / WI rapporteur name: Intel
- 2562: affects: NR. TR 38.8xx; 6/1/21: WID:RP-200513->RP-202276; 7/4/21: 0%->100 / WI rapporteur name: Ericsson
- 2563: affects: NR. TR 38.8xx / WI rapporteur name: Huawei
- 2564: affects: NR. TR 38.8xx; 6/1/21: 0%->100 / WI rapporteur name: Huawei
- 2565: affects: NR. TR 38.8xx; 6/1/21: 0%->100 / WI rapporteur name: Huawei
- 2566: 7/4/21: WID:RP-201232->RP-210827; 2/7/21: WID:RP-210827->RP-211568; 13/9/21: C / WI rapporteur name: Ericsson
- 2567: 2/7/21: 0%->100; 29/9/21: WID:RP-211568->RP-212528 / WI rapporteur name: Ericsson
- 2568: 29/9/21: 100%->100 / WI rapporteur name: Ericsson
- 2569: 2/7/21: WID:RP-201357->RP-211505 / WI rapporteur name: Ligado Networks
- 2570: 2/7/21: 0%->100 / WI rapporteur name: Ligado Networks
- 2571: 7/4/21: 0%->100 / WI rapporteur name: Ligado Networks

| ID | WBS | Task | Type | Duration | Start | Finish | Complete | Remaining | Total slack | Constraint | Resources | Work | Actual work | Acronym | PCG approved | Release | TSG approved | Status Report | Impacted TSs and TRs |
| --- | --- | --- | --- | --- | --- | --- | --- | --- | --- | --- | --- | --- | --- | --- | --- | --- | --- | --- | --- |
| 2572 | 1114 | **Introduction of 6GHz NR licensed bands** |  | 762.12d | 2020-09-17 A | 2022-09-22 A | 100% |  |  |  | R4 | 12096h | 12096h | NR_6GHz | 45 | Rel-17 | 89 |  |  |
| 2573 | 1114.1 | Core part: Introduction of 6GHz NR licensed bands |  | 460d | 2020-09-17 A | 2022-06-22 A | 100% |  |  | finish no earlier than 2022-06-22 | R4 | 3680h | 3680h | NR_6GHz-Core | 45 | Rel-17 | 89 | RP-221503 |  |
| 2574 | 1114.2 | Perf. part: Introduction of 6GHz NR licensed bands |  | 526d | 2020-09-17 A | 2022-09-22 A | 100% |  |  | finish no earlier than 2022-09-22 | R4 | 4208h | 4208h | NR_6GHz-Perf | 45 | Rel-17 | 89 | RP-221503 |  |
| 2575 | 1115 | **Introduction of operation in full unlicensed band 5925-7125MHz for NR** |  | 378.88d | 2021-06-15 A | 2022-06-15 | 43% | 214.4d | 39149.2d |  | R4 | 5800h | 2517.93h | NR_6GHz_unlic_full | 47 | Rel-17 | 92 |  |  |
| 2576 | 1115.1 | Core part: Introduction of operation in full unlicensed band 5925-7125MHz for NR |  | 201d | 2021-06-15 A | 2022-03-22 A | 100% |  |  | finish no earlier than 2022-03-22 | R4 | 1608h | 1608h | NR_6GHz_unlic_full-Core | 47 | Rel-17 | 92 | RP-220450 |  |
| 2577 | 1115.2 | Perf. part: Introduction of operation in full unlicensed band 5925-7125MHz for NR |  | 262d | 2021-10-05 | 2022-06-15 |  |  | 39149.2d | finish no earlier than 2022-06-15 | R4 | 2096h |  | NR_6GHz_unlic_full-Perf | 47 | Rel-17 | 92 |  |  |
| 2578 | 1116 | **Introduction of lower 6GHz NR unlicensed operation for Europe** |  | 560.12d | 2020-09-17 A | 2022-03-11 A | 100% |  |  |  | R4 | 9288h | 9288h | NR_6GHz_unlic_EU | 45 | Rel-17 | 89 |  |  |
| 2579 | 1116.1 | Core part: Introduction of lower 6GHz NR unlicensed operation for Europe |  | 387d | 2020-09-17 A | 2022-03-11 A | 100% |  |  | finish no earlier than 2022-03-12 | R4 | 3096h | 3096h | NR_6GHz_unlic_EU-Core | 45 | Rel-17 | 89 | RP-220325 | 38.849 |
| 2580 | 1116.2 | Perf. part: Introduction of lower 6GHz NR unlicensed operation for Europe |  | 387d | 2020-09-17 A | 2022-03-11 A | 100% |  |  | finish no earlier than 2022-03-12 | R4 | 3096h | 3096h | NR_6GHz_unlic_EU-Perf | 45 | Rel-17 | 89 | RP-220325 |  |
| 2581 | 1117 | **Introduction of NR band n67** |  | 186.25d | 2020-12-14 A | 2021-06-11 A | 100% |  |  |  | R4 | 3120h | 3120h | NR_n67 | 46 | Rel-17 | 90 |  |  |
| 2582 | 1117.1 | Core part: Introduction of NR band n67 |  | 130d | 2020-12-14 A | 2021-06-11 A | 100% |  |  | finish no earlier than 2021-06-12 | R4 | 1040h | 1040h | NR_n67-Core | 46 | Rel-17 | 90 |  |  |
| 2583 | 1117.2 | Perf. Part: Introduction of NR band n67 |  | 130d | 2020-12-14 A | 2021-06-11 A | 100% |  |  | finish no earlier than 2021-06-12 | R4 | 1040h | 1040h | NR_n67-Perf | 46 | Rel-17 | 90 |  |  |
| 2584 | 1118 | **Introduction of NR band n85** |  | 186.25d | 2020-12-14 A | 2021-06-11 A | 100% |  |  |  | R4 | 3120h | 3120h | NR_n85 | 46 | Rel-17 | 90 |  |  |
| 2585 | 1118.1 | Core part: Introduction of NR band n85 |  | 130d | 2020-12-14 A | 2021-06-11 A | 100% |  |  | finish no earlier than 2021-06-12 | R4 | 1040h | 1040h | NR_n85-Core | 46 | Rel-17 | 90 |  |  |
| 2586 | 1118.2 | Perf. part: Introduction of NR band n85 |  | 130d | 2020-12-14 A | 2021-06-11 A | 100% |  |  | finish no earlier than 2021-06-12 | R4 | 1040h | 1040h | NR_n85-Perf | 46 | Rel-17 | 90 |  |  |
| 2587 | 1119 | **Introduction of 1.6 GHz NR supplemental uplink (SUL) band with same uplink frequency range of Band 24** |  | 379d | 2020-03-19 A | 2021-03-19 A | 100% |  |  |  |  | 4192h | 4192h | NR_SUL_UL_n24 | 45 | Rel-17 | 88 |  |  |
| 2588 | 1119.1 | Core part: NR_SUL_UL_n24 |  | 262d | 2020-03-19 A | 2021-03-19 A | 100% |  |  | finish no earlier than 2021-03-19 | R4 | 2096h | 2096h | NR_SUL_UL_n24-Core | 45 | Rel-17 | 88 |  |  |
| 2589 | 1119.2 | Perf. part: NR_SUL_UL_n24 |  | 262d | 2020-03-19 A | 2021-03-19 A | 100% |  |  | finish no earlier than 2021-03-19 | R4 | 2096h | 2096h | NR_SUL_UL_n24-Perf | 45 | Rel-17 | 88 |  |  |
| 2590 | 1120 | **Introduction of NR supplemental uplink (SUL) band 1880-1920MHz** |  | 183.25d | 2020-06-22 A | 2020-12-15 A | 100% |  |  |  |  | 2032h | 2032h | NR_SUL_band_1880_1920MHz | 45 | Rel-17 | 88 |  |  |
| 2591 | 1120.1 | Core part: NR_SUL_band_1880_1920MHz |  | 127d | 2020-06-22 A | 2020-12-15 A | 100% |  |  | start no earlier than 2020-06-22 | R4 | 1016h | 1016h | NR_SUL_band_1880_1920MHz-Core | 45 | Rel-17 | 88 |  |  |
| 2592 | 1120.2 | Perf. part: NR_SUL_band_1880_1920MHz |  | 127d | 2020-06-22 A | 2020-12-15 A | 100% |  |  | start no earlier than 2020-06-22 | R4 | 1016h | 1016h | NR_SUL_band_1880_1920MHz-Perf | 45 | Rel-17 | 88 |  |  |
| 2593 | 1121 | **Introduction of NR supplemental uplink (SUL) band 2300-2400MHz** |  | 183.25d | 2020-06-22 A | 2020-12-15 A | 100% |  |  |  |  | 2032h | 2032h | NR_SUL_band_2300_2400MHz | 45 | Rel-17 | 88 |  |  |
| 2594 | 1121.1 | Core part: NR_SUL_band_2300_2400MHz |  | 127d | 2020-06-22 A | 2020-12-15 A | 100% |  |  | start no earlier than 2020-06-22 | R4 | 1016h | 1016h | NR_SUL_band_2300_2400MHz-Core | 45 | Rel-17 | 88 |  |  |
| 2595 | 1121.2 | Perf. part: NR_SUL_band_2300_2400MHz |  | 127d | 2020-06-22 A | 2020-12-15 A | 100% |  |  | start no earlier than 2020-06-22 | R4 | 1016h | 1016h | NR_SUL_band_2300_2400MHz-Perf | 45 | Rel-17 | 88 |  |  |
| 2596 | 1122 | UE Conformance - New Rel-17 NR licensed bands and extension of existing NR bands |  | 514d | 2020-12-14 A | 2022-12-01 A | 100% |  |  | finish no earlier than 2022-12-01 | R5 | 4112h | 4112h | NR_lic_bands_BW_R17-UEConTest | 46 | Rel-17 | 90 | RP-223215 |  |
| 2597 | 1123 | Rel-17 LTE new/modified bands | milestone, manual | 0d | 2016-06-09 A | 2016-06-09 A | 100% |  |  |  |  |  |  |  |  | Rel-17 |  |  | 26.234; 26.247 |

Notes:
- 2572: missing target dates to be updated ; 6/1/21: WID:RP-202114->RP-202844; 6/1/22: WID:RP-202844->RP-213696; 5/4/22: WID:RP-213696->RP-220686; 12/7/22: WID:RP-220686->RP-221504 / WI rapporteur name: Huawei
- 2573: missing target dates to be updated ; 13/9/21: CD:Tue 15/03/22->Tue 22/03/22 ; 22/3/22: Compl:0%->35% ; 20/6/22: Rapporteur: Huawei->Liehai Liu, Dominique Everaere, Iwajlo Angelow, Fei Xue, Huawei, Ericsson, Nokia, ZTE Corporation; Rap eMail: ->l... / WI rapporteur name: Liehai Liu, Dominique Everaere, Iwajlo Angelow, Fei Xue, Huawei, Ericsson, Nokia, ZTE Corporation / WI rapporteur e-mail: liuliehai@huawei.com, dominique.everaere@ericsson.com, iwajlo.angelow@nokia.com, xue.fei25@zte.com.cn
- 2574: missing target dates to be updated ; 13/9/21: CD:Fri 17/06/22->Wed 22/06/22 ; 22/3/22: Compl:0%->20%; 2 20/6/22: Rapporteur: Huawei->Liehai Liu, Dominique Everaere, Iwajlo Angelow, Fei Xue, Huawei, Ericsson, Nokia, ZTE Corporation; Rap eMail: ->... / WI rapporteur name: Liehai Liu, Dominique Everaere, Iwajlo Angelow, Fei Xue, Huawei, Ericsson, Nokia, ZTE Corporation / WI rapporteur e-mail: liuliehai@huawei.com, dominique.everaere@ericsson.com, iwajlo.angelow@nokia.com, xue.fei25@zte.com.cn
- 2575: in contrast to NR_6GHz_unlic_EU this WI targets Region 2 (Canada, Brazil, Peru, Chile) and Region 3 (South Korea); TR 38.8xx ; 29/9/21: WID:RP-211602->RP-212302; 6/1/22: WID:RP-212302->RP-213683 / WI rapporteur name: Apple
- 2576: in contrast to NR_6GHz_unlic_EU this WI targets Region 2 (Canada, Brazil, Peru, Chile) and Region 3 (South Korea); TR 38.8xx ; 20/6/22: FCD:15/03/2022->22/03/2022; Compl:0%->100%; WID: RP-213683->RP-212683; Stat Rep: ->RP-220450; Rapporteur: Apple->Alexander Sayenko; Rap eMail: ->asayenko@apple.com; / WI rapporteur name: Alexander Sayenko / WI rapporteur e-mail: asayenko@apple.com
- 2577: WI rapporteur name: Apple
- 2578: missing target dates to be updated ; 6/1/21: WID:RP-202116->RP-202592; 7/4/21: WID:RP-202592->RP-210762; 29/9/21: WID:RP-210762->RP-212625; 6/1/22: WID:RP-212625->RP-213604 / WI rapporteur name: Nokia
- 2579: missing target dates to be updated ; 10/2/21: 38.849 added;; 13/9/21: Compl:0%->30%; 13/9/21: CD:Tue 15/03/22->Tue 21/12/21; 13/9/21: Stat Rep: ->RP-211822; / WI rapporteur name: Nokia
- 2580: missing target dates to be updated ; 13/9/21: Compl:0%->15%; 13/9/21: CD:Fri 17/06/22->Tue 21/12/21; 13/9/21: Stat Rep: ->RP-211822; / WI rapporteur name: Nokia
- 2581: WI rapporteur name: Ericsson
- 2582: ; 2/7/21: 0%->100 / WI rapporteur name: Ericsson
- 2583: ; 2/7/21: 0%->100 / WI rapporteur name: Ericsson
- 2584: ; 7/4/21: WID:RP-202830->RP-210707 / WI rapporteur name: Ericsson
- 2585: ; 2/7/21: 0%->100 / WI rapporteur name: Ericsson
- 2586: ; 2/7/21: 0%->100 / WI rapporteur name: Ericsson
- 2587: 7/4/21: WID:RP-201251->RP-210341 / WI rapporteur name: Ligado Networks
- 2588: 7/4/21: 0%->100 / WI rapporteur name: Ligado Networks
- 2589: 7/4/21: 0%->100 / WI rapporteur name: Ligado Networks
- 2590: WI rapporteur name: CMCC
- 2591: 6/1/21: 0%->100 / WI rapporteur name: CMCC
- 2592: 6/1/21: 0%->100 / WI rapporteur name: CMCC
- 2593: WI rapporteur name: CMCC
- 2594: 6/1/21: 0%->100 / WI rapporteur name: CMCC
- 2595: 6/1/21: 0%->100 / WI rapporteur name: CMCC
- 2596: tested: REL-17 WIs: NR_n13, NR_47GHz_band, NR_band_n24, NR_SUL_UL_n24, NR_SUL_band_1880_1920MHz, NR_SUL_band_2300_2400MHz, NR_bands_R17_BWs, NR_FR1_35MHz_45MHz_BW ; 8/4/21: 0%->16 ; 20/6/22: Rapporteur: Huawei->Yuxin Hao, Huawei Technologies. Co.,...;...; 9/1/23: 100%->100 / WI rapporteur name: Yuxin Hao, Huawei Technologies. Co., Ltd / WI rapporteur e-mail: haoyuxin@huawei.com

| ID | WBS | Task | Type | Duration | Start | Finish | Complete | Constraint | Resources | Work | Actual work | Acronym | PCG approved | WI rapporteur name | Release | TSG approved | Status Report | WI rapporteur e-mail | Impacted TSs and TRs | TSG stopped |
| --- | --- | --- | --- | --- | --- | --- | --- | --- | --- | --- | --- | --- | --- | --- | --- | --- | --- | --- | --- | --- |
| 2598 | 1124 | **New bands and bandwidth allocation for 5G terrestrial broadcast - part 1** |  | 461.88d | 2021-01-01 A | 2022-03-22 A | 100% |  | R1; R2; R3 | 15264h | 15264h | LTE_terr_bcast_bands_part1 | 46 | EBU | Rel-17 | 91 |  |  |  |  |
| 2599 | 1124.1 | Core part: New bands and bandwidth allocation for 5G terrestrial broadcast - part 1 |  | 318d | 2021-01-01 A | 2022-03-22 A | 100% | finish no earlier than 2022-03-22 | R1; R2; R3 | 7632h | 7632h | LTE_terr_bcast_bands_part1-Core | 46 | EBU | Rel-17 | 91 | RP-220172 |  |  |  |
| 2600 | 1125 | **Additional LTE bands for UE categories M1/M2/NB1/NB2** |  | 771.38d | 2020-06-08 A | 2022-06-22 A | 100% |  |  | 8528h | 8528h | LTE_bands_R17_M1_M2_NB1_NB2 | 45 | Ericsson | Rel-17 | 88 |  |  |  |  |
| 2601 | 1125.1 | Core part: LTE_bands_R17_M1_M2_NB1_NB2 |  | 533d | 2020-06-08 A | 2022-06-22 A | 100% | finish no earlier than 2022-06-22 | R4 | 4264h | 4264h | LTE_bands_R17_M1_M2_NB1_NB2-Core | 45 | Chunhui Zhang, Ericsson | Rel-17 | 88 | RP-221173 | Chunhui.Zhang@ericsson.com |  |  |
| 2602 | 1125.2 | Perf. part: LTE_bands_R17_M1_M2_NB1_NB2 |  | 533d | 2020-06-08 A | 2022-06-22 A | 100% | finish no earlier than 2022-06-22 | R4 | 4264h | 4264h | LTE_bands_R17_M1_M2_NB1_NB2-Perf | 45 | Chunhui Zhang, Ericsson | Rel-17 | 88 | RP-221173 | Chunhui.Zhang@ericsson.com |  |  |
| 2603 | 1126 | **Modification of LTE Band 24 Specifications to comply with updated regulatory emission limits** |  | 568.38d | 2020-06-15 A | 2021-12-15 A | 100% |  |  | 4256h | 4256h | LTE_B24_mod | 45 | Ligado Networks | Rel-17 | 88 |  |  |  |  |
| 2604 | 1126.1 | Core part: LTE_B24_mod |  | 200d | 2020-06-15 A | 2021-03-19 A | 100% | start no earlier than 2020-06-15 | R4 | 1600h | 1600h | LTE_B24_mod-Core | 45 | Ligado Networks | Rel-17 | 88 |  |  |  |  |
| 2605 | 1126.2 | Perf. part: LTE_B24_mod |  | 200d | 2020-06-15 A | 2021-03-19 A | 100% | finish no earlier than 2021-03-19 | R4 | 1600h | 1600h | LTE_B24_mod-Perf | 45 | Ligado Networks | Rel-17 | 88 |  |  |  |  |
| 2606 | 1126.3 | UE Conformance - Modification of LTE Band 24 Specifications to comply with updated regulatory emission limits |  | 132d | 2021-06-15 A | 2021-12-15 A | 100% | finish no earlier than 2021-12-15 | R5 | 1056h | 1056h | LTE_B24_mod-UEConTest | 47 | Ligado Networks | Rel-17 | 92 |  |  |  |  |
| 2607 | 1127 | Rel-17 LTE inter-band Carrier Aggregation (LTE iterbCA) | milestone, manual | 0d | 2016-06-09 A | 2016-06-09 A | 100% |  |  |  |  |  |  |  | Rel-17 |  |  |  | 26.234; 26.247 |  |
| 2608 | 1128 | **LTE iterbCA for 2 bands DL with 1 band UL** |  | 756.88d | 2020-06-22 A | 2022-06-22 A | 100% |  |  | 8368h | 8368h | LTE_CA_R17_2BDL_1BUL | 45 | Qualcomm | Rel-17 | 88 |  |  |  |  |
| 2609 | 1128.1 | Core part: LTE_CA_R17_2BDL_1BUL |  | 523d | 2020-06-22 A | 2022-06-22 A | 100% | finish no earlier than 2022-06-22 | R4 | 4184h | 4184h | LTE_CA_R17_2BDL_1BUL-Core | 45 | Bin Han, Qualcomm Incorporated | Rel-17 | 88 | RP-221388 | binhan@qti.qualcomm.com |  |  |
| 2610 | 1128.2 | Perf. part: LTE_CA_R17_2BDL_1BUL |  | 523d | 2020-06-22 A | 2022-06-22 A | 100% | finish no earlier than 2022-06-22 | R4 | 4184h | 4184h | LTE_CA_R17_2BDL_1BUL-Perf | 45 | Bin Han, Qualcomm Incorporated | Rel-17 | 88 | RP-221388 | binhan@qti.qualcomm.com |  |  |
| 2611 | 1129 | **LTE iterbCA for 3 bands DL with 1 band UL** |  | 756.88d | 2020-06-22 A | 2022-06-22 A | 100% |  |  | 8368h | 8368h | LTE_CA_R17_3BDL_1BUL | 45 | Huawei | Rel-17 | 88 |  |  |  |  |
| 2612 | 1129.1 | Core part: LTE_CA_R17_3BDL_1BUL |  | 523d | 2020-06-22 A | 2022-06-22 A | 100% | finish no earlier than 2022-06-22 | R4 | 4184h | 4184h | LTE_CA_R17_3BDL_1BUL-Core | 45 | Mohammad Abdi Abyaneh, Huawei, HiSilicon | Rel-17 | 88 | RP-221525 | mohammad.abdi.abyaneh@huawei.com |  |  |
| 2613 | 1129.2 | Stopped - Perf. part: LTE iterbCA for 3 bands DL with 1 band UL |  | 523d | 2020-06-22 A | 2022-06-22 A | 100% | finish no earlier than 2022-06-22 | R4 | 4184h | 4184h | LTE_CA_R17_3BDL_1BUL-Perf | 45 | Mohammad Abdi Abyaneh, Huawei, HiSilicon | Rel-17 | 88 | RP-221525 | mohammad.abdi.abyaneh@huawei.com |  | 96 |
| 2614 | 1130 | **LTE iterbCA Core for x bands DL (x=4, 5, 6) with 1 band UL** |  | 756.88d | 2020-06-22 A | 2022-06-22 A | 100% |  |  | 8368h | 8368h | LTE_CA_R17_xBDL_1BUL | 45 | Nokia | Rel-17 | 88 |  |  |  |  |
| 2615 | 1130.1 | Core part: LTE_CA_R17_xBDL_1BUL |  | 523d | 2020-06-22 A | 2022-06-22 A | 100% | finish no earlier than 2022-06-22 | R4 | 4184h | 4184h | LTE_CA_R17_xBDL_1BUL-Core | 45 | Iwajlo ANGELOW, Nokia | Rel-17 | 88 | RP-221306 | iwajlo.angelow@nokia.com |  |  |
| 2616 | 1130.2 | Perf. part: LTE_CA_R17_xBDL_1BUL |  | 523d | 2020-06-22 A | 2022-06-22 A | 100% | finish no earlier than 2022-06-22 | R4 | 4184h | 4184h | LTE_CA_R17_xBDL_1BUL-Perf | 45 | Iwajlo ANGELOW, Nokia | Rel-17 | 88 | RP-221306 | iwajlo.angelow@nokia.com |  |  |
| 2617 | 1131 | **LTE iterbCA for 2 bands DL with 2 bands UL** |  | 756.88d | 2020-06-22 A | 2022-06-22 A | 100% |  |  | 8368h | 8368h | LTE_CA_R17_2BDL_2BUL | 45 | Huawei | Rel-17 | 88 |  |  |  |  |
| 2618 | 1131.1 | Core part: LTE_CA_R17_2BDL_2BUL |  | 523d | 2020-06-22 A | 2022-06-22 A | 100% | finish no earlier than 2022-06-22 | R4 | 4184h | 4184h | LTE_CA_R17_2BDL_2BUL-Core | 45 | Liu Ye, Huawei | Rel-17 | 88 | RP-221527 | leo.liuye@huawei.com |  |  |
| 2619 | 1131.2 | Perf. part: LTE_CA_R17_2BDL_2BUL |  | 523d | 2020-06-22 A | 2022-06-22 A | 100% | finish no earlier than 2022-06-22 | R4 | 4184h | 4184h | LTE_CA_R17_2BDL_2BUL-Perf | 45 | Liu Ye, Huawei | Rel-17 | 88 | RP-221527 | leo.liuye@huawei.com |  |  |
| 2620 | 1132 | **LTE iterbCA for x bands DL (x= 3, 4, 5) with 2 bands UL** |  | 756.88d | 2020-06-22 A | 2022-06-22 A | 100% |  |  | 8368h | 8368h | LTE_CA_R17_xBDL_2BUL | 45 | LG | Rel-17 | 88 |  |  |  |  |
| 2621 | 1132.1 | Core part: LTE_CA_R17_xBDL_2BUL |  | 523d | 2020-06-22 A | 2022-06-22 A | 100% | finish no earlier than 2022-06-22 | R4 | 4184h | 4184h | LTE_CA_R17_xBDL_2BUL-Core | 45 | Jin Woong Park, LG Electronics | Rel-17 | 88 | RP- 221189 | jinwoong.park@lge.com |  |  |
| 2622 | 1132.2 | Perf. part: LTE_CA_R17_xBDL_2BUL |  | 523d | 2020-06-22 A | 2022-06-22 A | 100% | finish no earlier than 2022-06-22 | R4 | 4184h | 4184h | LTE_CA_R17_xBDL_2BUL-Perf | 45 | Jin Woong Park, LG Electronics | Rel-17 | 88 | RP- 221189 | jinwoong.park@lge.com |  |  |
| 2623 | 1133 | UE Conformance - Rel-17 LTE CA Configurations |  | 332d | 2023-09-09 A | 2024-12-12 A | 100% | finish no earlier than 2024-12-12 | R5 | 2656h | 2656h | LTE_CA_R17-UEConTest | 51 | Lei GAO, China Telecom | Rel-17 | 101 | RP-242868 | gaol8@chinatelecom.cn |  |  |
| 2624 | 1134 | Release 17 other Studies | milestone | 0d? | 2016-03-15 A | 2016-03-15 A | 100% | start no earlier than 2016-03-15 |  |  |  |  |  |  | Rel-17 |  |  |  |  |  |
| 2625 | 1135 | Study on the security of AMF re-allocation |  | 323d | 2020-09-16 A | 2021-12-10 A | 100% | finish no earlier than 2021-12-12 | S3 | 2584h | 2584h | FS_AMFREAL_SEC | 45 | Tsiatsis, Vlasios, Ericsson | Rel-17 | 89 |  | vlasios.tsiatsis@ericsson.com | 33.864 |  |
| 2626 | 1136 | Study on enhanced Security Aspects of the 5G Service Based Architecture |  | 266d | 2020-12-04 A | 2021-12-10 A | 100% | finish no earlier than 2021-12-12 | S3 | 2128h | 2128h | FS_eSBA_SEC | 46 | Anja Jerichow, Nokia | Rel-17 | 90 |  | anja.jerichow@nokia.com | 33.875 |  |
| 2627 | 1137 | Study on SECAM and SCAS for 3GPP virtualized network products |  | 834d? | 2018-10-02 A | 2021-12-10 A | 100% | finish no earlier than 2021-12-12 | S3 | 6672h | 6672h | FS_VNP_SECAM_SCAS | 41 | Minpeng Qi, China Mobile | Rel-17 | 81 |  | qiminpeng@chinamobile.com | New |  |
| 2628 | 1138 | Study on Long Term Key Update Process (LTKUP) Detailed solutions |  | 326d | 2018-12-13 A | 2020-03-12 A | 100% | finish no earlier than 2020-03-12 | S3 | 2608h | 2608h | FS_LTKUP_Detail | 42 | Evans, Tim, Vodafone | Rel-17 | 82 |  | tim.evans1@vodafone.com |  |  |
| 2629 | 1139 | Study on 5G Glass-type AR/MR Devices |  | 447d | 2020-06-25 A | 2022-03-11 A | 100% | finish no earlier than 2022-03-12 | S4 | 3576h | 3576h | FS_5GSTAR | 45 | Hakju Ryan Lee | Rel-17 | 88 |  | hakju00.lee@samsung.com | 26.998 |  |
| 2630 | 1140 | Study on VR Streaming Conformance and Guidelines |  | 651d | 2019-09-13 A | 2022-03-11 A | 100% | finish no earlier than 2022-03-12 | S4 | 5208h | 5208h | FS_VR_CoGui | 43 | Igor CURCIO | Rel-17 | 85 |  | igor.curcio@nokia.com | New ; 26.999; 26.119 |  |
| 2631 | 1141 | Study on 5G media streaming extensions |  | 331d | 2020-12-04 A | 2022-03-11 A | 100% | finish no earlier than 2022-03-12 | S4 | 2648h | 2648h | FS_5GMS_EXT | 46 | Iraj Sodagar, Company, Tencent | Rel-17 | 90 |  | irajs@live.com | 26.804 |  |
| 2632 | 1142 | Study on Streaming Architecture extensions For Edge processing |  | 318d | 2020-03-25 A | 2021-06-11 A | 100% | finish no earlier than 2021-06-12 | S4 | 2544h | 2544h | FS_EMSA | 44 | Bouazizi, Imed, Qualcomm | Rel-17 | 87 |  | bouazizi@qti.qualcomm.com |  |  |
| 2633 | 1143 | Study on 5G Video Codec Characteristics |  | 578d | 2020-03-25 A | 2022-06-10 A | 100% | finish no earlier than 2022-06-12 | S4 | 4624h | 4624h | FS_5GVideo | 44 | Thomas Stockhammer | Rel-17 | 87 |  | tsto@qti.qualcomm.com |  |  |
| 2634 | 1144 | Study on the use of NBMP in FLUS |  | 381d | 2020-03-25 A | 2021-09-08 A | 100% | finish no earlier than 2021-09-08 | S4 | 3048h | 3048h | FS_FLUS_NBMP | 44 | Iraj Sodagar | Rel-17 | 87 |  | irajsodagar@tencent.com | 26.939 |  |

Notes:
- 2598: 13/09/21: "-part 1/" added' R4->R1, R2, R3
- 2599: WID will be split into RAN1/2/3 REL-17 WID (part1; target March 22) and a RAN4 REL18 WID (part2; REL-indep. From REL-17; target March 23) at RAN #92e; no Perf. Part; 13/9/21: C ; ; 14/5/24: 97%->100
- 2600: 25/9/20: WID:RP-200804->RP-201646; 29/9/21: WID:RP-201646->RP-211857; 6/1/22: WID:RP-211857->RP-212906; 5/4/22: WID:RP-212906->RP-220816
- 2601: ; 13/9/21: Compl:0%->70%; 13/9/21: CD:Wed 15/09/21->Tue 21/09/21; 13/9/21: Stat Rep: ->RP-211856 ; 20/6/22: Rapporteur: Ericsson->Chunhui Zhang, Ericsson; Rap eMail: ->Chunhui.Zhang@ericsson.com;
- 2602: ; 13/9/21: Compl:0%->70%; 13/9/21: CD:Wed 15/09/21->Tue 21/09/21; 13/9/21: Stat Rep: ->RP-211856 ; 20/6/22: Rapporteur: Ericsson->Chunhui Zhang, Ericsson; Rap eMail: ->Chunhui.Zhang@ericsson.com;
- 2603: 2/7/21: WID:RP-201356->RP-211507
- 2604: 2/7/21: 0%->100
- 2605: 7/4/21: 0%->100
- 2606: tested: REL-17 WI LTE_B24_mod-Core ; 29/9/21: WID:RP-211396->RP-212497; 6/1/22: 0%->100
- 2608: 25/9/20: WID:RP-201248->RP-201754; 6/1/21: WID:RP-201754->RP-202573; 7/4/21: WID:RP-202573->RP-210227; 2/7/21: WID:RP-210227->RP-211560; 29/9/21: WID:RP-211560->RP-211859; 6/1/22: WID:RP-211859->RP-212933; 5/4/22: WID:RP-212933->RP-220552; 12/7/22: WID:RP-220552->RP-221389
- 2609: 20/6/22: FCD:15/09/2021->22/06/2022; Compl:0%->100%; WID: RP-220552->RP-212933; Stat Rep: ->RP-221388; Rapporteur: Qualcomm->Bin Han, Qualcomm Incorporated; Rap eMail: ->binhan@qti.qualcomm.com;
- 2610: ; 6/6/22: Comp ; 20/6/22: Rapporteur: Qualcomm->Bin Han, Qualcomm Incorporated; Rap eMail: ->binhan@qti.qualcomm.com;
- 2611: 25/9/20: WID:RP-201244->RP-201730; 6/1/21: WID:RP-201730->RP-202615; 7/4/21: WID:RP-202615->RP-210540; 2/7/21: WID:RP-210540->RP-211388; 29/9/21: WID:RP-211388->RP-212192; 6/1/22: WID:RP-212192->RP-213144; 5/4/22: WID:RP-213144->RP-220715; 12/7/22: WID:RP-220715->RP-221526
- 2612: ; 22/3/22: Compl:0%->67%; 20/6/22: Rapporteur: Huawei->Mohammad Abdi Abyaneh, Huawei, HiSilicon; Rap eMail: ->mohammad.abdi.abyaneh@huawei.com;
- 2613: 6/1/21: stopped at 0%; 22/3/22: Compl:100%->10%; 22/3/22: CD:15/09/2021->10/06/2022 ; 20/6/22: Rapporteur: Huawei->Mohammad Abdi Abyaneh, Huawei, HiSilicon; Rap eMail: ->mohammad.abdi.abyaneh@huawei.com;
- 2614: 25/9/20: WID:RP-201245->RP-201911; 6/1/21: WID:RP-201911->RP-202212; 7/4/21: WID:RP-202212->RP-210837; 2/7/21: WID:RP-210837->RP-211068; 29/9/21: WID:RP-211068->RP-211885; 6/1/22: WID:RP-211885->RP-212813; 5/4/22: WID:RP-212813->RP-220175; 12/7/22: WID:RP-220175->RP-221305
- 2615: ; 13/9/21: Compl:0%->85%; 13/9/21: CD:Wed 15/09/21->Tue 22/03/22; ; 20/6/22: Rapporteur: Nokia->Iwajlo ANGELOW, Nokia; Rap eMail: ->iwajlo.angelow@nokia.com;
- 2616: ; 13/9/21: Compl:0%->85%; 13/9/21: CD:Wed 15/09/21->Tue 22/03/22; ; 20/6/22: Rapporteur: Nokia->Iwajlo ANGELOW, Nokia; Rap eMail: ->iwajlo.angelow@nokia.com;
- 2617: 25/9/20: WID:RP-201246->RP-201732; 7/4/21: WID:RP-201732->RP-210542; 2/7/21: WID:RP-210542->RP-211390; 29/9/21: WID:RP-211390->RP-212194; 5/4/22: WID:RP-212194->RP-220718; 12/7/22: WID:RP-220718->RP-221528
- 2618: ; 22/3/22: Compl:0%->70%; 20/6/22: Rapporteur: Huawei->Liu Ye, Huawei; Rap eMail: ->leo.liuye@huawei.com;
- 2619: 22/3/22: CD:15/09/2021->12/06/202222/3/22: Stat Rep: ->RP-220716 ; 20/6/22: Rapporteur: Huawei->Liu Ye, Huawei; Rap eMail: ->leo.liuye@huawei.com;
- 2620: 25/9/20: WID:RP-201247->RP-201475; 6/1/21: WID:RP-201475->RP-202289; 7/4/21: WID:RP-202289->RP-210200; 2/7/21: WID:RP-210200->RP-211041; 29/9/21: WID:RP-211041->RP-211748; 6/1/22: WID:RP-211748->RP-212874; 5/4/22: WID:RP-212874->RP-220295; 12/7/22: WID:RP-220295->RP-221188
- 2621: ; 22/3/22: Compl:0%->95%; ; 20/6/22: FCD:11/03/2022->22/06/2022; Compl:95%->100%; Stat Rep: RP-220299->RP- 221189; Rapporteur: LG->Jin Woong Park, LG Electronics; Rap eMail: ->jinwoong.park@lge.com;
- 2622: ; 22/3/22: Compl:0%->95%; ; 20/6/22: FCD:11/03/2022->22/06/2022; Compl:95%->100%; Stat Rep: RP-220299->RP- 221189; Rapporteur: LG->Jin Woong Park, LG Electronics; Rap eMail: ->jinwoong.park@lge.com;
- 2623: 8/12/23: Compl:0%->5%; Stat Rep: ->RP-233566; Rapporteur: China Telecom->Lei GAO, China Telecom; Rap eMail: ->gaol8@chinatelecom.cn; ; 14/3/24: FCD:11/12/2024->12/12/2024; Compl:5%->30%; Stat Rep: RP-233566->RP-240360; ; 13/6/24: Compl:30%->50%; Stat ...; 24/1/25: 99%->100
- 2624: -
- 2625: 5/12/20: 0%->30; 19/3/21: 30%->50; 19/3/21: FCD:12/03/2021->09/21; 11/6/21: 50%->70; 11/6/21: FCD:Wed 08/09/->12/21; 13/9/21: 70%->75; 12/3/22: 75%->100
- 2626: 10/2/21: 33.875 added;; 19/3/21: 0%->45; 19/3/21: FCD:11/06/2021->09/21; 11/6/21: 45%->70; 11/6/21: FCD:Wed 08/09/->12/21; 4/6/22: 70%->75; 12/9/22: 75%->87; 31/3/23: 87%->100
- 2627: 2/10/18: Moved from Rel-17¦7/12/18: 0%->5¦20/3/19: 5%->20; 13/9/19: 20%->30; 13/9/19: FCD:13/09/2019->12/20; 6/12/19: 30%->35; 6/12/19: FCD:12/12/2019->03/20; 25/03/20: Rel-16->Rel-17; 26/6/20: FCD:12/03/2020->12/20; 26/6/20: 35%->60; 5/12/20: 60%->70;
- 2628: 20/3/19: 0%->60¦20/3/19: 0%->60; 13/9/19: FCD:19/09/2019->12/20; 6/12/19: FCD:12/12/2019->03/20; 25/03/20: Rel-16->Rel-17; 26/6/20: 60%->100
- 2629: 25/9/20: 26.998 added;; 5/12/20: 0%->10; 21/3/21: 10%->20; 21/3/21: FCD:11/06/2021->09/21; 11/6/21: 20%->65; 11/6/21: FCD:Wed 08/09/->12/21; 13/9/21: 65%->80; 13/12/21: 80%->90; 13/12/21: FCD:Fri 10/12/->03/22; 12/3/22: 90%->100
- 2630: ; 8/10/19: 26.999 added;; 8/10/19: 26.119 added;; 25/3/20: 0%->10; 20/4/20: FCD:12/06/2020->12/20; 5/12/20: FCD:17/12/2020->06/20; 21/3/21: 10%->20; 11/6/21: FCD:Fri 11/06/->12/21; 13/12/21: 20%->90; 13/12/21: FCD:Fri 10/12/->03/22; 12/3/22: 90%->100
- 2631: 21/3/21: 0%->5; 11/6/21: 5%->40; 2/7/21: 26.804 added;; 13/9/21: 40%->50; 13/12/21: 50%->60; 13/12/21: FCD:Wed 08/09/->03/22; 12/3/22: 60%->100
- 2632: 10/6/20: 0%->5; 26/6/20: 5%->15; 5/12/20: 15%->30; 5/12/20: FCD:17/12/2020->06/20; 21/3/21: 30%->60; 11/6/21: 60%->100
- 2633: 10/6/20: 0%->20; 26/6/20: 20%->20; 5/12/20: 20%->45; 5/12/20: FCD:17/12/2020->06/20; 21/3/21: 45%->55; 11/6/21: 55%->70; 11/6/21: FCD:Fri 11/06/->12/21; 13/9/21: 70%->75; 13/12/21: 75%->85; 13/12/21: FCD:Fri 10/12/->03/22; 12/3/22: 85%->90; 12/3/22: FC
- 2634: ; 10/6/20: 0%->10; 5/12/20: 10%->30; 5/12/20: FCD:11/12/2020->09/20; 21/3/21: 30%->40; 11/6/21: 40%->96; 13/9/21: 96%->100

| ID | WBS | Task | Type | Duration | Start | Finish | Complete | Constraint | Resources | Work | Actual work | Acronym | PCG approved | Impacted TSs and TRs | WI rapporteur name | WI rapporteur e-mail | Release | TSG approved | Status Report | TSG stopped |
| --- | --- | --- | --- | --- | --- | --- | --- | --- | --- | --- | --- | --- | --- | --- | --- | --- | --- | --- | --- | --- |
| 2635 | 1145 | **Study on enhanced IMS to 5GC Integration Phase 2** |  | 551.88d | 2020-09-25 A | 2022-03-11 A | 100% |  | ct | 12192h | 12192h | FS_eIMS5G2 | 45 | 23.700-10 | Haitao Wei (Huawei) | weihaitao@huawei.com | Rel-17 | 88 |  |  |
| 2636 | 1145.1 | CT1 aspects of FS_eIMS5G2 |  | 381d | 2020-09-25 A | 2022-03-11 A | 100% | finish no earlier than 2022-03-12 | C1 | 3048h | 3048h | FS_eIMS5G2 | 45 | 23.700-10 | Haitao Wei (Huawei) | weihaitao@huawei.com | Rel-17 | 88 |  |  |
| 2637 | 1145.2 | CT3 aspects of FS_eIMS5G2 |  | 381d | 2020-09-25 A | 2022-03-11 A | 100% | finish no earlier than 2022-03-12 | C3 | 3048h | 3048h | FS_eIMS5G2 | 45 | 23.700-10 | Haitao Wei (Huawei) | weihaitao@huawei.com | Rel-17 | 88 |  |  |
| 2638 | 1145.3 | CT4 aspects of FS_eIMS5G2 |  | 381d | 2020-09-25 A | 2022-03-11 A | 100% | finish no earlier than 2022-03-12 | C4 | 3048h | 3048h | FS_eIMS5G2 | 45 | 23.700-10 | Haitao Wei (Huawei) | weihaitao@huawei.com | Rel-17 | 88 |  |  |
| 2639 | 1146 | Study on Port Number Allocation Alternatives for New 3GPP Interfaces |  | 388d | 2020-09-16 A | 2022-03-11 A | 100% | finish no earlier than 2022-03-12 | C4 | 3104h | 3104h | FS_PortAl | 45 |  | Giorgi Gulbani, Huawei | giorgi.gulbani@huawei.com | Rel-17 | 89 |  |  |
| 2640 | 1147 | Study on scenarios and requirements of in-coverage, partial coverage, and out-of-coverage NR positioning use cases |  | 323d | 2020-06-22 A | 2021-09-15 A | 100% | finish no earlier than 2021-09-15 | RP | 2584h | 2584h | FS_NR_pos_cov | 45 |  | LG Electronics |  | Rel-17 | 88 |  |  |
| 2641 | 1148 | Study on XR (Extended Reality) evaluations for NR |  | 527d | 2019-12-16 A | 2021-12-21 A | 100% | finish no earlier than 2021-12-21 | R1 | 4216h | 4216h | FS_NR_XR_eval | 44 |  | Qualcomm |  | Rel-17 | 86 | RP-212047 |  |
| 2642 | 1149 | Study on enhancement of RAN slicing for NR |  | 262d | 2019-12-16 A | 2020-12-15 A | 100% | finish no earlier than 2020-12-15 | R2 | 2096h | 2096h | FS_NR_slice | 44 |  | CMCC |  | Rel-17 | 86 |  |  |
| 2643 | 1150 | Study on enhancement for data collection for NR and ENDC |  | 450d | 2020-06-22 A | 2022-03-11 A | 100% | finish no earlier than 2022-03-22 | R3 | 3600h | 3600h | FS_NR_ENDC_data_collect | 45 | 37.817; 38.817 | CMCC |  | Rel-17 | 88 | RP-220634 |  |
| 2644 | 1151 | Study on high-power UE operation for fixed-wireless/vehicle-mounted use cases in LTE bands 5 and 12 and NR band n71 |  | 1d | 2020-03-19 A | 2020-03-19 A | 100% | start no earlier than 2020-03-19 | R4 | 8h | 8h | FS_LTE_NR_HPUE_FWVM | 45 | 37.880 | Nokia |  | Rel-17 | 88 |  |  |
| 2645 | 1152 | Study on high power UE (power class 2) for one NR FDD band |  | 202d | 2020-12-14 A | 2021-09-21 A | 100% | finish no earlier than 2021-09-21 | R4 | 1616h | 1616h | FS_NR_PC2_UE_FDD | 46 |  | China Unicom |  | Rel-17 | 90 | RP-211854 |  |
| 2646 | 1153 | Study on extended 600MHz NR band |  | 193d | 2020-12-14 A | 2021-09-08 A | 100% | finish no earlier than 2021-09-08 | R4 | 1544h | 1544h | FS_NR_600MHz_ext | 46 |  | Spark |  | Rel-17 | 90 |  |  |
| 2647 | 1154 | Study on charging aspects of 5GS CIoT |  | 323d | 2020-09-16 A | 2021-12-10 A | 100% | finish no earlier than 2021-12-12 | S5 | 2584h | 2584h | FS_5G_CIoT_CH | 45 |  | Zhu, Lei, Huawei | lei.zhu@huawei.com | Rel-17 | 89 |  |  |
| 2648 | 1155 | Stopped - Study on the Usage of User Identifiers in the 5G System |  | 267d | 2019-06-06 A | 2020-06-12 A | 100% | finish no earlier than 2020-06-12 | S2 | 2136h | 2136h | FS_UUI5 | 43 | New ; 23.700-094; | Starsinic, Michael, Convida Wireless LLC | starsinic.michael@convidawireless.com | Rel-17 | 84 |  | 95 |
| 2649 | 1156 | Stopped - Study on service-based support for SMS in 5GC |  | 195.88d | 2019-03-07 A | 2019-12-05 A | 100% |  | S2 | 1567h | 1567h | FS_SB_SMS | 42 | New | George Foti | George dot Foti at ericsson dot com | Rel-17 | 83 |  | 95 |
| 2650 | 1157 | Stopped - Study on UPF enhancement for control and SBA |  | 261.88d | 2019-03-07 A | 2020-03-06 A | 100% |  | S2 | 2095h | 2095h | FS_UPCAS | 42 | New | Dan Wang, China Mobile | wangdanyjy@chinamobile.com | Rel-17 | 83 |  | 95 |
| 2651 | 1158 | Stopped - Study on security aspects of the Disaggregated gNB Architecture |  | 187d | 2020-06-25 A | 2021-03-12 A | 100% | finish no earlier than 2021-03-12 | S3 | 1496h | 1496h | FS_disagg_gNB_Sec | 45 | 33.840 | Sen XU, China Telecom | xusen@chinatelecom.cn | Rel-17 | 88 |  | 95 |
| 2652 | 1159 | --- RELEASE 16 --- | milestone | 0d? | 2016-03-15 A | 2016-03-15 A | 100% | start no earlier than 2016-03-15 |  |  |  |  |  |  |  |  | Rel-16 |  |  |  |
| 2653 | 1160 | Release 16 Features and related studies | milestone | 0d? | 2016-03-15 A | 2016-03-15 A | 100% | start no earlier than 2016-03-15 |  |  |  |  |  |  |  |  | Rel-16 |  |  |  |
| 2654 | 1161 | Enhancement of Ultra-Reliable (UR) Low Latency Communications (URLLC) | milestone | 0d? | 2017-12-15 A | 2017-12-15 A | 100% |  |  |  |  |  |  |  |  |  | Rel-16 |  |  |  |
| 2655 | 1162 | **Enhancement of URLLC support in the 5G Core network** |  | 2351.88d? | 2017-12-15 A | 2024-03-03 A | 100% |  |  | 18544h | 18544h | 5G_URLLC | 42 | 23.501; 23.502; 23.503 | Hui Ni, Huawei | Hui.ni@huawei.com | Rel-16 | 82 |  |  |
| 2656 | 1162.1 | Study on enhancement of URLLC supporting in 5GC |  | 197d? | 2018-03-15 A | 2018-12-14 A | 100% | finish no earlier than 2018-12-14 | S2 | 1576h | 1576h | FS_5G_URLLC | 40 | 23.xyz; 23.725 | Hui Ni, Huawei | Hui.ni@huawei.com | Rel-16 | 79 |  |  |
| 2657 | 1162.2 | Study on the security of URLLC for 5GS |  | 200d? | 2018-09-06 A | 2019-06-12 A | 100% | finish no earlier than 2019-06-12 | S3 | 1600h | 1600h | FS_5G_URLLC_SEC | 41 | New | Rong Wu, Huawei Technologies | Raina.wu@huawei.com | Rel-16 | 81 |  |  |
| 2658 | 1162.3 | Stage 2 of 5G_URLLC |  | 136d | 2018-12-13 A | 2019-06-20 A | 100% | start no earlier than 2018-12-13 | S2 | 1088h | 1088h | 5G_URLLC | 42 | 23.501; 23.502; 23.503 | Hui Ni, Huawei | Hui.ni@huawei.com | Rel-16 | 82 |  |  |
| 2659 | 1162.4 | Security of URLLC for 5GS |  | 201d | 2019-06-06 A | 2020-03-12 A | 100% | finish no earlier than 2020-03-12 | S3 | 1608h | 1608h | 5G_URLLC_SEC | 43 | 33.501 | Rong Wu, Huawei Technologies | Raina.wu@huawei.com | Rel-16 | 84 |  |  |

Notes:
- 2635: 13/9/20: 0%->5; 13/9/20: FCD:19/03/2021->09/21; 25/9/20: 23.700-10 added;; 5/12/20: 5%->10; 5/12/20: 10%->70; 21/3/21: 70%->15
- 2636: 13/9/20: 0%->5; 13/9/20: FCD:19/03/2021->09/21; 25/9/20: 23.700-10 added;; 5/12/20: 5%->10; 5/12/20: 10%->70; 21/3/21: 70%->15; 13/9/21: 15%->60; 13/12/21: 60%->90; 12/3/22: FCD:08/09/2021->3/22; 12/3/22: 90%->100
- 2637: 13/9/20: 0%->5; 13/9/20: FCD:19/03/2021->09/21; 25/9/20: 23.700-10 added;; 5/12/20: 5%->10; 5/12/20: 10%->70; 21/3/21: 70%->15; 8/4/21: 15%->30; 11/6/21: 0%->5; 13/9/21: FCD:Wed 08/09/->03/22; 12/3/22: 5%->100
- 2638: 13/9/20: 0%->5; 13/9/20: FCD:19/03/2021->09/21; 25/9/20: 23.700-10 added;; 5/12/20: 5%->10; 5/12/20: 10%->70; 21/3/21: 70%->15; 8/4/21: 15%->30; 11/6/21: 30%->40; 11/6/21: 40%->30; 14/6/21: 30%->40; 13/9/21: 40%->50; 13/9/21: FCD:Wed 08/09/->12/21; 13
- 2639: 13/9/20: FCD:11/06/2021->09/21; 25/9/20: WID:CP-202029->CP-202243; 5/12/20: 0%->30; 21/3/21: 30%->50; 11/6/21: 50%->70; 13/9/21: 70%->85; 13/9/21: FCD:Wed 08/09/->03/22; 13/12/21: 85%->100; 22/3/22: WID:CP-202243->CP-220391
- 2640: 25/9/20: WID:RP-201384->RP-201518; 29/9/21: 0%->100
- 2641: affects: NR.; 28/7/20: WID:RP-193241->RP-201145; 7/4/21: WID:RP-201145->RP-210460; 13/9/21: Compl:0%->70% ; 6/1/22: 70%->100
- 2642: affects: NR. TR 38.8xx; 25/9/20: WID:RP-193254->RP-201612; 2/7/21: 0%->100
- 2643: 25/9/20: WID:RP-201304->RP-201620; 25/9/20: 37.817 added;; 25/9/20: 38.817 added;; 13/9/21: Compl:0%->60% ; ; 5/4/22: 100%->100
- 2644: 25/9/20: 37.880 added;; 2/7/21: 0%->100
- 2645: TR 38.8xx ; 13/9/21: Compl:0%->100%; 13/9/21: CD:Wed 08/09/21->Tue 21/09/21; 13/9/21: Stat Rep: ->RP- ; 29/9/21: 100%->100; 6/1/22: WID:RP-202870->RP-212892
- 2646: TR 38.8xx ; 29/9/21: 0%->100
- 2647: 5/12/20: 0%->15; 5/12/20: FCD:12/03/2021->09/20; 21/3/21: 15%->30; 13/9/21: 30%->70; 13/9/21: FCD:Wed 08/09/->12/21; 4/6/22: 70%->100
- 2648: 26/6/19: 23.700-094 added;; 8/10/19: 23.700-94 added; 21/1/22: stopped at 0%; 21/1/22: 0%->100
- 2649: 21/1/22: stopped at 0%; 21/1/22: 0%->100
- 2650: 21/1/22: stopped at 0%; 21/1/22: 0%->100
- 2651: 12/9/20: 0%->5; 5/12/20: 5%->15; 5/12/20: FCD:16/12/2020->03/20; 19/3/21: 15%->100. 13/7/22: marked as stopped (was already at 100%!) as per e-mail from Mirko on 02/06/22 14.03
- 2652: -
- 2653: -
- 2654: -
- 2655: 14/3/19: 0%->50
- 2656: 7/6/18: 0%->15¦6/8/18: 23.725 added;¦10/9/18: 15%->60¦7/12/18: 60%->85¦14/3/19: 85%->90; 31/5/19: 90%->95; 13/9/19: 95%->100
- 2657: 7/12/18: 0%->20¦20/3/19: FCD:019->06/19¦20/3/19: 20%->65; 31/5/19: 65%->80; 13/9/19: 80%->100
- 2658: 14/3/19: 0%->50; 31/5/19: 50%->80; 13/9/19: 80%->100
- 2659: 13/9/19: 0%->30; 6/12/19: 30%->80; 6/12/19: FCD:12/12/2019->03/20; 9/4/21: 80%->100

| ID | WBS | Task | Type | Duration | Start | Finish | Complete | Constraint | Resources | Work | Actual work | Acronym | PCG approved | WI rapporteur name | WI rapporteur e-mail | Release | TSG approved | Impacted TSs and TRs | TSG stopped | Status Report |
| --- | --- | --- | --- | --- | --- | --- | --- | --- | --- | --- | --- | --- | --- | --- | --- | --- | --- | --- | --- | --- |
| 2660 | 1162.5 | **CT Aspects of 5G_URLLC** |  | 291d | 2019-06-06 A | 2020-03-12 A | 100% |  | ct | 6432h | 6432h | 5G_URLLC | 43 | Qi Caixia, Huawei | caixia.qi@huawei.com | Rel-16 | 84 |  |  |  |
| 2661 | 1162.5.1 | CT1 Aspects of 5G_URLLC |  | 201d | 2019-06-06 A | 2020-03-12 A | 100% | finish no earlier than 2020-03-12 | C1 | 1608h | 1608h | 5G_URLLC | 44 | Qi Caixia, Huawei | caixia.qi@huawei.com | Rel-16 | 87 |  |  |  |
| 2662 | 1162.5.2 | CT3 Aspects of 5G_URLLC |  | 201d | 2019-06-06 A | 2020-03-12 A | 100% | finish no earlier than 2020-03-12 | C3 | 1608h | 1608h | 5G_URLLC | 43 | Qi Caixia, Huawei | caixia.qi@huawei.com | Rel-16 | 84 | 29.512; 29.513; 29.514; 29.522; 29.508 |  |  |
| 2663 | 1162.5.3 | CT4 Aspects of 5G_URLLC |  | 201d | 2019-06-06 A | 2020-03-12 A | 100% | finish no earlier than 2020-03-12 | C4 | 1608h | 1608h | 5G_URLLC | 43 | Qi Caixia, Huawei | caixia.qi@huawei.com | Rel-16 | 84 | 29.244; 29.502; 29.503; 29.510; 29.281 |  |  |
| 2664 | 1162.6 | Charging enhancement for URLLC |  | 193d | 2020-09-16 A | 2021-06-11 A | 100% | finish no earlier than 2021-06-12 | S5 | 1544h | 1544h | 5G_URLLC | 45 | Chen, Shan, Huawei | chenshan@huawei.com | Rel-17 | 89 | 32.255; 32.291; 32.298 |  |  |
| 2665 | 1162.7 | Management Aspects of URLLC |  | 194d | 2023-06-08 A | 2024-03-03 A | 100% | finish no earlier than 2024-03-03 | S5 | 1552h | 1552h | URLLC_Mgt | 51 | Wang Zhaoning, China Unicom, | wangzn18@chinaunicom.cn | Rel-18 | 100 | 28.541; 28.552; 28.554 |  |  |
| 2666 | 1162.8 | Stopped - Study on EPC support for Mobility with Low Latency Communication |  | 196d? | 2017-12-15 A | 2018-09-14 A | 100% | finish no earlier than 2018-09-14 | S2 | 1568h | 1568h | FS_LLC_Mob | 40 | Chris PUDNEY | chris dot pudney at vodafone dot com | Rel-16 | 78 | new 23.739 | 84 |  |
| 2667 | 1162.9 | Stopped - Study on enht of systems using EPS for UR and Availability using commodity equipment |  | 197d? | 2018-03-15 A | 2018-12-14 A | 100% | start no earlier than 2018-03-15 | S2 | 1576h | 1576h | FS_EPS_URACE | 40 | Chris Pudney | chris.pudney@vodafone.com | Rel-16 | 79 | new; 23.736 | 84 |  |
| 2668 | 1163 | **Physical Layer Enhancements for NR Ultra-Reliable and Low Latency Communication (URLLC)** |  | 2078.5d? | 2018-06-15 A | 2023-12-12 A | 100% |  | R1 | 24632h | 24632h | NR_L1enh_URLLC | 42 | Huawei |  | Rel-16 | 83 |  |  |  |
| 2669 | 1163.1 | Study on physical layer enhancements for NR UR Low Latency Cases |  | 196d? | 2018-06-15 A | 2019-03-15 A | 100% | finish no earlier than 2019-03-15 | R1 | 1568h | 1568h | FS_NR_L1enh_URLLC | 41 | Huawei |  | Rel-16 | 80 |  |  |  |
| 2670 | 1163.2 | Core part: Physical Layer Enhancements for NR URLLC |  | 261d | 2019-03-01 A | 2020-02-28 A | 100% | finish no earlier than 2020-03-01 | R1 | 2088h | 2088h | NR_L1enh_URLLC-Core | 42 | Huawei |  | Rel-16 | 83 |  |  |  |
| 2671 | 1163.3 | Perf. part: Physical Layer Enhancements for NR URLLC |  | 403d | 2019-03-01 A | 2020-09-15 A | 100% | finish no earlier than 2020-09-15 | R4 | 3224h | 3224h | NR_L1enh_URLLC-Perf | 42 | Huawei |  | Rel-16 | 83 |  |  |  |
| 2672 | 1163.4 | UE Conformance Test Aspects - Physical Layer Enhancements for NR URLLC |  | 784d | 2020-12-14 A | 2023-12-12 A | 100% | finish no earlier than 2023-12-12 | R5 | 6272h | 6272h | NR_L1enh_URLLC-UEConTest | 46 | Chunying GU, Huawei | guchunying@huawei.com | Rel-16 | 90 |  |  | RP-233758 |
| 2673 | 1164 | **Support of NR Industrial Internet of Things (IoT)** |  | 1414.62d? | 2018-06-15 A | 2022-03-11 A | 100% |  | R2 | 17152h | 17152h | NR_IIOT | 42 | Nokia |  | Rel-16 | 83 |  |  |  |
| 2674 | 1164.1 | Study on channel modeling for indoor industrial scenarios |  | 261d? | 2018-09-14 A | 2019-09-13 A | 100% | finish no earlier than 2019-09-13 | R1 | 2088h | 2088h | FS_IIIOT_CM | 41 | Ericsson |  | Rel-16 | 81 |  |  |  |
| 2675 | 1164.2 | Study on NR Industrial Internet of Things (IoT) |  | 196d? | 2018-06-15 A | 2019-03-15 A | 100% | finish no earlier than 2019-03-15 | R2 | 1568h | 1568h | FS_NR_IIOT | 41 | Nokia |  | Rel-16 | 80 | 38.825 |  |  |
| 2676 | 1164.3 | Core part: Support of NR Industrial Internet of Things (IoT) |  | 261d | 2019-03-01 A | 2020-02-28 A | 100% | finish no earlier than 2020-03-01 | R2 | 2088h | 2088h | NR_IIOT-Core | 42 | Nokia |  | Rel-16 | 83 |  |  |  |
| 2677 | 1164.4 | UE Conformance Test Aspects – Support of NR Industrial Internet of Things (IoT) |  | 450d | 2020-06-22 A | 2022-03-11 A | 100% | finish no earlier than 2022-03-12 | R5 | 3600h | 3600h | NR_IioT-UEConTest | 45 | CMCC |  | Rel-16 | 88 |  |  | RP-220623 |
| 2678 | 1165 | 5GS Enhanced support of Vertical and LAN Services | milestone | 0d? | 2017-12-15 A | 2017-12-15 A | 100% |  |  |  |  |  | 42 |  |  | Rel-16 | 82 |  |  |  |
| 2679 | 1166 | Study on Communication for Automation in Vertical Domains |  | 271d? | 2017-03-02 A | 2018-03-15 A | 100% | finish no earlier than 2018-03-15 | S1 | 2168h | 2168h | FS_CAV | 38 | Walewski, Joachim, Siemens AG | joachim.walewski@siemens.com | Rel-16 | 75 | 22.804 |  |  |
| 2680 | 1167 | Service requirements for cyber-physical control applications in vertical domains |  | 73d? | 2018-06-06 A | 2018-09-14 A | 100% | finish no earlier than 2018-09-14 | S1 | 584h | 584h | cyberCAV | 41 | Joachim W. Walewski (Siemens) |  | Rel-16 | 80 | 22.261; 22.104 |  |  |
| 2681 | 1168 | **5GS Enhanced support of Vertical and LAN Services** |  | 669d? | 2018-06-06 A | 2020-03-12 A | 100% |  |  | 14816h | 14816h | Vertical_LAN | 42 | Devaki Chandramouli, Nokia | Devaki.chandramouli@nokia.com | Rel-16 | 82 |  |  |  |
| 2682 | 1168.1 | Study on 5GS Enhanced support of Vertical and LAN Services |  | 138d? | 2018-06-06 A | 2018-12-14 A | 100% | finish no earlier than 2018-12-14 | S2 | 1104h | 1104h | FS_Vertical_LAN | 41 | Devaki Chandramouli, Nokia | Devaki.chandramouli@nokia.com | Rel-16 | 80 | 23.734 |  |  |
| 2683 | 1168.2 | Stage 2 of Vertical_LAN |  | 138d | 2018-12-13 A | 2019-06-24 A | 100% | start no earlier than 2018-12-13 | S2 | 1104h | 1104h | Vertical_LAN | 42 | Devaki Chandramouli, Nokia | Devaki.chandramouli@nokia.com | Rel-16 | 82 | 23.501; 23.502; 23.503 |  |  |
| 2684 | 1168.3 | Study on Security for 5GS Enhanced support of Vertical and LAN Services |  | 331d? | 2018-09-06 A | 2019-12-12 A | 100% | finish no earlier than 2019-12-12 | S3 | 2648h | 2648h | FS_Vertical_LAN_SEC | 41 | Jerichow, Anja (Nokia) | anja.jerichow@nokia.com | Rel-16 | 81 | New |  |  |
| 2685 | 1168.4 | Security for Vertical_LAN |  | 201d | 2019-06-06 A | 2020-03-12 A | 100% | finish no earlier than 2020-03-12 | S3 | 1608h | 1608h | Vertical_LAN_SEC | 43 | Jerichow, Anja, Nokia | anja.jerichow@nokia.com | Rel-16 | 84 | 33.501 |  |  |

Notes:
- 2660: 16/9/19: WID:CP-191063->CP-192022
- 2661: 26/3/20: CT1 aspects added as per Peter's e-mail; 26/3/20: 0%->100
- 2662: 13/9/19: 0%->50; 6/12/19: 50%->80; 26/3/20: 80%->100
- 2663: 31/5/19: 0%->5; 13/9/19: 5%->20; 6/12/19: 20%->60; 26/3/20: 60%->98; 26/6/20: 98%->100
- 2664: ; 5/12/20: 0%->20; 5/12/20: FCD:12/03/2021->06/20; 21/3/21: 20%->30; 13/9/21: 30%->100
- 2665: ; 7/9/23: 0%->10; 8/12/23: 10%->20; 14/3/24: 20%->100
- 2666: 16/3/18: 0%->35¦7/6/18: 35%->75¦6/6/19: stopped at 75% as per SP-190395
- 2667: 7/6/18: 0%->10¦6/8/18: 23.736 added¦6/6/19: stopped at 10% as per SP-190395; 6/6/19: 10%->100
- 2668: 26/6/19: WID:RP-190726->RP-191584
- 2669: TR 38.8xx¦26/3/19: 0%->100
- 2670: 26/3/20: 0%->100
- 2671: 7/4/21: 0%->100
- 2672: tested: REL-16 WI NR_L1enh_URLLC-Core ; 8/4/21: 0%->5; 2/7/21: 5%->16; 22/3/22: Compl:16 ; 20/6/22: Rapporteur: Huawei->Chunying GU, Huawei; Rap eMail: ->guchunying@huawei.com; 9/12/22: FCD:22/12/2022->01/12/2023; Compl:90%->91%; Stat Rep: RP-2214.....; 8/12/23: Compl:99%->100%; Stat Rep: RP-232349->RP-233758;
- 2673: 26/6/19: WID:RP-190728->RP-191561; 8/10/19: WID:RP-191561->RP-192324; 14/1/20: WID:RP-192324->RP-192590
- 2674: 8/10/19: 0%->100
- 2675: TR 38.8XX?¦6/8/18: 38.825 added;¦26/3/19: 0%->100
- 2676: 28/7/20: WID:RP-192590->RP-200797; 28/7/20: 0%->100
- 2677: 8/10/20: 0%->5; 8/4/21: 5%->68; 2/7/21: 68%->77; 13/9/21: Compl:77%->95%; 13/9/21: C ; 29/9/21: WID:RP-200757->RP-211786; 6/1/22: WID:RP-211786->RP-212943;
- 2678: -
- 2679: 7/6/17: 0%->30¦25/8/17: FCD:12/17->03/18¦11/9/17: 30%->65¦15/12/17: 65%->85¦16/3/18: 85%->95¦7/6/18: 95%->100
- 2680: 10/9/18: 5%->40¦4/12/18: 40%->100
- 2682: 10/9/18: 0%->25¦7/12/18: 25%->88¦14/3/19: 88%->92; 31/5/19: 92%->100
- 2683: 14/3/19: 0%->43; 31/5/19: 43%->90; 13/9/19: 90%->97; 6/12/19: 97%->100
- 2684: 7/12/18: 0%->10¦20/3/19: FCD:019->06/19¦20/3/19: 10%->65; 31/5/19: 65%->75; 13/9/19: FCD:12/06/2019->12/20; 13/9/19: 75%->78; 6/12/19: 78%->92; 25/3/20: 92%->100
- 2685: 13/9/19: 0%->30; 6/12/19: 30%->95; 6/12/19: FCD:12/12/2019->03/20; 26/6/20: 95%->100

| ID | WBS | Task | Type | Duration | Start | Finish | Complete | Actual finish | Constraint | Resources | Work | Actual work | Acronym | PCG approved | WI rapporteur name | WI rapporteur e-mail | Release | TSG approved | Status Report |
| --- | --- | --- | --- | --- | --- | --- | --- | --- | --- | --- | --- | --- | --- | --- | --- | --- | --- | --- | --- |
| 2686 | 1168.5 | **CT aspects of Vertical_LAN** |  | 378d | 2019-03-14 A | 2020-03-12 A | 100% |  |  | ct | 8352h | 8352h | Vertical_LAN | 42 | WON, Sung Hwan, Nokia | sung.won@nokia.com | Rel-16 | 83 |  |
| 2687 | 1168.5.1 | CT1 aspects of Vertical_LAN |  | 261d | 2019-03-14 A | 2020-03-12 A | 100% |  | finish no earlier than 2020-03-12 | C1 | 2088h | 2088h | Vertical_LAN | 42 | WON, Sung Hwan, Nokia | sung.won@nokia.com | Rel-16 | 83 |  |
| 2688 | 1168.5.2 | CT3 aspects of Vertical_LAN |  | 261d | 2019-03-14 A | 2020-03-12 A | 100% |  | finish no earlier than 2020-03-12 | C3 | 2088h | 2088h | Vertical_LAN | 42 | WON, Sung Hwan, Nokia | sung.won@nokia.com | Rel-16 | 83 |  |
| 2689 | 1168.5.3 | CT4 aspects of Vertical_LAN |  | 261d | 2019-03-14 A | 2020-03-12 A | 100% |  | finish no earlier than 2020-03-12 | C4 | 2088h | 2088h | Vertical_LAN | 42 | WON, Sung Hwan, Nokia | sung.won@nokia.com | Rel-16 | 83 |  |
| 2690 | 1169 | **Service Enabler Architecture Layer for Verticals** |  | 480.5d | 2019-03-07 A | 2020-06-12 A | 100% |  |  |  | 5568h | 5568h | SEAL | 42 | Basavaraj (Basu) Pattan, Samsung | basavarajjp@samsung.com | Rel-16 | 85 |  |
| 2691 | 1169.1 | Stage 2 of SEAL |  | 182.25d | 2019-03-07 A | 2019-08-29 A | 100% |  |  | S6 | 1008h | 1008h | SEAL | 42 | Basavaraj (Basu) Pattan, Samsung | basavarajjp@samsung.com | Rel-16 | 82 |  |
| 2692 | 1169.2 | Security aspects of SEAL |  | 192d | 2019-09-19 A | 2020-06-12 A | 100% |  | finish no earlier than 2020-06-12 | S3 | 1536h | 1536h | SEAL | 43 | Rajavelsamy Rajadurai (Samsung) | rajvel@samsung.com | Rel-16 | 85 |  |
| 2693 | 1169.3 | **CT aspects of SEAL** |  | 182.25d | 2019-09-19 A | 2020-03-12 A | 100% |  |  | ct | 3024h | 3024h | SEAL | 43 | Sapan Shah (Samsung Electronics) | sapan.shah@samsung.com | Rel-16 | 85 |  |
| 2694 | 1169.3.1 | CT1 aspects of SEAL |  | 126d | 2019-09-19 A | 2020-03-12 A | 100% |  | finish no earlier than 2020-03-12 | C1 | 1008h | 1008h | SEAL | 43 | Sapan Shah (Samsung Electronics) | sapan.shah@samsung.com | Rel-16 | 85 |  |
| 2695 | 1169.3.2 | CT3 aspects of SEAL |  | 126d | 2019-09-19 A | 2020-03-12 A | 100% |  | finish no earlier than 2020-03-12 | C3 | 1008h | 1008h | SEAL | 43 | Sapan Shah (Samsung Electronics) | sapan.shah@samsung.com | Rel-16 | 85 |  |
| 2696 | 1170 | **NR-based access to unlicensed spectrum** |  | 1042d? | 2017-03-15 A | 2019-12-15 | 100% | 2025-03-03 |  | R1 | 25643h | 25643h | NR_unlic | 42 | Qualcomm |  | Rel-16 | 82 |  |
| 2697 | 1170.1 | Study on NR-based access to unlicensed spectrum |  | 458d? | 2017-03-15 A | 2018-12-14 A | 100% |  | finish no earlier than 2018-12-15 | R1 | 3664h | 3664h | FS_NR_unlic | 38 | Qualcomm |  | Rel-16 | 75 |  |
| 2698 | 1170.2 | Core part: NR-based access to unlicensed spectrum | manual | 262d | 2018-12-15 A | 2019-08-24 A | 100% |  |  | R1 | 2096h | 2096h | NR_unlic-Core | 42 | Qualcomm |  | Rel-16 | 82 |  |
| 2699 | 1170.3 | Perf. part: NR-based access to unlicensed spectrum | manual | 262d | 2018-12-15 A | 2019-08-24 A | 100% |  |  | R4 | 2096h | 2096h | NR_unlic-Perf | 42 | Qualcomm |  | Rel-16 | 82 |  |
| 2700 | 1170.4 | UE Conformance Test Aspects - NR-based access to unlicensed spectrum |  | 1504.38d | 2021-03-12 A | 2025-03-03 A | 100% |  | finish no earlier than 2025-03-03 | R5 | 12035h | 12035h | NR_unlic-UEConTest | 46 | Vijay Balasubramanian, Qualcomm | vijayb[at]qti.qualcomm.com | Rel-16 | 91 | RP-250393 |
| 2701 | 1171 | **LAN support in 5G** |  | 577.75d? | 2017-06-05 A | 2018-12-14 A | 100% |  |  | S1 | 4304h | 4304h | 5GLAN | 41 | Almodovar Chico, Jose Luis, KPN | jose.almodovarchico@tno.nl | Rel-16 | 80 |  |
| 2702 | 1171.1 | Study on LAN Support in 5G |  | 204d? | 2017-06-05 A | 2018-03-15 A | 100% |  | finish no earlier than 2018-03-15 | S1 | 1632h | 1632h | FS_5GLAN | 39 | Nasielski, Jack, Qualcomm Incorporated | jackn@qti.qualcomm.com | Rel-16 | 76 |  |
| 2703 | 1171.2 | Stage 1 of 5GLAN |  | 138d? | 2018-06-06 A | 2018-12-14 A | 100% |  | finish no earlier than 2018-12-14 | S1 | 1104h | 1104h | 5GLAN | 41 | Almodovar Chico, Jose Luis, KPN | jose.almodovarchico@tno.nl | Rel-16 | 80 |  |
| 2704 | 1172 | Study on non-public networks management |  | 331.88d | 2019-03-07 A | 2020-06-12 A | 100% |  | finish no earlier than 2020-06-12 | S5 | 2655h | 2655h | FS_OAM_NPN | 42 | ZHANG, Kai, Huawei | kai.zhangkai@huawei.com | Rel-16 | 83 |  |
| 2705 | 1173 | Cellular IoT support and evolution | milestone | 0d? | 2016-06-18 A | 2016-06-18 A | 100% |  |  |  |  |  |  |  |  |  | Rel-16 |  |  |
| 2706 | 1174 | **Cellular IoT support and evolution for the 5G System** |  | 1045d? | 2017-09-08 A | 2020-06-12 A | 100% |  |  |  | 15712h | 15712h | 5G_CIoT | 42 |  |  | Rel-16 | 83 |  |
| 2707 | 1174.1 | Study on 5G_CIoT |  | 331d? | 2017-09-08 A | 2018-12-14 A | 100% |  | finish no earlier than 2018-12-14 | S2 | 2648h | 2648h | FS_CIoT_5G | 39 | Sebastian Speicher | sspeiche@qti.qualcomm.com | Rel-16 | 77 |  |
| 2708 | 1174.2 | Stage 2 of 5G_CIoT |  | 136d | 2018-12-13 A | 2019-06-20 A | 100% |  | start no earlier than 2018-12-13 | S2 | 1088h | 1088h | 5G_CIoT | 42 | Sebastian Speicher | sspeiche@qti.qualcomm.com | Rel-16 | 82 |  |
| 2709 | 1174.3 | **CT aspects of 5G_CIoT** |  | 378d | 2019-03-14 A | 2020-03-12 A | 100% |  |  | ct | 10440h | 10440h | 5G_CIoT | 42 | Waqar Zia; Qualcomm Incorporated | wzia@qti.qualcomm.com | Rel-16 | 83 |  |
| 2710 | 1174.3.1 | CT1 aspects of 5G_CIoT |  | 261d | 2019-03-14 A | 2020-03-12 A | 100% |  | finish no earlier than 2020-03-12 | C1 | 2088h | 2088h | 5G_CIoT | 42 | Waqar Zia; Qualcomm Incorporated | wzia@qti.qualcomm.com | Rel-16 | 83 |  |
| 2711 | 1174.3.2 | CT3 aspects of 5G_CIoT |  | 261d | 2019-03-14 A | 2020-03-12 A | 100% |  | finish no earlier than 2020-03-12 | C3 | 2088h | 2088h | 5G_CIoT | 42 | Waqar Zia; Qualcomm Incorporated | wzia@qti.qualcomm.com | Rel-16 | 83 |  |
| 2712 | 1174.3.3 | CT4 aspects of 5G_CIoT |  | 261d | 2019-03-14 A | 2020-03-12 A | 100% |  | finish no earlier than 2020-03-12 | C4 | 2088h | 2088h | 5G_CIoT | 42 | Waqar Zia; Qualcomm Incorporated | wzia@qti.qualcomm.com | Rel-16 | 83 |  |
| 2713 | 1174.3.4 | CT6 aspects of 5G_CIoT |  | 261d | 2019-03-14 A | 2020-03-12 A | 100% |  | finish no earlier than 2020-03-12 | C6 | 2088h | 2088h | 5G_CIoT | 42 | Waqar Zia; Qualcomm Incorporated | wzia@qti.qualcomm.com | Rel-16 | 83 |  |
| 2714 | 1174.4 | Security of 5G_CIoT |  | 192d | 2019-09-19 A | 2020-06-12 A | 100% |  | finish no earlier than 2020-06-12 | S3 | 1536h | 1536h | 5G_CIoT | 43 | Henrik Normann, Ericsson | henrik.normann@ericsson.com | Rel-16 | 85 |  |
| 2715 | 1175 | Study on evolution of Cellular IoT security for the 5G System |  | 397d? | 2018-06-06 A | 2019-12-12 A | 100% |  | finish no earlier than 2019-12-12 | S3 | 3176h | 3176h | FS_CIoT_sec_5G | 41 | Noamen Ben Henda | noamen.ben.henda@ericsson.com | Rel-16 | 80 |  |
| 2716 | 1176 | Study on MBMS User Services for IoT |  | 335d? | 2017-06-05 A | 2018-09-14 A | 100% |  | finish no earlier than 2018-09-14 | S4 | 2680h | 2680h | FS_MBMS_IoT | 39 | Cedric thienot, Expway | cedric (dot) thienot (at) expway (dot) com | Rel-16 | 76 |  |

Notes:
- 2686: 3/6/19: WID:CP-190195->CP-191157; 16/9/19: WID:CP-191157->CP-192258; 9/12/19: WID:CP-192258->CP-193142; 9/12/19: WID:CP-193142->CP-193272
- 2687: 31/5/19: 0%->20; 3/6/19: WID:CP-190195->CP-191157; 3/6/19: FCD:12/12/2019->03/20; 13/9/19: 20%->75; 6/12/19: 75%->90; 26/3/20: 90%->95; 26/6/20: 95%->99; 13/9/20: 99%->100 / Impacted TSs and TRs: 23.122; 24.368; 24.501; 24.526
- 2688: 31/5/19: FCD:12/12/2019->03/20; 3/6/19: WID:CP-190195->CP-191157; 13/9/19: 0%->30; 6/12/19: 30%->60; 6/12/19: WID:CP-192258->CP-193142; 26/3/20: 60%->100; 26/6/20: WID:CP-193272->CP-201174 / Impacted TSs and TRs: 29.122; 29.507; 29.508; 29.512; 29.513; 29.514; 29.519; 29.520; 29.521; 29.522; 29.523; 29.525; 29.554; 29.561; 29.594; 29.061
- 2689: 31/5/19: 0%->5; 3/6/19: WID:CP-190195->CP-191157; 3/6/19: FCD:12/12/2019->03/20; 13/9/19: 5%->50; 6/12/19: 50%->85; 26/3/20: 85%->95; 26/6/20: 95%->100 / Impacted TSs and TRs: 23.003; 23.008; 29.502; 29.503; 29.505; 29.509; 29.510; 29.518; 29.571; 29.244; 29.281
- 2690: 14/3/19: 0%->60; 31/5/19: 60%->95; 8/10/19: 33.434 added;; 8/10/19: 24.548 added; / Impacted TSs and TRs: new 23.434; 33.434; 24.548; 24.547
- 2691: 14/3/19: 0%->60; 31/5/19: 60%->95; 13/9/19: 0%->100 / Impacted TSs and TRs: new 23.434
- 2692: ; 6/12/19: 0%->40; 25/3/20: 40%->65; 25/3/20: FCD:12/03/2020->06/20; 26/6/20: 65%->100 / Impacted TSs and TRs: New
- 2693: Impacted TSs and TRs: New
- 2694: ; 6/12/19: 0%->60; 6/12/19: 60%->60; 26/3/20: 60%->80; 26/6/20: 80%->100 / Impacted TSs and TRs: New
- 2695: ; 26/3/20: 0%->75; 26/6/20: 75%->100 / Impacted TSs and TRs: New
- 2696: 26/3/19: WID:RP-182878->RP-190706; 26/6/19: WID:RP-190706->RP-191575; 14/1/20: WID:RP-191575->RP-192926; 25/9/20: WID:RP-192926->RP-201834
- 2697: TR 38.8XX19/6/17: WID: RP-170828->RP-171416¦30/6/17: 32.889 added;¦19/9/17: WID: RP-171416->RP-17202127/3/18: Compl:0%->10%¦27/6/18: Compl:10%->40%¦27/6/18: CD:Fri 15/06/18->Sat 15/12/18¦16/1/19: 40%->100 / Impacted TSs and TRs: 32.889
- 2698: 26/3/19: WID:RP-182878->RP-190706; 6/1/21: 0%->100
- 2699: 26/3/19: WID:RP-182878->RP-190706; 2/7/21: 0%->100
- 2700: tested: REL-16 WI NR_unlic-Core ; 2/7/21: 0%->5 ; ; 6/6/22: Compl:18%->20% 20/6/22: Rapporteur: Qualcomm->Vijay Balasubramanian, Qualcomm; Rap eMail: ->vijayb[at]qti.qualcomm.com ; 9/...; 9/12/22: FCD:22/12/2022->01/06/2023; Compl:25%->28%; Stat Re...; 3/4/25: WID:RP-210708->RP-250394
- 2701: 11/3/22: 99%->100 / Impacted TSs and TRs: 22.261; 22.278
- 2702: 11/9/17: 0%->35¦15/12/17: 35%->65¦16/3/18: 65%->100 / Impacted TSs and TRs: 22.821;
- 2703: 10/9/18: 40%->75¦10/9/18: FCD:09/18->12/18¦4/12/18: 75%->100 / Impacted TSs and TRs: 22.261; 22.278
- 2704: 31/5/19: 0%->2; 13/9/19: 2%->10; 26/3/20: 10%->70; 26/3/20: FCD:05/12/2019->06/20; 28/6/20: 70%->100 / Impacted TSs and TRs: New
- 2705: -
- 2707: 11/09/17: rapporteur change¦15/12/17: 23.724 added;¦16/3/18: 0%->20¦7/6/18: 20%->50¦15/6/18: WID:SP-170801->SP-180614¦15/6/18: FCD:09/18->12/18¦10/9/18: 50%->70¦7/12/18: 70%->95; 31/5/19: 95%->100 / Impacted TSs and TRs: New; 23.724
- 2708: 14/3/19: 0%->50; 31/5/19: 50%->95; 13/9/19: 95%->98; 22/3/22: 98%->100 / Impacted TSs and TRs: 23.501; 23.502
- 2709: 3/6/19: WID:CP-190198->CP-111158; 9/12/19: WID:CP-111237->CP-193274; 25/3/20: WID:CP-193274->CP-200147
- 2710: 31/5/19: 0%->40; 3/6/19: WID:CP-190198->CP-111158; 3/6/19: FCD:12/12/2019->03/20; 13/9/19: 40%->60; 6/12/19: 60%->85; 26/3/20: 85%->92; 26/6/20: 92%->99; 13/9/20: 99%->100 / Impacted TSs and TRs: 23.122; 24.250; 24.301; 24.368; 24.501; 27.007
- 2711: 31/5/19: 0%->15; 3/6/19: WID:CP-190198->CP-111158; 3/6/19: FCD:12/12/2019->03/20; 13/9/19: 15%->40; 6/12/19: 40%->65; 6/12/19: WID:CP-111237->CP-193147; 26/3/20: 65%->90; 26/6/20: 90%->100 / Impacted TSs and TRs: 29.122; 29.522; 29.525; 29.222; 29.512; 29.513; 29.514
- 2712: 31/5/19: 0%->10; 3/6/19: WID:CP-190198->CP-111158; 3/6/19: FCD:12/12/2019->03/20; 13/9/19: 10%->25; 6/12/19: 25%->60; 26/3/20: 60%->90; 26/6/20: 90%->100 / Impacted TSs and TRs: 23.008; 29.274; 29.502; 29.503; 29.505; 29.518
- 2713: 3/6/19: WID:CP-190198->CP-111158; 3/6/19: FCD:12/12/2019->03/20; 26/3/20: 0%->100 / Impacted TSs and TRs: TBD
- 2714: 6/12/19: 0%->50; 6/12/19: FCD:12/12/2019->03/20; 25/3/20: 50%->90; 25/3/20: FCD:12/03/2020->06/20; 26/6/20: 90%->100 / Impacted TSs and TRs: 33.501
- 2715: 6/8/18: 33.861 added;¦7/12/18: 5%->30¦20/3/19: 30%->75¦20/3/19: FCD:019->09/19; 31/5/19: 75%->80; 13/9/19: FCD:12/09/2019->12/20; 13/9/19: 80%->90; 6/12/19: 90%->95; 26/6/20: 95%->100 / Impacted TSs and TRs: New; 33.861
- 2716: 11/9/17: 0%->10¦15/12/17: 10%->30¦16/3/18: 30%->80¦16/3/18: FCD:03/18->06/18¦7/6/18: 80%->90¦7/6/18: FCD:06/18->09/18. 14/06/18: Moved from Rel-15¦10/9/18: 90%->100 / Impacted TSs and TRs: 26.8xx

| ID | WBS | Task | Type | Duration | Start | Finish | Complete | Constraint | Resources | Work | Actual work | Acronym | PCG approved | WI rapporteur name | Release | TSG approved | WI rapporteur e-mail | Status Report |
| --- | --- | --- | --- | --- | --- | --- | --- | --- | --- | --- | --- | --- | --- | --- | --- | --- | --- | --- |
| 2717 | 1177 | **Additional MTC enhancements for LTE** |  | 758.25d? | 2018-06-15 A | 2020-06-15 A | 100% |  | R1 | 11480h | 11480h | LTE_eMTC5 | 41 | Ericsson | Rel-16 | 80 |  |  |
| 2718 | 1177.1 | Core part: Additional MTC enhancements for LTE |  | 391d? | 2018-06-15 A | 2019-12-13 A | 100% | finish no earlier than 2019-12-15 | R1 | 3128h | 3128h | LTE_eMTC5-Core | 41 | Ericsson | Rel-16 | 80 |  |  |
| 2719 | 1177.2 | Perf. part: Additional MTC enhancements for LTE |  | 522d? | 2018-06-15 A | 2020-06-15 A | 100% | finish no earlier than 2020-06-15 | R4 | 4176h | 4176h | LTE_eMTC5-Perf | 41 | Ericsson | Rel-16 | 80 |  |  |
| 2720 | 1178 | **Additional enhancements for NB-IoT** |  | 758.25d? | 2018-06-15 A | 2020-06-15 A | 100% |  | R1 | 11480h | 11480h | NB_IOTenh3 | 41 | Huawei | Rel-16 | 80 |  |  |
| 2721 | 1178.1 | Core part: Additional enhancements for NB-IoT |  | 391d? | 2018-06-15 A | 2019-12-13 A | 100% | finish no earlier than 2019-12-15 | R1 | 3128h | 3128h | NB_IOTenh3-Core | 41 | Huawei | Rel-16 | 80 |  |  |
| 2722 | 1178.2 | Perf. part: Additional enhancements for NB-IoT |  | 522d? | 2018-06-15 A | 2020-06-15 A | 100% | finish no earlier than 2020-06-15 | R4 | 4176h | 4176h | NB_IOTenh3-Perf | 41 | Huawei | Rel-16 | 80 |  |  |
| 2723 | 1179 | **5G message service** |  | 941.58d? | 2016-06-18 A | 2018-12-14 A | 100% |  | S1 | 7905.6h | 7905.6h | 5GMSG | 41 |  | Rel-16 | 81 |  |  |
| 2724 | 1179.1 | Study on 5G message service for MIoT |  | 266d? | 2016-06-18 A | 2018-09-14 A | 100% | finish no earlier than 2018-09-14 | S1 | 2128h | 2128h | FS_5GMSG | 39 | Zheng, Jianping, China Mobile | Rel-16 | 77 | zhengjianping@chinamobile.com |  |
| 2725 | 1179.2 | Message Service Within the 5G System requirements |  | 72d? | 2018-09-06 A | 2018-12-14 A | 100% | finish no earlier than 2018-12-14 | S1 | 576h | 576h | MSGin5G | 41 | Zheng, Jianping, China Mobile | Rel-16 | 81 | zhengjianping@chinamobile.com |  |
| 2726 | 1180 | Advanced V2X support | milestone | 0d? | 2017-06-05 A | 2017-06-05 A | 100% |  |  |  |  |  |  |  | Rel-16 |  |  |  |
| 2727 | 1181 | Study on Improvement of V2X Service Handling |  | 66d? | 2018-03-15 A | 2018-06-14 A | 100% | finish no earlier than 2018-06-14 | S1 | 528h | 528h | FS_V2XIMP | 40 | SungDuck Chun; LG Electronics | Rel-16 | 79 | sungduck.chun@lge.com |  |
| 2728 | 1182 | Improvement of V2X service Handling |  | 29d | 2018-10-25 A | 2018-12-04 A | 100% | finish no earlier than 2018-12-04 | S1 | 232h | 232h | V2XIMP | 42 | SungDuck Chun; LG Electronics | Rel-16 | 82 | sungduck.chun@lge.com |  |
| 2729 | 1183 | **Application layer support for V2X services** |  | 848.25d? | 2017-12-15 A | 2020-03-12 A | 100% |  |  | 9616h | 9616h | V2XAPP | 41 | Niranth Amogh, Huawei Telecommunications India | Rel-16 | 84 | namogh@huawei.com |  |
| 2730 | 1183.1 | Study on V2XAPP |  | 196d? | 2017-12-15 A | 2018-09-14 A | 100% | finish no earlier than 2018-09-14 | S6 | 1568h | 1568h | FS_V2XAPP | 40 | Niranth Amogh, Huawei Telecommunications India | Rel-16 | 78 | namogh@huawei.com |  |
| 2731 | 1183.2 | Stage 2 of V2XAPP |  | 202d? | 2018-09-06 A | 2019-06-14 A | 100% | finish no earlier than 2019-06-14 | S6 | 1616h | 1616h | V2XAPP | 41 | Niranth Amogh, Huawei Telecommunications India | Rel-16 | 81 | namogh@huawei.com |  |
| 2732 | 1183.3 | **CT aspects of V2XAPP** |  | 291d | 2019-06-06 A | 2020-03-12 A | 100% |  | ct | 6432h | 6432h | V2XAPP | 43 | Herrero Veron, Christian (Huawei) | Rel-16 | 84 | Christian.Herrero at huawei.com |  |
| 2733 | 1183.3.1 | CT1 aspects of V2XAPP |  | 201d | 2019-06-06 A | 2020-03-12 A | 100% | finish no earlier than 2020-03-12 | C1 | 1608h | 1608h | V2XAPP | 43 | Herrero Veron, Christian (Huawei) | Rel-16 | 84 | Christian.Herrero at huawei.com |  |
| 2734 | 1183.3.2 | CT3 aspects of V2XAPP |  | 201d | 2019-06-06 A | 2020-03-12 A | 100% | finish no earlier than 2020-03-12 | C3 | 1608h | 1608h | V2XAPP | 43 | Herrero Veron, Christian (Huawei) | Rel-16 | 84 | Christian.Herrero at huawei.com |  |
| 2735 | 1183.3.3 | CT4 aspects of V2XAPP |  | 201d | 2019-06-06 A | 2020-03-12 A | 100% | finish no earlier than 2020-03-12 | C4 | 1608h | 1608h | V2XAPP | 43 | Herrero Veron, Christian (Huawei) | Rel-16 | 84 | Christian.Herrero at huawei.com |  |
| 2736 | 1184 | **Architecture enhancements for 3GPP support of advanced V2X services** |  | 1048d? | 2017-06-05 A | 2020-03-12 A | 100% |  |  | 12856h | 12856h | eV2XARC | 43 | LaeYoung Kim, LG Electronics | Rel-16 | 84 | laeyoung.kim@lge.com |  |
| 2737 | 1184.1 | Study on eV2XARC |  | 400d? | 2017-06-05 A | 2018-12-14 A | 100% | finish no earlier than 2018-12-14 | S2 | 3200h | 3200h | FS_eV2XARC | 39 | LaeYoung Kim, LG Electronics | Rel-16 | 76 | laeyoung.kim@lge.com | SP-170412 |
| 2738 | 1184.2 | Stage 2 of eV2XARC |  | 132d | 2018-12-13 A | 2019-06-14 A | 100% | finish no earlier than 2019-06-14 | S2 | 1056h | 1056h | eV2XARC | 42 | LaeYoung Kim, LG Electronics | Rel-16 | 82 | laeyoung.kim@lge.com |  |
| 2739 | 1184.3 | **CT aspects of eV2XARC** |  | 291d | 2019-06-06 A | 2020-03-12 A | 100% |  | ct | 8040h | 8040h | eV2XARC | 43 | Herrero Veron, Christian (Huawei) | Rel-16 | 84 | Christian.Herrero at huawei.com |  |
| 2740 | 1184.3.1 | CT1 aspects of eV2XARC |  | 201d | 2019-06-06 A | 2020-03-12 A | 100% | finish no earlier than 2020-03-12 | C1 | 1608h | 1608h | eV2XARC | 43 | Herrero Veron, Christian (Huawei) | Rel-16 | 84 | Christian.Herrero at huawei.com |  |
| 2741 | 1184.3.2 | CT3 aspects of eV2XARC |  | 201d | 2019-06-06 A | 2020-03-12 A | 100% | finish no earlier than 2020-03-12 | C3 | 1608h | 1608h | eV2XARC | 43 | Herrero Veron, Christian (Huawei) | Rel-16 | 84 | Christian.Herrero at huawei.com |  |
| 2742 | 1184.3.3 | CT4 aspects of eV2XARC |  | 201d | 2019-06-06 A | 2020-03-12 A | 100% | finish no earlier than 2020-03-12 | C4 | 1608h | 1608h | eV2XARC | 43 | Herrero Veron, Christian (Huawei) | Rel-16 | 84 | Christian.Herrero at huawei.com |  |
| 2743 | 1184.3.4 | CT6 aspects of eV2XARC |  | 201d | 2019-06-06 A | 2020-03-12 A | 100% | finish no earlier than 2020-03-12 | C6 | 1608h | 1608h | eV2XARC | 43 | Herrero Veron, Christian (Huawei) | Rel-16 | 84 | Christian.Herrero at huawei.com |  |
| 2744 | 1184.4 | Security Aspects of eV2XARC |  | 70d | 2019-12-06 A | 2020-03-12 A | 100% | finish no earlier than 2020-03-12 | S3 | 560h | 560h | eV2XARC | 44 | Dongjoo Kim, LG Electronics Inc. | Rel-16 | 86 | dongjoo7.kim@lge.com |  |
| 2745 | 1185 | Study on NR Vehicle-to-Everything (V2X) |  | 196d? | 2018-06-15 A | 2019-03-15 A | 100% | finish no earlier than 2019-03-15 | R1 | 1568h | 1568h | FS_NR_V2X | 41 | LG Electronics | Rel-16 | 80 |  |  |
| 2746 | 1186 | Study on V2X Media Handling and Interaction |  | 525d? | 2017-09-08 A | 2019-09-12 A | 100% | finish no earlier than 2019-09-12 | S4 | 4200h | 4200h | FS_mV2X | 39 | Jung, Kyunghun, Samsung Electronics Co., Ltd | Rel-16 | 77 | kyunghun.jung@samsung.com |  |
| 2747 | 1187 | Study on Security Aspects of 3GPP support for Advanced V2X Services |  | 265.88d | 2019-03-07 A | 2020-03-12 A | 100% | finish no earlier than 2020-03-12 | S3 | 2127h | 2127h | FS_eV2X_Sec | 42 | Joonwoong Kim, LG Electronics | Rel-16 | 83 | joonwoong.kim@lge.com |  |

Notes:
- 2717: RAN3 impact?¦16/1/19: WID:RP-181450->RP-182891¦26/3/19: WID:RP-182891->RP-190770; 26/6/19: WID:RP-190770->RP-191356; 14/1/20: WID:RP-191356->RP-192875
- 2718: RAN3 impact?¦26/3/19: WID:RP-182891->RP-190770; 28/7/20: 0%->100
- 2719: 26/3/19: WID:RP-182891->RP-190770; 6/1/21: 0%->100
- 2720: RAN3 impact?¦16/1/19: WID:RP-181451->RP-182902¦26/3/19: WID:RP-182902->RP-190757; 26/6/19: WID:RP-190757->RP-191576; 8/10/19: WID:RP-191576->RP-192313; 14/1/20: WID:RP-192313->RP-193224; 26/3/20: WID:RP-193224->RP-200293
- 2721: RAN3 impact?¦26/3/19: WID:RP-182902->RP-190757; 28/7/20: 0%->100
- 2722: 26/3/19: WID:RP-182902->RP-190757; 6/1/21: 0%->100
- 2723: Impacted TSs and TRs: 22.262
- 2724: 15/12/17: 22.824 added;¦15/12/17: 0%->25¦16/3/18: 25%->60¦10/9/18: 60%->95¦4/12/18: 95%->100 / Impacted TSs and TRs: New; 22.824
- 2725: 4/12/18: 0%->100 / Impacted TSs and TRs: 22.262; 22.261
- 2726: -
- 2727: 7/6/18: 0%->75¦10/9/18: 75%->95¦4/12/18: 95%->100 / Impacted TSs and TRs: 22.886
- 2728: 4/12/18: 0%->95¦14/3/19: 95%->100 / Impacted TSs and TRs: 22.186
- 2729: 7/12/18: 0%->25¦14/3/19: 25%->65 / Impacted TSs and TRs: New
- 2730: 16/3/18: 0%->45¦14/6/18: 45%->75¦10/9/18: 75%->95¦7/12/18: 95%->100
- 2731: 7/12/18: 0%->25¦14/3/19: 25%->65; 31/5/19: 65%->95; 13/9/19: 95%->100 / Impacted TSs and TRs: New
- 2732: 16/9/19: WID:CP-191153->CP-192077
- 2733: 13/9/19: 0%->10; 6/12/19: 10%->30; 26/3/20: 30%->65; 26/6/20: 65%->100 / Impacted TSs and TRs: 24.386; 27.007
- 2734: 13/9/19: 0%->10; 6/12/19: 10%->60; 26/3/20: 60%->100 / Impacted TSs and TRs: 29.122; 29.116
- 2735: 26/3/20: 0%->100 / Impacted TSs and TRs: 23.003; 23.008
- 2736: 14/3/19: 0%->30 / Impacted TSs and TRs: 23.501; 23.502; 23.503; 23.285
- 2737: 11/9/17: 0%->20¦15/12/17: Changed Rel-15->Rel-16¦16/3/18: WID:SP-170379->SP 170590¦16/3/18: 20%->25¦7/6/18: 25%->35¦10/9/18: 35%->58¦10/9/18: FCD:09/18->12/18¦2/10/18: WID:SP 170590->SP-180733¦7/12/18: 58%->88¦14/3/19: 88%->95; 31/5/19: 95%->100 / Impacted TSs and TRs: 23.786
- 2738: 14/3/19: 0%->30; 31/5/19: 30%->75; 26/6/19: 24.588 added;; 13/9/19: 75%->90; 6/12/19: 90%->96; 25/3/20: 96%->100 / Impacted TSs and TRs: 23.501; 23.502; 23.503; 23.285; 24.588
- 2739: 16/9/19: WID:CP-191154->CP-192078; 25/3/20: WID:CP-192078->CP-200291; 2/7/20: WID:CP-200291->CP-201343
- 2740: 13/9/19: 0%->30; 6/12/19: 30%->65; 26/3/20: 65%->95; 26/6/20: 95%->99; 13/9/20: 99%->100 / Impacted TSs and TRs: 23.122; 24.501; 24.301; 27.007
- 2741: 13/9/19: 0%->30; 6/12/19: 30%->80; 26/3/20: 80%->90; 26/6/20: 90%->100; 26/6/20: WID:CP-200291->CP-201199 / Impacted TSs and TRs: 29.512; 29.513; 29.514; 29.519; 29.122; 29.522
- 2742: 26/3/20: 0%->95; 26/6/20: 95%->100 / Impacted TSs and TRs: 23.003; 23.008; 29.502; 29.503; 29.505; 29.510; 29.518; 29.527; 29.571
- 2743: 26/3/20: 0%->100 / Impacted TSs and TRs: 31.102
- 2744: ; 6/12/19: 0%->10; 25/3/20: 10%->70; 26/6/20: 70%->95; 12/9/20: 95%->98; 5/12/20: 98%->99; 19/3/21: 99%->100 / Impacted TSs and TRs: 33.220; TS 33.536
- 2745: TR 38.8XX¦compare SA1 REL-15 SI FS_eV2X, RAN1 REL-15 SI FS_LTE_NR_V2X_eval, SA2 REL-16 SI FS_eV2XARC, SA1 REL-16 SI FS_V2XIMP¦26/3/19: WID:RP-181480->RP-190224¦26/3/19: 0%->100
- 2746: 15/12/17: 26.985 added;¦15/12/17: 0%->30¦16/3/18: 30%->50¦22/3/18: FCD:09/18->12/18¦7/6/18: 50%->60. 14/06/18: Moved from Rel-15¦10/9/18: 60%->80¦13/12/18: 80%->60¦13/12/18: FCD:12/18->09/19¦12/3/19: 60%->70; 31/5/19: 70%->80; 26/6/20: 80%->100 / Impacted TSs and TRs: New; 26.985
- 2747: 31/5/19: 0%->20; 13/9/19: 20%->60; 13/9/19: FCD:05/09/2019->12/20; 6/12/19: 60%->75; 6/12/19: FCD:12/12/2019->03/20; 26/6/20: 75%->100 / Impacted TSs and TRs: New

| ID | WBS | Task | Type | Duration | Start | Finish | Complete | Actual finish | Constraint | Resources | Work | Actual work | Acronym | PCG approved | WI rapporteur name | Release | TSG approved | WI rapporteur e-mail | Status Report | Impacted TSs and TRs |
| --- | --- | --- | --- | --- | --- | --- | --- | --- | --- | --- | --- | --- | --- | --- | --- | --- | --- | --- | --- | --- |
| 2748 | 1188 | **5G V2X with NR sidelink** |  | 2189d | 2019-03-01 A | 2024-12-12 | 100% | 2025-06-06 |  | R1 | 32423h | 32423h | 5G_V2X_NRSL | 42 | LG Electronics | Rel-16 | 83 |  |  |  |
| 2749 | 1188.1 | Core part: 5G V2X with NR sidelink |  | 261d | 2019-03-01 A | 2020-02-28 A | 100% |  | finish no earlier than 2020-03-01 | R1 | 2088h | 2088h | 5G_V2X_NRSL-Core | 42 | LG Electronics | Rel-16 | 83 |  |  |  |
| 2750 | 1188.2 | Perf. part: 5G V2X with NR sidelink |  | 403d | 2019-03-01 A | 2020-09-15 A | 100% |  | finish no earlier than 2020-09-15 | R4 | 3224h | 3224h | 5G_V2X_NRSL-Perf | 42 | LG Electronics | Rel-16 | 83 |  |  |  |
| 2751 | 1188.3 | UE Conformance Test Aspects - 5G V2X with NR sidelink |  | 1874.88d | 2020-06-22 A | 2025-06-06 A | 100% |  | finish no earlier than 2025-06-06 | R5 | 14999h | 14999h | 5G_V2X_NRSL_eV2XARC-UEConTest | 45 | Xuesong Wang, Huawei Technologies. Co., Ltd | Rel-16 | 88 | wangxuesong743@huawei.com | RP-250440 |  |
| 2752 | 1189 | 5G Location and Positionning Services | milestone | 0d? | 2017-06-05 A | 2017-06-05 A | 100% |  |  |  |  |  |  |  |  | Rel-16 |  |  |  |  |
| 2753 | 1190 | **5G positioning services** |  | 577.75d? | 2017-06-05 A | 2018-12-14 A | 100% |  |  | S1 | 6464h | 6464h | 5G_HYPOS | 41 | Ries, Lionel, ESA | Rel-16 | 80 | lionel.ries at esa.int |  | 22.261 |
| 2754 | 1190.1 | Study on positioning use cases |  | 270d? | 2017-06-05 A | 2018-06-15 A | 100% |  | finish no earlier than 2018-06-15 | S1 | 2160h | 2160h | FS_5G_HYPOS | 39 | Ries, Lionel, ESA | Rel-16 | 76 | lionel.ries@esa.int |  | 22.872 |
| 2755 | 1190.2 | Stage 1 of 5G_HYPOS |  | 138d? | 2018-06-06 A | 2018-12-14 A | 100% |  | finish no earlier than 2018-12-14 | S1 | 1104h | 1104h | 5G_HYPOS | 41 | Ries, Lionel, ESA | Rel-16 | 80 | lionel.ries at esa.int |  | 22.261 |
| 2756 | 1191 | **Enhancement to the 5GC LoCation Services** |  | 943.5d? | 2017-12-15 A | 2020-06-12 A | 100% |  |  |  | 14152h | 14152h | 5G_eLCS | 42 | Ming Ai, CATT | Rel-16 | 83 | aiming@catt.cn |  | 23.501; 23.502 |
| 2757 | 1191.1 | Study on Enhancement to the 5GC Location Services |  | 325d? | 2017-12-15 A | 2019-03-14 A | 100% |  | finish no earlier than 2019-03-14 | S2 | 2600h | 2600h | FS_eLCS | 40 | Ming Ai, CATT | Rel-16 | 78 | aiming@catt.cn |  | new 23.731 |
| 2758 | 1191.2 | Study on Security of the enhancement to the 5GC location services |  | 332d? | 2018-09-06 A | 2019-12-13 A | 100% |  | finish no earlier than 2019-12-13 | S3 | 2656h | 2656h | FS_eLCS_Sec | 41 | Wei Zhou, CATT | Rel-16 | 81 | zhouwei@catt.cn |  | New |
| 2759 | 1191.3 | Stage 2 of 5G_eLCS |  | 136d | 2018-12-13 A | 2019-06-20 A | 100% |  | start no earlier than 2018-12-13 | S2 | 1088h | 1088h | 5G_eLCS | 42 | Ming Ai, CATT | Rel-16 | 82 | aiming@catt.cn |  | 23.501; 23.502; 29.515 |
| 2760 | 1191.4 | **CT aspects of 5G_eLCS** |  | 283.75d | 2019-03-07 A | 2019-12-05 A | 100% |  |  | ct | 6272h | 6272h | 5G_eLCS | 42 | Tingfang Tang, CATT | Rel-16 | 83 | tangtingfang@catt.cn |  |  |
| 2761 | 1191.4.1 | CT1 aspects of 5G_eLCS |  | 196d | 2019-03-07 A | 2019-12-05 A | 100% |  | start no earlier than 2019-03-07 | C1 | 1568h | 1568h | 5G_eLCS | 42 | Tingfang Tang, CATT | Rel-16 | 83 | tangtingfang@catt.cn |  | 24.501; 27.007 |
| 2762 | 1191.4.2 | CT3 aspects of 5G_eLCS |  | 196d | 2019-03-07 A | 2019-12-05 A | 100% |  | start no earlier than 2019-03-07 | C3 | 1568h | 1568h | 5G_eLCS | 42 | Tingfang Tang, CATT | Rel-16 | 83 | tangtingfang@catt.cn |  | 29.522; 29.122 |
| 2763 | 1191.4.3 | CT4 aspects of 5G_eLCS |  | 196d | 2019-03-07 A | 2019-12-05 A | 100% |  | start no earlier than 2019-03-07 | C4 | 1568h | 1568h | 5G_eLCS | 42 | Tingfang Tang, CATT | Rel-16 | 83 | tangtingfang@catt.cn |  | 24.080; 29.518; 29.572; 29.503; 29.505 |
| 2764 | 1191.5 | Security of 5G_eLCS |  | 192d | 2019-09-19 A | 2020-06-12 A | 100% |  | finish no earlier than 2020-06-12 | S3 | 1536h | 1536h | 5G_eLCS | 43 | Wei Zhou, CATT | Rel-16 | 85 | zhouwei@catt.cn |  | 33.501 |
| 2765 | 1192 | **NR positioning support** |  | 1980.12d? | 2018-06-15 A | 2023-09-08 A | 100% |  |  | R1 | 25192h | 25192h | NR_pos | 42 | Intel | Rel-16 | 83 |  |  |  |
| 2766 | 1192.1 | Study on NR positioning support |  | 196d? | 2018-06-15 A | 2019-03-15 A | 100% |  | finish no earlier than 2019-03-15 | R1 | 1568h | 1568h | FS_NR_pos | 41 | Intel | Rel-16 | 80 |  |  |  |
| 2767 | 1192.2 | Study on local NR positioning in NG-RAN |  | 206d | 2019-03-01 A | 2019-12-13 A | 100% |  | finish no earlier than 2019-12-15 | R3 | 1648h | 1648h | FS_NR_local_pos | 42 | CMCC | Rel-16 | 83 |  |  | 38.856 |
| 2768 | 1192.3 | Core part: NR positioning support |  | 261d | 2019-03-01 A | 2020-02-28 A | 100% |  | finish no earlier than 2020-03-01 | R1 | 2088h | 2088h | NR_pos-Core | 42 | Intel | Rel-16 | 83 |  |  |  |
| 2769 | 1192.4 | Perf. part: NR positioning support |  | 403d | 2019-03-01 A | 2020-09-15 A | 100% |  | finish no earlier than 2020-09-15 | R4 | 3224h | 3224h | NR_pos-Perf | 42 | Intel | Rel-16 | 83 |  |  |  |
| 2770 | 1192.5 | UE Conformance Test Aspects - NR positioning support |  | 716d | 2020-12-14 A | 2023-09-08 A | 100% |  | finish no earlier than 2023-09-08 | R5 | 5728h | 5728h | NR_pos-UEConTest | 46 | Xiaoyang TIAN, CATT | Rel-16 | 90 | tianxiaoyang@catt.cn | RP-231835 |  |
| 2771 | 1193 | UE radio capability signalling optimization | milestone | 0d? | 2018-06-06 A | 2018-06-06 A | 100% |  |  |  |  |  |  |  |  | Rel-16 |  |  |  |  |

Notes:
- 2748: 26/6/19: WID:RP-190766->RP-190984; 8/10/19: WID:RP-190984->RP-191723; 26/3/20: WID:RP-191723->RP-200129
- 2749: 28/7/20: 0%->100
- 2750: 2/7/21: 0%->100
- 2751: 8/10/20: 0%->5; 8/4/21: 5%->11; 2/7/21: 11%->18; 22/3/22: Compl:18%->43%; ; 5/4/22: WID:RP-200894->RP-220744 20/6/22: Rapporteur: Huawei->Xuesong Wang, Huawei Technologies. Co., Ltd; Rap eMail: ->wangxuesong743@huawei.com12/7/22: WID:RP-20089...; 9/1...; 11/9/25: WID: RP-251783->RP-200894; Stat Rep: RP-251479->RP-250440;
- 2752: -
- 2754: 11/9/17: 0%->10¦15/12/17: 10%->50¦15/12/17: FCD:03/18->06/18¦16/3/18: 50%->75¦7/6/18: 75%->90¦10/9/18: 90%->100
- 2755: 10/9/18: 0%->50¦10/9/18: FCD:09/18->12/18¦4/12/18: 50%->100
- 2757: 16/3/18: 0%->15¦7/6/18: 15%->45¦10/9/18: 45%->55¦10/9/18: FCD:12/18->03/19¦2/10/18: WID:SP-170937->SP-180734¦7/12/18: 55%->100
- 2758: 7/12/18: 0%->5¦20/3/19: 5%->50; 31/5/19: 50%->80; 13/9/19: 80%->100
- 2759: 14/3/19: 0%->45; 31/5/19: 45%->85; 26/6/19: 29.515 added;; 13/9/19: 85%->100
- 2760: 17/9/19: WID:CP-190014->CP-192260
- 2761: 3/6/19: WID:CP-190190->CP-191064; 13/9/19: 0%->40; 6/12/19: 40%->90; 26/6/20: 90%->99; 13/9/20: 99%->100
- 2762: 3/6/19: WID:CP-190190->CP-191064; 26/3/20: 0%->25; 26/6/20: 25%->85
- 2763: 31/5/19: 0%->10; 3/6/19: WID:CP-190190->CP-191064; 13/9/19: 10%->20; 6/12/19: 20%->90; 26/3/20: 90%->98; 26/6/20: 98%->100
- 2764: ; 6/12/19: 0%->75; 6/12/19: FCD:12/12/2019->03/20; 25/3/20: FCD:12/03/2020->06/20; 26/6/20: 75%->100
- 2765: 26/6/19: WID:RP-190752->RP-191156; 14/1/20: WID:RP-191156->RP-192581
- 2766: TR 38.8xx¦26/3/19: 0%->100
- 2767: 8/10/19: WID:RP-190754->RP-191774; 8/10/19: 38.856 added;; 14/1/20: 0%->100
- 2768: 25/9/20: 0%->100
- 2769: 2/7/21: 0%->100
- 2770: tested: REL-16 WI NR_pos-Core ; 8/4/21: 0%->5; 29/9/21: WID:RP-202727->RP-212227; 22/3/22: Compl:5%->54%; ; 20/6/22: Rapporteur: CATT->Xiaoyang TIAN, CATT; Rap eMail: ->tianxiaoyang@catt.cn12/7/22: WID:RP-212227->RP-221450 ; ;...; 9/12/22: FCD:22/12...; 6/9/23: FCD:09/09/2023->08/09/2023; Compl:95%->100%; Stat Rep: RP-230393->RP-231835;
- 2771: -

| ID | WBS | Task | Type | Duration | Start | Finish | Complete | Constraint | Resources | Work | Actual work | Acronym | PCG approved | Impacted TSs and TRs | WI rapporteur name | WI rapporteur e-mail | Release | TSG approved | Status Report |
| --- | --- | --- | --- | --- | --- | --- | --- | --- | --- | --- | --- | --- | --- | --- | --- | --- | --- | --- | --- |
| 2772 | 1194 | **Optimisations on UE radio capability signalling** |  | 669d? | 2018-06-06 A | 2020-03-12 A | 100% |  |  | 8063h | 8063h | RACS | 43 | 23.501; 23.502; 23.401 | Haris Zisimopoulos | harisz@qti.qualcomm.com | Rel-16 | 84 |  |
| 2773 | 1194.1 | Study on RACS |  | 138d? | 2018-06-06 A | 2018-12-14 A | 100% | finish no earlier than 2018-12-14 | S2 | 1104h | 1104h | FS_RACS | 41 | New | Haris Zisimopoulos, Qualcomm Incorporated | harisz@qti.qualcomm.com | Rel-16 | 80 |  |
| 2774 | 1194.2 | Stage 2 of RACS |  | 65.88d | 2019-03-07 A | 2019-06-06 A | 100% |  | S2 | 527h | 527h | RACS | 42 | 23.501; 23.502; 23.401; 29.673 | Haris Zisimopoulos | harisz@qti.qualcomm.com | Rel-16 | 83 |  |
| 2775 | 1194.3 | **CT aspects of RACS** |  | 291d | 2019-06-06 A | 2020-03-12 A | 100% |  | ct | 6432h | 6432h | RACS | 43 |  | Waqar Zia; Qualcomm Incorporated | wzia@qti.qualcomm.com | Rel-16 | 84 |  |
| 2776 | 1194.3.1 | CT1 aspects of RACS |  | 201d | 2019-06-06 A | 2020-03-12 A | 100% | finish no earlier than 2020-03-12 | C1 | 1608h | 1608h | RACS | 43 | 24.301; 24.501; 24.368; 27.007 | Waqar Zia; Qualcomm Incorporated | wzia@qti.qualcomm.com | Rel-16 | 84 |  |
| 2777 | 1194.3.2 | CT3 aspects of RACS |  | 201d | 2019-06-06 A | 2020-03-12 A | 100% | finish no earlier than 2020-03-12 | C3 | 1608h | 1608h | RACS | 43 | 29.122; 29.522 | Waqar Zia; Qualcomm Incorporated | wzia@qti.qualcomm.com | Rel-16 | 84 |  |
| 2778 | 1194.3.3 | CT4 aspects of RACS |  | 201d | 2019-06-06 A | 2020-03-12 A | 100% | finish no earlier than 2020-03-12 | C4 | 1608h | 1608h | RACS | 43 | 23.003; 23.008; 29.230; 29.274; 29.510; 29.518 | Waqar Zia; Qualcomm Incorporated | wzia@qti.qualcomm.com | Rel-16 | 84 |  |
| 2779 | 1195 | **Optimisations on UE radio capability signalling – NR/E-UTRA Aspects** |  | 1784.38d? | 2018-06-15 A | 2023-03-03 A | 100% |  | R2 | 19664h | 19664h | RACS-RAN | 42 |  | MediaTek |  | Rel-16 | 83 |  |
| 2780 | 1195.1 | Study on optimisations on UE radio capability signalling – NR/E-UTRA Aspects |  | 196d? | 2018-06-15 A | 2019-03-15 A | 100% | finish no earlier than 2019-03-15 | R2 | 1568h | 1568h | FS_RACS_RAN | 41 | 37.873 | MediaTek |  | Rel-16 | 80 |  |
| 2781 | 1195.2 | Core part: Optimisations on UE radio capability signalling – NR/E-UTRA Aspects |  | 261d | 2019-03-01 A | 2020-02-28 A | 100% | finish no earlier than 2020-03-01 | R2 | 2088h | 2088h | RACS-RAN-Core | 42 |  | MediaTek |  | Rel-16 | 83 |  |
| 2782 | 1195.3 | UE Conformance Test Aspects - Optimisations on UE radio capability signalling - NR/E-UTRA Aspects |  | 772d | 2020-03-19 A | 2023-03-03 A | 100% | finish no earlier than 2023-03-03 | R5 | 6176h | 6176h | RACS-UEConTest | 45 |  | Yogesh Tugnawat, Qualcomm | yogesht[at]qti.qualcomm.com | Rel-16 | 88 | RP-230098 |
| 2783 | 1196 | Study on solutions for NR to support non-terrestrial networks (NTN) |  | 391d? | 2018-06-15 A | 2019-12-13 A | 100% | finish no earlier than 2019-12-15 | R3 | 3128h | 3128h | FS_NR_NTN_solutions | 41 | 38.821 | Thales |  | Rel-16 | 80 |  |
| 2784 | 1197 | Enablers for Network Automation Architecture for 5G |  | 1d? | 2017-06-05 A | 2017-06-05 A | 100% | finish no earlier than 2017-06-05 |  |  |  |  |  |  |  |  | Rel-16 |  |  |
| 2785 | 1198 | **Enablers for Network Automation for 5G** |  | 1048d? | 2017-06-05 A | 2020-03-12 A | 100% |  |  | 10128h | 10128h | eNA | 42 | 23.501; 23.502; 23.503 | Xiaobo Wu, Huawei Technologies | wuxiaobo@huawei.com | Rel-16 | 83 |  |
| 2786 | 1198.1 | Study of enablers for Network Automation for 5G |  | 400d? | 2017-06-05 A | 2018-12-14 A | 100% | finish no earlier than 2018-12-14 | S2 | 3200h | 3200h | FS_eNA | 39 | new 23.791 | Xiaobo Wu, Huawei Technologies | wuxiaobo@huawei.com | Rel-16 | 76 |  |
| 2787 | 1198.2 | Stage 2 of eNA |  | 138d | 2018-12-06 A | 2019-06-17 A | 100% | start no earlier than 2018-12-06 | S2 | 1104h | 1104h | eNA | 42 | 23.501; 23.502; 23.503; 29.517 | Xiaobo Wu, Huawei Technologies | wuxiaobo@huawei.com | Rel-16 | 82 |  |
| 2788 | 1198.3 | **CT aspects of eNA** |  | 385.25d | 2019-03-07 A | 2020-03-12 A | 100% |  | ct | 5824h | 5824h | eNA | 42 |  | Yali Yan, Huawei | yanyali@huawei.com | Rel-16 | 83 |  |
| 2789 | 1198.3.1 | CT3 aspects of eNA |  | 266d | 2019-03-07 A | 2020-03-12 A | 100% | finish no earlier than 2020-03-12 | C3 | 2128h | 2128h | eNA | 42 | 29.122; 29.508; 29.514; 29.520; 29.522; 29.523; 29.554 | Yali Yan, Huawei | yanyali@huawei.com | Rel-16 | 83 |  |
| 2790 | 1198.3.2 | CT4 aspects of eNA |  | 196d | 2019-03-07 A | 2019-12-05 A | 100% |  | C4 | 1568h | 1568h | eNA | 42 | 29.244; 29.510; 29.518; 29.503; 29.505 | Yali Yan, Huawei | yanyali@huawei.com | Rel-16 | 83 |  |
| 2791 | 1199 | Wireless and Wireline Convergence Enhancement | milestone | 0d? | 2017-06-05 A | 2017-06-05 A | 100% |  |  |  |  |  |  |  |  |  | Rel-16 |  |  |
| 2792 | 1200 | Study on the Wireless and Wireline Convergence for the 5G system architecture |  | 400d? | 2017-06-05 A | 2018-12-14 A | 100% | finish no earlier than 2018-12-14 | S2 | 3200h | 3200h | FS_5WWC | 39 | 23.716 | Marco Spini, Huawei Technologies | m.spini@huawei.com | Rel-16 | 76 |  |
| 2793 | 1201 | Study on the security of the Wireless and Wireline Convergence for the 5G system architecture |  | 332d? | 2018-06-06 A | 2019-09-12 A | 100% | finish no earlier than 2019-09-12 | S3 | 2656h | 2656h | FS_5WWC_SEC | 41 | New; 33.807 | He Li, Huawei Technologies | LIHE2@HUAWEI.COM | Rel-16 | 80 |  |
| 2794 | 1202 | **Wireless and Wireline Convergence for the 5G system architecture** |  | 574.75d | 2018-12-06 A | 2020-06-12 A | 100% |  |  | 14432h | 14432h | 5WWC | 42 | 23.501; 23.502; 23.503 | Marco Spini, Huawei Technologies | m.spini@huawei.com | Rel-16 | 83 |  |
| 2795 | 1202.1 | Stage 2 of 5WWC |  | 136d | 2018-12-06 A | 2019-06-13 A | 100% |  | S2 | 1088h | 1088h | 5WWC | 42 | 23.501; 23.502; 23.503 | Marco Spini, Huawei Technologies | m.spini@huawei.com | Rel-16 | 82 |  |

Notes:
- 2772: 26/6/19: WID:SP-190180->RP-191460
- 2773: 10/9/18: 0%->40¦7/12/18: 40%->70¦14/3/19: 70%->100
- 2774: 31/5/19: 0%->90; 26/6/19: 29.673 added;; 13/9/19: 90%->100
- 2775: 17/9/19: WID:CP-191061->CP-192207; 25/3/20: WID:CP-192207->CP-200058
- 2776: 13/9/19: 0%->50; 6/12/19: 50%->80; 26/3/20: 80%->100
- 2777: 13/9/19: 0%->50; 6/12/19: 50%->90; 26/3/20: 90%->100
- 2778: 13/9/19: 0%->20; 6/12/19: 20%->75; 26/3/20: 75%->90; 26/6/20: 90%->100
- 2779: 26/3/20: WID:RP-190657->RP-200164
- 2780: TR 37.873¦related SA2 SI FS_RACS was started at SA #80 ¦6/8/18: 37.873 added;¦26/3/19: 0%->100
- 2781: 26/6/19: WID:RP-190657->RP-191088; 28/7/20: 0%->100
- 2782: 8/10/20: 0%->5; 7/4/21: WID:RP-201153->RP-210714; 8/4/21: 5%->25; 8/4/21: FCD:19/03/2021->09/21; 2/7/21: 25%->50; 22/3/22: ; 5/4/22: WID:RP-210714->RP-220434 ; 9/12/22: Acronym:RACS-UEConTest->NG_RAN_PRN_Vertical_LAN-UEConTest; FCD:22/12/2022->01/03...
- 2783: TR 38.xx1¦compare REL-15 SI FS_NR_nonterr_nw¦26/3/19: WID:RP-181370->RP-190710; 14/1/20: 0%->100
- 2784: -
- 2786: 16/3/18: FCD:09/18->06/18¦16/3/18: 0%->15¦7/6/18: 15%->30¦15/6/18: WID:SP-170383->SP-180613¦15/6/18: FCD:06/18->09/18¦10/9/18: 30%->50¦10/9/18: FCD:09/18->12/18¦2/10/18: WID:SP-180613->SP-180792¦7/12/18: 50%->90¦14/3/19: 90%->94; 31/5/19: 94%->100
- 2787: 14/3/19: 0%->50; 31/5/19: 50%->85; 26/6/19: 29.517 added;; 13/9/19: 85%->92; 6/12/19: 92%->97; 25/3/20: 97%->100
- 2788: 3/6/19: WID:CP-190194->CP-191111; 17/9/19: WID:CP-191111->CP-192259
- 2789: 31/5/19: 0%->20; 3/6/19: WID:CP-190194->CP-191111; 13/9/19: 20%->55; 6/12/19: 55%->85; 6/12/19: FCD:05/12/2019->03/20; 26/3/20: 85%->100
- 2790: 31/5/19: 0%->20; 3/6/19: WID:CP-190194->CP-191111; 13/9/19: 20%->25; 6/12/19: 25%->90; 26/3/20: 90%->100
- 2791: -
- 2792: 11/9/17: 0%->15¦15/12/17: Changed Rel-15->Rel-16¦16/3/18: 15%->25¦7/6/18: 25%->35¦10/9/18: 35%->60¦10/9/18: FCD:06/18->12/18¦7/12/18: 60%->100
- 2793: 6/8/18: 33.807 added;¦10/9/18: 0%->5¦7/12/18: 5%->30¦20/3/19: 30%->60¦20/3/19: FCD:019->09/19; 31/5/19: 60%->75; 8/10/19: 75%->100
- 2795: 14/3/19: 0%->50; 31/5/19: 50%->85; 13/9/19: 85%->100

| ID | WBS | Task | Duration | Start | Finish | Complete | Constraint | Resources | Work | Actual work | Acronym | PCG approved | WI rapporteur name | WI rapporteur e-mail | Release | TSG approved | Status Report |
| --- | --- | --- | --- | --- | --- | --- | --- | --- | --- | --- | --- | --- | --- | --- | --- | --- | --- |
| 2796 | 1202.2 | **CT aspects of 5WWC** | 385.25d | 2019-03-07 A | 2020-03-12 A | 100% |  | ct | 7952h | 7952h | 5WWC | 42 | Herrero Veron, Christian (Huawei) | Christian.Herrero at huawei.com | Rel-16 | 83 |  |
| 2797 | 1202.2.1 | CT1 aspects of 5WWC | 266d | 2019-03-07 A | 2020-03-12 A | 100% | finish no earlier than 2020-03-12 | C1 | 2128h | 2128h | 5WWC | 42 | Herrero Veron, Christian (Huawei) | Christian.Herrero at huawei.com | Rel-16 | 82 |  |
| 2798 | 1202.2.2 | CT3 aspects of 5WWC | 266d | 2019-03-07 A | 2020-03-12 A | 100% | finish no earlier than 2020-03-12 | C3 | 2128h | 2128h | 5WWC | 42 | Herrero Veron, Christian (Huawei) | Christian.Herrero at huawei.com | Rel-16 | 82 |  |
| 2799 | 1202.2.3 | CT4 aspects of 5WWC | 196d | 2019-06-13 A | 2020-03-12 A | 100% | finish no earlier than 2020-03-12 | C4 | 1568h | 1568h | 5WWC | 42 | Herrero Veron, Christian (Huawei) | Christian.Herrero at huawei.com | Rel-16 | 82 |  |
| 2800 | 1202.3 | Security of 5WWC | 192d | 2019-09-19 A | 2020-06-12 A | 100% | finish no earlier than 2020-06-12 | S3 | 1536h | 1536h | 5WWC | 43 | He Li, Huawei Technologies | lihe2@huawei.com | Rel-16 | 85 |  |
| 2801 | 1202.4 | Charging Aspect for 5WWC | 70d | 2019-12-06 A | 2020-03-12 A | 100% | finish no earlier than 2020-03-12 | S5 | 560h | 560h | 5WWC | 44 | ZHU, Lei, Huawei | lei.zhu@huawei.com | Rel-16 | 86 |  |
| 2802 | 1202.5 | **NG interface usage for WWC** | 298.25d | 2019-03-01 A | 2019-12-13 A | 100% |  | R3 | 3296h | 3296h | 5WWC-NG_interface | 42 | Huawei |  | Rel-16 | 83 |  |
| 2803 | 1202.5.1 | Core part: NG interface usage for WWC | 206d | 2019-03-01 A | 2019-12-13 A | 100% | finish no earlier than 2019-12-15 | R3 | 1648h | 1648h | 5WWC-NG_interface-Core | 42 | Huawei |  | Rel-16 | 83 |  |
| 2804 | 1203 | Mission Critical, Public Warning, Railways and Maritime | 1d? | 2016-09-19 A | 2016-09-19 A | 100% |  |  |  |  |  |  |  |  | Rel-16 |  |  |
| 2805 | 1204 | Study on MC services access aspects | 325d? | 2018-03-15 A | 2019-06-12 A | 100% | finish no earlier than 2019-06-12 | S6 | 2600h | 2600h | FS_MCSAA | 40 | Joakim Åkesson, Ericsson | Joakim.akesson@ericsson.com | Rel-16 | 79 |  |
| 2806 | 1205 | Study into discreet listening and logging for mission critical services | 266d? | 2018-06-06 A | 2019-06-12 A | 100% | finish no earlier than 2019-06-12 | S6 | 2128h | 2128h | FS_MCLOG | 41 | Chater-Lea, David, Motorola Solutions | david.chater-lea@motorolasolutions.com | Rel-16 | 80 |  |
| 2807 | 1206 | **Enhanced Mission Critical Push-to-talk architecture phase 2** | 101.5d | 2019-12-06 A | 2020-03-12 A | 100% |  | S6 | 1680h | 1680h | enh2MCPTT | 41 | Dom Lazara; Motorola Solutions | Dom.Lazara@motorolasolutions.com | Rel-16 | 80 |  |
| 2808 | 1206.1 | Stage 2 of enh2MCPTT | 101.5d | 2019-12-06 A | 2020-03-12 A | 100% |  | S6 | 560h | 560h | enh2MCPTT | 41 | Dom Lazara; Motorola Solutions | Dom.Lazara@motorolasolutions.com | Rel-16 | 80 |  |
| 2809 | 1206.2 | CT aspects of enh2MCPTT | 70d | 2019-12-06 A | 2020-03-12 A | 100% | finish no earlier than 2020-03-12 | C1 | 560h | 560h | enh2MCPTT-CT | 44 | Mike Dolan, FirstNet | michael.dolan@firstnet.gov | Rel-16 | 86 |  |
| 2810 | 1207 | **Enhancements to Functional architecture and information flows for Mission Critical Data** | 669d? | 2018-06-06 A | 2020-03-12 A | 100% |  | S6 | 7928h | 7928h | eMCData2 | 42 | Shih, Jerry, AT&T | jerry.shih@att.com | Rel-16 | 83 |  |
| 2811 | 1207.1 | Stage 2 of eMCData2 | 268d? | 2018-06-06 A | 2019-06-14 A | 100% | finish no earlier than 2019-06-14 | S6 | 2144h | 2144h | eMCData2 | 41 | Shih, Jerry, AT&T | jerry.shih@att.com | Rel-16 | 80 |  |
| 2812 | 1207.2 | CT aspects of eMCData2 | 261d? | 2019-03-14 A | 2020-03-12 A | 100% | finish no earlier than 2020-03-12 | C1 | 2088h | 2088h | eMCData2 | 42 | Val Oprescu (AT&T) | vo4887@att.com | Rel-16 | 83 |  |
| 2813 | 1208 | **MCData File Distribution support over xMB** | 573.75d? | 2018-09-06 A | 2020-03-12 A | 100% |  |  | 2584h | 2584h | MC_XMB | 43 | Thiénot Cédric, Expway | cedric.thienot@expway.com | Rel-16 | 85 |  |
| 2814 | 1208.1 | Stage 2 of MC_XMB | 197d? | 2018-09-06 A | 2019-06-07 A | 100% | finish no earlier than 2019-06-07 | S4 | 1576h | 1576h | MC_XMB | 41 | Thiénot Cédric, Expway | cedric.thienot@expway.com | Rel-16 | 81 |  |
| 2815 | 1208.2 | CT aspects of MC_XMB | 126d | 2019-09-19 A | 2020-03-12 A | 100% | finish no earlier than 2020-03-12 | C3 | 1008h | 1008h | MC_XMB-CT | 43 | Wenliang Xu, Ericsson | wenliang.xu@ericsson.com | Rel-16 | 85 |  |
| 2816 | 1209 | Protocol enhancements for Mission Critical Services | 337d? | 2018-09-06 A | 2019-12-20 A | 100% | finish no earlier than 2019-12-20 | C1 | 2696h | 2696h | MCProtoc16 | 41 | AXELL, Jörgen | jorgen.axell@ericsson.com | Rel-16 | 81 |  |
| 2817 | 1210 | Conformance Test Aspects - Protocol enhancements for Mission Critical Services for Rel-16 (MCPTT, MCVideo, MCData) | 526d | 2022-09-08 A | 2024-09-09 A | 100% | finish no earlier than 2024-09-24 | R5 | 4208h | 4208h | MCProtoc16_enh2MCPTT_eMCData2-ConTest | 49 | Jason Kahn, NIST | jason.kahn@nist.gov | Rel-16 | 97 | RP-242140 |
| 2818 | 1211 | **MBMS APIs for Mission Critical Services** | 671d? | 2017-06-05 A | 2019-03-14 A | 100% |  | S6 | 7488h | 7488h | MBMSAPI_MCS | 41 | Ling Zhang, TD Tech Ltd. | zhangling@td-tech.com | Rel-16 | 80 |  |
| 2819 | 1211.1 | Study on MBMS APIs for MC Services | 270d? | 2017-06-05 A | 2018-06-15 A | 100% | finish no earlier than 2018-06-15 | S6 | 2160h | 2160h | FS_MBMSAPI_MC | 39 | Ling Zhang, TD Tech Ltd | zhangling@td-tech.com | Rel-16 | 76 |  |
| 2820 | 1211.2 | Stage 2 of MBMS APIs for MC Services | 202d? | 2018-06-06 A | 2019-03-14 A | 100% | finish no earlier than 2019-03-14 | S6 | 1616h | 1616h | MBMSAPI_MCS | 41 | Ling Zhang, TD Tech Ltd. | zhangling@td-tech.com | Rel-16 | 80 |  |

Notes:
- 2796: 3/6/19: WID:CP-190200->CP-191156. Confusion with UID (was 829910 instead of 830015); 17/9/19: WID:CP-191156->CP-192079; 9/12/19: WID:CP-192079->CP-193145; 2/7/20: WID:CP-193145->CP-192079
- 2797: 31/5/19: 0%->30; 3/6/19: WID:CP-190200->CP-191156; 3/6/19: FCD:05/12/2019->03/20; 13/9/19: 30%->60; 6/12/19: 60%->80; 26/3/20: 80%->95; 30/6/20: 95%->100 / Impacted TSs and TRs: 24.501; 24.502; 24.526
- 2798: 31/5/19: 0%->15; 3/6/19: WID:CP-190200->CP-191156; 3/6/19: FCD:05/12/2019->03/20; 13/9/19: 15%->50; 6/12/19: 50%->70; 6/12/19: WID:CP-192079->CP-193145; 26/3/20: 70%->95; 26/6/20: 95%->100 / Impacted TSs and TRs: 29.512; 29.513; 29.514; 29.507; 29.122; 29.522
- 2799: 3/6/19: WID:CP-190200->CP-191156; 3/6/19: FCD:05/12/2019->03/20; 13/9/19: 0%->5; 6/12/19: 5%->60; 26/3/20: 60%->95; 26/6/20: 95%->100 / Impacted TSs and TRs: 23.003; 29.518; 29.502; 29.509; 29.244; 29.503; 29.571; 29.505
- 2800: 13/9/19: 0%->100; 8/10/19: 100%->0; 6/12/19: 0%->90; 6/12/19: FCD:12/12/2019->03/20; 25/3/20: FCD:12/03/2020->06/20; 25/3/20: 90%->95; 26/6/20: 95%->100 / Impacted TSs and TRs: 33.501
- 2801: ; 26/3/20: 0%->35; 28/6/20: 35%->100 / Impacted TSs and TRs: 32.240; 32.255; 32.291; 32.298
- 2803: 26/6/19: WID:RP-190772->RP-190999; 28/7/20: 0%->100
- 2804: -
- 2805: 19/4/18: 0%->5¦14/6/18: 5%->15¦15/6/18: WID:SP-180163->SP-180385¦15/6/18: FCD:12/18->03/19¦6/8/18: 23.778 added;¦10/9/18: 15%->25¦7/12/18: 25%->70¦14/12/18: WID:SP-180385->SP-181135¦14/3/19: FCD:03/19->06/19¦14/3/19: 70%->75; 31/5/19: 75%->100 / Impacted TSs and TRs: new 23.xxx; 23.778
- 2806: 6/8/18: 23.784 added;¦10/9/18: 0%->10¦7/12/18: 10%->50¦7/12/18: FCD:03/19->06/19¦14/12/18: WID:SP-180384->SP-181138¦14/3/19: 50%->75; 31/5/19: 75%->100 / Impacted TSs and TRs: New; 23.784
- 2807: 10/9/18: 0%->5¦7/12/18: 5%->35¦14/3/19: 35%->60¦14/3/19: FCD:03/19->06/19¦21/3/19: WID:SP-180382->SP-190068; 31/5/19: 60%->100 / Impacted TSs and TRs: 23.280; 23.379; 23.281; 23.282; 23.283
- 2808: 10/9/18: 0%->5¦7/12/18: 5%->35¦14/3/19: 35%->60¦14/3/19: FCD:03/19->06/19¦21/3/19: WID:SP-180382->SP-190068; 31/5/19: 60%->100; 1/7/20: 0%->100 / Impacted TSs and TRs: 23.280; 23.379; 23.281; 23.282; 23.283
- 2809: ; 26/3/20: 0%->100 / Impacted TSs and TRs: 24.379; 24.380; 24.481; 24.482; 24.483; 24.484
- 2810: 10/9/18: 0%->10¦7/12/18: 10%->40
- 2811: 10/9/18: 0%->10¦7/12/18: 10%->40¦14/3/19: 40%->75; 31/5/19: 75%->90; 13/9/19: 90%->100 / Impacted TSs and TRs: 23.280; 23.282
- 2812: 31/5/19: 0%->15; 13/9/19: 15%->25; 17/9/19: WID:CP-190199->CP-192081; 6/12/19: 25%->55; 9/12/19: FCD:12/12/2019->03/20; 9/12/19: WID:CP-192081->CP-193146; 26/3/20: 55%->70; 26/6/20: 70%->100 / Impacted TSs and TRs: 24.282; 24.582; 24.483; 24.484; 24.zzz
- 2813: 7/12/18: 0%->80¦7/3/19: 80%->90¦7/3/19: FCD:03/19->06/19; 31/5/19: 90%->100 / Impacted TSs and TRs: 26.348
- 2814: 7/12/18: 0%->80¦7/3/19: 80%->90¦7/3/19: FCD:03/19->06/19; 31/5/19: 90%->100 / Impacted TSs and TRs: 26.348
- 2815: ; 6/12/19: 0%->90; 26/3/20: 90%->100 / Impacted TSs and TRs: 29.116
- 2816: 7/12/18: 0%->20¦14/3/19: 20%->40; 31/5/19: 40%->60; 13/9/19: 60%->80; 6/12/19: 80%->90; 26/3/20: 90%->100 / Impacted TSs and TRs: 24.229; 24.281; 24.282; 24.379; 24.380; 24.481; 24.482; 24.483; 24.484; 24.581; 24.582; 24.980
- 2817: 9/12/22: Acronym:MCProtoc16_enh2MCPTT_eMCData2-ConTest->MCProtoc16_enh2MCPTT_eMCData2-UEConTest; FCD:08/09/2024->30/08/2024; Compl:0%->5%; Stat Rep: ->RP-222804; Rapporteur: NIST->Jason Kahn, NIST; Rap eMail: ->jason.kahn@nist.gov; 10/1/23: acronym re...; 26/9/24: WID:RP-222549->RP-242148 / Impacted TSs and TRs: 36.579-9; 36.579-8
- 2818: Impacted TSs and TRs: New
- 2819: 12/7/17: WID:SP-170596->SP-170598¦11/9/17: 0%->10¦15/12/17: 10%->20¦15/12/17: Changed Rel-15->Rel-16¦16/3/18: 20%->60¦23/3/18: WID:SP-170598->SP-180237¦23/3/18: FCD:03/18->06/18¦14/6/18: 60%->100 / Impacted TSs and TRs: new 23.792
- 2820: 6/8/18: 23.479 added;¦10/9/18: 0%->15¦7/12/18: 15%->65¦14/3/19: 65%->90; 31/5/19: 90%->100 / Impacted TSs and TRs: New; 23.479

| ID | WBS | Task | Type | Duration | Start | Finish | Complete | Constraint | Resources | Work | Actual work | Acronym | PCG approved | WI rapporteur name | WI rapporteur e-mail | Release | TSG approved | Status Report |
| --- | --- | --- | --- | --- | --- | --- | --- | --- | --- | --- | --- | --- | --- | --- | --- | --- | --- | --- |
| 2821 | 1212 | **Enhancement of 3GPP Northbound APIs** |  | 291d | 2019-06-06 A | 2020-03-12 A | 100% |  | C3 | 4240h | 4240h | eNAPIs | 43 | Yali Yan, Huawei | yanyali@huawei.com | Rel-16 | 84 |  |
| 2822 | 1212.1 | CT3 aspects of eNAPIs |  | 201d | 2019-06-06 A | 2020-03-12 A | 100% | finish no earlier than 2020-03-12 | C3 | 1608h | 1608h | eNAPIs | 43 | Yali Yan, Huawei | yanyali@huawei.com | Rel-16 | 85 |  |
| 2823 | 1212.2 | CT4 aspects of eNAPIs |  | 128d | 2019-09-17 A | 2020-03-12 A | 100% | start no earlier than 2019-09-17 | C4 | 1024h | 1024h | eNAPIs | 43 | Yali Yan, Huawei | yanyali@huawei.com | Rel-16 | 85 |  |
| 2824 | 1213 | Enhanced Mission Critical System Migration and Interconnection |  | 266d? | 2018-06-06 A | 2019-06-12 A | 100% | finish no earlier than 2019-06-12 | S6 | 2128h | 2128h | eMCSMI | 41 | Chater-Lea, David; Motorola Solutions | david.chater-lea@motorolasolutions.com | Rel-16 | 80 |  |
| 2825 | 1214 | **Enhanced Mission Critical Communication Interworking with Land Mobile Radio Systems** |  | 387.25d? | 2018-06-06 A | 2019-06-14 A | 100% |  |  | 2144h | 2144h | eMCCI | 41 | Monnes, Peter, Harris Corporation | pmonnes@harris.com | Rel-16 | 80 |  |
| 2826 | 1214.1 | Enhanced Mission Critical Communication Interworking with Land Mobile Radio Systems |  | 268d? | 2018-06-06 A | 2019-06-14 A | 100% | finish no earlier than 2019-06-14 | S6 | 2144h | 2144h | eMCCI | 41 | Monnes, Peter, Harris Corporation | pmonnes at harris dot com | Rel-16 | 80 |  |
| 2827 | 1215 | Stage 3 for MC Communication Interworking with Land Mobile Radio Systems |  | 332d? | 2018-06-06 A | 2019-09-12 A | 100% | finish no earlier than 2019-09-12 | C1 | 2656h | 2656h | MCCI_CT | 41 | Monnes, Peter, Harris Corporation | pmonnes@harris.com | Rel-16 | 80 |  |
| 2828 | 1216 | Mission Critical Services Security Enhancements |  | 527d? | 2018-06-06 A | 2020-06-11 A | 100% | finish no earlier than 2020-06-11 | S3 | 4216h | 4216h | MCXSec | 41 | Woodward, Tim, Motorola Solutions, Inc |  | Rel-16 | 80 |  |
| 2829 | 1217 | **Enhancements of Public Warning System** |  | 1316.25d? | 2016-09-19 A | 2020-03-12 A | 100% |  |  | 14752h | 14752h | ePWS | 41 | Hyounhee Koo, SyncTechno Inc. | koo at synctechno dot com | Rel-16 | 80 |  |
| 2830 | 1217.1 | Study on enhancements of Public Warning System |  | 259d? | 2016-09-19 A | 2017-09-14 A | 100% | finish no earlier than 2017-09-14 | S1 | 2072h | 2072h | FS_ePWS | 37 | SyncTechno Inc., Hyounhee Koo | koo at synctechno dot com | Rel-16 | 73 |  |
| 2831 | 1217.2 | Stage 1 of ePWS |  | 261d? | 2017-12-15 A | 2018-12-14 A | 100% | finish no earlier than 2018-12-14 | S1 | 2088h | 2088h | ePWS | 41 | Hyounhee Koo, SyncTechno Inc. | koo at synctechno dot com | Rel-16 | 80 |  |
| 2832 | 1217.3 | **CT aspects of enhancements of Public Warning System** |  | 573.75d? | 2018-09-06 A | 2020-03-12 A | 100% |  | ct | 10592h | 10592h | ePWS | 41 | Hyounhee Koo, SyncTechno Inc. | koo at synctechno dot com | Rel-16 | 81 |  |
| 2833 | 1217.3.1 | Study on stages 2 and 3 of enhancements of ePWS |  | 200d? | 2018-09-10 A | 2019-06-14 A | 100% | finish no earlier than 2019-06-14 | C1 | 1600h | 1600h | ePWS | 41 | Hyounhee Koo, SyncTechno Inc. | koo at synctechno dot com | Rel-16 | 81 |  |
| 2834 | 1217.3.2 | CT1 aspects of ePWS |  | 396d? | 2018-09-06 A | 2020-03-12 A | 100% | finish no earlier than 2020-03-12 | C1 | 3168h | 3168h | ePWS | 41 | Hyounhee Koo, SyncTechno Inc. | koo at synctechno dot com | Rel-16 | 81 |  |
| 2835 | 1217.3.3 | deleted- CT4 aspects of ePWS (Possible impacts) |  | 332d? | 2018-09-06 A | 2019-12-13 A | 100% | finish no earlier than 2019-12-13 | C4 | 2656h | 2656h | ePWS | 41 | Hyounhee Koo, SyncTechno Inc. | koo at synctechno dot com | Rel-16 | 81 |  |
| 2836 | 1218 | **Mobile Communication System for Railways 2** |  | 1048d? | 2017-06-05 A | 2020-03-12 A | 100% |  |  | 14864h | 14864h | MONASTERY2 | 42 | Merkel, Juergen, Nokia | juergen.merkel@nokia.com | Rel-16 | 76 |  |
| 2837 | 1218.1 | Study on MONASTERY2 |  | 530d? | 2017-06-05 A | 2019-06-14 A | 100% | finish no earlier than 2019-06-14 | S1 | 4240h | 4240h | FS_FRMCS2 | 39 | Merkel, Juergen, Nokia | juergen.merkel@nokia.com | Rel-16 | 76 |  |
| 2838 | 1218.2 | Study on application architecture for the Future Railway Mobile Communication System (FRMCS) Phase 2 |  | 259d? | 2018-03-15 A | 2019-03-12 A | 100% | finish no earlier than 2019-03-12 | S6 | 2072h | 2072h | FS_FRMCS2_SA6 | 40 | Oettl, Martin, Nokia | martin(dot)oettl(at)nokia(dot)com | Rel-16 | 79 |  |
| 2839 | 1218.3 | Stage 1 of MONASTERY2 |  | 400d? | 2017-06-05 A | 2018-12-14 A | 100% | finish no earlier than 2018-12-14 | S1 | 3200h | 3200h | MONASTERY2 | 39 | Merkel, Juergen, Nokia | juergen.merkel@nokia.com | Rel-16 | 76 |  |
| 2840 | 1218.4 | Application Architecture for MONASTERY2 | manual | 66d | 2019-03-14 A | 2019-06-13 A | 100% |  | S6 | 528h | 528h | MONASTERY2 | 42 | Oettl, Martin, Nokia | martin(dot)oettl(at)nokia(dot)com | Rel-16 | 83 |  |
| 2841 | 1218.5 | **CT aspects of MONASTERY2** |  | 291d | 2019-06-06 A | 2020-03-12 A | 100% |  | ct | 4824h | 4824h | MONASTERY2 | 43 | Gkatzikis, Lazaros (Nokia) | lazaros(dot)gkatzikis(at)nokia(dot)com | Rel-16 | 84 |  |
| 2842 | 1218.5.1 | CT1 aspects of MONASTERY2 |  | 201d | 2019-06-06 A | 2020-03-12 A | 100% | finish no earlier than 2020-03-12 | C1 | 1608h | 1608h | MONASTERY2 | 43 | Gkatzikis, Lazaros (Nokia) | lazaros(dot)gkatzikis(at)nokia(dot)com | Rel-16 | 84 |  |
| 2843 | 1218.5.2 | deleted: CT3 aspects of MONASTERY2 |  | 201d | 2019-06-06 A | 2020-03-12 A | 100% | finish no earlier than 2020-03-12 | C3 | 1608h | 1608h | MONASTERY2 | 43 | Gkatzikis, Lazaros (Nokia) | lazaros(dot)gkatzikis(at)nokia(dot)com | Rel-16 | 84 |  |
| 2844 | 1219 | **NR support for high speed train scenario** |  | 1141.12d | 2019-06-17 A | 2022-06-22 A | 100% |  | R4 | 12608h | 12608h | NR_HST | 43 | CMCC |  | Rel-16 | 84 |  |
| 2845 | 1219.1 | Core part: NR support for high speed train scenario |  | 195d | 2019-06-17 A | 2020-03-13 A | 100% | finish no earlier than 2020-03-15 | R4 | 1560h | 1560h | NR_HST-Core | 43 | CMCC |  | Rel-16 | 84 |  |
| 2846 | 1219.2 | Perf. part: NR support for high speed train scenario |  | 195d | 2019-06-17 A | 2020-03-13 A | 100% | finish no earlier than 2020-03-15 | R4 | 1560h | 1560h | NR_HST-Perf | 43 | CMCC |  | Rel-16 | 84 |  |
| 2847 | 1219.3 | UE Conformance Test Aspects - NR support for high speed train scenario |  | 398d | 2020-12-14 A | 2022-06-22 A | 100% | finish no earlier than 2022-06-22 | R5 | 3184h | 3184h | NR_HST-UEConTest | 46 | Dan SONG, CMCC | songdan@chinamobile.com | Rel-16 | 90 | RP-221361 |

Notes:
- 2821: ; 13/9/19: 0%->50; 17/9/19: WID:CP-191233->CP-192184; 9/12/19: WID:CP-192184->CP-193175 / Impacted TSs and TRs: 29.122; 29.222; 29.522; 29.116
- 2822: ; 13/9/19: 0%->50; 17/9/19: WID:CP-191233->CP-192184; 6/12/19: 50%->85; 6/12/19: WID:CP-192184->CP-193175; 26/3/20: 85%->100 / Impacted TSs and TRs: 29.122; 29.222; 29.522; 29.116
- 2823: ; 13/9/19: 0%->50; 17/9/19: WID:CP-191233->CP-192184; 9/12/19: 0%->80; 26/3/20: 80%->100 / Impacted TSs and TRs: 29.122; 29.222; 29.522; 29.116
- 2824: 10/9/18: 0%->5¦7/12/18: 5%->10¦7/12/18: FCD:03/19->06/19¦14/3/19: 10%->50; 31/5/19: 50%->100. / Impacted TSs and TRs: 23.280; 23.379; 23.281; 23.282; 23.283
- 2826: 10/9/18: 0%->5¦2/10/18: WID:SP-180381->SP-180680¦7/12/18: 5%->15¦14/3/19: 15%->40; 31/5/19: 40%->70; 13/9/19: 70%->100 / Impacted TSs and TRs: 23.283
- 2827: 10/9/18: 5%->15¦7/12/18: 15%->45¦10/12/18: FCD:12/18->06/19¦10/12/18: WID:CP-181187->CP-183247. 06/03/19: both name and acronym changed (was MCCI3)¦14/3/19: 45%->60¦18/3/19: WID:CP-183248->CP-190203¦18/3/19: FCD:019->09/19; 31/5/19: 60%->70; 13/9/19: 7 / Impacted TSs and TRs: 24.379; 24.380; 24.282; 24.481; 24.483; 24.484; 24.482
- 2828: 10/9/18: 0%->40¦7/12/18: 40%->50¦20/3/19: FCD:019->09/19¦20/3/19: 50%->0; 31/5/19: 0%->45; 13/9/19: FCD:12/09/2019->12/20; 6/12/19: 45%->55; 6/12/19: FCD:12/12/2019->03/20; 25/3/20: 55%->75; 26/6/20: 75%->80; 12/9/20: FCD:12/03/2020->06/20; 9/4/21: 80% / Impacted TSs and TRs: 33.180
- 2829: 16/3/18: 0%->100
- 2830: 22.xxx¦1/12/16: 0%->5¦2/3/17: 5%->45¦7/6/17: 45%->75¦30/6/17: 22.869 added;¦25/8/17: 75%->95¦15/12/17: 95%->100 / Impacted TSs and TRs: 22.869
- 2831: 16/3/18: 0%->100
- 2832: 3/6/19: WID:CP-182228->CP-191155
- 2833: 7/12/18: 0%->10¦21/3/19: 10%->30; 31/5/19: 30%->85; 3/6/19: WID:CP-182228->CP-191155; 13/9/19: 85%->100 / Impacted TSs and TRs: New
- 2834: 14/3/19: 0%->30; 3/6/19: FCD:14/06/2019->03/20; 3/6/19: WID:CP-182228->CP-191155; 20/9/19: 0%->100; 6/12/19: 100%->65; 26/3/20: 65%->95; 26/6/20: 95%->100 / Impacted TSs and TRs: 23.041
- 2835: 3/6/19: WID:CP-182228->CP-191155; 16/9/19: 0%->100 / Impacted TSs and TRs: 29.168
- 2836: 15/12/17: 10%->35 / Impacted TSs and TRs: New 22.289; 22.280; 22.281; 22.282; 22.179
- 2837: 15/12/17: 35%->50¦16/3/18: 50%->80¦7/6/18: 80%->85¦10/9/18: FCD:06/18->06/19¦4/12/18: 85%->100 / Impacted TSs and TRs: New 22.889
- 2838: 19/4/18: 0%->5¦14/6/18: 5%->15¦6/8/18: 23.796 added;¦10/9/18: 15%->20¦7/12/18: 20%->65¦7/12/18: FCD:12/18->03/19¦14/3/19: 65%->100 / Impacted TSs and TRs: 23.cde; 23.796
- 2839: 16/3/18: 35%->55¦7/6/18: 55%->70¦7/6/18: FCD:06/18->12/18¦10/9/18: 70%->75¦4/12/18: 75%->100 / Impacted TSs and TRs: New 22.289; 22.280; 22.281; 22.282; 22.179
- 2840: 31/5/19: 0%->100 / Impacted TSs and TRs: 23.280; 23.379; 23.281; 23.282
- 2841: 9/12/19: WID:CP-191152->CP-193143
- 2842: 13/9/19: 0%->10; 6/12/19: 10%->50; 26/3/20: 50%->65; 26/6/20: 65%->100 / Impacted TSs and TRs: 24.379 ; 24.281 ; 24.282 ; 24.481 ; 24.483 ; 24.484 ; 24.581; 24.582
- 2843: 2/7/20: deleted, put at 100% (was at 0) / Impacted TSs and TRs: 29.165
- 2844: 8/10/19: WID:RP-191512->RP-191788
- 2845: 28/7/20: 0%->100
- 2846: 6/1/21: WID:RP-191788->RP-202320; 6/1/21: 0%->100
- 2847: tested: REL-16 WI NR_HST-Core ; 7/4/21: WID:RP-202328->RP-210372; 8/4/21: 0%->39; 2/7/21: 39%->41; 13/9/21: Compl:41%->44%; ; 20/6/22: Rapporteur: CMCC->Dan SONG, CMCC; Rap eMail: ->songdan@chinamobile.com12/7/22: WID:RP-202328->RP-221362

| ID | WBS | Task | Type | Duration | Start | Finish | Complete | Remaining | Total slack | Constraint | Resources | Work | Actual work | Acronym | PCG approved | WI rapporteur name | WI rapporteur e-mail | Release | TSG approved |
| --- | --- | --- | --- | --- | --- | --- | --- | --- | --- | --- | --- | --- | --- | --- | --- | --- | --- | --- | --- |
| 2848 | 1220 | **Maritime Communication Services over 3GPP System** |  | 845d? | 2016-09-19 A | 2018-12-13 A | 100% |  |  |  | S1 | 5950h | 5950h | MARCOM | 41 | Hyounhee Koo, SyncTechno Inc | koo at synctechno dot com | Rel-16 | 80 |
| 2849 | 1220.1 | Study on Maritime Communication Services over 3GPP system |  | 455d? | 2016-09-19 A | 2018-06-15 A | 100% |  |  | finish no earlier than 2018-06-15 | S1 | 3640h | 3640h | FS_MARCOM | 37 | SyncTechno Inc., Hyounhee Koo | koo at synctechno dot com | Rel-16 | 73 |
| 2850 | 1220.2 | Stage 1 of MARCOM |  | 137d? | 2018-06-06 A | 2018-12-13 A | 100% |  |  | finish no earlier than 2018-12-13 | S1 | 1096h | 1096h | MARCOM | 41 | Hyounhee Koo, SyncTechno Inc | koo at synctechno dot com | Rel-16 | 80 |
| 2851 | 1221 | Streaming and TV |  | 655d? | 2016-12-01 A | 2019-06-05 A | 100% |  |  |  |  |  |  |  |  |  |  | Rel-16 |  |
| 2852 | 1222 | **Enhancement of LTE for Efficient delivery of Streaming Service** |  | 676.25d? | 2016-12-01 A | 2018-09-14 A | 100% |  |  |  | S1 | 7176h | 7176h | eLSTR | 41 | Xia, Xu, China Telecom | xiaxu.bri@chinatelecom.cn | Rel-16 | 80 |
| 2853 | 1222.1 | Study on eLSTR |  | 336d? | 2016-12-01 A | 2018-03-15 A | 100% |  |  | finish no earlier than 2018-03-15 | S1 | 2688h | 2688h | FS_eLESTR | 38 | China Telecommunications, XIA Xu | xiaxu@ctbri.com.cn | Rel-16 | 74 |
| 2854 | 1222.2 | Stage 1 of eLSTR |  | 94d? | 2018-05-08 A | 2018-09-14 A | 100% |  |  | finish no earlier than 2018-09-14 | S1 | 752h | 752h | eLSTR | 41 | Xia, Xu, China Telecom | xiaxu.bri@chinatelecom.cn | Rel-16 | 80 |
| 2855 | 1223 | Enhancements to Framework for Live Uplink Streaming |  | 543d? | 2018-06-06 A | 2019-11-12 | 95% | 27.15d? | 0d | finish no earlier than 2020-07-03 | S4 | 4344h | 4344h | E_FLUS | 41 | Lo, Charles, Qualcomm Incorporated | clo@qti.qualcomm.com | Rel-16 | 80 |
| 2856 | 1224 | Coverage and Handoff Enhancements for Multimedia |  | 197d? | 2018-09-06 A | 2019-06-07 A | 100% |  |  | finish no earlier than 2019-06-07 | S4 | 1576h | 1576h | CHEM | 41 | Nikolai Leung | nleung@qti.qualcomm.com | Rel-16 | 81 |
| 2857 | 1225 | Study on QoE metrics for VR |  | 531d? | 2017-09-08 A | 2019-09-20 A | 100% |  |  | finish no earlier than 2019-09-20 | S4 | 4248h | 4248h | FS_QoE_VR | 39 | Ericsson (Gunnar Heikkilä | gunnar.heikkila@ericsson.com | Rel-16 | 77 |
| 2858 | 1226 | Study on 5G enhanced Mobile Broadband Media Distribution |  | 335d? | 2017-06-05 A | 2018-09-14 A | 100% |  |  | finish no earlier than 2018-09-14 | S4 | 2680h | 2680h | FS_5GMedia_Distribution | 39 | Bouazizi, Imed, Samsung Electronics Co., Ltd., | i (dot) Bouazizi (at) Samsung (dot) com | Rel-16 | 76 |
| 2859 | 1227 | Media streaming architecture | manual | 135d | 2018-12-06 A | 2019-06-12 A | 100% |  |  |  | S4 | 1080h | 1080h | 5GMSA | 42 | Frédéric GABIN | Frederic.gabin@ericsson.com | Rel-16 | 82 |
| 2860 | 1228 | VR QoE metrics |  | 201d | 2019-06-06 A | 2020-03-12 A | 100% |  |  | finish no earlier than 2020-03-12 | S4 | 1608h | 1608h | VRQoE | 43 | Gunnar HEIKKILÄ | gunnar.heikkila@ericsson.com | Rel-16 | 84 |
| 2861 | 1229 | **Media Handling Extensions for 5G Conversational Services** |  | 953.75d? | 2017-06-05 A | 2019-12-12 A | 100% |  |  |  | S4 | 10600h | 10600h | 5G_MEDIA_MTSI_ext | 41 | Oyman, Ozgur, Company: Intel | ozgur.oyman@intel.com | Rel-16 | 81 |
| 2862 | 1229.1 | Study on Media Handling Aspects of Conversational Services in 5G Systems |  | 335d? | 2017-06-05 A | 2018-09-14 A | 100% |  |  | finish no earlier than 2018-09-15 | S4 | 2680h | 2680h | FS_5G_MEDIA_MTSI | 39 | Oyman, Ozgur, Company: Intel | ozgur.oyman@intel.com | Rel-16 | 76 |
| 2863 | 1229.2 | Media Handling Extensions for 5G Conversational Services |  | 331d? | 2018-09-06 A | 2019-12-12 A | 100% |  |  | finish no earlier than 2019-12-12 | S4 | 2648h | 2648h | 5G_MEDIA_MTSI_ext | 41 | Oyman, Ozgur, Company: Intel | ozgur.oyman@intel.com | Rel-16 | 81 |
| 2864 | 1230 | Study on EVS Float Conformance Non Bit-Exact |  | 266d? | 2017-09-08 A | 2018-09-14 A | 100% |  |  | finish no earlier than 2018-09-14 | S4 | 2128h | 2128h | FS_EVS_FCNBE | 39 | Fabrice Plante, Intel | fabrice.m.plante@intel.com | Rel-16 | 77 |
| 2865 | 1231 | EVS Floating-point Conformance for Non Bit-Exact |  | 397d? | 2018-06-06 A | 2019-12-12 A | 100% |  |  | finish no earlier than 2019-12-12 | S4 | 3176h | 3176h | EVS_FCNBE | 42 | Fabrice, Plante, Intel | fabrice.m.plante@intel.om | Rel-16 | 82 |
| 2866 | 1232 | Addition of HLG HDR to TV Video Profiles |  | 73d? | 2018-06-06 A | 2018-09-14 A | 100% |  |  | finish no earlier than 2018-09-14 | S4 | 584h | 584h | HLG_HDR | 41 | Paul Szucs, Sony Europe Limited | paul.szucs@sony.com | Rel-16 | 80 |
| 2867 | 1233 | User Identities, Authentication, multi-device | milestone | 0d? | 2017-12-15 A | 2017-12-15 A | 100% |  |  | finish no earlier than 2017-12-15 |  |  |  |  |  |  |  | Rel-16 |  |
| 2868 | 1234 | **User Identities and Authentication** |  | 283.75d? | 2017-12-15 A | 2018-09-14 A | 100% |  |  |  | S1 | 3192h | 3192h | UIA | 41 | Bischinger, Kurt; Deutsche Telekom | kurt.bischinger@t-mobile.at | Rel-16 | 80 |
| 2869 | 1234.1 | Study on a Layer for User Centric Identifiers and Authentication |  | 130d? | 2017-12-15 A | 2018-06-14 A | 100% |  |  | finish no earlier than 2018-06-14 | S1 | 1040h | 1040h | FS_LUCIA | 40 | Bischinger, Kurt; Deutsche Telekom | kurt.bischinger@t-mobile.at | Rel-16 | 78 |
| 2870 | 1234.2 | Stage 1 of User Identities and Authentication |  | 73d? | 2018-06-06 A | 2018-09-14 A | 100% |  |  | finish no earlier than 2018-09-14 | S1 | 584h | 584h | UIA | 41 | Bischinger, Kurt; Deutsche Telekom | kurt.bischinger@t-mobile.at | Rel-16 | 80 |
| 2871 | 1235 | **Multi-device and multi-identity** |  | 767.5d? | 2018-06-06 A | 2020-06-15 A | 100% |  |  |  |  | 11696h | 11696h | MuD | 41 | Peter Bleckert, Ericsson | Peter.Bleckert@ericsson.com | Rel-16 | 80 |
| 2872 | 1235.1 | Stage 1 of Multi-device and multi-identity |  | 73d? | 2018-06-06 A | 2018-09-14 A | 100% |  |  | finish no earlier than 2018-09-14 | S1 | 584h | 584h | MuD | 41 | Peter Bleckert, Ericsson | Peter.Bleckert@ericsson.com | Rel-16 | 80 |

Notes:
- 2848: Impacted TSs and TRs: 22.179; 22.280; 22.281; 22.282; 22.261; 22.346; 22.468
- 2849: 22.xxx¦1/12/16: 0%->10¦2/3/17: 10%->15¦2/3/17: WID:SP-160556->SP-170166¦10/3/17: FCD:06/17->06/20¦21/3/17: 22.819 added;¦8/6/17: WID:SP-170166->SP-170453¦25/8/17: 15%->35¦15/12/17: 35%->55¦16/3/18: 55%->75¦7/6/18: 75%->95¦10/9/18: 95%->100 / Impacted TSs and TRs: 22.819
- 2850: 10/9/18: 0%->70¦4/12/18: 70%->95¦14/3/19: 95%->100 / Impacted TSs and TRs: 22.119; 22.179; 22.280; 22.281; 22.282; 22.261; 22.346; 22.468
- 2851: -
- 2852: Impacted TSs and TRs: 22.278; 22.115
- 2853: 2/3/17: 0%->20¦7/6/17: 20%->50¦11/9/17: 50%->70¦15/12/17: 70%->75¦15/12/17: FCD:09/17->03/18¦16/3/18: 75%->100 / Impacted TSs and TRs: 22.833
- 2854: 15/6/18: FCD:06/18->09/18¦10/9/18: 90%->100 / Impacted TSs and TRs: 22.278; 22.115
- 2855: 10/9/18: 0%->20¦7/12/18: 20%->40¦7/3/19: 40%->45¦7/3/19: FCD:03/19->09/19; 31/5/19: 45%->55; 13/9/19: FCD:20/09/2019->12/20; 13/9/19: 55%->75; 6/12/19: 75%->85; 25/3/20: 85%->90; 25/3/20: FCD:12/12/2019->06/20; 10/6/20: 90%->100; 26/6/20: FCD:12/06/202 / Impacted TSs and TRs: 26.238; 26.939
- 2856: 7/12/18: 0%->70¦7/3/19: 70%->80¦7/3/19: FCD:03/19->06/19; 31/5/19: 80%->90; 13/9/19: 90%->100 / Impacted TSs and TRs: 26.114
- 2857: 15/12/17: 26.929 added;¦15/12/17: 26.119 added;¦15/12/17: FCD:06/18->09/18¦15/12/17: 0%->10¦16/3/18: 10%->15¦7/6/18: 15%->20¦7/6/18: FCD:09/18->12/18. 14/06/18: Moved from Rel-15¦10/9/18: 20%->25¦12/3/19: 25%->55¦12/3/19: FCD:12/18->09/19; 31/5/19: 55% / Impacted TSs and TRs: New; 26.929; 26.119
- 2858: 11/9/17: 0%->10¦15/12/17: FCD:03/18->06/20¦15/12/17: 10%->25¦16/3/18: 25%->60¦7/6/18: 60%->70¦7/6/18: FCD:06/18->09/18. 14/06/18: Moved from Rel-15¦10/9/18: 70%->75; 26/6/20: 75%->100; 25/9/20: 26.998 added; / Impacted TSs and TRs: 26.8xx; 26.998
- 2859: ; 31/5/19: 0%->100 / Impacted TSs and TRs: 26.501; 26.233
- 2860: 22.280¦22.281¦22.282¦22.179¦22.289 ; 13/9/19: 0%->25; 6/12/19: 25%->50; 6/12/19: FCD:12/12/2019->03/20; 25/3/20: 50%->100 / Impacted TSs and TRs: 22.280; 22.281; 22.282; 22.179; 22.289
- 2861: Impacted TSs and TRs: 26.114
- 2862: 11/9/17: 0%->5¦15/12/17: 5%->35¦16/3/18: 35%->55¦16/3/18: FCD:03/18->09/18¦7/6/18: 55%->80. 14/06/18: Moved from Rel-15¦10/9/18: 80%->100 / Impacted TSs and TRs: 26.919
- 2863: 7/12/18: 0%->35¦7/3/19: 35%->50; 31/5/19: 50%->75; 13/9/19: 75%->80; 13/9/19: FCD:13/09/2019->12/20; 19/9/19: WID:SP-180663->SP-190640; 6/12/19: 80%->90; 25/3/20: 90%->100 / Impacted TSs and TRs: 26.114; 26.131; 26.132; 26.223; 26.919
- 2864: 15/12/17: 26.843 added;¦15/12/17: 0%->50¦16/3/18: 50%->60¦16/3/18: FCD:03/18->06/18¦7/6/18: 60%->70¦7/6/18: FCD:06/18->09/18. 14/06/18: Moved from Rel-15¦10/9/18: 70%->100 / Impacted TSs and TRs: New; 26.843
- 2865: ¦7/3/19: 0%->25¦7/3/19: 0%->25¦7/3/19: 0%->25. CANNOT CHANGE STARTING DATE… Real one: Thu 06/12/18; 31/5/19: 25%->50; 13/9/19: 50%->80; 13/9/19: FCD:12/09/2019->12/20; 6/12/19: 80%->100 / Impacted TSs and TRs: 26.444
- 2866: 10/9/18: 0%->100 / Impacted TSs and TRs: 26.116; 26.346; 26.234
- 2867: -
- 2868: Impacted TSs and TRs: 22.101; 22.115
- 2869: 16/3/18: 0%->60¦7/6/18: 60%->90¦10/9/18: 90%->100 / Impacted TSs and TRs: 22.904
- 2870: 10/9/18: 0%->100 / Impacted TSs and TRs: 22.101; 22.115
- 2872: 10/9/18: 85%->90¦4/12/18: 90%->100 / Impacted TSs and TRs: 22.173

| ID | WBS | Task | Type | Duration | Start | Finish | Complete | Remaining | Total slack | Constraint | Resources | Work | Actual work | Acronym | PCG approved | WI rapporteur name | WI rapporteur e-mail | Release | TSG approved | Status Report |
| --- | --- | --- | --- | --- | --- | --- | --- | --- | --- | --- | --- | --- | --- | --- | --- | --- | --- | --- | --- | --- |
| 2873 | 1235.2 | **CT aspects of Multi-device and multi-identity** |  | 672.25d? | 2018-09-06 A | 2020-06-15 A | 100% |  |  |  | ct | 11112h | 11112h | MuD | 41 | Axell, Jörgen, Ericsson | Jorgen.Axell@ericsson.com | Rel-16 | 81 |  |
| 2874 | 1235.2.1 | CT1 aspects of Multi-device and multi-identity |  | 463d? | 2018-09-06 A | 2020-06-15 A | 100% |  |  | finish no earlier than 2020-06-15 | C1 | 3704h | 3704h | MuD | 41 | Axell, Jörgen, Ericsson | Jorgen.Axell@ericsson.com | Rel-16 | 81 |  |
| 2875 | 1235.2.2 | CT3 aspects of Multi-device and multi-identity |  | 463d? | 2018-09-06 A | 2020-06-15 A | 100% |  |  | finish no earlier than 2020-06-15 | C3 | 3704h | 3704h | MuD | 41 | Axell, Jörgen, Ericsson | Jorgen.Axell@ericsson.com | Rel-16 | 81 |  |
| 2876 | 1236 | Slicing | milestone | 0d? | 2017-09-08 A | 2017-09-08 A | 100% |  |  | finish no earlier than 2017-09-08 |  |  |  |  |  |  |  | Rel-16 |  |  |
| 2877 | 1237 | **Enhancement of Network Slicing** |  | 1616.12d? | 2018-03-15 A | 2022-06-22 | 94% | 96.74d? | 39142.5d |  |  | 18856h | 17344h | eNS | 42 | ZTE, Tricci So | tso at ztetx dot com | Rel-16 | 83 |  |
| 2878 | 1237.1 | Study on Enhancement of Network Slicing |  | 197d? | 2018-03-15 A | 2018-12-14 A | 100% |  |  | start no earlier than 2018-03-15 | S2 | 1576h | 1576h | FS_eNS | 40 | ZTE, Tricci So | tso at ztetx dot com | Rel-16 | 79 |  |
| 2879 | 1237.2 | Stage 2 of eNS |  | 136d | 2018-12-13 A | 2019-06-20 A | 100% |  |  | start no earlier than 2018-12-13 | S2 | 1088h | 1088h | eNS | 42 | ZTE, Tricci So | tso at ztetx dot com | Rel-16 | 82 |  |
| 2880 | 1237.3 | **CT aspects of eNS** |  | 283.75d | 2019-03-07 A | 2019-12-05 A | 100% |  |  |  | ct | 6272h | 6272h | eNS | 42 | Fei Lu, ZTE | lu.fei1@zte.com.cn | Rel-16 | 83 |  |
| 2881 | 1237.3.1 | CT1 aspects of eNS |  | 196d | 2019-03-07 A | 2019-12-05 A | 100% |  |  |  | C1 | 1568h | 1568h | eNS | 42 | Fei Lu, ZTE | lu.fei1@zte.com.cn | Rel-16 | 83 |  |
| 2882 | 1237.3.2 | CT3 aspects of eNS |  | 196d | 2019-03-07 A | 2019-12-05 A | 100% |  |  |  | C3 | 1568h | 1568h | eNS | 42 | Fei Lu, ZTE | lu.fei1@zte.com.cn | Rel-16 | 83 |  |
| 2883 | 1237.3.3 | CT4 aspects of eNS |  | 196d | 2019-03-07 A | 2019-12-05 A | 100% |  |  |  | C4 | 1568h | 1568h | eNS | 42 | Fei Lu, ZTE | lu.fei1@zte.com.cn | Rel-16 | 83 |  |
| 2884 | 1237.4 | Study on Security aspects of Enhancement of Network Slicing |  | 396d? | 2018-09-06 A | 2020-03-12 A | 100% |  |  | finish no earlier than 2020-03-12 | S3 | 3168h | 3168h | FS_eNS_SEC | 41 |  | Suresh.p.nair@nokia.com | Rel-16 | 81 |  |
| 2885 | 1237.5 | Security aspects of Enhanced Network Slicing |  | 452d | 2019-09-19 A | 2021-06-11 A | 100% |  |  | finish no earlier than 2021-06-12 | S3 | 3616h | 3616h | eNS | 43 | Suresh.p.nair@nokia.com |  | Rel-16 | 85 |  |
| 2886 | 1237.6 | UE Conformance Test Aspects - Enhancement of Network Slicing |  | 392d | 2021-03-12 A | 2022-06-22 | 67% | 129.36d | 39142.5d | finish no earlier than 2022-09-12 | R5 | 3136h | 1624h | eNS-UEConTest | 46 | CMCC |  | Rel-16 | 91 | R5-220262 |
| 2887 | 1238 | **Business Role Models for Network Slicing** |  | 478.5d? | 2017-09-08 A | 2018-12-13 A | 100% |  |  |  | S1 | 5336h | 5336h | BRMNS | 41 | Covell, Betsy, Nokia | betsy.covell@nokia.com | Rel-16 | 81 |  |
| 2888 | 1238.1 | Study on Business Role Models for Network Slicing |  | 266d? | 2017-09-08 A | 2018-09-14 A | 100% |  |  | start no earlier than 2017-09-08 | S1 | 2128h | 2128h | FS_BMNS | 39 | Covell, Betsy, Nokia | betsy.covell@nokia.com | Rel-16 | 77 |  |
| 2889 | 1238.2 | Business Role Models for Network Slicing |  | 71d? | 2018-09-06 A | 2018-12-13 A | 100% |  |  | finish no earlier than 2018-12-13 | S1 | 568h | 568h | BRMNS | 41 | Covell, Betsy, Nokia | betsy.covell@nokia.com | Rel-16 | 81 |  |
| 2890 | 1239 | Study on tenancy concept in 5G networks and network slicing management |  | 202d? | 2018-09-06 A | 2019-06-14 A | 100% |  |  | finish no earlier than 2019-06-14 | S5 | 1616h | 1616h | FS_TENANCYC | 41 | ZHU, Lei (Huawei | Lei.zhu@huawei.com | Rel-16 | 81 |  |
| 2891 | 1240 | **Enhancement of performance assurance for 5G networks including network slicing** |  | 573.75d? | 2018-09-06 A | 2020-03-12 A | 100% |  |  |  | S5 | 6824h | 6824h | 5G_SLICE_ePA | 41 | Xiaowei Sun (China Mobile) |  | Rel-16 | 81 |  |
| 2892 | 1240.1 | Overall aspects of 5G_SLICE_ePA |  | 331d? | 2018-09-06 A | 2019-12-12 A | 100% |  |  | finish no earlier than 2019-12-12 | S5 | 2648h | 2648h | 5G_SLICE_ePA | 41 | Xiaowei Sun (China Mobile) |  | Rel-16 | 81 |  |
| 2893 | 1240.2 | KPI reporting |  | 126d | 2019-09-19 A | 2020-03-12 A | 100% |  |  | finish no earlier than 2020-03-12 | S5 | 1008h | 1008h | 5G_SLICE_ePA-KPI | 43 | ZHU, Weihong, ZTE Corporation | zhu.weihong@zte.com.cn | Rel-16 | 85 |  |
| 2894 | 1241 | Study on Charging Aspects of Network Slicing |  | 261d | 2018-12-13 A | 2019-12-12 A | 100% |  |  | finish no earlier than 2019-12-12 | S5 | 2088h | 2088h | FS_NETSLICE_CH | 42 | Chen Shan, Huawei | chenshan@huawei.com | Rel-16 | 82 |  |
| 2895 | 1242 | Other cross-TSG Release 16 Features | milestone | 0d? | 2016-06-09 A | 2016-06-09 A | 100% |  |  | finish no earlier than 2016-06-09 |  |  |  |  |  |  |  | Rel-16 |  |  |
| 2896 | 1243 | **Provision of Access to Restricted Local Operator Services by Unauthenticated UEs** |  | 1147.5d? | 2016-12-01 A | 2019-12-13 A | 100% |  |  |  |  | 18200h | 18200h | PARLOS | 38 | Covell, Betsy Nokia | betsy.covell@nokia.com | Rel-16 | 76 |  |
| 2897 | 1243.1 | Study on Stage 1 of PARLOS |  | 463d? | 2016-12-01 A | 2018-09-10 A | 100% |  |  | finish no earlier than 2018-09-10 | S1 | 3704h | 3704h | FS_PARLOS | 38 | Covell, Betsy | betsy.covell@nokia.com | Rel-15 | 74 |  |
| 2898 | 1243.2 | Study on Stage 2 for PARLOS |  | 335d? | 2017-06-05 A | 2018-09-14 A | 100% |  |  | finish no earlier than 2018-09-14 | S2 | 2680h | 2680h | FS_PARLOS_SA2 | 39 | Nokia (Nicolas Drevon | nicolas.drevon@nokia.com | Rel-16 | 76 |  |
| 2899 | 1243.3 | Study on Security Aspects of PARLOS |  | 332d? | 2018-06-06 A | 2019-09-12 A | 100% |  |  | finish no earlier than 2019-09-12 | S3 | 2656h | 2656h | FS_PARLOS_Sec | 41 | Greg Schumacher, Sprint | Gregory.schumacher@sprint.com | Rel-16 | 80 |  |
| 2900 | 1243.4 | Stage 1 of PARLOS |  | 22d? | 2017-05-10 A | 2017-06-08 A | 100% |  |  | finish no earlier than 2017-06-08 | S1 | 176h | 176h | PARLOS | 39 | Covell, Betsy Nokia | betsy.covell@nokia.com | Rel-16 | 76 |  |
| 2901 | 1243.5 | Stage 2 of PARLOS |  | 137d? | 2018-09-06 A | 2019-03-15 A | 100% |  |  | finish no earlier than 2019-03-15 | S2 | 1096h | 1096h | PARLOS | 41 | Nokia (Nicolas Drevon | nicolas.drevon@nokia.com) | Rel-16 | 81 |  |

Notes:
- 2873: 9/12/19: WID:CP-182227->CP-193273; 25/3/20: WID:CP-193273->CP-200148
- 2874: 7/12/18: 0%->10¦14/3/19: 10%->15; 31/5/19: 15%->35; 13/9/19: 35%->65; 6/12/19: 65%->85; 25/3/20: FCD:14/06/2019->03/20; 26/3/20: 85%->100; 2/7/20: FCD:25/03/2020->06/20 / Impacted TSs and TRs: 24.173; 24.229; 24.167
- 2875: 7/12/18: 0%->5; 13/9/19: 5%->95; 6/12/19: 95%->98; 26/3/20: 98%->100; 2/7/20: FCD:25/03/2020->06/20 / Impacted TSs and TRs: 29.165
- 2876: -
- 2878: 7/6/18: 0%->10¦15/6/18: WID:SP-180121->SP-180503¦6/8/18: 23.740 added;¦10/9/18: 10%->50¦7/12/18: 50%->85¦7/12/18: 85%->¦14/3/19: 85%->100 / Impacted TSs and TRs: new; 23.740
- 2879: 14/3/19: 0%->60; 31/5/19: 60%->100
- 2880: 2/7/20: WID:CP-190196->CP-201161
- 2881: 13/9/19: 0%->40; 6/12/19: 40%->85; 26/3/20: 85%->95; 26/6/20: 95%->97; 13/9/20: 97%->100 / Impacted TSs and TRs: 24.501
- 2882: 6/12/19: 0%->80; 26/3/20: 80%->98; 26/6/20: 98%->100 / Impacted TSs and TRs: 29.061; 29.561
- 2883: 31/5/19: 0%->30; 13/9/19: 30%->50; 6/12/19: 50%->95; 26/3/20: 95%->85 (went down); 26/6/20: 85%->100 / Impacted TSs and TRs: 29.502; 29.503; 29.505; 29.509; 29.518
- 2884: 7/12/18: 0%->15¦20/3/19: 15%->65¦20/3/19: FCD:019->06/19; 31/5/19: 65%->75; 13/9/19: FCD:12/06/2019->12/20; 13/9/19: 75%->80; 6/12/19: 80%->85; 6/12/19: FCD:12/12/2019->03/20; 26/6/20: 85%->100 / Impacted TSs and TRs: New
- 2885: ; 6/12/19: 0%->30; 6/12/19: FCD:12/12/2019->03/20; 25/3/20: FCD:12/03/2020->06/20; 26/6/20: 30%->95; 12/9/20: 95%->97; 19/3/21: FCD:12/06/2020->06/21; 11/6/21: 97%->100 / Impacted TSs and TRs: New
- 2886: tested: CT1 and SA3 REL-16 WI eNS (Enhancement of Network Slicing); compare REL-17 SI FS_NR_slice; 2/7/21: 0%->15; 13/9/21: Compl:15%->47%; ; 6/1/22: 47%->100 ;
- 2887: Impacted TSs and TRs: 22.261
- 2888: 15/12/17: 22.830 added;¦15/12/17: 0%->10¦15/3/18: WID:SP-170705->SP-180169¦16/3/18: 10%->50¦7/6/18: 50%->75¦10/9/18: 75%->95¦4/12/18: 95%->100 / Impacted TSs and TRs: New; 22.830
- 2889: 10/9/18: 0%->95¦4/12/18: 95%->100 / Impacted TSs and TRs: 22.261
- 2890: 7/12/18: 0%->20¦14/3/19: 20%->26; 31/5/19: 26%->40; 13/9/19: 40%->100 / Impacted TSs and TRs: New
- 2891: 7/12/18: 0%->30¦17/1/19: WID:SP-180843->SP-180906¦14/3/19: 30%->60¦21/3/19: FCD:06/19->12/19¦21/3/19: WID:SP-180906(->SP-190141)->SP-190247; 31/5/19: 60%->70 / Impacted TSs and TRs: 28.550; 28.532; 28.552; 28.554; 32.425; 32.426; 32.450; 32.451; 32.455; 28.622; 28.623
- 2892: 7/12/18: 0%->30¦17/1/19: WID:SP-180843->SP-180906¦14/3/19: 30%->60¦21/3/19: FCD:06/19->12/19¦21/3/19: WID:SP-180906(->SP-190141)->SP-190247; 31/5/19: 60%->70; 13/9/19: 70%->85; 13/9/19: 85%->; 26/3/20: 85%->97; 28/6/20: 97%->100 / Impacted TSs and TRs: 28.550; 28.532; 28.552; 28.554; 32.425; 32.426; 32.450; 32.451; 32.455; 28.622; 28.623
- 2893: ; 26/3/20: 0%->100 / Impacted TSs and TRs: 28.550; 28.554; 28.622; 28.532
- 2894: 14/3/19: 0%->30¦14/3/19: FCD:06/19->09/19; 31/5/19: 30%->45; 13/9/19: 45%->85; 13/9/19: FCD:12/09/2019->12/20; 6/12/19: 85%->100
- 2895: -
- 2896: 16/03/18: Moved to Rel-16 as per SA2 chair indication that St 2 work to be shifted from Rel-15 to Rel-16 / Impacted TSs and TRs: 22.115; 22.101; 22.228
- 2897: 1/12/16: 0%->75¦2/3/17: 75%->100¦10/9/18: FCD:03/17->09/18 / Impacted TSs and TRs: 22.820
- 2898: 11/9/17: 0%->20¦16/3/18: FCD:12/17->12/18.¦16/3/18: 20%->45¦23/3/18: WID:SP-170382->SP-180116¦23/3/18: FCD:12/18->06/18¦7/6/18: 45%->70¦15/6/18: WID:SP-180116->SP-180501¦15/6/18: FCD:06/18->09/18¦10/9/18: 70%->100 / Impacted TSs and TRs: 23.715
- 2899: 6/8/18: 33.815 added;¦10/9/18: 0%->5¦7/12/18: 5%->50¦20/3/19: FCD:018->09/19¦20/3/19: 50%->55; 31/5/19: 55%->60; 13/9/19: 60%->100 / Impacted TSs and TRs: New; 33.815
- 2900: 7/6/17: 0%->100 / Impacted TSs and TRs: 22.115; 22.101; 22.228
- 2901: 14/3/19: 0%->95; 31/5/19: 95%->100 / Impacted TSs and TRs: 23.401; 23.203; 23.221; 23.228; 23.167

| ID | WBS | Task | Duration | Start | Finish | Complete | Constraint | Resources | Work | Actual work | Acronym | PCG approved | WI rapporteur name | WI rapporteur e-mail | Release | TSG approved | Impacted TSs and TRs | Status Report |
| --- | --- | --- | --- | --- | --- | --- | --- | --- | --- | --- | --- | --- | --- | --- | --- | --- | --- | --- |
| 2902 | 1243.6 | **CT aspects of PARLOS** | 283.75d? | 2019-03-14 A | 2019-12-12 A | 100% |  | ct | 7840h | 7840h | PARLOS | 42 | Liu, Jennifer; Nokia | Jennifer.Liu@nokia.com | Rel-16 | 83 |  |  |
| 2903 | 1243.6.1 | CT1 aspects of PARLOS | 196d? | 2019-03-14 A | 2019-12-12 A | 100% | finish no earlier than 2019-12-12 | C1 | 1568h | 1568h | PARLOS | 42 | Liu, Jennifer; Nokia | Jennifer.Liu@nokia.com | Rel-16 | 83 | 24.301; 24.008; 23.122; 24.368; 24.167; 24.229; 27.007 |  |
| 2904 | 1243.6.2 | CT3 aspects of PARLOS | 196d? | 2019-03-14 A | 2019-12-12 A | 100% | finish no earlier than 2019-12-12 | C3 | 1568h | 1568h | PARLOS | 42 | Liu, Jennifer; Nokia | Jennifer.Liu@nokia.com | Rel-16 | 83 | 29.212; 29.213; 29.214 |  |
| 2905 | 1243.6.3 | CT4 aspects of PARLOS | 196d? | 2019-03-14 A | 2019-12-12 A | 100% | finish no earlier than 2019-12-12 | C4 | 1568h | 1568h | PARLOS | 42 | Liu, Jennifer; Nokia | Jennifer.Liu@nokia.com | Rel-16 | 83 | 29.228; 29.229; 29.274 |  |
| 2906 | 1243.6.4 | CT6 aspects of PARLOS | 196d? | 2019-03-14 A | 2019-12-12 A | 100% | finish no earlier than 2019-12-12 | C6 | 1568h | 1568h | PARLOS | 42 | Liu, Jennifer; Nokia | Jennifer.Liu@nokia.com | Rel-16 | 83 | 31.102; 31.103 |  |
| 2907 | 1243.7 | Security Aspects of PARLOS | 6d | 2019-12-06 A | 2019-12-13 A | 100% | finish no earlier than 2019-12-13 | S3 | 48h | 48h | PARLOS | 44 | Schumacher, Greg, Sprint | Gregory.schumacher@sprint.com | Rel-16 | 86 | 33.401 |  |
| 2908 | 1244 | **Enhancing Topology of SMF and UPF in 5G Networks** | 949.75d? | 2017-09-08 A | 2020-03-12 A | 100% |  |  | 9456h | 9456h | ETSUN | 42 |  |  | Rel-16 | 82 |  |  |
| 2909 | 1244.1 | Study on ETSUN | 331d? | 2017-09-08 A | 2018-12-14 A | 100% | finish no earlier than 2018-12-15 | S2 | 2648h | 2648h | FS_ETSUN | 39 | Laurent Thiebaut (Nokia) | Laurent.thiebaut@nokia.com | Rel-16 | 77 | 23.726 |  |
| 2910 | 1244.2 | Stage 2 of ETSUN | 137d | 2018-12-07 A | 2019-06-17 A | 100% | start no earlier than 2018-12-07 | S2 | 1096h | 1096h | ETSUN | 42 |  |  | Rel-16 | 82 |  |  |
| 2911 | 1244.3 | **CT aspects of ETSUN** | 283.75d | 2019-03-08 A | 2019-12-06 A | 100% |  | ct | 4704h | 4704h | ETSUN | 42 | Landais, Bruno, Nokia | bruno.landais@nokia.com | Rel-16 | 83 |  |  |
| 2912 | 1244.3.1 | CT3 aspects of ETSUN | 196d | 2019-03-08 A | 2019-12-06 A | 100% | start no earlier than 2019-03-08 | C3 | 1568h | 1568h | ETSUN | 42 | Landais, Bruno, Nokia | bruno.landais@nokia.com | Rel-16 | 83 | 29.508; 29.561 |  |
| 2913 | 1244.3.2 | CT4 aspects of ETSUN | 196d | 2019-03-08 A | 2019-12-06 A | 100% | start no earlier than 2019-03-08 | C4 | 1568h | 1568h | ETSUN | 42 | Landais, Bruno, Nokia | bruno.landais@nokia.com | Rel-16 | 83 | 29.244; 29.502; 29.510; 29.518; 29.281 |  |
| 2914 | 1244.4 | Charging aspects of ETSUN | 126d | 2019-09-19 A | 2020-03-12 A | 100% | finish no earlier than 2020-03-12 | S5 | 1008h | 1008h | ETSUN | 43 | Dong, Jia, China Mobile | dongjia@chinamobile.com | Rel-16 | 85 | 32.255; 32.291; 32.298 |  |
| 2915 | 1245 | **Access Traffic Steering, Switch and Splitting support in the 5G system architecture** | 2271.12d? | 2017-06-05 A | 2023-06-06 A | 100% |  |  | 14576h | 14576h | ATSSS | 42 | So, Tricci, ZTE | tso@ztetx.com | Rel-16 | 82 | 23.501; 23.502; 23.503 |  |
| 2916 | 1245.1 | Study on ATSSS | 400d? | 2017-06-05 A | 2018-12-14 A | 100% | finish no earlier than 2018-12-15 | S2 | 3200h | 3200h | FS_ATSSS | 39 | So, Tricci, ZTE | tso@ztetx.com | Rel-16 | 76 | new 23.793 |  |
| 2917 | 1245.2 | Stage 2 of ATSSS | 136d | 2018-12-14 A | 2019-06-21 A | 100% | start no earlier than 2018-12-14 | S2 | 1088h | 1088h | ATSSS | 42 | So, Tricci, ZTE | tso@ztetx.com | Rel-16 | 82 | 23.501; 23.502; 23.503 |  |
| 2918 | 1245.3 | **CT aspects of ATSSS** | 283.75d | 2019-03-11 A | 2019-12-09 A | 100% |  | ct | 8176h | 8176h | ATSSS | 42 | ZHOU, Xingyue (Joy), ZTE | zhou.xingyue@zte.com.cn | Rel-16 | 83 |  |  |
| 2919 | 1245.3.1 | CT1 aspects of ATSSS | 196d | 2019-03-11 A | 2019-12-09 A | 100% | start no earlier than 2019-03-11 | C1 | 1568h | 1568h | ATSSS | 42 | ZHOU, Xingyue (Joy), ZTE | zhou.xingyue@zte.com.cn | Rel-16 | 83 | 24.501; 24.526; 24.502 |  |
| 2920 | 1245.3.2 | CT3 aspects of ATSSS | 196d | 2019-03-11 A | 2019-12-09 A | 100% | start no earlier than 2019-03-11 | C3 | 1568h | 1568h | ATSSS | 42 | ZHOU, Xingyue (Joy), ZTE | zhou.xingyue@zte.com.cn | Rel-16 | 83 | 29.512; 29.513 |  |
| 2921 | 1245.3.3 | CT4 aspects of ATSSS | 196d | 2019-03-11 A | 2019-12-09 A | 100% | start no earlier than 2019-03-11 | C4 | 1568h | 1568h | ATSSS | 42 | ZHOU, Xingyue (Joy), ZTE | zhou.xingyue@zte.com.cn | Rel-16 | 83 | 29.244; 29.502; 29.503; 29.505; 29.518; 29.510; 23.008 |  |
| 2922 | 1245.3.4 | (IETF) TCP Extensions for Multipath Operation with Multiple Addresses (draft-ietf-mptcp-rfc6824bis) | 119d | 2019-06-26 A | 2019-12-09 A | 100% | finish no earlier than 2019-12-09 | S2-IETF | 952h | 952h | ATSSS | 43 |  |  | Rel-16 | 84 | RFC 8684 |  |
| 2923 | 1245.3.5 | (IETF) 0-RTT TCP Convert Protocol (draft-ietf-tcpm-converters) | 119d | 2019-06-26 A | 2019-12-09 A | 100% | finish no earlier than 2019-12-09 | S2-IETF | 952h | 952h | ATSSS | 43 |  |  | Rel-16 | 84 | RFC 8803 |  |
| 2924 | 1245.4 | Charging Access of ATSSS | 70d | 2019-12-06 A | 2020-03-12 A | 100% | finish no earlier than 2020-03-12 | S5 | 560h | 560h | ATSSS | 44 | Gardella, Maryse, Nokia | maryse.gardella@nokia.com | Rel-16 | 86 | 32.255; 32.290; 32.291; 32.298 |  |
| 2925 | 1245.5 | UE Conformance Test Aspects - Access Traffic Steering, Switch and Splitting support in 5G system | 194d | 2022-09-08 A | 2023-06-06 A | 100% | finish no earlier than 2023-12-12 | R5 | 1552h | 1552h | ATSSS-UEConTest | 49 | Jing Zhao, China telecom | Zhaoj16@chinatelecom.cn | Rel-16 | 97 |  | RP-230078 |

Notes:
- 2903: 31/5/19: 0%->80; 13/9/19: 80%->95; 6/12/19: 95%->98; 26/3/20: 98%->100
- 2904: 13/9/19: 0%->95; 26/3/20: 95%->100
- 2905: 6/12/19: 0%->100
- 2906: 31/5/19: 0%->10; 26/3/20: 10%->100
- 2907: ; 6/12/19: 0%->100
- 2909: 15/12/17: 23.726 added;¦16/3/18: 0%->25¦7/6/18: 25%->40¦10/9/18: 40%->65¦10/9/18: FCD:09/18->12/18¦2/10/18: WID:SP-170743->SP-180731¦2/10/18: FCD:12/18->12/18¦7/12/18: 65%->100
- 2910: 14/3/19: 0%->45; 31/5/19: 45%->90; 13/9/19: 90%->100
- 2912: 13/9/19: 0%->80; 6/12/19: 80%->85; 26/3/20: 85%->100
- 2913: 31/5/19: 0%->25; 13/9/19: 25%->95; 6/12/19: 95%->100
- 2914: ; 6/12/19: 0%->70; 26/3/20: 70%->100
- 2916: 11/9/17: 0%->100¦14/9/17: 100%->10¦15/12/17: Changed Rel-15->Rel-16¦16/3/18: 10%->20¦7/6/18: 20%->40¦10/9/18: 40%->70¦10/9/18: FCD:09/18->12/18¦2/10/18: WID:SP-170411->SP-180732¦2/10/18: FCD:12/18->12/18¦7/12/18: 70%->100
- 2917: 14/3/19: 0%->45; 31/5/19: 45%->85; 13/9/19: 85%->100
- 2919: 31/5/19: 0%->25; 13/9/19: 25%->55; 6/12/19: 55%->65; 26/3/20: 65%->70; 26/6/20: 70%->100
- 2920: 31/5/19: 0%->50; 13/9/19: 50%->55; 6/12/19: 55%->60; 26/3/20: 60%->100
- 2921: 31/5/19: 0%->25; 13/9/19: 25%->45; 6/12/19: 45%->75; 26/3/20: 75%->85; 26/6/20: 85%->100
- 2922: 23/4/20: 80%->100; 9/4/21: RFC 8684 added;
- 2923: 23/4/20: 30%->90; 25/9/20: 90%->100; 9/4/21: RFC 8803 added;
- 2924: ; 26/3/20: 0%->15; 28/6/20: 15%->70; 13/9/20: 70%->100
- 2925: 9/12/22: FCD:10/12/2023->01/12/2023; Compl:0%->5%; Stat Rep: ->RP-222738; Rapporteur: China Telecom->Jing Zhao, China telecom; Rap eMail: ->Zhaoj16@chinatelecom.cn; 17/3/23: FCD:30/11/2023->12/12/2023; Compl:5%->55%; Stat Rep: RP-222738->RP-230078; ...

| ID | WBS | Task | Type | Duration | Start | Finish | Complete | Actual finish | Constraint | Resources | Work | Actual work | Acronym | PCG approved | WI rapporteur name | WI rapporteur e-mail | Release | TSG approved |
| --- | --- | --- | --- | --- | --- | --- | --- | --- | --- | --- | --- | --- | --- | --- | --- | --- | --- | --- |
| 2926 | 1246 | **Single radio voice continuity from 5GS to 3G** |  | 1415.75d? | 2018-03-15 A | 2021-12-10 A | 100% |  |  |  | 18480h | 18480h | 5G_SRVCC | 41 | Chi Ren, China Unicom | renchi1@chinaunicom.cn | Rel-16 | 81 |
| 2927 | 1246.1 | Study for single radio voice continuity from 5GS to 3G |  | 67d? | 2018-03-15 A | 2018-06-15 A | 100% |  | finish no earlier than 2018-06-15 | S2 | 536h | 536h | FS_5G-SRVCC | 40 | Chi Ren, China Unicom | renchi1@chinaunicom.cn | Rel-16 | 79 |
| 2928 | 1246.2 | Single radio voice continuity from 5GS to 3G |  | 136d? | 2018-09-06 A | 2019-03-14 A | 100% |  | finish no earlier than 2019-03-14 | S2 | 1088h | 1088h | 5G_SRVCC | 41 | Chi Ren, China Unicom | renchi1@chinaunicom.cn | Rel-16 | 81 |
| 2929 | 1246.3 | Security aspects of single radio voice continuity from 5GS to UTRAN |  | 130d | 2018-12-13 A | 2019-06-12 A | 100% |  | start no earlier than 2018-12-13 | S3 | 1040h | 1040h | 5GS_UTRAN_SEC | 42 | Feng Gao, China Unicom | gaofeng149@chinaunicom.cn | Rel-16 | 82 |
| 2930 | 1246.4 | **RAN aspects of 5G_SRVCC** |  | 379.25d | 2018-12-15 A | 2019-12-15 | 100% | 2021-12-10 |  | R2 | 9384h | 9384h | SRVCC_NR_to_UMTS | 42 | China Unicom |  | Rel-16 | 82 |
| 2931 | 1246.4.1 | Core part: Single Radio Voice Call Continuity from 5G to 3G | manual | 262d | 2018-12-15 A | 2019-12-15 A | 100% |  |  | R2 | 2096h | 2096h | SRVCC_NR_to_UMTS-Core | 42 | China Unicom |  | Rel-16 | 82 |
| 2932 | 1246.4.2 | Perf. part: Single Radio Voice Call Continuity from 5G to 3G |  | 327d | 2019-03-01 A | 2020-06-01 A | 100% |  | finish no earlier than 2020-06-01 | R4 | 2616h | 2616h | SRVCC_NR_to_UMTS-Perf | 42 | China Unicom |  | Rel-16 | 83 |
| 2933 | 1246.4.3 | UE Conformance Test Aspects - Single Radio Voice Call Continuity from 5G to 3G |  | 322d | 2020-09-17 A | 2021-12-10 A | 100% |  | finish no earlier than 2021-12-12 | R5 | 2576h | 2576h | SRVCC_NR_to_UMTS-UEConTest | 45 | China Unicom |  | Rel-16 | 89 |
| 2934 | 1246.5 | **CT aspect of 5G_SRVCC** |  | 291d | 2019-06-06 A | 2020-03-12 A | 100% |  |  | ct | 6432h | 6432h | 5G_SRVCC | 43 | Chi Ren, China Unicom | renchi1@chinaunicom.cn | Rel-16 | 84 |
| 2935 | 1246.5.1 | CT1 aspect of 5G_SRVCC |  | 201d | 2019-06-06 A | 2020-03-12 A | 100% |  | finish no earlier than 2020-03-12 | C1 | 1608h | 1608h | 5G_SRVCC | 43 | Chi Ren, China Unicom | renchi1@chinaunicom.cn | Rel-16 | 84 |
| 2936 | 1246.5.2 | CT3 aspect of 5G_SRVCC |  | 201d | 2019-06-06 A | 2020-03-12 A | 100% |  | finish no earlier than 2020-03-12 | C3 | 1608h | 1608h | 5G_SRVCC | 44 | Chi Ren, China Unicom | renchi1@chinaunicom.cn | Rel-16 | 86 |
| 2937 | 1246.5.3 | CT4 aspect of 5G_SRVCC |  | 201d | 2019-06-06 A | 2020-03-12 A | 100% |  | finish no earlier than 2020-03-12 | C4 | 1608h | 1608h | 5G_SRVCC | 43 | Chi Ren, China Unicom | renchi1@chinaunicom.cn | Rel-16 | 84 |
| 2938 | 1247 | Study on Remote Identification of Uncrewed Aerial Systems |  | 132d? | 2018-03-15 A | 2018-09-14 A | 100% |  | finish no earlier than 2018-09-14 | S1 | 1056h | 1056h | FS_ID_UAS | 40 | Eddy Hall; Qualcomm Incorporated | edhall@qti.qualcomm.com | Rel-16 | 79 |
| 2939 | 1248 | Study on Security Aspects of the 5G Service Based Architecture |  | 462d? | 2018-06-06 A | 2020-03-12 A | 100% |  | finish no earlier than 2020-03-12 | S3 | 3696h | 3696h | FS_SBA_Sec | 41 | Hans Christian Rudolph, Deutsche Telekom AG | hans-christian.rudolph@telekom.de | Rel-16 | 80 |
| 2940 | 1249 | **Enhancements to the Service-Based 5G System Architecture** |  | 850.25d? | 2018-03-15 A | 2020-06-12 A | 100% |  |  |  | 8904h | 8904h | 5G_eSBA | 42 |  |  | Rel-16 | 82 |
| 2941 | 1249.1 | Study on Enhancements to the Service-Based 5G System Architecture |  | 197d? | 2018-03-15 A | 2018-12-14 A | 100% |  | finish no earlier than 2018-12-14 | S2 | 1576h | 1576h | FS_eSBA | 40 | Tao Sun (China Mobile) | suntao@chinamobile.com | Rel-16 | 79 |
| 2942 | 1249.2 | Stage 2 of 5G_eSBA |  | 136d | 2018-12-13 A | 2019-06-20 A | 100% |  | start no earlier than 2018-12-13 | S2 | 1088h | 1088h | 5G_eSBA | 42 | Tao Sun (China Mobile) | suntao@chinamobile.com | Rel-16 | 82 |
| 2943 | 1249.3 | **CT aspects of 5G_eSBA** |  | 283.75d | 2019-03-14 A | 2019-12-12 A | 100% |  |  | ct | 4704h | 4704h | 5G_eSBA | 42 | Song Yue (China Mobile) | songyue at chinamobile dot com | Rel-16 | 83 |
| 2944 | 1249.3.1 | CT3 aspects of 5G_eSBA |  | 196d | 2019-03-14 A | 2019-12-12 A | 100% |  | start no earlier than 2019-03-14 | C3 | 1568h | 1568h | 5G_eSBA | 42 | Song Yue (China Mobile) | songyue at chinamobile dot com | Rel-16 | 83 |
| 2945 | 1249.3.2 | CT4 aspects of 5G_eSBA |  | 196d | 2019-03-14 A | 2019-12-12 A | 100% |  | start no earlier than 2019-03-14 | C4 | 1568h | 1568h | 5G_eSBA | 42 | Song Yue (China Mobile) | songyue at chinamobile dot com | Rel-16 | 83 |
| 2946 | 1249.4 | Security for 5G_eSBA |  | 192d | 2019-09-19 A | 2020-06-12 A | 100% |  | finish no earlier than 2020-06-12 | S3 | 1536h | 1536h | 5G_eSBA | 43 | Nagendra Bykampadi, Nokia | nagendra.bykampadi@nokia.com | Rel-16 | 85 |
| 2947 | 1250 | Study on Enhanced IMS to 5GC Integration |  | 391d? | 2017-12-15 A | 2019-06-14 A | 100% |  | finish no earlier than 2019-06-14 | S2 | 3128h | 3128h | FS_eIMS5G | 40 | Joul, Chris, T-Mobile USA | chris <dot> joul <at> t-mobile <dot> com | Rel-16 | 78 |
| 2948 | 1251 | **SBA aspects of enhanced IMS to 5GC integration** |  | 66d | 2019-03-14 A | 2019-06-13 | 100% | 2020-03-12 |  |  | 6959h | 6959h | eIMS5G_SBA | 42 | T-Mobile USA, Christopher Joul |  | Rel-16 | 84 |
| 2949 | 1251.1 | Stage 2 of eIMS5G_SBA | manual | 65.88d | 2019-03-14 A | 2019-06-13 A | 100% |  |  | S2 | 527h | 527h | eIMS5G_SBA | 42 | T-Mobile USA, Christopher Joul |  | Rel-16 | 83 |

Notes:
- 2926: Impacted TSs and TRs: 23.216; 23.501; 23.502
- 2927: 7/6/18: 0%->80¦6/8/18: 23.756 added;¦10/9/18: 80%->100 / Impacted TSs and TRs: 23.756
- 2928: 14/3/19: 0%->100 / Impacted TSs and TRs: 23.216; 23.501; 23.502
- 2929: 20/3/19: 0%->20; 13/9/19: 20%->100; 20/9/19: WID:SP-181037->SP-190703 / Impacted TSs and TRs: 33.501; 33.401; 33.220
- 2930: no Perf. part¦26/3/19: WID:RP-182811->RP-190713; 26/3/20: WID:RP-190713->RP-200151
- 2931: no Perf. part¦26/3/19: WID:RP-182811->RP-190713; 26/3/20: 0%->100
- 2932: 28/7/20: 0%->100
- 2933: tested: REL-16 WI SRVCC_NR_to_UMTS-Core ; 7/4/21: WID:RP-201794->RP-210400; 8/4/21: 0%->31; 8/4/21: FCD:08/09/2021->09/21; 2/7/21: FCD:Fri 10/09/->12/21; 2/7/21: 31%->85; 6/1/22: 85%->100
- 2934: 6/12/19: WID:CP-191062->CP-193014
- 2935: 13/9/19: 0%->65; 6/12/19: 65%->90; 26/3/20: 90%->100 / Impacted TSs and TRs: 24.501; 24.237; 24.008; 27.007
- 2936: 6/12/19: created, 0%->60; 26/3/20: 60%->100
- 2937: 13/9/19: 0%->60; 6/12/19: 60%->80; 26/3/20: 80%->100 / Impacted TSs and TRs: 29.303; 29.503; 29.504; 29.505; 29.518; 29.274
- 2938: 7/6/18: 0%->60¦10/9/18: 60%->100 / Impacted TSs and TRs: 22.825
- 2939: 6/8/18: 33.855 added;¦10/9/18: 65%->75¦7/12/18: 75%->76¦20/3/19: 76%->65¦20/3/19: FCD:018->09/19; 31/5/19: 65%->75; 13/9/19: FCD:12/09/2019->12/20; 13/9/19: 75%->80; 6/12/19: 80%->85; 6/12/19: FCD:12/12/2019->03/20; 26/6/20: 85%->100 / Impacted TSs and TRs: New; 33.855
- 2941: 7/6/18: 0%->15¦6/8/18: 23.742 added;¦10/9/18: 15%->60¦7/12/18: 60%->100 / Impacted TSs and TRs: 23.xxx; 23.742
- 2942: 14/3/19: 0%->50; 31/5/19: 50%->80; 13/9/19: 80%->100 / Impacted TSs and TRs: 23.501; 23.502; 23.503
- 2944: 6/12/19: 0%->30; 26/3/20: 30%->100 / Impacted TSs and TRs: 29.507; 29.508; 29.513; 29.512; 29.514; 29.519; 29.520; 29.521; 29.523; 29.525; 29.551; 29.554
- 2945: 31/5/19: 0%->10; 13/9/19: 10%->40; 6/12/19: 40%->70; 26/3/20: 70%->95; 26/6/20: 95%->100 / Impacted TSs and TRs: 29.500; 29.501; 29.502; 29.503; 29.504; 29.505; 29.509; 29.510; 29.511; 29.518; 29.531; 29.540; 29.571; 29.572; 29.573
- 2946: ; 6/12/19: 0%->45; 6/12/19: FCD:12/12/2019->03/20; 25/3/20: 45%->70; 25/3/20: FCD:12/03/2020->06/20; 26/6/20: 70%->95; 12/9/20: 95%->100 / Impacted TSs and TRs: 33.501
- 2947: 16/3/18: 0%->20¦7/6/18: 20%->40¦10/9/18: FCD:09/18->06/19¦2/10/18: WID:SP-171052->SP-180736¦14/3/19: 40%->70; 6/12/19: 70%->100 / Impacted TSs and TRs: new 23.794
- 2948: Impacted TSs and TRs: 23.501; 23.502; 23.503; 23.228
- 2949: 31/5/19: 0%->100 / Impacted TSs and TRs: 23.501; 23.502; 23.503; 23.228

| ID | WBS | Task | Type | Duration | Start | Finish | Complete | Actual start | Actual finish | Constraint | Resources | Work | Actual work | Acronym | PCG approved | WI rapporteur name | WI rapporteur e-mail | Release | TSG approved | Impacted TSs and TRs | Status Report |
| --- | --- | --- | --- | --- | --- | --- | --- | --- | --- | --- | --- | --- | --- | --- | --- | --- | --- | --- | --- | --- | --- |
| 2950 | 1251.2 | **CT aspects of eIMS5G_SBA** |  | 291d | 2019-06-06 A | 2020-03-12 A | 100% |  |  |  | ct | 6432h | 6432h | eIMS5G_SBA | 43 | de Gregorio, Jesus. Ericsson | jesus.de.gregorio@ericsson.com | Rel-16 | 84 |  |  |
| 2951 | 1251.2.1 | CT1 aspects of eIMS5G_SBA |  | 201d | 2019-06-06 A | 2020-03-12 A | 100% |  |  | finish no earlier than 2020-03-12 | C1 | 1608h | 1608h | eIMS5G_SBA | 43 | de Gregorio, Jesus. Ericsson | jesus.de.gregorio@ericsson.com | Rel-16 | 85 |  |  |
| 2952 | 1251.2.2 | CT3 aspects of eIMS5G_SBA |  | 201d | 2019-06-06 A | 2020-03-12 A | 100% |  |  | finish no earlier than 2020-03-12 | C3 | 1608h | 1608h | eIMS5G_SBA | 43 | de Gregorio, Jesus. Ericsson | jesus.de.gregorio@ericsson.com | Rel-16 | 84 | 29.513; 29.514 |  |
| 2953 | 1251.2.3 | CT4 aspects of eIMS5G_SBA |  | 201d | 2019-06-06 A | 2020-03-12 A | 100% |  |  | finish no earlier than 2020-03-12 | C4 | 1608h | 1608h | eIMS5G_SBA | 43 | de Gregorio, Jesus. Ericsson | jesus.de.gregorio@ericsson.com | Rel-16 | 84 | 29.510; 29.571; 23.380 |  |
| 2954 | 1252 | **Private Network Support for NG-RAN** |  | 1441.62d | 2019-03-01 A | 2022-12-21 A | 100% |  |  |  | R3 | 15280h | 15280h | NG_RAN_PRN | 42 | China Telecom |  | Rel-16 | 83 |  |  |
| 2955 | 1252.1 | Core part: Private Network Support for NG-RAN |  | 261d | 2019-03-01 A | 2020-02-28 A | 100% |  |  | finish no earlier than 2020-03-01 | R3 | 2088h | 2088h | NG_RAN_PRN-Core | 42 | China Telecom |  | Rel-16 | 83 |  |  |
| 2956 | 1252.2 | UE Conformance Test Aspects - Private Network Support for NG-RAN |  | 654d | 2020-06-22 A | 2022-12-21 A | 100% |  |  | finish no earlier than 2022-12-22 | R5 | 5232h | 5232h | NG_RAN_PRN_Vertical_LAN-UEConTest | 45 | Yogesh Tugnawat, Qualcomm | yogesht[at]qti.qualcomm.com | Rel-16 | 88 |  | RP-221246 |
| 2957 | 1253 | **Media Handling Aspects of RAN Delay Budget Reporting in MTSI** |  | 754d? | 2017-12-15 A | 2019-12-12 A | 100% |  |  |  |  | 9416h | 9416h | E2E_DELAY | 41 | Oyman, Ozgur, Company: Intel | ozgur.oyman@intel.com | Rel-16 | 81 | 26.114 |  |
| 2958 | 1253.1 | Study on E2E_DELAY |  | 196d? | 2017-12-15 A | 2018-09-14 A | 100% |  |  | finish no earlier than 2018-09-14 | S4 | 1568h | 1568h | FS_E2E_DELAY | 40 | Oyman, Ozgur, Company: Intel, | ozgur.oyman@intel.com | Rel-16 | 78 | new |  |
| 2959 | 1253.2 | Stage 2 of E2E_DELAY |  | 197d? | 2018-09-06 A | 2019-06-07 A | 100% |  |  | finish no earlier than 2019-06-07 | S4 | 1576h | 1576h | E2E_DELAY | 41 | Oyman, Ozgur, Company: Intel | ozgur.oyman@intel.com | Rel-16 | 81 | 26.114 |  |
| 2960 | 1253.3 | **CT Aspects of E2E_DELAY** |  | 283.75d? | 2019-03-14 A | 2019-12-12 A | 100% |  |  |  | ct | 6272h | 6272h | E2E_DELAY | 42 | Luetzenkirchen, Thomas, Intel | Thomas.luetzenkirchen@intel.com | Rel-16 | 83 |  |  |
| 2961 | 1253.3.1 | CT1 Aspects of E2E_DELAY |  | 196d? | 2019-03-14 A | 2019-12-12 A | 100% |  |  | finish no earlier than 2019-12-12 | C1 | 1568h | 1568h | E2E_DELAY | 42 | Luetzenkirchen, Thomas, Intel | Thomas.luetzenkirchen@intel.com | Rel-16 | 83 | 24.229 |  |
| 2962 | 1253.3.2 | CT3 Aspects of E2E_DELAY |  | 196d? | 2019-03-14 A | 2019-12-12 A | 100% |  |  | finish no earlier than 2019-12-12 | C3 | 1568h | 1568h | E2E_DELAY | 42 | Luetzenkirchen, Thomas, Intel | Thomas.luetzenkirchen@intel.com | Rel-16 | 83 | 29.162 |  |
| 2963 | 1253.3.3 | CT4 Aspects of E2E_DELAY |  | 196d? | 2019-03-14 A | 2019-12-12 A | 100% |  |  | finish no earlier than 2019-12-12 | C4 | 1568h | 1568h | E2E_DELAY | 42 | Luetzenkirchen, Thomas, Intel | Thomas.luetzenkirchen@intel.com | Rel-16 | 83 | 23.334; 29.334; 29.238; 23.333; 29.333 |  |
| 2964 | 1254 | **Enhancements for Common API Framework for 3GPP Northbound APIs** |  | 755d? | 2018-03-15 A | 2020-03-12 A | 100% |  |  |  |  | 5216h | 5216h | eCAPIF | 42 | Basavaraj Pattan, Samsung | basavarajjp@samsung.com | Rel-16 | 83 | 23.222 |  |
| 2965 | 1254.1 | Stage 2 for eCAPIF |  | 325d? | 2018-03-15 A | 2019-06-12 A | 100% |  |  | finish no earlier than 2019-06-12 | S6 | 2600h | 2600h | eCAPIF | 40 | Basavaraj Pattan, Samsung | basavarajjp@samsung.com | Rel-16 | 79 | 23.222 |  |
| 2966 | 1254.2 | Security aspects of eCAPIF |  | 201d | 2019-03-07 A | 2019-12-12 A | 100% |  |  | finish no earlier than 2019-12-12 | S3 | 1608h | 1608h | eCAPIF | 42 | Rajavelsamy Rajadurai, Samsung | rajvel{@]samsung.com | Rel-16 | 83 | 33.122 |  |
| 2967 | 1254.3 | CT aspects of eCAPIF |  | 126d | 2019-09-19 A | 2020-03-12 A | 100% |  |  | finish no earlier than 2020-03-12 | C3 | 1008h | 1008h | eCAPIF | 43 | Narendranath Durga, Tangudu (Samsung) | n.tangudu {@]samsung.com | Rel-16 | 85 | 29.222 |  |
| 2968 | 1255 | **User data interworking, Coexistence and Migration** |  | 96.25d? | 2019-03-14 | 2019-06-14 | 100% | 2018-06-15 | 2020-03-12 |  | S2 | 4750h | 4750h | UDICOM | 42 | Alessio Casati, Nokia | Alessio.casati@nokia.com | Rel-16 | 84 | 23.501; 23.502; 23.228 |  |
| 2969 | 1255.1 | Study on UDICOM |  | 259d? | 2018-06-15 A | 2019-06-12 A | 100% |  |  | finish no earlier than 2019-06-12 | S2 | 2072h | 2072h | FS_UDICoM | 41 | Susana Sabater (Vodafone | susana.sabater@vodafone.com | Rel-16 | 80 | 23.732; new |  |
| 2970 | 1255.2 | Stage 2 of UDICOM | manual | 66.88d | 2019-03-14 A | 2019-06-14 A | 100% |  |  |  | S2 | 535h | 535h | UDICOM | 42 | Alessio Casati, Nokia | Alessio.casati@nokia.com | Rel-16 | 83 | 23.501; 23.502; 23.228; 23.632 |  |
| 2971 | 1255.3 | CT aspects of UDICOM |  | 201d | 2019-06-06 A | 2020-03-12 A | 100% |  |  | finish no earlier than 2020-03-12 | C4 | 1608h | 1608h | UDICOM | 43 | Wiehe, Ulrich, Nokia | ulrich.wiehe@nokia.com | Rel-16 | 84 | 29.503; 29.505; 29.571; 29.510 |  |
| 2972 | 1256 | UICC-terminal interface testing for UEs with non-removable UICCs |  | 257d | 2021-03-18 A | 2022-03-10 A | 100% |  |  | finish no earlier than 2022-03-11 | C6 | 2056h | 2056h | nrUICC_UEConTest | 46 | Marquordt, Arne, COMPRION GmbH | amarquordt@comprion.com | Rel-16 | 91 | TS 31.121,TS 31.124,TS 31.127 |  |
| 2973 | 1257 | Study on authentication and key management for applications based on 3GPP credential in 5G |  | 397d? | 2018-06-06 A | 2019-12-12 A | 100% |  |  | finish no earlier than 2019-12-12 | S3 | 3176h | 3176h | FS_AKMA | 41 | Jin Peng, China Mobile | pengjin@chinamobile.com | Rel-16 | 80 | New; 33.835 |  |
| 2974 | 1258 | Removal of AKMA from Rel-16 |  | 6d | 2020-12-04 A | 2020-12-11 A | 100% |  |  | finish no earlier than 2020-12-12 | S3 | 48h | 48h | RM_AKMA_R16 | 46 | Xiaoting Huang, China Mobile | huangxiaoting@chinamobile.com | Rel-16 | 90 |  |  |
| 2975 | 1259 | NR-related Release 16 Features | milestone | 0d? | 2019-03-07 A | 2019-03-07 A | 100% |  |  |  |  |  |  |  |  |  |  | Rel-16 |  |  |  |

Notes:
- 2950: 16/9/19: WID:CP-191065->CP-192023
- 2951: 6/12/19: 0%->70; 26/6/20: 70%->100
- 2952: 13/9/19: 0%->70; 6/12/19: 70%->90; 26/3/20: 90%->100
- 2953: 13/9/19: 0%->25; 6/12/19: 25%->50; 26/3/20: 50%->90; 26/6/20: 90%->100
- 2954: 26/3/20: WID:RP-190729->RP-200122
- 2955: 26/6/19: WID:RP-190729->RP-191563; 28/7/20: 0%->100
- 2956: 8/10/20: 0%->5; 8/4/21: 5%->10; 2/7/21: 10%->31; 20/6/22: FCD:15/12/2021->22/12/2022; Compl:31%->89%; Stat Rep: ->RP-221246; Rapporteur: Qualcomm->Yogesh Tugnawat, Qualcomm; Rap eMail: ->yogesht[at]qti.qualcomm.com 9/9/22: Compl:89%->97%; 29/3/23: 97%->100
- 2958: 16/3/18: 0%->10¦7/6/18: 10%->60¦10/9/18: 60%->100
- 2959: 7/12/18: 0%->75¦7/3/19: 75%->85¦7/3/19: FCD:03/19->06/19; 31/5/19: 85%->100
- 2961: 31/5/19: 0%->100; 13/9/19: 100%->100
- 2962: 31/5/19: 0%->100
- 2963: 31/5/19: 0%->100
- 2964: 7/6/18: 0%->15¦10/9/18: 15%->30¦7/12/18: 30%->45¦7/12/18: FCD:12/18->06/19¦13/12/18: WID:SP-180161->SP-181137
- 2965: 7/6/18: 0%->15¦10/9/18: 15%->30¦7/12/18: 30%->45¦7/12/18: FCD:12/18->06/19¦13/12/18: WID:SP-180161->SP-181137¦14/3/19: 45%->80; 31/5/19: 80%->100
- 2966: 31/5/19: 0%->30; 31/5/19: 0%->30; 31/5/19: 0%->30; 13/9/19: 30%->90; 13/9/19: FCD:13/09/2019->12/20; 6/12/19: 90%->100
- 2967: ; 6/12/19: 0%->65; 26/3/20: 65%->95; 26/6/20: 95%->100
- 2969: 10/9/18: 0%->30¦2/10/18: WID:SP-180620->SP-180735¦7/12/18: 30%->80¦14/12/18: FCD:12/18->03/20¦14/3/19: 80%->100¦21/3/19: WID:SP-181110->SP-190148¦21/3/19: FCD:019->06/19; 13/9/19: 75%->100
- 2970: 6/6/19: 0%->100; 26/6/19: 23.632 added;
- 2971: 31/5/19: 0%->10; 13/9/19: 10%->25; 6/12/19: 25%->75; 9/12/19: WID:CP-191066->CP-193016; 26/3/20: 75%->90; 26/6/20: 90%->100
- 2973: 6/8/18: 33.835 added;¦7/12/18: 5%->20¦20/3/19: 20%->60¦20/3/19: FCD:019->09/19; 13/9/19: 60%->70; 13/9/19: FCD:12/09/2019->12/19; 6/12/19: 70%->95; 26/6/20: 95%->100
- 2974: 33.535; 33.501; 33.220 ; 9/4/21: 0%->100
- 2975: -

| ID | WBS | Task | Duration | Start | Finish | Complete | Remaining | Total slack | Constraint | Resources | Work | Actual work | Acronym | PCG approved | Release | TSG approved | Status Report | Impacted TSs and TRs |
| --- | --- | --- | --- | --- | --- | --- | --- | --- | --- | --- | --- | --- | --- | --- | --- | --- | --- | --- |
| 2976 | 1260 | **Addition of wider channel bandwidth in NR band n3** | 92d | 2019-12-16 A | 2020-03-13 A | 100% |  |  |  | R4 | 1560h | 1560h | NR_n3_BW | 44 | Rel-16 | 86 |  |  |
| 2977 | 1260.1 | Core part: Addition of wider channel bandwidth in NR band n3 | 65d | 2019-12-16 A | 2020-03-13 A | 100% |  |  | finish no earlier than 2020-03-15 | R4 | 520h | 520h | NR_n3_BW-Core | 44 | Rel-16 | 86 |  |  |
| 2978 | 1260.2 | Perf. part: Addition of wider channel bandwidth in NR band n3 | 65d | 2019-12-16 A | 2020-03-13 A | 100% |  |  | finish no earlier than 2020-03-15 | R4 | 520h | 520h | NR_n3_BW-Perf | 44 | Rel-16 | 86 |  |  |
| 2979 | 1261 | **Addition of wider channel bandwidth in NR band n65** | 92d | 2019-12-16 A | 2020-03-13 A | 100% |  |  |  | R4 | 1560h | 1560h | NR_n65_BW | 44 | Rel-16 | 86 |  |  |
| 2980 | 1261.1 | Core part: Addition of wider channel bandwidth in NR band n65 | 65d | 2019-12-16 A | 2020-03-13 A | 100% |  |  | finish no earlier than 2020-03-15 | R4 | 520h | 520h | NR_n65_BW-Core | 44 | Rel-16 | 86 |  |  |
| 2981 | 1261.2 | Perf. part: Addition of wider channel bandwidth in NR band n65 | 65d | 2019-12-16 A | 2020-03-13 A | 100% |  |  | finish no earlier than 2020-03-15 | R4 | 520h | 520h | NR_n65_BW-Perf | 44 | Rel-16 | 86 |  |  |
| 2982 | 1262 | **UE Power Saving in NR** | 853.5d? | 2018-06-15 A | 2020-09-15 A | 100% |  |  |  | R1 | 12104h | 12104h | NR_UE_pow_sav | 42 | Rel-16 | 83 |  |  |
| 2983 | 1262.1 | Study on UE power saving in NR | 261d? | 2018-06-15 A | 2019-06-14 A | 100% |  |  | finish no earlier than 2019-06-15 | R1 | 2088h | 2088h | FS_NR_UE_pow_sav | 41 | Rel-16 | 80 |  |  |
| 2984 | 1262.2 | Core part: UE Power Saving in NR | 261d | 2019-03-01 A | 2020-02-28 A | 100% |  |  | finish no earlier than 2020-03-01 | R1 | 2088h | 2088h | NR_UE_pow_sav-Core | 42 | Rel-16 | 83 |  |  |
| 2985 | 1262.3 | Perf. part: UE Power Saving in NR | 403d | 2019-03-01 A | 2020-09-15 A | 100% |  |  | finish no earlier than 2020-09-15 | R4 | 3224h | 3224h | NR_UE_pow_sav-Perf | 42 | Rel-16 | 83 |  |  |
| 2986 | 1263 | **Band combinations for SA NR supplementary uplink (SUL), NSA NR SUL, NSA NR SUL with UL sharing from the UE perspective (ULSUP)** | 566.5d? | 2018-06-15 A | 2019-12-13 A | 100% |  |  |  | R4 | 9384h | 9384h | NR_SUL_combos_R16 | 41 | Rel-16 | 80 |  |  |
| 2987 | 1263.1 | Core part: Band combinations for SA NR supplementary uplink (SUL), NSA NR SUL, NSA NR SUL with UL sharing from the UE perspective (ULSUP) | 391d? | 2018-06-15 A | 2019-12-13 A | 100% |  |  | finish no earlier than 2019-12-15 | R4 | 3128h | 3128h | NR_SUL_combos_R16-Core | 41 | Rel-16 | 80 |  |  |
| 2988 | 1263.2 | Perf. part: Band combinations for SA NR supplementary uplink (SUL), NSA NR SUL, NSA NR SUL with UL sharing from the UE perspective (ULSUP) | 391d? | 2018-06-15 A | 2019-12-13 A | 100% |  |  | finish no earlier than 2019-12-15 | R4 | 3128h | 3128h | NR_SUL_combos_R16-Perf | 41 | Rel-16 | 80 |  |  |
| 2989 | 1264 | **NR intra-band Carrier Aggregation** | 566.5d? | 2018-06-15 A | 2019-12-13 A | 100% |  |  |  |  | 18768h | 18768h |  | 41 | Rel-16 | 80 |  |  |
| 2990 | 1264.1 | **Rel-16 NR intra band CA for xCC DL/yCC UL including contiguous and non-contiguous spectrum (x>=y)** | 566.5d? | 2018-06-15 A | 2019-12-13 A | 100% |  |  |  | R4 | 9384h | 9384h | NR_CA_R16_intra | 41 | Rel-16 | 80 |  |  |
| 2991 | 1264.1.1 | Core part: Rel-16 NR intra band CA for xCC DL/yCC UL including contiguous and non-contiguous spectrum (x>=y) | 391d? | 2018-06-15 A | 2019-12-13 A | 100% |  |  | finish no earlier than 2019-12-15 | R4 | 3128h | 3128h | NR_CA_R16_intra-Core | 41 | Rel-16 | 80 |  |  |
| 2992 | 1264.1.2 | Perf. part: Rel-16 NR intra band CA for xCC DL/yCC UL including contiguous and non-contiguous spectrum (x>=y) | 391d? | 2018-06-15 A | 2019-12-13 A | 100% |  |  | finish no earlier than 2019-12-15 | R4 | 3128h | 3128h | NR_CA_R16_intra-Perf | 41 | Rel-16 | 80 |  |  |
| 2993 | 1264.2 | **Rel-16 NR inter-band CA/Dual Connectivity for 2 bands DL with x bands UL (x=1, 2)** | 566.5d? | 2018-06-15 A | 2019-12-13 A | 100% |  |  |  | R4 | 9384h | 9384h | NR_CADC_R16_2BDL_xBUL | 41 | Rel-16 | 80 |  |  |
| 2994 | 1264.2.1 | Core part: Rel-16 NR inter-band CA/Dual Connectivity for 2 bands DL with x bands UL (x=1, 2) | 391d? | 2018-06-15 A | 2019-12-13 A | 100% |  |  | finish no earlier than 2019-12-15 | R4 | 3128h | 3128h | NR_CADC_R16_2BDL_xBUL-Core | 41 | Rel-16 | 80 |  |  |
| 2995 | 1264.2.2 | Perf. part: Rel-16 NR inter-band CA/Dual Connectivity for 2 bands DL with x bands UL (x=1, 2) | 391d? | 2018-06-15 A | 2019-12-13 A | 100% |  |  | finish no earlier than 2019-12-15 | R4 | 3128h | 3128h | NR_CADC_R16_2BDL_xBUL-Perf | 41 | Rel-16 | 80 |  |  |
| 2996 | 1265 | **NR inter-band Carrier Aggregation** | 2189d | 2019-03-01 A | 2024-12-12 | 76% | 523.5d |  |  |  | 34513h | 12528h |  | 42 | Rel-16 | 83 |  |  |
| 2997 | 1265.1 | UE Conformance Test Aspects - Rel-16 NR CA and DC; and NR and LTE DC Configurations | 2748.12d | 2019-03-01 A | 2026-06-05 | 67% | 906.88d | 37647d | finish no earlier than 2026-06-05 | R5 | 21985h |  | NR_CADC_NR_LTE_DC_R16-UEConTest | 42 | Rel-16 | 83 | RP-253373 |  |
| 2998 | 1265.2 | **Rel16 NR inter-band Carrier Aggregation for 3 bands DL with 1 band UL** | 378d | 2019-03-01 A | 2020-02-28 A | 100% |  |  |  | R4 | 6264h | 6264h | NR_CA_R16_3BDL_1BUL | 42 | Rel-16 | 83 |  |  |
| 2999 | 1265.2.1 | Core part: Rel16 NR inter-band Carrier Aggregation for 3 bands DL with 1 band UL | 261d | 2019-03-01 A | 2020-02-28 A | 100% |  |  | finish no earlier than 2020-03-01 | R4 | 2088h | 2088h | NR_CA_R16_3BDL_1BUL-Core | 42 | Rel-16 | 83 |  | 38.716-03-01 |
| 3000 | 1265.2.2 | Perf. part: Rel16 NR inter-band Carrier Aggregation for 3 bands DL with 1 band UL | 261d | 2019-03-01 A | 2020-02-28 A | 100% |  |  | finish no earlier than 2020-03-01 | R4 | 2088h | 2088h | NR_CA_R16_3BDL_1BUL-Perf | 42 | Rel-16 | 83 |  |  |

Notes:
- 2976: affects: NR.; 26/3/20: WID:RP-193056->RP-200305 / WI rapporteur name: Ericsson
- 2977: affects: NR.; 28/7/20: 0%->100 / WI rapporteur name: Ericsson
- 2978: affects: NR.; 28/7/20: 0%->100 / WI rapporteur name: Ericsson
- 2979: affects: NR.; 26/3/20: WID:RP-193057->RP-200306 / WI rapporteur name: Ericsson
- 2980: affects: NR.; 28/7/20: 0%->100 / WI rapporteur name: Ericsson
- 2981: affects: NR.; 28/7/20: 0%->100 / WI rapporteur name: Ericsson
- 2982: 26/6/19: WID:RP-190727->RP-191607; 30/6/20: WID:RP-191607->RP-200494 / WI rapporteur name: CATT
- 2983: TR 38.8xx; 26/6/19: 0%->100 / WI rapporteur name: CATT
- 2984: 28/7/20: 0%->100 / WI rapporteur name: CATT
- 2985: 7/4/21: 0%->100 / WI rapporteur name: CATT
- 2986: basket WI¦TR 37.716-00-00¦note: WI covers for SA NR: 1 NR SUL band (already defined) + 1 or more NR bands and for NSA NR: 1 NR SUL band (already defined) + 1 or more NR bands + 1 or more LTE bands¦26/3/19: WID:RP-182559->RP-190714; 26/6/19: WID:RP-1907 / WI rapporteur name: Huawei
- 2987: basket WI¦TR 37.716-00-00¦note: WI covers for SA NR: 1 NR SUL band (already defined) + 1 or more NR bands and for NSA NR: 1 NR SUL band (already defined) + 1 or more NR bands + 1 or more LTE bands¦26/3/19: WID:RP-182559->RP-190714; 28/7/20: 0%->100 / WI rapporteur name: Huawei
- 2988: basket WI¦26/3/19: WID:RP-182559->RP-190714; 28/7/20: 0%->100 / WI rapporteur name: Huawei
- 2990: basket WI¦TR 38.716-01-01¦16/1/19: WID:RP-181426->RP-182256¦26/3/19: WID:RP-182256->RP-190689; 26/6/19: WID:RP-190689->RP-191194; 8/10/19: WID:RP-191194->RP-191812; 14/1/20: WID:RP-191812->RP-192445; 26/3/20: WID:RP-192445->RP-200101; 28/7/20: WID:RP-2 / WI rapporteur name: Ericsson
- 2991: basket WI¦TR 38.716-01-01¦26/3/19: WID:RP-182256->RP-190689; 28/7/20: 0%->100 / WI rapporteur name: Ericsson
- 2992: basket WI¦26/3/19: WID:RP-182256->RP-190689; 28/7/20: 0%->100 / WI rapporteur name: Ericsson
- 2993: basket WI¦TR 38.716-02-00¦16/1/19: WID:RP-180817->RP-182501¦26/3/19: WID:RP-182501->RP-190494; 26/6/19: WID:RP-190494->RP-191565; 8/10/19: WID:RP-191565->RP-191822; 14/1/20: WID:RP-191822->RP-192615; 26/3/20: WID:RP-192615->RP-200168; 28/7/20: WID:RP-2 / WI rapporteur name: ZTE
- 2994: basket WI¦TR 38.716-02-00¦26/3/19: WID:RP-182501->RP-190494; 28/7/20: 0%->100 / WI rapporteur name: ZTE
- 2995: basket WI¦26/3/19: WID:RP-182501->RP-190494; 28/7/20: 0%->100 / WI rapporteur name: ZTE
- 2997: 8/10/19: WID:RP-190321->RP-191772; 28/7/20: WID:RP-191772->RP-200759; 8/10/20: 0%->6; 8/10/20: FCD:01/06/2020->06/21; 8/4/21: 6%->6; 2/7/21: FCD:Fri 11/06/->12/21; 2/7/21: 6%->7 ; 22/3/22: Co ; 20/6/22: Rapporteur: CMCC->Dan SONG, Leif Mattisson, Y...; 3/12/25: FCD:Fri 12/12/25->Fri 05/06/26; Compl:64%->67%; Stat Rep: RP-252593->RP-253373; / WI rapporteur name: Luyang ZHAO, Kuba Kolodziej, Yu SHI, CMCC, Ericsson, China Unicom / WI rapporteur e-mail: zhaoluyang@chinamobile.com, kuba.kolodziej@ericsson.com, shiyu19@chinaunicom.cn
- 2998: 26/6/19: WID:RP-190692->RP-191153; 8/10/19: WID:RP-191153->RP-192245; 14/1/20: WID:RP-192245->RP-193206; 26/3/20: WID:RP-193206->RP-200238; 28/7/20: WID:RP-200238->RP-200918 / WI rapporteur name: CATT
- 2999: 26/6/19: 38.716-03-01 added;; 28/7/20: 0%->100 / WI rapporteur name: CATT
- 3000: 28/7/20: 0%->100 / WI rapporteur name: CATT

| ID | WBS | Task | Duration | Start | Finish | Complete | Constraint | Resources | Work | Actual work | Acronym | PCG approved | WI rapporteur name | Release | TSG approved | WI rapporteur e-mail | Status Report |
| --- | --- | --- | --- | --- | --- | --- | --- | --- | --- | --- | --- | --- | --- | --- | --- | --- | --- |
| 3001 | 1265.3 | **Rel-16 NR Inter-band Carrier Aggregation/Dual Connectivity for 3 bands DL with 2 bands UL** | 378d | 2019-03-01 A | 2020-02-28 A | 100% |  | R4 | 6264h | 6264h | NR_CADC_R16_3BDL_2BUL | 42 | ZTE | Rel-16 | 83 |  |  |
| 3002 | 1265.3.1 | Core part: Rel-16 NR Inter-band Carrier Aggregation/Dual Connectivity for 3 bands DL with 2 bands UL | 261d | 2019-03-01 A | 2020-02-28 A | 100% | finish no earlier than 2020-03-01 | R4 | 2088h | 2088h | NR_CADC_R16_3BDL_2BUL-Core | 42 | ZTE | Rel-16 | 83 |  |  |
| 3003 | 1265.3.2 | Perf. part: Rel-16 NR Inter-band Carrier Aggregation/Dual Connectivity for 3 bands DL with 2 bands UL | 261d | 2019-03-01 A | 2020-02-28 A | 100% | finish no earlier than 2020-03-01 | R4 | 2088h | 2088h | NR_CADC_R16_3BDL_2BUL-Perf | 42 | ZTE | Rel-16 | 83 |  |  |
| 3004 | 1266 | **New bands for New Radio** | 1689.12d? | 2018-06-15 A | 2022-12-01 A | 100% |  | R4 | 44816h | 44816h |  | 42 | Dish Network | Rel-16 | 83 |  |  |
| 3005 | 1266.1 | UE Conformance Test Aspects for new Rel-16 NR bands and extension of existing NR bands | 836d | 2019-09-19 A | 2022-12-01 A | 100% | finish no earlier than 2022-12-01 | R5 | 6688h | 6688h | NR_bands_BW_R16-UEConTest | 43 | Leif MATTISSON, Ericsson | Rel-16 | 85 | Leif[dot]mattisson[at]ericsson[dot]com | RP-222816 |
| 3006 | 1266.2 | **Band 65 for New Radio** | 189.5d? | 2018-06-15 A | 2018-12-14 A | 100% |  | R4 | 3144h | 3144h | NR_band_n65 | 41 | Dish Network | Rel-16 | 80 |  |  |
| 3007 | 1266.2.1 | Core part: Band 65 for New Radio | 131d? | 2018-06-15 A | 2018-12-14 A | 100% | finish no earlier than 2018-12-15 | R4 | 1048h | 1048h | NR_band_n65-Core | 41 | Dish Network | Rel-16 | 80 |  |  |
| 3008 | 1266.2.2 | Perf. part: Band 65 for New Radio | 131d? | 2018-06-15 A | 2018-12-14 A | 100% | finish no earlier than 2018-12-15 | R4 | 1048h | 1048h | NR_band_n65-Perf | 41 | Dish Network | Rel-16 | 80 |  |  |
| 3009 | 1266.3 | **Introduction of NR band n18** | 379d | 2018-12-13 A | 2019-12-13 A | 100% |  | R4 | 6288h | 6288h | NR_n18 | 42 | KDDI | Rel-16 | 82 |  |  |
| 3010 | 1266.3.1 | Core part: Introduction of NR band n18 | 262d | 2018-12-13 A | 2019-12-13 A | 100% | start no earlier than 2018-12-13 | R4 | 2096h | 2096h | NR_n18-Core | 42 | KDDI | Rel-16 | 82 |  |  |
| 3011 | 1266.3.2 | Perf. part: Introduction of NR band n18 | 262d | 2018-12-13 A | 2019-12-13 A | 100% | start no earlier than 2018-12-13 | R4 | 2096h | 2096h | NR_n18-Perf | 42 | KDDI | Rel-16 | 82 |  |  |
| 3012 | 1266.4 | **Introduction of NR band n48** | 176d | 2018-12-13 A | 2019-05-31 A | 100% |  | R4 | 2048h | 2048h | NR_n48 | 42 | US Cellular | Rel-16 | 82 |  |  |
| 3013 | 1266.4.1 | Core part: Introduction of NR band n48 | 68d | 2018-12-13 A | 2019-03-18 A | 100% | start no earlier than 2018-12-13 | R4 | 544h | 544h | NR_n48-Core | 42 | US Cellular | Rel-16 | 82 |  |  |
| 3014 | 1266.4.2 | Perf. part: Introduction of NR band n48 | 66d | 2019-03-01 A | 2019-05-31 A | 100% | finish no earlier than 2019-06-01 | R4 | 528h | 528h | NR_n48-Perf | 42 | Nokia | Rel-16 | 83 |  |  |
| 3015 | 1266.5 | **Introduction of NR band n14** | 95.25d | 2019-03-01 A | 2019-05-31 A | 100% |  | R4 | 1584h | 1584h | NR_n14 | 42 | AT&T | Rel-16 | 83 |  |  |
| 3016 | 1266.5.1 | Core part: Introduction of NR band n14 | 66d | 2019-03-01 A | 2019-05-31 A | 100% | finish no earlier than 2019-06-01 | R4 | 528h | 528h | NR_n14-Core | 42 | AT&T | Rel-16 | 83 |  |  |
| 3017 | 1266.5.2 | Perf. part: Introduction of NR band n14 | 66d | 2019-03-01 A | 2019-05-31 A | 100% | finish no earlier than 2019-06-01 | R4 | 528h | 528h | NR_n14-Perf | 42 | AT&T | Rel-16 | 83 |  |  |
| 3018 | 1266.6 | **Introduction of NR band n30** | 95.25d | 2019-03-01 A | 2019-05-31 A | 100% |  | R4 | 1584h | 1584h | NR_n30 | 42 | AT&T | Rel-16 | 83 |  |  |
| 3019 | 1266.6.1 | Core part: Introduction of NR band n30 | 66d | 2019-03-01 A | 2019-05-31 A | 100% | finish no earlier than 2019-06-01 | R4 | 528h | 528h | NR_n30-Core | 42 | AT&T | Rel-16 | 83 |  |  |
| 3020 | 1266.6.2 | Perf. part: Introduction of NR band n30 | 66d | 2019-03-01 A | 2019-05-31 A | 100% | finish no earlier than 2019-06-01 | R4 | 528h | 528h | NR_n30-Perf | 42 | AT&T | Rel-16 | 83 |  |  |
| 3021 | 1266.7 | **Introduction of NR band n259** | 298.25d | 2019-03-01 A | 2019-12-13 A | 100% |  | R4 | 4944h | 4944h | NR_n259 | 42 | Ericsson | Rel-16 | 83 |  |  |
| 3022 | 1266.7.1 | Core part: Introduction of NR band n259 | 206d | 2019-03-01 A | 2019-12-13 A | 100% | finish no earlier than 2019-12-15 | R4 | 1648h | 1648h | NR_n259-Core | 42 | Ericsson | Rel-16 | 83 |  |  |
| 3023 | 1266.7.2 | Perf. part: Introduction of NR band n259 | 206d | 2019-03-01 A | 2019-12-13 A | 100% | finish no earlier than 2019-12-15 | R4 | 1648h | 1648h | NR_n259-Perf | 42 | Ericsson | Rel-16 | 83 |  |  |
| 3024 | 1266.8 | **Introduction of NR band n26** | 183.25d | 2019-09-19 A | 2020-03-13 A | 100% |  | R4 | 3048h | 3048h | NR_n26 | 43 | Sprint | Rel-16 | 85 |  |  |
| 3025 | 1266.8.1 | Core part: Introduction of NR band n26 | 127d | 2019-09-19 A | 2020-03-13 A | 100% | finish no earlier than 2020-03-15 | R4 | 1016h | 1016h | NR_n26-Core | 43 | Sprint | Rel-16 | 85 |  |  |
| 3026 | 1266.8.2 | Perf. part: Introduction of NR band n26 | 127d | 2019-09-19 A | 2020-03-13 A | 100% | finish no earlier than 2020-03-15 | R4 | 1016h | 1016h | NR_n26-Perf | 43 | Sprint | Rel-16 | 85 |  |  |

Notes:
- 3001: 26/6/19: WID:RP-190693->RP-191566; 8/10/19: WID:RP-191566->RP-191824; 14/1/20: WID:RP-191824->RP-192617; 26/3/20: WID:RP-192617->RP-200171; 28/7/20: WID:RP-200171->RP-200673
- 3002: 28/7/20: 0%->100
- 3003: 28/7/20: 0%->100
- 3004: 16/1/19: WID:RP-181445->RP-182258
- 3005: testing all new NR band(s) and NR channel bandwidth addition Wis of REL-16; 14/1/20: WID:RP-192128->RP-192893; 26/3/20: WID:RP-192893->RP-200146; 28/7/20: WID:RP-200146->RP-200633; 8/10/20: 0%->47; 8/10/20: FCD:15/06/2020->12/20; 8/4/21: 47%->67; 8/4/2...; 9/1/23: 100%->100
- 3006: 16/1/19: WID:RP-181445->RP-182258¦26/3/19: WID:RP-182258->RP-190360
- 3007: 26/3/19: WID:RP-182258->RP-190360; 26/6/19: 0%->100
- 3008: 26/3/19: WID:RP-182258->RP-190360; 26/6/19: 0%->100
- 3009: 26/3/19: WID:RP-182826->RP-190173; 26/6/19: WID:RP-190173->RP-191556
- 3010: 26/3/19: WID:RP-182826->RP-190173; 26/6/19: 0%->100
- 3011: 26/3/19: WID:RP-182826->RP-190173; 26/6/19: 0%->100
- 3012: 26/6/19: WID:RP-182865->RP-190908
- 3013: 26/6/19: 0%->100
- 3014: 26/6/19: 0%->100
- 3015: 26/6/19: WID:RP-190165->RP-190965
- 3016: 26/6/19: 0%->100
- 3017: 26/6/19: 0%->100
- 3018: 26/6/19: WID:RP-190166->RP-190967
- 3019: 26/6/19: 0%->100
- 3020: 26/6/19: 0%->100
- 3021: 26/6/19: WID:RP-190765->RP-191416; 8/10/19: WID:RP-191416->RP-191880; 26/3/20: WID:NR_n259->RP-200249
- 3022: 28/7/20: 0%->100
- 3023: 28/7/20: 0%->100
- 3024: UL: 814-849MHz, DL: 859-894MHz; 14/1/20: WID:RP-192273->RP-192736
- 3025: 26/3/20: 0%->100
- 3026: 26/3/20: 0%->100

| ID | WBS | Task | Duration | Start | Finish | Complete | Constraint | Resources | Work | Actual work | Acronym | PCG approved | WI rapporteur name | Release | TSG approved | WI rapporteur e-mail | Status Report | Impacted TSs and TRs |
| --- | --- | --- | --- | --- | --- | --- | --- | --- | --- | --- | --- | --- | --- | --- | --- | --- | --- | --- |
| 3027 | 1266.9 | **Introduction of NR supplementary DL band n29** | 92d | 2019-06-17 A | 2019-09-13 A | 100% |  | R4 | 1560h | 1560h | NR_n29 | 43 | Dish Network | Rel-16 | 84 |  |  |  |
| 3028 | 1266.9.1 | Core part: Introduction of NR supplementary DL band n29 | 65d | 2019-06-17 A | 2019-09-13 A | 100% | finish no earlier than 2019-09-15 | R4 | 520h | 520h | NR_n29-Core | 43 | Dish Network | Rel-16 | 84 |  |  |  |
| 3029 | 1266.9.2 | Perf. part: Introduction of NR supplementary DL band n29 | 65d | 2019-06-17 A | 2019-09-13 A | 100% | finish no earlier than 2019-09-15 | R4 | 520h | 520h | NR_n29-Perf | 43 | Dish Network | Rel-16 | 84 |  |  |  |
| 3030 | 1266.10 | **Introduction of 2010-2025MHz SUL (supplemental uplink) band for NR** | 183.25d | 2019-09-19 A | 2020-03-13 A | 100% |  | R4 | 3048h | 3048h | NR_SUL_band_2010_2025MHz | 43 | CMCC | Rel-16 | 85 |  |  |  |
| 3031 | 1266.10.1 | Core part: Introduction of 2010-2025MHz SUL (supplemental uplink) band for NR | 127d | 2019-09-19 A | 2020-03-13 A | 100% | finish no earlier than 2020-03-15 | R4 | 1016h | 1016h | NR_SUL_band_2010_2025MHz-Core | 43 | CMCC | Rel-16 | 85 |  |  |  |
| 3032 | 1266.10.2 | Perf. part: Introduction of 2010-2025MHz SUL (supplemental uplink) band for NR | 127d | 2019-09-19 A | 2020-03-13 A | 100% | finish no earlier than 2020-03-15 | R4 | 1016h | 1016h | NR_SUL_band_2010_2025MHz-Perf | 43 | CMCC | Rel-16 | 85 |  |  |  |
| 3033 | 1266.11 | **Introduction of band n53** | 92d | 2019-12-16 A | 2020-03-13 A | 100% |  | R4 | 1560h | 1560h | NR_n53 | 44 | Globalstar | Rel-16 | 86 |  |  |  |
| 3034 | 1266.11.1 | Core part: Introduction of band n53 | 65d | 2019-12-16 A | 2020-03-13 A | 100% | finish no earlier than 2020-03-15 | R4 | 520h | 520h | NR_n53-Core | 44 | Globalstar | Rel-16 | 86 |  |  |  |
| 3035 | 1266.11.2 | Perf. part: Introduction of band n53 | 65d | 2019-12-16 A | 2020-03-13 A | 100% | finish no earlier than 2020-03-15 | R4 | 520h | 520h | NR_n53-Perf | 44 | Globalstar | Rel-16 | 86 |  |  |  |
| 3036 | 1267 | **New Radio Band-related topics** | 1891d | 2018-12-13 A | 2023-12-12 A | 100% |  | R4 | 98784h | 98784h |  | 42 | Dish Network | Rel-16 | 83 |  |  |  |
| 3037 | 1267.1 | **RF requirements for NR frequency range 1 (FR1)** | 1810.25d | 2019-03-01 A | 2023-12-12 A | 100% |  | R4 | 22480h | 22480h | NR_RF_FR1 | 42 | Huawei | Rel-16 | 83 |  |  |  |
| 3038 | 1267.1.1 | Core part: RF requirements for NR FR1 | 261d | 2019-03-01 A | 2020-02-28 A | 100% | finish no earlier than 2020-03-01 | R4 | 2088h | 2088h | NR_RF_FR1-Core | 42 | Huawei | Rel-16 | 83 |  |  |  |
| 3039 | 1267.1.2 | Perf. Part: RF requirements for NR FR1 | 327d | 2019-03-01 A | 2020-06-01 A | 100% | finish no earlier than 2020-06-01 | R4 | 2616h | 2616h | NR_RF_FR1-Perf | 42 | Huawei | Rel-16 | 83 |  |  |  |
| 3040 | 1267.1.3 | UE Conformance Test Aspects - RF requirements for NR FR1 | 972d | 2020-03-25 A | 2023-12-12 A | 100% | finish no earlier than 2023-12-12 | R5 | 7776h | 7776h | NR_RF_FR1-UEConTest | 44 | Yuxin HAO, Huawei Technologies. Co., Ltd. | Rel-16 | 87 | haoyuxin@huawei.com | RP-233756 |  |
| 3041 | 1267.2 | **Add support of NR DL 256QAM for frequency range 2 (FR2)** | 1146.38d | 2019-03-01 A | 2022-03-11 A | 100% |  | R4 | 14240h | 14240h | NR_DL256QAM_FR2 | 42 | China Telecom | Rel-16 | 83 |  |  |  |
| 3042 | 1267.2.1 | Core part: Add support of NR DL 256QAM for FR2 | 261d | 2019-03-01 A | 2020-02-28 A | 100% | finish no earlier than 2020-03-01 | R4 | 2088h | 2088h | NR_DL256QAM_FR2-Core | 42 | China Telecom | Rel-16 | 83 |  |  | 38.883 |
| 3043 | 1267.2.2 | Perf. part: Add support of NR DL 256QAM for FR2 | 403d | 2019-03-01 A | 2020-09-15 A | 100% | finish no earlier than 2020-09-15 | R4 | 3224h | 3224h | NR_DL256QAM_FR2-Perf | 42 | China Telecom | Rel-16 | 83 |  |  |  |
| 3044 | 1267.2.3 | UE Conformance Test Aspects - Add support of NR DL 256QAM for FR2 | 325d | 2020-12-14 A | 2022-03-11 A | 100% | finish no earlier than 2022-06-22 | R5 | 2600h | 2600h | NR_DL256QAM_FR2-UEConTest | 46 | China Telecom | Rel-16 | 90 |  | RP-220571 |  |
| 3045 | 1267.3 | **NR RF requirement enhancements for frequency range 2 (FR2)** | 1726.25d | 2019-03-01 A | 2023-09-22 A | 100% |  | R4 | 17952h | 17952h | NR_RF_FR2_req_enh | 42 | Nokia | Rel-16 | 83 |  |  |  |
| 3046 | 1267.3.1 | Core part: NR RF requirement enhancements for FR2 | 261d | 2019-03-01 A | 2020-02-28 A | 100% | finish no earlier than 2020-03-01 | R4 | 2088h | 2088h | NR_RF_FR2_req_enh-Core | 42 | Nokia | Rel-16 | 83 |  |  | 38.831 |
| 3047 | 1267.3.2 | Perf. part: NR RF requirement enhancements for FR2 | 127d | 2019-09-19 A | 2020-03-13 A | 100% | finish no earlier than 2020-03-15 | R4 | 1016h | 1016h | NR_RF_FR2_req_enh-Perf | 43 | Nokia | Rel-16 | 85 |  |  |  |
| 3048 | 1267.3.3 | UE Conformance Test Aspects - NR RF requirement enhancements for frequency range 2 (FR2) | 663d | 2021-03-12 A | 2023-09-22 A | 100% | finish no earlier than 2023-09-22 | R5 | 5304h | 5304h | NR_RF_FR2_req_enh-UEConTest | 46 | Tuomo S yn j kangas, Ashwin Mohan, Nokia, Apple | Rel-16 | 91 | tuomo.saynajakangas@nokia.com ashwin_mohan@apple.com | RP-231610 |  |
| 3049 | 1267.4 | **Introduction of an NR SUL (supplemental uplink) band with same uplink frequency range as NR band n5** | 204d | 2019-03-01 A | 2019-09-13 A | 100% |  | R4 | 3384h | 3384h | NR_SUL_UL_n5 | 42 | Huawei | Rel-16 | 83 |  |  |  |
| 3050 | 1267.4.1 | Core part: Introduction of an NR SUL band with same uplink frequency range as NR band n5 | 141d | 2019-03-01 A | 2019-09-13 A | 100% | finish no earlier than 2019-09-15 | R4 | 1128h | 1128h | NR_SUL_UL_n5-Core | 42 | Huawei | Rel-16 | 83 |  |  |  |
| 3051 | 1267.4.2 | Perf. part: Introduction of an NR SUL band with same uplink frequency range as NR band n5 | 141d | 2019-03-01 A | 2019-09-13 A | 100% | finish no earlier than 2019-09-15 | R4 | 1128h | 1128h | NR_SUL_UL_n5-Perf | 42 | Huawei | Rel-16 | 83 |  |  |  |

Notes:
- 3027: 8/10/19: WID:RP-191474->RP-192236
- 3028: 8/10/19: 0%->100
- 3029: 8/10/19: 0%->100
- 3030: 14/1/20: WID:RP-192274->RP-192584
- 3031: 14/1/20: 0%->100
- 3032: 14/1/20: 0%->100
- 3033: affects: NR.
- 3034: affects: NR.; 18/2/20: FCD:15/06/2020->03/20. Rel17->Rel-16; 26/3/20: 0%->100
- 3035: affects: NR.; 18/2/20: FCD:15/06/2020->03/20. Rel17->Rel-16; 26/3/20: 0%->100
- 3036: 16/1/19: WID:RP-181445->RP-182258
- 3037: 26/6/19: WID:RP-190759->RP-191114; 8/10/19: WID:RP-191114->RP-192282; 14/1/20: WID:RP-192282->RP-193266
- 3038: 25/9/20: 0%->100
- 3039: 6/1/21: 0%->100
- 3040: affects: NR. TR 38.8xx; 8/10/20: 0%->15; 8/4/21: 15%->43; ; 6/6/22: CD:10/06/2022->22/12/2022 ; 20/6/22: Rapporteur: Huawei->Chunying Gu, Huawei Technologies. Co., Ltd.; Rap eMail: ->guchunying@huawei.com9/9/22: Compl:64%->69%; 9/12/22: FCD:22/12/20...; 8/12/23: Compl:73%->100%; Stat Rep: RP-232347->RP-233756;
- 3041: 26/6/19: WID:RP-190760->RP-190925; 8/10/19: WID:RP-190925->RP-191891; 26/3/20: WID:RP-191891->RP-200124
- 3042: 8/10/19: 38.883 added;; 28/7/20: 0%->100
- 3043: 7/4/21: 0%->100
- 3044: tested: REL-16 WI NR_DL256QAM_FR2-Core ; 8/4/21: 0%->20; 2/7/21: 20%->44; 13/9/21: Compl:44%->82%; 13/9/21: CD:Fri 10/06/22->Wed 22/06/22 ; ;
- 3045: 26/6/19: WID:RP-190761->RP-191290; 8/10/19: WID:RP-191290->RP-192227; 14/1/20: WID:RP-192227->RP-192653; 26/3/20: WID:RP-192653->RP-200246; 28/7/20: WID:RP-200246->RP-200668; 25/9/20: WID:RP-200668->RP-201606
- 3046: 8/10/19: 38.831 added;; 25/9/20: 0%->100
- 3047: 25/9/20: 0%->100
- 3048: tested: REL-16 WI NR_RF_FR2_req_enh-Core ; 2/7/21: 0%->20; 29/9/21: WID:RP-210363->RP-212304; 22/3/22: Compl:20%->57% ; 20/6/22: Rapporteur: Nokia->Tuomo S yn j kangas, Ashwin Mohan, Nokia, Apple; Rap eMail: ->tuomo.saynajakangas@nokia.com ashwin...;...; 6/9/23: FCD:09/09/2023->22/09/2023; Compl:98%->100%; Stat Rep: RP-230128->RP-231610;
- 3049: 26/6/19: WID:RP-190390->RP-191116; 8/10/19: WID:RP-191116->RP-192080
- 3050: 8/10/19: 0%->100
- 3051: 8/10/19: 0%->100

| ID | WBS | Task | Duration | Start | Finish | Complete | Constraint | Resources | Work | Actual work | Acronym | PCG approved | WI rapporteur name | Release | TSG approved | TSG stopped |
| --- | --- | --- | --- | --- | --- | --- | --- | --- | --- | --- | --- | --- | --- | --- | --- | --- |
| 3052 | 1267.5 | **Adding wider channel bandwidths in NR band n7** | 284.75d | 2018-12-13 A | 2019-09-13 A | 100% |  | R4 | 3152h | 3152h | NR_n7_BW | 42 | BT | Rel-16 | 82 |  |
| 3053 | 1267.5.1 | Core part: Adding wider channel bandwidths in NR band n7 | 197d | 2018-12-13 A | 2019-09-13 A | 100% | start no earlier than 2018-12-13 | R4 | 1576h | 1576h | NR_n7_BW-Core | 42 | BT | Rel-16 | 82 |  |
| 3054 | 1267.6 | **Addition of wider channel bandwidth in NR band n38** | 298.25d | 2019-03-01 A | 2019-12-13 A | 100% |  | R4 | 4944h | 4944h | NR_n38_BW | 42 | Huawei | Rel-16 | 83 |  |
| 3055 | 1267.6.1 | Core part: Addition of wider channel bandwidth in NR band n38 | 206d | 2019-03-01 A | 2019-12-13 A | 100% | finish no earlier than 2019-12-15 | R4 | 1648h | 1648h | NR_n38_BW-Core | 42 | Huawei | Rel-16 | 83 |  |
| 3056 | 1267.6.2 | Perf. part: Addition of wider channel bandwidth in NR band n38 | 206d | 2019-03-01 A | 2019-12-13 A | 100% | finish no earlier than 2019-12-15 | R4 | 1648h | 1648h | NR_n38_BW-Perf | 42 | Huawei | Rel-16 | 83 |  |
| 3057 | 1267.7 | **Addition of further channel bandwidths in NR band 38** | 183.25d | 2019-09-19 A | 2020-03-13 A | 100% |  | R4 | 3048h | 3048h | NR_n38_BW2 | 43 | Ericsson | Rel-16 | 85 |  |
| 3058 | 1267.7.1 | Core part: Addition of further channel bandwidths in NR band 38 | 127d | 2019-09-19 A | 2020-03-13 A | 100% | finish no earlier than 2020-03-15 | R4 | 1016h | 1016h | NR_n38_BW2-Core | 43 | Ericsson | Rel-16 | 85 |  |
| 3059 | 1267.7.2 | Perf. part: Addition of further channel bandwidths in NR band 38 | 127d | 2019-09-19 A | 2020-03-13 A | 100% | finish no earlier than 2020-03-15 | R4 | 1016h | 1016h | NR_n38_BW2-Perf | 43 | Ericsson | Rel-16 | 85 |  |
| 3060 | 1267.8 | **Addition of 30MHz channel bandwidth for NR band n41** | 194.75d | 2018-12-13 A | 2019-06-18 A | 100% |  | R4 | 3216h | 3216h | NR_n41_BW | 42 | KDDI | Rel-16 | 82 |  |
| 3061 | 1267.8.1 | Core part: Addition of 30MHz channel bandwidth for NR band n41 | 134d | 2018-12-13 A | 2019-06-18 A | 100% | start no earlier than 2018-12-13 | R4 | 1072h | 1072h | NR_n41_BW-Core | 42 | KDDI | Rel-16 | 82 |  |
| 3062 | 1267.8.2 | Stopped - Perf. part: Addition of 30MHz channel bandwidth for NR band n41 | 134d | 2018-12-13 A | 2019-06-18 A | 100% | start no earlier than 2018-12-13 | R4 | 1072h | 1072h | NR_n41_BW-Perf | 42 | KDDI | Rel-16 | 82 | 84 |
| 3063 | 1267.9 | **Adding wider channel bandwidths in NR band n50** | 194.75d | 2018-12-13 A | 2019-06-18 A | 100% |  | R4 | 2144h | 2144h | NR_n50_BW | 42 | Huawei | Rel-16 | 82 |  |
| 3064 | 1267.9.1 | Core part: Adding wider channel bandwidths in NR band n50 | 134d | 2018-12-13 A | 2019-06-18 A | 100% | start no earlier than 2018-12-13 | R4 | 1072h | 1072h | NR_n50_BW-Core | 42 | Huawei | Rel-16 | 82 |  |
| 3065 | 1267.10 | **Addition of wider channel bandwidths in NR band n75** | 183.25d | 2019-09-19 A | 2020-03-13 A | 100% |  | R4 | 3048h | 3048h | NR_n75_BW | 43 | Ericsson | Rel-16 | 85 |  |
| 3066 | 1267.10.1 | Core part: Addition of wider channel bandwidths in NR band n75 | 127d | 2019-09-19 A | 2020-03-13 A | 100% | finish no earlier than 2020-03-15 | R4 | 1016h | 1016h | NR_n75_BW-Core | 43 | Ericsson | Rel-16 | 85 |  |
| 3067 | 1267.10.2 | Perf. part: Addition of wider channel bandwidths in NR band n75 | 127d | 2019-09-19 A | 2020-03-13 A | 100% | finish no earlier than 2020-03-15 | R4 | 1016h | 1016h | NR_n75_BW-Perf | 43 | Ericsson | Rel-16 | 85 |  |
| 3068 | 1267.11 | **Addition of 25, 30, 35 and 40 MHz channel bandwidth for NR band n25** | 183.25d | 2019-09-19 A | 2020-03-13 A | 100% |  | R4 | 3048h | 3048h | NR_n25_BW | 43 | Nokia | Rel-16 | 85 |  |
| 3069 | 1267.11.1 | Core part: Addition of 25, 30, 35 and 40 MHz channel bandwidth for NR band n25 | 127d | 2019-09-19 A | 2020-03-13 A | 100% | finish no earlier than 2020-03-15 | R4 | 1016h | 1016h | NR_n25_BW-Core | 43 | Nokia | Rel-16 | 85 |  |
| 3070 | 1267.11.2 | Perf. part: Addition of 25, 30, 35 and 40 MHz channel bandwidth for NR band n25 | 127d | 2019-09-19 A | 2020-03-13 A | 100% | finish no earlier than 2020-03-15 | R4 | 1016h | 1016h | NR_n25_BW-Perf | 43 | Nokia | Rel-16 | 85 |  |
| 3071 | 1267.12 | **Addition of wider channel bandwidths in NR band n28** | 183.25d | 2019-09-19 A | 2020-03-13 A | 100% |  | R4 | 3048h | 3048h | NR_n28_BW | 43 | CBN | Rel-16 | 85 |  |
| 3072 | 1267.12.1 | Core part: Addition of wider channel bandwidths in NR band n28 | 127d | 2019-09-19 A | 2020-03-13 A | 100% | finish no earlier than 2020-03-15 | R4 | 1016h | 1016h | NR_n28_BW-Core | 43 | CBN | Rel-16 | 85 |  |
| 3073 | 1267.12.2 | Perf. part: Addition of wider channel bandwidths in NR band n28 | 127d | 2019-09-19 A | 2020-03-13 A | 100% | finish no earlier than 2020-03-15 | R4 | 1016h | 1016h | NR_n28_BW-Perf | 43 | CBN | Rel-16 | 85 |  |
| 3074 | 1267.13 | **Addition of new channel bandwidth in NR band n1** | 183.25d | 2019-09-19 A | 2020-03-13 A | 100% |  | R4 | 3048h | 3048h | NR_n1_BW2 | 43 | China Unicom | Rel-16 | 85 |  |
| 3075 | 1267.13.1 | Core part: Addition of new channel bandwidth in NR band n1 | 127d | 2019-09-19 A | 2020-03-13 A | 100% | finish no earlier than 2020-03-15 | R4 | 1016h | 1016h | NR_n1_BW2-Core | 43 | China Unicom | Rel-16 | 85 |  |
| 3076 | 1267.13.2 | Perf. part: Addition of new channel bandwidth in NR band n1 | 127d | 2019-09-19 A | 2020-03-13 A | 100% | finish no earlier than 2020-03-15 | R4 | 1016h | 1016h | NR_n1_BW2-Perf | 43 | China Unicom | Rel-16 | 85 |  |

Notes:
- 3052: no Perf. part¦26/3/19: WID:RP-182827->RP-190137
- 3053: no Perf. part¦26/3/19: WID:RP-182827->RP-190137; 8/10/19: 0%->100
- 3054: 26/6/19: WID:RP-190392->RP-191472; 14/1/20: WID:RP-191472->RP-192513; 13/6/21: WID:RP-192513->RP-191472
- 3055: 14/1/20: 0%->100
- 3056: 14/1/20: 0%->100
- 3057: 13/6/21: WID:RP-192215->RP-192513
- 3058: compare REL-16 WI NR_n38_BW; 26/3/20: 0%->100
- 3059: 26/3/20: 0%->100
- 3060: 26/3/19: WID:RP-182828->RP-190174; 26/6/19: WID:RP-190174->RP-191569; 8/10/19: WID:RP-191569->RP-191681
- 3061: 26/3/19: WID:RP-182828->RP-190174; 8/10/19: 0%->100
- 3062: 26/3/19: WID:RP-182828->RP-190174. 08/10/2019: stopped at 0%; 8/10/19: 0%->100
- 3063: no Perf. part
- 3064: no Perf. part; 26/6/19: 0%->100
- 3066: 14/1/20: 0%->100
- 3067: 14/1/20: 0%->100
- 3068: 14/1/20: WID:RP-192219->RP-192401
- 3069: 14/1/20: 0%->100
- 3070: 14/1/20: 0%->100
- 3071: 14/1/20: WID:RP-192261->RP-192656
- 3072: 26/3/20: 0%->100
- 3073: 26/3/20: 0%->100
- 3074: 8/10/19: WID:RP-192275->RP-192009. compare REL-16 WI NR_n1_BW; 14/1/20: WID:RP-192275->RP-192801
- 3075: 28/7/20: 0%->100
- 3076: 28/7/20: 0%->100

| ID | WBS | Task | Type | Duration | Start | Finish | Complete | Actual finish | Constraint | Resources | Work | Actual work | Acronym | PCG approved | Release | TSG approved | WI rapporteur e-mail | Status Report | Impacted TSs and TRs |
| --- | --- | --- | --- | --- | --- | --- | --- | --- | --- | --- | --- | --- | --- | --- | --- | --- | --- | --- | --- |
| 3077 | 1267.14 | **Addition of asymmetric channel bandwidth for NR band n66** |  | 183.25d | 2019-09-19 A | 2020-03-13 A | 100% |  |  | R4 | 2032h | 2032h | NR_n66_BW | 43 | Rel-16 | 85 |  |  |  |
| 3078 | 1267.14.1 | Core part: Addition of asymmetric channel bandwidth for NR band n66 |  | 127d | 2019-09-19 A | 2020-03-13 A | 100% |  | finish no earlier than 2020-03-15 | R4 | 1016h | 1016h | NR_n66_BW-Core | 43 | Rel-16 | 85 |  |  |  |
| 3079 | 1268 | **Enhancements on MIMO for NR** |  | 1616.62d? | 2018-06-15 A | 2022-09-22 A | 100% |  |  | R1 | 21464h | 21464h | NR_eMIMO | 41 | Rel-16 | 80 |  |  |  |
| 3080 | 1268.1 | Core part: Enhancements on MIMO for NR |  | 391d? | 2018-06-15 A | 2019-12-13 A | 100% |  | finish no earlier than 2019-12-15 | R1 | 3128h | 3128h | NR_eMIMO-Core | 41 | Rel-16 | 80 |  |  |  |
| 3081 | 1268.2 | Perf. part: Enhancements on MIMO for NR |  | 588d? | 2018-06-15 A | 2020-09-15 A | 100% |  | finish no earlier than 2020-09-15 | R4 | 4704h | 4704h | NR_eMIMO-Perf | 41 | Rel-16 | 80 |  |  |  |
| 3082 | 1268.3 | UE Conformance Test Aspects - Enhancements on MIMO for NR |  | 589d | 2020-06-22 A | 2022-09-22 A | 100% |  | finish no earlier than 2022-12-22 | R5 | 4712h | 4712h | NR_eMIMO-UEConTest | 45 | Rel-16 | 88 | guchunying@huawei.com | RP-221483 |  |
| 3083 | 1269 | **NR mobility enhancements** |  | 1616.62d? | 2018-06-15 A | 2022-09-22 A | 100% |  |  | R2 | 19888h | 19888h | NR_Mob_enh | 41 | Rel-16 | 80 |  |  |  |
| 3084 | 1269.1 | Core part: NR mobility enhancements |  | 391d? | 2018-06-15 A | 2019-12-13 A | 100% |  | finish no earlier than 2019-12-15 | R2 | 3128h | 3128h | NR_Mob_enh-Core | 41 | Rel-16 | 80 |  |  |  |
| 3085 | 1269.2 | Perf. part: NR mobility enhancements |  | 391d? | 2018-06-15 A | 2019-12-13 A | 100% |  | finish no earlier than 2019-12-15 | R4 | 3128h | 3128h | NR_Mob_enh-Perf | 41 | Rel-16 | 80 |  |  |  |
| 3086 | 1269.3 | UE Conformance Test Aspects - NR Mobility Enhancements |  | 589d | 2020-06-22 A | 2022-09-22 A | 100% |  | finish no earlier than 2022-12-22 | R5 | 4712h | 4712h | NR_Mob_enh-UEConTest | 45 | Rel-16 | 88 | yangzhaobing @hisilicon.com | RP-221480 |  |
| 3087 | 1270 | **2-step RACH for NR** |  | 379.25d | 2018-12-15 A | 2019-12-15 | 100% | 2022-09-22 |  | R1 | 8472h | 8472h | NR_2step_RACH | 42 | Rel-16 | 82 |  |  |  |
| 3088 | 1270.1 | Core part: 2-step RACH for NR | manual | 262d | 2018-12-15 A | 2019-12-15 A | 100% |  |  | R1 | 2096h | 2096h | NR_2step_RACH-Core | 42 | Rel-16 | 82 |  |  |  |
| 3089 | 1270.2 | Perf. part: 2-step RACH for NR | manual | 135d | 2018-12-15 A | 2019-06-20 A | 100% |  |  | R4 | 1080h | 1080h | NR_2step_RACH-Perf | 42 | Rel-16 | 82 |  |  |  |
| 3090 | 1270.3 | UE Conformance Test Aspects - 2-step RACH for NR |  | 400d | 2021-03-12 A | 2022-09-22 A | 100% |  | finish no earlier than 2022-12-22 | R5 | 3200h | 3200h | NR_2step_RACH-UEConTest | 46 | Rel-16 | 91 | ma.wei4@zte.com.cn, zhaoj16@chinatelecom.cn | RP-221195 |  |
| 3091 | 1271 | **SON (Self-Organising Networks) and MDT (Minimization of Drive Tests) support for NR** |  | 1141.12d | 2019-06-17 A | 2022-06-22 A | 100% |  |  | R3 | 11544h | 11544h | NR_SON_MDT | 43 | Rel-16 | 84 |  |  |  |
| 3092 | 1271.1 | Core part: SON (Self-Organising Networks) and MDT (Minimization of Drive Tests) support for NR |  | 195d | 2019-06-17 A | 2020-03-13 A | 100% |  | finish no earlier than 2020-03-15 | R3 | 1560h | 1560h | NR_SON_MDT-Core | 43 | Rel-16 | 84 |  |  | 38.314 |
| 3093 | 1271.2 | UE Conformance Test Aspects - SON (Self-Organising Networks) and MDT (Minimization of Drive Tests) support for NR |  | 460d | 2020-09-17 A | 2022-06-22 A | 100% |  | finish no earlier than 2022-06-22 | R5 | 3680h | 3680h | NR_SON_MDT-UEConTest | 45 | Rel-16 | 89 | dongwenjia@chinamobile.com, leif.mattisson@ericsson.com | RP-221368 |  |
| 3094 | 1272 | Study on Self-Organizing Networks (SON) for 5G |  | 202d? | 2018-09-06 A | 2019-06-14 A | 100% |  | finish no earlier than 2019-06-14 | S5 | 1616h | 1616h | FS_SON_5G | 41 | Rel-16 | 81 | joey<dot>chou<at>intel<dot>com |  | New |
| 3095 | 1273 | Self-Organizing Networks (SON) for 5G networks |  | 258d | 2019-09-19 A | 2020-09-14 A | 100% |  | finish no earlier than 2020-09-14 | S5 | 2064h | 2064h | SON_5G | 43 | Rel-16 | 85 | joey<dot>chou<at>intel<dot>com |  | 28.552; 28.545 ; 28.544; 28.313 |
| 3096 | 1274 | **RRM requirement for CSI-RS based L3 measurement in NR** |  | 473.25d | 2019-06-17 A | 2020-09-15 A | 100% |  |  | R4 | 6792h | 6792h | NR_CSIRS_L3meas | 43 | Rel-16 | 84 |  |  |  |
| 3097 | 1274.1 | Core part: RRM requirement for CSI-RS based L3 measurement in NR |  | 195d | 2019-06-17 A | 2020-03-13 A | 100% |  | finish no earlier than 2020-03-15 | R4 | 1560h | 1560h | NR_CSIRS_L3meas-Core | 43 | Rel-16 | 84 |  |  |  |
| 3098 | 1274.2 | Perf. part: RRM requirement for CSI-RS based L3 measurement in NR |  | 327d | 2019-06-17 A | 2020-09-15 A | 100% |  | finish no earlier than 2020-09-15 | R4 | 2616h | 2616h | NR_CSIRS_L3meas-Perf | 43 | Rel-16 | 84 |  |  |  |
| 3099 | 1275 | **NR performance requirement enhancement** |  | 1141.12d | 2019-06-17 A | 2022-06-22 A | 100% |  |  | R4 | 10504h | 10504h | NR_perf_enh | 43 | Rel-16 | 84 |  |  |  |
| 3100 | 1275.1 | Perf. part: NR performance requirement enhancement |  | 65d | 2019-06-17 A | 2019-09-13 A | 100% |  | finish no earlier than 2019-09-15 | R4 | 520h | 520h | NR_perf_enh-Perf | 43 | Rel-16 | 84 |  |  |  |
| 3101 | 1275.2 | UE Conformance Test Aspects - NR performance requirement enhancement |  | 460d | 2020-09-17 A | 2022-06-22 A | 100% |  | finish no earlier than 2022-06-22 | R5 | 3680h | 3680h | NR_perf_enh-UEConTest | 45 | Rel-16 | 89 | wujingzhou@chinatelecom.cn, vijayb@qti.qualcomm.com | RP-221294 |  |

Notes:
- 3077: no Perf. Part; 14/1/20: WID:RP-192276->RP-192808; 26/3/20: WID:RP-192808->RP-200265 / WI rapporteur name: Huawei
- 3078: 28/7/20: WID:RP-200265->RP-201010; 28/7/20: 0%->100 / WI rapporteur name: Huawei
- 3079: 16/1/19: WID:RP-181453->RP-182863; 8/10/19: WID:RP-182863->RP-192271; 26/3/20: WID:RP-192271->RP-200474 / WI rapporteur name: Samsung
- 3080: 25/9/20: 0%->100 / WI rapporteur name: Samsung
- 3081: 7/4/21: 0%->100 / WI rapporteur name: Samsung
- 3082: 8/10/20: 0%->1; 8/4/21: 1%->16; 2/7/21: 16%->20; 22/3/22: Compl:20%->57%; 6/6/22: Compl:57%-> ; 20/6/22: Rapporteur: Huawei->Chunying GU, Huawei; Rap eMail: ->guchunying@huawei.com 9/9/22: Compl:64%->100% ; 9/9/22: CD:22/12/202... / WI rapporteur name: Chunying GU, Huawei
- 3083: 26/3/19: WID:RP-181433->RP-190489; 8/10/19: WID:RP-190489->RP-192277; 14/1/20: WID:RP-192277->RP-192534 / WI rapporteur name: Intel
- 3084: 26/3/19: WID:RP-181433->RP-190489; 28/7/20: 0%->100 / WI rapporteur name: Intel
- 3085: 26/3/19: WID:RP-181433->RP-190489; 6/1/21: 0%->100 / WI rapporteur name: Intel
- 3086: 8/10/20: 0%->5; 8/4/21: 5%->35; 22 6/6/22: CD:10 ; 20/6/22: Rapporteur: Huawei->Zhaobing Yang, Huawei Technologies. Co., Ltd.; Rap eMail: ->yangzhaobing @hisilicon.com12/7/22: WID:RP-200893->RP-2214819/9/22: Compl:97%->100%9/9/22: ... / WI rapporteur name: Zhaobing Yang, Huawei Technologies. Co., Ltd.
- 3087: WI was created after REL-16 SI FS_NR_NOMA was completed¦26/3/19: WID:RP-182894->RP-190711; 8/10/19: WID:RP-190711->RP-192330; 26/3/20: WID:RP-192330->RP-200085 / WI rapporteur name: ZTE
- 3088: WI was created after REL-16 SI FS_NR_NOMA was completed¦26/3/19: WID:RP-182894->RP-190711; 28/7/20: 0%->100; 28/7/20: 100%->100 / WI rapporteur name: ZTE
- 3089: 26/3/19: WID:RP-182894->RP-190711; 6/1/21: 0%->100 / WI rapporteur name: ZTE
- 3090: tested REL-16 WI NR_2step_RACH-Core ; 2/7/21: 0%->25; 13/9/21: Compl:25%->54%; 13/9/21: CD:Fri 11/03/22->Tue 22/03/22; 13/9/21: Stat Rep: ->RP-211763; 20/6/22: Rapporteur: ZTE->Wei Ma, Jing Zhao, ZTE, China Telecom; Rap eMail: ->ma.wei4@zte.com... / WI rapporteur name: Wei Ma, Jing Zhao, ZTE, China Telecom
- 3091: no Perf. part; impact on SA2, SA5, CT4?; TR 38.314 / WI rapporteur name: CMCC
- 3092: no Perf. part; impact on SA2, SA5, CT4?; TR 38.314; 8/10/19: WID:RP-191594->RP-191776; 8/10/19: 38.314 added;; 14/1/20: WID:RP-191776->RP-192610; 28/7/20: 0%->100 / WI rapporteur name: CMCC
- 3093: tested: REL-16 WI NR_SON_MDT-Core ; 7/4/21: WID:RP-201625->RP-210377; 8/4/21: 0%->37; 2/7/21: 37%->71; 13/9/21: Compl:71%->85%; ; 20/6/22: Rapporteur: CMCC->Wenjia DONG, Leif Mattisson, CMCC, Ericsson; Rap eMail: ->dongwenjia@chinamobile.com, ... / WI rapporteur name: Wenjia DONG, Leif Mattisson, CMCC, Ericsson
- 3094: 7/12/18: 0%->10¦14/3/19: 10%->40; 31/5/19: 40%->50; 6/12/19: 50%->100 / WI rapporteur name: Joey Chou, Intel
- 3095: ; 13/9/19: 0%->80; 8/10/19: 28.544 added;; 8/10/19: 28.313 added;; 28/6/20: 80%->75; 13/9/20: 75%->100; 13/9/20: WID:SP-190785->SP-200763; 13/9/20: FCD:12/03/2020->09/20 / WI rapporteur name: Joey Chou, Intel
- 3096: 8/10/19: WID:RP-191580->RP-191992; 26/3/20: WID:RP-191992->RP-200240; 28/7/20: WID:RP-200240->RP-201345; 25/9/20: WID:RP-201345->RP-201975; 6/1/21: WID:RP-201975->RP-202723; 7/4/21: WID:RP-202723->RP-210590 / WI rapporteur name: CATT
- 3097: 25/9/20: 0%->100 / WI rapporteur name: CATT
- 3098: 2/7/21: 0%->100 / WI rapporteur name: CATT
- 3099: no Core part; 8/10/19: WID:RP-191587->RP-192281; 14/1/20: WID:RP-192281->RP-192532; 26/3/20: WID:RP-192532->RP-200472 / WI rapporteur name: China Telecom
- 3100: no Core part; 7/4/21: 0%->100 / WI rapporteur name: China Telecom
- 3101: tested: REL-16 WI NR_perf_enh-Perf ; 6/1/21: WID:RP-201941->RP-202557; Qualcomm -> China Telecom; 8/4/21: 0%->15; 2/7/21: 15%->18; 13/9/21: Compl:18%->21%; ; 20/6/22: Rapporteur: Qualcomm -> China Telecom->Wu Jingzhou, Balasubramanian Vijay, C... / WI rapporteur name: Wu Jingzhou, Balasubramanian Vijay, China Telecom, Qualcomm Inc

| ID | WBS | Task | Type | Duration | Start | Finish | Complete | Remaining | Total slack | Constraint | Resources | Work | Actual work | Acronym | PCG approved | WI rapporteur name | Release | TSG approved | WI rapporteur e-mail | Status Report |
| --- | --- | --- | --- | --- | --- | --- | --- | --- | --- | --- | --- | --- | --- | --- | --- | --- | --- | --- | --- | --- |
| 3102 | 1276 | **NR RRM enhancement** |  | 2077d | 2019-06-17 A | 2024-12-12 | 96% | 78.41d |  |  | R4 | 26400h | 5736h | NR_RRM_enh | 43 | Intel | Rel-16 | 84 |  |  |
| 3103 | 1276.1 | Core part: NR RRM enhancement |  | 195d | 2019-06-17 A | 2020-03-13 A | 100% |  |  | finish no earlier than 2020-03-15 | R4 | 1560h | 1560h | NR_RRM_enh-Core | 43 | Intel | Rel-16 | 84 |  |  |
| 3104 | 1276.2 | Perf. part: NR RRM enhancement |  | 261d | 2019-06-17 A | 2020-06-15 A | 100% |  |  | finish no earlier than 2020-06-15 | R4 | 2088h | 2088h | NR_RRM_enh-Perf | 43 | Intel | Rel-16 | 84 |  |  |
| 3105 | 1276.3 | UE Conformance Test Aspects - NR RRM enhancements |  | 1406d | 2022-06-15 A | 2026-03-03 | 95% | 70.3d | 37744.2d | finish no earlier than 2026-03-03 | R5 | 11248h |  | NR_RRM_enh-UEConTest | 49 | Xinrong Wang, Apple | Rel-16 | 96 | xinrong_wang@apple.com | RP-253216 |
| 3106 | 1277 | **Rel-16 NR inter-band Carrier Aggregation for 4 bands DL with 1 band UL** |  | 280.5d | 2019-06-17 A | 2020-03-13 A | 100% |  |  |  | R4 | 4680h | 4680h | NR_CA_R16_4BDL_1BUL | 43 | Ericsson | Rel-16 | 84 |  |  |
| 3107 | 1277.1 | Core part: Rel-16 NR inter-band Carrier Aggregation for 4 bands DL with 1 band UL |  | 195d | 2019-06-17 A | 2020-03-13 A | 100% |  |  | finish no earlier than 2020-03-15 | R4 | 1560h | 1560h | NR_CA_R16_4BDL_1BUL-Core | 43 | Ericsson | Rel-16 | 84 |  |  |
| 3108 | 1277.2 | Perf. part: Rel-16 NR inter-band Carrier Aggregation for 4 bands DL with 1 band UL |  | 195d | 2019-06-17 A | 2020-03-13 A | 100% |  |  | finish no earlier than 2020-03-15 | R4 | 1560h | 1560h | NR_CA_R16_4BDL_1BUL-Perf | 43 | Ericsson | Rel-16 | 84 |  |  |
| 3109 | 1278 | **Addition of wider channel bandwidth in NR band n1** |  | 280.5d | 2019-06-17 A | 2020-03-13 A | 100% |  |  |  | R4 | 4680h | 4680h | NR_n1_BW | 43 | Ericsson | Rel-16 | 84 |  |  |
| 3110 | 1278.1 | Core part: Addition of wider channel bandwidth in NR band n1 |  | 195d | 2019-06-17 A | 2020-03-13 A | 100% |  |  | finish no earlier than 2020-03-15 | R4 | 1560h | 1560h | NR_n1_BW-Core | 43 | Ericsson | Rel-16 | 84 |  |  |
| 3111 | 1278.2 | Perf. part: Addition of wider channel bandwidth in NR band n1 |  | 195d | 2019-06-17 A | 2020-03-13 A | 100% |  |  | finish no earlier than 2020-03-15 | R4 | 1560h | 1560h | NR_n1_BW-Perf | 43 | Ericsson | Rel-16 | 84 |  |  |
| 3112 | 1279 | **Addition of channel bandwidths in Band n77 and n78** |  | 186.25d | 2019-06-17 A | 2019-12-13 A | 100% |  |  |  | R4 | 2080h | 2080h | NR_n77_n78_BW | 43 | Huawei | Rel-16 | 84 |  |  |
| 3113 | 1279.1 | Core part: Addition of channel bandwidths in Band n77 and n78 |  | 130d | 2019-06-17 A | 2019-12-13 A | 100% |  |  | finish no earlier than 2019-12-15 | R4 | 1040h | 1040h | NR_n77_n78_BW-Core | 43 | Huawei | Rel-16 | 84 |  |  |
| 3114 | 1280 | **Dual Connectivity (EN-DC) with 3 bands DL and 3 bands UL** |  | 280.5d | 2019-06-17 A | 2020-03-13 A | 100% |  |  |  | R4 | 4680h | 4680h | DC_R16_LTE_NR_3DL3UL | 43 | ZTE | Rel-16 | 84 |  |  |
| 3115 | 1280.1 | Core part: Dual Connectivity (EN-DC) with 3 bands DL and 3 bands UL |  | 195d | 2019-06-17 A | 2020-03-13 A | 100% |  |  | finish no earlier than 2020-03-15 | R4 | 1560h | 1560h | DC_R16_LTE_NR_3DL3UL-Core | 43 | ZTE | Rel-16 | 84 |  |  |
| 3116 | 1280.2 | Perf. part: Dual Connectivity (EN-DC) with 3 bands DL and 3 bands UL |  | 195d | 2019-06-17 A | 2020-03-13 A | 100% |  |  | finish no earlier than 2020-03-15 | R4 | 1560h | 1560h | DC_R16_LTE_NR_3DL3UL-Perf | 43 | ZTE | Rel-16 | 84 |  |  |
| 3117 | 1281 | **Introduction of NR FDD bands with variable duplex and corresponding framework** |  | 186.25d | 2019-06-17 A | 2019-12-13 A | 100% |  |  |  | R4 | 2576h | 2576h | NR_FDD_bands_varduplex | 43 | Huawei | Rel-16 | 84 |  |  |
| 3118 | 1281.1 | Core part: Introduction of NR FDD bands with variable duplex and corresponding framework |  | 130d | 2019-06-17 A | 2019-12-13 A | 100% |  |  | start no earlier than 2019-06-17 | R4 | 1040h | 1040h | NR_FDD_bands_varduplex-Core | 43 | Huawei | Rel-16 | 84 |  |  |
| 3119 | 1281.2 | Perf. part: Introduction of NR FDD bands with variable duplex and corresponding framework |  | 62d | 2019-09-19 A | 2019-12-13 A | 100% |  |  | finish no earlier than 2019-12-15 | R4 | 496h | 496h | NR_FDD_bands_varduplex-Perf | 43 | Huawei | Rel-16 | 85 |  |  |
| 3120 | 1282 | **Common RF requirement configured output power for EN-DC with 3 uplink CC and 2 different bands (2CC LTE, 1CC NR FR1)** |  | 1023.62d | 2019-10-08 A | 2022-06-22 | 46% | 552.76d | 39142d |  | R4 | 8448h | 3768.11h | DC_Pcmax_3UL_CC | 43 | Huawei | Rel-16 | 84 |  |  |
| 3121 | 1282.1 | Core part: Common RF requirement configured output power for EN-DC with 3 uplink CC and 2 different bands (2CC LTE, 1CC NR FR1) |  | 162d | 2019-10-08 | 2020-03-12 |  |  | 40003.6d | finish no earlier than 2020-03-12 | R4 | 1296h |  | DC_Pcmax_3UL_CC-Core | 43 | Huawei | Rel-16 | 84 |  |  |
| 3122 | 1282.2 | UE Conformance Test Aspects - Common RF requirement configured output power for EN-DC with 3 uplink CC and 2 different bands (2CC LTE, 1CC NR FR1) |  | 138d | 2021-12-13 A | 2022-06-22 A | 100% |  |  | finish no earlier than 2022-06-22 | R5 | 1104h | 1104h | DC_Pcmax_3UL_CC-UEConTest | 48 | Huawei | Rel-16 | 94 |  | RP-221486 |
| 3123 | 1283 | **Addition of NR UE measurements to enable OTA conformance testing** |  | 38.25d | 2020-06-22 A | 2020-07-28 A | 100% |  |  |  | R1 | 432h | 432h | NR_OTA_Uemeas | 45 | Keysight Technologies | Rel-16 | 88 |  |  |
| 3124 | 1283.1 | Core part: Addition of NR UE measurements to enable OTA conformance testing |  | 27d | 2020-06-22 A | 2020-07-28 A | 100% |  |  | finish no earlier than 2020-07-28 | R1 | 216h | 216h | NR_OTA_Uemeas-Core | 45 | Keysight Technologies | Rel-16 | 88 |  |  |
| 3125 | 1284 | Release 16 Features impacting both LTE and NR | milestone | 0d? | 2019-03-07 A | 2019-03-07 A | 100% |  |  |  |  |  |  |  |  |  | Rel-16 |  |  |  |

Notes:
- 3102: 8/10/19: WID:RP-191601->RP-192157; 14/1/20: WID:RP-192157->RP-193211; 26/3/20: WID:RP-193211->RP-200256; 28/7/20: WID:RP-200256->RP-201112; 25/9/20: WID:RP-201112->RP-201883
- 3103: 25/9/20: 0%->100
- 3104: 6/1/21: WID:RP-201883->RP-202655; 7/4/21: 0%->100
- 3105: 9/9/22: Comp...; 9/12/22: FCD:23/12/2022->01/12/2023; Compl:5%->9%; Stat Rep: ->RP-222901; Rapporteur: Apple->Ashwin Mohan, Apple; Rap eMail: ->ashwin_mohan[at]apple.com; 17/3/23: FCD:30/11/2023->12/12/2023; Compl:9%->12%; Stat Rep: RP-22.....; 3/12/25: FCD:Fri 12/12/25->Tue 03/03/26; Compl:93%->95%; Stat Rep: RP-252334->RP-253216;
- 3106: basket WI; TR 38.716-04-01; 8/10/19: WID:RP-191196->RP-191814; 14/1/20: WID:RP-191814->RP-192447; 26/3/20: WID:RP-192447->RP-200103; 28/7/20: WID:RP-200103->RP-200658
- 3107: basket WI; TR 38.716-04-01; 28/7/20: 0%->100
- 3108: basket WI; 28/7/20: 0%->100
- 3109: 8/10/19: WID:RP-191595->RP-192009
- 3110: 26/3/20: 0%->100
- 3111: 26/3/20: 0%->100
- 3112: no Perf. part
- 3113: no Perf. part; 8/10/19: WID:RP-191606->RP-192349; 14/1/20: WID:RP-192349->RP-192822; 26/3/20: 0%->100
- 3114: max. 2 NR bands for DL and UL; min. 1 NR FR2 band; TR 37.716-xx-xx; 8/10/19: WID:RP-191598->RP-191882; 14/1/20: WID:RP-191882->RP-192537; 26/3/20: WID:RP-192537->RP-200110; 28/7/20: WID:RP-200110->RP-201254
- 3115: max. 2 NR bands for DL and UL; min. 1 NR FR2 band; TR 37.716-xx-xx; 28/7/20: 0%->100
- 3116: max. 2 NR bands for DL and UL; min. 1 NR FR2 band; 28/7/20: 0%->100
- 3117: no Perf. part as no Perf. part objectives; NR FDD bands are based on NR SDL/SUL bands; framework part will consider interworking with LTE but without normative changes (they may follow later in EN-DC basket WIs; 8/10/19: WID:RP-191567->RP-192285; 14/1
- 3118: no Perf. part as no Perf. part objectives; NR FDD bands are based on NR SDL/SUL bands; framework part will consider interworking with LTE but without normative changes (they may follow later in EN-DC basket WIs; 8/10/19: WID:RP-191567->RP-192285; 14/1
- 3119: 14/1/20: 0%->100
- 3120: no Perf. Part; note: Some combinations were removed from REL-15 due to missing Pc,max; the combinations will be covered in existing REL-16 basket Wis once Pc,max is specified in this WI
- 3121: no Perf. Part; note: Some combinations were removed from REL-15 due to missing Pc,max; the combinations will be covered in existing REL-16 basket Wis once Pc,max is specified in this WI; 8/10/19: WID:RP-191604->RP-192093
- 3122: tested: REL-16 WI DC_Pcmax_3UL_CC-Core; 22/3/22: Compl:0%->71%; ;
- 3124: 28/7/20: 0%->100; 28/7/20: 0%->100
- 3125: -

| ID | WBS | Task | Duration | Start | Finish | Complete | Constraint | Resources | Work | Actual work | Acronym | PCG approved | WI rapporteur name | Release | TSG approved | WI rapporteur e-mail | Status Report |
| --- | --- | --- | --- | --- | --- | --- | --- | --- | --- | --- | --- | --- | --- | --- | --- | --- | --- |
| 3126 | 1285 | **Over the air (OTA) base station (BS) testing TR** | 94.25d | 2019-03-07 A | 2019-06-05 A | 100% |  | R4 | 1040h | 1040h | OTA_BS_testing | 44 | Huawei | Rel-16 | 86 |  |  |
| 3127 | 1285.1 | Perf. Part: Over the air (OTA) base station (BS) testing TR | 65d | 2019-03-07 A | 2019-06-05 A | 100% |  | R4 | 520h | 520h | OTA_BS_testing-Perf | 44 | Huawei | Rel-16 | 86 |  |  |
| 3128 | 1286 | **High power UE (power class 2) for EN-DC (1 LTE FDD band + 1 NR TDD band)** | 758.88d | 2019-12-16 A | 2021-12-17 A | 100% |  | R4 | 7336h | 7336h | ENDC_UE_PC2_FDD_TDD | 44 | China Unicom | Rel-16 | 86 |  |  |
| 3129 | 1286.1 | Core part: High power UE (power class 2) for EN-DC (1 LTE FDD band + 1 NR TDD band) | 65d | 2019-12-16 A | 2020-03-13 A | 100% | finish no earlier than 2020-03-15 | R4 | 520h | 520h | ENDC_UE_PC2_FDD_TDD-Core | 44 | China Unicom | Rel-16 | 86 |  |  |
| 3130 | 1286.2 | UE Conformance Test Aspects - High power UE (power class 2) for EN-DC (1 LTE FDD band + 1 NR TDD band) | 327d | 2020-09-17 A | 2021-12-17 A | 100% | finish no earlier than 2021-12-17 | R5 | 2616h | 2616h | ENDC_UE_PC2_FDD_TDD-UEConTest | 45 | China Unicom | Rel-16 | 89 |  |  |
| 3131 | 1287 | **Dual Connectivity (EN-DC) of LTE inter-band CA xDL/1UL bands (x=2,3,4) and NR FR1 1DL/1UL band and NR FR2 1DL/1UL band** | 92d | 2019-12-16 A | 2020-03-13 A | 100% |  | R4 | 1560h | 1560h | DC_R16_xBLTE_2BNR_yDL3UL | 44 | NTT DOCOMO | Rel-16 | 86 |  |  |
| 3132 | 1287.1 | Core part: Dual Connectivity (EN-DC) of LTE inter-band CA xDL/1UL bands (x=2,3,4) and NR FR1 1DL/1UL band and NR FR2 1DL/1UL band | 65d | 2019-12-16 A | 2020-03-13 A | 100% | finish no earlier than 2020-03-15 | R4 | 520h | 520h | DC_R16_xBLTE_2BNR_yDL3UL-Core | 44 | NTT DOCOMO | Rel-16 | 86 |  |  |
| 3133 | 1287.2 | Perf. part: Dual Connectivity (EN-DC) of LTE inter-band CA xDL/1UL bands (x=2,3,4) and NR FR1 1DL/1UL band and NR FR2 1DL/1UL band | 65d | 2019-12-16 A | 2020-03-13 A | 100% | finish no earlier than 2020-03-15 | R4 | 520h | 520h | DC_R16_xBLTE_2BNR_yDL3UL-Perf | 44 | NTT DOCOMO | Rel-16 | 86 |  |  |
| 3134 | 1288 | **LTE/NR spectrum sharing in band 48/n48 frequency range** | 92d | 2019-12-16 A | 2020-03-13 A | 100% |  | R4 | 1040h | 1040h | NR_n48_LTE_48_coex | 44 | Apple | Rel-16 | 86 |  |  |
| 3135 | 1288.1 | Core part: LTE/NR spectrum sharing in band 48/n48 frequency range | 65d | 2019-12-16 A | 2020-03-13 A | 100% | finish no earlier than 2020-03-15 | R4 | 520h | 520h | NR_n48_LTE_48_coex-Core | 44 | Apple | Rel-16 | 86 |  |  |
| 3136 | 1289 | **LTE-NR & NR-NR Dual Connectivity and NR Carrier Aggregation enhancements** | 1882.88d? | 2018-06-15 A | 2023-06-06 A | 100% |  | R2 | 22368h | 22368h | LTE_NR_DC_CA_enh | 41 | Ericsson | Rel-16 | 80 |  |  |
| 3137 | 1289.1 | Core part: LTE-NR & NR-NR Dual Connectivity and NR CA enhancements | 391d? | 2018-06-15 A | 2019-12-13 A | 100% | finish no earlier than 2019-12-15 | R2 | 3128h | 3128h | LTE_NR_DC_CA_enh-Core | 41 | Ericsson | Rel-16 | 80 |  |  |
| 3138 | 1289.2 | Perf. part: LTE-NR & NR-NR Dual Connectivity and NR CA enhancements | 522d? | 2018-06-15 A | 2020-06-15 A | 100% | finish no earlier than 2020-06-15 | R4 | 4176h | 4176h | LTE_NR_DC_CA_enh-Perf | 41 | Ericsson | Rel-16 | 80 |  |  |
| 3139 | 1289.3 | UE Conformance Test Aspects - LTE-NR & NR-NR Dual Connectivity and NR CA enhancements | 584d | 2021-03-12 A | 2023-06-06 A | 100% | finish no earlier than 2023-06-06 | R5 | 4672h | 4672h | LTE_NR_DC_CA_enh-UEConTest | 46 | Matti Kangas | Rel-16 | 91 | matti.kangas@nokia.com | RP-230915 |
| 3140 | 1290 | **High power UE (power class 2) for EN-DC (1 LTE TDD band + 1 NR TDD band)** | 478.5d | 2018-12-13 A | 2020-03-18 A | 100% |  | R4 | 10064h | 10064h | ENDC_UE_PC2_TDD_TDD | 42 | CMCC | Rel-16 | 82 |  |  |
| 3141 | 1290.1 | Study on high power UE (power class 2) for EN-DC (1 LTE FDD band + 1 NR TDD band) | 134d | 2018-12-13 A | 2019-06-18 A | 100% | start no earlier than 2018-12-13 | R4 | 1072h | 1072h | FS_ENDC_UE_PC2_FDD_TDD | 42 | China Unicom | Rel-16 | 82 |  |  |
| 3142 | 1290.2 | Core part: High power UE (power class 2) for EN-DC (1 LTE TDD band + 1 NR TDD band) | 262d | 2018-12-13 A | 2019-12-13 A | 100% | start no earlier than 2018-12-13 | R4 | 2096h | 2096h | ENDC_UE_PC2_TDD_TDD-Core | 42 | CMCC | Rel-16 | 82 |  |  |
| 3143 | 1290.3 | Perf. part: Power class 2 UE for EN-DC (1 LTE TDD band + 1 NR TDD band) | 262d | 2018-12-13 A | 2019-12-13 A | 100% | start no earlier than 2018-12-13 | R4 | 2096h | 2096h | ENDC_UE_PC2_TDD_TDD-Perf | 42 | CMCC | Rel-16 | 82 |  |  |
| 3144 | 1290.4 | UE Conformance Test Aspects - High power UE (power class 2) for EN-DC (1 LTE TDD band + 1 NR TDD band) | 270d | 2019-03-07 A | 2020-03-18 A | 100% | finish no earlier than 2020-03-18 | R5 | 2160h | 2160h | ENDC_UE_PC2_TDD_TDD-UEConTest | 44 | CMCC | Rel-16 | 87 |  |  |
| 3145 | 1291 | **eNB(s) Architecture Evolution for E-UTRAN and NG-RAN** | 661.75d? | 2018-03-15 A | 2019-12-13 A | 100% |  | R3 | 7312h | 7312h | LTE_NR_arch_evo | 40 | China Unicom | Rel-16 | 79 |  |  |
| 3146 | 1291.1 | Core part: eNB(s) Architecture Evolution for E-UTRAN and NG-RAN | 457d? | 2018-03-15 A | 2019-12-13 A | 100% | finish no earlier than 2019-12-15 | R3 | 3656h | 3656h | LTE_NR_arch_evo-Core | 40 | China Unicom | Rel-16 | 79 |  |  |
| 3147 | 1292 | **LTE/NR spectrum sharing in Band 41/n41 frequency range** | 194.75d | 2018-12-13 A | 2019-06-18 A | 100% |  | R4 | 2144h | 2144h | NR_n41_LTE_41_coex | 42 | KDDI | Rel-16 | 82 |  |  |
| 3148 | 1292.1 | Core part: LTE/NR spectrum sharing in Band 41/n41 frequency range | 134d | 2018-12-13 A | 2019-06-18 A | 100% | start no earlier than 2018-12-13 | R4 | 1072h | 1072h | NR_n41_LTE_41_coex-Core | 42 | KDDI | Rel-16 | 82 |  |  |
| 3149 | 1293 | **29 dBm UE Power Class for LTE band 41 and NR Band n41** | 1689.12d? | 2018-06-15 A | 2022-12-01 A | 100% |  | R4 | 14472h | 14472h | LTE_NR_B41_Bn41_PC29dBm | 41 | Sprint | Rel-16 | 80 |  |  |
| 3150 | 1293.1 | Core part: 29 dBm UE Power Class for LTE band 41 and NR Band n41 | 261d? | 2018-06-15 A | 2019-06-14 A | 100% | finish no earlier than 2019-06-15 | R4 | 2088h | 2088h | LTE_NR_B41_Bn41_PC29dBm-Core | 41 | Sprint | Rel-16 | 80 |  |  |
| 3151 | 1293.2 | UE Conformance Test Aspects - 29 dBm UE Power Class for LTE Band 41 and NR Band n41 | 383d | 2021-06-15 A | 2022-12-01 A | 100% | finish no earlier than 2022-12-01 | R5 | 3064h | 3064h | LTE_NR_B41_Bn41_PC29dBm-UEConTest | 47 | Dan SONG, CMCC, T-Mobile | Rel-16 | 92 | songdan@chinamobile.com | RP-223059 |

Notes:
- 3126: affects: UTRA, LTE, NR. no Core part; note: WI will introduce TR 37.9xx for REL-15 and REL-16
- 3127: affects: UTRA, LTE, NR. no Core part; note: WI will introduce TR 37.9xx for REL-15 and REL-16; 26/3/20: WID:RP-193225->RP-200276; 28/7/20: WID:RP-200276->RP-201021; 25/9/20: 37.941 added;; 6/1/21: 0%->100 / Impacted TSs and TRs: 37.941
- 3128: affects: LTE, NR. no Perf. part
- 3129: affects: LTE, NR. no Perf. part; 25/9/20: WID:RP-193244->RP-201578; 25/9/20: 0%->100
- 3130: tested: REL-16 WI ENDC_UE_PC2_FDD_TDD-Core ; 8/4/21: 0%->78; 29/9/21: WID:RP-201776->RP-212501; 29/9/21: 78%->100
- 3131: affects: LTE, NR. basket WI; suggested TR 37.716-41-22; 26/3/20: WID:RP-192784->RP-200228; 28/7/20: WID:RP-200228->RP-200905
- 3132: affects: LTE, NR. basket WI; suggested TR 37.716-41-22; 28/7/20: 0%->100; 25/9/20: 37.716-41-22 added; / Impacted TSs and TRs: 37.716-41-22
- 3133: affects: LTE, NR.; 28/7/20: 0%->100
- 3134: affects: LTE, NR. no Perf. part; 26/3/20: WID:RP-193213->RP-200234; 28/7/20: WID:RP-200234->RP-201359; 25/9/20: WID:RP-201359->RP-201858
- 3135: affects: LTE, NR. no Perf. part; 6/1/21: 0%->100
- 3136: RAN3 impact?¦26/3/19: WID:RP-181469->RP-190452; 26/6/19: WID:RP-190452->RP-191600; 8/10/19: WID:RP-191600->RP-192336; 28/7/20: WID:RP-192336->RP-200791
- 3137: RAN3 impact?¦26/3/19: WID:RP-181469->RP-190452; 25/9/20: 0%->100
- 3138: 26/3/19: WID:RP-181469->RP-190452; 2/7/21: 0%->100
- 3139: lested: REL-16 WI LTE_NR_DC_CA_enh-Core ; 2/7/21: WID:RP-210746->RP-211442; 2/7/21: 0%->5; 5/4/22: WID:RP-211442->RP-220801; 20/6/22: FCD:11/03/2022->22/12/2022; Compl:5%->40%; WID: RP-220801->RP-211442; Stat Rep: ->RP-221416; Rapporteur: Nokia->Matti...; 9/8/23: WID:RP-222021->RP-231105
- 3140: 26/3/19: WID:RP-182877->RP-190315
- 3141: EN-DC = E-UTRA-NR Dual Connectivity¦TR 37.8xx¦26/3/19: WID:RP-182895->RP-190167; 8/10/19: WID:RP-190167->RP-192268; 14/1/20: 0%->100
- 3142: 26/3/19: WID:RP-182877->RP-190315; 14/1/20: 0%->100
- 3143: 26/3/19: WID:RP-182877->RP-190315; 14/1/20: 0%->100
- 3144: affects: NR. TR 38.8xx; 28/7/20: WID:RP-200434->RP-200761; 25/9/20: WID:RP-200761->RP-202066; 25/9/20: 0%->100
- 3145: follow-up WI of REL-15 SI FS_LTE_arch_evo; 14/1/20: WID:RP-180531->RP-192917
- 3146: follow-up WI of REL-15 SI FS_LTE_arch_evo¦27/6/18: Compl:0%->15%¦27/6/18: CD:Fri 15/06/18->Sun 15/12/19¦27/6/18: WID: RP-180531->RP-181375¦27/6/18: Release: Rel-15->Rel-16¦6/8/18: 37.470 to 473 and 36.470 to 473 added;; 14/1/20: 15%->100 / Impacted TSs and TRs: 37.470; 37.471; 37.472; 37.473; 36.470; 36.471; 36.472; 36.473
- 3147: no Perf. part¦changes will happen only on NR side¦26/3/19: WID:RP-182883->RP-190175; 26/6/19: WID:RP-190175->RP-191588
- 3148: no Perf. part¦changes will happen only on NR side¦26/3/19: WID:RP-182883->RP-190175; 26/6/19: 0%->100
- 3149: no Perf. part¦26/3/19: WID:RP-181655->RP-190502; 14/1/20: WID:RP-190502->RP-192738; 28/7/20: WID:RP-192738->RP-201134
- 3150: no Perf. part¦7/3/19: WID:RP-181460->RP-181655¦26/3/19: WID:RP-181655->RP-190502; 25/9/20: 0%->100; 25/9/20: 100%->100
- 3151: tested: REL-17 WI LTE_NR_B41_Bn41_PC29dBm-Core ; 5/4/22: WID:RP-211443->RP-220124 6/6/22: C ; 20/6/22: Stat Rep: R5-222679->RP-221180 / R5-222679; Rapporteur: T-Mobile USA->Scott Probasco, Dan SONG, T-Mobile, CMCC; Rap eMail: ->scott.probasco@t-mobile....; 9/1/23: 100%->100

| ID | WBS | Task | Type | Duration | Start | Finish | Complete | Constraint | Resources | Work | Actual work | PCG approved | Release | TSG approved | Acronym | WI rapporteur name | Impacted TSs and TRs |
| --- | --- | --- | --- | --- | --- | --- | --- | --- | --- | --- | --- | --- | --- | --- | --- | --- | --- |
| 3152 | 1294 | **Dual Connectivity (EN-DC)** |  | 566.5d? | 2018-06-15 A | 2019-12-13 A | 100% |  |  | 56304h | 56304h | 41 | Rel-16 | 80 |  |  |  |
| 3153 | 1294.1 | **Dual Connectivity (EN-DC) of 1 LTE band (1UL/1DL) and 1 NR band (1DL/1UL)** |  | 566.5d? | 2018-06-15 A | 2019-12-13 A | 100% |  | R4 | 9384h | 9384h | 41 | Rel-16 | 80 | DC_R16_1BLTE_1BNR_2DL2UL | NTT DOCOMO |  |
| 3154 | 1294.1.1 | Core part: Dual Connectivity (EN-DC) of 1 LTE band (1UL/1DL) and 1 NR band (1DL/1UL) |  | 391d? | 2018-06-15 A | 2019-12-13 A | 100% | start no earlier than 2018-06-15 | R4 | 3128h | 3128h | 41 | Rel-16 | 80 | DC_R16_1BLTE_1BNR_2DL2UL-Core | NTT DOCOMO |  |
| 3155 | 1294.1.2 | Perf. part: Dual Connectivity (EN-DC) of 1 LTE band (1UL/1DL) and 1 NR band (1DL/1UL) |  | 391d? | 2018-06-15 A | 2019-12-13 A | 100% | finish no earlier than 2019-12-15 | R4 | 3128h | 3128h | 41 | Rel-16 | 80 | DC_R16_1BLTE_1BNR_2DL2UL-Perf | NTT DOCOMO |  |
| 3156 | 1294.2 | **Dual Connectivity (EN-DC) of 2 bands LTE inter-band CA (2DL/1UL) and 1 NR band (1DL/1UL)** |  | 566.5d? | 2018-06-15 A | 2019-12-13 A | 100% |  | R4 | 9384h | 9384h | 41 | Rel-16 | 80 | DC_R16_2BLTE_1BNR_3DL2UL | Huawei |  |
| 3157 | 1294.2.1 | Core part: Dual Connectivity (EN-DC) of 2 bands LTE inter-band CA (2DL/1UL) and 1 NR band (1DL/1UL) |  | 391d? | 2018-06-15 A | 2019-12-13 A | 100% | finish no earlier than 2019-12-15 | R4 | 3128h | 3128h | 41 | Rel-16 | 80 | DC_R16_2BLTE_1BNR_3DL2UL-Core | Huawei |  |
| 3158 | 1294.2.2 | Perf. part: Dual Connectivity (EN-DC) of 2 bands LTE inter-band CA (2DL/1UL) and 1 NR band (1DL/1UL) |  | 391d? | 2018-06-15 A | 2019-12-13 A | 100% | finish no earlier than 2019-12-15 | R4 | 3128h | 3128h | 41 | Rel-16 | 80 | DC_R16_2BLTE_1BNR_3DL2UL-Perf | Huawei |  |
| 3159 | 1294.3 | **Dual Connectivity (EN-DC) of 3 bands LTE inter-band CA (3DL/1UL) and 1 NR band (1DL/1UL)** |  | 566.5d? | 2018-06-15 A | 2019-12-13 A | 100% |  | R4 | 9384h | 9384h | 41 | Rel-16 | 80 | DC_R16_3BLTE_1BNR_4DL2UL | Ericsson |  |
| 3160 | 1294.3.1 | Core part: Dual Connectivity (EN-DC) of 3 bands LTE inter-band CA (3DL/1UL) and 1 NR band (1DL/1UL) |  | 391d? | 2018-06-15 A | 2019-12-13 A | 100% | finish no earlier than 2019-12-15 | R4 | 3128h | 3128h | 41 | Rel-16 | 80 | DC_R16_3BLTE_1BNR_4DL2UL-Core | Ericsson |  |
| 3161 | 1294.3.2 | Perf. part: Dual Connectivity (EN-DC) of 3 bands LTE inter-band CA (3DL/1UL) and 1 NR band (1DL/1UL) |  | 391d? | 2018-06-15 A | 2019-12-13 A | 100% | finish no earlier than 2019-12-15 | R4 | 3128h | 3128h | 41 | Rel-16 | 80 | DC_R16_3BLTE_1BNR_4DL2UL-Perf | Ericsson |  |
| 3162 | 1294.4 | **Dual Connectivity (EN-DC) of 4 bands LTE inter-band CA (4DL/1UL) and 1 NR band (1DL/1UL)** |  | 566.5d? | 2018-06-15 A | 2019-12-13 A | 100% |  | R4 | 9384h | 9384h | 41 | Rel-16 | 80 | DC_R16_4BLTE_1BNR_5DL2UL | Nokia |  |
| 3163 | 1294.4.1 | Core part: Dual Connectivity (EN-DC) of 4 bands LTE inter-band CA (4DL/1UL) and 1 NR band (1DL/1UL) |  | 391d? | 2018-06-15 A | 2019-12-13 A | 100% | finish no earlier than 2019-12-15 | R4 | 3128h | 3128h | 41 | Rel-16 | 80 | DC_R16_4BLTE_1BNR_5DL2UL-Core | Nokia |  |
| 3164 | 1294.4.2 | Perf. part: Dual Connectivity (EN-DC) of 4 bands LTE inter-band CA (4DL/1UL) and 1 NR band (1DL/1UL) |  | 391d? | 2018-06-15 A | 2019-12-13 A | 100% | finish no earlier than 2019-12-15 | R4 | 3128h | 3128h | 41 | Rel-16 | 80 | DC_R16_4BLTE_1BNR_5DL2UL-Perf | Nokia |  |
| 3165 | 1294.5 | **Dual Connectivity (EN-DC) of 5 bands LTE inter-band CA (5DL/1UL) and 1 NR band (1DL/1UL)** |  | 566.5d? | 2018-06-15 A | 2019-12-13 A | 100% |  | R4 | 9384h | 9384h | 41 | Rel-16 | 80 | DC_R16_5BLTE_1BNR_6DL2UL | Samsung |  |
| 3166 | 1294.5.1 | Stopped : Core part: Dual Connectivity (EN-DC) of 5 bands LTE inter-band CA (5DL/1UL) and 1 NR band (1DL/1UL) |  | 391d? | 2018-06-15 A | 2019-12-13 A | 100% | finish no earlier than 2019-12-15 | R4 | 3128h | 3128h | 41 | Rel-16 | 80 | DC_R16_5BLTE_1BNR_6DL2UL-Core | Samsung |  |
| 3167 | 1294.5.2 | Stopped: Perf. part: Dual Connectivity (EN-DC) of 5 bands LTE inter-band CA (5DL/1UL) and 1 NR band (1DL/1UL) |  | 391d? | 2018-06-15 A | 2019-12-13 A | 100% | finish no earlier than 2019-12-15 | R4 | 3128h | 3128h | 41 | Rel-16 | 80 | DC_R16_5BLTE_1BNR_6DL2UL-Perf | Samsung |  |
| 3168 | 1294.6 | **Dual Connectivity (EN-DC) of x bands (x=1, 2, 3, 4) LTE inter-band CA (xDL/1UL) and 2 bands NR inter-band CA (2DL/1UL)** |  | 566.5d? | 2018-06-15 A | 2019-12-13 A | 100% |  | R4 | 9384h | 9384h | 41 | Rel-16 | 80 | DC_R16_xBLTE_2BNR_yDL2UL | LG Electronics |  |
| 3169 | 1294.6.1 | Core part: Dual Connectivity (EN-DC) of x bands (x=2, 3, 4) LTE inter-band CA (xDL/1UL) and 2 bands NR inter-band CA (2DL/1UL) |  | 391d? | 2018-06-15 A | 2019-12-13 A | 100% | finish no earlier than 2019-12-15 | R4 | 3128h | 3128h | 41 | Rel-16 | 80 | DC_R16_xBLTE_2BNR_yDL2UL-Core | LG Electronics |  |
| 3170 | 1294.6.2 | Perf. part: Dual Connectivity (EN-DC) of x bands (x=2, 3, 4) LTE inter-band CA (xDL/1UL) and 2 bands NR inter-band CA (2DL/1UL) |  | 391d? | 2018-06-15 A | 2019-12-13 A | 100% | finish no earlier than 2019-12-15 | R4 | 3128h | 3128h | 41 | Rel-16 | 80 | DC_R16_xBLTE_2BNR_yDL2UL-Perf | LG Electronics |  |
| 3171 | 1295 | LTE-related Release 16 Features | milestone | 0d? | 2016-06-09 A | 2016-06-09 A | 100% | finish no earlier than 2016-06-09 |  |  |  |  | Rel-16 |  |  |  |  |
| 3172 | 1296 | **E-UTRA 2.4 GHz TDD Band for US** |  | 477.5d? | 2018-03-15 A | 2019-06-18 A | 100% |  | R4 | 5800h | 5800h | 40 | Rel-16 | 79 | LTE_TDD_2400_US | Globalstar | 36.791 |
| 3173 | 1296.1 | Core part: E-UTRA 2.4 GHz TDD Band for US |  | 197d? | 2018-03-15 A | 2018-12-14 A | 100% | finish no earlier than 2018-12-15 | R4 | 1576h | 1576h | 40 | Rel-16 | 79 | LTE_TDD_2400_US-Core | Globalstar | 36.791 |
| 3174 | 1296.2 | Perf. part: E-UTRA 2.4 GHz TDD Band for US |  | 197d? | 2018-03-15 A | 2018-12-14 A | 100% | finish no earlier than 2018-12-15 | R4 | 1576h | 1576h | 40 | Rel-16 | 79 | LTE_TDD_2400_US-Perf | Globalstar |  |
| 3175 | 1296.3 | UE Conformance Test Aspects - E-UTRA 2.4 GHz TDD Band for US (Band 53) |  | 134d | 2018-12-13 A | 2019-06-18 A | 100% | start no earlier than 2018-12-13 | R5 | 1072h | 1072h | 42 | Rel-15 | 82 | LTE_TDD_2400_US-UEConTest | Globalstar |  |

Notes:
- 3153: basket WI¦TR 37.716-01-01¦16/1/19: WID:RP-181447->RP-182567¦26/3/19: WID:RP-182567->RP-190705; 26/6/19: WID:RP-190705->RP-191568; 8/10/19: WID:RP-191568->RP-191752; 14/1/20: WID:RP-191752->RP-192742; 26/3/20: WID:RP-192742->RP-200221; 28/7/20: WID:RP-2
- 3154: basket WI¦TR 37.716-01-01¦26/3/19: WID:RP-182567->RP-190705; 28/7/20: 0%->100
- 3155: basket WI¦26/3/19: WID:RP-182567->RP-190705; 28/7/20: 0%->100
- 3156: basket WI¦TR 37.716-02-01¦16/1/19: WID:RP-181357->RP-182557¦26/3/19: WID:RP-182557->RP-190379; 26/6/19: WID:RP-190379->RP-191124; 8/10/19: WID:RP-191124->RP-192087; 14/1/20: WID:RP-192087->RP-192815; 26/3/20: WID:RP-192815->RP-200271; 28/7/20: WID:RP-2
- 3157: basket WI¦TR 37.716-02-01¦26/3/19: WID:RP-182557->RP-190379; 28/7/20: 0%->100
- 3158: basket WI¦26/3/19: WID:RP-182557->RP-190379; 28/7/20: 0%->100
- 3159: basket WI¦TR 37.716-03-01¦16/1/19: WID:RP-181407->RP-182257¦26/3/19: WID:RP-182257->RP-190159; 26/6/19: WID:RP-190159->RP-191195; 8/10/19: WID:RP-191195->RP-191813; 14/1/20: WID:RP-191813->RP-192446; 26/3/20: WID:RP-192446->RP-200102; 28/7/20: WID:RP-2
- 3160: basket WI¦TR 37.716-03-01¦26/3/19: WID:RP-182257->RP-190159; 28/7/20: 0%->100
- 3161: basket WI¦26/3/19: WID:RP-182257->RP-190159; 28/7/20: 0%->100
- 3162: basket WI¦TR 37.716-04-01¦16/1/19: WID:RP-181001->RP-182534¦26/3/19: WID:RP-182534->RP-190294; 26/6/19: WID:RP-190294->RP-191205; 8/10/19: WID:RP-191205->RP-191728; 14/1/20: WID:RP-191728->RP-192768; 26/3/20: WID:RP-192768->RP-200134; 28/7/20: WID:RP-2
- 3163: basket WI¦TR 37.716-04-01¦26/3/19: WID:RP-182534->RP-190294; 28/7/20: 0%->100
- 3164: basket WI¦26/3/19: WID:RP-182534->RP-190294; 28/7/20: 0%->100
- 3165: basket WI¦TR 37.716-05-01
- 3166: basket WI¦TR 37.716-05-01; 14/1/20: 0%->100
- 3167: basket WI; 14/1/20: 0%->100
- 3168: basket WI¦TR 37.716-00-02¦16/1/19: WID:RP-180777->RP-182302, "x=1" added¦26/3/19: WID:RP-182302->RP-190151; 26/6/19: WID:RP-190151->RP-190949; 8/10/19: WID:RP-190949->RP-191744; 14/1/20: WID:RP-191744->RP-192592; 26/3/20: WID:RP-192592->RP-200080; 28/7
- 3169: basket WI¦TR 37.716-00-02¦26/3/19: WID:RP-182302->RP-190151; 28/7/20: 0%->100
- 3170: basket WI¦26/3/19: WID:RP-182302->RP-190151; 28/7/20: 0%->100
- 3171: -
- 3172: new LTE TDD band for 2483.5 to 2495MHz¦compare band 41: 2,496-2,69GHz introduced by WI LTE_TDD_2600_US¦6/8/18: 36.791 added;¦16/1/19: WID:RP-180583->RP-182405
- 3173: new LTE TDD band for 2483.5 to 2495MHz¦compare band 41: 2,496-2,69GHz introduced by WI LTE_TDD_2600_US¦6/8/18: 36.791 added;¦16/1/19: 0%->100
- 3174: new LTE TDD band for 2483.5 to 2495MHz¦compare band 41: 2,496-2,69GHz introduced by WI LTE_TDD_2600_US¦16/1/19: 0%->100
- 3175: tested: REL-15 WI LTE_TDD_2400_US-Core; 26/6/19: 0%->100

| ID | WBS | Task | Duration | Start | Finish | Complete | Remaining | Total slack | Constraint | Resources | Work | Actual work | PCG approved | Release | TSG approved | Acronym | WI rapporteur name | WI rapporteur e-mail | Status Report | Impacted TSs and TRs |
| --- | --- | --- | --- | --- | --- | --- | --- | --- | --- | --- | --- | --- | --- | --- | --- | --- | --- | --- | --- | --- |
| 3176 | 1297 | **LTE intra-band Carrier Aggregation (CA)** | 1209.25d? | 2018-06-15 A | 2021-08-25 | 82% | 215.93d? | 39454.1d |  |  | 65224h | 56304h | 41 | Rel-16 | 80 |  |  |  |  |  |
| 3177 | 1297.1 | **Rel-16 LTE intra-band CA for x CC DL/y CC UL including contiguous and non-contiguous spectrum (x>=y)** | 566.5d? | 2018-06-15 A | 2019-12-13 A | 100% |  |  |  | R4 | 9384h | 9384h | 41 | Rel-16 | 80 | LTE_CA_R16_intra | Ericsson |  |  |  |
| 3178 | 1297.1.1 | Core part: Rel-16 LTE intra-band CA for x CC DL/y CC UL including contiguous and non-contiguous spectrum (x>=y) | 391d? | 2018-06-15 A | 2019-12-13 A | 100% |  |  | start no earlier than 2018-06-15 | R4 | 3128h | 3128h | 41 | Rel-16 | 80 | LTE_CA_R16_intra-Core | Ericsson |  |  |  |
| 3179 | 1297.1.2 | Perf. part: Rel-16 LTE intra-band CA for x CC DL/y CC UL including contiguous and non-contiguous spectrum (x>=y) | 391d? | 2018-06-15 A | 2019-12-13 A | 100% |  |  | finish no earlier than 2019-12-15 | R4 | 3128h | 3128h | 41 | Rel-16 | 80 | LTE_CA_R16_intra-Perf | Ericsson |  |  |  |
| 3180 | 1297.2 | **Rel-16 LTE inter-band CA for 2 bands DL with 1 band UL** | 566.5d? | 2018-06-15 A | 2019-12-13 A | 100% |  |  |  | R4 | 9384h | 9384h | 41 | Rel-16 | 80 | LTE_CA_R16_2BDL_1BUL | Qualcomm |  |  |  |
| 3181 | 1297.2.1 | Core part: Rel-16 LTE inter-band CA for 2 bands DL with 1 band UL | 391d? | 2018-06-15 A | 2019-12-13 A | 100% |  |  | finish no earlier than 2019-12-15 | R4 | 3128h | 3128h | 41 | Rel-16 | 80 | LTE_CA_R16_2BDL_1BUL-Core | Qualcomm |  |  |  |
| 3182 | 1297.2.2 | Perf. part: Rel-16 LTE inter-band CA for 2 bands DL with 1 band UL | 391d? | 2018-06-15 A | 2019-12-13 A | 100% |  |  | finish no earlier than 2019-12-15 | R4 | 3128h | 3128h | 41 | Rel-16 | 80 | LTE_CA_R16_2BDL_1BUL-Perf | Qualcomm |  |  |  |
| 3183 | 1297.3 | **Rel-16 LTE inter-band CA for 3 bands DL with 1 band UL** | 566.5d? | 2018-06-15 A | 2019-12-13 A | 100% |  |  |  | R4 | 9384h | 9384h | 41 | Rel-16 | 80 | LTE_CA_R16_3BDL_1BUL | Huawei |  |  |  |
| 3184 | 1297.3.1 | Core part: Rel-16 LTE inter-band CA for 3 bands DL with 1 band UL | 391d? | 2018-06-15 A | 2019-12-13 A | 100% |  |  | finish no earlier than 2019-12-15 | R4 | 3128h | 3128h | 41 | Rel-16 | 80 | LTE_CA_R16_3BDL_1BUL-Core | Huawei |  |  |  |
| 3185 | 1297.3.2 | Perf. part: Rel-16 LTE inter-band CA for 3 bands DL with 1 band UL | 391d? | 2018-06-15 A | 2019-12-13 A | 100% |  |  | finish no earlier than 2019-12-15 | R4 | 3128h | 3128h | 41 | Rel-16 | 80 | LTE_CA_R16_3BDL_1BUL-Perf | Huawei |  |  |  |
| 3186 | 1297.4 | **Rel-16 LTE inter-band CA for x bands DL (x=4, 5) with 1 band UL** | 566.5d? | 2018-06-15 A | 2019-12-13 A | 100% |  |  |  | R4 | 9384h | 9384h | 41 | Rel-16 | 80 | LTE_CA_R16_xBDL_1BUL | Nokia |  |  |  |
| 3187 | 1297.4.1 | Core part: Rel-16 LTE inter-band CA for x bands DL (x=4, 5) with 1 band UL | 391d? | 2018-06-15 A | 2019-12-13 A | 100% |  |  | finish no earlier than 2019-12-15 | R4 | 3128h | 3128h | 41 | Rel-16 | 80 | LTE_CA_R16_xBDL_1BUL-Core | Nokia |  |  |  |
| 3188 | 1297.4.2 | Perf. part: Rel-16 LTE inter-band CA for x bands DL (x=4, 5) with 1 band UL | 391d? | 2018-06-15 A | 2019-12-13 A | 100% |  |  | finish no earlier than 2019-12-15 | R4 | 3128h | 3128h | 41 | Rel-16 | 80 | LTE_CA_R16_xBDL_1BUL-Perf | Nokia |  |  |  |
| 3189 | 1297.5 | **Rel-16 LTE inter-band CA for 2 bands DL with 2 band UL** | 566.5d? | 2018-06-15 A | 2019-12-13 A | 100% |  |  |  | R4 | 9384h | 9384h | 41 | Rel-16 | 80 | LTE_CA_R16_2BDL_2BUL | Huawei |  |  |  |
| 3190 | 1297.5.1 | Core part: Rel-16 LTE inter-band CA for 2 bands DL with 2 band UL | 391d? | 2018-06-15 A | 2019-12-13 A | 100% |  |  | finish no earlier than 2019-12-15 | R4 | 3128h | 3128h | 41 | Rel-16 | 80 | LTE_CA_R16_2BDL_2BUL-Core | Huawei |  |  |  |
| 3191 | 1297.5.2 | Perf. part: Rel-16 LTE inter-band CA for 2 bands DL with 2 band UL | 391d? | 2018-06-15 A | 2019-12-13 A | 100% |  |  | start no earlier than 2018-06-15 | R4 | 3128h | 3128h | 41 | Rel-16 | 80 | LTE_CA_R16_2BDL_2BUL-Perf | Huawei |  |  |  |
| 3192 | 1297.6 | **Rel-16 LTE inter-band CA for x bands DL (x= 3, 4, 5) with 2 band UL** | 566.5d? | 2018-06-15 A | 2019-12-13 A | 100% |  |  |  | R4 | 9384h | 9384h | 41 | Rel-16 | 80 | LTE_CA_R16_xBDL_2BUL | LG Electronics |  |  |  |
| 3193 | 1297.6.1 | Core part: Rel-16 LTE inter-band CA for x bands DL (x= 3, 4, 5) with 2 band UL | 391d? | 2018-06-15 A | 2019-12-13 A | 100% |  |  | start no earlier than 2018-06-15 | R4 | 3128h | 3128h | 41 | Rel-16 | 80 | LTE_CA_R16_xBDL_2BUL-Core | LG Electronics |  |  |  |
| 3194 | 1297.6.2 | Perf. part: Rel-16 LTE inter-band CA for x bands DL (x= 3, 4, 5) with 2 band UL | 391d? | 2018-06-15 A | 2019-12-13 A | 100% |  |  | finish no earlier than 2019-12-15 | R4 | 3128h | 3128h | 41 | Rel-16 | 80 | LTE_CA_R16_xBDL_2BUL-Perf | LG Electronics |  |  |  |
| 3195 | 1297.7 | UE Conformance Test Aspects – Rel-16 LTE CA configurations | 1115d? | 2018-09-14 A | 2021-08-25 | 7% | 1036.95d? | 39454.1d | finish no earlier than 2022-12-22 | R5 | 8920h |  | 41 | Rel-16 | 81 | LTE_CA_R16-UEConTest | Leif MATTISSON | Leif[dot]mattisson[at]ericsson[dot]com | RP-222098 |  |
| 3196 | 1298 | **LTE-based 5G terrestrial broadcast** | 743.75d? | 2018-06-15 A | 2020-06-01 A | 100% |  |  |  | R1 | 9928h | 9928h | 42 | Rel-16 | 83 | LTE_terr_bcast | Qualcomm |  |  | 36.276; 36.476 |
| 3197 | 1298.1 | Study on LTE-based 5G terrestrial broadcast | 196d? | 2018-06-15 A | 2019-03-15 A | 100% |  |  | finish no earlier than 2019-03-15 | R1 | 1568h | 1568h | 41 | Rel-16 | 80 | FS_LTE_terr_bcast | Qualcomm |  |  |  |
| 3198 | 1298.2 | Core part: LTE-based 5G terrestrial broadcast | 206d | 2019-03-01 A | 2019-12-13 A | 100% |  |  | finish no earlier than 2019-12-15 | R1 | 1648h | 1648h | 42 | Rel-16 | 83 | LTE_terr_bcast-Core | Qualcomm |  |  |  |
| 3199 | 1298.3 | Perf. part: LTE-based 5G terrestrial broadcast | 327d | 2019-03-01 A | 2020-06-01 A | 100% |  |  | finish no earlier than 2020-06-01 | R4 | 2616h | 2616h | 42 | Rel-16 | 83 | LTE_terr_bcast-Perf | Qualcomm |  |  |  |

Notes:
- 3177: basket WI¦TR 36.716-01-01¦16/1/19: WID:RP-180806->SP-182255¦26/3/19: WID:RP-182255->RP-190157; 26/6/19: WID:RP-190157->RP-191193; 8/10/19: WID:RP-191193->RP-191811; 14/1/20: WID:RP-191811->RP-192444; 26/3/20: WID:RP-192444->RP-200100; 28/7/20: WID:RP-2
- 3178: basket WI¦TR 36.716-01-01¦26/3/19: WID:RP-182255->RP-190157; 28/7/20: 0%->100
- 3179: basket WI¦26/3/19: WID:RP-182255->RP-190157; 28/7/20: 0%->100
- 3180: basket WI¦TR 36.716-02-01¦16/1/19: WID:RP-181441->RP-182345¦26/3/19: WID:RP-182345->RP-190500; 26/6/19: WID:RP-190500->RP-191085; 8/10/19: WID:RP-191085->RP-191733; 14/1/20: WID:RP-191733->RP-192525; 26/3/20: WID:RP-192525->RP-200231; 28/7/20: WID:RP-2
- 3181: basket WI¦TR 36.716-02-01¦16/1/19: WID:RP-181441->RP-182345¦26/3/19: WID:RP-182345->RP-190500; 26/6/19: WID:RP-190500->RP-191085; 28/7/20: 0%->100
- 3182: basket WI¦TR 36.716-02-01¦16/1/19: WID:RP-181441->RP-182345¦26/3/19: WID:RP-182345->RP-190500; 26/6/19: WID:RP-190500->RP-191085; 28/7/20: 0%->100
- 3183: basket WI¦TR 36.716-03-01¦16/1/19: WID:RP-181436->RP-182553¦26/3/19: WID:RP-182553->RP-190375; 26/6/19: WID:RP-190375->RP-191120; 8/10/19: WID:RP-191120->RP-192083; 14/1/20: WID:RP-192083->RP-192811; 26/3/20: WID:RP-192811->RP-200451; 28/7/20: WID:RP-2
- 3184: basket WI¦TR 36.716-03-01¦26/3/19: WID:RP-182553->RP-190375; 28/7/20: 0%->100
- 3185: basket WI¦26/3/19: WID:RP-182553->; 28/7/20: 0%->100
- 3186: basket WI¦TR 36.716-04-01¦16/1/19: WID:RP-181408->RP-182330¦26/3/19: WID:RP-182330->RP-190138; 26/6/19: WID:RP-190138->RP-190906; 8/10/19: WID:RP-190906->RP-191730; 14/1/20: WID:RP-191730->RP-192423; 26/3/20: WID:RP-192423->RP-200157; 28/7/20: WID:RP-2
- 3187: basket WI¦TR 36.716-04-01¦26/3/19: WID:RP-182330->RP-190138; 28/7/20: 0%->100
- 3188: basket WI¦26/3/19: WID:RP-182330->RP-190138; 28/7/20: 0%->100
- 3189: basket WI¦TR 36.716-02-02¦16/1/19: WID:RP-181356->RP-182555¦26/3/19: WID:RP-182555->RP-190377; 8/10/19: WID:RP-190377->RP-192085; 14/1/20: WID:RP-192085->RP-192813; 26/3/20: WID:RP-192813->RP-200269; 28/7/20: WID:RP-200269->RP-201014
- 3190: basket WI¦TR 36.716-02-02¦26/3/19: WID:RP-182555->RP-190377; 28/7/20: 0%->100
- 3191: basket WI¦26/3/19: WID:RP-182555->RP-190377; 28/7/20: 0%->100
- 3192: basket WI¦TR 36.716-00-02¦16/1/19: WID:RP-180778->RP-182301¦26/3/19: WID:RP-182301->RP-190150; 26/6/19: WID:RP-190150->RP-190946; 8/10/19: WID:RP-190946->RP-191743; 14/1/20: WID:RP-191743->RP-192586; 26/3/20: WID:RP-192586->RP-200510; 28/7/20: WID:RP-2
- 3193: basket WI¦TR 36.716-00-02¦26/3/19: WID:RP-182301->RP-190150; 28/7/20: 0%->100
- 3194: basket WI¦26/3/19: WID:RP-182301->RP-190150; 28/7/20: 0%->100
- 3195: 16/1/19: WID:RP-181605->RP-182648; 8/10/20: 0%->7; 8/10/20: FCD:19/06/2020->12/20; 8/4/21: 7%->7; 8/4/21: FCD:11/12/2020->09/21; 2/7/21: 7%->; 2/7/21: FCD:Wed 08/09/->03/22; 20/6/22: FCD:11/03/2022->22/12/2022; WID: RP-182648->RP-171886; Stat Rep: ->RP...; 9/9/22: WID: RP-171886->RP-182648; 9/9/22: Stat Rep: RP-221219->RP-222098
- 3196: 8/10/19: WID:RP-190732->RP-191924; 8/10/19: 36.276 added;; 14/1/20: WID:RP-191924->RP-193050
- 3197: TR 36.7xx¦26/3/19: 0%->100
- 3198: 26/3/20: 0%->100
- 3199: 25/9/20: 0%->100

| ID | WBS | Task | Duration | Start | Finish | Complete | Remaining | Actual finish | Total slack | Constraint | Resources | Work | Actual work | Acronym | PCG approved | WI rapporteur name | Release | TSG approved | Status Report | WI rapporteur e-mail |
| --- | --- | --- | --- | --- | --- | --- | --- | --- | --- | --- | --- | --- | --- | --- | --- | --- | --- | --- | --- | --- |
| 3200 | 1299 | **Power class 2 UE for LTE bands 31 and 72** | 581d | 2019-03-01 A | 2020-09-11 A | 100% |  |  |  |  | R4 | 7024h | 7024h | LTE_PC2_B31_B72 | 42 | Nokia | Rel-16 | 83 |  |  |
| 3201 | 1299.1 | Core part: Power class 2 UE for LTE bands 31 and 72 | 141d | 2019-03-01 A | 2019-09-13 A | 100% |  |  |  | finish no earlier than 2019-09-15 | R4 | 1128h | 1128h | LTE_PC2_B31_B72-Core | 42 | Nokia | Rel-16 | 83 |  |  |
| 3202 | 1299.2 | Perf. part: Power class 2 UE for LTE bands 31 and 72 | 141d | 2019-03-01 A | 2019-09-13 A | 100% |  |  |  | finish no earlier than 2019-09-15 | R4 | 1128h | 1128h | LTE_PC2_B31_B72-Perf | 42 | Nokia | Rel-16 | 83 |  |  |
| 3203 | 1299.3 | UE Conformance Test Aspects – Addition of Power Class 2 UE for LTE bands 31 and 72 | 195d | 2019-12-16 A | 2020-09-11 A | 100% |  |  |  | finish no earlier than 2020-09-12 | R5 | 1560h | 1560h | LTE_PC2_B31_B72-UEConTest | 44 | Airbus | Rel-16 | 86 |  |  |
| 3204 | 1300 | **Additional LTE bands** | 1237.75d? | 2018-06-15 A | 2021-09-21 | 100% |  | 2021-09-08 |  |  |  | 26120h | 26120h |  | 41 |  | Rel-16 | 80 |  |  |
| 3205 | 1300.1 | **Additional LTE bands for UE category M1 and/or NB1 in Rel-16** | 1237.75d? | 2018-06-15 A | 2021-09-21 | 100% |  | 2021-09-08 |  |  | R4 | 14624h | 14624h | LTE_bands_R16_M1_NB1 | 41 | Ericsson | Rel-16 | 80 | RP-211863 |  |
| 3206 | 1300.1.1 | Core part: Additional LTE bands for UE category M1 and/or NB1 in Rel-16 | 391d? | 2018-06-15 A | 2019-12-13 A | 100% |  |  |  | finish no earlier than 2019-12-15 | R4 | 3128h | 3128h | LTE_bands_R16_M1_NB1-Core | 41 | Ericsson | Rel-16 | 80 |  |  |
| 3207 | 1300.1.2 | Perf. part: Additional LTE bands for UE category M1 and/or NB1 in Rel-16 | 391d? | 2018-06-15 A | 2019-12-13 A | 100% |  |  |  | finish no earlier than 2019-12-15 | R4 | 3128h | 3128h | LTE_bands_R16_M1_NB1-Perf | 41 | Ericsson | Rel-16 | 80 |  |  |
| 3208 | 1300.1.3 | UE Conformance Test Aspects - Additional LTE bands for UE category M1 and/or NB1 in Rel-16 | 193d | 2020-12-14 A | 2021-09-08 A | 100% |  |  |  | finish no earlier than 2021-09-08 | R5 | 1544h | 1544h | LTE_bands_R16_M1_NB1-UEConTest | 46 | Ericsson | Rel-16 | 90 |  |  |
| 3209 | 1300.2 | **Additional LTE bands for UE category M2 and/or NB2 in Rel-16** | 1237.75d? | 2018-06-15 A | 2021-09-21 | 100% |  | 2021-09-08 |  |  | R4 | 11496h | 11496h | LTE_bands_R16_M2_NB2 | 41 | Ericsson | Rel-16 | 80 | RP-211864 |  |
| 3210 | 1300.2.1 | Core part: Additional LTE bands for UE category M2 and/or NB2 in Rel-16 | 391d? | 2018-06-15 A | 2019-12-13 A | 100% |  |  |  | finish no earlier than 2019-12-15 | R4 | 3128h | 3128h | LTE_bands_R16_M2_NB2-Core | 41 | Ericsson | Rel-16 | 80 |  |  |
| 3211 | 1300.2.2 | UE Conformance Test Aspects - Additional LTE bands for UE category M2 and/or NB2 in Rel-16 | 193d | 2020-12-14 A | 2021-09-08 A | 100% |  |  |  | finish no earlier than 2021-09-08 | R5 | 1544h | 1544h | LTE_bands_R16_M2_NB2-UEConTest | 46 | Ericsson | Rel-16 | 90 |  |  |
| 3212 | 1301 | **Further performance enhancement for LTE in high speed scenario** | 566.5d? | 2018-06-15 A | 2019-12-13 A | 100% |  |  |  |  | R4 | 9384h | 9384h | LTE_high_speed_enh2 | 41 | NTT DOCOMO | Rel-16 | 80 |  |  |
| 3213 | 1301.1 | Core part: Further performance enhancement for LTE in high speed scenario | 391d? | 2018-06-15 A | 2019-12-13 A | 100% |  |  |  | finish no earlier than 2019-12-15 | R4 | 3128h | 3128h | LTE_high_speed_enh2-Core | 41 | NTT DOCOMO | Rel-16 | 80 |  |  |
| 3214 | 1301.2 | Perf. part: Further performance enhancement for LTE in high speed scenario | 391d? | 2018-06-15 A | 2019-12-13 A | 100% |  |  |  | finish no earlier than 2019-12-15 | R4 | 3128h | 3128h | LTE_high_speed_enh2-Perf | 41 | NTT DOCOMO | Rel-16 | 80 |  |  |
| 3215 | 1302 | **Cross Link Interference (CLI) handling and Remote Interference Management (RIM) for NR** | 1564.5d? | 2018-06-15 A | 2022-08-03 | 62% | 595.06d? |  | 39098.9d |  | R1 | 18493h | 6264h | NR_CLI_RIM | 41 | LG Electronics | Rel-16 | 80 |  |  |
| 3216 | 1302.1 | Core part: Cross Link Interference (CLI) handling and Remote Interference Management (RIM) for NR | 261d? | 2018-06-15 A | 2019-06-14 A | 100% |  |  |  | finish no earlier than 2019-06-15 | R1 | 2088h | 2088h | NR_CLI_RIM-Core | 41 | LG Electronics | Rel-16 | 80 |  |  |
| 3217 | 1302.2 | Perf. part: Cross Link Interference (CLI) handling and Remote Interference Management (RIM) for NR | 261d? | 2018-06-15 A | 2019-06-14 A | 100% |  |  |  | finish no earlier than 2019-06-15 | R4 | 2088h | 2088h | NR_CLI_RIM-Perf | 41 | LG Electronics | Rel-16 | 80 |  |  |
| 3218 | 1302.3 | UE Conformance Test Aspects - Cross Link Interference (CLI) handling for NR | 710d | 2020-09-17 A | 2022-08-03 | 34% | 468.6d |  | 39098.9d | finish no earlier than 2023-06-06 | R5 | 5680h |  | NR_CLI-UEConTest | 45 | Vijay Balasubramanian | Rel-16 | 89 | RP-223381 | vijayb[at]qti.qualcomm.com |
| 3219 | 1303 | **DL MIMO efficiency enhancements for LTE** | 566.5d? | 2018-06-15 A | 2019-12-13 A | 100% |  |  |  |  | R1 | 9384h | 9384h | LTE_DL_MIMO_EE | 41 | Huawei | Rel-16 | 80 |  |  |
| 3220 | 1303.1 | Core part: DL MIMO efficiency enhancements for LTE | 391d? | 2018-06-15 A | 2019-12-13 A | 100% |  |  |  | finish no earlier than 2019-12-15 | R1 | 3128h | 3128h | LTE_DL_MIMO_EE-Core | 41 | Huawei | Rel-16 | 80 |  |  |
| 3221 | 1303.2 | Perf. part: DL MIMO efficiency enhancements for LTE | 391d? | 2018-06-15 A | 2019-12-13 A | 100% |  |  |  | finish no earlier than 2019-12-15 | R4 | 3128h | 3128h | LTE_DL_MIMO_EE-Perf | 41 | Huawei | Rel-16 | 80 |  |  |
| 3222 | 1304 | **Transfer of Iuant interface specifications from 25-series to 37-series** | 99.5d | 2018-12-13 A | 2019-03-18 A | 100% |  |  |  |  | R3 | 1088h | 1088h | Iuant_transfer | 42 | Huawei | Rel-16 | 82 |  |  |
| 3223 | 1304.1 | Core part: Transfer of Iuant interface specifications from 25-series to 37-series | 68d | 2018-12-13 A | 2019-03-18 A | 100% |  |  |  | start no earlier than 2018-12-13 | R3 | 544h | 544h | Iuant_transfer-Core | 42 | Huawei | Rel-16 | 82 |  |  |

Notes:
- 3200: 26/6/19: WID:RP-190665->RP-191285
- 3201: 8/10/19: 0%->100
- 3202: 8/10/19: 0%->100
- 3203: affects: LTE. tested: REL-16 WI LTE_PC2_B31_B72-Core; 25/9/20: 0%->100; 8/10/20: FCD:15/03/2020->09/20
- 3205: basket WI¦16/1/19: WID:RP-181006->RP-182768¦26/3/19: WID:RP-182768->RP-190332; 14/1/20: WID:RP-190332->RP-192453; 26/3/20: WID:RP-192453->RP-200153; 28/7/20: WID:RP-200153->RP-201200; 13/9/21: Compl
- 3206: basket WI¦26/3/19: WID:RP-182768->RP-190332; 28/7/20: 0%->100
- 3207: basket WI¦26/3/19: WID:RP-182768->RP-190332; 28/7/20: 0%->100
- 3208: tested: REL-16 WI LTE_bands_R16_M1_NB1-Core ; 8/4/21: 0%->26; 2/7/21: 26%->80
- 3209: basket WI¦no Perf. part¦16/1/19: WID:RP-181007->RP-182769¦26/3/19: WID:RP-182769->RP-190333; 14/1/20: WID:RP-190333->RP-192454; 26/3/20: WID:RP-192454->RP-200154; 13/9/21: Compl:86%->100% ;
- 3210: basket WI¦no Perf. part¦26/3/19: WID:RP-182769->RP-190333; 28/7/20: WID:RP-200154->RP-201201; 28/7/20: 0%->100
- 3211: tested: REL-16 WI LTE_bands_R16_M2_NB2-Core ; 8/4/21: 0%->33; 2/7/21: 33%->59
- 3213: 14/1/20: 0%->100
- 3214: 26/3/20: 0%->100
- 3215: 16/1/19: WID:RP-181431->RP-182864¦26/3/19: WID:RP-182864->RP-190700; 26/6/19: WID:RP-190700->RP-191546; 8/10/19: WID:RP-191546->RP-191997; 14/1/20: WID:RP-191997->RP-193190
- 3216: 26/3/19: WID:RP-182864->RP-190700; 28/7/20: 0%->100
- 3217: 26/3/19: WID:RP-182864->RP-190700; 28/7/20: 0%->100
- 3218: tested: CLI part of REL-16 WI NR_CLI_RIM-Core ; 7/4/21: WID:RP-201940->RP-210716; 8/4/21: 0%->5; 20/6/22: FCD:17/12/2021->22/12/2022; Compl:5%->19%; Stat Rep: ->RP-221247; Rapporteur: Qualcomm->Vijay Balasubramanian; Rap eMail: ->vijayb@qti.qualcomm.c...; 31/3/23: FCD:31/05/2023->06/06/2023;
- 3219: 16/1/19: WID:RP-181485->RP-182901; 14/1/20: WID:RP-182901->RP-192766
- 3220: 26/3/20: 0%->100
- 3221: 28/7/20: 0%->100
- 3222: administrative WI that transfers REL-8 to REL-15 25.46x specs (formerly created for UMTS, later misused for LTE and recently extended to NR) into 37 series specs affecting UMTS, LTE and NR turning 25.46x specs into pointers to 37 series specs¦no Perf .
- 3223: administrative WI that transfers REL-8 to REL-15 25.46x specs (formerly created for UMTS, later misused for LTE and recently extended to NR) into 37 series specs affecting UMTS, LTE and NR turning 25.46x specs into pointers to 37 series specs¦no Perf .

| ID | WBS | Task | Type | Duration | Start | Finish | Complete | Constraint | Resources | Work | Actual work | Acronym | PCG approved | WI rapporteur name | Release | TSG approved | WI rapporteur e-mail | Status Report | TSG stopped |
| --- | --- | --- | --- | --- | --- | --- | --- | --- | --- | --- | --- | --- | --- | --- | --- | --- | --- | --- | --- |
| 3224 | 1305 | **Direct data forwarding between NG-RAN and E-UTRAN nodes for inter-system mobility** |  | 194.75d | 2018-12-13 A | 2019-06-18 A | 100% |  | R3 | 2144h | 2144h | Direct_data_fw_NR | 42 | Ericsson | Rel-16 | 82 |  |  |  |
| 3225 | 1305.1 | Core part: Direct data forwarding between NG-RAN and E-UTRAN nodes for inter-system mobility |  | 134d | 2018-12-13 A | 2019-06-18 A | 100% | start no earlier than 2018-12-13 | R3 | 1072h | 1072h | Direct_data_fw_NR-Core | 42 | Ericsson | Rel-16 | 82 |  |  |  |
| 3226 | 1306 | **Even further mobility enhancement in E-UTRAN** |  | 1521.38d? | 2018-06-15 A | 2022-06-22 A | 100% |  | R2 | 18832h | 18832h | LTE_feMob | 41 | China Telecom | Rel-16 | 80 |  |  |  |
| 3227 | 1306.1 | Core part: Even further mobility enhancement in E-UTRAN |  | 391d? | 2018-06-15 A | 2019-12-13 A | 100% | finish no earlier than 2019-12-15 | R2 | 3128h | 3128h | LTE_feMob-Core | 41 | China Telecom | Rel-16 | 80 |  |  |  |
| 3228 | 1306.2 | Perf. part: Even further mobility enhancement in E-UTRAN |  | 391d? | 2018-06-15 A | 2019-12-13 A | 100% | finish no earlier than 2019-12-15 | R4 | 3128h | 3128h | LTE_feMob-Perf | 41 | China Telecom | Rel-16 | 80 |  |  |  |
| 3229 | 1306.3 | UE Conformance Test Aspects - Even further mobility enhancement in E-UTRAN |  | 523d | 2020-06-22 A | 2022-06-22 A | 100% | finish no earlier than 2022-06-22 | R5 | 4184h | 4184h | LTE_feMob-UEConTest | 45 | Jingzhou Wu, China Telecom | Rel-16 | 88 | wujingzhou@chinatelecom.cn | RP-221293 |  |
| 3230 | 1307 | **410 - 430 MHz E-UTRA FDD Band(s) for LTE PPDR and PMR/PAMR in Europe** |  | 762.25d | 2018-12-13 A | 2020-12-17 A | 100% |  | R4 | 8928h | 8928h | LTE410_Europe_PPDR | 42 | Nokia | Rel-16 | 82 |  |  |  |
| 3231 | 1307.1 | Core part: 410 - 430 MHz E-UTRA FDD Band(s) for LTE PPDR and PMR/PAMR in Europe |  | 262d | 2018-12-13 A | 2019-12-13 A | 100% | finish no earlier than 2019-12-13 | R4 | 2096h | 2096h | LTE410_Europe_PPDR-Core | 42 | Nokia | Rel-16 | 82 |  |  |  |
| 3232 | 1307.2 | Perf. part: 410 - 430 MHz E-UTRA FDD Band(s) for LTE PPDR and PMR/PAMR in Europe |  | 262d | 2018-12-13 A | 2019-12-13 A | 100% | finish no earlier than 2019-12-13 | R4 | 2096h | 2096h | LTE410_Europe_PPDR-Perf | 42 | Nokia | Rel-16 | 82 |  |  |  |
| 3233 | 1307.3 | UE Conformance Test Aspects - 410-430 MHz E-UTRA FDD Band(s) for LTE PPDR and PMR/PAMR in Europe (Bands 87 and 88) |  | 66d | 2020-09-17 A | 2020-12-17 A | 100% | finish no earlier than 2020-12-17 | R5 | 528h | 528h | LTE410_Europe_PPDR-UEConTest | 45 | Nokia | Rel-16 | 89 |  |  |  |
| 3234 | 1308 | **Support for NavIC Navigation Satellite System for LTE** |  | 183.25d | 2019-09-19 A | 2020-03-13 A | 100% |  | R2 | 3048h | 3048h | LCS_NAVIC | 43 | Reliance Jio | Rel-16 | 85 |  |  |  |
| 3235 | 1308.1 | Core part: Support for NavIC Navigation Satellite System for LTE |  | 127d | 2019-09-19 A | 2020-03-13 A | 100% | finish no earlier than 2020-03-15 | R2 | 1016h | 1016h | LCS_NAVIC-Core | 43 | Reliance Jio | Rel-16 | 85 |  |  |  |
| 3236 | 1308.2 | Perf. part: Support for NavIC Navigation Satellite System for LTE |  | 127d | 2019-09-19 A | 2020-03-13 A | 100% | finish no earlier than 2020-03-15 | R4 | 1016h | 1016h | LCS_NAVIC-Perf | 43 | Reliance Jio | Rel-16 | 85 |  |  |  |
| 3237 | 1309 | All other Release 16 Features | milestone | 0d? | 2016-06-09 A | 2016-06-09 A | 100% | finish no earlier than 2016-06-09 |  |  |  |  |  |  | Rel-16 |  |  |  |  |
| 3238 | 1310 | 5G Media Streaming stage 3 |  | 334d | 2019-06-06 A | 2020-09-15 A | 100% | finish no earlier than 2020-09-15 | S4 | 2672h | 2672h | 5GMS3 | 43 | Paul Szucs, Sony | Rel-16 | 84 | Paul.Szucs@Sony.com |  |  |
| 3239 | 1311 | User Plane Integrity Protection |  | 10d | 2020-06-12 A | 2020-06-25 A | 100% | finish no earlier than 2020-06-25 | S3 | 80h | 80h | UPIP_SEC | 45 | Tim Evans, Vodafone Group | Rel-16 | 88 | tim.evans1@vodafone.com |  |  |
| 3240 | 1312 | Removal of H.263 and MPEG-4 Visual from 3GPP Services |  | 60d | 2020-06-25 A | 2020-09-16 A | 100% | finish no earlier than 2020-09-16 | S4 | 480h | 480h | RM_H263_MP4V | 45 | Thomas Stockhammer | Rel-16 | 88 | tsto@qti.qualcomm.com |  |  |
| 3241 | 1313 | **Introduction of GSM, UTRA, E-UTRA and NR capability set(s) (CS(s)) to the multi-standard radio (MSR) specifications** |  | 204d | 2019-03-01 A | 2019-09-13 A | 100% |  | R4 | 3384h | 3384h | MSR_GSM_UTRA_LTE_NR | 42 | Ericsson | Rel-16 | 83 |  |  |  |
| 3242 | 1313.1 | Core part: Introduction of GSM, UTRA, E-UTRA and NR CS(s) to the MSR specifications |  | 141d | 2019-03-01 A | 2019-09-13 A | 100% | finish no earlier than 2019-09-15 | R4 | 1128h | 1128h | MSR_GSM_UTRA_LTE_NR-Core | 42 | Ericsson | Rel-16 | 83 |  |  |  |
| 3243 | 1313.2 | Perf. Part: Introduction of GSM, UTRA, E-UTRA and NR CS(s) to the MSR specifications |  | 141d | 2019-03-01 A | 2019-09-13 A | 100% | finish no earlier than 2019-09-15 | R4 | 1128h | 1128h | MSR_GSM_UTRA_LTE_NR-Perf | 42 | Ericsson | Rel-16 | 83 |  |  |  |
| 3244 | 1314 | **Volume Based Charging Aspects for VoLTE** |  | 573.75d? | 2018-09-06 A | 2020-03-12 A | 100% |  |  | 7472h | 7472h | VBCLTE | 43 | Chen, Ai, China Mobile | Rel-16 | 84 | chenai@chinamobile.com |  |  |
| 3245 | 1314.1 | Stage 2 of VBCLTE |  | 331d? | 2018-09-06 A | 2019-12-12 A | 100% | finish no earlier than 2019-12-12 | S5 | 2648h | 2648h | VBCLTE | 41 | Chen, Ai, China Mobile | Rel-16 | 81 | chenai@chinamobile.com |  |  |
| 3246 | 1314.2 | **CT aspects of VBCLTE** |  | 291d | 2019-06-06 A | 2020-03-12 A | 100% |  | ct | 4824h | 4824h | VBCLTE | 43 | Huang Zhenning (China Mobile) | Rel-16 | 84 | huangzhenning (at) chinamobile (dot) com |  |  |
| 3247 | 1314.2.1 | Stopped - CT1 aspects of VBCLTE |  | 201d | 2019-06-06 A | 2020-03-12 A | 100% | finish no earlier than 2020-03-12 | C1 | 1608h | 1608h | VBCLTE | 43 | Huang Zhenning (China Mobile) | Rel-16 | 84 | huangzhenning (at) chinamobile (dot) com |  | 84 |
| 3248 | 1314.2.2 | CT3 aspects of VBCLTE |  | 201d | 2019-06-06 A | 2020-03-12 A | 100% | finish no earlier than 2020-03-12 | C3 | 1608h | 1608h | VBCLTE | 43 | Huang Zhenning (China Mobile) | Rel-16 | 84 | huangzhenning (at) chinamobile (dot) com |  |  |

Notes:
- 3224: no Perf. part
- 3225: no Perf. part; 26/6/19: 0%->100
- 3226: compare REL-14 WI LTE_eMob¦26/3/19: WID:RP-181475->RP-190272; 26/6/19: WID:RP-190272->RP-190921; 26/3/20: WID:RP-190921->RP-200148
- 3227: compare REL-14 WI LTE_eMob¦26/3/19: WID:RP-181475->RP-190272; 28/7/20: 0%->100
- 3228: 26/3/19: WID:RP-181475->RP-190272; 7/4/21: 0%->100
- 3229: 8/10/20: 0%->5; 8/4/21: 5%->16; 13/9/21: Compl:16%->32%; 13/9/21: CD:Wed 15/12/21->Tue 21/12/21; 13/9/21: Stat Rep: ->RP-211837 ; 20/6/22: Rapporteur: China Telecom->Jingzhou Wu, China Telecom; Rap eMail: ->wujingzhou@chinatelecom.cn;
- 3230: 26/6/19: WID:RP-182898->RP-191287
- 3231: 26/6/19: 0%->100
- 3232: 26/6/19: 0%->100
- 3233: tested: REL-16 WI LTE410_Europe_PPDR-Core ; 6/1/21: 0%->100
- 3234: introduction of Indian GNSS; 14/1/20: WID:RP-192350->RP-192408
- 3235: 26/3/20: 0%->100
- 3236: 26/3/20: 0%->100
- 3237: -
- 3238: 13/9/19: 0%->25; 6/12/19: 25%->50; 6/12/19: FCD:12/12/2019->03/20; 25/3/20: 50%->70; 25/3/20: FCD:12/03/2020->06/20; 10/6/20: 70%->85; 26/6/20: FCD:12/06/2020->09/20; 12/9/20: 85%->100. Moved to Rel-16 / Impacted TSs and TRs: 26.234; 26.247; 26.117; 26.502; 26.503; 26.504; 26.511; 26.512
- 3239: 33.501; 33.401 ; 26/6/20: 0%->100; 25/9/20: WID:SP-200354->SP-200656
- 3240: 26.140; 26.114; 26.244; 26.346; 26.234; 26/6/20: 0%->60; 12/9/20: 60%->100
- 3242: 8/10/19: 0%->100
- 3243: 8/10/19: 0%->100
- 3244: 14/3/19: 0%->50 / Impacted TSs and TRs: 32.251; 32.260; 32.298; 32.299
- 3245: 14/3/19: 0%->50; 13/9/19: 50%->55; 13/9/19: FCD:14/06/2019->12/20; 6/12/19: 55%->100 / Impacted TSs and TRs: 32.251; 32.260; 32.298; 32.299
- 3247: 2/7/20: 0%->100 / Impacted TSs and TRs: 24.229
- 3248: 6/12/19: 0%->100; 26/6/20: WID:CP-191110->CP-201206 / Impacted TSs and TRs: 29.212; 29.213; 29.214

| ID | WBS | Task | Duration | Start | Finish | Complete | Constraint | Resources | Work | Actual work | Acronym | PCG approved | WI rapporteur name | Release | TSG approved | WI rapporteur e-mail |
| --- | --- | --- | --- | --- | --- | --- | --- | --- | --- | --- | --- | --- | --- | --- | --- | --- |
| 3249 | 1315 | **Integrated access and backhaul for NR** | 1228.25d? | 2017-03-15 A | 2020-06-12 A | 100% |  |  | 12904h | 12904h | NR_IAB | 42 | Qualcomm | Rel-16 | 82 |  |
| 3250 | 1315.1 | Study on NR_IAB | 458d? | 2017-03-15 A | 2018-12-14 A | 100% | finish no earlier than 2018-12-15 | R2 | 3664h | 3664h | FS_NR_IAB | 38 | Qualcomm | Rel-16 | 75 |  |
| 3251 | 1315.2 | **Architecture enhancements for the support of Integrated access and backhaul (IAB)** | 182.25d | 2019-09-19 A | 2020-03-12 A | 100% |  | S2 | 3512h | 3512h | IABARC | 43 | Hong Cheng, Qualcomm Incorporated | Rel-16 | 85 | hongc@qti.qualcomm.com |
| 3252 | 1315.2.1 | Stage 2 of IABARC | 61d | 2019-09-19 A | 2019-12-12 A | 100% | finish no earlier than 2019-12-12 | S2 | 488h | 488h | IABARC | 43 | Hong Cheng, Qualcomm Incorporated | Rel-16 | 85 | hongc@qti.qualcomm.com |
| 3253 | 1315.2.2 | CT4 aspects of IABARC | 126d | 2019-09-19 A | 2020-03-12 A | 100% | finish no earlier than 2020-03-12 | C4 | 1008h | 1008h | IABARC | 43 | Chaponniere, Lena, Qualcomm Incorporated | Rel-16 | 85 | lguellec@qti.qualcomm.com |
| 3254 | 1315.2.3 | CT1 aspects of IABARC | 126d | 2019-09-19 A | 2020-03-12 A | 100% | finish no earlier than 2020-03-12 | C1 | 1008h | 1008h | IABARC | 43 | Chaponniere, Lena, Qualcomm Incorporated | Rel-16 | 85 | lguellec@qti.qualcomm.com |
| 3255 | 1315.3 | Core part: NR_IAB | 262d | 2019-03-07 A | 2020-03-06 A | 100% |  | R2 | 2096h | 2096h | NR_IAB-Core | 42 | Qualcomm | Rel-16 | 82 |  |
| 3256 | 1315.4 | Perf. Part: NR_IAB | 262d | 2019-03-07 A | 2020-03-06 A | 100% |  | R4 | 2096h | 2096h | NR_IAB-Perf | 42 | Qualcomm | Rel-16 | 82 |  |
| 3257 | 1315.5 | Security for IAB | 192d | 2019-09-19 A | 2020-06-12 A | 100% | finish no earlier than 2020-06-12 | S3 | 1536h | 1536h | NR_IAB | 43 | Rajavelsamy Rajadurai, Samsung | Rel-16 | 85 | rajvel{@]samsung.com |
| 3258 | 1316 | User Plane Gateway Function for Inter-PLMN Security | 70d | 2019-12-06 A | 2020-03-12 A | 100% | finish no earlier than 2020-03-12 | S3 | 560h | 560h | UPGF | 44 | Steve Kohalmi, Juniper Networks | Rel-16 | 86 | skohalmi@juniper.net |
| 3259 | 1317 | Enhancements to IMS for new real time communication services | 197d? | 2018-03-15 A | 2018-12-14 A | 100% | finish no earlier than 2018-12-14 | S1 | 1576h | 1576h | enIMS | 40 | China Mobile, Hui Cai | Rel-16 | 79 | caihui at chinamobile dot com |
| 3260 | 1318 | Enhancement of 5G PCC related services | 266d | 2018-12-13 A | 2019-12-19 A | 100% | start no earlier than 2018-12-13 | C3 | 2128h | 2128h | en5GPccSer | 42 | Xiaoyun Zhou, Huawei | Rel-16 | 82 | zhouxiaoyun8@huawei.com |
| 3261 | 1319 | Energy efficiency of 5G | 396d? | 2018-09-06 A | 2020-03-12 A | 100% | finish no earlier than 2020-03-12 | S5 | 3168h | 3168h | EE_5G | 41 | CORNILY, Jean-Michel, ORANGE | Rel-16 | 81 | jeanmichel.cornily@orange.com |
| 3262 | 1320 | Signalling Improvements for Network Efficiency in 5GS | 261d | 2018-12-13 A | 2019-12-12 A | 100% | finish no earlier than 2019-12-12 | C1 | 2088h | 2088h | SINE_5G | 42 | Shu, Lin | Rel-16 | 82 | shulin@huawei.com |
| 3263 | 1321 | New Services and Markets Technology Enablers – Phase 2 | 197d? | 2018-03-15 A | 2018-12-14 A | 100% | finish no earlier than 2018-12-14 | S1 | 1576h | 1576h | SMARTER_Ph2 | 40 | Li, Alice, Vodafone | Rel-16 | 79 | alice.li@vodafone.com |
| 3264 | 1322 | 5G Voice Service Continuity | 59d? | 2017-12-21 A | 2018-03-13 A | 100% | finish no earlier than 2018-03-13 | S1 | 472h | 472h | 5GVSC | 40 | Qun Wei, China Unicom | Rel-16 | 78 | weiqun5@chinaunico.cn |
| 3265 | 1323 | Security Assurance Specification for 5G | 392d? | 2018-03-15 A | 2019-09-13 A | 100% | finish no earlier than 2019-09-13 | S3 | 3136h | 3136h | SCAS_5G | 40 | Marcus Wong, Huawei Technologies | Rel-16 | 79 | mwong@huawei.com |
| 3266 | 1324 | **5GS Transfer of Policies for Background Data Transfer** | 385.25d? | 2019-03-07 A | 2020-03-12 A | 100% |  |  | 7456h | 7456h | xBDT | 43 |  | Rel-16 | 84 | ta-usui@kddi.com |
| 3267 | 1324.1 | Stage 2 of xBDT | 201d? | 2019-03-07 A | 2019-12-12 A | 100% |  | S2 | 1608h | 1608h | xBDT | 41 |  | Rel-16 | 80 | ta-usui@kddi.com |
| 3268 | 1324.2 | **CT aspects of xBDT** | 291d | 2019-06-06 A | 2020-03-12 A | 100% |  | ct | 5848h | 5848h | xBDT | 43 | Yan Xiaojian, ZTE | Rel-16 | 84 | yan.xiaojian@zte.com.cn |
| 3269 | 1324.2.1 | CT1 aspects of xBDT | 201d | 2019-06-06 A | 2020-03-12 A | 100% | finish no earlier than 2020-03-12 | C1 | 1608h | 1608h | xBDT | 43 | Yan Xiaojian, ZTE | Rel-16 | 84 | yan.xiaojian@zte.com.cn |
| 3270 | 1324.2.2 | CT3 aspects of xBDT | 201d | 2019-06-06 A | 2020-03-12 A | 100% | finish no earlier than 2020-03-12 | C3 | 1608h | 1608h | xBDT | 43 | Yan Xiaojian, ZTE | Rel-16 | 84 | yan.xiaojian@zte.com.cn |
| 3271 | 1324.2.3 | CT4 aspects of xBDT | 128d | 2019-09-17 A | 2020-03-12 A | 100% | start no earlier than 2019-09-17 | C4 | 1024h | 1024h | xBDT | 43 | Yan Xiaojian, ZTE | Rel-16 | 85 | yan.xiaojian@zte.com.cn |
| 3272 | 1325 | Service Interactivity | 590d? | 2017-09-08 A | 2019-12-12 A | 100% | finish no earlier than 2019-12-12 | S4 | 4720h | 4720h | SerInter | 39 | Lo, Charles, Qualcomm Incorporated | Rel-16 | 77 | clo@qti.qualcomm.com |
| 3273 | 1326 | Alternative EVS implementation using updated fixed-point basic operators | 138d? | 2018-06-06 A | 2018-12-14 A | 100% | finish no earlier than 2018-12-14 | S4 | 1104h | 1104h | Alt_FX_EVS | 41 | Pawate, Raj, Cadence Design Systems Inc | Rel-16 | 80 | pawateb@cadence.com |
| 3274 | 1327 | Shared Data Handling on Nudm and Nudr | 138d? | 2018-06-06 A | 2018-12-14 A | 100% | finish no earlier than 2018-12-14 | C4 | 1104h | 1104h | Shared_Data | 41 | Wiehe, Ulrich, Nokia | Rel-16 | 80 | ulrich.wiehe@nokia.com |
| 3275 | 1328 | Usage of CAPIF for xMB API | 197d? | 2018-03-15 A | 2018-12-14 A | 100% | finish no earlier than 2018-12-14 | S4 | 1576h | 1576h | CAPIF4xMB | 40 | Thorsten Lohmar, Ericsson LM | Rel-16 | 79 | Thorsten.lohmar@ericsson.com |
| 3276 | 1329 | Policy delivery to UE for background data transfer | 29d? | 2018-05-08 A | 2018-06-15 A | 100% | start no earlier than 2018-05-08 | S1 | 232h | 232h | PDBDT | 41 | Takatsugu Kito, KDDI | Rel-16 | 80 | ta-kito at kddi dot com |
| 3277 | 1330 | QoS Monitoring | 197d? | 2018-03-15 A | 2018-12-14 A | 100% | finish no earlier than 2018-12-14 | S1 | 1576h | 1576h | QoS_MON | 40 | Amar Deol | Rel-16 | 79 | amar.deol@huawei.com |
| 3278 | 1331 | Inter-RAT Mobility requirements for real time service | 73d? | 2018-06-06 A | 2018-09-14 A | 100% | finish no earlier than 2018-09-14 | S1 | 584h | 584h | MOBRT | 41 | Yang Xu, Oppo | Rel-16 | 80 | xuyang@oppo.com |
| 3279 | 1332 | Management of QoE measurement collection | 659d? | 2017-06-05 A | 2019-12-12 A | 100% | finish no earlier than 2019-12-12 | S5 | 5272h | 5272h | QOED | 39 | Petersen, Robert, Ericsson | Rel-16 | 76 | robert <dot> petersen <at>ericsson<dot>ericsson |
| 3280 | 1333 | Study on network policy management for mobile networks based on NFV scenarios | 269d? | 2017-06-05 A | 2018-06-14 A | 100% | finish no earlier than 2018-06-14 | S5 | 2152h | 2152h | FS_NETPOL | 39 | China Mobile Jinglei Liu | Rel-15 | 76 | liujinglei@chinamobile.com |
| 3281 | 1334 | Network policy management for mobile networks based on NFV scenarios | 331d? | 2018-09-06 A | 2019-12-12 A | 100% | finish no earlier than 2019-12-12 | S5 | 2648h | 2648h | NETPOL | 41 | China Mobile Hao Zhang | Rel-16 | 81 | zhanghao@chinamobile.com |
| 3282 | 1335 | OAM aspects of LTE and WLAN integration | 202d? | 2018-09-06 A | 2019-06-14 A | 100% | finish no earlier than 2019-06-14 | S5 | 1616h | 1616h | OAM_LTE_WLAN | 41 | Yizhi Yao, Intel Corporation | Rel-16 | 81 | yizhi dot yao at intel dot com |
| 3283 | 1336 | Methodology for 5G management specifications | 137d? | 2018-09-06 A | 2019-03-15 A | 100% | finish no earlier than 2019-03-15 | S5 | 1096h | 1096h | METHOGY | 41 | Groenendijk, Jan, Ericsson | Rel-16 | 81 | jan<dot>Groenendijk<at>ericsson<dot>com |
| 3284 | 1337 | Nchf Online and Offline charging services | 201d | 2018-12-13 A | 2019-09-19 A | 100% | start no earlier than 2018-12-13 | S5 | 1608h | 1608h | OFSBI_CH | 42 | Zhu Lei, Huawei | Rel-16 | 82 | Zhulei@huawei.com |
| 3285 | 1338 | Charging Enhancement of 5GC interworking with EPC | 201d | 2018-12-13 A | 2019-09-19 A | 100% | start no earlier than 2018-12-13 | S5 | 1608h | 1608h | 5GIEPC_CH | 42 | Chen Shan, Huawei | Rel-16 | 82 | chenshan@huawei.com |
| 3286 | 1339 | NRM enhancements | 326d | 2018-12-13 A | 2020-03-12 A | 100% | finish no earlier than 2020-03-12 | S5 | 2608h | 2608h | eNRM | 42 | Jing Ping, Nokia | Rel-16 | 82 | jing.ping@nokia-sbell.com |
| 3287 | 1340 | Network Exposure Charging in 5G System Architecture | 266d | 2018-12-13 A | 2019-12-19 A | 100% | start no earlier than 2018-12-13 | S5 | 2128h | 2128h | 5GS_Ph1_NEFCH | 42 | Tornkvist, Robert, Ericsson | Rel-16 | 82 | robert(dot)tornkvist(at)Ericsson(dot)com |
| 3288 | 1341 | Charging AMF in 5G System Architecture Phase 1 | 266d | 2018-12-13 A | 2019-12-19 A | 100% | start no earlier than 2018-12-13 | S5 | 2128h | 2128h | 5GS_Ph1_AMFCH | 42 | Gardella, Maryse, Nokia | Rel-16 | 82 | maryse.gardella@nokia.com |
| 3289 | 1342 | Trace Management in the context of Services Based Management Architecture | 326d | 2018-12-13 A | 2020-03-12 A | 100% | finish no earlier than 2020-03-12 | S5 | 2608h | 2608h | TM_SBMA | 42 | Andrianov, Anatoly, Nokia | Rel-16 | 82 | anatoly.andrianov@nokia.com |
| 3290 | 1343 | Lawful Interception Rel-16 | 652d | 2018-12-13 A | 2021-06-11 A | 100% | finish no earlier than 2021-06-12 | S3LI | 5216h | 5216h | LI16 | 42 | Alex Leadbeater, BT | Rel-16 | 82 | alex.leadbeater@bt.com |

Notes:
- 3249: follow-up WI of REL-16 SI FS_NR_IAB¦26/3/19: WID:RP-182882->RP-190712; 26/6/19: WID:RP-190712->RP-191558; 8/10/19: WID:RP-191558->RP-192188; 14/1/20: WID:RP-192188->RP-193226; 26/3/20: WID:RP-193226->RP-200084; 28/7/20: WID:RP-200084->RP-200840; 25/9/2 / Impacted TSs and TRs: 38.809
- 3250: TR 38.8XX¦30/6/17: 38.874 added;¦19/9/17: WID: RP-170831->RP-171880¦8/1/18: WID: RP-171880->RP-17229027/3/18: Compl:0%->20%¦27/6/18: Compl:20%->50%¦27/6/18: CD:Fri 15/06/18->Sat 15/12/18;¦16/1/19: 50%->100 / Impacted TSs and TRs: 38.874
- 3251: 13/9/19: 0%->33 / Impacted TSs and TRs: 23.501; 23.502; 23.401
- 3252: 13/9/19: 0%->33; 6/12/19: 33%->100 / Impacted TSs and TRs: 23.501; 23.502; 23.401
- 3253: ; 9/12/19: WID:CP-192256->CP-193015; 26/3/20: 0%->100; 2/7/20: WID:CP-193015->CP 201074 / Impacted TSs and TRs: 24.301; 24.501; 23.008; 29.230; 29.272; 29.274; 29.503; 29.504; 29.505; 29.509; 29.518
- 3254: ; 9/12/19: WID:CP-192256->CP-193015; 26/3/20: 0%->100; 2/7/20: 0%->100 / Impacted TSs and TRs: 24.301; 24.501; 23.008; 29.230; 29.272; 29.274; 29.503; 29.504; 29.505; 29.509; 29.518
- 3255: follow-up WI of REL-16 SI FS_NR_IAB¦26/3/19: WID:RP-182882->RP-190712; 8/10/19: WID:RP-190712->RP-192188; 28/7/20: WID:RP-200084->RP-200840; 25/9/20: 0%->100; 25/9/20: 38.175 added;; 25/9/20: 38.809 added; / Impacted TSs and TRs: 38.175; 38.809
- 3256: 26/3/19: WID:RP-182882->RP-190712; 8/10/19: WID:RP-190712->RP-192188; 25/9/20: 38.809 added;; 9/4/21: 38.176-1 and 2 added;; 2/7/21: 0%->100 / Impacted TSs and TRs: 38.809; 38.176-1; 38.176-2
- 3257: ; 6/12/19: 0%->65; 6/12/19: FCD:12/12/2019->03/20; 25/3/20: FCD:12/03/2020->06/20; 26/6/20: 65%->100 / Impacted TSs and TRs: 33.501
- 3258: ; 6/12/19: 0%->90; 25/3/20: 90%->100 / Impacted TSs and TRs: 33.501
- 3259: 7/6/18: 0%->25¦10/9/18: 25%->50¦10/9/18: FCD:09/18->12/18¦4/12/18: 50%->100 / Impacted TSs and TRs: 22.261; 22.468; 22.228; 22.280; 22.281; 22.282; 22.179
- 3260: ¦14/3/19: 0%->10; 31/5/19: 10%->60; 13/9/19: 60%->70; 6/12/19: 70%->90; 26/3/20: 90%->100 / Impacted TSs and TRs: 29.507; 29.512; 29.513; 29.514; 29.551; 29.594; 29.214; 29.519
- 3261: 7/12/18: 0%->20¦14/3/19: 20%->40; 31/5/19: 40%->45; 13/9/19: 45%->70; 12/12/19: WID:SP-180819->SP-191193; 12/12/19: FCD:13/12/2019->03/20; 26/3/20: 70%->95; 28/6/20: 95%->100 / Impacted TSs and TRs: 28.540; 28.541; 28.552; 28.554
- 3262: ¦14/3/19: 0%->50¦18/3/19: FCD:019->12/19¦18/3/19: WID:CP-183085->CP-190142; 31/5/19: 50%->75; 13/9/19: 75%->85; 6/12/19: 85%->95; 26/3/20: 95%->100 / Impacted TSs and TRs: 24.501; 24.301; 24.368; 27.007; 24.008
- 3263: 7/6/18: WID:SP-180138->SP-180313¦7/6/18: 0%->10¦10/9/18: 10%->40¦4/12/18: 40%->100 / Impacted TSs and TRs: 22.261; 22.278
- 3264: 16/3/18: 0%->100 / Impacted TSs and TRs: 22.261
- 3265: 27/3/18: added: 33.514¦33.513¦33.511¦33.512¦33.515 ¦6/8/18: 33.511 to 515 added;¦10/9/18: 0%->10¦2/10/18: WID:SP-180238->SP-180689¦7/12/18: 10%->20¦20/3/19: 20%->60; 31/5/19: 60%->75; 13/9/19: 75%->100 / Impacted TSs and TRs: 33.216; 33.926; 33.515; 33.511; 33.512; 33.513; 33.514; 33.515
- 3266: Impacted TSs and TRs: 23.501; 23.502; 23.503
- 3267: 31/5/19: 0%->100 / Impacted TSs and TRs: 23.501; 23.502; 23.503
- 3268: 17/9/19: WID:CP-191113->CP-192182
- 3269: 13/9/19: 0%->100 / Impacted TSs and TRs: 24.526
- 3270: 13/9/19: 0%->70; 6/12/19: 70%->95; 26/3/20: 95%->100 / Impacted TSs and TRs: 29.519; 29.513; 29.514; 29.122; 29.522; 29.525
- 3271: 26/3/20: 0%->100
- 3272: 15/12/17: 0%->10¦16/3/18: 10%->20¦7/6/18: 20%->40¦7/6/18: FCD:06/18->12/18. Moved from Rel-15¦10/9/18: 40%->50¦7/12/18: 50%->60¦7/3/19: 60%->70¦7/3/19: FCD:12/18->06/19; 31/5/19: FCD:14/06/2019->09/20; 31/5/19: 70%->80; 13/9/19: FCD:12/09/2019->12/20; / Impacted TSs and TRs: 26.346; 26.247; 26.347
- 3273: 6/8/18: 26.452 added;¦10/9/18: 0%->20¦7/12/18: 20%->90¦7/3/19: 90%->100 / Impacted TSs and TRs: 26.441; 26.442; 26.444; 26.445; 26.446; 26.447; 26.449; 26.450; 26.451; 26.952; 26.452
- 3274: 10/9/18: 0%->90¦10/12/18: 90%->100 / Impacted TSs and TRs: 29.503; 29.505; 29.504
- 3275: 7/6/18: 0%->25¦6/8/18: 26.348 added;¦10/9/18: 25%->40¦7/12/18: 40%->100 / Impacted TSs and TRs: 26.346; new; 26.348
- 3276: 10/9/18: 90%->100 / Impacted TSs and TRs: 22.261
- 3277: 7/6/18: 0%->60¦10/9/18: 60%->85¦10/9/18: FCD:06/18->12/18¦4/12/18: 85%->100 / Impacted TSs and TRs: 22.261
- 3278: 10/9/18: 70%->100 / Impacted TSs and TRs: 22.261
- 3279: 30/6/17: 28.309 added;¦30/6/17: 28.308 added;¦30/6/17: 28.307 added;¦30/6/17: 28.406 added;¦11/9/17: 0%->5¦15/12/17: 5%->15¦16/3/18: 15%->25¦7/6/18: FCD:06/18->12/18. 16/6/16: moved from Rel-15¦10/9/18: 25%->30¦7/12/18: 30%->40¦13/12/18: FCD: ; 31/5 / Impacted TSs and TRs: 32.101; 32.103; 6 new TS; 28.309; 28.308; 28.307; 28.406; 28.405; 28.404
- 3280: 30/6/17: 32.871 added;¦11/9/17: 0%->20¦15/12/17: 20%->30¦16/3/18: 30%->35¦7/6/18: 35%->100 / Impacted TSs and TRs: new; 32.871
- 3281: 7/12/18: 0%->10; 13/9/19: 10%->85; 13/9/19: FCD:13/09/2019->12/20; 6/12/19: 85%->100; 12/12/19: WID:SP-180821->SP-191194 / Impacted TSs and TRs: New
- 3282: 7/12/18: 0%->50¦14/3/19: 50%->100 / Impacted TSs and TRs: 32.425; 28.621; 28.622; 28.623; 28.657; 28.658; 28.659
- 3283: 7/12/18: 0%->60¦14/3/19: 60%->85; 13/9/19: 85%->100 / Impacted TSs and TRs: New; 32.156
- 3284: ¦14/3/19: 0%->40; 31/5/19: 40%->70; 13/9/19: 70%->100 / Impacted TSs and TRs: 32.240; 32.255; 32.290; 32.291; 32.298
- 3285: ¦14/3/19: 0%->30; 31/5/19: 30%->60; 13/9/19: 60%->100 / Impacted TSs and TRs: 32.255; 32.291; 32.298
- 3286: ¦14/3/19: 0%->10¦21/3/19: WID:SP-181068 ->SP-190140¦21/3/19: FCD:019->09/19; 31/5/19: 10%->20; 13/9/19: 20%->40; 13/9/19: FCD:12/09/2019->03/20; 20/9/19: WID:SP-190140->SP-190778; 26/3/20: 40%->92; 28/6/20: 92%->98; 13/9/20: 98%->100 / Impacted TSs and TRs: 28.540; 28.541; 28.622 ; 28.623; 28.620
- 3287: ¦14/3/19: 0%->20; 31/5/19: 20%->50; 13/9/19: 50%->60; 6/12/19: 60%->100 / Impacted TSs and TRs: 32.240; 32.254; 32.290; 32.291; 32.298
- 3288: ¦14/3/19: 0%->20; 31/5/19: 20%->50; 13/9/19: 50%->70; 6/12/19: 70%->100 / Impacted TSs and TRs: 32.240; 32.290; 32.291; 32.298; 32.297
- 3289: ; 31/5/19: 0%->10; 13/9/19: FCD:19/06/2019->03/20; 26/3/20: 10%->50; 28/6/20: 50%->100 / Impacted TSs and TRs: 32.421; 32.422; 28.530; 28.532; 28.533; 28.540; 28.541
- 3290: 31/5/19: 0%->15; 13/9/19: 15%->40; 6/12/19: 40%->55; 25/3/20: 55%->60; 25/3/20: FCD:19/12/2019->03/20; 26/6/20: FCD:13/03/2020->09/20; 26/6/20: 60%->85; 12/9/20: 85%->92; 5/12/20: 92%->97; 19/3/21: 97%->99; 19/3/21: FCD:15/09/2020->06/21; 11/6/21: 99%- / Impacted TSs and TRs: 33.107; 33.108; 33.126; 33.127; 33.128

| ID | WBS | Task | Duration | Start | Finish | Complete | Total slack | Constraint | Resources | Work | Actual work | Acronym | PCG approved | WI rapporteur name | WI rapporteur e-mail | Release | TSG approved |
| --- | --- | --- | --- | --- | --- | --- | --- | --- | --- | --- | --- | --- | --- | --- | --- | --- | --- |
| 3291 | 1344 | **IMS Stage-3 IETF Protocol Alignment** | 485.75d | 2018-12-13 A | 2020-03-25 A | 100% |  |  | C1 | 9552h | 9552h | IMSProtoc16 | 42 | Leis, Peter, Nokia | peter.leis@nokia.com | Rel-16 | 82 |
| 3292 | 1344.1 | CT1 aspects of IMSProtoc16 | 262d | 2018-12-13 A | 2019-12-13 A | 100% |  | finish no earlier than 2019-12-13 | C1 | 2096h | 2096h | IMSProtoc16 | 44 | Leis, Peter, Nokia | peter.leis@nokia.com | Rel-16 | 87 |
| 3293 | 1344.2 | CT3 aspects of IMSProtoc16 | 262d | 2018-12-13 A | 2019-12-13 A | 100% |  | finish no earlier than 2019-12-13 | C3 | 2096h | 2096h | IMSProtoc16 | 44 | Leis, Peter, Nokia | peter.leis@nokia.com | Rel-16 | 87 |
| 3294 | 1344.3 | (IETF) Location Source Parameter for the SIP Geolocation Header Field (draft-ietf-sipcore-locparam) | 335d | 2018-12-13 A | 2020-03-25 A | 100% |  | finish no earlier than 2020-03-25 | C1-IETF | 2680h | 2680h | 5GProtoc16 | 44 | Sedlacek, Ivo, Ericsson | ivo <dot> sedlacek <at> ericsson <dot> com | Rel-16 | 87 |
| 3295 | 1345 | **Stage-3 5GS NAS protocol development** | 485.75d | 2018-12-13 A | 2020-03-25 A | 100% |  |  | C1 | 8040h | 8040h | 5GProtoc16 | 42 | Sedlacek, Ivo, Ericsson | ivo <dot> sedlacek <at> ericsson <dot> com | Rel-16 | 82 |
| 3296 | 1345.1 | Stage-3 5GS NAS protocol development general aspects | 335d | 2018-12-13 A | 2020-03-25 A | 100% |  | finish no earlier than 2020-03-25 | C1 | 2680h | 2680h | 5GProtoc16 | 42 | Sedlacek, Ivo, Ericsson | ivo <dot> sedlacek <at> ericsson <dot> com | Rel-16 | 82 |
| 3297 | 1345.2 | Stage-3 5GS NAS protocol development for support for non-3GPP accesses | 335d | 2018-12-13 A | 2020-03-25 A | 100% |  | finish no earlier than 2020-03-25 | C1 | 2680h | 2680h | 5GProtoc16-non3GPP | 42 | Sedlacek, Ivo, Ericsson | ivo <dot> sedlacek <at> ericsson <dot> com | Rel-16 | 82 |
| 3298 | 1346 | **Stage-3 SAE Protocol Development for Rel16** | 385.25d | 2018-12-13 A | 2019-12-19 A | 100% |  |  | C1 | 8512h | 8512h | SAES16 | 42 | Aghili, Behrouz, InterDigital Communications | behrouz.aghili@interdigital.com | Rel-16 | 82 |
| 3299 | 1346.1 | Stage-3 SAE Protocol Development for Rel16 general aspects | 266d | 2018-12-13 A | 2019-12-19 A | 100% |  | start no earlier than 2018-12-13 | C1 | 2128h | 2128h | SAES16 | 42 | Aghili, Behrouz, InterDigital Communications | behrouz.aghili@interdigital.com | Rel-16 | 82 |
| 3300 | 1346.2 | Stage-3 SAE Protocol Development for Rel16 for CS Fallback in EPS | 266d | 2018-12-13 A | 2019-12-19 A | 100% |  | start no earlier than 2018-12-13 | C1 | 2128h | 2128h | SAES16-CSFB | 42 | Aghili, Behrouz, InterDigital Communications | behrouz.aghili@interdigital.com | Rel-16 | 82 |
| 3301 | 1346.3 | Stage-3 SAE Protocol Development Rel16 for support for non-3GPP accesses | 266d | 2018-12-13 A | 2019-12-19 A | 100% |  | start no earlier than 2018-12-13 | C1 | 2128h | 2128h | SAES16-non3GPP | 42 | Aghili, Behrouz, InterDigital Communications | behrouz.aghili@interdigital.com | Rel-16 | 82 |
| 3302 | 1347 | S6b Optional for ePDG connected to 5GS | 21d | 2019-05-09 A | 2019-06-06 A | 100% |  | start no earlier than 2019-05-09 | S2 | 168h | 168h | 5GS_S6b_Optional | 43 | Irfan Ali, Cisco | irfaali at cisco dot com | Rel-16 | 84 |
| 3303 | 1348 | **Service Based Interface Protocol Improvements** | 291d | 2019-06-06 A | 2020-03-12 A | 100% |  |  | ct | 4824h | 4824h | SBIProtoc16 | 43 | Yue Song, China Mobile | songyue (at) chinamobile (dot) com | Rel-16 | 84 |
| 3304 | 1348.1 | CT3 aspects of SBIProtoc16 | 201d | 2019-06-06 A | 2020-03-12 A | 100% |  | finish no earlier than 2020-03-12 | C3 | 1608h | 1608h | SBIProtoc16 | 43 | Yue Song, China Mobile | songyue (at) chinamobile (dot) com | Rel-16 | 84 |
| 3305 | 1348.2 | CT4 aspects of SBIProtoc16 | 201d | 2019-06-06 A | 2020-03-12 A | 100% |  | finish no earlier than 2020-03-12 | C4 | 1608h | 1608h | SBIProtoc16 | 43 | Yue Song, China Mobile | songyue (at) chinamobile (dot) com | Rel-16 | 84 |
| 3306 | 1349 | Withdrawal of TS 24.323 from Rel-11, Rel-12, Rel-13 | 201d | 2019-06-06 A | 2020-03-12 A | 100% |  | finish no earlier than 2020-03-12 | C1 | 1608h | 1608h | ISAT-MO-WITHDRAW | 43 | Dawes, Peter, Vodafone | peter(dot)dawes(at)vodafone(dot)com | Rel-16 | 84 |
| 3307 | 1350 | Lawful Interception Report Rel-16 | 136d | 2019-08-03 | 2019-12-12 |  | 40097.9d | finish no earlier than 2019-12-12 | S3LI | 1088h |  | LIR16 | 43 | Nag Rao, Nokia | nagaraja.rao@nokia.com | Rel-16 | 84 |
| 3308 | 1351 | RTCP Verification for Real-Time Services | 130d | 2019-09-13 A | 2020-03-12 A | 100% |  | start no earlier than 2019-09-13 | S4 | 1040h | 1040h | RTCPVer | 43 | Burman, Bo, Ericsson LM, | bo.burman@ericsson.com | Rel-16 | 85 |
| 3309 | 1352 | Network Slice Performance and Analytics Charging in 5G System | 126d | 2019-09-19 A | 2020-03-12 A | 100% |  | finish no earlier than 2020-03-12 | S5 | 1008h | 1008h | 5GS_NSPACH | 43 | Chen Shan, Huawei | chenshan@huawei.com | Rel-16 | 85 |
| 3310 | 1353 | Closed loop SLS Assurance | 126d | 2019-09-19 A | 2020-03-12 A | 100% |  | finish no earlier than 2020-03-12 | S5 | 1008h | 1008h | COSLA | 43 | Groenendijk, Jan, Ericsson | jan.groenendijk@ericsson.com | Rel-16 | 85 |
| 3311 | 1354 | Streaming trace reporting | 126d | 2019-09-19 A | 2020-03-12 A | 100% |  | finish no earlier than 2020-03-12 | S5 | 1008h | 1008h | OAM_RTT | 43 | Andrianov, Anatoly, Nokia | anatoly.andrianov@nokia.com | Rel-16 | 85 |
| 3312 | 1355 | Enhancement of 3GPP management system for multiple tenant environment support | 126d | 2019-09-19 A | 2020-03-12 A | 100% |  | finish no earlier than 2020-03-12 | S5 | 1008h | 1008h | MEMTANE | 43 | Zhu, Lei, Huawei | lei.zhu@huawei.com | Rel-16 | 85 |
| 3313 | 1356 | Network Slice Management Charging in 5G System | 126d | 2019-09-19 A | 2020-03-12 A | 100% |  | finish no earlier than 2020-03-12 | S5 | 1008h | 1008h | 5GS_NSMCH | 43 | Gardella, Maryse, Nokia | maryse.gardella@nokia.com | Rel-16 | 85 |
| 3314 | 1357 | Management Aspects of 5G Service-Level Agreement | 126d | 2019-09-19 A | 2020-03-12 A | 100% |  | finish no earlier than 2020-03-12 | S5 | 1008h | 1008h | MA5SLA | 43 | Hu, Yushuang, CMCC | huyushuang@chinamobile.com | Rel-16 | 85 |

Notes:
- 3291: ¦14/3/19: 0%->25; 31/5/19: 25%->45; 13/9/19: 45%->65; 6/12/19: 65%->90; 26/3/20: 90%->100; 30/6/20: 99%->100 / Impacted TSs and TRs: 23.218; 24.229; 24.930; 29.163; 29.165; 29.292
- 3292: ¦14/3/19: 0%->25; 31/5/19: 25%->45; 13/9/19: 45%->65; 6/12/19: 65%->90; 26/3/20: 90%->100; 23/4/20: FCD:19/12/2019-> / Impacted TSs and TRs: 23.218; 24.229; 24.930; 29.163; 29.165; 29.292
- 3293: ¦14/3/19: 0%->25; 31/5/19: 25%->45; 13/9/19: 45%->65; 6/12/19: 65%->90; 26/3/20: 90%->100; 23/4/20: FCD:19/12/2019-> / Impacted TSs and TRs: 23.218; 24.229; 24.930; 29.163; 29.165; 29.292
- 3294: ¦14/3/19: 0%->25; 31/5/19: 25%->50; 13/9/19: 50%->65; 6/12/19: 65%->90; 25/3/20: FCD:19/12/2019->03/20; 26/3/20: 90%->98; 30/6/20: 90%->100; 9/4/21: RFC 8787 added; / Impacted TSs and TRs: 23.040; 23.041; 23.122; 24.007; 24.008; 24.011; 24.229; 24.301; 24.302; 24.305; 24.368; 24.501; 24.502; 24.526; 27.007 ; RFC 8787
- 3295: ; 25/3/20: WID:CP-183087->CP-200146 / Impacted TSs and TRs: 23.040; 23.041; 23.122; 24.007; 24.008; 24.011; 24.229; 24.301; 24.302; 24.305; 24.368; 24.501; 24.502; 24.526; 27.007
- 3296: ¦14/3/19: 0%->25; 31/5/19: 25%->50; 13/9/19: 50%->65; 6/12/19: 65%->90; 25/3/20: FCD:19/12/2019->03/20; 26/3/20: 90%->98; 26/6/20: 98%->100 / Impacted TSs and TRs: 23.040; 23.041; 23.122; 24.007; 24.008; 24.011; 24.229; 24.301; 24.302; 24.305; 24.368; 24.501; 24.502; 24.526; 27.007
- 3297: ¦14/3/19: 0%->25; 31/5/19: 25%->50; 25/3/20: FCD:19/12/2019->03/20; 30/6/20: 50%->100 / Impacted TSs and TRs: 23.040; 23.041; 23.122; 24.007; 24.008; 24.011; 24.229; 24.301; 24.302; 24.305; 24.368; 24.501; 24.502; 24.526; 27.007
- 3298: Impacted TSs and TRs: 23.122; 24.008; 24.167; 24.229; 24.301; 24.302; 24.303; 24.304; 24.305; 24.312; 29.018; 29.118; 24.368
- 3299: 14/3/19: 0%->25; 31/5/19: 25%->50; 13/9/19: 50%->65; 6/12/19: 65%->90; 26/3/20: 90%->100 / Impacted TSs and TRs: 23.122; 24.008; 24.167; 24.229; 24.301; 24.302; 24.303; 24.304; 24.305; 24.312; 29.018; 29.118; 24.368
- 3300: 14/3/19: 0%->25; 31/5/19: 25%->50; 30/6/20: 50%->100 / Impacted TSs and TRs: 23.122; 24.008; 24.167; 24.229; 24.301; 24.302; 24.303; 24.304; 24.305; 24.312; 29.018; 29.118; 24.368
- 3301: 14/3/19: 0%->25; 31/5/19: 25%->50; 30/6/20: 50%->100 / Impacted TSs and TRs: 23.122; 24.008; 24.167; 24.229; 24.301; 24.302; 24.303; 24.304; 24.305; 24.312; 29.018; 29.118; 24.368
- 3302: 6/6/19: 0%->100 / Impacted TSs and TRs: 23.501; 23.502
- 3304: 13/9/19: 0%->25; 6/12/19: 25%->75; 26/3/20: 75%->100 / Impacted TSs and TRs: 29.507; 29.508; 29.512; 29.514; 29.519; 29.520; 29.521; 29.522; 29.523; 29.525; 29.551; 29.554
- 3305: 31/5/19: 0%->10; 6/12/19: 10%->90; 26/3/20: 90%->95; 26/6/20: 95%->100 / Impacted TSs and TRs: 29.500; 29.501; 29.502; 29.503; 29.504; 29.505; 29.509; 29.510; 29.511; 29.531; 29.540; 29.518; 29.571; 29.572; 29.573
- 3306: ; 13/9/19: 0%->100 / Impacted TSs and TRs: 24.323
- 3307: Impacted TSs and TRs: New
- 3308: ; 8/10/19: 26.139 added;; 6/12/19: 0%->60; 25/3/20: 60%->100 / Impacted TSs and TRs: 26.114; 24.380; 24.581; 26.281; New ; 26.139
- 3309: 8/10/19: 28.201 added;; 6/12/19: 0%->15; 26/3/20: 15%->30; 28/6/20: 30%->60; 13/9/20: 60%->100 / Impacted TSs and TRs: 32.240; 32.290; 32.291; 32.298; 32.297 ; 28.201
- 3310: ; 8/10/19: 28.536 added;; 26/3/20: 0%->55; 28/6/20: 55%->100 / Impacted TSs and TRs: 28.533; 28.540; 28.541; 28.530; 28.531; 28.545; 28.546; 28.550; 28.552; 28.553 ; 28.536; 28.535
- 3311: ; 26/3/20: 0%->25; 28/6/20: 25%->100 / Impacted TSs and TRs: 32.421; 32.422; 32.423; 28.532; 28.533
- 3312: ; 26/3/20: 0%->35; 28/6/20: 35%->100 / Impacted TSs and TRs: 28.531; 28.532; 28.533; 28.541; 28.552; 28.554
- 3313: ; 8/10/19: 28.202 added;; 6/12/19: 0%->5; 28/6/20: 5%->50; 13/9/20: 50%->100 / Impacted TSs and TRs: 32.240; 32.290; 32.291; 32.298; 32.297 ; 28.202
- 3314: ; 25/3/20: WID:SP-190789->SP-200185; 26/3/20: 0%->100 / Impacted TSs and TRs: 28.540; 28.541

| ID | WBS | Task | Type | Duration | Start | Finish | Complete | Remaining | Total slack | Constraint | Resources | Work | Actual work | Acronym | PCG approved | WI rapporteur name | WI rapporteur e-mail | Release | TSG approved | Impacted TSs and TRs | Status Report | TSG stopped |
| --- | --- | --- | --- | --- | --- | --- | --- | --- | --- | --- | --- | --- | --- | --- | --- | --- | --- | --- | --- | --- | --- | --- |
| 3315 | 1358 | **Load and Overload Control of 5GC Service Based Interfaces** |  | 669d? | 2018-06-06 A | 2020-03-12 A | 100% |  |  |  |  | 4160h | 4160h | LOLC | 43 | Giorgi Gulbani (Huawei) | giorgi.gulbani@huawei.com | Rel-16 | 85 |  |  |  |
| 3316 | 1358.1 | Study on Load and Overload Control of 5GC Service Based Interfaces |  | 268d? | 2018-06-06 A | 2019-06-14 A | 100% |  |  | finish no earlier than 2019-06-14 | C4 | 2144h | 2144h | FS_LOLC | 41 | Sridhar Bhaskaran (Huawei) | sridhar.bhaskaran@huawei.com | Rel-16 | 80 | New; 22.943 |  |  |
| 3317 | 1358.2 | Deleted: C3 aspects of LOLC (TBD) |  | 126d | 2019-09-19 A | 2020-03-12 A | 100% |  |  | finish no earlier than 2020-03-12 | C3 | 1008h | 1008h | LOLC | 43 | Giorgi Gulbani (Huawei) | giorgi.gulbani@huawei.com | Rel-16 | 85 | TBD |  |  |
| 3318 | 1358.3 | C4 aspects of LOLC |  | 126d | 2019-09-19 A | 2020-03-12 A | 100% |  |  | finish no earlier than 2020-03-12 | C4 | 1008h | 1008h | LOLC | 43 | Giorgi Gulbani (Huawei) | giorgi.gulbani@huawei.com | Rel-16 | 85 | 29.500; 29.510 |  |  |
| 3319 | 1359 | **5GS Enhanced support of Over the air (OTA) mechanism for UICC configuration parameter update** |  | 182.25d | 2019-09-19 A | 2020-03-12 A | 100% |  |  |  | C4 | 3024h | 3024h | 5GS_OTAF | 43 | Wiehe, Ulrich, Nokia | Ulrich.Wiehe@nokia.com | Rel-16 | 85 | 23.122; 29.503 ; 29.510 |  |  |
| 3320 | 1359.1 | C1 aspects of 5GS_OTAF |  | 126d | 2019-09-19 A | 2020-03-12 A | 100% |  |  | finish no earlier than 2020-03-12 | C1 | 1008h | 1008h | 5GS_OTAF | 43 | Wiehe, Ulrich, Nokia | Ulrich.Wiehe@nokia.com | Rel-16 | 85 | 23.122; 29.503 ; 29.510 |  |  |
| 3321 | 1359.2 | C4 aspects of 5GS_OTAF |  | 126d | 2019-09-19 A | 2020-03-12 A | 100% |  |  | finish no earlier than 2020-03-12 | C4 | 1008h | 1008h | 5GS_OTAF | 43 | Wiehe, Ulrich, Nokia | Ulrich.Wiehe@nokia.com | Rel-16 | 85 | 23.122; 29.503 ; 29.510 |  |  |
| 3322 | 1360 | Integration of ONAP and 3GPP 5G management framework |  | 265.88d | 2019-03-07 A | 2020-03-12 A | 100% |  |  | finish no earlier than 2020-03-12 | S5 | 2127h | 2127h | ONAP3GPP | 42 | SMITH David K., AT&T | DS9930@att.com | Rel-16 | 83 | 28.540; 28.622; 28.623; 28.532 |  |  |
| 3323 | 1361 | Support of Hybrid DASH/HLS over eMBMS |  | 70d | 2019-12-06 A | 2020-03-12 A | 100% |  |  | start no earlier than 2019-12-06 | S4 | 560h | 560h | DAHOE | 44 | Thienot, Cédric, Enensys | cedric.thienot@enensys.com | Rel-16 | 86 | 26.346; 26.347; 26.348 |  |  |
| 3324 | 1362 | 3GPP profiles for cryptographic algorithms and security protocols |  | 70d | 2019-12-06 A | 2020-03-12 A | 100% |  |  | finish no earlier than 2020-03-12 | S3 | 560h | 560h | CryptPr | 44 | Christine Jost, Ericsson | christine.jost@ericsson.com | Rel-16 | 86 | 33.210; 33.310; 33.501 |  |  |
| 3325 | 1363 | CHF-controlled quota management |  | 70d | 2019-12-06 A | 2020-03-12 A | 100% |  |  | finish no earlier than 2020-03-12 | S5 | 560h | 560h | CHFCQM | 44 | Lagha, Naceur, Amdocs | nlagha@amdocs.com | Rel-16 | 86 | 32.255; 32.290; 32.291 |  |  |
| 3326 | 1364 | Management of MDT in 5G |  | 70d | 2019-12-06 A | 2020-03-12 A | 100% |  |  | finish no earlier than 2020-03-12 | S5 | 560h | 560h | 5GMDT | 44 | Ayani, Zhulia, Ericsson | zhulia.Ayani@ericsson.com | Rel-16 | 86 | 32.421; 32.422; 32.423; 28.532; 28.533 |  |  |
| 3327 | 1365 | 5G management capabilities |  | 70d | 2019-12-06 A | 2020-03-12 A | 100% |  |  | finish no earlier than 2020-03-12 | S5 | 560h | 560h | 5GMNC | 44 | CORNILY, Jean-Michel, ORANGE | jeanmichel.cornily@orange.com | Rel-16 | 86 | 28.532 |  |  |
| 3328 | 1366 | Nudsf Service Based Interface |  | 70d | 2019-12-06 A | 2020-03-12 A | 100% |  |  | finish no earlier than 2020-03-12 | C4 | 560h | 560h | NUDSF | 44 | Askerup, Anders, Hewlett Packard Enterprise, | Anders.Askerup@hpe.com. | Rel-16 | 86 | 29.510; 29.500 |  |  |
| 3329 | 1367 | Study on Nudsf Service Based Interface |  | 136d | 2019-06-06 A | 2019-12-12 A | 100% |  |  | finish no earlier than 2019-12-12 | C4 | 1088h | 1088h | FS_NUDSF | 43 | Askerup, Anders, Hewlett Packard Enterprise | Anders.Askerup@hpe.com | Rel-16 | 84 | 29.808 |  |  |
| 3330 | 1368 | Nsoraf Service Based Interface |  | 70d | 2019-12-06 A | 2020-03-12 A | 100% |  |  | finish no earlier than 2020-03-12 | C4 | 560h | 560h | NSORAF | 44 | EL MOATAMID, Abdessamad, Orange | abdessamad.elmoatamid@orange.com. | Rel-16 | 86 | 29.503; 29.510 |  |  |
| 3331 | 1369 | Video enhancement of IMS CAT/CRS/announcement services |  | 70d | 2019-12-06 A | 2020-03-12 A | 100% |  |  | finish no earlier than 2020-03-12 | C1 | 560h | 560h | eIMSVideo | 44 | Hongxia Hao, Huawei | haohongxia@huawei.com | Rel-16 | 86 | 24.182; 24.183; 24.628 |  |  |
| 3332 | 1370 | Ambient noise test methodology for evaluation of acoustic UE performance |  | 28d | 2020-02-17 A | 2020-03-25 A | 100% |  |  | start no earlier than 2020-02-17 | S4 | 224h | 224h | ANTeM | 44 | Jan Reimes, HEAD acoustics GmbH, | jan.reimes@head-acoustics.de | Rel-16 | 87 | 26.132 |  |  |
| 3333 | 1371 | UE Conformance Test Aspects - B1C Signal in BDS Positioning System Support for LTE and NR |  | 255d | 2020-09-17 A | 2021-09-08 A | 100% |  |  | finish no earlier than 2021-09-08 | R5 | 2040h | 2040h | B1C_BDS_pos_UEConTest | 45 | CATT |  | Rel-16 | 89 |  |  |  |
| 3334 | 1372 | UE Conformance Test Aspects - Support of eCall over IMS for NR |  | 517d | 2021-03-12 A | 2023-03-03 A | 100% |  |  | finish no earlier than 2023-03-03 | R5 | 4136h | 4136h | NR_EIEI-UEConTest | 46 | Bharadwaj Kumar Cheruvu, Qualcomm | bcheruvu[at]qti.qualcomm.com | Rel-16 | 91 |  | RP-230094 |  |
| 3335 | 1373 | UE Conformance Test Aspects Release 16 |  | 332d | 2022-06-03 A | 2023-09-09 A | 100% |  |  | finish no earlier than 2023-09-09 | C6 | 2656h | 2656h | UEConTest_R16 | 49 | COLLET, Hervé, Thales | herve.collet@thalesgroup.com | Rel-16 | 96 | 31.121; 31.124 |  |  |
| 3336 | 1374 | **(Small) Technical Enhancements and Improvements for Rel-16** |  | 1060.5d? | 2017-09-11 A | 2020-06-30 |  | 1060.5d? | 39889.6d |  |  | 912h |  | TEI16 | 41 |  |  | Rel-16 | 77 |  |  |  |
| 3337 | 1374.1 | (IETF) The Transport Layer Security (TLS) Protocol Version 1.3 (RFC 8446) | milestone | 0d? | 2017-09-11 A | 2017-09-11 A | 100% |  |  | finish no earlier than 2018-12-14 | S3-IETF |  |  | TEI16 | 41 |  |  | Rel-16 | 80 |  |  |  |
| 3338 | 1374.2 | (Small) Test Technical Enhancements and Improvements for Rel-16 |  | 114d? | 2020-03-13 | 2020-06-30 |  |  | 39889.6d | finish no earlier than 2020-06-30 | R5 | 912h |  | TEI16_Test | 41 |  |  | Rel-16 | 86 |  |  |  |
| 3339 | 1375 | Release 16 Studies with no corresponding Feature | milestone | 0d? | 2016-03-15 A | 2016-03-15 A | 100% |  |  | start no earlier than 2016-03-15 |  |  |  |  |  |  |  | Rel-16 |  |  |  |  |
| 3340 | 1376 | Release 16 Studies on 5G/5GS/5GC/NR | milestone | 0d? | 2016-06-09 A | 2016-06-09 A | 100% |  |  | finish no earlier than 2016-06-09 |  |  |  |  |  |  |  | Rel-16 |  |  |  |  |
| 3341 | 1377 | Stopped - Study on system architecture for next generation real time communication services |  | 202d? | 2018-06-06 A | 2019-03-14 A | 100% |  |  | finish no earlier than 2019-03-14 | S2 | 1616h | 1616h | FS_NG_RTC | 41 | Yi Jiang | jiangyi at chinamobile dot com | Rel-16 | 80 | New |  | 84 |
| 3342 | 1378 | Study on security aspects of single radio voice continuity from 5G to UTRAN |  | 262d? | 2018-03-15 A | 2019-03-15 A | 100% |  |  | finish no earlier than 2019-03-15 | S3 | 2096h | 2096h | FS_5G_UTRAN_SEC | 40 | Feng Gao, China Unicom | gaofeng149@chinaunicom.cn | Rel-16 | 79 | 33.856 |  |  |
| 3343 | 1379 | Study on supporting 256-bit algorithms for 5G |  | 196d? | 2017-12-15 A | 2018-09-14 A | 100% |  |  | finish no earlier than 2018-09-14 | S3 | 1568h | 1568h | FS_256_Algo | 40 | Evans, Tim, Vodafone Group | tim.evans1@vodafone.com | Rel-16 | 78 | new |  |  |
| 3344 | 1380 | Study on User Plane Protocol in 5GC |  | 391d? | 2017-12-15 A | 2019-06-14 A | 100% |  |  | finish no earlier than 2019-06-14 | C4 | 3128h | 3128h | FS_UPPS | 40 | Satoru Matsushima, SoftBank Corp | satoru.matsushima@g.softbank.co.jp | Rel-16 | 78 | 29.892 |  |  |
| 3345 | 1381 | Stopped - Study on Application Awareness Interworking between LTE and NR |  | 261d? | 2018-03-15 A | 2019-03-14 A | 100% |  |  | finish no earlier than 2019-03-14 | S2 | 2088h | 2088h | FS_AAI_LTE_NR | 40 | Biao Long, China Telecom | longb.gd@chinatelecom.cn | Rel-16 | 79 | new; 23.727 |  | 84 |
| 3346 | 1382 | Study on NR beyond 52.6 GHz |  | 66d? | 2018-06-15 A | 2018-09-14 A | 100% |  |  | finish no earlier than 2018-09-14 | RP | 528h | 528h | FS_NR_beyond_52GHz | 41 | Intel |  | Rel-16 | 80 | 38.8xx |  |  |
| 3347 | 1383 | Study on remote interference management for NR |  | 131d? | 2018-06-15 A | 2018-12-14 A | 100% |  |  | finish no earlier than 2018-12-15 | R1 | 1048h | 1048h | FS_NR_RIM | 41 | CMCC |  | Rel-16 | 80 |  |  |  |
| 3348 | 1384 | Study on RAN-centric data collection and utilization for LTE and NR |  | 261d? | 2018-06-01 A | 2019-05-31 A | 100% |  |  | finish no earlier than 2019-06-01 | R3 | 2088h | 2088h | FS_LTE_NR_data_collect | 41 | CMCC |  | Rel-16 | 80 |  |  |  |
| 3349 | 1385 | Study on radiated metrics and test methodology for the verification of multi-antenna reception performance of NR UEs |  | 391d? | 2018-06-15 A | 2019-12-13 A | 100% |  |  | finish no earlier than 2019-12-15 | R4 | 3128h | 3128h | FS_NR_MIMO_OTA_test | 41 | CAICT |  | Rel-16 | 80 |  |  |  |
| 3350 | 1386 | Study on evaluation for 2 RX exception in Rel-15 vehicle mounted UE for NR |  | 141d? | 2018-06-01 A | 2018-12-14 A | 100% |  |  | finish no earlier than 2018-12-15 | R4 | 1128h | 1128h | FS_NR_2RX_vehUE | 41 | Samsung |  | Rel-16 | 80 |  |  |  |
| 3351 | 1387 | Study of test methods for New Radio |  | 393d? | 2017-03-15 A | 2018-09-14 A | 100% |  |  | finish no earlier than 2018-09-15 | R4 | 3144h | 3144h | FS_NR_test_methods | 38 | Intel |  | Rel-16 | 75 | 38.810 |  |  |
| 3352 | 1388 | Study on Non-Orthogonal Multiple Access (NOMA) for NR |  | 458d? | 2017-03-15 A | 2018-12-14 A | 100% |  |  | finish no earlier than 2018-12-15 | R1 | 3664h | 3664h | FS_NR_NOMA | 38 | ZTE |  | Rel-16 | 75 | 32.812 |  |  |
| 3353 | 1389 | Stopped - Study of KDF negotiation for 5G System Security |  | 202d? | 2018-09-06 A | 2019-06-14 A | 100% |  |  | finish no earlier than 2019-06-14 | S3 | 1616h | 1616h | FS_5GS_KDF | 41 | Ahmad Muhanna | ahmad.muhanna@huawei.com | Rel-16 | 81 | New |  | 84 |
| 3354 | 1390 | Study on Long Term Key Update Procedures |  | 400d? | 2017-06-05 A | 2018-12-14 A | 100% |  |  | finish no earlier than 2018-12-14 | S3 | 3200h | 3200h | FS_LTKUP | 39 | Evans, Tim, Vodafone | tim.evans1@vodafone.com | Rel-16 | 76 | Internal TR |  |  |
| 3355 | 1391 | Study on eXtended Reality (XR) in 5G |  | 378d? | 2018-10-02 A | 2020-03-12 A | 100% |  |  | finish no earlier than 2020-03-12 | S4 | 3024h | 3024h | FS_5GXR | 41 | Thomas Stockhammer, Qualcomm Incorporated | tsto@qti.qualcomm.com | Rel-16 | 81 | 26.9xx; 26.998 |  |  |
| 3356 | 1392 | Study on 7 - 24 GHz frequency range for NR |  | 262d | 2018-12-13 A | 2019-12-13 A | 100% |  |  | start no earlier than 2018-12-13 | R4 | 2096h | 2096h | FS_7to24GHz_NR | 42 | Huawei |  | Rel-16 | 82 |  |  |  |
| 3357 | 1393 | Study on UEs Supporting Handset Mode with Non-Traditional Earpieces |  | 130.88d | 2019-03-07 A | 2019-09-05 A | 100% |  |  |  | S4 | 1047h | 1047h | FS_HaNTE | 42 | Schevciw, Andre, Qualcomm Incorporated | aschevci@qti.qualcomm.com | Rel-16 | 83 | New |  |  |
| 3358 | 1394 | Study on enhancement for disaggregated gNB architecture |  | 206d | 2019-03-01 A | 2019-12-13 A | 100% |  |  | finish no earlier than 2019-12-15 | R3 | 1648h | 1648h | FS_enh_disagg_gNB | 42 | China Telecom |  | Rel-16 | 83 | 38.823 |  |  |
| 3359 | 1395 | Study on 5G NR UE Application Layer Data Throughput Performance |  | 583d | 2019-06-17 A | 2021-09-08 A | 100% |  |  | finish no earlier than 2021-09-08 | R5 | 4664h | 4664h | FS_UE_5GNR_App_Data_Perf | 43 | Qualcomm |  | Rel-16 | 84 | 37.901-5 |  |  |
| 3360 | 1396 | Release 16 other Studies | milestone | 0d? | 2016-06-09 A | 2016-06-09 A | 100% |  |  | finish no earlier than 2016-06-09 |  |  |  |  |  |  |  | Rel-16 |  |  |  |  |
| 3361 | 1397 | Study on using Satellite Access in 5G |  | 201d? | 2017-09-08 A | 2018-06-15 A | 100% |  |  | finish no earlier than 2018-06-15 | S1 | 1608h | 1608h | FS_5GSAT | 39 | MICHEL, Cyril | cyril.michel@thalesaleniaspace.com | Rel-16 | 77 | New; 22.822 |  |  |
| 3362 | 1398 | Study on enhancements to IMS for new real time communication services |  | 71d? | 2017-09-08 A | 2017-12-15 A | 100% |  |  | start no earlier than 2017-09-08 | S1 | 568h | 568h | FS_enIMS | 39 | China Mobile, Hui Cai | caihui at chinamobile dot com | Rel-16 | 77 | New; 22.823; 26.998 |  |  |
| 3363 | 1399 | Stopped - Study on protocol enhancement for real time communication |  | 528d? | 2018-06-06 A | 2020-06-12 A | 100% |  |  | finish no earlier than 2020-06-12 | S5 | 4224h | 4224h | FS_PROTIMP | 41 | Olaf Pollakowski, Nokia | olaf.pollakowski@nokia.com | Rel-16 | 80 | New; 28.823 |  | 84 |
| 3364 | 1400 | Study on integration of ONAP and 3GPP configuration management services for 5G networks |  | 202d? | 2018-06-06 A | 2019-03-14 A | 100% |  |  | finish no earlier than 2019-03-14 | S5 | 1616h | 1616h | FS_ONAPCINT | 41 | Li Gang, Ericsson | gang.g.li@ericsson.com | Rel-16 | 80 | New; 28.890 |  |  |
| 3365 | 1401 | Study on integration of ONAP DCAE and 3GPP management architecture |  | 326d? | 2017-12-15 A | 2019-03-15 A | 100% |  |  | finish no earlier than 2019-03-15 | S5 | 2608h | 2608h | FS_ONAPDCAE | 40 | ORANGE (Jean-Michel Cornily | jeanmichel.cornily@orange.com | Rel-16 | 78 | 28.900 |  |  |
| 3366 | 1402 | Study on management aspects of edge computing |  | 202d? | 2018-06-06 A | 2019-03-14 A | 100% |  |  | finish no earlier than 2019-03-14 | S5 | 1616h | 1616h | FS_MAN_EC | 41 | Joey Chou, Intel | joey<dot>chou<at>intel<dot>com | Rel-16 | 80 | New; 28.803 |  |  |
| 3367 | 1403 | Study on self-evaluation towards IMT-2020 submission |  | 653d? | 2016-12-14 A | 2019-06-14 A | 100% |  |  | finish no earlier than 2019-06-15 | ITU-R AH; ITU-RAH | 10448h | 10448h | FS_5G_eval | 38 | Huawei |  | Rel-16 | 75 |  |  |  |
| 3368 | 1404 | Study on management aspects of communication services |  | 202d? | 2018-09-06 A | 2019-06-14 A | 100% |  |  | finish no earlier than 2019-06-14 | S5 | 1616h | 1616h | FS_CSMAN | 41 | Groenendijk, Jan, Ericsson | jan<dot>Groenendijk<at>ericsson<dot>com. | Rel-16 | 81 | New |  |  |
| 3369 | 1405 | Study on Typical Traffic Characteristics of Media Services |  | 378d? | 2018-10-02 A | 2020-03-12 A | 100% |  |  | finish no earlier than 2020-03-12 | S4 | 3024h | 3024h | FS_TyTrac | 41 | Thomas Stockhammer, Qualcomm Incorporated | tsto@qti.qualcomm.com | Rel-16 | 81 | 26.9xx |  |  |
| 3370 | 1406 | Study on non-file-based trace reporting |  | 135d? | 2018-12-06 A | 2019-06-12 A | 100% |  |  | finish no earlier than 2019-06-12 | S5 | 1080h | 1080h | FS_OAM_RTT | 42 | Andrianov, Anatoly, Nokia | anatoly.andrianov@nokia.com | Rel-16 | 82 |  |  |  |
| 3371 | 1407 | Study on ambient noise test methodology for evaluation of acoustic UE performance |  | 266d | 2018-12-06 A | 2019-12-12 A | 100% |  |  | finish no earlier than 2019-12-12 | S4 | 2128h | 2128h | FS_ANTeM | 42 | Jan Reimes, HEAD acoustics GmbH | jan.reimes@head-acoustics.de | Rel-16 | 82 |  |  |  |
| 3372 | 1408 | Stopped - Study on supporting Flexible Local Area Data Network |  | 202d? | 2018-06-06 A | 2019-03-14 A | 100% |  |  | finish no earlier than 2019-03-14 | S2 | 1616h | 1616h | FS_FLADN | 41 | LG Electronics, | hyuns.kim@lge.com | Rel-16 | 80 | New |  | 84 |
| 3373 | 1409 | Stopped - Study on encrypted traffic detection |  | 528d? | 2017-06-05 A | 2019-06-12 A | 100% |  |  | finish no earlier than 2019-06-12 | S2 | 4224h | 4224h | FS_ENTRADE | 39 | Chi Ren, China Unicom | renchi1@chinaunicom.cn | Rel-16 | 76 | new 23.787 |  | 84 |
| 3374 | 1410 | Study on storage and transport of 5GC security parameters for ARPF authentication |  | 387d | 2019-09-19 A | 2021-03-12 A | 100% |  |  | finish no earlier than 2021-03-12 | S3 | 3096h | 3096h | FS_5GC_SEC_ARPF | 43 | Evans, Timothy, Vodafone | tim.evans1@vodafone.com | Rel-16 | 85 | New ; 33.502 |  |  |
| 3375 | 1411 | --- RELEASE 15 --- | milestone | 0d? | 2016-03-15 A | 2016-03-15 A | 100% |  |  | finish no earlier than 2016-03-15 |  |  |  |  |  |  |  | Rel-15 |  |  |  |  |
| 3376 | 1412 | Release 15 Features on 5G | milestone | 0d? | 2016-06-09 A | 2016-06-09 A | 100% |  |  | finish no earlier than 2016-06-09 |  |  |  |  |  |  |  | Rel-15 |  |  |  |  |

Notes:
- 3315: ; 25/3/20: WID:CP-192019->CP-200059
- 3316: 6/8/18: 22.943 added;¦10/9/18: 0%->5¦10/12/18: 5%->25¦14/3/19: 25%->50; 31/5/19: 50%->90; 6/12/19: 90%->100
- 3317: 2/7/20: deleted, put at 100% (was at 0)
- 3318: ; 26/3/20: 0%->90; 26/6/20: 90%->100
- 3319: ; 6/12/19: 0%->65; 26/3/20: 65%->100
- 3320: ; 6/12/19: 0%->65; 26/3/20: 65%->100
- 3321: ; 6/12/19: 0%->65; 26/3/20: 65%->100
- 3322: 31/5/19: 0%->10; 13/9/19: 10%->25; 13/9/19: FCD:05/03/2020->03/20; 26/3/20: 25%->100
- 3323: 25/3/20: 0%->100
- 3324: ; 25/3/20: 0%->100
- 3325: ; 26/3/20: 0%->50; 28/6/20: 50%->100
- 3326: ; 26/3/20: 0%->100
- 3327: ; 26/3/20: 0%->100
- 3328: ; 6/12/19: 0%->5; 26/3/20: 5%->85; 2/7/20: 85%->100
- 3329: 31/5/19: 0%->10; 6/12/19: 10%->100
- 3330: ; 6/12/19: 0%->5; 26/3/20: 5%->85; 2/7/20: 85%->100
- 3331: ; 26/3/20: 0%->33; 26/6/20: 33%->100
- 3332: ; 26/6/20: 0%->100
- 3333: tested: REL-16 TEI16 CR set (R2-2000238, R2-2002121, R2-2000240) of RP-200357 and (R4-2008551, R4-2008540) of RP-201055 ; 8/4/21: 0%->71; 2/7/21: FCD:Thu 17/06/->09/21; 29/9/21: 71%->100
- 3334: tested: REL-16 TEI CRs of SA2/CT1/R2; compare LTE REL-14 WI EIEI-UEConTest "Evolution to and Interworking with eCall in IMS" ; 2/7/21: 0%->5; 22/3/22: 20/6/22: Rapporteur: Qualcomm->Bharadwaj Kumar Cheruvu, Qualcomm; Rap eMail: ->bcheruvu[at]qti.q...;...; 17/3/23: FCD:28/02/2023->03/03/2023; Compl:98%->100%; Stat Rep: RP-223382->RP-230094;
- 3335: 20/6/22: FCD:12/06/2023->09/20; 6/6/23: Compl:90%->98%
- 3339: -
- 3340: -
- 3341: 03/22: stopped at 0% ("deprioritised"in SA2 language)
- 3342: 27/3/18: 33.856 added;¦7/6/18: 0%->50¦10/9/18: 50%->79¦7/12/18: 79%->100
- 3343: 16/3/18: 0%->30¦7/6/18: 30%->55¦10/9/18: 55%->60¦7/12/18: 60%->100
- 3344: 16/3/18: 0%->5¦2/10/18: WID:CP-173160->CP-182052¦2/10/18: FCD:09/18->06/19¦14/3/19: 20%->70; 31/5/19: 70%->90; 14/1/20: 90%->100
- 3345: 7/6/18: 0%->30¦6/8/18: 23.727 added; 03/22: stopped at 30% ("deprioritised"in SA2 language)
- 3346: 14/1/20: 0%->100
- 3347: TR 38.8xx¦see follow-up REL-16 WI NR_CLI_RIM¦16/1/19: 0%->100
- 3348: TR 37.8XX, related to SON, MDT; 26/6/19: 0%->100
- 3349: related REL-15 SI FS_NR_test_methods; 23/1/20: 0%->45; 23/1/20: WID:RP-181402->RP-182305; 28/7/20: WID:RP-182305->RP-201069; 28/7/20: 45%->100
- 3350: TR 38.8XX¦16/1/19: 0%->100
- 3351: TR 38.8XX¦19/6/17: Compl:0%->10%¦19/6/17: WID: RP-170824->RP-171021¦30/6/17: 38.810 added;19/9/17: Compl:10%->15%19/9/17: WID: RP-171021->RP-171828¦8/1/18: Compl:15%->20%27/3/18: Compl:20%->45%27/3/18: CD:Thu 15/ ¦2¦16/1/19: 75%->100
- 3352: TR 38.8XX¦19/6/17: WID: RP-170829->RP-171043¦30/6/17: 32.812 added;¦27/6/18: Compl:0%->40%¦27/6/18: CD:Fri 15/06/18->Sat 15/12/18¦27/6/18: WID: RP-171043->RP-181403;¦16/1/19: 40%->100
- 3353: 7/12/18: 0%->55¦20/3/19: 55%->100
- 3354: 11/9/17: 0%->10¦15/12/17: 10%->70¦15/12/17: FCD:12/17->03/18¦16/3/18: 70%->90¦16/3/18: FCD:03/18->06/18¦7/6/18: FCD:06/18->12/18. 10/9/18: moved from Rel-15 as per SP-180687¦7/12/18: 90%->100
- 3355: 2/10/18: Moved from Rel-17. 17/01/19: acronym corrected from FS_XR5G¦12/3/19: 0%->35; 31/5/19: 35%->45; 13/9/19: 45%->60; 13/9/19: FCD:13/12/2019->03/20; 25/3/20: 60%->100; 25/9/20: 26.998 added;
- 3356: TR. 38.8xx¦26/3/19: WID:RP-182884->RP-190373; 8/10/19: WID:RP-190373->RP-192076; 28/7/20: 0%->100
- 3357: 31/5/19: 0%->10; 13/9/19: 10%->100
- 3358: 26/6/19: WID:RP-190702->RP-191481; 8/10/19: WID:RP-191481->RP-191975; 8/10/19: 38.823 added;; 14/1/20: 0%->100
- 3359: compare: REL-11 SI FS_UE_App_Data_Perf; TR 37.9xx. 07/2019: title changed from "…UE 5G NR…"; 8/10/19: 37.901-5 added;; 14/1/20: WID:RP-191590->RP-192712; 8/10/20: 0%->87; 8/10/20: FCD:13/03/2020->12/20; 6/1/21: WID:RP-192712->RP-202849; 7/4/21: WID:RP-
- 3360: -
- 3361: 15/12/17: 22.822 added;¦15/12/17: 0%->30¦15/12/17: FCD:12/17->06/18¦16/3/18: 30%->70¦7/6/18: 70%->100
- 3362: 11/9/17: 0%->20¦15/12/17: 22.823 added;¦15/12/17: 20%->75¦16/3/18: 75%->100; 25/9/20: 26.998 added;
- 3363: 6/8/18: 28.823 added;; 26/3/20: FCD:14/03/2019->06/20; 25/9/20: Stopped, so 0%->100
- 3364: 10/9/18: 0%->5¦7/12/18: 5%->60¦14/12/18: WID:SP-180388->SP-181075¦14/3/19: 60%->100; 26/6/19: 28.890 added;
- 3365: 16/3/18: 0%->10¦27/3/18: 28.900 added;¦7/6/18: 10%->20¦7/6/18: FCD:09/18->03/19¦15/6/18: WID:SP-170948->SP-180389¦10/9/18: 20%->35¦7/12/18: 35%->80¦14/12/18: WID:SP-180389->SP-181074¦14/3/19: 80%->100
- 3366: 6/8/18: 28.803 added;¦10/9/18: 0%->10¦7/12/18: 10%->20¦14/3/19: 20%->50; 31/5/19: 50%->65; 13/9/19: 65%->100
- 3367: TR 38.9XX¦19/6/17: CD:Sat 15/09/18->Fri 15/06/18¦19/6/17: WID: RP-170832->RP-171451¦19/6/17: Release: Rel-16->Rel-15¦8/1/18: Compl:0%->15%27/3/18: Compl:15%->25%¦27/6/18: Compl:25%->35%¦27/6/18: CD:Fri 15/0; 26/6/19: 35%->100
- 3368: 7/12/18: 0%->40¦14/3/19: 40%->70; 31/5/19: 70%->75; 13/9/19: 75%->100
- 3369: 2/10/18: Moved from Rel-17¦12/3/19: 0%->45; 31/5/19: 45%->50; 13/9/19: 50%->60; 13/9/19: FCD:13/12/2019->03/20; 25/3/20: 60%->100
- 3370: 13/9/19: 0%->100
- 3371: 12/3/19: 0%->10; 31/5/19: 0%->10; 31/5/19: 0%->10; 13/9/19: 10%->70; 25/3/20: 70%->100
- 3372: 10/9/18: FCD:12/18->03/19¦6/6/19: stopped at 0% as per SP-190395
- 3373: ¦15/12/17: Changed Rel-15->Rel-16¦16/3/18: WID:SP-170381->SP-170934¦16/3/18: 0%->20¦7/6/18: 20%->70¦14/12/18: FCD:09/18->06/19. Name changed; 22/3/22: stopped at 70% ("deprioritised"in SA2 language)
- 3374: ; 8/10/19: 33.502 added;; 6/12/19: 0%->30; 6/12/19: FCD:12/12/2019->03/20; 26/6/20: FCD:12/03/2020->09/20; 26/6/20: 30%->60; 12/9/20: 60%->75; 12/9/20: FCD:15/09/2020->12/20; 5/12/20: 75%->90; 5/12/20: FCD:15/12/2020->03/20; 19/3/21: 90%->98; 11/6/21:
- 3375: -
- 3376: -

| ID | WBS | Task | Duration | Start | Finish | Complete | Remaining | Total slack | Constraint | Resources | Work | Actual work | Acronym | PCG approved | WI rapporteur name | WI rapporteur e-mail | Release | TSG approved |
| --- | --- | --- | --- | --- | --- | --- | --- | --- | --- | --- | --- | --- | --- | --- | --- | --- | --- | --- |
| 3377 | 1413 | **5G System - Phase 1** | 1140.12d? | 2016-06-09 A | 2019-06-14 | 97% | 30.57d? | 40285.4d |  |  | 55632h | 52936h | 5GS_Ph1 | 38 | China Mobile, Tao Sun | suntao@chinamobile.com | Rel-15 | 74 |
| 3378 | 1413.1 | Study on Charging Aspects of 5G System Architecture Phase 1 | 206d? | 2017-03-03 A | 2017-12-15 A | 100% |  |  | finish no earlier than 2017-12-15 | S5 | 1648h | 1648h | FS_5GS_Ph1_CH | 38 | Chen, Shan, Huawei | chenshan@huawei.com | Rel-15 | 75 |
| 3379 | 1413.2 | (Stage 1 of 5G) New Services and Markets Technology Enablers | 201d? | 2016-06-09 A | 2017-03-15 A | 100% |  |  | finish no earlier than 2017-03-15 | S1 | 1608h | 1608h | SMARTER | 37 | Li, Alice | alice.li@vodafone.com | Rel-15 | 72 |
| 3380 | 1413.3 | Stage 2 of 5G System - Phase 1 | 271d? | 2016-12-01 A | 2017-12-14 A | 100% |  |  | finish no earlier than 2017-12-14 | S2 | 2168h | 2168h | 5GS_Ph1 | 38 | China Mobile, Tao Sun | suntao@chinamobile.com | Rel-15 | 74 |
| 3381 | 1413.4 | Security aspects of 5G System - Phase 1 | 337d? | 2017-03-02 A | 2018-06-15 A | 100% |  |  | finish no earlier than 2018-06-15 | S3 | 2696h | 2696h | 5GS_Ph1-SEC | 38 | NTT DOCOMO, Alf Zugenmaier | alf.zugenmaier@hm.edu | Rel-15 | 75 |
| 3382 | 1413.5 | Security aspects of 5G System - Phase 1 IETF | 337d? | 2017-03-02 A | 2018-01-21 | 50% | 168.5d? | 40813.1d | finish no earlier than 2018-06-15 | S3-IETF | 2696h |  | 5GS_Ph1-SEC | 44 |  |  | Rel-15 | 87 |
| 3383 | 1413.6 | **CT aspects of 5G System - Phase 1** | 485.75d? | 2017-03-03 A | 2018-06-14 A | 100% |  |  |  | ct | 30600h | 30600h | 5GS_Ph1-CT | 38 | Song Yue (China Mobile) | songyue at chinamobile.com | Rel-15 | 75 |
| 3384 | 1413.6.1 | **Studies on CT1 aspects of 5G System - Phase 1** | 297.25d? | 2017-03-03 A | 2017-12-14 A | 100% |  |  |  |  | 11480h | 11480h | 5GS_Ph1-CT | 38 | Herrero Veron, Christian (Huawei) | Christian.Herrero at huawei.com | Rel-15 | 75 |
| 3385 | 1413.6.1.1 | Study on 5G Network selection | 205d? | 2017-03-03 A | 2017-12-14 A | 100% |  |  | finish no earlier than 2017-12-14 | C1 | 1640h | 1640h | 5GS_Ph1-CT | 39 | Herrero Veron, Christian (Huawei) | Christian.Herrero at huawei.com | Rel-15 | 77 |
| 3386 | 1413.6.1.2 | Study on 5G Mobility management | 205d? | 2017-03-03 A | 2017-12-14 A | 100% |  |  | finish no earlier than 2017-12-14 | C1 | 1640h | 1640h | 5GS_Ph1-CT | 39 | Herrero Veron, Christian (Huawei) | Christian.Herrero at huawei.com | Rel-15 | 77 |
| 3387 | 1413.6.1.3 | Study on 5G Session management | 205d? | 2017-03-03 A | 2017-12-14 A | 100% |  |  | finish no earlier than 2017-12-14 | C1 | 1640h | 1640h | 5GS_Ph1-CT | 39 | Herrero Veron, Christian (Huawei) | Christian.Herrero at huawei.com | Rel-15 | 77 |
| 3388 | 1413.6.1.4 | Study on 5G Non-3GPP access networks | 205d? | 2017-03-03 A | 2017-12-14 A | 100% |  |  | finish no earlier than 2017-12-14 | C1 | 1640h | 1640h | 5GS_Ph1-CT | 39 | Herrero Veron, Christian (Huawei) | Christian.Herrero at huawei.com | Rel-15 | 77 |
| 3389 | 1413.6.1.5 | Study on 5G Interworking with EPC | 205d? | 2017-03-03 A | 2017-12-14 A | 100% |  |  | finish no earlier than 2017-12-14 | C1 | 1640h | 1640h | 5GS_Ph1-CT | 39 | Herrero Veron, Christian (Huawei) | Christian.Herrero at huawei.com | Rel-15 | 77 |
| 3390 | 1413.6.1.6 | Study on 5G System core network impact on services, network functions and capabilities | 205d? | 2017-03-03 A | 2017-12-14 A | 100% |  |  | finish no earlier than 2017-12-14 | C1 | 1640h | 1640h | 5GS_Ph1-CT | 39 | Herrero Veron, Christian (Huawei) | Christian.Herrero at huawei.com | Rel-15 | 77 |
| 3391 | 1413.6.1.7 | Study on 5G Network slicing | 205d? | 2017-03-03 A | 2017-12-14 A | 100% |  |  | finish no earlier than 2017-12-14 | C1 | 1640h | 1640h | 5GS_Ph1-CT | 39 | Herrero Veron, Christian (Huawei) | Christian.Herrero at huawei.com | Rel-15 | 77 |
| 3392 | 1413.6.2 | **CT1 aspects of 5G System - Phase 1 (normative work)** | 188.5d? | 2017-12-15 A | 2018-06-14 A | 100% |  |  |  | C1 | 8320h | 8320h | 5GS_Ph1-CT | 38 | Herrero Veron, Christian (Huawei) | Christian.Herrero at huawei.com | Rel-15 | 75 |
| 3393 | 1413.6.2.1 | 5G Network selection | 130d? | 2017-12-15 A | 2018-06-14 A | 100% |  |  | finish no earlier than 2018-06-14 | C1 | 1040h | 1040h | 5GS_Ph1-CT | 39 | Herrero Veron, Christian (Huawei) | Christian.Herrero at huawei.com | Rel-15 | 77 |
| 3394 | 1413.6.2.2 | 5G Mobility management | 130d? | 2017-12-15 A | 2018-06-14 A | 100% |  |  | start no earlier than 2017-12-15 | C1 | 1040h | 1040h | 5GS_Ph1-CT | 39 | Herrero Veron, Christian (Huawei) | Christian.Herrero at huawei.com | Rel-15 | 77 |
| 3395 | 1413.6.2.3 | 5G Session management | 130d? | 2017-12-15 A | 2018-06-14 A | 100% |  |  | start no earlier than 2017-12-15 | C1 | 1040h | 1040h | 5GS_Ph1-CT | 39 | Herrero Veron, Christian (Huawei) | Christian.Herrero at huawei.com | Rel-15 | 77 |
| 3396 | 1413.6.2.4 | 5G Non-3GPP access networks | 130d? | 2017-12-15 A | 2018-06-14 A | 100% |  |  | start no earlier than 2017-12-15 | C1 | 1040h | 1040h | 5GS_Ph1-CT | 39 | Herrero Veron, Christian (Huawei) | Christian.Herrero at huawei.com | Rel-15 | 77 |
| 3397 | 1413.6.2.5 | 5G Interworking with EPC | 130d? | 2017-12-15 A | 2018-06-14 A | 100% |  |  | start no earlier than 2017-12-15 | C1 | 1040h | 1040h | 5GS_Ph1-CT | 39 | Herrero Veron, Christian (Huawei) | Christian.Herrero at huawei.com | Rel-15 | 77 |
| 3398 | 1413.6.2.6 | 5G System core network impact on services, network functions and capabilities | 130d? | 2017-12-15 A | 2018-06-14 A | 100% |  |  | start no earlier than 2017-12-15 | C1 | 1040h | 1040h | 5GS_Ph1-CT | 39 | Herrero Veron, Christian (Huawei) | Christian.Herrero at huawei.com | Rel-15 | 77 |
| 3399 | 1413.6.2.7 | 5G Network slicing | 130d? | 2017-12-15 A | 2018-06-14 A | 100% |  |  | start no earlier than 2017-12-15 | C1 | 1040h | 1040h | 5GS_Ph1-CT | 39 | Herrero Veron, Christian (Huawei) | Christian.Herrero at huawei.com | Rel-15 | 77 |
| 3400 | 1413.6.3 | Study on CT3 aspects of 5G System - Phase 1 | 205d? | 2017-03-03 A | 2017-12-14 A | 100% |  |  | finish no earlier than 2017-12-14 | C3 | 1640h | 1640h | 5GS_Ph1-CT | 38 | Fernandez, Susana (Ericsson) | Susana.Fernandez at ericsson.com | Rel-15 | 75 |
| 3401 | 1413.6.4 | CT3 aspects of 5G System - Phase 1 | 130d? | 2017-12-15 A | 2018-06-14 A | 100% |  |  | start no earlier than 2017-12-15 | C3 | 1040h | 1040h | 5GS_Ph1-CT | 38 | Fernandez, Susana (Ericsson) | Susana.Fernandez at ericsson.com | Rel-15 | 75 |
| 3402 | 1413.6.5 | CT4 aspects of 5G System - Phase 1 | 205d? | 2017-03-03 A | 2017-12-14 A | 100% |  |  | finish no earlier than 2017-12-14 | C4 | 1640h | 1640h | 5GS_Ph1-CT | 38 | Landais, Bruno (Nokia) | Bruno.Landais at nokia.com | Rel-15 | 75 |
| 3403 | 1413.6.6 | (IETF) Improved Extensible Authentication Protocol Method for 3GPP Mobile Network Authentication and Key Agreement (EAP-AKA') (draft-ietf-emu-rfc5448bis) | 205d? | 2017-03-03 A | 2017-12-14 A | 100% |  |  | finish no earlier than 2017-12-14 | C4-IETF | 1640h | 1640h | 5GS_Ph1-CT | 44 |  |  | Rel-15 | 87 |
| 3404 | 1413.6.7 | Study on CT6 aspects of 5G System - Phase 1 | 205d? | 2017-03-03 A | 2017-12-14 A | 100% |  |  | finish no earlier than 2017-12-14 | C6 | 1640h | 1640h | 5GS_Ph1-CT | 38 | Amandeep Virk from Qualcomm |  | Rel-15 | 75 |
| 3405 | 1413.6.8 | CT6 aspects of 5G System - Phase 1 | 65d? | 2018-03-16 A | 2018-06-14 A | 100% |  |  | finish no earlier than 2018-06-14 | C6 | 520h | 520h | 5GS_Ph1-CT | 38 | Landais, Bruno (Nokia) | Bruno.Landais at nokia.com | Rel-15 | 75 |
| 3406 | 1413.7 | UE Conformance Test Aspects – 5G System Non-3GPP Access | 196d? | 2018-06-15 A | 2019-03-15 A | 100% |  |  | finish no earlier than 2019-03-15 | R5 | 1568h | 1568h | 5GS_Ph1-CT_n3GPPA-UEConTest | 41 | Motorola |  | Rel-15 | 80 |

Notes:
- 3377: 15/12/17: 23.503 added;
- 3378: 7/6/17: 0%->15¦11/9/17: 15%->60¦11/9/17: WID:SP-170128->SP-170659¦15/12/17: 60%->100¦21/12/17: WID:SP-170659->SP-170953
- 3379: Resulting from FS_SMARTER¦19/9/16: 0%->55¦6/10/16: 22.261 added¦1/12/16: FCD:09/16->03/20¦1/12/16: 55%->75¦2/3/17: 75%->90¦7/6/17: 90%->100 / Impacted TSs and TRs: 22.261
- 3380: 3/3/17: 0%->30¦7/6/17: 30%->55¦11/9/17: 55%->75¦21/12/17: 75%->95¦11/6/18: 95%->100 / Impacted TSs and TRs: 23.401; 23.167; 23.271; 23.002; 23.228; 23.401; 23.167; 23.271; 23.502; 23.501; 23.503
- 3381: 7/6/17: 0%->10¦11/9/17: 10%->30¦15/12/17: 30%->65¦21/12/17: WID:SP-170234->SP-170881¦16/3/18: 65%->85¦16/3/18: FCD:03/18->06/18¦7/6/18: 85%->95¦10/9/18: WID:SP-170881->100¦10/9/18: 95%->100¦2/10/18: WID:SP-170881->SP-180693 / Impacted TSs and TRs: 33.501; 33.401; 33.210; 33.310; 33.220
- 3383: 6/17: WID:CP-170204->CP-171105¦9/17: WID:CP-171105->CP-172034. Rapp changed, impacted TS clarified¦12/17: added: 24.501 ¦24.502 ¦29.520 added¦29.514¦29.513 ¦29.520a¦29.514a¦12/17: 29.519 added¦29.516 added;¦: 2.. 3/18: 29.554 added;29.59¦6 / Impacted TSs and TRs: 24.501; 24.502; 29.520; 29.514; 29.513; ; 29.520a; 29.514a; 29.519; 29.516; 29.512; 29.508; 29.507; 29.551; 29.554; 29.522; 24.568; 29.521; 29.525; 29.524; 29.523
- 3384: 18/12/17: WID:CP-172034->CP-173161 / Impacted TSs and TRs: 23.122; 23.040; 23.041; 24.007; 24.301; 24.008; 24.302; 24.011; 24.312; 24.305; 24.368; 27.007
- 3385: Task introduced as per CT1's chair e-mail¦11/9/17: 10%->55¦15/12/17: 55%->80¦16/3/18: 80%->100
- 3386: Task introduced as per CT1's chair e-mail¦11/9/17: 40%->70¦15/12/17: 70%->100
- 3387: Task introduced as per CT1's chair e-mail¦11/9/17: 35%->75¦15/12/17: 75%->100
- 3388: Task introduced as per CT1's chair e-mail¦11/9/17: 15%->55¦15/12/17: 55%->100
- 3389: Task introduced as per CT1's chair e-mail¦11/9/17: 15%->45¦15/12/17: 45%->100
- 3390: Task introduced as per CT1's chair e-mail¦11/9/17: 20%->65¦15/12/17: 65%->85¦16/3/18: 85%->100
- 3391: Task introduced as per CT1's chair e-mail¦11/9/17: 10%->45¦15/12/17: 45%->100
- 3392: Impacted TSs and TRs: 23.122; 23.040; 23.041; 24.007; 24.301; 24.008; 24.302; 24.011; 24.312; 24.305; 24.368; 27.007
- 3393: 16/3/18: 0%->60¦7/6/18: 60%->100
- 3394: 15/12/17: 0%->25¦16/3/18: 25%->70¦7/6/18: 70%->95¦10/9/18: 95%->100
- 3395: 15/12/17: 0%->35¦16/3/18: 35%->85¦7/6/18: 85%->100
- 3396: 15/12/17: 0%->20¦16/3/18: 20%->60¦7/6/18: 60%->95¦10/9/18: 95%->100
- 3397: 15/12/17: 0%->20¦16/3/18: 20%->60¦7/6/18: 60%->100
- 3398: 15/12/17: 0%->10¦16/3/18: 10%->70¦7/6/18: 70%->90¦10/9/18: 90%->100
- 3399: 15/12/17: 0%->10¦16/3/18: 10%->60¦7/6/18: 60%->100
- 3400: 5/6/17: 0%->20¦15/12/17: 20%->95¦22/3/18: 95%->100 / Impacted TSs and TRs: 29.213; 29.214; 29.219; 29.122
- 3401: 5/6/17: 0%->20¦15/12/17: 20%->95¦7/6/18: 35%->70¦7/6/18: 70%->100 / Impacted TSs and TRs: 29.213; 29.214; 29.219; 29.122
- 3402: 5/6/17: 0%->5¦11/9/17: 5%->25¦15/12/17: 25%->45¦16/3/18: 45%->50¦7/6/18: 50%->95¦10/9/18: 95%->99¦10/12/18: 99%->100 / Impacted TSs and TRs: 23.003; 23.008; 23.380; 29.281; 29.272; 29.274; 29.303
- 3403: 20/6/22: Compl:80%->100%
- 3404: 5/6/17: 0%->10¦11/9/17: 10%->60¦15/12/17: 60%->85¦22/3/18: 85%->95¦7/6/18: 95%->100
- 3405: 5/6/17: 0%->5¦11/9/17: 5%->25¦15/12/17: 25%->45¦16/3/18: 45%->50¦16/3/18: 0%->20¦7/6/18: 20%->90¦10/9/18: 90%->95. 10/9/18: 95->100 as per CT81 discussions¦10/12/18: 100%->95¦11/12/18: 95%->100 / Impacted TSs and TRs: 23.003; 23.008; 23.380; 29.281; 29.272; 29.274; 29.303
- 3406: tested: non-3GPP Access part of REL-15 WI 5GS_Ph1-CT (note: 3GPP Access part of 5GS_Ph1-CT is already covered in REL-15 WI 5GS_NR_LTE-UEConTest);; 26/3/20: 0%->100

| ID | WBS | Task | Type | Duration | Start | Finish | Complete | Remaining | Total slack | Constraint | Resources | Work | Actual work | Acronym | PCG approved | WI rapporteur name | WI rapporteur e-mail | Release | TSG approved | Status Report |
| --- | --- | --- | --- | --- | --- | --- | --- | --- | --- | --- | --- | --- | --- | --- | --- | --- | --- | --- | --- | --- |
| 3407 | 1413.8 | **IMS impact due to 5GS IP-CAN** |  | 295d? | 2017-09-04 A | 2018-06-15 A | 100% |  |  |  | ct | 6560h | 6560h | 5GS_Ph1-IMSo5G | 39 | Song Yue (China Mobile) | songyue (at) chinamobile (dot) com | Rel-15 | 76 |  |
| 3408 | 1413.8.1 | CT1 aspects of IMSo5G |  | 205d? | 2017-09-04 A | 2018-06-15 A | 100% |  |  | finish no earlier than 2018-06-15 | C1 | 1640h | 1640h | 5GS_Ph1-IMSo5G | 39 | Song Yue, China Mobile | songyue@chinamobile.com | Rel-15 | 77 |  |
| 3409 | 1413.8.2 | CT3 aspects of IMSo5G |  | 205d? | 2017-09-04 A | 2018-06-15 A | 100% |  |  | finish no earlier than 2018-06-15 | C3 | 1640h | 1640h | 5GS_Ph1-IMSo5G | 39 | Herrero Veron, Christian (Huawei) | Christian.Herrero at huawei.com | Rel-15 | 77 |  |
| 3410 | 1413.8.3 | CT4 aspects of IMSo5G |  | 205d? | 2017-09-04 A | 2018-06-15 A | 100% |  |  | finish no earlier than 2018-06-15 | C4 | 1640h | 1640h | 5GS_Ph1-IMSo5G | 39 | Herrero Veron, Christian (Huawei) | Christian.Herrero at huawei.com | Rel-15 | 77 |  |
| 3411 | 1413.9 | Service Based Interface for 5G Charging |  | 196d? | 2017-12-15 A | 2018-09-14 A | 100% |  |  | finish no earlier than 2018-09-14 | S5 | 1568h | 1568h | 5GS_Ph1-SBI_CH | 40 | Chen, Shan, Huawei | chenshan@huawei.com | Rel-15 | 78 |  |
| 3412 | 1413.10 | Data Charging in 5G System Architecture Phase 1 |  | 196d? | 2017-12-15 A | 2018-09-14 A | 100% |  |  | finish no earlier than 2018-09-14 | S5 | 1568h | 1568h | 5GS_Ph1-DCH | 40 | Gardella, Maryse, Nokia | maryse.gardella@nokia.com | Rel-15 | 78 |  |
| 3413 | 1413.11 | SMS Charging in 5G System Architecture Phase 1 |  | 72d? | 2018-09-06 A | 2018-12-14 A | 100% |  |  | finish no earlier than 2018-12-14 | S5 | 576h | 576h | 5GS_Ph1-SMSCH | 41 | Gardella, Maryse, Nokia | maryse.gardella@nokia.com | Rel-15 | 81 |  |
| 3414 | 1413.12 | Charging for IMS over 5G System Architecture Phase 1 |  | 30d? | 2018-05-07 A | 2018-06-15 A | 100% |  |  | start no earlier than 2018-05-07 | S5 | 240h | 240h | 5GS_Ph1_IMSCH | 41 | Gardella, Maryse, Nokia | maryse.gardella@nokia.com | Rel-15 | 80 |  |
| 3415 | 1413.13 | UE Conformance Test Aspects - CT6 aspects of 5G System |  | 267d? | 2018-06-07 A | 2019-06-14 A | 100% |  |  | finish no earlier than 2019-06-14 | C6 | 2136h | 2136h | 5GS_Ph1_UEConTest | 41 | Azem, Dania (COMPRION GmbH) | DAzem@comprion.com | Rel-15 | 80 |  |
| 3416 | 1414 | **EPC enhancements to support 5G New Radio via Dual Connectivity** |  | 392.5d? | 2017-03-02 A | 2018-03-15 A | 100% |  |  |  |  | 8336h | 8336h | EDCE5 | 38 | Chris Pudney, Vodafone Group | Chris Pudney, Vodafone Group | Rel-15 | 75 |  |
| 3417 | 1414.1 | SA2 aspects of EDCE5 |  | 141d? | 2017-03-02 A | 2017-09-14 A | 100% |  |  | finish no earlier than 2017-09-14 | S2 | 1128h | 1128h | EDCE5 | 38 | Chris Pudney, Vodafone Group |  | Rel-15 | 75 |  |
| 3418 | 1414.2 | SA3 aspects of EDCE5 |  | 141d? | 2017-03-02 A | 2017-09-14 A | 100% |  |  | finish no earlier than 2017-09-14 | S3 | 1128h | 1128h | EDCE5 | 38 | Adrian Escott, Qualcomm Incorporated |  | Rel-15 | 75 |  |
| 3419 | 1414.3 | **CT aspects of EDCE5** |  | 199.75d? | 2017-06-05 A | 2017-12-14 A | 100% |  |  |  | ct | 4448h | 4448h | EDCE5-CT | 39 | Jesús de Gregorio, Ericsson | jesus.de.gregorio@ericsson.com | Rel-15 | 76 |  |
| 3420 | 1414.3.1 | CT1 aspects of EDCE5 |  | 139d? | 2017-06-05 A | 2017-12-14 A | 100% |  |  | finish no earlier than 2017-12-14 | C1 | 1112h | 1112h | EDCE5-CT | 39 | Jesús de Gregorio, Ericsson | jesus.de.gregorio@ericsson.com | Rel-15 | 76 |  |
| 3421 | 1414.3.2 | CT3 aspects of EDCE5 |  | 139d? | 2017-06-05 A | 2017-12-14 A | 100% |  |  | finish no earlier than 2017-12-14 | C3 | 1112h | 1112h | EDCE5-CT | 39 | Jesús de Gregorio, Ericsson | jesus.de.gregorio@ericsson.com | Rel-15 | 76 |  |
| 3422 | 1414.3.3 | CT4 aspects of EDCE5 |  | 139d? | 2017-06-05 A | 2017-12-14 A | 100% |  |  | finish no earlier than 2017-12-14 | C4 | 1112h | 1112h | EDCE5-CT | 39 | Jesús de Gregorio, Ericsson | jesus.de.gregorio@ericsson.com | Rel-15 | 76 |  |
| 3423 | 1414.4 | Charging aspects of EDCE5: PS Charging enhancements to support 5G New Radio via Dual Connectivity |  | 204d? | 2017-06-05 A | 2018-03-15 A | 100% |  |  | finish no earlier than 2018-03-15 | S5 | 1632h | 1632h | EDCE5-CH | 39 | Törnkvist, Robert, Ericsson | robert.tornkvist(at)ericsson.com | Rel-15 | 76 |  |
| 3424 | 1415 | **New Radio Access Technology** |  | 851.25d? | 2017-03-15 A | 2019-06-14 A | 100% |  |  |  | R1 | 13072h | 13072h | NR_newRAT | 38 | NTT DOCOMO |  | Rel-15 | 75 |  |
| 3425 | 1415.1 | Core part: New Radio Access Technology |  | 458d? | 2017-03-15 A | 2018-12-14 A | 100% |  |  | finish no earlier than 2018-12-15 | R1 | 3664h | 3664h | NR_newRAT-Core | 38 | NTT DOCOMO |  | Rel-15 | 75 | RP-181466 |
| 3426 | 1415.2 | Perf. part: New Radio Access Technology |  | 588d? | 2017-03-15 A | 2019-06-14 A | 100% |  |  | finish no earlier than 2019-06-15 | R4 | 4704h | 4704h | NR_newRAT-Perf | 38 | NTT DOCOMO |  | Rel-15 | 75 |  |
| 3427 | 1416 | **LTE connectivity to 5G-CN** |  | 669d? | 2017-03-15 A | 2018-12-20 A | 100% |  |  |  | R2 | 9432h | 9432h | LTE_5GCN_connect | 38 | Huawei |  | Rel-15 | 75 |  |
| 3428 | 1416.1 | Core part: LTE connectivity to 5G-CN |  | 393d? | 2017-03-15 A | 2018-09-14 A | 100% |  |  | finish no earlier than 2018-09-15 | R2 | 3144h | 3144h | LTE_5GCN_connect-Core | 38 | Huawei |  | Rel-15 | 75 | RP-180862 |
| 3429 | 1416.2 | Perf. part: LTE connectivity to 5G-CN |  | 393d? | 2017-06-20 A | 2018-12-20 A | 100% |  |  | finish no earlier than 2018-12-20 | R4 | 3144h | 3144h | LTE_5GCN_connect-Perf | 38 | Huawei |  | Rel-15 | 75 | RP-180862 |
| 3430 | 1417 | UE Conformance Test Aspects - 5G system with NR and LTE |  | 1175d? | 2017-06-15 A | 2020-08-18 | 87% | 152.75d? | 39839.4d | finish no earlier than 2021-12-15 | R5 | 9400h | 470.4h | 5GS_NR_LTE-UEConTest | 39 | Ericsson |  | Rel-15 | 76 |  |
| 3431 | 1418 | Release 15 Features on V2X | milestone | 0d? | 2016-06-09 A | 2016-06-09 A | 100% |  |  | finish no earlier than 2016-06-09 |  |  |  |  |  |  |  | Rel-15 |  |  |

Notes:
- 3407: 8/9/17: WID:CP-171103->CP-172033¦FCD: 12/17->06/18¦19/3/18: WID:CP-172033->CP-180094
- 3408: 14/9/17: 0%->10¦15/12/17: 10%->65¦rapporteur changed¦20/3/18: 65%->75¦7/6/18: 75%->95¦10/9/18: 95%->100 / Impacted TSs and TRs: 24.229; 24.167
- 3409: 7/6/18: 0%->80¦10/9/18: 80%->100 / Impacted TSs and TRs: 29.213; 29.214
- 3410: 7/6/18: 0%->100 / Impacted TSs and TRs: 23.008; 29.228; 29.229; 29.328; 29.329; 23.003
- 3411: 16/3/18: 0%->15¦7/6/18: 15%->55¦7/6/18: FCD:06/18->09/18¦10/9/18: 55%->100 / Impacted TSs and TRs: 32.240; 32.298
- 3412: 16/3/18: 0%->10¦7/6/18: 10%->60¦7/6/18: FCD:06/18->09/18¦10/9/18: 60%->100 / Impacted TSs and TRs: 32.240
- 3413: 7/12/18: 0%->100 / Impacted TSs and TRs: 32.240; 32.274; 32.290; 32.291; 32.299; 32.298
- 3414: 7/6/18: 0%->100 / Impacted TSs and TRs: 32.240; 32.260; 32.299; 32.298
- 3415: 10/12/18: 0%->5¦10/12/18: 5%->¦10/12/18: WID:CP-181187->CP-183242; 31/5/19: 5%->10; 6/12/19: 10%->60; 26/3/20: 60%->85; 26/6/20: 85%->95; 13/9/20: 95%->98; 13/12/21: 98%->100 / Impacted TSs and TRs: 31.121 ; 31.124
- 3416: 9/6/17: WID:SP-170058->SP-170583
- 3417: 7/6/17: 0%->55¦11/9/17: 55%->90¦15/12/17: 90%->100
- 3418: 7/6/17: 0%->60¦11/9/17: 60%->70¦15/12/17: 70%->100
- 3419: 18/12/17: WID:CP-171045->CP-173038
- 3420: 14/9/17: 0%->65¦15/12/17: 65%->100 / Impacted TSs and TRs: 24.301; 27.007
- 3421: Impacted TSs and TRs: 29.212; 29.213; 29.214; 29.215; 29.201
- 3422: 11/9/17: 0%->50¦15/12/17: 50%->100 / Impacted TSs and TRs: 23.008; 29.272; 29.230; 29.002; 29.305; 29.274
- 3423: 15/12/17: 0%->20¦16/3/18: 20%->100 / Impacted TSs and TRs: 32.251; 32.298; 32.299
- 3424: follow-up WI of REL-14 SI FS_NR_newRAT completed at RAN #75¦30/6/17: 38.425 added;¦14/9/17: WID:RP-170855->RP-171485¦15/12/17: added: 38.305¦38.113¦37.863-04-01¦37.863-03-01¦37.863-02-01¦38.820-04-01¦38.820-03-01¦38.820-02-01¦15/12/17: 37.32 / Impacted TSs and TRs: 38.425; 38.424; 38.423; 38.422; 38.421; 38.420; 38.305; 38.113; 37.863-04-01; 37.863-03-01; 37.863-02-01; 38.820-04-01; 38.820-03-01; 38.820-02-01; 37.324; 37.872; 37.864-11-22; 37.866-00-02
- 3425: follow-up WI of REL-14 SI FS_NR_newRAT¦19/6/17: Compl:0%->22%19/6/17: WID: RP-170855->RP-171485¦30/6/17 & 12/6/17: impacted specs added19/9/17: Compl:22%->50%19/9/17: WID: RP-171485->RP-172115¦15/12/17: added: 38.818¦37.865-01-01¦37.834-01-01¦37 .; 2 / Impacted TSs and TRs: 37.340;37.834-01-01;37.863-05-01;37.864-41-21;37.865-01-01;38.101;38.104;38.12?;38.201/2;38.211/2;38.213to215;38.300;38.304to307;38.321to323;38.331;38.401;38.410to414;38.455;38.470to475;38.815;38.817-01-02;38.818; 38.113; 29.413; 37.864-11-22; 38.415; 38.
- 3426: follow-up WI of REL-14 SI FS_NR_newRAT completed at RAN #75¦19/6/17: WID: RP-170855->RP-171485¦12/7/17: 38.133 added;¦12/7/17: 38.141 added;¦19/9/17: WID: RP-171485->RP-172115¦15/12/17: 38.101-4 added¦8/1/18: WID: RP-172115->RP-172834¦27/3/18: W ; 8 / Impacted TSs and TRs: 38.133; 38.141; 38.101-4; 38.171
- 3427: no Perf. part¦14/9/17: WID:RP-170840->RP-171432
- 3428: no Perf. Part19/6/17: Compl:0%->5%19/6/17: WID: RP-170840->RP-17143219/9/17: Compl:5%->10%¦8/1/18: Compl:10%->20%¦27/3/18: Compl:20%->30%¦ ¦27/6/18: Compl:30%->99%¦7/3/19: 99%->100
- 3429: 16/1/19: 0%->100
- 3430: ¦19/9/17: Compl:0%->2%¦15/12/17: impacted specs add¦15/12/17: 38.508-2 added;¦ ;; 8/10/19: WID:RP-181206->RP-192123; 8/10/19: 34.229-5 added;; 24/4/20: FCD:14/12/2018->12/20; 24/4/20: 15%->69; 8/10/20: 69%->79; 8/10/20: FCD:15/12/2020->12/20; 7/4/21: W / Impacted TSs and TRs: 38.507-1; 38.533; 38.522; 38.521-1-2-3; 38.508; 38.509; 38.903; 38.905; 38.523-1-2-3; ; 38.508-2; 34.229-5
- 3431: -

| ID | WBS | Task | Type | Duration | Start | Finish | Complete | Remaining | Total slack | Constraint | Resources | Work | Actual work | Acronym | PCG approved | WI rapporteur name | WI rapporteur e-mail | Release | TSG approved | Impacted TSs and TRs | Status Report |
| --- | --- | --- | --- | --- | --- | --- | --- | --- | --- | --- | --- | --- | --- | --- | --- | --- | --- | --- | --- | --- | --- |
| 3432 | 1419 | **Enhancement of 3GPP support for V2X scenarios** |  | 297.12d? | 2016-06-09 A | 2017-03-22 A | 100% |  |  |  |  | 1520h | 1520h | eV2X | 38 | Chun, SungDuck, LG Electronics | sungduck.chun@lge.com | Rel-15 | 75 |  |  |
| 3433 | 1419.1 | Study on Enhancement of 3GPP support for V2X services |  | 137d? | 2016-06-09 A | 2016-12-15 A | 100% |  |  | finish no earlier than 2016-12-15 | S1 | 1096h | 1096h | FS_eV2X | 37 | LG Electronics, SungDuck Chun | sungduck.chun@lge.com | Rel-15 | 72 | 22.886 |  |
| 3434 | 1419.2 | Stage 1 of Enhancement of 3GPP support for V2X scenarios |  | 53d? | 2017-01-09 A | 2017-03-22 A | 100% |  |  | finish no earlier than 2017-03-22 | S1 | 424h | 424h | eV2X | 38 | Chun, SungDuck, LG Electronics | sungduck.chun@lge.com | Rel-15 | 75 | 22.186 |  |
| 3435 | 1420 | **V2X new band combinations for LTE** |  | 474.25d? | 2017-03-15 A | 2018-06-15 A | 100% |  |  |  | R4 | 5248h | 5248h | LTE_V2X_CA_bands | 38 | LG Electronics |  | Rel-15 | 75 | 36.787 |  |
| 3436 | 1420.1 | Core part: V2X new band combinations for LTE |  | 328d? | 2017-03-15 A | 2018-06-15 A | 100% |  |  | finish no earlier than 2018-06-15 | R4 | 2624h | 2624h | LTE_V2X_CA_bands-Core | 38 | LG Electronics |  | Rel-15 | 75 |  |  |
| 3437 | 1421 | **Enhancements on LTE-based V2X Services** |  | 662.75d? | 2017-03-15 A | 2018-12-14 | 99% | 3.05d? | 40473.9d |  | R1 | 10472h | 10423.7h | LTE_eV2X | 38 | Huawei |  | Rel-15 | 75 |  |  |
| 3438 | 1421.1 | Core part: V2X phase 2 based on LTE |  | 393d? | 2017-03-15 A | 2018-03-29 | 99% | 3.93d? | 40743.6d | finish no earlier than 2018-09-15 | R1 | 3144h | 3112.56h | LTE_eV2X-Core | 38 | Huawei |  | Rel-15 | 75 | 36.788 | RP-180858 |
| 3439 | 1421.2 | Perf. Part: V2X phase 2 based on LTE |  | 458d? | 2017-03-15 A | 2018-12-14 A | 100% |  |  | finish no earlier than 2018-12-15 | R4 | 3664h | 3664h | LTE_eV2X-Perf | 38 | Huawei |  | Rel-15 | 75 |  |  |
| 3440 | 1422 | Study on security aspects for LTE support of V2X services |  | 465d? | 2015-09-07 A | 2017-06-15 A | 100% |  |  | finish no earlier than 2017-06-15 | S3 | 3720h | 3720h | FS_V2XLTE_ARC | 36 | Huawei, Marcus Wong | mwong@huawei.com | Rel-15 | 70 | 33.885 |  |
| 3441 | 1423 | Release 15 Features on Ultra/Highly Reliable Low Latency Communication | milestone | 0d? | 2016-06-09 A | 2016-06-09 A | 100% |  |  | finish no earlier than 2016-06-09 |  |  |  |  |  |  |  | Rel-15 |  |  |  |
| 3442 | 1424 | EPC support for E-UTRAN Ultra Reliable Low Latency Communication |  | 135d? | 2017-09-08 A | 2018-03-15 A | 100% |  |  | finish no earlier than 2018-03-15 | S2 | 1080h | 1080h | EPS_URLLC | 39 | Chris PUDNEY | chris dot pudney at vodafone dot com | Rel-15 | 77 | 23.401; 23.214; 23.203 |  |
| 3443 | 1425 | **Highly Reliable Low Latency Communication for LTE** |  | 663.88d? | 2017-03-15 A | 2018-12-15 | 46% | 360.36d? | 40472.8d |  | R1 | 10472h | 4787.72h | LTE_HRLLC | 38 | Ericsson |  | Rel-15 | 75 |  |  |
| 3444 | 1425.1 | Core part: Highly Reliable Low Latency Communication for LTE |  | 393d? | 2017-03-15 A | 2018-03-29 | 99% | 3.93d? | 40743.6d | finish no earlier than 2018-09-15 | R1 | 3144h | 3112.56h | LTE_HRLLC-Core | 38 | Ericsson |  | Rel-15 | 75 |  | RP-180693 |
| 3445 | 1425.2 | Perf. part: Highly Reliable Low Latency Communication for LTE |  | 458d? | 2017-09-29 | 2018-12-15 |  |  | 40472.8d | finish no earlier than 2018-12-15 | R4 | 3664h |  | LTE_HRLLC-Perf | 38 | Ericsson |  | Rel-15 | 75 |  |  |
| 3446 | 1426 | Release 15 Features on improvements of Mission Critical (MC) | milestone | 0d? | 2016-06-09 A | 2016-06-09 A | 100% |  |  | finish no earlier than 2016-06-09 |  |  |  |  |  |  |  | Rel-15 |  |  |  |
| 3447 | 1427 | Study on MC system migration and interconnect between MCPTT systems |  | 262d? | 2016-06-13 A | 2017-06-12 A | 100% |  |  | finish no earlier than 2017-06-12 | S6 | 2096h | 2096h | FS_MCSMI | 37 | Chater-Lea, David |  | Rel-15 | 72 | New 23.781 |  |
| 3448 | 1428 | Study on MC Communication Interworking between LTE and non-LTE Systems |  | 262d? | 2016-06-13 A | 2017-06-12 A | 100% |  |  | finish no earlier than 2017-06-12 | S6 | 2096h | 2096h | FS_MCCI | 37 | Monnes, Peter (Harris Corp.) |  | Rel-15 | 72 | New 23.782 |  |
| 3449 | 1429 | Study on MC Security Enhancements |  | 456d? | 2016-06-17 A | 2018-03-15 A | 100% |  |  | finish no earlier than 2018-03-15 | S3 | 3648h | 3648h | FS_MC_Sec | 37 | Haigh, Peter, CESG | peter.haigh@cesg.gsi.gov.uk | Rel-15 | 72 | 33.xxx; 33.280; 39.880 |  |
| 3450 | 1430 | MC Communication Interworking between LTE and non-LTE Systems (Stage 3 in Rel16) |  | 139d? | 2017-06-05 A | 2017-12-14 A | 100% |  |  | start no earlier than 2017-06-05 | S6 | 1112h | 1112h | MCCI | 39 | Monnes, Peter, Harris Corporation | pmonnes at harris dot com | Rel-15 | 76 | New 23.283; 23.280; 23.379; 23.282 |  |
| 3451 | 1431 | Removal of 'over LTE' limitation from Mission Critical Specifications |  | 23d? | 2017-11-15 A | 2017-12-15 A | 100% |  |  | finish no earlier than 2017-12-15 | S1 | 184h | 184h | MCOver | 40 | Kees Verweij ;The Police of the Netherlands | KeesdotVerweijatPolitiedotNL | Rel-15 | 78 | 22.179; 22.280; 22.281; 22.282; 22.468 |  |
| 3452 | 1432 | **Enhancements to MCPTT functional architecture and information flows** |  | 486.75d? | 2017-03-03 A | 2018-06-15 A | 100% |  |  |  |  | 3248h | 3248h | enhMCPTT | 38 | Dom Lazara, Motorola Solutions | dom.lazara@motorolasolutions.com | Rel-15 | 75 | 23.280 + 23.379 |  |
| 3453 | 1432.1 | Stage 2 of enhMCPTT |  | 205d? | 2017-03-03 A | 2017-12-14 A | 100% |  |  | finish no earlier than 2017-12-14 | S6 | 1640h | 1640h | enhMCPTT | 38 | Dom Lazara, Motorola Solutions | dom.lazara@motorolasolutions.com | Rel-15 | 75 | 23.280 + 23.379 |  |
| 3454 | 1432.2 | Stage 3 of enhMCPTT |  | 201d? | 2017-09-08 A | 2018-06-15 A | 100% |  |  | finish no earlier than 2018-06-15 | C1 | 1608h | 1608h | enhMCPTT-CT | 39 | FREDERICKS, Bob | bobfredericks@motorolasolutions.com | Rel-15 | 77 | 24.379; 24.380; 24.481; 24.482; 24.483; 24.484 |  |
| 3455 | 1433 | **Enhancements to MC Data Functional architecture and information flows** |  | 486.75d? | 2017-03-03 A | 2018-06-15 A | 100% |  |  |  |  | 3248h | 3248h | eMCData | 38 | David Freeman, Home Office | david@dnf-consulting.co.uk | Rel-15 | 75 | 23.280 + 23.282 |  |
| 3456 | 1433.1 | Stage 2 of eMCData |  | 205d? | 2017-03-03 A | 2017-12-14 A | 100% |  |  | finish no earlier than 2017-12-14 | S6 | 1640h | 1640h | eMCData | 38 | David Freeman, Home Office | david@dnf-consulting.co.uk | Rel-15 | 75 | 23.280 + 23.282 |  |
| 3457 | 1433.2 | Stage 3 of eMCData |  | 201d? | 2017-09-08 A | 2018-06-15 A | 100% |  |  | finish no earlier than 2018-06-15 | C1 | 1608h | 1608h | eMCData-CT | 39 | HASON, Baruh | Baruh.Hason@motorolasolutions.com | Rel-15 | 77 | 24.282; 24.582; 24.481; 24.483; 24.484 |  |

Notes:
- 3433: 19/9/16: 30%->70¦6/10/16: 22.886 added¦1/12/16: 70%->95¦2/3/17: 95%->100
- 3434: 7/6/17: 90%->100
- 3435: no Perf. part¦12/7/17: 36.787 added;
- 3436: no Perf. part¦19/6/17: Compl:0%->20%¦19/9/17: Compl:20%->40%¦8/1/18: Compl:40%->50%¦27/3/18: Compl:50%->70%;
- 3437: follow-up WI of REL-14 WI LTE_V2X for which the Core part was completed at RAN #75¦14/9/17: WID:RP-170798->RP-171069
- 3438: follow-up WI of REL-14 WI LTE_V2X for which the Core part was completed at RAN #75¦19/6/17: Compl:0%->15%¦ 30/6/17: 36.788 added;¦19/9/17: Compl:15%->30% 8/1/18: Compl:30%->55%27/3/18: Compl:55%->75%
- 3439: follow-up WI of REL-14 WI LTE_V2X for which the Core part was completed at RAN #7519/6/17: WID: RP-170798->RP-17106919/9/17: WID: RP-171069->RP-171740¦27/6/18: Compl:0%->5%¦16/1/19: 5%->100¦16/1/19: WID:RP-171740->RP-182549
- 3440: 11/12/15: WID:SP-150715->SP-150743. 28/01/16: typo on name corrected, WD corrected (was SP-150743)¦7/3/16: 0%->10¦19/9/16: 10%->65¦1/12/16: 65%->85¦6/3/17: 85%->90¦21/3/17: FCD shifted, moved from Rel-14¦21/3/17: FCD:09/16->06/17¦8/8/18: 90%->100
- 3441: -
- 3442: 15/12/17: WID:SP-170797->SP-170811¦15/12/17: 0%->15¦20/3/18: 15%->100
- 3443: 14/9/17: WID:RP-170796->RP-171489
- 3444: ¦19/6/17: WID: RP-170796->RP-171489¦8/1/18: Compl:0%->10%¦8/1/18: WID: RP-171489->RP-172845¦27/3/18: Compl:10%->30%¦27/6/18: Compl:30%->99%¦27/6/18: CD:Fri 15
- 3445: ¦19/6/17: WID: RP-170796->RP-171489¦8/1/18: WID: RP-171489->RP-172845¦27/6/18: WID: RP-172845->RP-181259
- 3446: -
- 3447: 28/7/16: 23.781 added¦19/9/16: WID:SP-160340->SP-160526¦FCD: 09/16->12/16¦19/9/16: 0%->40¦1/12/16: WID:SP-160526->SP-160880¦1/12/16: 40%->48¦9/12/16: FCD:12/16->06/17, Rel-14->Rel-15¦3/3/17: 48%->60¦7/6/17: 60%->100
- 3448: 28/7/16: 23.782 added¦19/9/16: WID:SP-160341->SP-160527¦19/9/16: 0%->20¦1/12/16: WID:SP-160527->SP-160881¦1/12/16: 20%->22¦9/12/16: FCD:12/16->06/17, Rel-14->Rel-15¦3/3/17: 22%->50¦7/6/17: 50%->90¦11/9/17: 90%->100
- 3449: 28/7/16: 33.280 added¦28/7/16: 39.880 added¦19/9/16: WID:SP-160374->SP-160567. FCD: 12/16->03/17¦1/12/16: 0%->35¦6/3/17: FCD:03/17->06/17¦6/3/17: 35%->60¦7/6/17: FCD:06/17->12/17 (Rel-14->Rel-15);60%->65¦8/6/17: WID:SP-160567->SP-170416¦11/9/17
- 3450: 11/9/17: 0%->40¦15/12/17: 40%->87¦16/3/18: 87%->100. 10/9/18: moved from Rel-15 since too late for St 3 in Rel-15 as said in CT81. 12/9/18: moved back to Rel-15, while St.3 will be Rel-16
- 3451: 7/6/18: WID:SP-170986->SP-180354
- 3452: 21/3/17: impacted TS/TR added¦7/6/17: 0%->25
- 3453: 21/3/17: impacted TS/TR added¦7/6/17: 0%->25¦11/9/17: 25%->45¦15/12/17: 45%->100
- 3454: 15/12/17: 0%->10¦7/6/18: 10%->20¦10/9/18: 20%->80¦7/12/18: 80%->85¦10/12/18: 85%->100
- 3455: 21/3/17: impacted TS/TR added¦7/6/17: 0%->10¦8/6/17: WID:SP-170249->SP-170462
- 3456: 21/3/17: impacted TS/TR added¦7/6/17: 0%->10¦8/6/17: WID:SP-170249->SP-170462¦11/9/17: 10%->15¦15/12/17: 15%->100
- 3457: 20/3/18: 0%->30¦7/6/18: 30%->85¦10/12/18: 85%->100

| ID | WBS | Task | Type | Duration | Start | Finish | Complete | Remaining | Total slack | Constraint | Resources | Work | Actual work | Acronym | PCG approved | Impacted TSs and TRs | WI rapporteur name | WI rapporteur e-mail | Release | TSG approved | Status Report |
| --- | --- | --- | --- | --- | --- | --- | --- | --- | --- | --- | --- | --- | --- | --- | --- | --- | --- | --- | --- | --- | --- |
| 3458 | 1434 | **Enhancements to MC Video Functional architecture and information flows** |  | 389.25d? | 2017-06-05 A | 2018-06-15 A | 100% |  |  |  |  | 6042.8h | 6042.8h | eMCVideo | 39 | 23.280; 23.281 | Niranth Amogh, Huawei Telecommunications (India | namogh@huawei.com | Rel-15 | 76 |  |
| 3459 | 1434.1 | Stage 2 of eMCVideo |  | 139d? | 2017-06-05 A | 2017-12-14 A | 100% |  |  | finish no earlier than 2017-12-14 | S6 | 1112h | 1112h | eMCVideo | 39 | 23.280; 23.281 | Niranth Amogh, Huawei Telecommunications (India | namogh@huawei.com | Rel-15 | 76 |  |
| 3460 | 1434.2 | **Stage 3 of eMCVideo** |  | 291d? | 2017-09-08 A | 2018-06-15 A | 100% |  |  |  | ct | 4930.8h | 4930.8h | eMCVideo-CT | 39 |  | WEI, Haitao | weihaitao@huawei.com | Rel-15 | 77 |  |
| 3461 | 1434.2.1 | CT1 aspects of eMCVideo |  | 138.45d? | 2017-09-08 A | 2018-06-15 A | 100% |  |  | finish no earlier than 2018-06-15 | C1 | 1107.6h | 1107.6h | eMCVideo-CT | 39 | 24.281; 24.581; 24.481; 24.483; 24.484 | WEI, Haitao | weihaitao@huawei.com | Rel-15 | 77 |  |
| 3462 | 1434.2.2 | CT3 aspects of eMCVideo |  | 138.45d? | 2017-12-05 A | 2018-06-15 A | 100% |  |  | finish no earlier than 2018-06-15 | C3 | 1107.6h | 1107.6h | eMCVideo-CT | 39 | 29.165; 29.213; 29.214 | WEI, Haitao | weihaitao@huawei.com | Rel-15 | 77 |  |
| 3463 | 1434.2.3 | CT6 aspects of eMCVideo |  | 138.45d? | 2017-12-05 A | 2018-06-15 A | 100% |  |  | finish no earlier than 2018-06-15 | C6 | 1107.6h | 1107.6h | eMCVideo-CT | 39 | 31.102; 31.103 | WEI, Haitao | weihaitao@huawei.com | Rel-15 | 77 |  |
| 3464 | 1435 | MC Security Enhancements |  | 270d? | 2017-06-05 A | 2018-06-15 A | 100% |  |  | finish no earlier than 2018-06-15 | S3 | 2160h | 2160h | eMCSec | 39 | 33.180 | Haigh, Peter, NCSC |  | Rel-15 | 76 |  |
| 3465 | 1436 | **MBMS usage for MC communication services** |  | 478.5d? | 2017-03-03 A | 2018-06-07 A | 100% |  |  |  | S6 | 4640h | 4640h | MBMS_Mcservices | 38 | 23.280 + 23.281 + 23.282 + 23.379 | Magnus Tränk, Ericsson | magnus.trank@ericsson.com | Rel-15 | 75 |  |
| 3466 | 1436.1 | Stage 2 for MBMS_Mcservices |  | 206d? | 2017-03-03 A | 2017-12-15 A | 100% |  |  | finish no earlier than 2017-12-15 | S6 | 1648h | 1648h | MBMS_Mcservices | 38 | 23.280 + 23.281 + 23.282 + 23.379 | Magnus Tränk, Ericsson | magnus.trank@ericsson.com | Rel-15 | 75 |  |
| 3467 | 1436.2 | Stage 3 for MBMS_Mcservices |  | 44d? | 2018-04-09 A | 2018-06-07 A | 100% |  |  | finish no earlier than 2018-06-07 | C1 | 352h | 352h | MBMS_Mcservices | 41 | 24.281; 24.282; 24.379; 24.380; 24.581; 24.380 | Axell, Jörgen, Ericsson | Jorgen.Axell@ericsson.com | Rel-15 | 80 |  |
| 3468 | 1437 | MC system migration and interconnection |  | 139d? | 2017-06-05 A | 2017-12-14 A | 100% |  |  | start no earlier than 2017-06-05 | S6 | 1112h | 1112h | MCSMI | 39 | 23.280; 23.379; 23.281; 23.282; 24.885 | Chater-Lea, David; Motorola Solutions | david.chater-lea@motorolasolutions.com | Rel-15 | 76 |  |
| 3469 | 1438 | Protocol enhancements for Mission Critical Services |  | 201d? | 2017-09-08 A | 2018-06-15 A | 100% |  |  | finish no earlier than 2018-06-15 | C1 | 1608h | 1608h | MCProtoc15 | 39 |  | Jörgen Axell |  | Rel-15 | 77 |  |
| 3470 | 1439 | UE Conformance Test Aspects - Enhancements for Mission Critical Services MCPTT, MCData and MCVideo |  | 460d | 2020-09-17 A | 2022-06-22 A | 100% |  |  | finish no earlier than 2022-06-22 | R5 | 3680h | 3680h | MCenhUEConTest | 45 |  | KAHN, Jason, NIST (U.S. Department of Commerce) | jason.kahn@nist.gov | Rel-15 | 89 | RP-221332 |
| 3471 | 1440 | Release 15 Features on MTC-IoT | milestone | 0d? | 2016-06-09 A | 2016-06-09 A | 100% |  |  | finish no earlier than 2016-06-09 |  |  |  |  |  |  |  |  | Rel-15 |  |  |
| 3472 | 1441 | Battery Efficient Security for very low Throughput MTC Devices |  | 389d? | 2016-09-19 A | 2018-03-15 A | 100% |  |  | finish no earlier than 2018-03-15 | S3 | 3112h | 3112h | BEST_MTC_Sec | 37 | 33.401; 43.020; 33.220; 33.163 | Evans, Tim, VODAFONE Group Plc. |  | Rel-15 | 73 |  |
| 3473 | 1442 | AT Commands for CIoT-Ext |  | 130d? | 2017-12-15 A | 2018-06-14 A | 100% |  |  | finish no earlier than 2018-06-14 | C1 | 1040h | 1040h | AT_CIoT-Ext | 40 | 27.007 | Bakker, John-Luc (Blackberry) | jbakker@blackberry.com | Rel-15 | 78 |  |
| 3474 | 1443 | **Even further enhanced MTC for LTE** |  | 1805.12d? | 2017-03-15 A | 2021-12-21 A | 100% |  |  |  | R1 | 20984h | 20984h | LTE_eMTC4 | 38 |  | Ericsson |  | Rel-15 | 75 |  |
| 3475 | 1443.1 | Core part: Even further enhanced MTC for LTE |  | 393d? | 2017-03-15 A | 2018-09-14 A | 100% |  |  | finish no earlier than 2018-09-15 | R1 | 3144h | 3144h | LTE_eMTC4-Core | 38 |  | Ericsson |  | Rel-15 | 75 | RP-181213 |
| 3476 | 1443.2 | Perf. part: Even further enhanced MTC for LTE |  | 458d? | 2017-03-15 A | 2018-12-14 A | 100% |  |  | finish no earlier than 2018-12-15 | R4 | 3664h | 3664h | LTE_eMTC4-Perf | 38 |  | Ericsson |  | Rel-15 | 75 |  |
| 3477 | 1443.3 | UE Conformance Test Aspects - Even further enhanced MTC for LTE |  | 527d | 2019-12-16 A | 2021-12-21 A | 100% |  |  | finish no earlier than 2021-12-21 | R5 | 4216h | 4216h | LTE_eMTC4-UEConTest | 44 |  | Ericsson |  | Rel-15 | 86 | RP-211862 |
| 3478 | 1444 | **Further NB-IoT enhancements** |  | 1697.5d? | 2017-03-15 A | 2021-09-08 | 98% | 25.54d? | 39439.1d |  | R1 | 19816h | 13870.2h | NB_IOTenh2 | 38 |  | Huawei |  | Rel-15 | 75 |  |
| 3479 | 1444.1 | Core part: Further NB-IoT enhancements |  | 393d? | 2017-03-15 A | 2018-03-29 | 95% | 19.65d? | 40743.6d | finish no earlier than 2018-09-15 | R1 | 3144h | 2986.8h | NB_IOTenh2-Core | 38 |  | Huawei |  | Rel-15 | 75 | RP-180851 |
| 3480 | 1444.2 | Perf. part: Further NB-IoT enhancements |  | 458d? | 2017-03-15 A | 2018-12-14 A | 100% |  |  | finish no earlier than 2018-12-15 | R4 | 3664h | 3664h | NB_IOTenh2-Perf | 38 |  | Huawei |  | Rel-15 | 75 |  |
| 3481 | 1444.3 | UE Conformance Test Aspects - Further NB-IoT enhancements |  | 455d | 2019-12-12 A | 2021-09-08 A | 100% |  |  | finish no earlier than 2021-09-08 | R5 | 3640h | 3640h | NB_IOTenh2-UEConTest | 44 |  |  |  | Rel-15 | 86 |  |
| 3482 | 1445 | Release 15 Features related to WLAN | milestone | 0d? | 2016-06-09 A | 2016-06-09 A | 100% |  |  | finish no earlier than 2016-06-09 |  |  |  |  |  |  |  |  | Rel-15 |  |  |

Notes:
- 3458: 7/6/17: 0%->10
- 3459: 7/6/17: 0%->10¦11/9/17: 10%->60¦15/12/17: 60%->100
- 3460: 7/6/18: WID:CP-172032->CP-181084
- 3461: 20/3/18: 0%->25¦7/6/18: 25%->100¦12/6/18: 100%->99¦10/9/18: 99%->100
- 3462: 10/9/18: 0%->100
- 3463: 10/9/18: 0%->100
- 3464: 15/12/17: 0%->80¦15/12/17: FCD:12/17->03/18¦21/12/17: FCD:03/18->05/18. Exception in SP-171056¦16/3/18: 80%->90¦16/3/18: FCD:05/18->06/18¦7/6/18: 90%->100
- 3465: 21/3/17: impacted TS/TR added¦7/6/17: 0%->45¦8/9/17: WID:SP-170075->SP-170686¦8/9/17: FCD:09/17->12/17¦11/9/17: 45%->70¦15/12/17: 70%->95¦16/3/18: 95%->100. Problem with % complete when set as Parent Feature. Has to be left as independent item…
- 3466: 21/3/17: impacted TS/TR added¦7/6/17: 0%->45¦8/9/17: WID:SP-170075->SP-170686¦8/9/17: FCD:09/17->12/17¦11/9/17: 45%->70¦15/12/17: 70%->95¦16/3/18: 95%->100
- 3467: 12/6/18: 10%->30¦10/9/18: 30%->70¦7/12/18: 70%->100
- 3468: 12/7/17: WID:SP-170402->SP-170577¦11/9/17: 0%->20¦15/12/17: 20%->80¦16/3/18: 80%->100
- 3469: 14/9/17: 0%->15¦15/12/17: 15%->40¦20/3/18: 40%->70¦7/6/18: 70%->100
- 3470: tested: REL-15 SA/CT WIs enhMCPTT, eMCVideo, eMCData, MBMS_Mcservices, MCSMI, MCProtoc15, MCOver ; 8/4/21: 0%->16; 2/7/21: 16%->33; 13/9/21: Compl:33%->40%; 13/9/21: CD:Fri 17/12/21->Tue 21/12/21; 13/9/21: Stat Rep: ->RP-211764; 6/1/22: WID:RP-201487- ; 20/6/22: Rapporteur: NIST->KAHN, Jason, NIST (U.S. Department of Commerce); Rap eMail: ->jason.kahn@nist.gov;
- 3471: -
- 3472: 6/10/16: 33.163 added 6/3/17: FCD:12/16->09/17¦6/3/17: 0%->20. Moved from Rel-14.¦7/6/17: 20%->95¦15/12/17: FCD:09/17->03/18¦16/3/18: 95%->100
- 3473: 20/3/18: 0%->20¦7/6/18: 20%->100
- 3474: WI LTE_feMTC-Core got a 3 months exception granted by RAN #75 to complete in REL-14¦note: RAN #75 approved WID RP-170732 with working agreement¦14/9/17: WID:RP-170732->RP-171427
- 3475: WI LTE_feMTC-Core got a 3 months exception granted by RAN #75 to complete in REL-14¦note: RAN #75 approved WID RP-170732 with working agreement¦19/6/17: Compl:0%- 19/9/ 8/1 2 ;¦16/1/19: 97%->100
- 3476: note: RAN #75 approved WID RP-170732 with working agreement19/6/17: WID: RP-170732->RP-171427¦8/1/18: WID: RP-171427->RP-172811¦27/6/18: Compl:0%->50%¦16/1/19: 50%->100
- 3477: affects: LTE. tested: REL-15 WI LTE_eMTC4-Core; 8/10/20: 0%->47; 8/4/21: 47%->54; 8/4/21: FCD:15/12/2020->06/21; 2/7/21: FCD:Fri 11/06/->12/21; 2/7/21: 54%->77; 13/9/21: Compl:77%->80%; ; 6/1/22: 80%->100
- 3478: follow-up WI of REL-14 WI NB_IOTenh which got an exception granted at RAN #75 to complete by RAN #76¦note: RAN #75 approved WID RP-170852 with working agreement¦14/9/17: WID:RP-170852->RP-171428
- 3479: follow-up WI of REL-14 WI NB_IOTenh which got an exception granted at RAN #75 to complete by RAN #76¦note: RAN #75 approved WID RP-170852 with working agreement;1 8/1/12 ;
- 3480: follow-up WI of REL-14 WI NB_IOTenh which got an exception granted at RAN #75 to complete by RAN #76¦note: RAN #75 approved WID RP-170852 with working agreement¦8/1 ;¦26/3/19: 30%->100
- 3481: 8/10/20: 0%->25; 8/10/20: FCD:11/12/2020->12/20; 8/4/21: 25%->79; 8/4/21: FCD:11/12/2020->06/21; 2/7/21: FCD:Fri 11/06/->09/21; 2/7/21: 79%->93; 29/9/21: 93%->100
- 3482: -

| ID | WBS | Task | Type | Duration | Start | Finish | Complete | Constraint | Resources | Work | Actual work | Acronym | PCG approved | Impacted TSs and TRs | WI rapporteur name | WI rapporteur e-mail | Release | TSG approved |
| --- | --- | --- | --- | --- | --- | --- | --- | --- | --- | --- | --- | --- | --- | --- | --- | --- | --- | --- |
| 3483 | 1446 | **Inclusion of WLAN direct discovery technologies as an alternative for ProSe direct discovery** |  | 503.25d? | 2016-11-15 A | 2018-03-15 A | 100% |  |  | 4528h | 4528h | ProSe_WLAN_DD | 38 | 22.278 | Intel Corporation; Ana Lucia Pinheiro | ana.lucia.a.pinheiro@intel.com | Rel-15 | 74 |
| 3484 | 1446.1 | Stage 1 of ProSe_WLAN_DD |  | 23d? | 2016-11-15 A | 2016-12-15 A | 100% | finish no earlier than 2016-12-15 | S1 | 184h | 184h | ProSe_WLAN_DD | 38 | 22.278 | Intel Corporation; Ana Lucia Pinheiro | ana.lucia.a.pinheiro@intel.com | Rel-15 | 74 |
| 3485 | 1446.2 | Stage 2 of ProSe_WLAN_DD |  | 76d? | 2017-03-02 A | 2017-06-15 A | 100% | finish no earlier than 2017-06-15 | S2 | 608h | 608h | ProSe_WLAN_DD_Stage2 | 38 |  | Intel, Sašo Stojanovski | saso.stojanovski@intel.com | Rel-15 | 75 |
| 3486 | 1446.3 | **Stage 3 of ProSe_WLAN_DD** |  | 194.75d? | 2017-06-02 A | 2017-12-06 A | 100% |  | ct | 3216h | 3216h | ProSe_WLAN_DD_Stage3 | 39 |  | Intel, Vivek Gupta | vivek.g.gupta@intel.com | Rel-15 | 76 |
| 3487 | 1446.3.1 | CT1 aspects of ProSe_WLAN_DD |  | 134d? | 2017-06-02 A | 2017-12-06 A | 100% | finish no earlier than 2017-12-06 | C1 | 1072h | 1072h | ProSe_WLAN_DD_Stage3 | 39 | 24.334 | Intel, Vivek Gupta | vivek.g.gupta@intel.com | Rel-15 | 76 |
| 3488 | 1446.3.2 | CT4 aspects of ProSe_WLAN_DD |  | 134d? | 2017-06-02 A | 2017-12-06 A | 100% | finish no earlier than 2017-12-06 | C4 | 1072h | 1072h | ProSe_WLAN_DD_Stage3 | 39 | 29.345; 29.230; 23.008 | Intel, Vivek Gupta | vivek.g.gupta@intel.com | Rel-15 | 76 |
| 3489 | 1446.4 | Charging of ProSe_WLAN_DD |  | 65d? | 2017-12-15 A | 2018-03-15 A | 100% | finish no earlier than 2018-03-15 | S5 | 520h | 520h | ProSe_WLAN_DD-CH | 38 | 32.277; 32.298; 32.299 | Yizhi Yao, Intel Corporation | yizhi.yao@intel.com | Rel-15 | 74 |
| 3490 | 1447 | **Complementary Features for Voice services over WLAN** |  | 757.88d? | 2016-06-13 A | 2018-06-14 A | 100% |  |  | 10416h | 10416h | VoWLAN | 39 |  |  |  | Rel-15 | 76 |
| 3491 | 1447.1 | Study on Complementary Features for Voice services over WLAN |  | 199d? | 2016-06-13 A | 2017-03-15 A | 100% | finish no earlier than 2017-03-15 | S2 | 1592h | 1592h | FS_VoWLAN | 37 | 23.751 | Nokia (Nicolas Drevon | nicolas.drevon@nokia.com | Rel-15 | 72 |
| 3492 | 1447.2 | Stage 2 of VoWLAN |  | 23d? | 2017-05-09 A | 2017-06-08 A | 100% | finish no earlier than 2017-06-08 | S2 | 184h | 184h | VoWLAN | 39 | 23.402 | Drevon Nicolas, Nokia | nicolas.drevon@nokia.com | Rel-15 | 76 |
| 3493 | 1447.3 | **CT aspects of VoWLAN** |  | 391.5d? | 2017-06-02 A | 2018-06-14 A | 100% |  | ct | 8640h | 8640h | VoWLAN-CT | 39 |  | Jennifer Liu (Nokia) | Jennifer.Liu at nokia.com | Rel-15 | 76 |
| 3494 | 1447.3.1 | CT1 aspects of VoWLAN |  | 270d? | 2017-06-02 A | 2018-06-14 A | 100% | finish no earlier than 2018-06-14 | C1 | 2160h | 2160h | VoWLAN-CT | 39 | 24.302 ; 24.312 ; 24.244 | Jennifer Liu (Nokia) | Jennifer.Liu at nokia.com | Rel-15 | 76 |
| 3495 | 1447.3.2 | CT4 aspects of VoWLAN |  | 270d? | 2017-06-02 A | 2018-06-14 A | 100% | finish no earlier than 2018-06-14 | C4 | 2160h | 2160h | VoWLAN-CT | 39 | 29.274 | Jennifer Liu (Nokia) | Jennifer.Liu at nokia.com | Rel-15 | 76 |
| 3496 | 1447.3.3 | CT6 aspects of VoWLAN |  | 270d? | 2017-06-02 A | 2018-06-14 A | 100% | finish no earlier than 2018-06-14 | C6 | 2160h | 2160h | VoWLAN-CT | 39 | 31.102 | Jennifer Liu (Nokia) | Jennifer.Liu at nokia.com | Rel-15 | 76 |
| 3497 | 1448 | Release 15 Features on Virtual Reality (VR) | milestone | 0d? | 2016-03-01 A | 2016-03-01 A | 100% |  |  |  |  |  |  |  |  |  | Rel-15 |  |
| 3498 | 1449 | Study on Virtual Reality |  | 402d? | 2016-03-01 A | 2017-09-12 A | 100% | finish no earlier than 2017-09-12 | S4 | 3216h | 3216h | FS_VR | 36 | 26.918 | Gilles TENIOU, Orange | gilles.teniou@orange.com | Rel-15 | 71 |
| 3499 | 1450 | Study on 3GPP codecs for VR audio |  | 71d? | 2017-09-08 A | 2017-12-15 A | 100% | finish no earlier than 2017-12-15 | S4 | 568h | 568h | FS_CODVRA | 39 | 26.918 | Toftgård, Tomas, Ericsson | tomas.toftgard@ericsson.com | Rel-15 | 77 |
| 3500 | 1451 | Test Methodologies for the Evaluation of Perceived Listening Quality in Immersive Audio Systems |  | 266d? | 2017-09-08 A | 2018-09-14 A | 100% | finish no earlier than 2018-09-14 | S4 | 2128h | 2128h | LiQuImAS | 39 | New; 26.861; 26.261; 26.260; 26.259 | Schevciw, Andre – Qualcomm Incorporated | aschevci@qti.qualcomm.com | Rel-15 | 77 |
| 3501 | 1452 | Addition of HDR to TV Video Profiles |  | 71d? | 2017-09-08 A | 2017-12-15 A | 100% | finish no earlier than 2017-12-15 | S4 | 568h | 568h | HDR | 39 | 26.116; 26.346; 26.234; 26.247; 26.244 | Thomas Stockhammer, Qualcomm Incorporated | tsto@qti.qualcomm.com | Rel-15 | 77 |
| 3502 | 1453 | Virtual Reality Profiles for Streaming Media |  | 266d? | 2017-09-08 A | 2018-09-14 A | 100% | finish no earlier than 2018-09-14 | S4 | 2128h | 2128h | VRStream | 39 | 26.118; 26.818; 26.247; 26.346; 26.234 | Thomas Stockhammer, Qualcomm Incorporated | tsto@qti.qualcomm.com | Rel-15 | 77 |
| 3503 | 1454 | Release 15 other Features | milestone | 0d? | 2016-06-09 A | 2016-06-09 A | 100% |  |  |  |  |  |  |  |  |  | Rel-15 |  |
| 3504 | 1455 | Forward compatibility for 3GPP Diameter Charging Applications |  | 67d? | 2018-03-15 A | 2018-06-15 A | 100% | finish no earlier than 2018-06-15 | S5 | 536h | 536h | FWDCA | 40 | 32.251; 32.277; 32.299 | Gardella, Maryse, Nokia | maryse.gardella@nokia.com | Rel-15 | 79 |
| 3505 | 1456 | Diameter Overload Control Mechanisms for Charging |  | 132d? | 2018-03-15 A | 2018-09-14 A | 100% | finish no earlier than 2018-09-14 | S5 | 1056h | 1056h | DOCME_CH | 40 | 32.299 | Törnkvist, Robert, Ericsson | robert(dot)tornkvist(at)Ericsson(dot)com | Rel-15 | 79 |
| 3506 | 1457 | Charging aspects of WLAN access in EPC |  | 67d? | 2018-03-15 A | 2018-06-15 A | 100% | start no earlier than 2018-03-15 | S5 | 536h | 536h | WAEPC_CH | 40 | 32.251; 32.260; 32.299; 32.298 | Gardella, Maryse, Nokia | maryse.gardella@nokia.com | Rel-15 | 79 |
| 3507 | 1458 | FEC and ROHC Activation for GCSE over MBMS |  | 132d? | 2018-03-15 A | 2018-09-14 A | 100% | finish no earlier than 2018-09-14 | S4 | 1056h | 1056h | FRASE | 40 | 26.346; new | Bouazizi, Imed, Samsung Electronics Co., Ltd | i.bouazizi@samsung.com. | Rel-15 | 79 |
| 3508 | 1459 | Media Handling Aspects of 5G Conversational Services |  | 132d? | 2018-03-15 A | 2018-09-14 A | 100% | finish no earlier than 2018-09-14 | S4 | 1056h | 1056h | 5G_MTSI_Codecs | 40 | 26.114; 26.223 | Oyman, Ozgur, Company: Intel | ozgur.oyman@intel.com | Rel-15 | 79 |

Notes:
- 3483: 1/12/16: 0%->100
- 3484: 1/12/16: 0%->100
- 3485: 6/3/17: 0%->55¦7/6/17: 55%->100
- 3486: 18/12/17: WID:CP-171102->CP-173084
- 3487: 14/9/17: 0%->60¦15/12/17: 60%->100
- 3488: 15/12/17: 0%->100
- 3489: 15/12/17: 0%->40¦16/3/18: 40%->100
- 3491: 28/7/16: 23.751 added¦19/9/16: 0%->10., 7/12/16: moved from Rel-14, according to SP-160806¦6/3/17: 10%->80¦7/6/17: 80%->100
- 3492: 15/12/17: 0%->100
- 3493: 7/6/18: WID:CP-171101->CP-181083
- 3494: 14/9/17: 0%->70¦15/12/17: 70%->100
- 3495: 7/6/18: 0%->100
- 3496: 7/6/18: 0%->100
- 3497: -
- 3498: 11/6/16: 0%->10¦19/9/16: 10%->40, FCD: 12/16->03/17¦1/12/16: FCD:03/17->06/17¦1/12/16: 40%->35¦14/12/16: 35%->45¦14/12/16: FCD:06/17->09/17¦6/3/17: 45%->55¦7/6/17: 55%->70¦11/9/17: 70%->100
- 3499: 15/12/17: 0%->100¦15/12/17: FCD:09/17->12/17
- 3500: 15/12/17: added: 26.861¦26.261¦26.260¦26.259¦15/12/17: 0%->15¦16/3/18: 15%->20¦7/6/18: 20%->35¦7/6/18: FCD:06/18->09/18¦10/9/18: 35%->100
- 3501: 15/12/17: 0%->100
- 3502: 15/12/17: 26.118 added;¦15/12/17: 0%->25¦16/3/18: 25%->40¦7/6/18: 40%->60¦7/6/18: FCD:06/18->09/18¦10/9/18: 60%->100¦2/10/18: WID:SP-170612->SP-180893
- 3503: -
- 3504: 7/6/18: 0%->100
- 3505: 7/6/18: 0%->10¦7/6/18: FCD:06/18->09/18¦10/9/18: 10%->100
- 3506: 7/6/18: 0%->100
- 3507: 7/6/18: 0%->30¦7/6/18: FCD:06/18->09/18¦10/9/18: 30%->100
- 3508: 7/6/18: 0%->60¦7/6/18: FCD:06/18->09/18¦10/9/18: 60%->100¦2/10/18: WID:SP-180033->SP-180650

| ID | WBS | Task | Duration | Start | Finish | Complete | Remaining | Total slack | Constraint | Resources | Work | Actual work | Acronym | PCG approved | WI rapporteur name | WI rapporteur e-mail | Release | TSG approved | Impacted TSs and TRs | Status Report |
| --- | --- | --- | --- | --- | --- | --- | --- | --- | --- | --- | --- | --- | --- | --- | --- | --- | --- | --- | --- | --- |
| 3509 | 1460 | **SRVCC for terminating call in pre-alerting phase** | 95.25d? | 2018-03-15 A | 2018-06-14 A | 100% |  |  |  |  | 1056h | 1056h | bSRVCC_MT | 40 | Song Yue (China Mobile) | songyue (at) chinamobile (dot) com | Rel-15 | 79 |  |  |
| 3510 | 1460.1 | CT1 aspects of bSRVCC_MT | 66d? | 2018-03-15 A | 2018-06-14 A | 100% |  |  | start no earlier than 2018-03-15 | C1 | 528h | 528h | bSRVCC_MT | 40 | Song Yue (China Mobile) | songyue (at) chinamobile (dot) com | Rel-15 | 79 | 24.237; 24.008 |  |
| 3511 | 1460.2 | CT3 aspects of bSRVCC_MT | 66d? | 2018-03-15 A | 2018-06-14 A | 100% |  |  | start no earlier than 2018-03-15 | C3 | 528h | 528h | bSRVCC_MT | 40 | Song Yue (China Mobile) | songyue (at) chinamobile (dot) com | Rel-15 | 79 | 29.165 |  |
| 3512 | 1461 | **Increasing the number of EPS bearers** | 95.25d? | 2018-03-16 A | 2018-06-15 A | 100% |  |  |  |  | 2112h | 2112h | INOBEAR | 40 | Andy.Bennett, Samsung | a <dot> bennett <at> Samsung.com | Rel-15 | 78 | 23.401; 23.167 |  |
| 3513 | 1461.1 | Stage 2 of INOBEAR | 66d? | 2018-03-16 A | 2018-06-15 A | 100% |  |  |  | S2 | 528h | 528h | INOBEAR | 40 | Andy.Bennett, Samsung | a <dot> bennett <at> Samsung.com | Rel-15 | 78 | 23.401; 23.167 |  |
| 3514 | 1461.2 | **Stage 3 of INOBEAR** | 95.25d? | 2018-03-16 A | 2018-06-15 A | 100% |  |  |  | ct | 1584h | 1584h | INOBEAR-CT | 40 | Samsung, Lalith Kumar | lalith.kumar@samsung.com | Rel-15 | 79 |  |  |
| 3515 | 1461.2.1 | CT1 aspects of INOBEAR | 66d? | 2018-03-16 A | 2018-06-15 A | 100% |  |  | start no earlier than 2018-03-16 | C1 | 528h | 528h | INOBEAR-CT | 40 | Samsung, Lalith Kumar | lalith.kumar@samsung.com | Rel-15 | 79 | 24.301; 24.007 |  |
| 3516 | 1461.2.2 | CT4 aspects of INOBEAR | 66d? | 2018-03-16 A | 2018-06-15 A | 100% |  |  | start no earlier than 2018-03-16 | C4 | 528h | 528h | INOBEAR-CT | 40 | Samsung, Lalith Kumar | lalith.kumar@samsung.com | Rel-15 | 79 | 29.274 |  |
| 3517 | 1462 | **Increased number of E-UTRAN data bearers** | 196d? | 2017-12-15 A | 2018-06-22 | 99% | 1.96d? | 40655.9d |  | R2 | 3136h | 3104.65h | INOBEARRAN | 40 | Samsung |  | Rel-15 | 78 |  |  |
| 3518 | 1462.1 | Core part: Increased number of E-UTRAN data bearers | 196d? | 2017-12-15 A | 2018-06-22 | 99% | 1.96d? | 40655.9d | finish no earlier than 2018-09-15 | R2 | 1568h | 1552.32h | INOBEARRAN-Core | 40 | Samsung |  | Rel-15 | 78 |  |  |
| 3519 | 1463 | **Remote UE access via relay UE** | 866.62d? | 2016-03-01 A | 2018-06-15 A | 100% |  |  |  |  | 4960h | 4960h | REAR | 36 | Huawei, Laurence Meriau | laurence.meriau@huawei.com | Rel-15 | 71 | 22.278; 22.115 |  |
| 3520 | 1463.1 | Study on architecture enhancements to ProSe UE-to-Network Relay | 206d? | 2016-12-01 A | 2017-09-14 A | 100% |  |  | finish no earlier than 2017-09-14 | S2 | 1648h | 1648h | FS_REAR | 38 | Dario Serafino Tonesi, Huawei | dario.tonesi@huawei.com | Rel-15 | 74 | 23.733 |  |
| 3521 | 1463.2 | Study on security aspects of enhancements to ProSe UE-to-Network Relay | 337d? | 2017-03-02 A | 2018-06-15 A | 100% |  |  | finish no earlier than 2018-06-15 | S3 | 2696h | 2696h | FS_REAR_Sec | 38 |  | lihe2@huawei.com | Rel-15 | 75 |  |  |
| 3522 | 1463.3 | Stage 1 for REAR | 77d? | 2016-03-01 A | 2016-06-15 A | 100% |  |  | finish no earlier than 2016-06-15 | S1 | 616h | 616h | REAR | 36 | Huawei, Laurence Meriau | laurence.meriau@huawei.com | Rel-15 | 71 | 22.278; 22.115 |  |
| 3523 | 1464 | **Enhanced VoLTE performance** | 582d? | 2016-12-01 A | 2018-06-15 A | 100% |  |  |  |  | 5680h | 5680h | eVoLP | 40 |  |  | Rel-15 | 78 |  |  |
| 3524 | 1464.1 | Stage 2 of eVoLP | 47d? | 2017-10-12 A | 2017-12-15 A | 100% |  |  | finish no earlier than 2017-12-15 | S2 | 376h | 376h | eVoLP | 40 | Xiaobo Wu, Huawei | wuxiaobo@ huawei.com | Rel-15 | 78 | 23.401; 23.203 |  |
| 3525 | 1464.2 | **CT aspects on enhanced VoLTE performance** | 188.5d? | 2017-12-15 A | 2018-06-14 A | 100% |  |  |  |  | 2080h | 2080h | eVoLP-CT | 40 | Yan, Yali, Huawei | yanyali@huawei.com | Rel-15 | 78 |  |  |
| 3526 | 1464.2.1 | CT3 aspects of EvoLP | 130d? | 2017-12-15 A | 2018-06-14 A | 100% |  |  | finish no earlier than 2018-06-14 | C3 | 1040h | 1040h | eVoLP-CT | 40 | Yan, Yali, Huawei | yanyali@huawei.com | Rel-15 | 78 | 29.212; 29.213 |  |
| 3527 | 1464.2.2 | CT4 aspects of EvoLP | 130d? | 2017-12-15 A | 2018-06-14 A | 100% |  |  | finish no earlier than 2018-06-14 | C4 | 1040h | 1040h | eVoLP-CT | 40 | Yan, Yali, Huawei | yanyali@huawei.com | Rel-15 | 78 | 29.274 |  |
| 3528 | 1464.3 | **Study on enhanced VoLTE performance** | 582d? | 2016-12-01 A | 2018-06-15 A | 100% |  |  |  |  | 3224h | 3224h | FS_eVoLP | 38 | Fabrice Plante, Intel | fabrice.m.plante@intel.com | Rel-15 | 74 | 23.759 |  |
| 3529 | 1464.3.1 | S2 aspects of FS_eVoLP | 206d? | 2016-12-01 A | 2017-09-14 A | 100% |  |  | finish no earlier than 2017-09-14 | S2 | 1648h | 1648h | FS_eVoLP | 38 | Xiaobo Wu |  | Rel-15 | 74 | 23.759 |  |
| 3530 | 1464.3.2 | S4 aspects of FS_eVoLP | 197d? | 2017-09-14 A | 2018-06-15 A | 100% |  |  | finish no earlier than 2018-06-15 | S4 | 1576h | 1576h | FS_eVoLP | 39 | Venkatraman, Atti, Qualcomm Incorporated | vatti@qti.qualcomm.com | Rel-15 | 77 | 26.959 |  |
| 3531 | 1465 | **Unlicensed Spectrum Offloading System** | 801.38d? | 2016-02-01 A | 2018-03-15 A | 100% |  |  |  |  | 2952h | 2952h | USOS | 36 | Edward Hall, Qualcomm Incorporated | edhall@qti.qualcomm.com | Rel-15 | 71 |  | SP-170526 |
| 3532 | 1465.1 | Study on unlicensed spectrum offloading system enhancements | 141d? | 2016-12-01 A | 2017-06-15 A | 100% |  |  | finish no earlier than 2017-06-15 | S2 | 1128h | 1128h | FS_USOS | 38 | Haris Zisimopoulos, Qualcomm Incorporated | harisz@qti.qualcomm.com | Rel-15 | 74 | 23.729 |  |
| 3533 | 1465.2 | Stage 1 of USOS | 22d? | 2016-02-01 A | 2016-03-01 A | 100% |  |  | start no earlier than 2016-02-01 | S1 | 176h | 176h | USOS | 36 | Edward Hall, Qualcomm Incorporated | edhall@qti.qualcomm.com | Rel-15 | 71 | 22.101; 22.115 | SP-170526 |
| 3534 | 1465.3 | Stage 2 of USOS | 71d? | 2017-09-08 A | 2017-12-15 A | 100% |  |  | finish no earlier than 2017-12-15 | S2 | 568h | 568h | USOS | 39 | Haris Zisimopoulos | harisz@qti.qualcomm.com | Rel-15 | 77 | 23.401; 23.203 |  |
| 3535 | 1465.4 | Stage 3 of USOS | 135d? | 2017-09-08 A | 2018-03-15 A | 100% |  |  | finish no earlier than 2018-03-15 | C4 | 1080h | 1080h | USOS-CT | 39 | Lena Chaponniere, Qualcomm Incorporated | lguellec@qti.qualcomm.com | Rel-15 | 77 | 23.008; 29.272; 29.230; 29.002; 29.305; 29.274 |  |

Notes:
- 3510: 16/3/18: 0%->80¦7/6/18: 80%->100
- 3511: 22/3/18: 0%->95¦10/9/18: 95%->100
- 3515: 7/6/18: 0%->100
- 3516: 7/6/18: 0%->100
- 3518: 27/3/18: WID: RP-172835->RP-180569¦27/6/18: Compl:0%->99%¦27/6/18:
- 3519: Previously known as "wearable devices"¦9/6/16: 0%->100¦9/6/16: WID:SP-160231->SP-160371
- 3520: 1/12/16: 0%->5. Study on Stage 2 for REAR. When normative work completed, Stage 1 and Stage 2 shall be in the same release¦6/3/17: 5%->30¦7/6/17: 30%->60¦11/9/17: 60%->95¦15/12/17: 95%->100
- 3521: 7/6/17: 0%->15¦11/9/17: 15%->50¦15/12/17: 50%->79¦16/3/18: 79%->99¦16/3/18: FCD:03/18->06/18¦7/6/18: 99%->100
- 3522: Previously known as "wearable devices"¦9/6/16: 0%->100¦9/6/16: WID:SP-160231->SP-160371¦15/12/17: moved Rel-14->Rel-15
- 3526: 16/3/18: 0%->100
- 3527: 7/6/18: 0%->100
- 3528: 1/12/16: 0%->5¦6/3/17: 5%->50¦7/6/17: 50%->60¦11/9/17: 60%->100
- 3529: 1/12/16: 0%->5¦6/3/17: 5%->50¦7/6/17: 50%->60¦11/9/17: 60%->100¦15/12/17: rapporteur changed
- 3530: 15/12/17: 26.959 added;¦15/12/17: 0%->50¦16/3/18: 50%->75¦16/3/18: FCD:03/18->06/18¦7/6/18: 75%->100
- 3531: 08/09/17: Moved from Rel-14
- 3532: 1/12/16: 0%->10¦6/3/17: 10%->30¦7/6/17: 30%->90¦11/9/17: 90%->100
- 3534: 15/12/17: 0%->100
- 3535: 15/12/17: acronym corrected to USOS-CT as per the approved WID¦18/12/17: 0%->60¦16/3/18: 60%->100

| ID | WBS | Task | Duration | Start | Finish | Complete | Constraint | Resources | Work | Actual work | Acronym | PCG approved | WI rapporteur name | WI rapporteur e-mail | Release | TSG approved | TSG stopped |
| --- | --- | --- | --- | --- | --- | --- | --- | --- | --- | --- | --- | --- | --- | --- | --- | --- | --- |
| 3536 | 1466 | **Mobile Communication System for Railways** | 763.12d? | 2016-06-09 A | 2018-06-15 A | 100% |  |  | 7440h | 7440h | MONASTERY | 38 | Merkel, Juergen, Nokia | juergen.merkel@nokia.com | Rel-15 | 75 |  |
| 3537 | 1466.1 | Study on Future Railway Mobile Communication System | 267d? | 2016-06-09 A | 2017-06-15 A | 100% | finish no earlier than 2017-06-15 | S1 | 2136h | 2136h | FS_FRMCS | 37 | Merkel, Juergen | Merkel, Juergen - Nokia Networks | Rel-15 | 72 |  |
| 3538 | 1466.2 | Study on Application Architecture for the Future Railway Mobile Communication System (stage 2) | 205d? | 2017-03-03 A | 2017-12-14 A | 100% | finish no earlier than 2017-12-14 | S6 | 1640h | 1640h | FS_FRMCS_ARCH | 38 | Oettl, Martin, Nokia | martin(dot)oettl(at)nokia(dot)com | Rel-15 | 75 |  |
| 3539 | 1466.3 | Stage 1 of MONASTERY | 76d? | 2017-03-02 A | 2017-06-15 A | 100% | finish no earlier than 2017-06-15 | S1 | 608h | 608h | MONASTERY | 38 | Merkel, Juergen, Nokia | juergen.merkel@nokia.com | Rel-15 | 75 |  |
| 3540 | 1466.4 | Stage 2 of MONASTERY | 71d? | 2017-09-08 A | 2017-12-15 A | 100% | finish no earlier than 2017-12-15 | S6 | 568h | 568h | MONASTERY | 39 | Oettl, Martin, Nokia | martin(dot)oettl(at)nokia(dot)com | Rel-15 | 77 |  |
| 3541 | 1466.5 | **Stage 3 of MONASTERY** | 95.25d? | 2018-03-16 A | 2018-06-15 A | 100% |  | ct | 2112h | 2112h | MONASTERY | 40 | Leis, Peter (Nokia) | peter(dot)leis(at)nokia(dot)com | Rel-15 | 79 |  |
| 3542 | 1466.5.1 | CT1 aspects of MONASTERY | 66d? | 2018-03-16 A | 2018-06-15 A | 100% | finish no earlier than 2018-06-15 | C1 | 528h | 528h | MONASTERY | 40 | Leis, Peter (Nokia) | peter(dot)leis(at)nokia(dot)com | Rel-15 | 79 |  |
| 3543 | 1466.5.2 | CT3 aspects of MONASTERY | 66d? | 2018-03-16 A | 2018-06-15 A | 100% | finish no earlier than 2018-06-15 | C3 | 528h | 528h | MONASTERY | 40 | Leis, Peter (Nokia) | peter(dot)leis(at)nokia(dot)com | Rel-15 | 79 |  |
| 3544 | 1466.5.3 | Stopped - CT6 aspects of MONASTERY | 66d? | 2018-03-16 A | 2018-06-15 A | 100% | finish no earlier than 2018-06-15 | C6 | 528h | 528h | MONASTERY | 40 | Leis, Peter (Nokia) | peter(dot)leis(at)nokia(dot)com | Rel-15 | 79 | 84 |
| 3545 | 1466.6 | Security Architecture of MONASTERY | 47d? | 2018-01-11 A | 2018-03-16 A | 100% | finish no earlier than 2018-06-15 | S3 | 376h | 376h | MONASTERY_SEC | 40 | Woodward, Tim, Motorola Solutions |  | Rel-15 | 79 |  |
| 3546 | 1467 | **PS Data Off Phase 2** | 486.75d? | 2017-03-02 A | 2018-06-14 A | 100% |  |  | 10296h | 10296h | PS_DATA_OFF2 | 38 | Murhammer, Leopold, Deutsche Telekom AG | leopold.murhammer@t-mobile.at | Rel-15 | 75 |  |
| 3547 | 1467.1 | Stage 2 of PS Data Off Phase 2 | 207d? | 2017-03-02 A | 2017-12-15 A | 100% | finish no earlier than 2017-12-15 | S2 | 1656h | 1656h | PS_DATA_OFF2 | 38 | Murhammer, Leopold, Deutsche Telekom AG | leopold.murhammer@t-mobile.at | Rel-15 | 75 |  |
| 3548 | 1467.2 | **Stage 3 of PS Data Off Phase 2** | 391.5d? | 2017-06-02 A | 2018-06-14 A | 100% |  | ct | 8640h | 8640h | PS_DATA_OFF2-CT | 39 | Herrero Veron, Christian (Huawei) | Christian.Herrero at huawei.com | Rel-15 | 76 |  |
| 3549 | 1467.2.1 | CT1 aspects of PS Data Off Phase 2 | 270d? | 2017-06-02 A | 2018-06-14 A | 100% | finish no earlier than 2018-06-14 | C1 | 2160h | 2160h | PS_DATA_OFF2-CT | 39 | Herrero Veron, Christian (Huawei) | Christian.Herrero at huawei.com | Rel-15 | 76 |  |
| 3550 | 1467.2.2 | CT4 aspects of PS Data Off Phase 2 | 270d? | 2017-06-02 A | 2018-06-14 A | 100% | finish no earlier than 2018-06-14 | C4 | 2160h | 2160h | PS_DATA_OFF2-CT | 39 | Herrero Veron, Christian (Huawei) | Christian.Herrero at huawei.com | Rel-15 | 76 |  |
| 3551 | 1467.2.3 | CT6 aspects of PS Data Off Phase 2 | 270d? | 2017-06-02 A | 2018-06-14 A | 100% | finish no earlier than 2018-06-14 | C6 | 2160h | 2160h | PS_DATA_OFF2-CT | 39 | Herrero Veron, Christian (Huawei) | Christian.Herrero at huawei.com | Rel-15 | 76 |  |
| 3552 | 1468 | **Northbound APIs for SCEF – SCS/AS Interworking** | 487.75d? | 2017-03-02 A | 2018-06-15 A | 100% |  |  | 10312h | 10312h | NAPS | 38 | Vaidya, Maulik, Huawei | Maulik.vaidya@huawei.com | Rel-15 | 75 |  |
| 3553 | 1468.1 | Stage 2 of NAPS | 142d? | 2017-03-02 A | 2017-09-15 A | 100% | start no earlier than 2017-03-02 | S2 | 1136h | 1136h | NAPS | 38 | Zhu Fenqin, Huawei | zhufenqin@huawei.com | Rel-15 | 75 |  |
| 3554 | 1468.2 | **Stage 3 of NAPS** | 391.5d? | 2017-06-02 A | 2018-06-14 A | 100% |  | C3 | 6480h | 6480h | NAPS-CT | 40 | Yan, Yali, Huawei, | yanyali@huawei.com | Rel-15 | 78 |  |
| 3555 | 1468.2.1 | CT3 aspects of NAPS | 270d? | 2017-06-02 A | 2018-06-14 A | 100% | finish no earlier than 2018-06-14 | C3 | 2160h | 2160h | NAPS-CT | 39 | Yan, Yali, Huawei, | yanyali@huawei.com | Rel-15 | 76 |  |
| 3556 | 1468.2.2 | CT4 aspects of NAPS | 270d? | 2017-06-02 A | 2018-06-14 A | 100% | finish no earlier than 2018-06-14 | C4 | 2160h | 2160h | NAPS-CT | 40 | Yan, Yali, Huawei, | yanyali@huawei.com | Rel-15 | 78 |  |
| 3557 | 1468.3 | Security aspects of NAPS | 136d? | 2017-09-08 A | 2018-03-16 A | 100% | finish no earlier than 2018-03-16 | S3 | 1088h | 1088h | NAPS-Sec | 39 | Zhao, Xuwen, Huawei | zhaoxuwen@huawei.com | Rel-15 | 77 |  |
| 3558 | 1468.4 | Carging aspects of NAPS | 201d? | 2017-09-08 A | 2018-06-15 A | 100% | finish no earlier than 2018-06-15 | S5 | 1608h | 1608h | NAPS-CH | 39 | Chen, Shan, Huawei | chenshan@huawei.com | Rel-15 | 76 |  |
| 3559 | 1469 | **Common API Framework for 3GPP Northbound APIs** | 479.5d? | 2017-03-10 A | 2018-06-15 A | 100% |  |  | 3216h | 3216h | CAPIF | 39 | Suresh Chitturi, Samsung | s.chitturi@samsung.com | Rel-15 | 77 |  |
| 3560 | 1469.1 | Study on CAPIF | 135d? | 2017-03-10 A | 2017-09-14 A | 100% | finish no earlier than 2017-09-14 | S6 | 1080h | 1080h | FS_CAPIF | 38 | Suresh Chitturi, Samsung | s.chitturi@samsung.com | Rel-15 | 75 |  |
| 3561 | 1469.2 | Stage 2 of CAPIF | 71d? | 2017-09-08 A | 2017-12-15 A | 100% | finish no earlier than 2017-12-15 | S6 | 568h | 568h | CAPIF | 39 | Suresh Chitturi, Samsung | s.chitturi@samsung.com | Rel-15 | 77 |  |
| 3562 | 1469.3 | Stage 3 of CAPIF | 66d? | 2018-03-16 A | 2018-06-15 A | 100% | finish no earlier than 2018-06-15 | C3 | 528h | 528h | CAPIF-CT | 40 | Nishant Gupta, Samsung | nishant.gup@samsung.com | Rel-15 | 79 |  |
| 3563 | 1469.4 | Security aspects of CAPIF | 130d? | 2017-12-15 A | 2018-06-14 A | 100% | finish no earlier than 2018-06-14 | S3 | 1040h | 1040h | CAPIF-Sec | 40 | Rajavelsamy Rajadurai, Samsung | rajvel{@]samsung.com | Rel-15 | 78 |  |

Notes:
- 3537: 19/9/16: 0%->25¦6/10/16: 22.989 added¦1/12/16: 25%->40¦1/12/16: WID:SP-160371->SP-160903¦9/12/16: FCD:12/16->3/201. WID was in SP-160903¦2/3/17: 40%->80¦2/3/17: FCD:03/17->06/17¦7/6/17: 80%->100 / Impacted TSs and TRs: 22.989
- 3538: 21/3/17: added impacted TR¦7/6/17: 0%->10¦11/9/17: 10%->50¦15/12/17: 50%->100 / Impacted TSs and TRs: new 23.790
- 3539: 7/6/17: 0%->10¦8/9/17: WID:SP-170163->SP-170697¦11/9/17: 10%->100 / Impacted TSs and TRs: 22.280; 22.179
- 3540: 14/9/17: SA6 and not SA2¦15/12/17: 0%->100 / Impacted TSs and TRs: 23.280; 23.379
- 3541: 10/9/18: WID:CP-180097->CP-182202
- 3542: 16/3/18: 0%->40¦7/6/18: 40%->85¦10/9/18: 85%->100 / Impacted TSs and TRs: 24.379; 24.380; 24.481; 24.483; 24.484
- 3543: 10/9/18: 0%->100 / Impacted TSs and TRs: 29.165
- 3544: 10/9/18: 0%->100 / Impacted TSs and TRs: 31.102; 31.103
- 3545: 16/3/18: 0%->100 / Impacted TSs and TRs: 33.180
- 3547: 7/6/17: 0%->10¦11/9/17: 10%->85¦15/12/17: 85%->100¦15/12/17: FCD:09/17->12/17
- 3548: 18/12/17: WID:CP-171104->CP-173162¦7/6/18: WID:CP-173162->CP-181082
- 3549: 7/6/18: 0%->100 / Impacted TSs and TRs: 24.008; 24.301; 27.007; 24.229; 24.368; 24.167; 24.173; 24.275; 24.341; 24.390; 24.391
- 3550: 15/12/17: 0%->100 / Impacted TSs and TRs: 29.272; 29.274; 29.328; 29.329; 29.228; 29.229; 23.008
- 3551: 7/6/18: 0%->100 / Impacted TSs and TRs: 31.102; 31.103; 31.111
- 3552: 6/3/17: 0%->10
- 3553: 6/3/17: 0%->10¦7/6/17: 10%->85¦30/6/17: 29.122 added;¦11/9/17: 85%->100¦15/12/17: rapoprteur changed / Impacted TSs and TRs: 29.122
- 3554: 5/6/17: 0%->25¦8/9/17: WID:CP-171143->CP-172057¦11/9/17: 25%->40¦11/9/17: 40%->90. 18/12/17: WID corrected¦18/12/17: WID:CP-171143 ->CP-173112 / Impacted TSs and TRs: 29.336; 29.128; 29.230
- 3555: 5/6/17: 0%->25¦8/9/17: WID:CP-171143->CP-172057¦11/9/17: 25%->40¦11/9/17: 40%->90¦15/12/17: 90%->65. 18/12/17: WID corrected¦16/3/18: 65%->72¦7/6/18: 72%->85¦7/6/18: 85%->95¦10/9/18: 95%->100 / Impacted TSs and TRs: 29.336; 29.128; 29.230
- 3556: 7/6/18: 95%->100
- 3557: 15/12/17: 0%->60¦16/3/18: 60%->100 / Impacted TSs and TRs: 33.187
- 3558: 30/6/17: 32.254 added;¦11/9/17: 0%->10¦15/12/17: 10%->20¦16/3/18: 20%->50¦7/6/18: 50%->100 / Impacted TSs and TRs: New TS; impact 32.240; 32.298; 32.299; 32.254
- 3559: 15/12/17: 23.222 added; / Impacted TSs and TRs: New; 23.222
- 3560: 21/3/17: added impacted TR¦7/6/17: 0%->35¦8/6/17: WID:SP-170279->SP-170405¦11/9/17: 35%->70¦15/12/17: 70%->100 / Impacted TSs and TRs: new 23.722
- 3561: 15/12/17: 0%->95¦16/3/18: 95%->100 / Impacted TSs and TRs: New
- 3562: 16/3/18: 0%->10¦27/3/18: 29.222 added¦19/4/18: CAPIF->CAPIF-CT¦7/6/18: 10%->35¦7/6/18: 35%->85¦10/9/18: 85%->100 / Impacted TSs and TRs: 29.122; 29.116; 29.222
- 3563: 16/3/18: 0%->40¦7/6/18: 40%->100

| ID | WBS | Task | Duration | Start | Finish | Complete | Constraint | Resources | Work | Actual work | Acronym | PCG approved | WI rapporteur name | WI rapporteur e-mail | Release | TSG approved | Status Report |
| --- | --- | --- | --- | --- | --- | --- | --- | --- | --- | --- | --- | --- | --- | --- | --- | --- | --- |
| 3564 | 1470 | **Management and orchestration of 5G networks and network slicing** | 853.12d? | 2016-06-13 A | 2018-09-14 A | 100% |  | S5 | 23664h | 23664h | NETSLICE | 39 | Jan Groenendijk, Ericsson | jan<dot>groenendijk<at>ericsson<dot>com | Rel-15 | 76 |  |
| 3565 | 1470.1 | General aspects of NETSLICE | 591d? | 2016-06-13 A | 2018-09-14 A | 100% | finish no earlier than 2018-09-14 | S5 | 4728h | 4728h | NETSLICE | 39 | Jan Groenendijk, Ericsson | jan<dot>groenendijk<at>ericsson<dot>com | Rel-15 | 76 |  |
| 3566 | 1470.2 | Study on management and orchestration of network slicing for next generation network | 328d? | 2016-06-13 A | 2017-09-12 A | 100% | finish no earlier than 2017-09-12 | S5 | 2624h | 2624h | FS_MONETS | 37 | Ericsson , Robert Petersen |  | Rel-15 | 72 |  |
| 3567 | 1470.3 | Study on security aspect of 5G Network Slicing Provisioning | 201d? | 2017-09-08 A | 2018-06-15 A | 100% | finish no earlier than 2018-06-15 | S3 | 1608h | 1608h | FS_NETSLICE_MGT_Sec | 39 | SA3: Huawei | lei.zhongding@huawei.com | Rel-15 | 77 |  |
| 3568 | 1470.4 | Provisioning of network slicing for 5G networks and services | 335d? | 2017-06-05 A | 2018-09-14 A | 100% | finish no earlier than 2018-09-14 | S5 | 2680h | 2680h | NETSLICE-PRO_NS | 39 | Zhang Kai, Huawei | kai.zhangkai@huawei.com | Rel-15 | 76 |  |
| 3569 | 1470.5 | Network Resource Model (NRM) for 5G networks and network slicing | 196d? | 2017-12-15 A | 2018-09-14 A | 100% | finish no earlier than 2018-09-14 | S5 | 1568h | 1568h | NETSLICE-5GNRM | 40 | Nokia (Jing Ping | jing.ping@nokia-sbell.com | Rel-15 | 78 |  |
| 3570 | 1470.6 | Performance Assurance for 5G networks including network slicing | 196d? | 2017-12-15 A | 2018-09-14 A | 100% | finish no earlier than 2018-09-14 | S5 | 1568h | 1568h | NETSLICE-ADPM5G | 40 | Yizhi Yao, Intel Corporation | yizhi dot yao at intel dot com | Rel-15 | 78 |  |
| 3571 | 1470.7 | Management and virtualization aspects of 5G networks | 196d? | 2017-12-15 A | 2018-09-14 A | 100% | finish no earlier than 2018-09-14 | S5 | 1568h | 1568h | NETSLICE-MNFV5G | 40 | Joey Chou, Intel | joey<dot>chou<at>intel<dot>com | Rel-15 | 78 |  |
| 3572 | 1470.8 | 5G Trace management | 125d? | 2017-12-15 A | 2018-06-07 A | 100% | finish no earlier than 2018-06-07 | S5 | 1000h | 1000h | NETSLICE-5GTRACE | 40 | Nokia (Anatoly Andrianov | anatoly.andrianov@nokia.com | Rel-15 | 78 |  |
| 3573 | 1470.9 | **CT aspects of 5G Trace management** | 1d? | 2018-09-06 A | 2018-09-06 A | 100% |  | ct | 24h | 24h | NETSLICE-5GTRACE-CT | 41 | Landais, Bruno, Nokia | bruno.landais@nokia.com | Rel-15 | 81 |  |
| 3574 | 1470.9.1 | CT3 aspects of 5G Trace management | 1d? | 2018-09-06 A | 2018-09-06 A | 100% | start no earlier than 2018-09-06 | C3 | 8h | 8h | NETSLICE-5GTRACE-CT | 41 | Landais, Bruno, Nokia | bruno.landais@nokia.com | Rel-15 | 81 |  |
| 3575 | 1470.9.2 | CT4 aspects of 5G Trace management | 1d? | 2018-09-06 A | 2018-09-06 A | 100% | start no earlier than 2018-09-06 | C4 | 8h | 8h | NETSLICE-5GTRACE-CT | 41 | Landais, Bruno, Nokia | bruno.landais@nokia.com | Rel-15 | 81 |  |
| 3576 | 1470.10 | Fault Supervision for 5G networks and network slicing | 196d? | 2017-12-15 A | 2018-09-14 A | 100% | finish no earlier than 2018-09-14 | S5 | 1568h | 1568h | NETSLICE-FS5G | 40 | Zhu Weihong, ZTE | zhu.weihong@zte.com.cn | Rel-15 | 78 |  |
| 3577 | 1471 | **Policy and Charging for Volume Based Charging** | 582d? | 2016-12-01 A | 2018-06-15 A | 100% |  |  | 7584h | 7584h | PC_VBC | 40 |  |  | Rel-15 | 78 |  |
| 3578 | 1471.1 | **Study on Policy and Charging for Volume Based Charging** | 393.5d? | 2016-12-01 A | 2017-12-15 A | 100% |  | C3 | 6528h | 6528h | FS_PC_VBC | 38 | Huang, Zhenning, China Mobile | huangzhenning <at> chinamobile <dot> com | Rel-15 | 74 |  |
| 3579 | 1471.1.1 | CT3 aspects of FS_PC_VBC | 272d? | 2016-12-01 A | 2017-12-15 A | 100% | finish no earlier than 2017-12-15 | C3 | 2176h | 2176h | FS_PC_VBC | 38 | Huang, Zhenning, China Mobile | huangzhenning <at> chinamobile <dot> com | Rel-15 | 74 |  |
| 3580 | 1471.1.2 | CT1 aspects of FS_PC_VBC | 272d? | 2016-12-01 A | 2017-12-15 A | 100% | finish no earlier than 2017-12-15 | C1 | 2176h | 2176h | FS_PC_VBC | 38 | Huang, Zhenning, China Mobile | huangzhenning <at> chinamobile <dot> com | Rel-15 | 74 |  |
| 3581 | 1471.2 | CT1 aspects of PV_VBC | 66d? | 2018-03-16 A | 2018-06-15 A | 100% | finish no earlier than 2018-06-15 | C1 | 528h | 528h | PC_VBC | 40 | Huang Zhenning (China Mobile) | huangzhenning (at) chinamobile (dot) com | Rel-15 | 79 |  |
| 3582 | 1471.3 | CT3 aspects of PV_VBC | 66d? | 2018-03-16 A | 2018-06-15 A | 100% | finish no earlier than 2018-06-15 | C3 | 528h | 528h | PC_VBC | 40 | Huang Zhenning (China Mobile) | huangzhenning (at) chinamobile (dot) com | Rel-15 | 79 |  |
| 3583 | 1472 | Framework for Live Uplink Streaming | 269d? | 2017-06-05 A | 2018-06-14 A | 100% | finish no earlier than 2018-06-14 | S4 | 2152h | 2152h | FLUS | 39 | Park, Kyungmo, SK Telecom | kyungmo.park@sk.com | Rel-15 | 76 |  |
| 3584 | 1473 | Self-Organizing Networks (SON) for Active Antenna System (AAS) deployment management | 201d? | 2017-09-08 A | 2018-06-15 A | 100% | finish no earlier than 2018-06-15 | S5 | 1608h | 1608h | OAM_SON_AAS | 39 | Nokia (Weixing Wang) | weixing.wang@nokia-sbell.com | Rel-15 | 77 |  |
| 3585 | 1474 | Server and Network Assisted DASH for 3GPP Multimedia Services | 206d? | 2016-12-01 A | 2017-09-14 A | 100% | finish no earlier than 2017-09-14 | S4 | 1648h | 1648h | SAND | 38 | Ozgur Oyman, Intel | ozgur.oyman@intel.com | Rel-15 | 74 | SP-170687 |
| 3586 | 1475 | SAND for MBMS | 201d? | 2017-09-08 A | 2018-06-15 A | 100% | finish no earlier than 2018-06-15 | S4 | 1608h | 1608h | SAND4M | 39 | Thomas Stockhammer, Qualcomm Incorporated | tsto@qti.qualcomm.com | Rel-15 | 77 |  |
| 3587 | 1476 | Management Enhancement for EPC CUPS | 196d? | 2017-12-15 A | 2018-09-14 A | 100% | finish no earlier than 2018-09-14 | S5 | 1568h | 1568h | ME_CUPS | 40 | Huawei (ZHU, Lei | lei.zhu@huawei.com | Rel-15 | 78 |  |
| 3588 | 1477 | Enhanced QoE Reporting for MTSI | 204d? | 2017-06-05 A | 2018-03-15 A | 100% | finish no earlier than 2018-03-15 | S4 | 1632h | 1632h | EQoE_MTSI | 39 | Gunnar Heikkilä, Ericsson LM | gunnar.heikkila@ericsson.com | Rel-15 | 76 |  |

Notes:
- 3564: 21/12/17: WID:SP-170586->SP-170960. Name changed from "Management of Network Slicing in Mobile Networks, Concepts, Use cases and Requirements"¦27/3/18: 32.159 added;¦6/8/18: 32.159 added;¦8/8/18: WID:SP-170960->SP 180124¦2/10/18: WID:SP 180124->SP- / Impacted TSs and TRs: 32.101; 32.103; new; 32.159; 32.159
- 3565: 21/12/17: created from the Feature level, since SP-170960 contains its own specs and completions¦16/3/18: 46%->60¦7/6/18: 60%->85¦7/6/18: FCD:06/18->09/18¦8/8/18: WID:SP-170960->SP 180124¦10/9/18: 85%->100 / Impacted TSs and TRs: 32.101; 32.103; 28.530
- 3566: 28/7/16: 28.801 added¦19/9/16: 0%->10¦1/12/16: 10%->25¦6/3/17: FCD:03/17->06/17¦6/3/17: 25%->60¦21/3/17: moved from rel-14¦7/6/17: FCD:06/17->09/17¦7/6/17: 60%->90¦11/9/17: 90%->100 / Impacted TSs and TRs: 32.8xx; 28.801
- 3567: 11/9/17: 0%->5¦15/12/17: 33.811 added;¦15/12/17: 5%->20. Acronym corrected.¦16/3/18: 20%->30¦7/6/18: 30%->100 / Impacted TSs and TRs: 33.811
- 3568: 15/12/17: 0%->15¦21/12/17: WID:SP-170580->SP-170955¦16/3/18: 15%->40¦27/3/18: 28.532 added;¦7/6/18: 40%->80¦7/6/18: FCD:06/18->09/18¦10/9/18: 80%->100¦2/10/18: WID:SP-170955->SP-180818 / Impacted TSs and TRs: 28.531
- 3569: 16/3/18: 0%->25¦7/6/18: 25%->60¦7/6/18: FCD:06/18->09/18¦10/9/18: 60%->100¦2/10/18: WID:SP-170956->SP-180812 / Impacted TSs and TRs: 28.657; 28.658; 28.659; 28.707; 28.708; 28.709
- 3570: 16/3/18: 0%->10¦7/6/18: 10%->50¦7/6/18: FCD:06/18->09/18¦10/9/18: 50%->100¦2/10/18: WID:SP-170957->SP-180814 / Impacted TSs and TRs: 32.404
- 3571: 16/3/18: 0%->25¦7/6/18: 25%->75¦7/6/18: FCD:06/18->09/18¦10/9/18: 75%->100 / Impacted TSs and TRs: 28.500; 28.510; 28.511; 28.512; 28.513; 28.515; 28.516; 28.517; 28.518; 28.520; 28.521; 28.522; 28.523; 28.525; 28.526; 28.527; 28.528
- 3572: 7/6/18: 0%->100 / Impacted TSs and TRs: 32.421; 32.422; 32.423; 32.441; 32.442; 32.446
- 3574: 10/9/18: 0%->100 / Impacted TSs and TRs: 29.507; 29.512
- 3575: 10/9/18: 0%->100 / Impacted TSs and TRs: 29.502; 29.503; 29.505; 29.509; 29.518; 29.540; 29.571; 29.244; 29.274
- 3576: 16/3/18: 0%->20¦7/6/18: 20%->60¦7/6/18: FCD:06/18->09/18¦10/9/18: 60%->100¦2/10/18: WID:SP-170961->SP-180817 / Impacted TSs and TRs: 28.545
- 3578: 6/3/17: 0%->30¦21/3/17: 29.827 added;¦5/6/17: 30%->60¦8/9/17: WID:CP-160822->CP-172058¦11/9/17: FCD:06/17->12/17 / Impacted TSs and TRs: 29.827
- 3579: 6/3/17: 0%->30¦21/3/17: 29.827 added;¦5/6/17: 30%->60¦8/9/17: WID:CP-160822->CP-172058¦11/9/17: FCD:06/17->12/17¦15/12/17: 60%->61¦15/12/17: 61%->100 / Impacted TSs and TRs: 29.827
- 3580: 15/12/17: 0%->100 / Impacted TSs and TRs: 29.827
- 3581: 7/6/18: 0%->100 / Impacted TSs and TRs: 24.605; 24.147
- 3582: 7/6/18: 0%->100 / Impacted TSs and TRs: 29.212; 29.213; 29.214
- 3583: 30/6/17: 26.238 added;¦11/9/17: 0%->10¦15/12/17: 10%->85¦15/12/17: FCD:12/17->06/18¦21/12/17: WID:SP-170576->SP-170824¦16/3/18: 85%->90¦7/6/18: 90%->100 / Impacted TSs and TRs: New TS; 26.238
- 3584: 15/12/17: 0%->80¦10/9/18: 80%->100 / Impacted TSs and TRs: 28.627; 28.628; 28.629; 28.658; 28.659
- 3585: 3/3/17: WID:SP-160779->SP-170031¦6/3/17: 0%->15¦7/6/17: 15%->60¦11/9/17: 60%->100 / Impacted TSs and TRs: 26.247; 26.233
- 3586: 15/12/17: 0%->50¦15/12/17: FCD:12/17->03/18¦21/12/17: WID:SP-170608->SP-170827¦16/3/18: 50%->60¦16/3/18: FCD:03/18->06/18¦7/6/18: 60%->100 / Impacted TSs and TRs: 26.247; 26.346; 26.347; TR26.946
- 3587: ASN.1-type of WID, hence later than St3, indpt of CUPS Rel-14¦16/3/18: 0%->5¦7/6/18: 5%->60¦10/9/18: 60%->100 / Impacted TSs and TRs: 32.426; 32.455; 28.658; 28.707; 28.708; 28.709
- 3588: 11/9/17: 0%->10¦15/12/17: 10%->80¦16/3/18: 80%->100 / Impacted TSs and TRs: 26.114

| ID | WBS | Task | Duration | Start | Finish | Complete | Constraint | Resources | Work | Actual work | Acronym | PCG approved | WI rapporteur name | Release | TSG approved | WI rapporteur e-mail | TSG stopped | Status Report |
| --- | --- | --- | --- | --- | --- | --- | --- | --- | --- | --- | --- | --- | --- | --- | --- | --- | --- | --- |
| 3589 | 1478 | **Enhanced Calling Name Service** | 565.5d? | 2016-09-15 A | 2018-03-14 A | 100% |  |  | 5424h | 5424h | eCNAM | 37 | Hala Mowafy, Ericsson | Rel-15 | 73 |  |  |  |
| 3590 | 1478.1 | Stage 1 of eCNAM | 66d? | 2016-09-15 A | 2016-12-15 A | 100% | finish no earlier than 2016-12-15 | S1 | 528h | 528h | eCNAM | 37 | Hala Mowafy, Ericsson | Rel-15 | 73 |  |  |  |
| 3591 | 1478.2 | **CT aspects of eCNAM** | 296.25d? | 2017-06-02 A | 2018-03-14 A | 100% |  | ct | 4896h | 4896h | eCNAM-CT | 39 | Mowafy, Hala. Ericsson | Rel-15 | 76 | hala.mowafy@ericsson.com |  |  |
| 3592 | 1478.2.1 | CT1 aspects of eCNAM | 204d? | 2017-06-02 A | 2018-03-14 A | 100% | finish no earlier than 2018-03-14 | C1 | 1632h | 1632h | eCNAM-CT | 39 | Mowafy, Hala. Ericsson | Rel-15 | 76 | hala.mowafy@ericsson.com |  |  |
| 3593 | 1478.2.2 | CT3 aspects of eCNAM | 204d? | 2017-06-02 A | 2018-03-14 A | 100% | finish no earlier than 2018-03-14 | C3 | 1632h | 1632h | eCNAM-CT | 39 | Mowafy, Hala. Ericsson | Rel-15 | 76 | hala.mowafy@ericsson.com |  |  |
| 3594 | 1479 | Enhancement of background data transfer | 38d? | 2017-01-16 A | 2017-03-08 A | 100% | finish no earlier than 2017-03-08 | S1 | 304h | 304h | eBT | 38 | Atsushi Minokuchi, NTT DOCOMO | Rel-15 | 75 | minokuchi at nttdocomo dot com |  |  |
| 3595 | 1480 | **Stage-3 SAE Protocol Development - Phase 6** | 395.75d? | 2017-06-02 A | 2018-06-18 A | 100% |  | C1 | 8704h | 8704h | SAES6 | 39 | Interdigital, Aghili, Behrouz | Rel-15 | 76 | Behrouz.aghili@interdigital.com |  |  |
| 3596 | 1480.1 | SAES6 CS Fallback in EPS | 272d? | 2017-06-02 A | 2018-06-18 A | 100% | start no earlier than 2017-06-02 | C1 | 2176h | 2176h | SAES6-CSFB | 39 | Interdigital, Aghili, Behrouz | Rel-15 | 76 | Behrouz.aghili@interdigital.com |  |  |
| 3597 | 1480.2 | SAES6 for support for non-3GPP accesses | 272d? | 2017-06-02 A | 2018-06-18 A | 100% | start no earlier than 2017-06-02 | C1 | 2176h | 2176h | SAES6-non3GPP | 39 | Interdigital, Aghili, Behrouz | Rel-15 | 76 | Behrouz.aghili@interdigital.com |  |  |
| 3598 | 1480.3 | SAE Protocol Development (Stage 3) - Phase 6 | 272d? | 2017-06-02 A | 2018-06-18 A | 100% | start no earlier than 2017-06-02 | C1 | 2176h | 2176h | SAES6 | 37 |  | Rel-15 | 72 |  |  |  |
| 3599 | 1481 | Security Assurance Specification for eNB network product class | 322d? | 2016-09-19 A | 2017-12-12 A | 100% | finish no earlier than 2017-12-12 | S3 | 2576h | 2576h | SCAS_eNB | 37 | Marcus Wong, Huawei Technologies | Rel-15 | 73 | mwong@huawei.com |  |  |
| 3600 | 1482 | Security Assurance Specification for PGW network product class | 389d? | 2016-06-17 A | 2017-12-12 A | 100% | finish no earlier than 2017-12-12 | S3 | 3112h | 3112h | SCAS_PGW | 37 | Peng Jin, China Mobile | Rel-15 | 72 | pengjin@chinamobile.com |  |  |
| 3601 | 1483 | HPLMN Radio Access Technology deployment Optimisation in Network Selection | 76d? | 2017-03-02 A | 2017-06-15 A | 100% | finish no earlier than 2017-06-15 | S1 | 608h | 608h | HORNS | 38 | Eddy Hall, Qualcomm Incorporated | Rel-15 | 75 | edhall@qti.qualcomm.com |  |  |
| 3602 | 1484 | **IMS Stage-3 IETF Protocol Alignment** | 1094.75d? | 2017-06-02 A | 2020-04-23 A | 100% |  | ct | 21336h | 21336h | IMSProtoc9 | 39 | Dr. Belling, Thomas, Nokia | Rel-15 | 76 | Thomas.Belling@nokia.com |  |  |
| 3603 | 1484.1 | CT1 aspects of IMS Stage-3 IETF Protocol Alignment | 269d? | 2017-06-02 A | 2018-06-13 A | 100% | finish no earlier than 2018-06-13 | C1 | 2152h | 2152h | IMSProtoc9 | 39 | Dr. Belling, Thomas, Nokia | Rel-15 | 76 | Thomas.Belling@nokia.com |  |  |
| 3604 | 1484.2 | **(IETF) CT1 aspects of IMS Stage-3 IETF Protocol Alignment** | 1094.75d? | 2017-06-02 A | 2020-04-23 A | 100% |  | C1-IETF | 10992h | 10992h | IMSProtoc9 | 39 | Dr. Belling, Thomas, Nokia | Rel-15 | 76 | Thomas.Belling@nokia.com |  |  |
| 3605 | 1484.2.1 | (IETF) Content-ID header field in SIP (draft-ietf-sipcore-content-id) | 271d? | 2017-06-02 A | 2018-06-15 A | 100% | finish no earlier than 2018-06-15 | C1-IETF | 2168h | 2168h | IMSProtoc9 | 40 | Christer Holmberg | Rel-15 | 78 | christer.holmberg@ericsson.com |  |  |
| 3606 | 1484.2.2 | (IETF) P-Visited-Network header updated (was: draft-jesske-update-p-visited-network ) | 271d? | 2017-06-02 A | 2018-06-15 A | 100% | finish no earlier than 2018-06-15 | C1-IETF | 2168h | 2168h | IMSProtoc9 | 40 | Michael KREIPL, Deutsche Telekom | Rel-15 | 78 | michael(dot)kreipl(at)telekom(dot)de |  |  |
| 3607 | 1484.2.3 | (IETF) Update to Private Header Field P-Visited-Network-ID in Session Initiation Protocol (SIP) Requests and Responses (draft-jesske-update-p-visited-network) | 77d | 2020-01-08 A | 2020-04-23 A | 100% | start no earlier than 2020-01-08 | C1-IETF | 616h | 616h | IMSProtoc8 | 44 | Michael KREIPL, Deutsche Telekom | Rel-15 | 87 | michael(dot)kreipl(at)telekom(dot)de |  |  |
| 3608 | 1484.3 | CT3 aspects of IMS Stage-3 IETF Protocol Alignment | 269d? | 2017-06-02 A | 2018-06-13 A | 100% | finish no earlier than 2018-06-13 | C3 | 2152h | 2152h | IMSProtoc9 | 39 | Dr. Belling, Thomas, Nokia | Rel-15 | 76 | Thomas.Belling@nokia.com |  |  |
| 3609 | 1485 | **Lawful Interception Rel-15** | 767.5d? | 2017-03-02 A | 2019-03-12 A | 100% |  |  | 7448h | 7448h | LI15 | 38 | Alex Leadbeater, BT | Rel-15 | 75 | alex.leadbeater@bt.com |  |  |
| 3610 | 1485.1 | Stopped - Study on R15 Lawful Interception Service | 402d? | 2017-03-02 A | 2018-09-14 A | 100% | finish no earlier than 2018-09-14 | S3LI | 3216h | 3216h | FS_15LIS | 38 | Gerry McQuaid, Vodafone | Rel-15 | 75 | Gerald.McQuaid@vodafone.com | 82 |  |
| 3611 | 1485.2 | Normative work on Lawful Interception Rel-15 | 529d? | 2017-03-02 A | 2019-03-12 A | 100% | finish no earlier than 2019-03-12 | S3LI | 4232h | 4232h | LI15 | 38 | Alex Leadbeater, BT | Rel-15 | 75 | alex.leadbeater@bt.com |  |  |
| 3612 | 1486 | **DL interference mitigation for UMTS** | 96.25d? | 2017-03-15 A | 2017-06-15 A | 100% |  | R2 | 1072h | 1072h | UTRA_DL_IM | 38 | Qualcomm | Rel-15 | 75 |  |  |  |
| 3613 | 1486.1 | Core part: DL interference mitigation for UMTS | 67d? | 2017-03-15 A | 2017-06-15 A | 100% | finish no earlier than 2017-06-15 | R2 | 536h | 536h | UTRA_DL_IM-Core | 38 | Qualcomm | Rel-14 | 75 |  |  | RP-171135 |
| 3614 | 1487 | Control and monitoring of Power, Energy and Environmental (PEE) parameters in Radio Access Networks (RAN) | 204d? | 2017-06-05 A | 2018-03-15 A | 100% | finish no earlier than 2018-03-15 | S5 | 1632h | 1632h | PEE_CMON | 39 | Jean-Michel CORNILY, ORANGE | Rel-15 | 76 |  |  |  |

Notes:
- 3589: 1/12/16: 0%->100 / Impacted TSs and TRs: 22.173
- 3590: 1/12/16: 0%->100¦30/6/17: 24.196 added; / Impacted TSs and TRs: 22.173; 24.196
- 3592: 14/9/17: 0%->40¦15/12/17: 40%->85¦20/3/18: 85%->100 / Impacted TSs and TRs: 24.259; 24.604; 24.606; 24.607; 24.608; 24.610; 24.611; 24.615; 24.616; 24.629; 24.642; 24.647; 24.654
- 3593: 7/6/18: 0%->100 / Impacted TSs and TRs: 29.165
- 3594: Impacted TSs and TRs: 22.101
- 3595: Impacted TSs and TRs: 23.122; 24.008; 24.167; 24.229; 24.301; 24.302; 24.303; 24.304; 24.305; 24.312; 29.018; 29.118; 24.368
- 3596: 14/9/17: 0%->20¦15/12/17: 20%->55¦16/3/18: 55%->80¦7/6/18: 80%->100 / Impacted TSs and TRs: 23.122; 24.008; 24.167; 24.229; 24.301; 24.302; 24.303; 24.304; 24.305; 24.312; 29.018; 29.118; 24.368
- 3597: 14/9/17: 0%->20¦15/12/17: 20%->55¦16/3/18: 55%->80¦7/6/18: 80%->100 / Impacted TSs and TRs: 23.122; 24.008; 24.167; 24.229; 24.301; 24.302; 24.303; 24.304; 24.305; 24.312; 29.018; 29.118; 24.368
- 3598: 14/9/17: 0%->20¦15/12/17: 20%->55¦16/3/18: 55%->80¦7/6/18: 80%->100
- 3599: 6/10/16: 33.216 added¦1/12/16: 0%->5¦6/3/17: 5%->25. Moved from Rel-14.¦7/6/17: FCD:06/17->12/17¦7/6/17: 25%->75¦11/9/17: 75%->100 / Impacted TSs and TRs: 33.117; 33.926; 33.216
- 3600: 28/7/16: 33.250 added¦19/9/16: 0%->10¦6/10/16: 33.216 added¦1/12/16: 10%->40. 06/03/17: moved from Rel-14.¦6/3/17: 40%->80¦7/6/17: FCD:06/17->12/17¦7/6/17: 80%->95¦11/9/17: 95%->100 / Impacted TSs and TRs: 33.250; 33.216
- 3601: 7/6/17: 75%->100
- 3603: 14/9/17: 0%->40¦15/12/17: 40%->60¦16/3/18: 60%->80¦7/6/18: 80%->100 / Impacted TSs and TRs: 23.218; 24.229; 24.930
- 3604: 16/7/24: 99%->100
- 3605: 22/3/18: 0%->100; 9/4/21: RFC 8262 added; / Impacted TSs and TRs: RFC 8262
- 3606: 27/6/18: 0%->100
- 3608: 15/12/17: 0%->40¦7/6/18: 40%->85¦10/9/18: 85%->100 / Impacted TSs and TRs: 29.163; 29.165; 29.949
- 3609: 21/12/17: WID:SP-170039->SP-170839¦16/3/18: 10%->20
- 3610: 12/7/17: 0%->5¦11/9/17: 5%->10¦16/3/18: 24%->35¦7/6/18: 35%->70¦7/6/18: FCD:06/18->09/18¦10/9/18: 70%->85. 17/01/19: deleted as per Alex's e-mail 13 Nov. Was at 85%
- 3611: 12/7/17: 0%->5¦15/12/17: 5%->10¦10/9/18: 17%->40¦7/12/18: FCD:12/18->03/19¦7/12/18: 40%->75¦20/3/19: 75%->80; 31/5/19: 80%->100
- 3612: no Perf. part
- 3613: no Perf. part19/6/17: Compl:0%->100%
- 3614: 30/6/17: 28.306 added;¦30/6/17: 28.305 added;¦30/6/17: 28.304 added;¦11/9/17: 0%->20¦15/12/17: 20%->80¦16/3/18: 80%->100 / Impacted TSs and TRs: New TSs; 52.402; 32.405; 32.425; 32.101; 32.103; 28.306; 28.305; 28.304

| ID | WBS | Task | Type | Duration | Start | Finish | Complete | Remaining | Total slack | Constraint | Resources | Work | Actual work | Acronym | PCG approved | WI rapporteur name | Release | TSG approved | Impacted TSs and TRs | WI rapporteur e-mail | Status Report |
| --- | --- | --- | --- | --- | --- | --- | --- | --- | --- | --- | --- | --- | --- | --- | --- | --- | --- | --- | --- | --- | --- |
| 3615 | 1488 | **Simplified HS-SCCH for UMTS** |  | 285.75d? | 2017-03-15 A | 2017-12-15 A | 100% |  |  |  | R6 | 3176h | 3176h | UTRA_simple_HSSCCH | 39 | Ericsson | Rel-15 | 76 |  |  |  |
| 3616 | 1488.1 | Study on a simplified HS-SCCH for UMTS |  | 67d? | 2017-03-15 A | 2017-06-15 A | 100% |  |  | start no earlier than 2017-03-15 | R1 | 536h | 536h | FS_UTRA_simple_HSSCCH | 38 | gerardo.agni.medina.acosta@ericsson.com | Rel-15 | 75 | 25.709 | gerardo.agni.medina.acosta@ericsson.com |  |
| 3617 | 1488.2 | Core part: Simplified HS-SCCH for UMTS |  | 132d? | 2017-06-15 A | 2017-12-15 A | 100% |  |  | finish no earlier than 2017-12-15 | R6 | 1056h | 1056h | UTRA_simple_HSSCCH-Core | 39 | Ericsson | Rel-15 | 76 |  |  | RP-172306 |
| 3618 | 1489 | Charging for enhancement to Flexible Mobile Service Steering (eFMSS) |  | 139d? | 2017-06-05 A | 2017-12-14 A | 100% |  |  | finish no earlier than 2017-12-14 | S5 | 1112h | 1112h | eFMSS_CH | 39 | Long,Biao, China Telecom | Rel-15 | 76 | 32.251; 32.298; 32.299 | longb.gd@chinatelecom.cn. |  |
| 3619 | 1490 | Receive acoustic output test in the presence of background noise |  | 131d? | 2017-12-15 A | 2018-06-15 A | 100% |  |  | finish no earlier than 2018-06-15 | S4 | 1048h | 1048h | RAOT | 40 | ISBERG, Peter, Sony Mobile Communications | Rel-15 | 78 | 26.131; 26.132 | peter.isberg [at] sony.com |  |
| 3620 | 1491 | Speech quality in the presence of ambient noise for super-wideband and fullband modes |  | 196d? | 2017-12-15 A | 2018-09-14 A | 100% |  |  | finish no earlier than 2018-09-14 | S4 | 1568h | 1568h | SPAN | 40 | Reimes, Jan – HEAD acoustics GmbH | Rel-15 | 78 | 26.131 | jan.reimes@head-acoustics.de |  |
| 3621 | 1492 | **REST Solution Sets** |  | 1132d? | 2016-09-19 A | 2019-09-16 A | 100% |  |  |  |  | 15112h | 15112h | REST_SS | 41 |  | Rel-15 | 78 |  |  |  |
| 3622 | 1492.1 | Study on a RESTful HTTP-based Solution Set |  | 322d? | 2016-09-19 A | 2017-12-12 A | 100% |  |  | finish no earlier than 2017-12-12 | S5 | 2576h | 2576h | FS_OAM_RESTFUL | 37 | Nokia: Pollakowski, Olaf | Rel-15 | 73 | 32.866 | olaf.pollakowski@nokia.com |  |
| 3623 | 1492.2 | REST Solution Sets (normative work) |  | 196d? | 2017-12-15 A | 2018-09-14 A | 100% |  |  | finish no earlier than 2018-09-14 | S5 | 1568h | 1568h | REST_SS | 40 | Pollakowski, Olaf, Nokia | Rel-15 | 78 | 32.101 | olaf.pollakowski@nokia.com |  |
| 3624 | 1492.3 | deleted - (IETF) JSON Schema: A Media Type for Describing JSON Documents (draft-handrews-json-schema) |  | 457d? | 2017-12-15 A | 2019-09-16 A | 100% |  |  | finish no earlier than 2019-09-16 | S5-IETF | 3656h | 3656h | REST_SS | 41 | Pollakowski, Olaf, Nokia | Rel-15 | 80 |  | olaf.pollakowski@nokia.com |  |
| 3625 | 1492.4 | deleted - (IETF) JSON Schema Validation: A Vocabulary for Structural Validation of JSON (draft-handrews-json-schema-validation) |  | 457d? | 2017-12-15 A | 2019-09-16 A | 100% |  |  | finish no earlier than 2019-09-16 | S5-IETF | 3656h | 3656h | REST_SS | 41 | Pollakowski, Olaf, Nokia | Rel-15 | 80 |  | olaf.pollakowski@nokia.com |  |
| 3626 | 1492.5 | deleted - (IETF) JSON Hyper-Schema: A Vocabulary for Hypermedia Annotation of JSON (draft-handrews-json-schema-hyperschema) |  | 457d? | 2017-12-15 A | 2019-09-16 A | 100% |  |  | finish no earlier than 2019-09-16 | S5-IETF | 3656h | 3656h | REST_SS | 41 | Pollakowski, Olaf, Nokia | Rel-15 | 80 |  | olaf.pollakowski@nokia.com |  |
| 3627 | 1493 | **Enhancements to Call spoofing functionality** |  | 370.75d? | 2018-03-15 A | 2019-03-07 A | 100% |  |  |  | C1 | 3648h | 3648h | eSPECTRE | 41 | Axell, Jörgen, Ericsson | Rel-15 | 79 |  | Jorgen.Axell@ericsson.com |  |
| 3628 | 1493.1 | CT1 aspects of eSPECTRE |  | 66d? | 2018-03-15 A | 2018-06-14 A | 100% |  |  | start no earlier than 2018-03-15 | C1 | 528h | 528h | eSPECTRE | 40 | Axell, Jörgen, Ericsson | Rel-15 | 79 | 24.229 | Jorgen.Axell@ericsson.com |  |
| 3629 | 1493.2 | (IETF) PASSporT SHAKEN Extension (draft-ietf-stir-passport-shaken)--> RFC 8588 |  | 67d? | 2018-06-14 A | 2018-09-14 A | 100% |  |  | start no earlier than 2018-06-14 | C1-IETF | 536h | 536h | eSPECTRE | 41 | Axell, Jörgen, Ericsson | Rel-15 | 80 |  |  |  |
| 3630 | 1493.3 | (IETF) PASSporT Extension for Diverted Calls (draft-ietf-stir-passport-divert) |  | 1d | 2019-03-07 A | 2019-03-07 A | 100% |  |  |  | C1-IETF | 8h | 8h | eSPECTRE | 44 |  | Rel-15 | 87 | RFC 8946 |  |  |
| 3631 | 1493.4 | CT3 aspects of eSPECTRE |  | 66d? | 2018-03-15 A | 2018-06-14 A | 100% |  |  | start no earlier than 2018-03-15 | C3 | 528h | 528h | eSPECTRE | 40 | Axell, Jörgen, Ericsson | Rel-15 | 79 | 29.163; 29.165 | Jorgen.Axell@ericsson.com |  |
| 3632 | 1494 | **(Small) Technical Enhancements and Improvements for Rel-15** |  | 472.25d? | 2017-03-17 A | 2018-06-15 A | 100% |  |  |  |  | 2608h | 2608h | TEI15 | 35 |  | Rel-15 | 68 |  |  |  |
| 3633 | 1494.1 | (IETF) The Transport Layer Security (TLS) Protocol Version 1.3 (draft-ietf-tls-tls13) |  | 326d? | 2017-03-17 A | 2018-06-15 A | 100% |  |  | finish no earlier than 2018-06-15 | S3-IETF | 2608h | 2608h | TEI15 | 41 |  | Rel-15 | 80 | RFC 8446 |  |  |
| 3634 | 1495 | (Small) Test Technical Enhancements and Improvements for Rel-15 |  | 196d? | 2017-03-17 A | 2017-12-15 A | 100% |  |  | finish no earlier than 2017-12-15 |  |  |  | TEI15_Test | 38 |  | Rel-15 | 75 |  |  |  |
| 3635 | 1496 | Release 15 Features on LTE improvements | milestone | 0d? | 2000-01-01 A | 2000-01-01 A | 100% |  |  |  |  |  |  |  |  |  | Rel-15 |  |  |  |  |
| 3636 | 1497 | **UL data compression in LTE** |  | 7259.88d? | 2000-01-03 A | 2019-03-15 | 99% | 69.79d? | 40379.6d |  | R2 | 80992h | 78130.7h | LTE_UDC | 39 | CATT | Rel-15 | 77 |  |  |  |
| 3637 | 1497.1 | Core part: UL data compression in LTE |  | 4899d? | 2000-01-03 A | 2012-12-16 | 99% | 48.99d? | 42740.5d | finish no earlier than 2018-09-15 | R2 | 39192h | 38800.1h | LTE_UDC-Core | 39 | CATT | Rel-15 | 77 |  |  | RP-180912 |
| 3638 | 1497.2 | UE Conformance Test Aspects - UL Data Compression in LTE |  | 196d? | 2018-06-15 A | 2019-03-15 A | 100% |  |  | finish no earlier than 2019-03-15 | R5 | 1568h | 1568h | LTE_UDC-UEConTest | 41 | CATT | Rel-15 | 80 |  |  |  |

Notes:
- 3616: 19/6/17: Compl:0%->100%¦30/6/17: 25.709 added;
- 3617: 11/9/17: 0%->85¦15/12/17: 85%->100¦8/1/18: WID: RP-171443->RP-172720¦
- 3618: 11/9/17: 0%->70¦15/12/17: 70%->100
- 3619: 16/3/18: 0%->80¦16/3/18: FCD:03/18->06/18¦7/6/18: 80%->100
- 3620: 16/3/18: 0%->50¦7/6/18: 50%->80¦7/6/18: FCD:06/18->09/18¦10/9/18: 80%->100
- 3622: 6/10/16: 32.866 added¦1/12/16: 0%->5¦7/6/17: 5%->45¦7/6/17: FCD:06/17->12/17¦11/9/17: 45%->80¦15/12/17: 80%->100
- 3623: 16/3/18: 0%->20¦7/6/18: 20%->70¦7/6/18: FCD:06/18->09/18¦10/9/18: 70%->100
- 3624: 16/7/24: 0%->100
- 3625: 16/7/24: 0%->100
- 3626: 16/7/24: 0%->100
- 3628: 16/3/18: 0%->5; 7/6/18: 5%->50; 10/9/18: 50%->100
- 3629: 23/4/20: 25%->100
- 3630: 9/4/21: RFC 8946 added;
- 3631: 10/9/18: 0%->100
- 3633: 26/6/19: 25%->100; 9/4/21: RFC 8446 added;
- 3634: Created upon demand of RAN5
- 3635: -
- 3637: ¦8/1/18: Compl:0%->70%¦8/1/18: CD:Mon 03/01/00->Thu 15/03/18¦27/3/18: Compl:70%->99%27/3/1 ¦27/6/18: CD:Fri 15/06/18->Sat 15/09/18;
- 3638: tested: REL-15 WI LTE_UDC-Core¦26/3/19: WID:RP-180918->RP-190311¦26/3/19: 0%->100

| ID | WBS | Task | Duration | Start | Finish | Complete | Remaining | Total slack | Constraint | Resources | Work | Actual work | Acronym | PCG approved | WI rapporteur name | Release | TSG approved | Impacted TSs and TRs | TSG stopped | WI rapporteur e-mail | Status Report |
| --- | --- | --- | --- | --- | --- | --- | --- | --- | --- | --- | --- | --- | --- | --- | --- | --- | --- | --- | --- | --- | --- |
| 3639 | 1498 | **LTE Advanced inter-band CA (4DL/4UL) of Band 41C and Band 42C** | 188.5d? | 2017-09-15 A | 2018-03-15 A | 100% |  |  |  | R4 | 3120h | 3120h | LTE_CA_4DL4UL_B41_B41_B42_B42 | 39 | KDDI | Rel-15 | 77 |  |  |  |  |
| 3640 | 1498.1 | Core part:LTE Advanced inter-band CA (4DL/4UL) of Band 41C and Band 42C | 130d? | 2017-09-15 A | 2018-03-15 A | 100% |  |  | finish no earlier than 2018-06-15 | R4 | 1040h | 1040h | LTE_CA_4DL4UL_B41_B41_B42_B42-Core | 39 | KDDI | Rel-15 | 77 | 36.715-04 |  |  |  |
| 3641 | 1498.2 | Perf. part:LTE Advanced inter-band CA (4DL/4UL) of Band 41C and Band 42C | 130d? | 2017-09-15 A | 2018-03-15 A | 100% |  |  | finish no earlier than 2018-06-15 | R4 | 1040h | 1040h | LTE_CA_4DL4UL_B41_B41_B42_B42-Perf | 39 | KDDI | Rel-15 | 77 |  |  |  |  |
| 3642 | 1499 | **Additional LTE bands for UE category M1 and/or NB1 in Rel-15** | 283.75d? | 2017-09-15 A | 2018-06-15 A | 100% |  |  |  | R4 | 5752h | 5752h | LTE_bands_R15_M1_NB1 | 39 | Ericsson | Rel-15 | 77 |  |  |  |  |
| 3643 | 1499.1 | Core part: Additional LTE bands for UE category M1 and/or NB1 in Rel-15 | 196d? | 2017-09-15 A | 2018-06-15 A | 100% |  |  | finish no earlier than 2018-06-15 | R4 | 1568h | 1568h | LTE_bands_R15_M1_NB1-Core | 39 | Ericsson | Rel-15 | 77 |  |  |  |  |
| 3644 | 1499.2 | Perf. part: Additional LTE bands for UE category M1 and/or NB1 in Rel-15 | 196d? | 2017-09-15 A | 2018-06-15 A | 100% |  |  | finish no earlier than 2018-06-15 | R4 | 1568h | 1568h | LTE_bands_R15_M1_NB1-Perf | 39 | Ericsson | Rel-15 | 77 |  |  |  |  |
| 3645 | 1499.3 | UE Conformance Test aspects - LTE bands with UE category M1 and/or NB1 in Rel-15 | 131d? | 2017-12-15 A | 2018-06-15 A | 100% |  |  | finish no earlier than 2018-06-15 | R5 | 1048h | 1048h | LTE_bands_R15_M1_NB1-UEConTest | 40 | Ericsson | Rel-15 | 78 |  |  |  |  |
| 3646 | 1500 | **Additional LTE bands for UE category M2 and/or NB2 in Rel-15** | 472.25d? | 2017-09-15 A | 2018-12-14 A | 100% |  |  |  | R4 | 6264h | 6264h | LTE_bands_R15_M2_NB2 | 39 | Ericsson | Rel-15 | 77 |  |  |  |  |
| 3647 | 1500.1 | Core part: Additional LTE bands for UE category M2 and/or NB2 in Rel-15 | 196d? | 2017-09-15 A | 2018-06-15 A | 100% |  |  | finish no earlier than 2018-06-15 | R4 | 1568h | 1568h | LTE_bands_R15_M2_NB2-Core | 39 | Ericsson | Rel-15 | 77 |  |  |  |  |
| 3648 | 1500.2 | UE Conformance Test aspects - LTE bands with UE category M2 and/or NB2 in Rel-15 | 261d? | 2017-12-15 A | 2018-12-14 A | 100% |  |  | finish no earlier than 2018-12-15 | R5 | 2088h | 2088h | LTE_bands_R15_M2_NB2-UEConTest | 40 | Ericsson | Rel-15 | 78 |  |  |  |  |
| 3649 | 1501 | **Extended-Band12 new E-UTRA Band** | 646.25d? | 2017-09-15 A | 2019-05-31 A | 100% |  |  |  | R4 | 6176h | 6176h | Ext_B12_LTE | 39 | Ericsson | Rel-15 | 77 |  |  |  |  |
| 3650 | 1501.1 | Core part: Extended-Band12 new E-UTRA Band | 130d? | 2017-09-15 A | 2018-03-15 A | 100% |  |  | finish no earlier than 2018-03-15 | R4 | 1040h | 1040h | Ext_B12_LTE-Core | 39 | Ericsson | Rel-15 | 77 | 37.761 |  |  |  |
| 3651 | 1501.2 | Perf. part: Extended-Band12 new E-UTRA Band | 130d? | 2017-09-15 A | 2018-03-15 A | 100% |  |  | finish no earlier than 2018-03-15 | R4 | 1040h | 1040h | Ext_B12_LTE-Perf | 39 | Ericsson | Rel-15 | 77 |  |  |  |  |
| 3652 | 1501.3 | UE Conformance Test Aspects - Extended-Band12 new E-UTRA Band (Band 85) | 66d | 2019-03-01 A | 2019-05-31 A | 100% |  |  | finish no earlier than 2019-06-01 | R5 | 528h | 528h | Ext_B12_LTE-UEConTest | 42 | Ericsson | Rel-15 | 83 |  |  |  |  |
| 3653 | 1502 | **Stopped - Signalling reduction to enable light connection for LTE** | 756.88d? | 2016-03-15 A | 2018-03-15 A | 100% |  |  |  |  | 7120h | 7120h | LTE_LIGHT_CON | 36 | Huawei | Rel-15 | 71 |  | 80 |  |  |
| 3654 | 1502.1 | Stopped - Core part: Signalling reduction to enable light connection for LTE | 524d? | 2016-03-15 A | 2018-03-15 A | 100% |  |  | finish no earlier than 2018-03-15 | R2 | 4192h | 4192h | LTE_LIGHT_CON-Core | 36 | Huawei | Rel-15 | 71 |  | 80 |  |  |
| 3655 | 1502.2 | Stopped - Study on Stage 2 of LTE_LIGHT_CON | 70d? | 2017-03-10 A | 2017-06-15 A | 100% |  |  | finish no earlier than 2017-06-15 | S2 | 560h | 560h | FS_LTE_LIGHT_CON | 38 | Sašo Stojanovski , intel | Rel-15 | 75 | 23.723 | 80 | saso.stojanovski@intel.com |  |
| 3656 | 1502.3 | **Stopped - Stage 3 of LTE_LIGHT_CON** | 107.75d? | 2016-12-01 A | 2017-03-14 A | 100% |  |  |  | ct | 2368h | 2368h | LTE_LIGHT_CON-CT | 38 | Herrero Veron, Christian (Huawei) | Rel-15 | 74 |  | 80 | Christian.Herrero at huawei.com |  |
| 3657 | 1502.3.1 | Stopped - CT1 aspects of LTE_LIGHT_CON | 74d? | 2016-12-01 A | 2017-03-14 A | 100% |  |  | finish no earlier than 2017-03-14 | C1 | 592h | 592h | LTE_LIGHT_CON-CT | 38 | Herrero Veron, Christian (Huawei) | Rel-15 | 74 | 24.008; 24.301; 29.118; 24.368; 27.007 | 80 | Christian.Herrero at huawei.com |  |
| 3658 | 1502.3.2 | Stopped - CT4 aspects of LTE_LIGHT_CON | 74d? | 2016-12-01 A | 2017-03-14 A | 100% |  |  | finish no earlier than 2017-03-14 | C4 | 592h | 592h | LTE_LIGHT_CON-CT | 38 | Herrero Veron, Christian (Huawei) | Rel-15 | 74 | 29.274; 29.272 | 80 | Christian.Herrero at huawei.com |  |
| 3659 | 1502.3.3 | Stopped - CT6 aspects of LTE_LIGHT_CON | 74d? | 2016-12-01 A | 2017-03-14 A | 100% |  |  | finish no earlier than 2017-03-14 | C6 | 592h | 592h | LTE_LIGHT_CON-CT | 38 | Herrero Veron, Christian (Huawei) | Rel-15 | 74 | 31.102 | 80 | Christian.Herrero at huawei.com |  |
| 3660 | 1503 | **Enhancements of Base Station (BS) RF and EMC requirements for Active Antenna System (AAS)** | 663.62d? | 2016-03-15 A | 2017-12-15 | 71% | 194.92d? | 40850.9d |  |  | 8920h | 6300h | AASenh_BS_LTE_UTRA | 36 | Huawei | Rel-15 | 71 | 37.843 |  |  |  |
| 3661 | 1503.1 | Core part: Enhancements of Base Station (BS) RF and EMC requirements for Active Antenna System (AAS) | 460d? | 2016-03-15 A | 2017-12-15 A | 100% |  |  | finish no earlier than 2017-12-15 | R4 | 3680h | 3680h | AASenh_BS_LTE_UTRA-Core | 36 | Huawei | Rel-15 | 71 |  |  |  | RP-172345 |
| 3662 | 1503.2 | Perf. part: Enhancements of Base Station (BS) RF and EMC requirements for Active Antenna System (AAS) | 655d? | 2016-03-15 A | 2017-12-07 | 50% | 327.5d? | 40859.5d | finish no earlier than 2018-09-15 | R4 | 5240h | 2620h | AASenh_BS_LTE_UTRA-Perf | 36 | Huawei | Rel-15 | 71 |  |  |  |  |

Notes:
- 3640: 15/12/17: 36.715-04 added;¦8/1/18: Compl:0%->80%27/3/18: Compl:80%->100%;
- 3641: ¦27/3/18: Compl:0%->100%;
- 3643: ¦8/1/18: Compl:0%->99%27/3/18: WID: RP-172077->RP-180262¦27/6/18: Compl:99%->100%
- 3644: ¦27/3/18: Compl:0%->99% ¦27/6/18: Compl:99%->100%
- 3645: tested: REL-15 WI LTE_bands_R15_M1_NB1-Core27/3/ ;
- 3647: ¦8/1/18: Compl:0%->99%¦27/3/18: WID: RP-172078->RP-180261¦27/6/18: Compl:99%->100%
- 3648: tested: REL-15 WI LTE_bands_R15_M2_NB2-Core¦27/ ;; 8/10/19: 20%->100
- 3650: 15/12/17: 37.761 added;¦8/1/18: Compl:0%->25%¦27/3/18: Compl:25%->100%;
- 3651: ¦8/1/18: WID: RP-172111->RP-17262527/3/18: Compl:0%->100%
- 3652: 26/6/19: WID:RP-190510->RP-190937; 26/6/19: 0%->100
- 3653: no Perf. part¦14/9/17: WID:RP-160540->RP-160937¦14/9/17: WID:RP-160937->RP-171459
- 3654: no Perf. part¦1/7/16: Compl:0%->10%¦1/7/16: CD:Thu 15/12/16->Wed 15/03/17¦1/7/16: WID: RP-160540->RP-16093726/9/16: Compl:10%->30%¦20/12/16: Compl:30%->75%¦20/12/16: Stat Rep: --> 21/3/17: Compl:75%->79% 21/3/17: CD:W ¦27/6
- 3655: 21/3/17: 23.723 added;¦7/6/17: 0%->55. Stopped at 55%, set at 100% artificially
- 3657: 6/3/17: 0%->25¦11/9/17: 25%->0
- 3659: 7/3/17: 0%->100
- 3660: follow-up WI of REL-13 WI AAS_BS_LTE_UTRA¦14/9/17: WID:RP-160548->RP-161668
- 3661: follow-up WI of REL-13 WI AAS_BS_LTE_UTRA1/7/16: Compl:0%->5%1/7/16: CD:Fri 15/09/17->Wed 15/03/1726/9/16: Compl:5%->10% 20/12/16: Compl:10%->20%21/3/17: Compl:20%->40% ;
- 3662: 1/7/16: WID: RP-160548->RP-1609401/7/16: Release: Rel-15->Rel-14¦26/9/16: WID: RP-160940->RP-161668 20/12/16: Stat Rep: -->¦21/3/17: Compl:0%->10%;

| ID | WBS | Task | Type | Duration | Start | Finish | Complete | Remaining | Total slack | Constraint | Resources | Work | Actual work | Acronym | PCG approved | WI rapporteur name | Release | TSG approved | Status Report | Impacted TSs and TRs |
| --- | --- | --- | --- | --- | --- | --- | --- | --- | --- | --- | --- | --- | --- | --- | --- | --- | --- | --- | --- | --- |
| 3663 | 1504 | **Shortened TTI and processing time for LTE** |  | 1700.5d? | 2016-06-15 A | 2020-12-12 | 99% | 6.11d? | 39718.8d |  |  | 13072h | 13024.9h | LTE_sTTIandPT | 37 | Ericsson | Rel-15 | 72 |  |  |
| 3664 | 1504.1 | Core part: Shortened TTI and processing time for LTE |  | 589d? | 2016-06-15 A | 2018-01-04 | 99% | 5.89d? | 40830.2d | finish no earlier than 2018-09-15 | R1 | 4712h | 4664.88h | LTE_sTTIandPT-Core | 37 | Ericsson | Rel-15 | 72 | RP-181008 |  |
| 3665 | 1504.2 | Perf. part: Shortened TTI and processing time for LTE |  | 523d? | 2016-09-14 A | 2018-09-14 A | 100% |  |  | finish no earlier than 2018-09-15 | R4 | 4184h | 4184h | LTE_sTTIandPT-Perf | 37 | Ericsson | Rel-15 | 72 |  |  |
| 3666 | 1504.3 | UE Conformance Test Aspects - Shortened TTI and processing time for LTE | manual | 522d | 2018-12-15 A | 2020-12-12 A | 100% |  |  |  | R5 | 4176h | 4176h | LTE_sTTIandPT-UEConTest | 42 | Huawei | Rel-15 | 82 |  |  |
| 3667 | 1505 | **450MHz E-UTRA FDD Band for LTE PPDR and PMR/PAMR in Europe** |  | 472.25d? | 2016-12-15 A | 2018-03-15 A | 100% |  |  |  |  | 4192h | 4192h | LTE450_Europe_PPDR | 38 | Airbus | Rel-15 | 74 |  | 36.748 |
| 3668 | 1505.1 | Core part: 450MHz E-UTRA FDD Band for LTE PPDR and PMR/PAMR in Europe |  | 197d? | 2016-12-15 A | 2017-09-15 A | 100% |  |  | finish no earlier than 2017-09-15 | R4 | 1576h | 1576h | LTE450_Europe_PPDR-Core | 38 | Airbus | Rel-15 | 74 |  |  |
| 3669 | 1505.2 | Perf. part: 450MHz E-UTRA FDD Band for LTE PPDR and PMR/PAMR in Europe |  | 197d? | 2016-12-15 A | 2017-09-15 A | 100% |  |  | finish no earlier than 2017-09-15 | R4 | 1576h | 1576h | LTE450_Europe_PPDR-Perf | 38 | Airbus | Rel-15 | 74 |  |  |
| 3670 | 1505.3 | UE Conformance Test Aspects - 450MHz E-UTRA FDD Band for LTE PPDR and PMR/PAMR in Europe (Band 72) |  | 130d? | 2017-09-15 A | 2018-03-15 A | 100% |  |  | finish no earlier than 2018-03-15 | R5 | 1040h | 1040h | LTE450_Europe_PPDR-UEConTest | 39 | Airbus | Rel-15 | 77 |  |  |
| 3671 | 1506 | **E-UTRA 700MHz in Europe for Broadband-PPDR (Public Protection and Disaster Relief)** |  | 472.25d? | 2016-12-15 A | 2018-03-15 | 83% | 78.31d? | 40757.6d |  |  | 3136h | 2616h | LTE700_Europe_PPDR | 38 | Airbus | Rel-15 | 74 |  |  |
| 3672 | 1506.1 | Core part: E-UTRA 700MHz in Europe for Broadband-PPDR |  | 197d? | 2016-12-15 A | 2017-09-15 A | 100% |  |  | finish no earlier than 2017-09-15 | R4 | 1576h | 1576h | LTE700_Europe_PPDR-Core | 38 | Airbus | Rel-15 | 74 |  |  |
| 3673 | 1506.2 | Perf. part: E-UTRA 700MHz in Europe for Broadband-PPDR |  | 65d? | 2017-01-12 | 2017-03-15 |  |  | 41135.6d | finish no earlier than 2017-03-15 | R4 | 520h |  | LTE700_Europe_PPDR-Perf | 38 | Airbus | Rel-15 | 74 |  |  |
| 3674 | 1506.3 | UE Conformance Test Aspects - E-UTRA 700MHz in Europe for Broadband-PPDR |  | 130d? | 2017-09-15 A | 2018-03-15 A | 100% |  |  | finish no earlier than 2018-03-15 | R5 | 1040h | 1040h | LTE700_Europe_PPDR-UEConTest | 39 | Airbus | Rel-15 | 77 |  |  |
| 3675 | 1507 | **FDD operating band in the L-band for LTE** |  | 661.75d? | 2016-12-15 A | 2018-09-14 A | 100% |  |  |  |  | 4720h | 4720h | LTE_FDD_L_Band | 38 | NTT DOCOMO | Rel-15 | 74 |  | 36.751 |
| 3676 | 1507.1 | Core part: FDD operating band in the L-band for LTE |  | 197d? | 2016-12-15 A | 2017-09-15 A | 100% |  |  | finish no earlier than 2017-09-15 | R4 | 1576h | 1576h | LTE_FDD_L_Band-Core | 38 | NTT DOCOMO | Rel-15 | 74 |  |  |
| 3677 | 1507.2 | Perf. part: FDD operating band in the L-band for LTE |  | 197d? | 2016-12-15 A | 2017-09-15 A | 100% |  |  | finish no earlier than 2017-09-15 | R4 | 1576h | 1576h | LTE_FDD_L_Band-Perf | 38 | NTT DOCOMO | Rel-15 | 74 |  |  |
| 3678 | 1507.3 | UE Conformance Test Aspects - FDD operating band in the L-band for LTE |  | 196d? | 2017-12-15 A | 2018-09-14 A | 100% |  |  | finish no earlier than 2018-09-15 | R5 | 1568h | 1568h | LTE_FDD_L_band-UEConTest | 40 | NTT DOCOMO | Rel-15 | 78 |  |  |
| 3679 | 1508 | **LTE Extended 1.5 GHz SDL band (1427 – 1518 MHz) and LTE CA (2DL/1UL) with Band 20** |  | 284.75d? | 2016-12-15 A | 2017-09-15 A | 100% |  |  |  |  | 2624h | 2624h | LTE_SDL_1500ext | 38 | Qualcomm | Rel-15 | 74 |  | 36.934; 36.753 |
| 3680 | 1508.1 | Core part: LTE Extended 1.5 GHz SDL band (1427 – 1518 MHz) and LTE CA (2DL/1UL) with Band 20 |  | 197d? | 2016-12-15 A | 2017-09-15 A | 100% |  |  | finish no earlier than 2017-09-15 | R4 | 1576h | 1576h | LTE_SDL_1500ext-Core | 38 | Qualcomm | Rel-15 | 74 |  |  |
| 3681 | 1508.2 | Perf. part: LTE Extended 1.5 GHz SDL band (1427 – 1518 MHz) and LTE CA (2DL/1UL) with Band 20 |  | 131d? | 2017-03-17 A | 2017-09-15 A | 100% |  |  | finish no earlier than 2017-09-15 | R4 | 1048h | 1048h | LTE_SDL_1500ext-Perf | 38 | Qualcomm | Rel-15 | 74 |  |  |
| 3682 | 1509 | **Add UE Power Class 2 to band 41 intra-band contiguous LTE CA** |  | 756d? | 2016-12-15 A | 2018-12-14 A | 100% |  |  |  |  | 4184h | 4184h | LTE_CA_C_B41_PC2 | 38 | Sprint | Rel-15 | 74 |  |  |
| 3683 | 1509.1 | Core part: Add UE Power Class 2 to band 41 intra-band contiguous LTE CA |  | 262d? | 2016-12-15 A | 2017-12-15 A | 100% |  |  | finish no earlier than 2017-12-15 | R4 | 2096h | 2096h | LTE_CA_C_B41_PC2-Core | 38 | Sprint | Rel-15 | 74 |  |  |
| 3684 | 1509.2 | UE Conformance Test Aspects - Add UE Power Class 2 to band 41 intra-band contiguous LTE CA |  | 261d? | 2017-12-15 A | 2018-12-14 A | 100% |  |  | finish no earlier than 2018-12-15 | R5 | 2088h | 2088h | LTE_CA_C_B41_PC2-UEConTest | 40 | Sprint | Rel-15 | 78 |  |  |
| 3685 | 1510 | **Addition of Power Class 1 UE to bands B3/B20/B28 for LTE** |  | 379d? | 2016-09-15 A | 2017-09-15 A | 100% |  |  |  |  | 2096h | 2096h | LTE_HPUE_B3_B20_B28 | 37 | Motorola Solutions | Rel-15 | 73 |  |  |
| 3686 | 1510.1 | Core part: Addition of Power Class 1 UE to bands B3/B20/B28 for LTE |  | 262d? | 2016-09-15 A | 2017-09-15 A | 100% |  |  | finish no earlier than 2017-09-15 | R4 | 2096h | 2096h | LTE_HPUE_B3_B20_B28-Core | 37 | Motorola Solutions | Rel-15 | 73 |  |  |

Notes:
- 3664: 26/9/16: Compl:0%->5%¦20/12/16: Compl:5%->10%21/3/17: Compl:10%->30%19/6/17: Compl:30%->65%19/6/17: CD: 19/9/17: Compl:65%->75%¦8/1/18: Compl:75%->99%¦8/1/18: CD:Fri 15/12/17->F ¦27/6/18: CD:Fri 15/06/1
- 3665: ¦26/9/16: WID: RP-161299->RP-161922¦20/12/16: WID: RP-161922->RP-16201421/3/17: WID: RP-162014->RP-170113¦19/6/17: CD:Thu 15/03/18->Fri 15/06/1827/3/18: Compl:0%->33%¦27/6/18: Compl:33%->60%¦26/3/19: 60%->100
- 3666: tested: REL-15 WI LTE_sTTIandPT-Core; 26/6/19: WID:RP-182429->RP-191003; 8/10/20: 0%->90; 8/10/20: 0%->90; 8/10/20: FCD:20/06/2019->12/20; 7/4/21: 0%->100; 8/4/21: 100%->100
- 3667: 21/3/17: 36.748 added;
- 3668: 21/3/17: Compl:0%->10%¦19/6/17: Compl:10%->75%¦19/9/17: Compl:75%->100%
- 3669: 19/6/17: Compl:0%->50%19/9/17: Compl:50%->100%
- 3670: ¦8/1/18: Compl:0%->77%¦27/3/18: Compl:77%->100%;
- 3672: 21/3/17: Compl:0%->25%¦19/6/17: Compl:25%->80%¦19/9/17: Compl:80%->100%
- 3673: 21/3/17: CD:Thu 15/06/17->Wed 15/03/17
- 3674: ¦8/1/18: Compl:0%->64%27/3/18: Compl:64%->100%;
- 3675: 21/3/17: 36.751 added;
- 3676: 21/3/17: Compl:0%->50%¦19/6/17: Compl:50%->99%¦19/9/17: Compl:99%->100%
- 3677: 19/6/17: Compl:0%->99%19/6/17: CD:Thu 15/06/19/9/17: Compl:99%->100%
- 3678: tested: REL-15 WI LTE_FDD_L_Band-Core27/3/18: Compl: ;; 11/10/20: 60%->100
- 3679: 21/3/17: 36.934 added;¦21/3/17: 36.753 added;
- 3680: 21/3/17: Compl:0%->20%19/6/17: Compl:20%->50%;19/9/17: Compl:50%->100%
- 3681: ¦19/6/17: CD:Thu 15/06/17->Fri 15/09/17 19/9/17: Compl:0%->100%
- 3683: 21/3/17: Compl:0%->5%¦19/6/17: Compl:5%->50%¦19/9/17: Compl:50%->90%¦8/1/18: Compl:90%->100%;
- 3684: tested: REL-15 WI LTE_CA_C_B41_PC2-Core¦27/3/18: Co ;; 28/7/20: 5%->100
- 3686: ¦20/12/16: Compl:0%->15%¦20/12/16: CD:Wed 15/03/17->Thu 15/06/1721/3/17: Compl:15%->70%19/6/17: Compl:70%->99%19/9/17: Compl:99%->100%;

| ID | WBS | Task | Type | Duration | Start | Finish | Complete | Remaining | Total slack | Constraint | Resources | Work | Actual work | Acronym | PCG approved | Impacted TSs and TRs | WI rapporteur name | Release | TSG approved | Status Report |
| --- | --- | --- | --- | --- | --- | --- | --- | --- | --- | --- | --- | --- | --- | --- | --- | --- | --- | --- | --- | --- |
| 3687 | 1511 | **TDD operating band in the L-band for LTE** |  | 284.75d? | 2016-12-15 A | 2017-09-15 A | 100% |  |  |  |  | 2624h | 2624h | LTE_TDD_L_Band | 38 | 36.753 | Huawei | Rel-15 | 74 |  |
| 3688 | 1511.1 | Core part: TDD operating band in the L-band for LTE |  | 197d? | 2016-12-15 A | 2017-09-15 A | 100% |  |  | finish no earlier than 2017-09-15 | R4 | 1576h | 1576h | LTE_TDD_L_Band-Core | 38 |  | Huawei | Rel-15 | 74 |  |
| 3689 | 1511.2 | Perf. part: TDD operating band in the L-band for LTE |  | 131d? | 2017-03-17 A | 2017-09-15 A | 100% |  |  | finish no earlier than 2017-09-15 | R4 | 1048h | 1048h | LTE_TDD_L_Band-Perf | 38 |  | Huawei | Rel-15 | 74 |  |
| 3690 | 1512 | **Further enhancements to Coordinated Multi-Point (CoMP) Operation for LTE** |  | 474.25d? | 2017-03-15 A | 2018-06-15 | 99% | 2.58d? | 40662.4d |  | R1 | 8912h | 7361.02h | feCOMP_LTE | 38 |  | Intel | Rel-15 | 75 |  |
| 3691 | 1512.1 | Core part: Further enhancements to Coordinated Multi-Point (CoMP) Operation for LTE |  | 393d? | 2017-03-15 A | 2018-03-29 | 99% | 3.93d? | 40743.6d | finish no earlier than 2018-09-15 | R1 | 3144h | 3112.56h | feCOMP_LTE-Core | 38 |  | Intel | Rel-15 | 75 | RP-180318 |
| 3692 | 1512.2 | Perf. part: Further enhancements to Coordinated Multi-Point (CoMP) Operation for LTE |  | 328d? | 2017-03-15 A | 2018-06-15 A | 100% |  |  | finish no earlier than 2018-06-15 | R4 | 2624h | 2624h | feCOMP_LTE-Perf | 38 |  | Intel | Rel-15 | 75 |  |
| 3693 | 1513 | **UE Positioning Accuracy Enhancements for LTE** |  | 568.5d? | 2017-03-15 A | 2018-09-14 A | 100% |  |  |  | R2 | 8912h | 8912h | LCS_LTE_acc_enh | 38 |  | Nokia | Rel-15 | 75 |  |
| 3694 | 1513.1 | Core part: UE Positioning Accuracy Enhancements for LTE |  | 393d? | 2017-03-15 A | 2018-09-14 A | 100% |  |  | finish no earlier than 2018-09-15 | R2 | 3144h | 3144h | LCS_LTE_acc_enh-Core | 38 |  | Nokia | Rel-15 | 75 | RP-180947 |
| 3695 | 1513.2 | Perf. part: UE Positioning Accuracy Enhancements for LTE |  | 328d? | 2017-03-15 A | 2018-06-15 A | 100% |  |  | finish no earlier than 2018-06-15 | R4 | 2624h | 2624h | LCS_LTE_acc_enh-Perf | 38 |  | Nokia | Rel-15 | 75 |  |
| 3696 | 1514 | **Enhancements for high capacity stationary wireless link and introduction of 1024 QAM for LTE DL** |  | 851.25d? | 2016-09-14 A | 2018-12-14 | 99% | 3.4d? | 40473.9d |  | R1 | 11512h | 8083.2h | LTE_1024QAM_DL | 38 |  | Huawei | Rel-15 | 75 |  |
| 3697 | 1514.1 | Core part: Enhancements for high capacity stationary wireless link and introduction of 1024 QAM for LTE DL |  | 393d? | 2017-03-15 A | 2018-03-29 | 99% | 3.93d? | 40743.6d | finish no earlier than 2018-09-15 | R1 | 3144h | 3112.56h | LTE_1024QAM_DL-Core | 38 | 36.783 | Huawei | Rel-15 | 75 | RP-180854 |
| 3698 | 1514.2 | Perf. part: Enhancements for high capacity stationary wireless link and introduction of 1024 QAM for LTE DL |  | 588d? | 2016-09-14 A | 2018-12-14 A | 100% |  |  | finish no earlier than 2018-12-15 | R4 | 4704h | 4704h | LTE_1024QAM_DL-Perf | 38 |  | Huawei | Rel-15 | 75 |  |
| 3699 | 1515 | **Enhancements to LTE operation in unlicensed spectrum** |  | 662.75d? | 2017-03-15 A | 2018-12-14 | 99% | 3.96d? | 40473.9d |  | R1 | 8904h | 5314.36h | LTE_unlic | 38 |  | Nokia | Rel-15 | 75 |  |
| 3700 | 1515.1 | Core part: Enhancements to LTE operation in unlicensed spectrum |  | 393d? | 2017-03-15 A | 2018-03-29 | 99% | 3.93d? | 40743.6d | finish no earlier than 2018-09-15 | R1 | 3144h | 3112.56h | LTE_unlic-Core | 38 | 37.107; 37.106 | Nokia | Rel-15 | 75 | RP-180948 |
| 3701 | 1515.2 | Perf. part: Enhancements to LTE operation in unlicensed spectrum |  | 262d? | 2017-12-14 A | 2018-12-14 A | 100% |  |  | finish no earlier than 2018-12-15 | R4 | 2096h | 2096h | LTE_unlic-Perf | 38 |  | Nokia | Rel-15 | 75 |  |
| 3702 | 1516 | **Further video enhancements for LTE** |  | 393d? | 2017-03-15 A | 2018-03-29 | 99% | 3.92d? | 40743.6d |  | R2 | 6288h | 6225.23h | LTE_ViLTE_enh2 | 38 |  | CMCC | Rel-15 | 75 |  |
| 3703 | 1516.1 | Core part: Further video enhancements for LTE |  | 393d? | 2017-03-15 A | 2018-03-29 | 99% | 3.93d? | 40743.6d | finish no earlier than 2018-09-15 | R2 | 3144h | 3112.56h | LTE_ViLTE_enh2-Core | 38 |  | CMCC | Rel-15 | 75 | RP-172381 |
| 3704 | 1517 | **Quality of Experience (QoE) Measurement Collection for streaming services in E-UTRAN** |  | 662.75d? | 2017-03-15 A | 2018-12-14 | 99% | 4.4d? | 40473.9d |  | R2 | 8384h | 7286.39h | LTE_QMC_Streaming | 38 |  | China Unicom | Rel-15 | 75 |  |
| 3705 | 1517.1 | Core part:Quality of Experience (QoE) Measurement Collection for streaming services in E-UTRAN |  | 393d? | 2017-03-15 A | 2018-03-29 | 99% | 3.93d? | 40743.6d | finish no earlier than 2018-09-15 | R2 | 3144h | 3112.56h | LTE_QMC_Streaming-Core | 38 |  | China Unicom | Rel-15 | 75 | RP-172192 |
| 3706 | 1517.2 | UE Conformance Test Aspects - Quality of Experience (QoE) Measurement Collection for streaming services in E-UTRAN |  | 197d? | 2018-03-15 A | 2018-12-14 A | 100% |  |  | finish no earlier than 2018-12-15 | R5 | 1576h | 1576h | LTE_QMC_Streaming-UEConTest | 40 |  | China Unicom | Rel-15 | 79 |  |
| 3707 | 1518 | **Enhancing LTE CA Utilization** |  | 1697.5d? | 2017-03-15 A | 2021-09-08 | 97% | 46.48d? | 39439.1d |  | R2 | 20848h | 11690.4h | LTE_euCA | 38 |  | Nokia | Rel-15 | 75 |  |
| 3708 | 1518.1 | Core part: Enhancing LTE CA Utilization |  | 393d? | 2017-03-15 A | 2018-03-29 | 90% | 39.3d? | 40743.6d | finish no earlier than 2018-09-15 | R2 | 3144h | 2829.6h | LTE_euCA-Core | 38 |  | Nokia | Rel-15 | 75 | RP-181069 |
| 3709 | 1518.2 | Perf. part: Enhancing LTE CA Utilization |  | 328d? | 2017-09-13 A | 2018-12-14 A | 100% |  |  | finish no earlier than 2018-12-15 | R4 | 2624h | 2624h | LTE_euCA-Perf | 38 |  | Nokia | Rel-15 | 75 |  |
| 3710 | 1518.3 | UE Conformance Test Aspects - Enhancing LTE CA Utilization | manual | 714d | 2018-12-15 A | 2021-09-08 A | 100% |  |  |  | R5 | 5712h | 5712h | LTE_euCA-UEConTest | 42 |  | Nokia | Rel-15 | 82 |  |

Notes:
- 3687: 21/3/17: 36.753 added;¦14/9/17: WID:RP-162557->RP-170304
- 3688: 21/3/17: Compl:0%->15%¦19/6/17: Compl:15%->70%¦ 19/9/17: Compl:70%->100%
- 3689: 21/3/17: WID: RP-162557->RP-170304¦19/6/17: CD:Thu 15/06/17->Fri 15/09/17¦19/9/17: Compl:0%->100%
- 3690: follow-up WI of REL-14 SI FS_feCOMP_LTE completed at RAN #75¦14/9/17: WID:RP-170750->RP-171031
- 3691: follow-up WI of REL-14 SI FS_feCOMP_LTE completed at RAN #75¦19/6/17: Compl:0%->70%¦19/6/17: CD:Fri 15/09/ 19/9/17: Compl:70%->90%¦27/3/18: Compl:90%->99%¦27/3/18: CD:Thu 15/03/18->Fri ¦27/6/18: CD:Fri
- 3692: follow-up WI of REL-14 SI FS_feCOMP_LTE completed at RAN #7519/6/17: WID: RP-170750->RP-171031¦8/1/18: Compl:0%->65%¦8/1/18: CD:Thu 15/03/18->Fri 15/06/1827/3/18: Compl:65%->80%27/3/ ¦27/6/18: Compl:80%->100%
- 3693: 14/9/17: WID:RP-170813->RP-171508
- 3694: ¦19/6/17: Compl:0%->10%¦19/6/17: CD:Fri 15/12/17->Fri 15/06/18 19/9/17: Compl:10%->20%¦8/1/18: Compl:20%->40%¦8/1/18: WID: RP-171508->RP-17231327/3/18: Compl:40%->50%¦27/6/18: Compl:50%->99%;; 24/4/20: 99%->100
- 3695: ¦19/6/17: WID: RP-170813->RP-171508¦8/1/18: Compl:0%->30%¦8/1/18: WID: RP-171508->RP-172313¦27/6/18: Compl:30%->100%¦27/6/18: WID: RP-17231
- 3696: 14/9/17: WID:RP-170838->RP-171067
- 3697: ¦19/6/17: Compl:0%->20%¦19/6/17: CD:Sat 15/12/18->Thu 15/03/18 19/6/17: FCD:03/18->06/18¦12/7/17: 36.783 added;19/9/17: Compl:20%->40%¦8/1/18: Compl:40%->85%27/3/18: Compl:85%->99%
- 3698: ¦19/6/17: CD:Sat 15/12/18->Fri 15/06/18¦19/6/17: WID: RP-170838->RP-171067 19/9/17: WID: RP-171067->RP-17173827/3/18: Compl:0%->25%¦27/6/18: Compl:25%->50%¦16/1/19: 50%->100
- 3699: note: The is actually a further LAA enhancement
- 3700: note: The is actually a further LAA enhancement¦19/6/17: Compl:0%->15%¦19/6/17: CD:Fri 15 19/9/17: Compl:15%->30%¦8/1/18: Compl:30%->65%¦ 27/3/18: Compl:65%->85% 27/3/18: 37.107 added;;
- 3701: 19/6/17: CD:Thu 15/03/18->Sat 15/12/18¦8/1/18: WID: RP-170848->RP-17284127/3/18: WID: RP-172841->RP-180402¦16/1/19: 0%->100
- 3702: no Perf. part¦compare REL-14 WI LTE_VoLTE_ViLTE_enh
- 3703: no Perf. part¦compare REL-14 WI LTE_VoLTE_ViLTE_enh19/6/17: Compl:0%->15%19/6/17: W 19/9/17: Compl:15%->35%¦8/1/18: Compl:35%->99%¦ ¦27/6/18: CD:Fri 15/06/18->Sat 15/09/18
- 3704: compare REL-14 WI UMTS_QMC_Streaming-Core
- 3705: compare REL-14 WI UMTS_QMC_Streaming-Core¦19/6/17: Compl:0%->25%¦19/6/17: WID: RP- 19/9/17: Compl:25%->45%¦8/1/18: Compl:45%->99%¦ ¦27/6/18: CD:Fri 15/06/18->Sat 15/09/18
- 3706: tested: REL-15 WI LTE_QMC_Streaming-Core¦WI code to be used: LTE_QMC_Streaming-UEConTest;; 26/6/19: 5%->100
- 3708: 19/9/17: Compl:0%->22%¦8/1/18: Compl:22%->40%¦16/3/18: FCD:12/17->06/1827/3/18: Compl:40%->60%27/3/18: WID: RP-170805->RP-180561¦27/6/18: Compl:60%->90%;
- 3709: 16/3/18: FCD:12/17->12/18¦27/3/18: WID: RP-170805->RP-180561¦27/6/18: Compl:0%->20%¦26/3/19: 20%->100
- 3710: tested: REL-15 WI LTE_euCA-Core; 8/10/20: 0%->35; 8/10/20: FCD:15/12/2019->12/20; 8/4/21: 0%->56; 8/4/21: FCD:12/12/2020->09/20; 2/7/21: 0%->82; 29/9/21: 0%->100

| ID | WBS | Task | Duration | Start | Finish | Complete | Remaining | Total slack | Constraint | Resources | Work | Actual work | Acronym | PCG approved | WI rapporteur name | Release | TSG approved |
| --- | --- | --- | --- | --- | --- | --- | --- | --- | --- | --- | --- | --- | --- | --- | --- | --- | --- |
| 3711 | 1519 | **450 MHz Band for LTE in Region 3** | 757d? | 2017-03-15 A | 2019-03-15 A | 100% |  |  |  | R4 | 9448h | 9448h | LTE450_Reg3 | 38 | China Unicom | Rel-15 | 75 |
| 3712 | 1519.1 | Core part: 450 MHz Band for LTE in Region 3 | 198d? | 2017-03-15 A | 2017-12-15 A | 100% |  |  | finish no earlier than 2017-12-15 | R4 | 1584h | 1584h | LTE450_Reg3-Core | 38 | China Unicom | Rel-15 | 75 |
| 3713 | 1519.2 | Perf. part: 450 MHz Band for LTE in Region 3 | 198d? | 2017-03-15 A | 2017-12-15 A | 100% |  |  | finish no earlier than 2017-12-15 | R4 | 1584h | 1584h | LTE450_Reg3-Perf | 38 | China Unicom | Rel-15 | 75 |
| 3714 | 1519.3 | UE Conformance Test Aspects - 450 MHz Band for LTE in Region 3 | 262d? | 2018-03-15 A | 2019-03-15 A | 100% |  |  | finish no earlier than 2019-03-15 | R5 | 2096h | 2096h | LTE450_Reg3-UEConTest | 40 | China Unicom, Shi Yu | Rel-15 | 79 |
| 3715 | 1520 | **US 600 MHz Band for LTE** | 285.75d? | 2017-03-15 A | 2017-12-15 A | 100% |  |  |  | R4 | 4240h | 4240h | LTE600_US | 38 | Ericsson | Rel-15 | 75 |
| 3716 | 1520.1 | Core part: US 600 MHz Band for LTE | 133d? | 2017-03-15 A | 2017-09-15 A | 100% |  |  | finish no earlier than 2017-09-15 | R4 | 1064h | 1064h | LTE600_US-Core | 38 | Ericsson | Rel-15 | 75 |
| 3717 | 1520.2 | Perf. part: US 600 MHz Band for LTE | 133d? | 2017-03-15 A | 2017-09-15 A | 100% |  |  | finish no earlier than 2017-09-15 | R4 | 1064h | 1064h | LTE600_US-Perf | 38 | Ericsson | Rel-15 | 75 |
| 3718 | 1520.3 | UE Conformance Test Aspects - US 600 MHz Band for LTE (Band 71) | 66d? | 2017-09-15 A | 2017-12-15 A | 100% |  |  | finish no earlier than 2018-03-15 | R5 | 528h | 528h | LTE600_US-UEConTest | 39 | Dish Network | Rel-15 | 77 |
| 3719 | 1521 | **LAA/eLAA for the CBRS 3.5GHz band in the United States** | 285.75d? | 2017-03-15 A | 2017-12-15 A | 100% |  |  |  | R4 | 4752h | 4752h | LTE_3550_CBRS_US_LAA | 38 | AT&T | Rel-15 | 75 |
| 3720 | 1521.1 | Core part: LAA/eLAA for the CBRS 3.5GHz band in the United States | 198d? | 2017-03-15 A | 2017-12-15 A | 100% |  |  | start no earlier than 2017-03-15 | R4 | 1584h | 1584h | LTE_3550_CBRS_US_LAA-Core | 38 | AT&T | Rel-15 | 75 |
| 3721 | 1521.2 | Perf. part: LAA/eLAA for the CBRS 3.5GHz band in the United States | 198d? | 2017-03-15 A | 2017-12-15 A | 100% |  |  | start no earlier than 2017-03-15 | R4 | 1584h | 1584h | LTE_3550_CBRS_US_LAA-Perf | 38 | AT&T | Rel-15 | 75 |
| 3722 | 1522 | **Introduction new band support for 4Rx antenna ports for LTE for REL-15** | 379d? | 2017-06-15 A | 2018-06-15 A | 100% |  |  |  | R4 | 6288h | 6288h | LTE_4Rx_AP_DL_bands_R15 | 39 | Huawei | Rel-15 | 76 |
| 3723 | 1522.1 | Core part: Introduction new band support for 4Rx antenna ports for LTE for REL-15 | 262d? | 2017-06-15 A | 2018-06-15 A | 100% |  |  | finish no earlier than 2018-06-15 | R4 | 2096h | 2096h | LTE_4Rx_AP_DL_bands_R15-Core | 39 | Huawei | Rel-15 | 76 |
| 3724 | 1522.2 | Perf. part: Introduction new band support for 4Rx antenna ports for LTE for REL-15 | 262d? | 2017-06-15 A | 2018-06-15 A | 100% |  |  | finish no earlier than 2018-06-15 | R4 | 2096h | 2096h | LTE_4Rx_AP_DL_bands_R15-Perf | 39 | Huawei | Rel-15 | 76 |
| 3725 | 1523 | **Addition of band 28 and 40 to LTE MTC cat.0** | 96.25d? | 2017-06-15 A | 2017-09-15 A | 100% |  |  |  | R4 | 1072h | 1072h | LC_MTC_LTE_cat0_B28_B40 | 39 | Huawei | Rel-15 | 76 |
| 3726 | 1523.1 | Core part: Addition of band 28 and 40 to LTE MTC cat.0 | 67d? | 2017-06-15 A | 2017-09-15 A | 100% |  |  | finish no earlier than 2017-09-15 | R4 | 536h | 536h | LC_MTC_LTE_cat0_B28_B40-Core | 39 | Huawei | Rel-15 | 76 |
| 3727 | 1524 | **LTE Advanced high power TDD UE (power class 2) for Rel-15** | 1510d? | 2017-06-15 A | 2021-06-11 A | 100% |  |  |  | R4 | 14048h | 14048h | LTE_TDD_HPUE_R15 | 39 | Huawei | Rel-15 | 76 |
| 3728 | 1524.1 | Core part: LTE Advanced high power TDD UE (power class 2) for Rel-15 | 262d? | 2017-06-15 A | 2018-06-15 A | 100% |  |  | finish no earlier than 2018-06-15 | R4 | 2096h | 2096h | LTE_TDD_HPUE_R15-Core | 39 | Huawei | Rel-15 | 76 |
| 3729 | 1524.2 | UE Conformance Test Aspects – LTE Advanced high power TDD UE (power class 2) for Rel-15 | 452d | 2019-09-19 A | 2021-06-11 A | 100% |  |  | finish no earlier than 2021-06-12 | R5 | 3616h | 3616h | LTE_TDD_HPUE_R15-UEConTest | 43 | Huawei | Rel-15 | 85 |
| 3730 | 1525 | **New LTE band for 3.3-3.4 GHz for Africa** | 283.75d? | 2017-06-15 A | 2018-03-15 A | 100% |  |  |  | R4 | 4704h | 4704h | LTE_TDD_3300_Africa | 39 | Huawei | Rel-15 | 76 |
| 3731 | 1525.1 | Core part: New LTE band for 3.3-3.4 GHz for Africa | 196d? | 2017-06-15 A | 2018-03-15 A | 100% |  |  | finish no earlier than 2018-03-15 | R4 | 1568h | 1568h | LTE_TDD_3300_Africa-Core | 39 | Huawei | Rel-15 | 76 |
| 3732 | 1525.2 | Perf. part: New LTE band for 3.3-3.4 GHz for Africa | 196d? | 2017-06-15 A | 2018-03-15 A | 100% |  |  | finish no earlier than 2018-03-15 | R4 | 1568h | 1568h | LTE_TDD_3300_Africa-Perf | 39 | Huawei | Rel-15 | 76 |
| 3733 | 1526 | **UE requirements for network-based CRS interference mitigation for LTE** | 567.5d? | 2017-06-15 A | 2018-12-14 | 93% | 38.71d? | 40473.9d |  | R4 | 8888h | 8281.69h | LTE_NW_CRS_IM | 39 | Ericsson | Rel-15 | 76 |
| 3734 | 1526.1 | Core part: UE requirements for network-based CRS interference mitigation for LTE | 327d? | 2017-06-15 A | 2018-04-26 | 85% | 49.05d? | 40714.4d | finish no earlier than 2018-09-15 | R4 | 2616h | 2223.6h | LTE_NW_CRS_IM-Core | 39 | Ericsson | Rel-15 | 76 |
| 3735 | 1526.2 | Perf. part: UE requirements for network-based CRS interference mitigation for LTE | 392d? | 2017-06-15 A | 2018-12-14 A | 100% |  |  | finish no earlier than 2018-12-15 | R4 | 3136h | 3136h | LTE_NW_CRS_IM-Perf | 39 | Ericsson | Rel-15 | 76 |

Notes:
- 3711: 14/9/17: WID:RP-170159->RP-170952
- 3712: ¦19/6/17: Compl:0%->30%¦19 12/7/17: 36.759 added;¦19/9/17: Compl:30%->80%¦8/1/18: Compl:80%->100% / Impacted TSs and TRs: 36.759
- 3713: ¦19/6/17: WID: RP-170159->RP-170952¦8/1/18: Compl:0%->100%
- 3714: ¦27/6/18: Compl:0%->5%;; 14/1/20: 5%->100 / Impacted TSs and TRs: 34.121-1; 36.508; 36.521-1; 36.521-2; 36.521-3; 36.523-2; 36.523-3; 37.571-1; 36.905
- 3716: ¦19/6/17: Compl:0%->95%¦19 12/7/17: 36.755 added;19/9/17: Compl:95%->100% / Impacted TSs and TRs: 36.755
- 3717: ¦19/6/17: Compl:0%->95%¦19 19/9/17: Compl:95%->100%
- 3718: ¦8/1/18: Compl:0%->100%¦
- 3719: compare REL-14 WI LTE_TDD_3550_CBRS_US¦related to LTE band 48, intending a new band definition¦includes 2DL/2UL CA with B2 Acronym changed, was "LTE_TDD_3550_CBRS_US_LAA"
- 3720: compare REL-14 WI LTE_TDD_3550_CBRS_US¦related to LTE band 48, intending a new band definition¦includes 2DL/2UL CA with B2;19/6/17: Com¦Acronym changed, was "LTE_TDD_3550_CBRS_US_LAA-Core"¦12/7/17: 36.790 added;; / Impacted TSs and TRs: 36.790
- 3721: compare REL-14 WI LTE_TDD_3550_CBRS_US¦related to LTE band 48, intending a new band definition¦includes 2DL/2UL CA with B2¦19/6/17: C Acronym changed, was "LTE_TDD_3550_CBRS_US_LAA-Perf";
- 3723: 19/9/17: Compl:0%->99%¦8/1/18: WID: RP-171131->RP-17234727/3/18: Compl:99%->90% ¦27/6/18: Compl:90%->100%
- 3724: ¦8/1/18: WID: RP-171131->RP-172347¦27/3/18: WID: RP-172347->RP-180073¦27/6/18: Compl:0%->100%
- 3726: 19/9/17: Compl:0%->100%
- 3728: 19/9/17: Compl:0%->10%¦ 15/12/17: 36.760 added;¦8/1/18: Compl:10%->40%27/3/18: Compl:40%->99%¦27/6/18: Comp / Impacted TSs and TRs: 36.760
- 3729: 8/10/20: 0%->50; 8/10/20: FCD:15/09/2020->12/20; 8/4/21: 50%->98; 8/4/21: FCD:11/12/2020->06/21; 2/7/21: 98%->100
- 3731: 12/7/17: 36.758 added;19/9/17: Compl:0%->10%¦ 8/1/18: Compl:10%->70%27/3/18: Compl:70%->100%; / Impacted TSs and TRs: 36.758
- 3732: ¦19/9/17: WID: RP-171506->RP-171759¦27/3/18: Compl:0%->100%;
- 3734: ¦19/9/17: Compl:0%->15%¦8/1/18: Compl:15%->50%27/3/18: Compl:50%->70%¦27/6/18: Compl:70%->85%
- 3735: ¦27/6/18: WID: RP-171408->RP-181315¦16/1/19: 0%->100

| ID | WBS | Task | Type | Duration | Start | Finish | Complete | Remaining | Total slack | Constraint | Resources | Work | Actual work | Acronym | PCG approved | WI rapporteur name | Release | TSG approved | Status Report | Impacted TSs and TRs |
| --- | --- | --- | --- | --- | --- | --- | --- | --- | --- | --- | --- | --- | --- | --- | --- | --- | --- | --- | --- | --- |
| 3736 | 1527 | **Bluetooth/WLAN measurement collection in LTE Minimization of Drive Tests (MDT)** |  | 757.25d? | 2017-12-15 A | 2019-12-15 | 98% | 16.19d? | 40094.6d |  | R2 | 7832h | 5075.26h | LTE_MDT_BT_WLAN | 40 | CMCC | Rel-15 | 78 |  |  |
| 3737 | 1527.1 | Core part: Bluetooth/WLAN measurement collection in LTE Minimization of Drive Tests (MDT) |  | 196d? | 2017-12-15 A | 2018-06-22 | 95% | 9.8d? | 40655.9d | finish no earlier than 2018-09-15 | R2 | 1568h | 1489.6h | LTE_MDT_BT_WLAN-Core | 40 | CMCC | Rel-15 | 78 | RP-180867 |  |
| 3738 | 1527.2 | UE Conformance Test Aspects - Bluetooth/WLAN measurement collection in LTE Minimization of Drive Tests (MDT) | manual | 262d | 2018-12-15 A | 2019-12-15 A | 100% |  |  |  | R5 | 2096h | 2096h | LTE_MDT_BT_WLAN-UEConTest | 42 | CMCC | Rel-15 | 82 |  |  |
| 3739 | 1528 | **Enhanced LTE Support for Aerial Vehicles** |  | 856.5d? | 2017-03-15 A | 2019-06-19 | 99% | 3.18d? | 40280.1d |  | R2 | 8952h | 7336.69h | LTE_Aerial | 40 | Ericsson | Rel-15 | 78 |  |  |
| 3740 | 1528.1 | Study on enhanced LTE Support for Aerial Vehicles |  | 198d? | 2017-03-15 A | 2017-12-15 A | 100% |  |  | finish no earlier than 2017-12-15 | R2 | 1584h | 1584h | FS_LTE_Aerial | 38 | NTT DOCOMO | Rel-15 | 75 |  | 36.777 |
| 3741 | 1528.2 | Core part: Enhanced LTE Support for Aerial Vehicles |  | 196d? | 2017-12-15 A | 2018-06-22 | 99% | 1.96d? | 40655.9d | finish no earlier than 2018-09-15 | R2 | 1568h | 1552.32h | LTE_Aerial-Core | 40 | Ericsson | Rel-15 | 78 | RP-181045 |  |
| 3742 | 1528.3 | UE Conformance Test Aspects - Enhanced LTE Support for Aerial Vehicles | manual | 134d | 2018-12-15 A | 2019-06-19 A | 100% |  |  |  | R5 | 1072h | 1072h | LTE_Aerial-UEConTest | 42 | NTT DOCOMO | Rel-15 | 82 |  |  |
| 3743 | 1529 | **Separation of CP and UP for Split Option 2 of NR** |  | 189.5d? | 2017-12-15 A | 2018-06-15 A | 100% |  |  |  | R3 | 2096h | 2096h | NR_CPUP_Split | 40 | Ericsson | Rel-15 | 78 |  |  |
| 3744 | 1529.1 | Core part: Separation of CP and UP for Split Option 2 of NR |  | 131d? | 2017-12-15 A | 2018-06-15 A | 100% |  |  | finish no earlier than 2018-06-15 | R3 | 1048h | 1048h | NR_CPUP_Split-Core | 40 | Ericsson | Rel-15 | 78 | RP-181149 |  |
| 3745 | 1530 | **UE requirements for LTE DL 8Rx antenna ports** |  | 378d? | 2017-12-15 A | 2018-12-14 A | 100% |  |  |  | R4 | 5224h | 5224h | LTE_8Rx_AP_DL | 40 | Huawei | Rel-15 | 78 |  |  |
| 3746 | 1530.1 | Core part: UE requirements for LTE DL 8Rx antenna ports |  | 131d? | 2017-12-15 A | 2018-06-15 A | 100% |  |  | finish no earlier than 2018-06-15 | R4 | 1048h | 1048h | LTE_8Rx_AP_DL-Core | 40 | Huawei | Rel-15 | 78 | RP-180959 |  |
| 3747 | 1530.2 | Perf. part: UE requirements for LTE DL 8Rx antenna ports |  | 261d? | 2017-12-15 A | 2018-12-14 A | 100% |  |  | finish no earlier than 2018-12-15 | R4 | 2088h | 2088h | LTE_8Rx_AP_DL-Perf | 40 | Huawei | Rel-15 | 78 |  |  |
| 3748 | 1531 | **ProSe Support for Band 72 in LTE** |  | 378d? | 2017-12-15 A | 2018-12-14 A | 100% |  |  |  | R4 | 2624h | 2624h | LTE450_B72_Europe_ProSe | 40 | Airbus | Rel-15 | 78 |  |  |
| 3749 | 1531.1 | Core part: ProSe Support for Band 72 in LTE |  | 1d? | 2017-12-15 A | 2017-12-15 A | 100% |  |  | finish no earlier than 2017-12-15 | R4 | 8h | 8h | LTE450_B72_Europe_ProSe-Core | 40 | Airbus | Rel-15 | 78 |  |  |
| 3750 | 1531.2 | UE Conformance Test Aspects - ProSe Support for Band 72 in LTE |  | 66d? | 2018-09-14 A | 2018-12-14 A | 100% |  |  | finish no earlier than 2018-12-14 | R5 | 528h | 528h | LTE450_B72_Europe_ProSe-UEConTest | 41 | Airbus | Rel-15 | 81 |  |  |
| 3751 | 1532 | **LTE Advanced inter-band CA Rel-15 for xDL/1UL with x>5** |  | 378d? | 2017-12-15 A | 2018-12-14 A | 100% |  |  |  | R4 | 5224h | 5224h | LTE_CA_R15_xDL1UL | 40 | Qualcomm | Rel-15 | 78 |  |  |
| 3752 | 1532.1 | Core part:LTE Advanced inter-band CA Rel-15 for xDL/1UL with x>5 |  | 131d? | 2017-12-15 A | 2018-06-15 A | 100% |  |  | finish no earlier than 2018-06-15 | R4 | 1048h | 1048h | LTE_CA_R15_xDL1UL-Core | 40 | Qualcomm | Rel-15 | 78 |  | 36.715-00-01 |
| 3753 | 1532.2 | Perf. part:LTE Advanced inter-band CA Rel-15 for xDL/1UL with x>5 |  | 261d? | 2017-12-15 A | 2018-12-14 A | 100% |  |  | finish no earlier than 2018-12-15 | R4 | 2088h | 2088h | LTE_CA_R15_xDL1UL-Perf | 40 | Qualcomm | Rel-15 | 78 |  |  |
| 3754 | 1533 | **Performance requirements of interference cancellation receiver for LTE BS** |  | 96.25d? | 2017-06-15 A | 2017-09-15 A | 100% |  |  |  | R4 | 1072h | 1072h | LTE_IC_BS | 39 | China Telecom | Rel-15 | 76 |  |  |
| 3755 | 1533.1 | Perf. part: Performance requirements of interference cancellation receiver for LTE BS |  | 67d? | 2017-06-15 A | 2017-09-15 A | 100% |  |  | finish no earlier than 2017-09-15 | R4 | 536h | 536h | LTE_IC_BS-Perf | 39 | China Telecom | Rel-15 | 76 |  |  |
| 3756 | 1534 | **LTE CRS-Interference Mitigation performance requirements for single RX chain UEs** |  | 379d? | 2017-06-15 A | 2018-06-15 A | 100% |  |  |  | R4 | 4192h | 4192h | LTE_1RX_CRS_IM | 39 | Intel | Rel-15 | 76 |  |  |
| 3757 | 1534.1 | Perf. part: LTE CRS-Interference Mitigation performance requirements for single RX chain UEs |  | 262d? | 2017-06-15 A | 2018-06-15 A | 100% |  |  | finish no earlier than 2018-06-15 | R4 | 2096h | 2096h | LTE_1RX_CRS_IM-Perf | 39 | Intel | Rel-15 | 76 |  |  |
| 3758 | 1535 | **LTE Advanced intra-band CA Rel-15 for xDL/yUL including contiguous and non-contiguous spectrum** |  | 379d? | 2017-06-15 A | 2018-06-15 A | 100% |  |  |  | R4 | 6288h | 6288h | LTE_CA_R15_intra | 39 | Ericsson | Rel-15 | 76 |  |  |
| 3759 | 1535.1 | Core part: LTE Advanced intra-band CA Rel-15 for xDL/yUL including contiguous and non-contiguous spectrum |  | 262d? | 2017-06-15 A | 2018-06-15 A | 100% |  |  | finish no earlier than 2018-06-15 | R4 | 2096h | 2096h | LTE_CA_R15_intra-Core | 39 | Ericsson | Rel-15 | 76 |  | 36.715-00-00 |
| 3760 | 1535.2 | Perf. part: LTE Advanced intra-band CA Rel-15 for xDL/yUL including contiguous and non-contiguous spectrum |  | 262d? | 2017-06-15 A | 2018-06-15 A | 100% |  |  | finish no earlier than 2018-06-15 | R4 | 2096h | 2096h | LTE_CA_R15_intra-Perf | 39 | Ericsson | Rel-15 | 76 |  |  |

Notes:
- 3736: MDT = Minimization of Drive Tests¦no Perf. part¦may have SA5 impact
- 3737: MDT = Minimization of Drive Tests¦no Perf. part¦may have SA5 impact27/3/18: Compl:0%->30%2 ¦27/6/18: Compl:30%->95%
- 3738: tested: REL-15 WI LTE_MDT_BT_WLAN-Core; 14/1/20: 0%->100; 14/1/20: 100%->100
- 3739: follow-up WI of REL-15 SI FS_LTE_Aerial¦no Perf. part
- 3740: TR 36.7XX19/6/17: Compl:0%->15%¦30/6/17: 36.777 added;¦19/9/17: Compl:15%->30%¦8/1/18: Compl:30%->100%
- 3741: follow-up WI of REL-15 SI FS_LTE_Aerial¦no Perf. part¦27/3/18: Compl:0%->15%¦27/6/18: Compl:15%->99%;
- 3742: tested: REL-15 WI LTE_Aerial-Core; 8/10/19: WID:RP-182324->RP-191747; 14/1/20: WID:RP-191747->RP-192747; 14/1/20: 0%->100
- 3743: follow-up WI of REL-15 SI FS_NR_CPUP_Split¦introduction of E1 interface
- 3744: follow-up WI of REL-15 SI FS_NR_CPUP_Split¦introduction of E1 interface. 30/1/18: acronym updated27/3/18: Compl:0%->30%27/3/18: WID: RP-172831->RP-180326¦27/6/18: Compl:30%->100%¦27/6/18: Stat Rep: ->RP-181149
- 3745: follow-up WI of REL-15 SI FS_LTE_8Rx_AP_DL
- 3746: follow-up WI of REL-15 SI FS_LTE_8Rx_AP_DL27/3/18: Compl:0%->40%¦27/6/18: Compl:40%->100%
- 3747: follow-up WI of REL-15 SI FS_LTE_8Rx_AP_DL¦27/6/18: Compl:0%->30%¦26/3/19: 30%->100
- 3748: This WI was opened, a RAN4 CR RP-172572 was approved and the WI was completed all at RAN #78¦compare REL-15 WI LTE450_Europe_PPDR-Core¦16/1/19: WID:RP-172568->RP-182441
- 3749: This WI was opened, a RAN4 CR RP-172572 was approved and the WI was completed all at RAN #78¦compare REL-15 WI LTE450_Europe_PPDR-Core;
- 3750: 16/1/19: 0%->100
- 3751: basket CA WI¦TR 36.715-00-01
- 3752: basket CA WI¦TR 36.715-00-01¦27/3/18: Compl:0%->10%¦27/3/18: 36.715-00-01 added;¦27/6/18: Compl:10%->100%;
- 3753: basket CA WI27/3/18: CD:Sat 15/12/18->Fri 15/06/18 ¦27/6/18: Compl:0%->50%;¦16/1/19: 50%->100
- 3755: ¦19/9/17: Compl:0%->100%
- 3757: ¦19/9/17: Compl:0%->20%¦19/9/17: WID: RP-171465->RP-171831¦8/1/18: Compl:20%->60%¦27/3/18: Compl:60%->85%¦27/6/18: Compl:85%->100%
- 3759: 12/7/17: 36.715-00-00 added;¦19/9/17: Compl:0%->25% 8/1/18: Compl:25%->70%;27/3/18: Compl:70%->67%¦ ¦27/6/18: Compl:67%->100%;
- 3760: 19/9/17: Compl:0%->25%¦ 8/1/18: Compl:25%->70%¦8/1/18:27/3/18: Compl:70%->67%¦ ¦27/6/18: Compl:67%->100%;

| ID | WBS | Task | Duration | Start | Finish | Complete | Remaining | Baseline start | Baseline finish | Baseline duration | Total slack | Constraint | Resources | Work | Actual work | Acronym | PCG approved | WI rapporteur name | Release | TSG approved | Impacted TSs and TRs | WI rapporteur e-mail | Status Report | MCC resp | TSG stopped | Acronym_3GU_Export |
| --- | --- | --- | --- | --- | --- | --- | --- | --- | --- | --- | --- | --- | --- | --- | --- | --- | --- | --- | --- | --- | --- | --- | --- | --- | --- | --- |
| 3761 | 1536 | **LTE Advanced inter-band CA Rel-15 for 2DL/1UL** | 379d? | 2017-06-15 A | 2018-06-15 A | 100% |  |  |  |  |  |  | R4 | 6288h | 6288h | LTE_CA_R15_2DL1UL | 39 | Qualcomm | Rel-15 | 76 |  |  |  |  |  |  |
| 3762 | 1536.1 | Core part:LTE Advanced inter-band CA Rel-15 for 2DL/1UL | 262d? | 2017-06-15 A | 2018-06-15 A | 100% |  |  |  |  |  | finish no earlier than 2018-06-15 | R4 | 2096h | 2096h | LTE_CA_R15_2DL1UL-Core | 39 | Qualcomm | Rel-15 | 76 | 36.715-02-01 |  |  |  |  |  |
| 3763 | 1536.2 | Perf. part:LTE Advanced inter-band CA Rel-15 for 2DL/1UL | 262d? | 2017-06-15 A | 2018-06-15 A | 100% |  |  |  |  |  | finish no earlier than 2018-06-15 | R4 | 2096h | 2096h | LTE_CA_R15_2DL1UL-Perf | 39 | Qualcomm | Rel-15 | 76 |  |  |  |  |  |  |
| 3764 | 1537 | **LTE Advanced inter-band CA Rel-15 for 3DL/1UL** | 379d? | 2017-06-15 A | 2018-06-15 A | 100% |  |  |  |  |  |  | R4 | 6288h | 6288h | LTE_CA_R15_3DL1UL | 39 | Huawei | Rel-15 | 76 |  |  |  |  |  |  |
| 3765 | 1537.1 | Core part:LTE Advanced inter-band CA Rel-15 for 3DL/1UL | 262d? | 2017-06-15 A | 2018-06-15 A | 100% |  |  |  |  |  | finish no earlier than 2018-06-15 | R4 | 2096h | 2096h | LTE_CA_R15_3DL1UL-Core | 39 | Huawei | Rel-15 | 76 | 36.715-03-01 |  |  |  |  |  |
| 3766 | 1537.2 | Perf. part:LTE Advanced inter-band CA Rel-15 for 3DL/1UL | 262d? | 2017-06-15 A | 2018-06-15 A | 100% |  |  |  |  |  | finish no earlier than 2018-06-15 | R4 | 2096h | 2096h | LTE_CA_R15_3DL1UL-Perf | 39 | Huawei | Rel-15 | 76 |  |  |  |  |  |  |
| 3767 | 1538 | **LTE Advanced inter-band CA Rel-15 for 4DL/1UL** | 379d? | 2017-06-15 A | 2018-06-15 A | 100% |  |  |  |  |  |  | R4 | 6288h | 6288h | LTE_CA_R15_4DL1UL | 39 | Ericsson | Rel-15 | 76 |  |  |  |  |  |  |
| 3768 | 1538.1 | Core part:LTE Advanced inter-band CA Rel-15 for 4DL/1UL | 262d? | 2017-06-15 A | 2018-06-15 A | 100% |  |  |  |  |  | finish no earlier than 2018-06-15 | R4 | 2096h | 2096h | LTE_CA_R15_4DL1UL-Core | 39 | Ericsson | Rel-15 | 76 | 36.715-04-01 |  |  |  |  |  |
| 3769 | 1538.2 | Perf. part:LTE Advanced inter-band CA Rel-15 for 4DL/1UL | 262d? | 2017-06-15 A | 2018-06-15 A | 100% |  |  |  |  |  | finish no earlier than 2018-06-15 | R4 | 2096h | 2096h | LTE_CA_R15_4DL1UL-Perf | 39 | Ericsson | Rel-15 | 76 |  |  |  |  |  |  |
| 3770 | 1539 | **LTE Advanced inter-band CA Rel-15 for 5DL/1UL** | 379d? | 2017-06-15 A | 2018-06-15 A | 100% |  |  |  |  |  |  | R4 | 6288h | 6288h | LTE_CA_R15_5DL1UL | 39 | Nokia | Rel-15 | 76 |  |  |  |  |  |  |
| 3771 | 1539.1 | Core part:LTE Advanced inter-band CA Rel-15 for 5DL/1UL | 262d? | 2017-06-15 A | 2018-06-15 A | 100% |  |  |  |  |  | finish no earlier than 2018-06-15 | R4 | 2096h | 2096h | LTE_CA_R15_5DL1UL-Core | 39 | Nokia | Rel-15 | 76 | 36.715-05-01 |  |  |  |  |  |
| 3772 | 1539.2 | Perf. part:LTE Advanced inter-band CA Rel-15 for 5DL/1UL | 262d? | 2017-06-15 A | 2018-06-15 A | 100% |  |  |  |  |  | finish no earlier than 2018-06-15 | R4 | 2096h | 2096h | LTE_CA_R15_5DL1UL-Perf | 39 | Nokia | Rel-15 | 76 |  |  |  |  |  |  |
| 3773 | 1540 | **LTE Advanced inter-band CA Rel-15 for 2DL/2UL** | 379d? | 2017-06-15 A | 2018-06-15 A | 100% |  |  |  |  |  |  | R4 | 6288h | 6288h | LTE_CA_R15_2DL2UL | 39 | Huawei | Rel-15 | 76 |  |  |  |  |  |  |
| 3774 | 1540.1 | Core part:LTE Advanced inter-band CA Rel-15 for 2DL/2UL | 262d? | 2017-06-15 A | 2018-06-15 A | 100% |  |  |  |  |  | finish no earlier than 2018-06-15 | R4 | 2096h | 2096h | LTE_CA_R15_2DL2UL-Core | 39 | Huawei | Rel-15 | 76 | 36.715-02-02 |  |  |  |  |  |
| 3775 | 1540.2 | Perf. part:LTE Advanced inter-band CA Rel-15 for 2DL/2UL | 262d? | 2017-06-15 A | 2018-06-15 A | 100% |  |  |  |  |  | finish no earlier than 2018-06-15 | R4 | 2096h | 2096h | LTE_CA_R15_2DL2UL-Perf | 39 | Huawei | Rel-15 | 76 |  |  |  |  |  |  |
| 3776 | 1541 | **LTE Advanced inter-band CA Rel-15 for xDL/2UL with x=3,4,5** | 379d? | 2017-06-15 A | 2018-06-15 A | 100% |  |  |  |  |  |  | R4 | 6288h | 6288h | LTE_CA_R15_xDL2UL | 39 | LG Electronics | Rel-15 | 76 |  |  |  |  |  |  |
| 3777 | 1541.1 | Core part:LTE Advanced inter-band CA Rel-15 for xDL/2UL with x=3,4,5 | 262d? | 2017-06-15 A | 2018-06-15 A | 100% |  |  |  |  |  | finish no earlier than 2018-06-15 | R4 | 2096h | 2096h | LTE_CA_R15_xDL2UL-Core | 39 | LG Electronics | Rel-15 | 76 | 36.715-00-02 |  |  |  |  |  |
| 3778 | 1541.2 | Perf. part:LTE Advanced inter-band CA Rel-15 for xDL/2UL with x=3,4,5 | 262d? | 2017-06-15 A | 2018-06-15 A | 100% |  |  |  |  |  | finish no earlier than 2018-06-15 | R4 | 2096h | 2096h | LTE_CA_R15_xDL2UL-Perf | 39 | LG Electronics | Rel-15 | 76 |  |  |  |  |  |  |
| 3779 | 1542 | UE Conformance Test Aspects – Rel-15 CA configurations | 1360d? | 2017-09-15 A | 2022-12-01 A | 100% |  |  |  |  |  | finish no earlier than 2022-12-01 | R5 | 10880h | 10880h | LTE_CA_R15-UEConTest | 39 | Leif MATTISSON, Ericsson | Rel-15 | 77 |  | Leif[dot]mattisson[at]ericsson[dot]com | RP-222814 |  |  |  |
| 3780 | 1543 | **Stopped - LTE UE Total Radiated Power (TRP) and Total Radiated Sensitivity (TRS) and UTRA Hand Phantom related UE TRP and TRS Requirements** | 1794.25d? | 2012-12-15 A | 2017-09-13 | 82% | 324.56d? | 2013-03-15 | 2015-06-12 | 591d? | 40947.6d |  |  | 17816h | 14593.1h | LTE_UTRA_TRP_TRS | 30 | Nokia | Rel-15 | 58 | UTRA; LTE | petri.j.vasenkari@nokia.com |  | Issam | 80 | LTE_UTRA_TRP_TRS |
| 3781 | 1543.1 | Stopped - Core part: LTE UE TRP and TRS and UTRA Hand Phantom related UE TRP and TRS Requirements | 1244d? | 2012-12-15 A | 2016-06-07 | 85% | 186.6d? | 2013-03-15 | 2014-09-12 | 393d? | 41426.9d | finish no earlier than 2017-12-15 | R4 | 9952h | 8459.2h | LTE_UTRA_TRP_TRS-Core | 30 | Nokia | Rel-15 | 58 | 25.144; New 37.144 | petri.j.vasenkari@nokia.com |  | Issam | 80 | LTE_UTRA_TRP_TRS-Core |
| 3782 | 1543.2 | Stopped - Test part: LTE UE TRP and TRS and UTRA Hand Phantom | 983d? | 2014-03-15 A | 2017-09-13 | 78% | 216.26d? | 2014-03-06 | 2015-06-12 | 332d? | 40947.6d | finish no earlier than 2017-12-15 | R5 | 7864h | 6133.92h | LTE_UTRA_TRP_TRS-UEConTest | 32 | ZTE | Rel-15 | 63 | New 37.544 | TAYLOR Carolyn (carolyn.tayl@zte.com.cn) |  | Ingbert | 80 | LTE_UTRA_TRP_TRS-UEConTest |
| 3783 | 1544 | **Further enhancements for Extended Coverage GSM for support of Cellular Internet of Things** | 190.5d? | 2018-03-15 A | 2018-09-14 | 90% | 19.05d? |  |  |  | 40568.1d |  | R6 | 3168h | 2115.17h | CIoT_EC_GSM_fenh | 40 | Nokia | Rel-15 | 79 |  |  |  |  |  |  |
| 3784 | 1544.1 | Core part: Further enhancements for Extended Coverage GSM for support of Cellular Internet of Things | 132d? | 2018-03-15 A | 2018-09-03 | 80% | 26.4d? |  |  |  | 40579.4d | finish no earlier than 2018-09-15 | R6 | 1056h | 844.8h | CIoT_EC_GSM_fenh-Core | 40 | Nokia | Rel-15 | 79 |  |  |  |  |  |  |
| 3785 | 1544.2 | Perf. part: Further enhancements for Extended Coverage GSM for support of Cellular Internet of Things | 132d? | 2018-03-15 A | 2018-09-14 A | 100% |  |  |  |  |  | finish no earlier than 2018-09-15 | R6 | 1056h | 1056h | CIoT_EC_GSM_fenh-Perf | 40 | Nokia | Rel-15 | 79 |  |  |  |  |  |  |

Notes:
- 3762: 12/7/17: 36.715-02-01 added;19/9/17: Compl:0%->20%¦ 8/1/18: Compl:20%->30%¦27/3/18: Compl:30%->40%¦ ¦27/6/18: Compl:40%->100%;
- 3763: ¦19/9/17: Compl:0%->20% 8/1/18: Compl:20%->30%;27/3/18: Compl:30%->40% ¦27/6/18: Compl:40%->100%;
- 3765: 12/7/17: 36.715-03-01 added;¦19/9/17: Compl:0%->20%¦ 8/1/18: Compl:20%->40%¦27/3/18: Compl:40%->65%¦ ¦27/6/18: Compl:65%->100%;
- 3766: ¦19/9/17: Compl:0%->20%¦ 8/1/18: Compl:20%->40%;27/3/18: Compl:40%->65%¦ ¦27/6/18: Compl:65%->100%;
- 3768: 12/7/17: 36.715-04-01 added;¦19/9/17: Compl:0%->54% 8/1/18: Compl:54%->65%;27/3/18: Compl:65%->63% ¦27/6/18: Compl:63%->100%;
- 3769: 19/9/17: Compl:0%->54%¦ 8/1/18: Compl:54%->65%¦27/3/18: Compl:65%->63% ¦27/6/18: Compl:63%->100%;
- 3771: 12/7/17: 36.715-05-01 added;19/9/17: Compl:0%->20%¦ 8/1/18: Compl:20%->50%;27/3/18: Compl:50%->75% ¦27/6/18: Compl:75%->100%;
- 3772: ¦19/9/17: Compl:0%->20% 8/1/18: Compl:20%->50%¦27/3/18: Compl:50%->75%¦ ¦27/6/18: Compl:75%->100%;
- 3774: 12/7/17: 36.715-02-02 added;¦19/9/17: Compl:0%->20%¦ 8/1/18: Compl:20%->40%;27/3/18: Compl:40%->60%¦27/6/18: Compl:60%
- 3775: ¦19/9/17: Compl:0%->20%¦ 8/1/18: Compl:20%->40%;27/3/18: Compl:40%->60%¦27/6/18: Compl:60%->100%
- 3777: 12/7/17: 36.715-00-02 added;¦19/9/17: Compl:0%->20% 8/1/18: Compl:20%->50%¦27/3/18: Compl:50%->80%¦ ¦27/6/18:
- 3778: 19/9/17: CD:Sat 15/09/18->Fri 15/06/18¦ 8/1/18: Compl:0%->50%¦27/3/18: Compl:50%->80% ¦27/6/18: Compl:80%->100%;
- 3779: ¦8/1/18: Compl:0%->7%¦27/3/18: Compl:7%->8% ;; 8/10/20: 9%->22; 8/10/20: FCD:14/06/2019->12/20; 8/4/21: FCD:11/12/2020->09/21; 8/4/21: 22%->22; 2/7/21: FCD:Wed 08/09/->03/22; 2/7/21: 22%->24; ; 20/6/22: Rapporteur: Ericsson->Leif MATTISSON, Er...;...; 9/1/23: 100%->100
- 3780: Triggered by Rel-11 TR 37.902 Study on Measurements of radio performances for LTE terminals - TRP and TRS test methodology (FS_LTE_OTA) UID_550022
- 3781: ¦CD:Wed 18/03/15->Sun 15/03/15¦Rel-12->Rel-13¦Stat Rep: RP-141158->RP-141973 1st Apr 15: Compl:35%->40% 1st Apr 15: Stat Rep: RP-141973->RP-150104 03/07/15: Stat Rep: RP-150104->RP-150615 29/09/15: Compl:40%->50% 29/09/15: Stat Rep: RP-150615->RP-15
- 3782: Stat Rep: RP-141132->RP-141848¦Rel 12->Rel13 1st Apr 15: Compl:15%->20% 1st Apr 15: CD:Mon 15/06/15->Wed 15/06/16 1st Apr 15: WID: RP-140090->RP-150070 1st Apr 15: Stat Rep: RP-141848->RP-150069 03/07/15: Compl:20%->25% 03/07/15: Stat Rep: RP-150069->
- 3783: follow-up WI of REL-14 WI CIoT_EC_GSM_radio_enh
- 3784: follow-up WI of REL-14 WI CIoT_EC_GSM_radio_enh¦27/6/18: Compl:0%->80%;
- 3785: follow-up WI of REL-14 WI CIoT_EC_GSM_radio_enh¦27/6/18: Compl:0%->80%;¦10/9/18: 80%->100

| ID | WBS | Task | Type | Duration | Start | Finish | Complete | Baseline start | Baseline finish | Baseline duration | Constraint | Resources | Work | Actual work | Acronym | PCG approved | WI rapporteur name | Release | TSG approved | Impacted TSs and TRs | WI rapporteur e-mail | TSG stopped | Status Report | MCC resp | Acronym_3GU_Export |
| --- | --- | --- | --- | --- | --- | --- | --- | --- | --- | --- | --- | --- | --- | --- | --- | --- | --- | --- | --- | --- | --- | --- | --- | --- | --- |
| 3786 | 1545 | **LTE Advanced inter-band CA Rel-15 for xDL/3UL with x=3,4,5** |  | 96.25d? | 2018-03-15 A | 2018-06-15 A | 100% |  |  |  |  | R4 | 1072h | 1072h | LTE_CA_R15_xDL3UL | 40 | KDDI | Rel-15 | 79 |  |  |  |  |  |  |
| 3787 | 1545.1 | Core part: LTE Advanced inter-band CA Rel-15 for xDL/3UL with x=3,4,5 |  | 67d? | 2018-03-15 A | 2018-06-15 A | 100% |  |  |  | finish no earlier than 2018-06-15 | R4 | 536h | 536h | LTE_CA_R15_xDL3UL-Core | 40 | KDDI | Rel-15 | 79 |  |  |  |  |  |  |
| 3788 | 1545.2 | Perf. Part: LTE Advanced inter-band CA Rel-15 for xDL/3UL with x=3,4,5 | milestone | 0d? | 2018-05-15 A | 2018-05-15 A | 100% |  |  |  | finish no earlier than 2018-06-15 | R4 |  |  | LTE_CA_R15_xDL3UL-Perf | 41 | KDDI | Rel-15 | 80 |  |  |  |  |  |  |
| 3789 | 1546 | **Addition of Power Class 1 UE to bands B31/B72 for LTE** |  | 284.75d? | 2018-03-15 A | 2018-12-14 A | 100% |  |  |  |  | R4 | 2640h | 2640h | LTE_PC1_B31_B72 | 40 | Airbus | Rel-15 | 79 |  |  |  |  |  |  |
| 3790 | 1546.1 | Core part: Addition of Power Class 1 UE to bands B31/B72 for LTE |  | 67d? | 2018-03-15 A | 2018-06-15 A | 100% |  |  |  | finish no earlier than 2018-12-15 | R4 | 536h | 536h | LTE_PC1_B31_B72-Core | 40 | Airbus | Rel-15 | 79 |  |  |  |  |  |  |
| 3791 | 1546.2 | UE Conformance Test Aspects - Addition of Power Class 1 UE to bands B31/B72 for LTE |  | 66d? | 2018-09-14 A | 2018-12-14 A | 100% |  |  |  | finish no earlier than 2018-12-14 | R5 | 528h | 528h | LTE_PC1_B31_B72-UEConTest | 41 | Airbus | Rel-15 | 81 |  |  |  |  |  |  |
| 3792 | 1547 | Release 15 Studies | milestone | 0d? | 2016-06-09 A | 2016-06-09 A | 100% |  |  |  | finish no earlier than 2016-06-09 |  |  |  |  |  |  | Rel-15 |  |  |  |  |  |  |  |
| 3793 | 1548 | Release 15 Studies on 5G | milestone | 0d? | 2016-06-09 A | 2016-06-09 A | 100% |  |  |  | finish no earlier than 2016-06-09 |  |  |  |  |  |  | Rel-15 |  |  |  |  |  |  |  |
| 3794 | 1549 | Study on management aspects of virtualized network functions that are part of the NR |  | 325d? | 2016-09-19 A | 2017-12-15 A | 100% |  |  |  | finish no earlier than 2017-12-15 | S5 | 2600h | 2600h | FS_MA_RNVNF | 37 | Intel (Joey Chou | Rel-15 | 73 | 32.864 | joey.chou@intel.com |  |  |  |  |
| 3795 | 1550 | Study on CU-DU lower layer split for New Radio |  | 328d? | 2017-03-15 A | 2018-06-15 A | 100% |  |  |  | finish no earlier than 2018-06-15 | R3 | 2624h | 2624h | FS_NR_CU_DU_LLS | 38 | NTT DOCOMO | Rel-15 | 75 | 38.816 |  |  |  |  |  |
| 3796 | 1551 | Study on NR to support non-terrestrial networks |  | 328d? | 2017-03-15 A | 2018-06-15 A | 100% |  |  |  | finish no earlier than 2018-06-15 | R1 | 2624h | 2624h | FS_NR_nonterr_nw | 38 | Thales | Rel-15 | 75 | 38.811 |  |  |  |  |  |
| 3797 | 1552 | STOPPED AT SA#77 - SA3 aspects on Study on Architecture and Security for Next Generation System |  | 467d? | 2016-03-01 A | 2017-12-12 A | 100% |  |  |  | finish no earlier than 2017-12-12 | S3 | 3736h | 3736h | FS_NSA | 36 | Vesa Torvinen, Ericsson | Rel-15 | 71 | 33.899 | vesa.torvinen@ericsson.com |  |  |  |  |
| 3798 | 1553 | Study on separation of CP and UP for split option 2 of NR |  | 132d? | 2017-06-15 A | 2017-12-15 A | 100% |  |  |  | finish no earlier than 2017-12-15 | R3 | 1056h | 1056h | FS_NR_CPUP_Split | 39 | Ericsson | Rel-15 | 76 | 38.806 |  |  |  |  |  |
| 3799 | 1554 | Release 15 Studies on 4G/LTE | milestone | 0d? | 2016-06-09 A | 2016-06-09 A | 100% |  |  |  | finish no earlier than 2016-06-09 |  |  |  |  |  |  | Rel-15 |  |  |  |  |  |  |  |
| 3800 | 1555 | Stopped - Study on LTE bandwidth flexibility enhancements |  | 263d? | 2016-03-15 A | 2017-03-15 A | 100% |  |  |  | finish no earlier than 2017-03-15 | R4 | 2104h | 2104h | FS_LTE_BW_flex | 36 | Huawei | Rel-15 | 71 | 36.740 |  | 80 |  |  |  |
| 3801 | 1556 | Study on interference cancellation receiver for LTE BS |  | 196d? | 2016-09-15 A | 2017-06-15 A | 100% |  |  |  | finish no earlier than 2017-06-15 | R4 | 1568h | 1568h | FS_LTE_IC_BS | 37 | China Telecom | Rel-15 | 73 | 36.766 |  |  |  |  |  |
| 3802 | 1557 | Study on uplink data compression in LTE |  | 197d? | 2016-12-15 A | 2017-09-15 A | 100% |  |  |  | finish no earlier than 2017-09-15 | R2 | 1576h | 1576h | FS_LTE_UDC | 38 | CATT | Rel-15 | 74 | 36.754 |  |  |  |  |  |
| 3803 | 1558 | Study on LTE DL 8Rx antenna ports |  | 132d? | 2017-06-15 A | 2017-12-15 A | 100% |  |  |  | finish no earlier than 2017-12-15 | R4 | 1056h | 1056h | FS_LTE_8Rx_AP_DL | 39 | Huawei | Rel-15 | 76 | 36.757 |  |  |  |  |  |
| 3804 | 1559 | Other Release 15 Studies |  | 136d? | 2017-09-08 A | 2018-03-16 A | 100% |  |  |  | finish no earlier than 2018-03-16 |  |  |  |  |  |  | Rel-15 |  |  |  |  |  |  |  |
| 3805 | 1560 | Study on Update to fixed-point basic operators |  | 135d? | 2017-09-08 A | 2018-03-15 A | 100% |  |  |  | finish no earlier than 2018-03-15 | S4 | 1080h | 1080h | FS_BASOP | 39 | Jelinek, Milan, VoiceAge Corporation | Rel-15 | 77 | New; 26.973 | Milan.Jelinek@USherbrooke.ca |  |  |  |  |
| 3806 | 1561 | Study on further enhancements to LTE Device to Device (D2D), UE to network relays for IoT (Internet of Things) and wearables |  | 460d? | 2016-03-15 A | 2017-12-15 A | 100% |  |  |  | finish no earlier than 2017-12-15 | R2 | 3680h | 3680h | FS_feD2D_IoT_relay_wearable | 36 | Qualcomm | Rel-15 | 71 | 36.746 |  |  |  |  |  |
| 3807 | 1562 | Study on Energy Efficiency Aspects of 3GPP Standards |  | 327d? | 2016-03-11 A | 2017-06-09 A | 100% |  |  |  | finish no earlier than 2017-06-09 | SP | 2616h | 2616h | FS_ENEFF | 36 | Orange, Xiaobao Chen | Rel-15 | 71 | 21.866 | xiaobao.chen@orange.com |  | _SP-170533 |  |  |
| 3808 | 1563 | Study on evaluation methodology of new V2X use cases for LTE and NR |  | 328d? | 2017-03-15 A | 2018-06-15 A | 100% |  |  |  | finish no earlier than 2018-06-15 | R1 | 2624h | 2624h | FS_LTE_NR_V2X_eval | 38 | LG Electronics | Rel-15 | 75 | 37.885 |  |  |  |  |  |
| 3809 | 1564 | Study on FEC for MC Services |  | 204d? | 2017-06-05 A | 2018-03-15 A | 100% |  |  |  | finish no earlier than 2018-03-15 | S4 | 1632h | 1632h | FS_FEC_MCS | 39 | Lambrou, John - Motorola Solutions | Rel-15 | 76 | 26.881 | john (dot) lambrou (at) motorolasolutions (dot) com |  |  |  |  |
| 3810 | 1565 | Study on Enhanced Isolated E-UTRAN Operation for Public Safety |  | 205d? | 2016-03-07 A | 2016-12-15 A | 100% |  |  |  | finish no earlier than 2016-12-15 | S2 | 1640h | 1640h | FS_IOPS_LB | 36 | Antoine Mouquet, Orange | Rel-15 | 71 | 23.798 | antoine.mouquet@orange.com |  |  |  |  |
| 3811 | 1566 | Study on Management Enhancement of CUPS of EPC Nodes |  | 269d? | 2016-12-01 A | 2017-12-12 A | 100% |  |  |  | finish no earlier than 2017-12-12 | S5 | 2152h | 2152h | FS_MECUPS | 38 | Huawei; Jiang, Junyi | Rel-15 | 74 | 32.867 | jiangjunyi@huawei.com |  |  |  |  |
| 3812 | 1567 | Study on Technical Requirements for a new secure platform for 3GPP applications |  | 328d? | 2016-06-13 A | 2017-09-12 A | 100% |  |  |  | finish no earlier than 2017-09-12 | C6 | 2624h | 2624h | FS_NG_SP | 37 | Heiko Kruse | Rel-15 | 72 | 31.801 | heiko.kruse@safrangroup.com |  |  |  |  |
| 3813 | 1568 | Study on technical requirements for a new secure platform for 3GPP applications |  | 140d? | 2017-03-03 A | 2017-09-14 A | 100% |  |  |  | finish no earlier than 2017-09-14 | C6 | 1120h | 1120h | FS_NG_SP2 | 38 | Heiko Kruse | Rel-15 | 75 | 31.801 | heiko.kruse@safrangroup.com |  |  |  |  |
| 3814 | 1569 | Study on scheduling enhancements with CA for UMTS |  | 67d? | 2017-03-15 A | 2017-06-15 A | 100% |  |  |  | finish no earlier than 2017-06-15 | R1 | 536h | 536h | FS_UTRA_CA_sched_enh | 38 | Huawei | Rel-15 | 75 | 25.708 |  |  |  |  |  |
| 3815 | 1570 | Study on Architecture Evolution for E-UTRAN |  | 262d? | 2017-03-15 A | 2018-03-15 A | 100% |  |  |  | finish no earlier than 2018-03-15 | R3 | 2096h | 2096h | FS_LTE_arch_evo | 38 | China Unicom | Rel-15 | 75 | 36.756; 37.876 |  |  |  |  |  |
| 3816 | 1571 | Study on Enhanced Acoustic Test Specifications |  | 1246d? | 2013-03-18 A | 2017-12-12 A | 100% | 2013-03-06 | 2014-09-17 | 401d? | finish no earlier than 2017-12-12 | S4 | 9968h | 9968h | FS_SEATS | 30 | Knowles, Intel | Rel-15 | 59 | 26.931 | Scott Isabelle (Knowles), David Isherwood (Intel) |  |  | Paolo | FS_SEATS |
| 3817 | 1572 | Study on User Services Enhancements in 3GPP for TV Services |  | 328d? | 2016-06-13 A | 2017-09-12 A | 100% |  |  |  | finish no earlier than 2017-09-12 | S4 | 2624h | 2624h | FS_USE_3GPP_4_TV | 37 | Thomas Stockhammer, Qualcomm Incorporated | Rel-15 | 72 | 26.9xx; 26.917 | tsto@qti.qualcomm.com |  |  |  |  |
| 3818 | 1573 | Study on OAM support for assessment of energy efficiency in mobile access networks |  | 421d? | 2015-11-02 A | 2017-06-09 A | 100% |  |  |  | finish no earlier than 2017-06-09 | S5 | 3368h | 3368h | FS_OAM_EE | 36 | Cornily,Jean-Michel, ORANGE | Rel-15 | 70 | 32.856 | jeanmichel.cornily@orange.com |  |  |  |  |
| 3819 | 1574 | Study on Management aspects of selected IoT-related features |  | 322d? | 2016-09-19 A | 2017-12-12 A | 100% |  |  |  | finish no earlier than 2017-12-12 | S5 | 2576h | 2576h | FS_OAM_IOT | 37 | Cisco Systems / Yanover, Vladimir | Rel-15 | 73 | 32.857 |  |  |  |  |  |
| 3820 | 1575 | Study on OAM aspects of SON for AAS-based deployments |  | 421d? | 2015-11-02 A | 2017-06-09 A | 100% |  |  |  | finish no earlier than 2017-06-09 | S5 | 3368h | 3368h | FS_OAM_SON_AAS | 36 | Nokia Networks (Yizhi Yao) | Rel-15 | 70 | (new) | Yizhi.yao@nokia.com |  |  |  |  |
| 3821 | 1576 | Study on OAM aspects of LTE and WLAN integration |  | 204d? | 2017-06-05 A | 2018-03-15 A | 100% |  |  |  | finish no earlier than 2018-03-15 | S5 | 1632h | 1632h | FS_OAM_LWI | 39 | Yizhi Yao, Intel Corporation | Rel-15 | 76 | new; 32.868 | yizhi.yao@intel.com |  |  |  |  |
| 3822 | 1577 | Study on Overload Control for Diameter Charging Applications |  | 653d? | 2015-06-18 A | 2017-12-15 A | 100% |  |  |  | finish no earlier than 2017-12-15 | S5 | 5224h | 5224h | FS_DOCME_CH | 35 | GUO Wenjie, ZTE | Rel-15 | 68 | New 32.869 | guo.wenjie1@zte.com.cn |  |  |  |  |
| 3823 | 1578 | Study on forward compatibility for 3GPP Diameter Charging Applications |  | 194d? | 2016-09-19 A | 2017-06-15 A | 100% |  |  |  | finish no earlier than 2017-06-15 | S5 | 1552h | 1552h | FS_FWDCA | 37 | Nokia, Maryse <dot> Gardella <at> Nokia <dot> com | Rel-15 | 73 | 32.870 | Nokia, Maryse <dot> Gardella <at> Nokia <dot> com |  |  |  |  |
| 3824 | 1579 | Study on Implementation for the Partitioning of Itf-N |  | 534d? | 2016-03-01 A | 2018-03-15 A | 100% |  |  |  | finish no earlier than 2018-03-15 | S5 | 4272h | 4272h | FS_IMP_ITFN | 36 | Hu, Yaxi, China Mobile | Rel-15 | 71 | New 32.880 | huyaxi@cmdi.chinamobile.com |  |  |  |  |
| 3825 | 1580 | Study on Management Aspects of Next Generation Network architecture and features |  | 393d? | 2016-06-13 A | 2017-12-12 A | 100% |  |  |  | finish no earlier than 2017-12-12 | S5 | 3144h | 3144h | FS_MAN_NGNAF | 37 | Nokia Networks, Yizhi Yao | Rel-15 | 72 | (new); 28.802 | Yizhi.yao@nokia.com |  |  |  |  |
| 3826 | 1581 | Study on Management and Orchestration Architecture of Next Generation Network and Service |  | 393d? | 2016-06-13 A | 2017-12-12 A | 100% |  |  |  | finish no earlier than 2017-12-12 | S5 | 3144h | 3144h | FS_NGNS_MOA | 37 | Huawei Technologies, Zou Lan | Rel-15 | 72 | xy.abc; 28.800 | zoulan@huawei.com |  |  |  |  |
| 3827 | 1582 | Study on SON for eCoMP for LTE |  | 263d? | 2016-06-15 A | 2017-06-15 A | 100% |  |  |  | finish no earlier than 2017-06-15 | R3 | 2104h | 2104h | FS_LTE_SON_eCOMP | 37 | Nokia | Rel-15 | 72 |  |  |  |  |  |  |
| 3828 | 1583 | Stopped - Study on IMS Enhanced Spoofed Call Prevention and Detection |  | 849d? | 2014-09-19 A | 2017-12-15 A | 100% |  |  |  | finish no earlier than 2017-12-15 | S3 | 6792h | 6792h | FS_ESCAPADES | 33 | Sprint | Rel-15 | 64 | 33.832 | Gregory.schumacher@sprint.com | 80 |  |  | FS_ESCAPADES |
| 3829 | 1584 | Study on Volume Based Charging Aspects for VoLTE |  | 269d? | 2017-06-05 A | 2018-06-14 A | 100% |  |  |  | start no earlier than 2017-06-05 | S5 | 2152h | 2152h | FS_VBCLTE | 39 | Chen, Ai, China Mobile | Rel-15 | 76 | new; 32.848 | chenai@chinamobile.com |  |  |  |  |
| 3830 | 1585 | STOPPED - Study on UE characteristics and performance for Video |  | 339d? | 2016-03-01 A | 2017-06-15 A | 100% |  |  |  | finish no earlier than 2017-06-15 | S4 | 2712h | 2712h | FS_UE_VTPerf | 36 | Stéphane PROUST, Orange | Rel-15 | 71 | 26.932 | stephane.proust@orange.com | 80 |  |  |  |
| 3831 | 1586 | Study on UE Application Layer Data Throughput Performance Expansion for CA |  | 131d? | 2017-12-15 A | 2018-06-15 A | 100% |  |  |  | finish no earlier than 2018-06-15 | R5 | 1048h | 1048h | FS_UE_App_Data_Perf_CA | 40 | PCTEST Engineering Lab | Rel-15 | 78 |  |  |  |  |  |  |
| 3832 | 1587 | Study on system and functional aspects of Energy Efficiency in 5G networks |  | 400d? | 2017-06-05 A | 2018-12-14 A | 100% |  |  |  | finish no earlier than 2018-12-14 | S5 | 3200h | 3200h | FS_EE_5G | 39 | CORNILY, Jean-Michel, ORANGE | Rel-15 | 76 | new; 32.872; 32.972 | jeanmichel.cornily@orange.com |  |  |  |  |
| 3833 | 1588 | --- RELEASE 14 --- | milestone | 0d? | 2014-12-12 A | 2014-12-12 A | 100% |  |  |  | finish no earlier than 2014-12-12 |  |  |  |  |  |  | Rel-14 |  |  |  |  |  |  |  |
| 3834 | 1589 | Release 14 on Mission Critical | milestone | 0d? | 2016-06-09 A | 2016-06-09 A | 100% |  |  |  | finish no earlier than 2016-06-09 |  |  |  |  |  |  | Rel-14 |  |  |  |  |  |  |  |

Notes:
- 3786: basket CA WI¦no Perf. part
- 3787: basket CA WI¦no Perf. part¦27/6/18: Compl:0%->100%¦…
- 3788: Perf. Part was introduced and completed at RAN #80
- 3789: to add Power Class 1 (+31dBm) for UE operating in Europe @ 450MHz in frequency bands that are suitable for BB-PPDR operation, i.e. band 31 and band 72;
- 3790: to add Power Class 1 (+31dBm) for UE operating in Europe @ 450MHz in frequency bands that are suitable for BB-PPDR operation, i.e. band 31 and band 72;27/6/18: moved from Rel-16
- 3791: 16/1/19: 0%->100
- 3792: -
- 3793: -
- 3794: 6/10/16: Acronym FS_MA_RVNF ->FS_MA_RNVNF ¦6/10/16: 32.864 added¦1/12/16: 0%->5¦6/3/17: 5%->10¦7/6/17: 10%->40¦11/9/17: 40%->70¦15/12/17: 70%->100¦15/12/17: FCD:09/17->12/17
- 3795: CU = central unit, DU = distributed unit¦results will be captured in existing TR 38.801¦19/9/17: Compl:0%->30%¦19/9/17: WID: RP-170818->RP-171717¦15/12/17: 38.816 added;¦8/1/18: Compl:30%->95%¦8/1/18: CD:Fr ¦27/6/18
- 3796: TR 38.8XX19/6/17: Compl:0%->25%19/6/17: CD:Fri 15/12/17->Thu 15/03/1819/6/17: WID: RP-170717->RP-171450¦30/6/17: 38.811 added;¦19/9/17: Compl:25%->40%¦8/1/18: CD:Thu 15/03/18->Fri 15/06/18¦27/3/18: Compl:40%->45%¦27/6/18: Compl:4
- 3797: 19/9/16: 0%->25¦22/9/16: WID:SP-160227->SP-160727¦22/9/16: FCD:12/16->03/17¦1/12/16: 25%->45¦6/3/17: 45%->60¦7/6/17: FCD:03/17->12/17 so Rel-14->Rel-15¦7/6/17: 60%->65¦11/9/17: 65%->100
- 3798: 19/9/17: Compl:0%->45%19/9/17: WID: RP-171421->RP-171905¦15/12/17: 38.806 added;¦8/1/18: Compl:45%->100%
- 3799: -
- 3800: 1/7/16: Compl:0%->50%¦28/7/16: 36.740 added¦26/9/16: WID: RP-161328->RP-161670¦20/12/16: CD:Thu 15/0;21/3/17: CD:Fri 15 12/7/17: 50%->100 since declared as stopped
- 3801: 6/10/16: 36.766 added¦20/12/16: Compl:0%->35% 21/3/17: Compl:35%->65%¦19/6/17: Compl:65%->100%
- 3802: ¦21/3/17: WID: RP-162541->RP-170403¦21/3/17: 36.754 added;19/6/17: Compl:0%->90%¦19/9/17: Compl:90%->100
- 3803: 12/7/17: 36.757 added;¦19/9/17: Compl:0%->35%¦ 8/1/18: Compl:35%->100%
- 3804: -
- 3805: 15/12/17: 26.973 added;¦15/12/17: 0%->80¦16/3/18: 80%->100
- 3806: 1/7/16: Compl:0%->2%;26/9/16: Compl:2%->5%¦6/10/16: 36.746 added¦20/12/16: Compl:5%->15%;21/3/17: Compl:15%->35%…19/6/17: ;
- 3807: 28/7/16: 21.866 added;¦9/6/17: FCD:12/16->9/6/17 (Rel-14->Rel-15)¦0%->100
- 3808: TR 38.8XX19/6/17: WID: RP-170837->RP-171093¦12/7/17: 37.885 added;19/9/17: Compl:0%->5%¦8/1/18: Compl:5%->10%¦8/1/18: CD:Fri 15/12/17->Thu 15/03/18¦27/3/18: Compl:10%->30%¦27/3/18: CD:Thu 15/03/18->Fri 15/06/18¦27
- 3809: 11/9/17: 0%->15¦15/12/17: 15%->60¦15/12/17: FCD:12/17->03/18¦16/3/18: 60%->100
- 3810: 9/6/16: 0%->6¦28/7/16: 23.798 added¦1/12/16: FCD:09/16->12/16¦1/12/16: 6%->15. 7/12/16: Moved from Rel-14 according to SP-160806.¦6/3/17: 15%->50¦7/6/17: 50%->100
- 3811: 6/3/17: 0%->5¦7/6/17: 5%->40¦7/6/17: FCD:09/17->12/17¦11/9/17: 40%->50¦15/12/17: 50%->100
- 3812: 16/9/16: 0%->15. ¦5/6/17: 15%->70. 5/6/17: moved to Rel-15 (talks with P. Jolivet)¦5/6/17: FCD:12/16->09/20¦15/12/17: 70%->100
- 3813: 21/3/17: 31.801 added;¦11/9/17: 0%->70¦15/12/17: 70%->100
- 3814: TR 25.7XX¦19/6/17: Compl:0%->100%¦ 12/7/17: 25.708 added;
- 3815: TR 36.8XX¦12/7/17: 36.756 added;19/9/17: Compl:0%->40%¦15/12/17: 37.876 added;¦8/1/18: Compl:40%->827/3/18: Compl:85%->100%
- 3816: SP#65 completion 09/14=>12/14. Moved to Rel-13. Dec.14: 30->35%, CD 12/14->03/15. Mar.15: CD: 06/16. 40%¦June2015: Compl:40%->45. . 15/4/16: moved from R 21/3/17: Moved from Rel-14 (not completed on time)¦7/6/17: FCD:06/17->12/17¦11/9/17: 80%->8
- 3817: 19/9/16: 0%->30¦6/10/16: 26.917 added¦1/12/16: 30%->60¦1/12/16: FCD:12/16->03/17¦6/3/17: 60%->75¦6/3/17: FCD:03/17->06/17¦21/3/17: Moved from Rel-14 (not completed on time)¦7/6/17: 75%->80¦7/6/17: FCD:06/17->09/17¦11/9/17: 80%->100
- 3818: 13/6/16: WID:SP-150674->SP-160430¦13/6/16: 0%->55¦1/12/16: 55%->80¦6/3/17: FCD:03/17->06/17¦6/3/17: 80%->90¦21/3/17: moved from rel-14¦7/6/17: 90%->100
- 3819: 6/10/16: 32.857 added¦1/12/16: 0%->5¦21/3/17: moved from Rel-14¦7/6/17: FCD:06/17->12/17¦7/6/17: 5%->20¦11/9/17: 20%->30¦15/12/17: 30%->45¦16/3/18: 45%->100
- 3820: 13/6/16: 0%->40¦19/9/16: FCD:09/16->12/16¦19/9/16: 40%->60¦1/12/16: FCD:12/16->03/17¦1/12/16: 60%->70¦6/3/17: FCD:03/17->06/17¦21/3/17: moved from rel-14¦7/6/17: 70%->100
- 3821: 30/6/17: 32.868 added;¦11/9/17: 0%->10¦15/12/17: 10%->50¦16/3/18: 50%->90¦7/6/18: 90%->100
- 3822: Aug2015: moved to Rel-14 (email CT and EG)¦07/09/15: 0%->5¦7/3/16: 5%->10¦13/6/16: FCD:03/16->09/16¦19/9/16: FCD: 09/16->06/17¦6/3/17: FCD:03/17->12/17¦21/3/17: moved from rel-14¦7/6/17: 10%->25¦8/6/17: WID:SP-150310->SP-170481¦11/9/17: 25%->3
- 3823: 6/10/16: 32.870 added¦1/12/16: 0%->10¦21/3/17: moved from rel-14¦11/9/17: 10%->40¦15/12/17: 40%->100
- 3824: 13/6/16: 0%->10¦19/9/16: 10%->35¦1/12/16: 35%->40¦6/3/17: FCD:03/17->03/18¦21/3/17: moved from rel-14¦7/6/17: 40%->60¦11/9/17: 60%->80¦15/12/17: 80%->100
- 3825: 28/7/16: 28.802 added¦19/9/16: 0%->5¦1/12/16: 5%->10¦6/3/17: FCD:03/17->06/17¦6/3/17: 10%->40¦21/3/17: moved from rel-14¦7/6/17: FCD:06/17->12/17¦7/6/17: 40%->60¦11/9/17: 60%->70¦15/12/17: 70%->100
- 3826: 28/7/16: 28.800 added¦19/9/16: 0%->10¦6/3/17: FCD:03/17->06/17¦21/3/17: moved from rel-14¦7/6/17: FCD:06/17->12/17¦7/6/17: 10%->25¦11/9/17: 25%->30¦15/12/17: 30%->100
- 3827: 26/9/16: Compl:0%->10%. ¦20/12/16: Compl:10%->40%21/3/17: Compl:40%->60%¦19/6/17: Compl:60%->100%
- 3828: Dec.14: TR number added. 3/3/15: 0->5%¦June2015: Compl:5%->25¦9/12/15: 25%->30¦21/3/17: moved from Rel-13¦21/3/17: FCD:09/15->12/17¦7/6/17: Stopped (30%->100%)
- 3829: 30/6/17: 32.848 added;¦11/9/17: 0%->5¦15/12/17: 5%->35¦16/3/18: 35%->45¦7/6/18: 45%->100
- 3830: 11/6/16: 0%->10¦19/9/16: 10%->30, FCD: 12/16->06/17¦21/3/17: Moved from Rel-14 (not completed on time)¦7/6/17: Stopped, so 30%->100
- 3831: compare REL-11 SI FS_UE_App_Data_Perf¦note: SI FS_UE_App_Data_Perf_CA is addressing 2DL/1UL involving also an unlicensed carrier of REL-13 LTE_LAA¦instead of a new TR, the TR 37.901 will be updated for REL-15¦ ;
- 3832: 30/6/17: 32.872 added;¦11/9/17: 0%->5¦15/12/17: 32.972 added;¦15/12/17: 5%->40¦16/3/18: 40%->60¦7/6/18: 60%->65¦7/6/18: FCD:06/18->12/18¦10/9/18: 65%->85¦7/12/18: 85%->100
- 3833: -
- 3834: -

| ID | WBS | Task | Duration | Start | Finish | Complete | Constraint | Resources | Work | Actual work | Acronym | PCG approved | Release | TSG approved | Impacted TSs and TRs | WI rapporteur name | WI rapporteur e-mail | Status Report |
| --- | --- | --- | --- | --- | --- | --- | --- | --- | --- | --- | --- | --- | --- | --- | --- | --- | --- | --- |
| 3835 | 1590 | **Mission Critical Improvements** | 1765.62d? | 2015-04-14 A | 2019-12-13 A | 100% |  |  | 30800h | 30800h | MCImp | 36 | Rel-14 | 70 |  |  |  |  |
| 3836 | 1590.1 | Mission Critical Push to Talk over LTE Realignment | 138d? | 2015-12-07 A | 2016-06-15 A | 100% | finish no earlier than 2016-06-15 | S1 | 1104h | 1104h | MCImp-MCPTTR | 36 | Rel-14 | 70 | 22.179 | Andrew Thiessen | andrew (at) its (dot) bldrdoc (dot) gov | SP-170406 |
| 3837 | 1590.2 | **Enhancements for Mission Critical Push To Talk** | 379.88d? | 2016-06-13 A | 2017-06-14 A | 100% |  |  | 5624h | 5624h | MCImp-eMCPTT | 37 | Rel-14 | 72 | 23.379; 23.280; 23.281; 23.282; 23.379 | Lazara, Dom | dom.lazara@motorolasolutions.com |  |
| 3838 | 1590.2.1 | Stage 2 of Enhancements for Mission Critical Push To Talk | 135d? | 2016-06-13 A | 2016-12-15 A | 100% | finish no earlier than 2016-12-15 | S6 | 1080h | 1080h | MCImp-eMCPTT | 37 | Rel-14 | 72 | 23.379; 23.280; 23.281; 23.282; 23.379 | Lazara, Dom | dom.lazara@motorolasolutions.com |  |
| 3839 | 1590.2.2 | **Stage 3 of Enhancements for Mission Critical Push To Talk** | 203d? | 2016-12-01 A | 2017-06-14 A | 100% |  | ct | 4544h | 4544h | MCImp-eMCPTT-CT | 38 | Rel-14 | 74 |  | FREDERICKS, Bob | bobfredericks@motorolasolutions.com |  |
| 3840 | 1590.2.2.1 | CT1 aspects of Enhancements for Mission Critical Push To Talk | 140d? | 2016-12-01 A | 2017-06-14 A | 100% | finish no earlier than 2017-06-14 | C1 | 1120h | 1120h | MCImp-eMCPTT-CT | 38 | Rel-14 | 74 | 24.379; 24.380; 24.381; 24.382; 24.383; 24.384 | FREDERICKS, Bob | bobfredericks@motorolasolutions.com |  |
| 3841 | 1590.2.2.2 | CT3 aspects of Enhancements for Mission Critical Push To Talk | 74d? | 2016-12-01 A | 2017-03-14 A | 100% | finish no earlier than 2017-03-14 | C3 | 592h | 592h | MCImp-eMCPTT-CT | 38 | Rel-14 | 74 | 29.165; 29.213; 29.214 | FREDERICKS, Bob | bobfredericks@motorolasolutions.com |  |
| 3842 | 1590.2.2.3 | CT4 aspects of Enhancements for Mission Critical Push To Talk | 74d? | 2016-12-01 A | 2017-03-14 A | 100% | finish no earlier than 2017-03-14 | C4 | 592h | 592h | MCImp-eMCPTT-CT | 38 | Rel-14 | 74 | 23.003; 29.228; 23.335; 29.283 | FREDERICKS, Bob | bobfredericks@motorolasolutions.com |  |
| 3843 | 1590.2.2.4 | CT6 aspects of Enhancements for Mission Critical Push To Talk | 140d? | 2016-12-01 A | 2017-06-14 A | 100% | finish no earlier than 2017-06-14 | C6 | 1120h | 1120h | MCImp-eMCPTT-CT | 38 | Rel-14 | 74 | 31.102; 31.103 | FREDERICKS, Bob | bobfredericks@motorolasolutions.com |  |
| 3844 | 1590.3 | Mission Critical Services Common Requirements | 138d? | 2015-12-07 A | 2016-06-15 A | 100% | finish no earlier than 2016-06-15 | S1 | 1104h | 1104h | MCImp-MCCoRe | 36 | Rel-14 | 70 | New 22.280 | Andrew Thiessen | andrew (at) its (dot) bldrdoc (dot) gov | SP-170407 |
| 3845 | 1590.4 | Common functional architecture to support mission critical services | 135d? | 2016-06-13 A | 2016-12-15 A | 100% | finish no earlier than 2016-12-15 | S6 | 1080h | 1080h | MCImp-MC_ARCH | 37 | Rel-14 | 72 | 23.280; 23.379; 23.281; 23.282; 23.280 | Niranth Amogh, Huawei Telecommunications India | namogh@huawei.com |  |
| 3846 | 1590.5 | **Mission Critical Video over LTE** | 821.12d? | 2015-04-14 A | 2017-06-14 A | 100% |  |  | 8528h | 8528h | MCImp-MCVideo | 36 | Rel-14 | 70 |  | Emmanuelle Villebrun | Emmanuelle.villebrun@gendarmerie.interieur.gouv.fr |  |
| 3847 | 1590.5.1 | Study on Mission Critical Video over LTE | 176d? | 2015-04-14 A | 2015-12-15 A | 100% | finish no earlier than 2015-12-15 | S1 | 1408h | 1408h | FS_MCVideo | 34 | Rel-14 | 67 | New 22.879 | Villebrun, Emmanuelle (French MoI) | emmanuelle.villebrun@gendarmerie.interieur.gouv.fr |  |
| 3848 | 1590.5.2 | Stage 1 of MCVideo | 138d? | 2015-12-07 A | 2016-06-15 A | 100% | finish no earlier than 2016-06-15 | S1 | 1104h | 1104h | MCImp-MCVideo | 36 | Rel-14 | 70 | New 22.281 | Emmanuelle Villebrun | Emmanuelle.villebrun@gendarmerie.interieur.gouv.fr |  |
| 3849 | 1590.5.3 | Stage 2 for MCVideo | 135d? | 2016-06-13 A | 2016-12-15 A | 100% | finish no earlier than 2016-12-15 | S6 | 1080h | 1080h | MCImp-MCVideo | 37 | Rel-14 | 72 | 23.281; 23.280; 23.379; 23.282; 23.281 | Niranth Amogh, Huawei Telecommunications India | namogh@huawei.com |  |
| 3850 | 1590.5.4 | MCVideo codecs and media handling | 47d? | 2017-01-11 A | 2017-03-16 A | 100% | finish no earlier than 2017-03-16 | S4 | 376h | 376h | MCImp-MCVideo | 38 | Rel-14 | 75 | 26.281 | John Lambrou (Motorola Solutions) | john (dot) lambrou (at) motorolasolutions (dot) com |  |
| 3851 | 1590.5.5 | **Stage 3 of MCVideo** | 203d? | 2016-12-01 A | 2017-06-14 A | 100% |  | ct | 4560h | 4560h | MCImp-MCVIDEO-CT | 38 | Rel-14 | 74 | 24.581; 24.281 | PATEL, Milan | milan.patel@huawei.com |  |
| 3852 | 1590.5.5.1 | CT1 aspects 3 of MCVideo | 140d? | 2016-12-01 A | 2017-06-14 A | 100% | finish no earlier than 2017-06-14 | C1 | 1120h | 1120h | MCImp-MCVIDEO-CT | 38 | Rel-14 | 74 | 24.381; 24.382; 24.383; 24.384 | PATEL, Milan | milan.patel@huawei.com |  |
| 3853 | 1590.5.5.2 | CT3 aspects 3 of MCVideo | 75d? | 2016-12-01 A | 2017-03-15 A | 100% | finish no earlier than 2017-03-15 | C3 | 600h | 600h | MCImp-MCVIDEO-CT | 38 | Rel-14 | 74 | 29.165; 29.213; 29.214 | PATEL, Milan | milan.patel@huawei.com |  |
| 3854 | 1590.5.5.3 | CT4 aspects 3 of MCVideo | 75d? | 2016-12-01 A | 2017-03-15 A | 100% | finish no earlier than 2017-03-15 | C4 | 600h | 600h | MCImp-MCVIDEO-CT | 38 | Rel-14 | 74 | 23.003; 23.335; 29.283 | PATEL, Milan | milan.patel@huawei.com |  |
| 3855 | 1590.5.5.4 | CT6 aspects 3 of MCVideo | 140d? | 2016-12-01 A | 2017-06-14 A | 100% | finish no earlier than 2017-06-14 | C6 | 1120h | 1120h | MCImp-MCVIDEO-CT | 38 | Rel-14 | 74 | 31.102; 31.103 | PATEL, Milan | milan.patel@huawei.com |  |
| 3856 | 1590.6 | **Mission Critical Data over LTE** | 821.12d? | 2015-04-14 A | 2017-06-14 A | 100% |  |  | 8152h | 8152h | MCImp-MCData | 36 | Rel-14 | 70 |  | Emmanuelle Villebrun | Emmanuelle.villebrun@gendarmerie.interieur.gouv.fr |  |
| 3857 | 1590.6.1 | Study on Mission Critical Data Communications | 176d? | 2015-04-14 A | 2015-12-15 A | 100% | finish no earlier than 2015-12-15 | S1 | 1408h | 1408h | FS_MCDATA | 34 | Rel-14 | 67 | New 22.880 | Villebrun, Emmanuelle (French MoI) | emmanuelle.villebrun@gendarmerie.interieur.gouv.fr |  |
| 3858 | 1590.6.2 | Stage 1 of MCData | 138d? | 2015-12-07 A | 2016-06-15 A | 100% | finish no earlier than 2016-06-15 | S1 | 1104h | 1104h | MCImp-MCData | 36 | Rel-14 | 70 | New 22.282 | Emmanuelle Villebrun | Emmanuelle.villebrun@gendarmerie.interieur.gouv.fr |  |
| 3859 | 1590.6.3 | Stage 2 for MCData | 135d? | 2016-06-13 A | 2016-12-15 A | 100% | start no earlier than 2016-06-13 | S6 | 1080h | 1080h | MCImp-MCData | 37 | Rel-14 | 72 | 23.282 | David Freeman (UK Home Office) | david@dnf-consulting.co.uk |  |

Notes:
- 3835: Umbrella Feature
- 3836: 2/3/16: FCD: 03/16->06/16. ES in SP-160102¦0->75%¦9/6/16: 75%->100
- 3837: 28/7/16: 23.379 added¦19/9/16: 0%->35¦1/12/16: 35%->100
- 3838: 28/7/16: 23.379 added¦19/9/16: 0%->35¦1/12/16: 35%->100
- 3840: 6/3/17: 0%->20¦5/6/17: 20%->95¦14/9/17: 95%->97¦15/12/17: 97%->100
- 3841: 5/6/17: 0%->100
- 3842: 6/3/17: 0%->100
- 3843: 5/6/17: 0%->100. No work identified for CT6.
- 3844: 2/3/16: FCD: 03/16->06/16. ES in SP-160104¦0->75%¦9/6/16: 75%->100
- 3845: 28/7/16: 23.280 added¦19/9/16: 0%->40¦1/12/16: 40%->95¦3/3/17: 95%->100
- 3846: 2/3/16: FCD: 03/16->06/16. ES in SP-160106¦0->80%¦9/6/16: 80%->100
- 3847: 1/4/15:TR number added¦June2015: Compl:0%->50¦07/09/15: 50%->70¦7/12/15: 70%->100
- 3848: 2/3/16: FCD: 03/16->06/16. ES in SP-160106¦0->80%¦9/6/16: 80%->100
- 3849: 28/7/16: 23.281 added¦19/9/16: 0%->25¦1/12/16: 25%->95¦3/3/17: 95%->100
- 3850: 6/3/17: 0%->100
- 3852: 6/3/17: 0%->25¦5/6/17: 25%->90¦14/9/17: 90%->100
- 3853: 5/6/17: 0%->100
- 3854: 6/3/17: 0%->100
- 3855: 5/6/17: 0%->100. No work identified for CT6.
- 3856: 2/3/16: FCD: 03/16->06/16. ES in SP-160109¦0->80%¦9/6/16: 80%->100
- 3857: 1/4/15:TR number added¦June2015: Compl:0%->20¦07/09/15: 20%->90¦7/12/15: 90%->100
- 3858: 2/3/16: FCD: 03/16->06/16. ES in SP-160109¦0->80%¦9/6/16: 80%->100
- 3859: 28/7/16: 23.282 added¦19/9/16: 0%->10¦1/12/16: 10%->95¦3/3/17: 95%->100

| ID | WBS | Task | Type | Duration | Start | Finish | Complete | Constraint | Resources | Work | Actual work | Acronym | PCG approved | WI rapporteur name | WI rapporteur e-mail | Release | TSG approved | Status Report |
| --- | --- | --- | --- | --- | --- | --- | --- | --- | --- | --- | --- | --- | --- | --- | --- | --- | --- | --- |
| 3860 | 1590.6.4 | **Stage 3 of MCData** |  | 203d? | 2016-12-01 A | 2017-06-14 A | 100% |  | ct | 4560h | 4560h | MCImp-MCDATA-CT | 38 | HASON, Baruh | baruh.hason@motorolasolutions.com | Rel-14 | 74 |  |
| 3861 | 1590.6.4.1 | CT1 aspects of MCData |  | 140d? | 2016-12-01 A | 2017-06-14 A | 100% | finish no earlier than 2017-06-14 | C1 | 1120h | 1120h | MCImp-MCDATA-CT | 38 | HASON, Baruh | baruh.hason@motorolasolutions.com | Rel-14 | 74 |  |
| 3862 | 1590.6.4.2 | CT3 aspects of MCData |  | 75d? | 2016-12-01 A | 2017-03-15 A | 100% | finish no earlier than 2017-03-15 | C3 | 600h | 600h | MCImp-MCDATA-CT | 38 | HASON, Baruh | baruh.hason@motorolasolutions.com | Rel-14 | 74 |  |
| 3863 | 1590.6.4.3 | CT4 aspects of MCData |  | 75d? | 2016-12-01 A | 2017-03-15 A | 100% | finish no earlier than 2017-03-15 | C4 | 600h | 600h | MCImp-MCDATA-CT | 38 | HASON, Baruh | baruh.hason@motorolasolutions.com | Rel-14 | 74 |  |
| 3864 | 1590.6.4.4 | CT6 aspects of MCData |  | 140d? | 2016-12-01 A | 2017-06-14 A | 100% | finish no earlier than 2017-06-14 | C6 | 1120h | 1120h | MCImp-MCDATA-CT | 38 | HASON, Baruh | baruh.hason@motorolasolutions.com | Rel-14 | 74 |  |
| 3865 | 1590.7 | Security of the Mission Critical Service |  | 194d? | 2016-09-19 A | 2017-06-15 A | 100% | finish no earlier than 2017-06-15 | S3 | 1552h | 1552h | MCSec | 37 | Haigh, Peter, CESG | peter.haigh@cesg.gsi.gov.uk | Rel-14 | 73 |  |
| 3866 | 1590.8 | UE Conformance Test Aspects - Mission Critical Improvements |  | 457d? | 2018-03-15 A | 2019-12-13 A | 100% | finish no earlier than 2019-12-15 | R5 | 3656h | 3656h | MCImp-UEConTest | 40 | NIST |  | Rel-14 | 79 |  |
| 3867 | 1591 | **Protocol enhancements for MCPTT over LTE** |  | 187.5d? | 2016-09-16 A | 2017-03-15 A | 100% |  | ct | 5160h | 5160h | MCPTTProtoc1 | 37 | Ricky Kaura | ricky.kaura@samsung.com | Rel-14 | 73 |  |
| 3868 | 1591.1 | CT1 aspects of MCPTTProtoc1 |  | 129d? | 2016-09-16 A | 2017-03-15 A | 100% | finish no earlier than 2017-03-15 | C1 | 1032h | 1032h | MCPTTProtoc1 | 37 | Ricky Kaura | ricky.kaura@samsung.com | Rel-14 | 73 |  |
| 3869 | 1591.2 | CT3 aspects of MCPTTProtoc1 |  | 129d? | 2016-09-16 A | 2017-03-15 A | 100% | finish no earlier than 2017-03-15 | C3 | 1032h | 1032h | MCPTTProtoc1 | 37 | Ricky Kaura | ricky.kaura@samsung.com | Rel-14 | 73 |  |
| 3870 | 1591.3 | CT4 aspects of MCPTTProtoc1 |  | 129d? | 2016-09-16 A | 2017-03-15 A | 100% | finish no earlier than 2017-03-15 | C4 | 1032h | 1032h | MCPTTProtoc1 | 37 | Ricky Kaura | ricky.kaura@samsung.com | Rel-14 | 73 |  |
| 3871 | 1591.4 | CT6 aspects of MCPTTProtoc1 |  | 129d? | 2016-09-16 A | 2017-03-15 A | 100% | finish no earlier than 2017-03-15 | C6 | 1032h | 1032h | MCPTTProtoc1 | 37 | Ricky Kaura | ricky.kaura@samsung.com | Rel-14 | 73 |  |
| 3872 | 1592 | Release 14 on V2X | milestone | 0d? | 2016-06-09 A | 2016-06-09 A | 100% | finish no earlier than 2016-06-09 |  |  |  |  |  |  |  | Rel-14 |  |  |
| 3873 | 1593 | **LTE support for V2X services** |  | 1454.88d? | 2015-02-09 A | 2018-12-14 A | 100% |  |  | 21216h | 21216h | V2XLTE | 35 |  |  | Rel-14 | 68 |  |
| 3874 | 1593.1 | Stage 1 for LTE support for V2X services |  | 137d? | 2015-09-09 A | 2016-03-17 A | 100% | finish no earlier than 2016-03-17 | S1 | 1096h | 1096h | V2XLTE | 35 |  |  | Rel-14 | 68 |  |
| 3875 | 1593.2 | Architecture enhancements for LTE support of V2X services |  | 137d? | 2016-06-09 A | 2016-12-15 A | 100% | finish no earlier than 2016-12-15 | S2 | 1096h | 1096h | V2XARC | 37 | LG Electronics, LaeYoung Kim | laeyoung.kim@lge.com | Rel-14 | 72 |  |
| 3876 | 1593.3 | Security aspect of LTE support of V2X services |  | 141d? | 2016-12-01 A | 2017-06-15 A | 100% | finish no earlier than 2017-06-15 | S3 | 1128h | 1128h | V2XLTE-Sec | 38 | Huawei, Marcus Wong | mwong@huawei.com | Rel-14 | 74 |  |
| 3877 | 1593.4 | **RAN aspects of LTE-based V2X Services** |  | 945.38d? | 2016-06-15 A | 2018-12-14 A | 100% |  |  | 7344h | 7344h | LTE_V2X | 37 | LG Electronics |  | Rel-14 | 72 |  |
| 3878 | 1593.4.1 | Core part: LTE-based V2X Services |  | 197d? | 2016-06-15 A | 2017-03-15 A | 100% | finish no earlier than 2017-03-15 | R1 | 1576h | 1576h | LTE_V2X-Core | 37 | LG Electronics |  | Rel-14 | 72 | RP-170237 |
| 3879 | 1593.4.2 | Perf. part: LTE-based V2X Services |  | 329d? | 2016-06-15 A | 2017-09-15 A | 100% | finish no earlier than 2017-09-15 | R4 | 2632h | 2632h | LTE_V2X-Perf | 37 | LG Electronics |  | Rel-14 | 72 |  |
| 3880 | 1593.4.3 | UE Conformance Test Aspects - Support for LTE-based V2X Services |  | 392d? | 2017-06-15 A | 2018-12-14 A | 100% | finish no earlier than 2018-12-15 | R5 | 3136h | 3136h | LTE_V2X-UEConTest | 39 | Huawei |  | Rel-14 | 76 |  |
| 3881 | 1593.5 | **CT aspects of V2X Services** |  | 187.5d? | 2016-09-16 A | 2017-03-15 A | 100% |  | ct | 5160h | 5160h | V2X-CT | 37 | Taehun Kim | taehun78.kim@lge.com | Rel-14 | 73 |  |
| 3882 | 1593.5.1 | CT1 aspects of V2X Services |  | 129d? | 2016-09-16 A | 2017-03-15 A | 100% | finish no earlier than 2017-03-15 | C1 | 1032h | 1032h | V2X-CT | 37 | Taehun Kim | taehun78.kim@lge.com | Rel-14 | 73 |  |
| 3883 | 1593.5.2 | CT3 aspects of V2X Services |  | 129d? | 2016-09-16 A | 2017-03-15 A | 100% | finish no earlier than 2017-03-15 | C3 | 1032h | 1032h | V2X-CT | 37 | Taehun Kim | taehun78.kim@lge.com | Rel-14 | 73 |  |
| 3884 | 1593.5.3 | CT4 aspects of V2X Services |  | 129d? | 2016-09-16 A | 2017-03-15 A | 100% | finish no earlier than 2017-03-15 | C4 | 1032h | 1032h | V2X-CT | 37 | Taehun Kim | taehun78.kim@lge.com | Rel-14 | 73 |  |
| 3885 | 1593.5.4 | CT6 aspects of V2X Services |  | 129d? | 2016-09-16 A | 2017-03-15 A | 100% | finish no earlier than 2017-03-15 | C6 | 1032h | 1032h | V2X-CT | 37 | Taehun Kim | taehun78.kim@lge.com | Rel-14 | 73 |  |

Notes:
- 3860: Impacted TSs and TRs: 24.582; 24.282
- 3861: 6/3/17: 0%->10¦5/6/17: 10%->65¦5/6/17: 65%->90¦14/9/17: 90%->96¦15/12/17: 96%->100 / Impacted TSs and TRs: 24.381; 24.382; 24.383; 24.384
- 3862: 5/6/17: 0%->100 / Impacted TSs and TRs: 29.165; 29.213; 29.214
- 3863: 6/3/17: 0%->100 / Impacted TSs and TRs: 23.003; 23.335; 29.283
- 3864: No work identified. / Impacted TSs and TRs: 31.102; 31.103
- 3865: 6/10/16: 33.180 added¦1/12/16: 0%->25¦6/3/17: 25%->60¦7/6/17: 60%->85¦11/9/17: 85%->100 / Impacted TSs and TRs: 33.180
- 3866: tested: REL-14 WI MCImp (SA/CT WI: Mission Critical Improvements)¦to provide conformance test specifications for the Rel-14 core requirements for improvements to Mission Critical Services (MCPTT, MCVideo and MCData).;; 25/9/20: 5%->100
- 3867: This Feature is a stage-3 only feature that fixes/enhances MCPTT protocol level (not visible from stage2). Not to be confused with Rel-14 MCPTT Stage 3.
- 3868: 6/3/17: 5%->100 / Impacted TSs and TRs: 24.229; 24.379; 24.380; 24.381; 24.382; 24.383; 24.384; 24.980
- 3869: 2/12/16: 0%->20¦6/3/17: 20%->100 / Impacted TSs and TRs: 29.165; 29.212; 29.213; 29.214
- 3870: 6/3/17: 0%->100 / Impacted TSs and TRs: 23.003; 23.008; 29.283
- 3871: 5/6/17: 0%->100. No more work identified. / Impacted TSs and TRs: 31.102
- 3872: -
- 3873: 7/12/15: 0%->5¦28/1/16: 22.185 added¦2/3/16: 5%->90¦9/6/16: 90%->100 / Impacted TSs and TRs: 22.278; 22.185
- 3874: 7/12/15: 0%->5¦28/1/16: 22.185 added¦2/3/16: 5%->90¦9/6/16: 90%->100 / Impacted TSs and TRs: 22.278; 22.185
- 3875: 28/7/16: 23.285 added¦19/9/16: 0%->85¦1/12/16: FCD:09/16->12/16¦1/12/16: 85%->100 / Impacted TSs and TRs: 23.285
- 3876: 6/3/17: 0%->75¦7/6/17: 75%->100 / Impacted TSs and TRs: 33.185
- 3877: follow-up WI of REL-14 SI FS_LTE_V2X
- 3878: follow-up WI of REL-14 SI FS_LTE_V2X26/9/16: Compl:0%->15%26/9/16: WID: RP-161298->RP-161894¦6/10/16: 36.786 added¦6/10/16: added¦20/12/16: Compl:15%->75% 21/3/17: Compl:75%->100% / Impacted TSs and TRs: 36.786;
- 3879: ¦26/9/16: WID: RP-161298->RP-161894¦20/12/16: WID: RP-161894->RP-162519¦20/12/16: Stat Rep: ->RP-162519¦19/6/17: Compl:0%->75%¦19/9/17: Compl:75%->100%
- 3880: ¦19/9/17: Compl:0%->20%¦8/1/18: Compl:20%->40%¦ 27/3/18: Compl:40%->55%; 14/1/20: WID:RP-172356->RP-192556; 14/1/20: 65%->100
- 3882: 6/10/16: 24.385 added¦6/10/16: 24.386 added¦2/12/16: 0%->65¦6/3/17: 65%->100 / Impacted TSs and TRs: 23.122; 24.301; 24.334; 24.385; 24.386
- 3883: 6/10/16: 29.387 added¦2/12/16: 0%->40¦6/3/17: 40%->60¦5/6/17: 60%->100 / Impacted TSs and TRs: 29.212; 29.468; 29.387
- 3884: 6/10/16: 29.388 added¦6/10/16: 29.389 added¦2/12/16: 0%->80¦6/3/17: 80%->100 / Impacted TSs and TRs: 23.003; 23.007; 23.008; 29.272; 29.388; 29.389
- 3885: 7/3/17: 0%->100 / Impacted TSs and TRs: 31.102; 31.111

| ID | WBS | Task | Type | Duration | Start | Finish | Complete | Constraint | Resources | Work | Actual work | Acronym | PCG approved | WI rapporteur name | WI rapporteur e-mail | Release | TSG approved | Status Report |
| --- | --- | --- | --- | --- | --- | --- | --- | --- | --- | --- | --- | --- | --- | --- | --- | --- | --- | --- |
| 3886 | 1593.6 | **Study on LTE support for V2X services** |  | 512.5d? | 2015-02-09 A | 2016-06-17 A | 100% |  |  | 5392h | 5392h | FS_V2XLTE | 34 | Ki-Dong Lee (LG electronics) | kidong.lee@lge.com | Rel-14 | 67 |  |
| 3887 | 1593.6.1 | Study on Stage 1 of LTE support for V2X services |  | 1d? | 2015-02-09 A | 2015-02-09 A | 100% | start no earlier than 2015-09-07 | S1 | 8h | 8h | FS_V2XLTE_S1 | 34 | Ki-Dong Lee (LG electronics) | kidong.lee@lge.com | Rel-14 | 67 |  |
| 3888 | 1593.6.2 | Study on Stage 2 of LTE support for V2X services |  | 205d? | 2015-09-07 A | 2016-06-17 A | 100% | finish no earlier than 2016-06-17 | S2 | 1640h | 1640h | FS_V2XARC | 36 | LG Electronics, LaeYoung Kim | laeyoung.kim@lge.com | Rel-14 | 70 |  |
| 3889 | 1593.6.3 | Study on Security of LTE support for V2X services |  | 205d? | 2015-09-07 A | 2016-06-17 A | 100% | finish no earlier than 2016-06-17 | S3 | 1640h | 1640h | FS_V2XARC_S3 | 36 |  |  | Rel-14 | 70 |  |
| 3890 | 1593.6.4 | RAN1 Study on LTE-based V2X Services |  | 263d? | 2015-06-15 A | 2016-06-15 A | 100% | finish no earlier than 2016-09-15 | R1 | 2104h | 2104h | FS_LTE_V2X | 35 | LG Electronics |  | Rel-14 | 68 |  |
| 3891 | 1594 | **Support for V2V services based on LTE sidelink** |  | 1040.62d? | 2015-12-15 A | 2018-09-14 A | 100% |  |  | 8920h | 8920h | LTE_SL_V2V | 36 | LG Electronics |  | Rel-14 | 70 |  |
| 3892 | 1594.1 | Core part: Support for V2V services based on LTE sidelink |  | 199d? | 2015-12-15 A | 2016-09-15 A | 100% | finish no earlier than 2016-09-15 | R1 | 1592h | 1592h | LTE_SL_V2V-Core | 36 | LG Electronics |  | Rel-14 | 70 |  |
| 3893 | 1594.2 | Perf. part: Support for V2V services based on LTE sidelink |  | 394d? | 2015-12-15 A | 2017-06-15 A | 100% | finish no earlier than 2017-06-15 | R4 | 3152h | 3152h | LTE_SL_V2V-Perf | 36 | LG Electronics |  | Rel-14 | 70 |  |
| 3894 | 1594.3 | UE Conformance Test Aspects - Support for V2V services based on LTE sidelink |  | 522d? | 2016-09-15 A | 2018-09-14 A | 100% | finish no earlier than 2018-09-15 | R5 | 4176h | 4176h | LTE_SL_V2V-UEConTest | 37 | Huawei |  | Rel-14 | 73 |  |
| 3895 | 1595 | Release 14 on CIoT | milestone | 0d? | 2016-06-09 A | 2016-06-09 A | 100% | finish no earlier than 2016-06-09 |  |  |  |  |  |  |  | Rel-14 |  |  |
| 3896 | 1596 | **Non-IP for Cellular Internet of Things (CIoT) for 2G/3G-GPRS(EC-EGPRS)** |  | 204.88d? | 2016-03-02 A | 2016-09-15 A | 100% |  |  | 4040h | 4040h | NonIP_GPRS | 36 |  |  | Rel-14 | 71 |  |
| 3897 | 1596.1 | Non-IP for Cellular IoT for EC-EGPRS |  | 76d? | 2016-03-02 A | 2016-06-15 A | 100% | start no earlier than 2016-03-02 | S2 | 608h | 608h | NonIP_GPRS | 36 | Hans Ronneke, Ericsson | hans . Ronneke (a) ericsson . Com | Rel-14 | 71 |  |
| 3898 | 1596.2 | **CT aspects for Non-IP for Cellular Internet of Things for EC-EGPRS** |  | 204.88d? | 2016-03-02 A | 2016-09-15 A | 100% |  |  | 3432h | 3432h | NonIP_GPRS-CT | 36 | Orange, Youssef CHADLI | youssef.chadli@orange.com | Rel-14 | 71 |  |
| 3899 | 1596.2.1 | CT1 aspects for Non-IP for Cellular Internet of Things for EC-EGPRS |  | 143d? | 2016-03-02 A | 2016-09-15 A | 100% | finish no earlier than 2016-09-15 | C1 | 1144h | 1144h | NonIP_GPRS-CT | 36 | Orange, Youssef CHADLI | youssef.chadli@orange.com | Rel-14 | 71 |  |
| 3900 | 1596.2.2 | CT3 aspects for Non-IP for Cellular Internet of Things for EC-EGPRS |  | 143d? | 2016-03-02 A | 2016-09-15 A | 100% | finish no earlier than 2016-09-15 | C3 | 1144h | 1144h | NonIP_GPRS-CT | 37 | Orange, Youssef CHADLI | youssef.chadli@orange.com | Rel-14 | 72 |  |
| 3901 | 1596.2.3 | CT4 aspects for Non-IP for Cellular Internet of Things for EC-EGPRS |  | 143d? | 2016-03-02 A | 2016-09-15 A | 100% | finish no earlier than 2016-09-15 | C4 | 1144h | 1144h | NonIP_GPRS-CT | 36 | Orange, Youssef CHADLI | youssef.chadli@orange.com | Rel-14 | 71 |  |
| 3902 | 1597 | **Further enhanced MTC for LTE** |  | 851.12d? | 2016-06-15 A | 2018-09-14 A | 100% |  |  | 7344h | 7344h | LTE_feMTC | 37 | Ericsson |  | Rel-14 | 72 |  |
| 3903 | 1597.1 | Core part: Further enhanced MTC for LTE |  | 263d? | 2016-06-15 A | 2017-06-15 A | 100% | finish no earlier than 2017-06-15 | R1 | 2104h | 2104h | LTE_feMTC-Core | 37 | Ericsson |  | Rel-14 | 72 | RP-171441 |
| 3904 | 1597.2 | Perf. part: Further enhanced MTC for LTE |  | 394d? | 2016-06-15 A | 2017-12-15 A | 100% | finish no earlier than 2017-12-15 | R4 | 3152h | 3152h | LTE_feMTC-Perf | 37 | Ericsson |  | Rel-14 | 72 |  |
| 3905 | 1597.3 | UE Conformance Test Aspects - Further enhanced MTC for LTE |  | 261d? | 2017-09-15 A | 2018-09-14 A | 100% | finish no earlier than 2018-09-15 | R5 | 2088h | 2088h | LTE_feMTC-UEConTest | 39 | Ericsson |  | Rel-14 | 77 |  |
| 3906 | 1598 | **Enhancements of NB-IoT** |  | 945.38d? | 2016-06-15 A | 2018-12-14 A | 100% |  |  | 7864h | 7864h | NB_IOTenh | 37 | Huawei |  | Rel-14 | 72 |  |
| 3907 | 1598.1 | Core part: Enhancements of NB-IoT |  | 263d? | 2016-06-15 A | 2017-06-15 A | 100% | finish no earlier than 2017-06-15 | R1 | 2104h | 2104h | NB_IOTenh-Core | 37 | Huawei |  | Rel-14 | 72 | RP-171061 |
| 3908 | 1598.2 | Perf. part: Enhancements of NB-IoT |  | 394d? | 2016-06-15 A | 2017-12-15 A | 100% | finish no earlier than 2017-12-15 | R4 | 3152h | 3152h | NB_IOTenh-Perf | 37 | Huawei |  | Rel-14 | 72 |  |
| 3909 | 1598.3 | UE Conformance Test Aspects - Enhancements of NB-IoT |  | 326d? | 2017-09-15 A | 2018-12-14 A | 100% | finish no earlier than 2018-12-15 | R5 | 2608h | 2608h | NB_IOTenh-UEConTest | 39 | Huawei |  | Rel-14 | 77 |  |
| 3910 | 1599 | AT Commands for CIoT |  | 65d? | 2016-09-16 A | 2016-12-15 A | 100% | finish no earlier than 2016-12-15 | C1 | 520h | 520h | AT_CIoT | 37 | John-Luc Bakker |  | Rel-14 | 73 |  |

Notes:
- 3886: 1/4/15:TR number added¦June2015: Compl:25%->50¦07/09/15: 50%->75 / Impacted TSs and TRs: New 22.885
- 3887: 1/4/15:TR number added¦June2015: Compl:25%->50¦07/09/15: 50%->75¦7/12/15: 75%->100 / Impacted TSs and TRs: New 22.885
- 3888: 11/12/15: WID:SP-150625->SP-150743¦7/3/16: 10%->22¦7/3/16: WID:SP-150743->SP-150852¦9/6/16: 22%->80¦19/9/16: 80%->100 / Impacted TSs and TRs: 23.785
- 3889: Introduced at 100% completion, as per SA3 report to SA#76 / Impacted TSs and TRs: 33.885
- 3890: 29/09/15: Compl:0%->5% 29/09/15: Stat Rep: -->RP-151311 ¦28/1/16: 33.885 added;22/3/16: Compl:35%->50%22/3/16: CD:Wed 15/06/16->Thu 15/09/1622/3/16: WID: RP-15¦ / Impacted TSs and TRs: 33.885
- 3892: 22/3/16: Compl:0%->15%22/3/16: WID: RP-152293->RP-1606491/7/16: Compl:15%->60%1/7/16: WID: RP-160649->RP-161272¦28/7/16: 36.785 added¦26/9/16: Compl:60%->100%¦26/9/16: WID: RP-161272->RP-161603 / Impacted TSs and TRs: 36.785
- 3893: 22/3/16: WID: RP-152293->RP-1606491/7/16: WID: RP-160649->RP-16127226/9/16: WID: RP-161272->RP-161603¦20/12/16: Compl:0%->50% 21/3/17: Compl:50%->80% 21/3/17: CD:Wed 15/03/17->Thu 15/06/1719/6/17: Compl:80%->100%
- 3894: ¦20/12/16: Compl:0%->5% 21/3/17: Compl:5%->15%19/9/17: Compl:15%- 8/1/18: Com27/ ;; 11/10/20: 98%->100
- 3895: -
- 3897: 9/6/16: 0%->50¦19/9/16: 50%->100 / Impacted TSs and TRs: 23.060; 23.682; 23.401?
- 3898: 11/6/16: WID:CP-160161->CP-160293
- 3899: 11/6/16: 0%->50¦11/6/16: WID:CP-160161->CP-160293¦16/9/16: 50%->65¦2/12/16: 65%->100 / Impacted TSs and TRs: 24.008
- 3900: 11/6/16: WID:CP-160161->CP-160293¦13/6/16: 0%->65¦20/9/16: 0%->100 / Impacted TSs and TRs: 29.060; 29.274; 29.002; 29.303; 23.008; 29.128; 29.272; 23.007
- 3901: 11/6/16: WID:CP-160161->CP-160293¦13/6/16: 0%->65¦2/12/16: 65%->100 / Impacted TSs and TRs: 29.060; 29.274; 29.002; 29.303; 23.008; 29.128; 29.272; 23.007
- 3903: 26/9/16: Compl:0%->12%26/9/16: WID: RP-161321->RP-161464¦20/12/16: Compl:12%->70%¦20/12/16: WID: RP-161464->RP-16252021/3/17: Compl:70%->95% ¦21/3/17: CD19/6/17: Compl:95%->100%
- 3904: ¦26/9/16: WID: RP-161321->RP-161464¦20/12/16: WID: RP-161464->RP-162520¦20/12/16: Stat Rep: ->RP-16252021/3/17: CD:Fri 15/09/17->Fri 15/12/1721/3/17 19/6/17: Compl:0%->35%19/9/17: Compl:35%->60%¦8/1/18: Compl:60%->100%
- 3905: ¦8/1/18: Compl:0%->6%¦27/3/18: Compl:6%->21%¦ ¦2¦26/3/19: WID:RP-180414->RP-190514; 26/6/19: WID:RP-190514->RP-190935; 14/1/20: WID:RP-190935->RP-192886; 26/3/20: 26%->100
- 3907: 26/9/16: Compl:0%->13%26/9/16: WID: RP-161324->RP-161901¦20/12/16: Compl:13%->70%¦21/3/17: Compl:70%->95%¦21/3/17: CD:Wed 15/03/17->Thu 15/06/1719/6/17: Compl:95%->100%
- 3908: 26/9/16: WID: RP-161324->RP-16190121/3/17: CD:Fri 15/09/17->Fri 15/12/17¦19/6/17: Compl:0%->50%¦19/6/17: WID: RP-161901->RP-171060¦19/9/17: Compl:50%->60%¦8/1/18: Compl:60%->100%
- 3909: ¦8/1/18: Compl:0%->5%27/3/18: Compl:5%->30%¦27/6/18: C; 11/10/20: 60%->100
- 3910: 2/12/16: 10%->95¦6/3/17: 95%->100

| ID | WBS | Task | Duration | Start | Finish | Complete | Constraint | Resources | Work | Actual work | Acronym | PCG approved | WI rapporteur name | WI rapporteur e-mail | Release | TSG approved | Status Report | TSG stopped |
| --- | --- | --- | --- | --- | --- | --- | --- | --- | --- | --- | --- | --- | --- | --- | --- | --- | --- | --- |
| 3911 | 1600 | **Extended architecture support for Cellular Internet of Things** | 280.62d? | 2016-06-17 A | 2017-03-14 A | 100% |  |  | 3360h | 3360h | CIoT_Ext | 37 | Intel : Puneet Jain | puneet.jain@intel.com | Rel-14 | 73 |  |  |
| 3912 | 1600.1 | Study on extended architecture support for Cellular Internet of Things | 131d? | 2016-06-17 A | 2016-12-15 A | 100% | finish no earlier than 2016-12-15 | S2 | 1048h | 1048h | FS_CIoT_Ext | 37 | Intel : Puneet Jain | puneet.jain@intel.com | Rel-14 | 72 |  |  |
| 3913 | 1600.2 | Stage 2 of Extended architecture support for Cellular Internet of Things | 67d? | 2016-09-15 A | 2016-12-16 A | 100% | finish no earlier than 2016-12-16 | S2 | 536h | 536h | CIoT_Ext | 37 | Intel : Puneet Jain | puneet.jain@intel.com | Rel-14 | 73 |  |  |
| 3914 | 1600.3 | **Stage 3 of extended architecture enhancements for Cellular Internet of Things** | 107.75d? | 2016-12-01 A | 2017-03-14 A | 100% |  | ct | 1776h | 1776h | CIoT_Ext-CT | 38 | Intel, Vivek Gupta | vivek.g.gupta@intel.com | Rel-14 | 74 |  |  |
| 3915 | 1600.3.1 | CT1 aspects of extended architecture enhancements for Cellular Internet of Things | 74d? | 2016-12-01 A | 2017-03-14 A | 100% | finish no earlier than 2017-03-14 | C1 | 592h | 592h | CIoT_Ext-CT | 38 | Intel, Vivek Gupta | vivek.g.gupta@intel.com | Rel-14 | 74 |  |  |
| 3916 | 1600.3.2 | CT4 aspects of extended architecture enhancements for Cellular Internet of Things | 74d? | 2016-12-01 A | 2017-03-14 A | 100% | finish no earlier than 2017-03-14 | C4 | 592h | 592h | CIoT_Ext-CT | 38 | Intel, Vivek Gupta | vivek.g.gupta@intel.com | Rel-14 | 74 |  |  |
| 3917 | 1601 | **Radio Interface Enhancements for Extended Coverage GSM for support of Cellular Internet of Things** | 661.75d? | 2016-09-15 A | 2018-06-15 A | 100% |  | R6 | 5760h | 5760h | CIoT_EC_GSM_radio_enh | 37 | Nokia |  | Rel-14 | 73 |  |  |
| 3918 | 1601.1 | Core part: Radio Interface Enhancements for Extended Coverage GSM for support of Cellular Internet of Things | 196d? | 2016-09-15 A | 2017-06-15 A | 100% | finish no earlier than 2017-06-15 | R6 | 1568h | 1568h | CIoT_EC_GSM_radio_enh-Core | 37 | Nokia |  | Rel-14 | 73 | RP-171321 |  |
| 3919 | 1601.2 | Perf. part: Radio Interface Enhancements for Extended Coverage GSM for support of Cellular Internet of Things | 67d? | 2018-03-15 A | 2018-06-15 A | 100% |  | R6 | 536h | 536h | CIoT_EC_GSM_radio_enh-Perf | 37 | Nokia |  | Rel-14 | 73 |  |  |
| 3920 | 1602 | **New band support for Rel-14 Narrowband Internet of Things (NB-IOT)** | 379d? | 2016-09-15 A | 2017-09-15 A | 100% |  | R4 | 6296h | 6296h | NB_IOT_R14_bands | 37 | Ericsson |  | Rel-14 | 73 |  |  |
| 3921 | 1602.1 | Core part: New band support for Rel-14 Narrowband Internet of Things (NB-IOT) | 196d? | 2016-09-15 A | 2017-06-15 A | 100% | finish no earlier than 2017-06-15 | R4 | 1568h | 1568h | NB_IOT_R14_bands-Core | 37 | Ericsson |  | Rel-14 | 73 | RP-170970 |  |
| 3922 | 1602.2 | Perf. part: New band support for Rel-14 Narrowband Internet of Things (NB-IOT) | 196d? | 2016-09-15 A | 2017-06-15 A | 100% | finish no earlier than 2017-06-15 | R4 | 1568h | 1568h | NB_IOT_R14_bands-Perf | 37 | Ericsson |  | Rel-14 | 73 |  |  |
| 3923 | 1602.3 | UE Conformance Test Aspects - New band support for Rel-14 NB-IoT | 133d? | 2017-03-15 A | 2017-09-15 A | 100% | finish no earlier than 2017-12-15 | R5 | 1064h | 1064h | NB_IOT_R14_bands-UEConTest | 38 | Ericsson |  | Rel-14 | 75 |  |  |
| 3924 | 1603 | **Enhancements of Dedicated Core Networks selection mechanism** | 850.12d? | 2015-09-17 A | 2017-12-15 A | 100% |  |  | 7808h | 7808h | eDecor | 35 | Roland Gustafsson | Roland.Gustafsson@ericsson.com | Rel-14 | 69 | SP-170537 |  |
| 3925 | 1603.1 | Study on Enhancements of Dedicated Core Networks selection mechanism | 132d? | 2015-09-17 A | 2016-03-18 A | 100% | finish no earlier than 2016-03-18 | S2 | 1056h | 1056h | FS_eDecor | 35 | Roland Gustafsson | Roland.Gustafsson@ericsson.com | Rel-14 | 69 |  |  |
| 3926 | 1603.2 | Enhancements of Dedicated Core Networks selection mechanism | 72d? | 2016-06-09 A | 2016-09-15 A | 100% | finish no earlier than 2016-09-15 | S2 | 576h | 576h | eDecor | 37 | Roland Gustafsson | Roland.Gustafsson@ericsson.com | Rel-14 | 72 |  |  |
| 3927 | 1603.3 | **CT aspects of eDecor** | 94.25d? | 2016-09-16 A | 2016-12-15 A | 100% |  | ct | 2080h | 2080h | eDecor-CT | 37 | Mikael Wass | Mikael.wass@ericsson.com | Rel-14 | 73 |  |  |
| 3928 | 1603.3.1 | CT1 aspects of eDecor | 65d? | 2016-09-16 A | 2016-12-15 A | 100% | finish no earlier than 2016-12-15 | C1 | 520h | 520h | eDecor-CT | 37 | Mikael Wass | Mikael.wass@ericsson.com | Rel-14 | 73 |  |  |
| 3929 | 1603.3.2 | CT4 aspects of eDecor | 65d? | 2016-09-16 A | 2016-12-15 A | 100% | finish no earlier than 2016-12-15 | C4 | 520h | 520h | eDecor-CT | 37 | Mikael Wass | Mikael.wass@ericsson.com | Rel-14 | 73 |  |  |
| 3930 | 1603.3.3 | CT6 aspects of eDecor | 65d? | 2016-09-16 A | 2016-12-15 A | 100% | finish no earlier than 2016-12-15 | C6 | 520h | 520h | eDecor-CT | 37 | Mikael Wass | Mikael.wass@ericsson.com | Rel-14 | 73 |  |  |
| 3931 | 1603.4 | **RAN aspects of eDECOR for UMTS and LTE** | 379d? | 2016-12-15 A | 2017-12-15 A | 100% |  | R3 | 3672h | 3672h | eDECOR-UTRA_LTE | 38 | Ericsson |  | Rel-14 | 74 |  |  |
| 3932 | 1603.4.1 | Core part: RAN aspects of eDECOR for UMTS and LTE | 65d? | 2016-12-15 A | 2017-03-15 A | 100% | finish no earlier than 2017-03-15 | R3 | 520h | 520h | eDECOR-UTRA_LTE-Core | 38 | Ericsson |  | Rel-14 | 74 | RP-170547 |  |
| 3933 | 1603.4.2 | UE Conformance Test Aspects - Enhancements of Dedicated Core Networks for UTRA and LTE | 132d? | 2017-06-15 A | 2017-12-15 A | 100% | finish no earlier than 2017-12-15 | R5 | 1056h | 1056h | eDECOR-UTRA_LTE-UEConTest | 39 | Ericsson |  | Rel-14 | 76 |  |  |
| 3934 | 1603.5 | Stopped - GSM aspects of eDECOR | 53d? | 2017-04-04 A | 2017-06-15 A | 100% | start no earlier than 2017-04-04 | R6 | 424h | 424h | eDecor | 39 | Ericsson |  | Rel-14 | 76 |  | 80 |

Notes:
- 3911: Impacted TSs and TRs: 23.401; 23.682; 23.060
- 3912: 28/7/16: 23.730 added¦19/9/16: 0%->70¦1/12/16: FCD:03/17->12/16¦1/12/16: 70%->100 / Impacted TSs and TRs: 23.730
- 3913: 1/12/16: 0%->100¦1/12/16: WID:SP-160732->SP-160830 / Impacted TSs and TRs: 23.401; 23.682; 23.060; 23.271
- 3914: 21/3/17: 24.250 added; / Impacted TSs and TRs: 24.250
- 3915: 6/3/17: 0%->50¦5/6/17: 50%->100 / Impacted TSs and TRs: 24.301; 24.008
- 3916: 6/3/17: 0%->90¦5/6/17: 90%->100 / Impacted TSs and TRs: 23.008; 29.272; 29.002; 29.336; 29.128; 29.171; 29.172; 29.173
- 3918: ¦20/12/16: Compl:0%->50% 21/3/17: Compl:50%->80%19/6/17: Compl:80%->100%
- 3919: ¦20/12/16: Compl:0%->20% ¦21/3/17: Compl:20%->80%¦ 19/6/17: Compl:80%->100%
- 3921: ¦20/12/16: Compl:0%->99% 21/3/17: CD:Wed 15/03/17->Thu 15/06/17;19/6/17: Compl:99%->100%19/6/17: Stat Rep: ->RP-170970
- 3922: ¦20/12/16: Compl:0%->99% 21/3/17: Compl:99%->70% 19/6/17: Compl:70%->100%
- 3923: tested: REL-14 NB_IOT_R14_bands-Core (which got an exception at RAN #75 to still complete in REL-14 by RAN #76);
- 3924: 7/12/15: 0%->70¦7/3/16: 70%->80¦9/6/16: 80%->95 / Impacted TSs and TRs: 23.711
- 3925: 7/12/15: 0%->70¦7/3/16: 70%->80¦9/6/16: 80%->95¦19/9/16: 95%->100 / Impacted TSs and TRs: 23.711
- 3926: 19/9/16: 70%->100 / Impacted TSs and TRs: 23.401; 23.060; 23.251
- 3928: 2/12/16: 0%->80¦6/3/17: 80%->95¦5/6/17: 95%->100 / Impacted TSs and TRs: 24.301; 24.008; 24.368
- 3929: 2/12/16: 0%->10¦6/3/17: 10%->100 / Impacted TSs and TRs: 29.303; 23.003; 23.008
- 3930: 14/12/16: 0%->15¦7/3/17: 15%->85¦5/6/17: 85%->100 / Impacted TSs and TRs: 31.102; 31.111
- 3932: 21/3/17: Compl:0%->100%21/3/17: Stat Rep: ->RP-170547
- 3933: ¦19/9/17: Compl:0%->50%¦ 8/1/18: Compl:50%->100%
- 3934: Verbal addition by Paolo U. 21/09/17: verbal deletion by Paolo / Impacted TSs and TRs: 44.060; 44.018; 48.018

| ID | WBS | Task | Type | Duration | Start | Finish | Complete | Constraint | Resources | Work | Actual work | Acronym | PCG approved | WI rapporteur name | Release | TSG approved | Impacted TSs and TRs | WI rapporteur e-mail | TSG stopped | Status Report |
| --- | --- | --- | --- | --- | --- | --- | --- | --- | --- | --- | --- | --- | --- | --- | --- | --- | --- | --- | --- | --- |
| 3935 | 1604 | **Addition of band 25 and 26 to LTE MTC cat.0** |  | 94.25d? | 2016-12-15 A | 2017-03-15 A | 100% |  | R4 | 1040h | 1040h | LC_MTC_LTE_cat0_B25_B26 | 38 | Sprint | Rel-14 | 74 |  |  |  |  |
| 3936 | 1604.1 | Core part: Addition of band 25 and 26 to LTE MTC cat.0 |  | 65d? | 2016-12-15 A | 2017-03-15 A | 100% | finish no earlier than 2017-03-15 | R4 | 520h | 520h | LC_MTC_LTE_cat0_B25_B26-Core | 38 | Sprint | Rel-14 | 74 |  |  |  |  |
| 3937 | 1605 | Addition of bands 25 and 40 to LTE MTC cat.1 |  | 65d? | 2016-12-15 A | 2017-03-15 A | 100% | finish no earlier than 2017-03-15 | R4 | 520h | 520h | LTE_MTCe2_L1_cat1_B25_B40-Core | 38 | Sprint | Rel-14 | 74 |  |  |  |  |
| 3938 | 1606 | Release 14 on WLAN | milestone | 0d? | 2016-06-09 A | 2016-06-09 A | 100% | finish no earlier than 2016-06-09 |  |  |  |  |  |  | Rel-14 |  |  |  |  |  |
| 3939 | 1607 | **EIR check for WLAN access to EPC** |  | 330.12d? | 2015-11-02 A | 2016-09-15 A | 100% |  |  | 3000h | 3000h | EWE | 36 | Alcatel-Lucent, Nicolas Drevon | Rel-14 | 70 | 23.002; 23.402 | Nicolas.Drevon@alcatel-lucent.com |  |  |
| 3940 | 1607.1 | Stage 2 of EWE |  | 165d? | 2015-11-02 A | 2016-06-17 A | 100% | finish no earlier than 2016-06-17 | S2 | 1320h | 1320h | EWE | 36 | Alcatel-Lucent, Nicolas Drevon | Rel-14 | 70 | 23.002; 23.402 | Nicolas.Drevon@alcatel-lucent.com |  |  |
| 3941 | 1607.2 | **CT aspects of EWE** |  | 98.12d? | 2016-06-13 A | 2016-09-15 A | 100% |  | ct | 1680h | 1680h | EWE-CT | 37 | Nokia, Bruno Landais | Rel-14 | 72 |  | bruno.landais@nokia.com |  |  |
| 3942 | 1607.2.1 | CT1 aspects of EWE |  | 70d? | 2016-06-13 A | 2016-09-15 A | 100% | finish no earlier than 2016-09-15 | C1 | 560h | 560h | EWE-CT | 37 | Nokia, Bruno Landais | Rel-14 | 72 | 24.302 | bruno.landais@nokia.com |  |  |
| 3943 | 1607.2.2 | CT4 aspects of EWE |  | 70d? | 2016-06-13 A | 2016-09-15 A | 100% | finish no earlier than 2016-09-15 | C4 | 560h | 560h | EWE-CT | 37 | Nokia, Bruno Landais | Rel-14 | 72 | 29.273 | bruno.landais@nokia.com |  |  |
| 3944 | 1608 | **Support of EAP Re-authentication Protocol for WLAN Interworking** |  | 188.5d? | 2016-09-16 A | 2017-03-16 A | 100% |  |  | 4152h | 4152h | ERP | 37 | ORANGE, Todor Gamishev | Rel-14 | 73 |  | Todor dot Gamishev at Orange dot com |  |  |
| 3945 | 1608.1 | Support of EAP Re-authentication Protocol for WLAN Interworking |  | 129d? | 2016-09-16 A | 2017-03-15 A | 100% | finish no earlier than 2017-03-15 | S3 | 1032h | 1032h | ERP | 37 | ORANGE, Todor Gamishev | Rel-14 | 73 | 33.402 | Todor dot Gamishev at Orange dot com |  |  |
| 3946 | 1608.2 | **CT aspects of ERP** |  | 188.5d? | 2016-09-16 A | 2017-03-16 A | 100% |  | ct | 3120h | 3120h | ERP-CT | 37 | Orange, Julien Bournelle | Rel-14 | 73 |  | Julien.bournelle@orange.com |  |  |
| 3947 | 1608.2.1 | CT1 aspects of ERP |  | 130d? | 2016-09-16 A | 2017-03-16 A | 100% | finish no earlier than 2017-03-16 | C1 | 1040h | 1040h | ERP-CT | 37 | Orange, Julien Bournelle | Rel-14 | 73 | 24.302 | Julien.bournelle@orange.com |  |  |
| 3948 | 1608.2.2 | CT4 aspects of ERP |  | 130d? | 2016-09-16 A | 2017-03-16 A | 100% | finish no earlier than 2017-03-16 | C4 | 1040h | 1040h | ERP-CT | 37 | Orange, Julien Bournelle | Rel-14 | 73 | 29.273; 23.008; 23.003 | Julien.bournelle@orange.com |  |  |
| 3949 | 1609 | **Phase 2 of the Support of Emergency services over WLAN** |  | 581.88d? | 2015-09-01 A | 2017-03-15 A | 100% |  |  | 5328h | 5328h | SEW2 | 37 | Nicolas Drevon | Rel-14 | 72 | new 23.771; 23.402; 23.167 | nicolas.drevon@nokia.com |  |  |
| 3950 | 1609.1 | Study on Phase 2 of the Support of Emergency services over WLAN |  | 208d? | 2015-09-01 A | 2016-06-16 A | 100% | finish no earlier than 2016-06-16 | S2 | 1664h | 1664h | FS_SEW2 | 34 | Laurent Thiebaut, Alcatel Lucent | Rel-14 | 67 | new 23.771 | Laurent.thiebaut@alcatel-lucent.com |  |  |
| 3951 | 1609.2 | Support of Emergency services over WLAN - phase 2 |  | 70d? | 2016-06-13 A | 2016-09-15 A | 100% | finish no earlier than 2016-09-15 | S2 | 560h | 560h | SEW2 | 37 | Nicolas Drevon | Rel-14 | 72 | 23.402; 23.167 | nicolas.drevon@nokia.com |  |  |
| 3952 | 1609.3 | **CT aspects of SEW2** |  | 187.5d? | 2016-09-16 A | 2017-03-15 A | 100% |  | ct | 3104h | 3104h | SEW2-CT | 37 | Jennifer Liu | Rel-14 | 73 |  | jennifer.liu@nokia.com |  |  |
| 3953 | 1609.3.1 | CT1 aspects of SEW2 |  | 129d? | 2016-09-16 A | 2017-03-15 A | 100% | finish no earlier than 2017-03-15 | C1 | 1032h | 1032h | SEW2-CT | 37 | Jennifer Liu | Rel-14 | 73 | 24.302; 24.312; 24.301; 24.244; 24.229; 24.237 | jennifer.liu@nokia.com |  |  |
| 3954 | 1609.3.2 | CT4 aspects of SEW2 |  | 129d? | 2016-09-16 A | 2017-03-15 A | 100% | finish no earlier than 2017-03-15 | C4 | 1032h | 1032h | SEW2-CT | 37 | Jennifer Liu | Rel-14 | 73 | 23.003; 29.272; 29.273; 29.274; 29.328 | jennifer.liu@nokia.com |  |  |
| 3955 | 1609.3.3 | Stopped - CT6 aspects of SEW2 |  | 1d? | 2016-12-14 A | 2016-12-14 A | 100% | finish no earlier than 2016-12-14 | C6 | 8h | 8h | SEW2-CT | 37 | Jennifer Liu | Rel-14 | 73 | 31.102 | jennifer.liu@nokia.com | 80 |  |
| 3956 | 1610 | T-ADS supporting WLAN Access |  | 134d? | 2016-03-15 A | 2016-09-15 A | 100% | finish no earlier than 2016-09-15 | S2 | 1072h | 1072h | TADS_WLAN | 37 | Jiang Yi | Rel-14 | 72 | 23.292; 23.221; 23.402 | jiangyi (at) chinamobile (dot) com |  | SP-170519 |
| 3957 | 1611 | **Enhanced LTE-WLAN Aggregation (LWA)** |  | 378.88d? | 2016-03-15 A | 2017-03-15 A | 100% |  | R2 | 4208h | 4208h | LTE_WLAN_aggr | 36 | Intel | Rel-14 | 71 |  |  |  |  |
| 3958 | 1611.1 | Core part: Enhanced LTE-WLAN Aggregation (LWA) |  | 263d? | 2016-03-15 A | 2017-03-15 A | 100% | finish no earlier than 2017-03-15 | R2 | 2104h | 2104h | LTE_WLAN_aggr-Core | 36 | Intel | Rel-14 | 71 |  |  |  | RP-170330 |
| 3959 | 1612 | Release 14 on IMS | milestone | 0d? | 2016-06-09 A | 2016-06-09 A | 100% | finish no earlier than 2016-06-09 |  |  |  |  |  |  | Rel-14 |  |  |  |  |  |

Notes:
- 3936: ¦21/3/17: Compl:0%->100%
- 3937: ¦21/3/17: Compl:0%->100%
- 3938: -
- 3939: 7/3/16: 45%->60¦9/6/16: 60%->100
- 3940: 7/3/16: 45%->60¦9/6/16: 60%->100
- 3942: 16/9/16: 0%->100
- 3943: 2/12/16: 0%->100
- 3945: 1/12/16: 0%->90¦6/3/17: 90%->100
- 3947: 2/12/16: 0%->80¦6/3/17: 80%->95¦5/6/17: 95%->100
- 3948: 2/12/16: 0%->50¦6/3/17: 50%->95¦5/6/17: 95%->100
- 3950: June2015: Compl:0%->100, SP-150151->SP-150251¦7/12/15: 0%->30, FCD: 12/15->06/16¦7/3/16: 30%->75¦7/3/16: WID:SP-150251->SP-160173¦9/6/16: 75%->100
- 3951: 11/6/16: 0%->45¦19/9/16: 45%->100
- 3952: 5/12/16: WID:CP-160476->CP-160694
- 3953: 2/12/16: 20%->95¦5/6/17: 95%->100
- 3954: 2/12/16: 0%->100
- 3955: Deleted at CT6#82
- 3956: 19/9/16: 0%->100
- 3957: follow-up WI of REL-13 WI LTE_WLAN_radio¦no Perf. part
- 3958: follow-up WI of REL-13 WI LTE_WLAN_radio¦no Perf. part1/7/16: Compl:0%->25%1/7/16: WID: RP-160600->RP-160923¦26/9/16: Compl:25%->45%¦20/12/16: Compl:45%->75%¦20/12/16: Stat Rep: --> ¦21/3/17: Compl:75%->100% ¦21/3/17
- 3959: -

| ID | WBS | Task | Type | Duration | Start | Finish | Complete | Baseline start | Baseline finish | Baseline duration | Constraint | Resources | Work | Actual work | Acronym | PCG approved | Impacted TSs and TRs | WI rapporteur name | Release | TSG approved | Status Report | WI rapporteur e-mail | MCC resp | Acronym_3GU_Export |
| --- | --- | --- | --- | --- | --- | --- | --- | --- | --- | --- | --- | --- | --- | --- | --- | --- | --- | --- | --- | --- | --- | --- | --- | --- |
| 3960 | 1613 | **Evolution to and Interworking with eCall in IMS** |  | 1076.88d? | 2015-05-11 A | 2018-03-15 A | 100% |  |  |  |  |  | 6288h | 6288h | EIEI | 35 | 22.101 | Kurt Bischinger | Rel-14 | 68 | SP-170538 |  |  |  |
| 3961 | 1613.1 | Stage 1 of Evolution to and Interworking with eCall in IMS |  | 30d? | 2015-05-11 A | 2015-06-19 A | 100% |  |  |  | start no earlier than 2015-05-11 | S1 | 240h | 240h | EIEI | 35 | 22.101 | Kurt Bischinger | Rel-14 | 68 |  |  |  |  |
| 3962 | 1613.2 | Stage 2 of Evolution to and Interworking with eCall in IMS |  | 131d? | 2015-12-11 A | 2016-06-10 A | 100% |  |  |  | finish no earlier than 2016-06-10 | S2 | 1048h | 1048h | EIEI | 35 | 23.167; 23.401 | Haris Zisimopoulos, Qualcomm Incorporated | Rel-14 | 68 |  | harisz@qti.qualcomm.com |  |  |
| 3963 | 1613.3 | **CT aspects of evolution to and interworking with eCall in IMS** |  | 204.88d? | 2016-03-02 A | 2016-09-15 A | 100% |  |  |  |  |  | 3432h | 3432h | EIEI-CT | 36 |  | Lena Chaponniere | Rel-14 | 71 |  | lguellec@qti.qualcomm.com |  |  |
| 3964 | 1613.3.1 | CT1 aspects of evolution to and interworking with eCall in IMS |  | 143d? | 2016-03-02 A | 2016-09-15 A | 100% |  |  |  | finish no earlier than 2016-09-15 | C1 | 1144h | 1144h | EIEI-CT | 36 | 24.229; 24.301 | Lena Chaponniere | Rel-14 | 71 |  | lguellec@qti.qualcomm.com |  |  |
| 3965 | 1613.3.2 | (IETF) Next-Generation Pan-European eCall (draft-ietf-ecrit-ecall) |  | 143d? | 2016-03-02 A | 2016-09-15 A | 100% |  |  |  | finish no earlier than 2016-09-15 | C1-IETF | 1144h | 1144h | EIEI-CT | 37 | draft-ietf-ecrit-ecall; RFC 8147 |  | Rel-14 | 72 |  |  |  |  |
| 3966 | 1613.3.3 | CT6 aspects of evolution to and interworking with eCall in IMS |  | 143d? | 2016-03-02 A | 2016-09-15 A | 100% |  |  |  | finish no earlier than 2016-09-15 | C6 | 1144h | 1144h | EIEI-CT | 36 | 31.102 | Lena Chaponniere | Rel-14 | 71 |  | lguellec@qti.qualcomm.com |  |  |
| 3967 | 1613.4 | UE Conformance Test Aspects - Evolution to and Interworking with eCall in IMS (EIEI) |  | 196d? | 2017-06-15 A | 2018-03-15 A | 100% |  |  |  | finish no earlier than 2018-03-15 | R5 | 1568h | 1568h | EIEI-UEConTest | 39 |  | Qualcomm | Rel-14 | 76 |  |  |  |  |
| 3968 | 1614 | **Password based service activation for IMS Multimedia Telephony service** |  | 668.88d? | 2015-03-11 A | 2016-12-15 A | 100% |  |  |  |  |  | 3264h | 3264h | PWDIMS | 34 | 22.173 | Peter Bleckert (Ericsson) | Rel-14 | 67 | SP-170536 |  |  |  |
| 3969 | 1614.1 | Stage 1 for PWDIMS |  | 3d? | 2015-03-11 A | 2015-03-13 A | 100% |  |  |  | finish no earlier than 2015-03-13 | S1 | 24h | 24h | PWDIMS | 34 | 22.173 | Peter Bleckert (Ericsson) | Rel-14 | 67 |  |  |  |  |
| 3970 | 1614.2 | **CT aspects for PWDIMS** |  | 192.38d? | 2016-06-13 A | 2016-12-15 A | 100% |  |  |  |  | ct | 3240h | 3240h | PWDIMS-CT | 37 |  | Axell, Jörgen | Rel-14 | 72 |  |  |  |  |
| 3971 | 1614.2.1 | CT1 aspects for PWDIMS |  | 135d? | 2016-06-13 A | 2016-12-15 A | 100% |  |  |  | finish no earlier than 2016-12-15 | C1 | 1080h | 1080h | PWDIMS-CT | 37 | 24.623; 24.611 | Axell, Jörgen | Rel-14 | 72 |  |  |  |  |
| 3972 | 1614.2.2 | CT3 aspects for PWDIMS |  | 135d? | 2016-06-13 A | 2016-12-15 A | 100% |  |  |  | finish no earlier than 2016-12-15 | C3 | 1080h | 1080h | PWDIMS-CT | 37 | 29.292 | Axell, Jörgen | Rel-14 | 72 |  |  |  |  |
| 3973 | 1615 | **IMS Signalling Activated Trace** |  | 763.88d? | 2014-03-05 A | 2016-03-11 A | 100% | 2014-03-05 | 2014-09-12 | 138d? |  |  | 22056h | 22056h | ISAT | 32 |  | Vodafone | Rel-14 | 63 |  | peter.dawes @vodafone.com | Frederic | ISAT |
| 3974 | 1615.1 | CT1 part of IMS Signalling Activated Trace |  | 528d? | 2014-03-10 A | 2016-03-11 A | 100% | 2014-03-05 | 2014-09-12 | 138d? | finish no earlier than 2016-03-11 | C1 | 4224h | 4224h | ISAT | 32 | 24.229; 24.323 | Vodafone | Rel-14 | 63 |  | peter.dawes @vodafone.com | Frederic |  |
| 3975 | 1615.2 | (IETF) IMS Signalling Activated Trace (draft-ietf-insipid-logme-marking) --> RFC 8497 |  | 391d? | 2014-09-12 A | 2016-03-11 A | 100% |  |  |  | finish no earlier than 2016-03-11 | C1-IETF | 3128h | 3128h | ISAT | 33 | draft-dawes-sipping-debug | Vodafone | Rel-14 | 65 |  | peter.dawes @vodafone.com |  |  |
| 3976 | 1615.3 | (IETF) IMS Signalling Activated Trace (draft-ietf-insipid-logme-marking) --> RFC 8497 |  | 391d? | 2014-09-12 A | 2016-03-11 A | 100% |  |  |  | finish no earlier than 2016-03-11 | C3-IETF | 3128h | 3128h | ISAT | 33 | draft-dawes-sipping-debug | Vodafone | Rel-14 | 65 |  | peter.dawes @vodafone.com |  |  |
| 3977 | 1615.4 | (IETF) IMS Signalling Activated Trace (draft-ietf-insipid-logme-marking) --> RFC 8497 |  | 391d? | 2014-09-12 A | 2016-03-11 A | 100% |  |  |  | finish no earlier than 2016-03-11 | C4-IETF | 3128h | 3128h | ISAT | 33 | draft-dawes-sipping-debug | Vodafone | Rel-14 | 65 |  | peter.dawes @vodafone.com |  |  |
| 3978 | 1615.5 | CT3 part of IMS Signalling Activated Trace |  | 528d? | 2014-03-10 A | 2016-03-11 A | 100% | 2014-03-05 | 2014-06-13 | 73d? | finish no earlier than 2016-03-11 | C3 | 4224h | 4224h | ISAT | 32 | 29.165 | Vodafone | Rel-14 | 63 |  | peter.dawes @vodafone.com | Adrian |  |
| 3979 | 1615.6 | CT4 part of IMS Signalling Activated Trace |  | 528d? | 2014-03-05 A | 2016-03-11 A | 100% | 2014-03-05 | 2014-09-12 | 138d? | finish no earlier than 2016-03-11 | C4 | 4224h | 4224h | ISAT | 32 | 23.008; 29.228; 29.229; 29.328; 29.329 | Vodafone | Rel-14 | 63 |  | peter.dawes @vodafone.com | Kimmo |  |
| 3980 | 1616 | Other Release 14 | milestone | 0d? | 2016-06-09 A | 2016-06-09 A | 100% |  |  |  | finish no earlier than 2016-06-09 |  |  |  |  |  |  |  | Rel-14 |  |  |  |  |  |
| 3981 | 1617 | **User Controlled Spoofed Call Treatment** |  | 685.5d? | 2016-08-23 A | 2018-06-15 A | 100% |  |  |  |  |  | 2856h | 2856h | SPECTRE | 37 |  | Greg Schumacher, Sprint | Rel-14 | 73 |  |  |  |  |
| 3982 | 1617.1 | Stage 1 of User Controlled Spoofed Call Treatment |  | 20d? | 2016-08-23 A | 2016-09-19 A | 100% |  |  |  | finish no earlier than 2016-09-19 | S1 | 160h | 160h | SPECTRE | 37 | 22.228; 22.173 | Greg Schumacher, Sprint | Rel-14 | 73 |  |  |  |  |
| 3983 | 1617.2 | Stage 3 of User Controlled Spoofed Call Treatment |  | 74d? | 2016-12-01 A | 2017-03-14 A | 100% |  |  |  | finish no earlier than 2017-03-14 | C1 | 592h | 592h | SPECTRE-CT | 38 | 24.229; 29.165 | Dolly, Martin | Rel-14 | 74 |  | md3135@att.com |  |  |
| 3984 | 1617.3 | (IETF) A SIP Response Code for Unwanted Calls (draft-ietf-sipcore-status-unwanted) |  | 1d? | 2017-03-14 A | 2017-03-14 A | 100% |  |  |  | finish no earlier than 2017-03-14 | C1-IETF | 8h | 8h | SPECTRE-CT_IETF | 38 | RFC 8197 | Ericsson | Rel-14 | 75 |  |  |  |  |
| 3985 | 1617.4 | (IETF) Authenticated Identity Management in SIP (draft-ietf-stir-rfc4474bis) |  | 262d? | 2017-06-15 A | 2018-06-15 A | 100% |  |  |  | finish no earlier than 2018-06-15 | C1-IETF | 2096h | 2096h | SPECTRE-CT_IETF2 | 40 | RFC 8224 | Christer Holmberg | Rel-14 | 78 |  | christer.holmberg@ericsson.com |  |  |

Notes:
- 3960: 12/15: created by MCC to distinguish Stage 1 from Stage 2
- 3962: 7/3/16: 0%->20¦9/6/16: 20%->100. FCD: 03/16->06/16
- 3964: 11/6/16: 0%->35¦16/9/16: 35%->85¦2/12/16: 85%->100
- 3965: 18/12/17: 30%->100; 9/4/21: RFC 8147 added;
- 3966: 16/9/16: 0%->100
- 3967: ¦19/9/17: Compl:0%->45%¦8/1/18: Compl:45%->80%¦27/3/18: Compl:80%->100%
- 3968: 1/4/15: rapporteur added, Impacted TS added. 31/07/15: 100%
- 3969: 1/4/15: rapporteur added, Impacted TS added. 31/07/15: 100%
- 3971: 2/12/16: 0%->15¦6/3/17: 15%->100
- 3972: 5/6/17: 0%->100
- 3973: Mar 15: WID: CP-140195->CP-150091. ES in CP-150637. 8/3/16: Moved from Rel-13 at CT#71
- 3974: CP66: moved to Rel-13. Mar 15: WID: CP-140195->CP-150091. ES in CP-150728¦5/6/17: 0%->100
- 3975: CP66: moved to Rel-13. Mar 15: WID: CP-140195->CP-150091. ES in CP-150637¦13/6/16: 25%->28; 26/6/19: 28%->100
- 3976: CP66: moved to Rel-13. Mar 15: WID: CP-140195->CP-150091. ES in CP-150637; 26/6/19: 25%->100
- 3977: CP66: moved to Rel-13. Mar 15: WID: CP-140195->CP-150091. ES in CP-150637¦5/6/17: 25%->70; 26/6/19: 70%->100
- 3978: CP66: moved to Rel-13. Mar 15: WID: CP-140195->CP-150091. ES in CP-150637¦5/6/17: 0%->100
- 3979: CP66: moved to Rel-13. Mar.15: 90%. ES in CP-150615. 7/3/16: Rel-13->Rel-14¦5/6/17: 90%->100
- 3980: -
- 3981: 1/12/16: moved from Rel-15 to Rel-14¦1/12/16: WID:SP-160729->SP-160898
- 3982: 1/12/16: moved from Rel-15 to Rel-14¦1/12/16: WID:SP-160729->SP-160898
- 3983: 2/12/16: 0%->25¦6/3/17: 25%->100
- 3984: 18/12/17: 20%->100; 9/4/21: RFC 8197 added;
- 3985: 22/3/18: 0%->100; 9/4/21: RFC 8224 added;

| ID | WBS | Task | Duration | Start | Finish | Complete | Constraint | Resources | Work | Actual work | Acronym | PCG approved | WI rapporteur name | WI rapporteur e-mail | Release | TSG approved | Status Report |
| --- | --- | --- | --- | --- | --- | --- | --- | --- | --- | --- | --- | --- | --- | --- | --- | --- | --- |
| 3986 | 1618 | **Enhancement for TV service** | 815.88d? | 2015-04-14 A | 2017-06-09 A | 100% |  |  | 7800h | 7800h | EnTV | 36 | Zhiming Li | Lizhiming@huawei.com | Rel-14 | 70 | SP-170532 |
| 3987 | 1618.1 | Study on 3GPP Enhancement for TV Video service | 176d? | 2015-04-14 A | 2015-12-15 A | 100% | finish no earlier than 2015-12-15 | S1 | 1408h | 1408h | FS_EnTV | 34 | Zhiming Li (Huawei) | lizhiming@huawei.com | Rel-14 | 67 |  |
| 3988 | 1618.2 | **System Architecture Enhancements to eMBMS for TV Video Service** | 289.88d? | 2016-03-11 A | 2016-12-15 A | 100% |  |  | 1736h | 1736h | AE_enTV | 36 |  |  | Rel-14 | 71 |  |
| 3989 | 1618.2.1 | Study on System Architecture Enhancements to eMBMS for TV Video Service | 136d? | 2016-03-11 A | 2016-09-15 A | 100% | finish no earlier than 2016-09-15 | S2 | 1088h | 1088h | FS_AE_enTV | 36 | Miguel Griot, Qualcomm | mgriot@qti.qualcomm.com | Rel-14 | 71 |  |
| 3990 | 1618.2.2 | System Architecture Enhancements for TV service | 81d? | 2016-08-25 A | 2016-12-15 A | 100% | finish no earlier than 2016-12-15 | S2 | 648h | 648h | AE_enTV | 37 | Miguel Griot, Qualcomm | mgriot@qti.qualcomm.com | Rel-14 | 73 |  |
| 3991 | 1618.3 | Mobile Network Interface for MBMS Delivery of Media and TV services | 80d? | 2016-08-22 A | 2016-12-09 A | 100% | finish no earlier than 2016-12-09 | S4 | 640h | 640h | AE_enTV-MI_MTV | 37 | Thorsten Lohmar | Thorsten.lohmar@ericsson.com | Rel-14 | 73 |  |
| 3992 | 1618.4 | Codec aspects for eMBMS Delivery of Media and TV Services | 132d? | 2016-12-08 A | 2017-06-09 A | 100% | finish no earlier than 2017-06-09 | S4 | 1056h | 1056h | AE_enTV-S4 | 38 | Imed Bouazizi | i.bouazizi@samsung.com | Rel-14 | 74 |  |
| 3993 | 1618.5 | **Stage 3 of system architecture enhancements for TV service** | 107.75d? | 2016-12-01 A | 2017-03-14 A | 100% |  | ct | 2960h | 2960h | AE_enTV-CT | 38 | Catovic, Amer | amerc@qti.qualcomm.com | Rel-14 | 74 |  |
| 3994 | 1618.5.1 | CT1 aspects of system architecture enhancements for TV service | 74d? | 2016-12-01 A | 2017-03-14 A | 100% | finish no earlier than 2017-03-14 | C1 | 592h | 592h | AE_enTV-CT | 38 | Catovic, Amer | amerc@qti.qualcomm.com | Rel-14 | 74 |  |
| 3995 | 1618.5.2 | CT3 aspects of system architecture enhancements for TV service | 74d? | 2016-12-01 A | 2017-03-14 A | 100% | finish no earlier than 2017-03-14 | C3 | 592h | 592h | AE_enTV-CT | 38 | Catovic, Amer | amerc@qti.qualcomm.com | Rel-14 | 74 |  |
| 3996 | 1618.5.3 | CT4 aspects of system architecture enhancements for TV service | 74d? | 2016-12-01 A | 2017-03-14 A | 100% | finish no earlier than 2017-03-14 | C4 | 592h | 592h | AE_enTV-CT | 38 | Catovic, Amer | amerc@qti.qualcomm.com | Rel-14 | 74 |  |
| 3997 | 1618.5.4 | CT6 aspects of system architecture enhancements for TV service | 74d? | 2016-12-01 A | 2017-03-14 A | 100% | finish no earlier than 2017-03-14 | C6 | 592h | 592h | AE_enTV-CT | 38 | Catovic, Amer | amerc@qti.qualcomm.com | Rel-14 | 74 |  |
| 3998 | 1619 | MBMS Transport Protocol and APIs | 330d? | 2015-12-11 A | 2017-03-15 A | 100% | finish no earlier than 2017-03-15 | S4 | 2640h | 2640h | TRAPI | 36 | Samsung, Imed Bouazizi | i.bouazizi@samsung.com | Rel-14 | 70 |  |
| 3999 | 1620 | Multimedia Priority Service Modifications | 331d? | 2015-03-11 A | 2016-06-15 A | 100% | finish no earlier than 2016-06-15 | S1 | 2648h | 2648h | MPS_Mods | 34 | Ray P. Singh (Applied Communications Science) | rsingh@appcomsci.com | Rel-14 | 67 |  |
| 4000 | 1621 | Lawful Interception Rel-14 | 394d? | 2016-06-15 A | 2017-12-15 A | 100% | finish no earlier than 2017-12-15 | S3LI | 3152h | 3152h | LI14 | 37 | Koen JASPERS, PIDS |  | Rel-14 | 72 |  |
| 4001 | 1622 | **SIP Reason header extension** | 659.75d? | 2016-09-16 A | 2018-06-14 A | 100% |  | ct | 7792h | 7792h | REAS_EXT | 37 | Mohali, Marianne | marianne.mohali@orange.com | Rel-14 | 73 | CP-171175 |
| 4002 | 1622.1 | CT1 aspects of SIP Reason header extension | 129d? | 2016-09-16 A | 2017-03-15 A | 100% | finish no earlier than 2017-03-15 | C1 | 1032h | 1032h | REAS_EXT | 37 | Mohali, Marianne | marianne.mohali@orange.com | Rel-14 | 73 |  |
| 4003 | 1622.2 | (IETF) ISUP Cause Location Parameter for the SIP Reason Header Field (draft-ietf-sipcore-reason-q850-loc) --> RFC 8606 | 261d? | 2017-06-15 A | 2018-06-14 A | 100% | finish no earlier than 2018-06-14 | C1-IETF | 2088h | 2088h | REAS_EXT | 40 | Michael KREIPL, Deutsche Telekom | michael(dot)kreipl(at)telekom(dot)de | Rel-14 | 78 |  |
| 4004 | 1622.3 | CT3 aspects of SIP Reason header extension | 129d? | 2016-09-16 A | 2017-03-15 A | 100% | finish no earlier than 2017-03-15 | C3 | 1032h | 1032h | REAS_EXT | 37 | Mohali, Marianne | marianne.mohali@orange.com | Rel-14 | 73 |  |
| 4005 | 1623 | Enhancements to User Location Reporting Support | 73d? | 2015-09-09 A | 2015-12-18 A | 100% | finish no earlier than 2015-12-18 | S1 | 584h | 584h | eULRS | 35 |  |  | Rel-14 | 68 |  |
| 4006 | 1624 | **Diameter Load Control Mechanism** | 863.62d? | 2014-12-03 A | 2017-03-15 A | 100% |  | ct | 8032h | 8032h | DLoCMe | 37 | Nokia, Ulrich Wiehe | ulrich.wiehe@nokia.com | Rel-14 | 73 | CP-171049 |
| 4007 | 1624.1 | CT3 aspects of Diameter Load Control Mechanism | 65d? | 2016-09-16 A | 2016-12-15 A | 100% | finish no earlier than 2016-12-15 | C3 | 520h | 520h | DLoCMe | 37 | Nokia, Ulrich Wiehe | ulrich.wiehe@nokia.com | Rel-14 | 73 |  |
| 4008 | 1624.2 | CT4 aspects of Diameter Load Control Mechanism | 65d? | 2016-09-16 A | 2016-12-15 A | 100% | finish no earlier than 2016-12-15 | C4 | 520h | 520h | DLoCMe | 37 | Nokia, Ulrich Wiehe | ulrich.wiehe@nokia.com | Rel-14 | 73 |  |
| 4009 | 1624.3 | (IETF) Diameter Load Information Conveyance (draft-ietf-dime-load) --> RFC 8583 | 74d? | 2016-12-02 A | 2017-03-15 A | 100% | finish no earlier than 2017-03-15 | C4-IETF | 592h | 592h | DLoCMe | 38 |  |  | Rel-14 | 74 |  |
| 4010 | 1624.4 | Study on Diameter Load Control Mechanisms | 203d? | 2014-12-03 A | 2015-09-11 A | 100% | finish no earlier than 2015-09-11 | C4 | 1624h | 1624h | FS_DLoCME | 34 | Alcatel-Lucent |  | Rel-13 | 66 |  |

Notes:
- 3986: 2/3/16: 0%->100 / Impacted TSs and TRs: 22.101
- 3987: 1/4/15:TR number added¦June2015: Compl:0%->20¦07/09/15: 20%->75¦7/12/15: 75%->100 / Impacted TSs and TRs: 22.816
- 3989: 9/6/16: 0%->70¦28/7/16: 23.746 added¦19/9/16: 70%->100 / Impacted TSs and TRs: 23.746
- 3990: 19/9/16: 0%->85¦1/12/16: FCD:09/16->12/16¦1/12/16: 85%->100 / Impacted TSs and TRs: 23.246
- 3991: 06/10/16: Acronym: SA_enTV-MI_MTV -> AE_enTV-MI_MTV¦1/12/16: FCD:09/16->2/16¦1/12/16: 0%->50¦8/12/16: 50%->100 / Impacted TSs and TRs: 26.346
- 3992: 6/3/17: 0%->20¦6/3/17: FCD:03/17->06/17¦7/6/17: 20%->100 / Impacted TSs and TRs: 26.347; 26.346
- 3993: 21/3/17: 29.116 added; / Impacted TSs and TRs: 24.116; 24.117; 29.116
- 3994: 2/12/16: 0%->40¦6/3/17: 40%->75¦5/6/17: 75%->100 / Impacted TSs and TRs: 24.008
- 3995: 6/3/17: 0%->80¦6/3/17: 80%->100 / Impacted TSs and TRs: 29.061
- 3996: 5/6/17: 0%->100 / Impacted TSs and TRs: 29.274; 23.003
- 3997: 7/3/17: 0%->100 / Impacted TSs and TRs: 31.102
- 3998: 28/1/16: 26.347 added¦7/3/16: 0%->20¦11/6/16: 20%->35¦19/9/16: 35%->60. FCD: 09/16->03/17¦1/12/16: 60%->70¦6/3/17: 70%->100 / Impacted TSs and TRs: 26.346; 26.852; New TS; 26.347
- 3999: 1/4/15: rapporteur added, Impacted TS added. 6/15: 0->25%¦07/09/15: 25%->40¦7/12/15: 40%->70¦2/3/16: 70%->80¦9/6/16: 80%->100 / Impacted TSs and TRs: 22.153
- 4000: 1/12/16: 0%->10¦2/3/17: WID:SP-160375->SP-1570038¦3/3/17: 8%->15¦6/3/17: 15%->20¦9/3/17: WID:SP-1570038->SP-170038¦7/6/17: 20%->50¦11/9/17: 50%->80¦15/12/17: 80%->100
- 4002: 2/12/16: 0%->50¦6/3/17: 50%->85¦5/6/17: 85%->100 / Impacted TSs and TRs: 24.229
- 4003: 23/4/20: 50%->100
- 4004: 5/6/17: 0%->100 / Impacted TSs and TRs: 29.163; 29.292
- 4005: 2/3/16: 0%->100
- 4006: 5/12/16: WID:CP-160412->CP-160645
- 4007: 2/12/16: 0%->100 / Impacted TSs and TRs: 29.272; 29.273; 29.228; 29.229; 29.328; 29.329; 29.336; 29.344; 29.345; 29.128; 29.283
- 4008: 2/12/16: 0%->100 / Impacted TSs and TRs: 29.153; 29.154; 29.212; 29.214; 29.215; 29.217; 29.219; 29.213
- 4009: 2/12/16: 0%->90
- 4010: 0->5%. Mar. 15: 10%¦7/12/15: 10%->40¦13/6/16: 40%->100 / Impacted TSs and TRs: New 29.810

| ID | WBS | Task | Duration | Start | Finish | Complete | Constraint | Resources | Work | Actual work | Acronym | PCG approved | WI rapporteur e-mail | Release | TSG approved | Status Report | TSG stopped |
| --- | --- | --- | --- | --- | --- | --- | --- | --- | --- | --- | --- | --- | --- | --- | --- | --- | --- |
| 4011 | 1625 | **Diameter Base Protocol Specification Update** | 107.75d? | 2016-12-01 A | 2017-03-14 A | 100% |  |  | 2352h | 2352h | DBPU | 38 | Peter.Schmitt@huawei.com | Rel-14 | 74 |  |  |
| 4012 | 1625.1 | **CT aspects of Diameter Base Protocol Specification Update** | 107.75d? | 2016-12-01 A | 2017-03-14 A | 100% |  | ct | 1776h | 1776h | DBPU | 38 | Peter.Schmitt@huawei.com | Rel-14 | 74 |  |  |
| 4013 | 1625.1.1 | CT3 aspects of Diameter Base Protocol Specification Update | 74d? | 2016-12-01 A | 2017-03-14 A | 100% | finish no earlier than 2017-03-14 | C3 | 592h | 592h | DBPU | 38 | Peter.Schmitt@huawei.com | Rel-14 | 74 |  |  |
| 4014 | 1625.1.2 | CT4 aspects of Diameter Base Protocol Specification Update | 74d? | 2016-12-01 A | 2017-03-14 A | 100% | finish no earlier than 2017-03-14 | C4 | 592h | 592h | DBPU | 38 | Peter.Schmitt@huawei.com | Rel-14 | 74 |  |  |
| 4015 | 1625.2 | Charging aspects for Diameter Base Protocol Specification Update | 72d? | 2016-12-01 A | 2017-03-10 A | 100% | finish no earlier than 2017-03-10 | S5 | 576h | 576h | DBPU-CH | 38 | Nokia, Maryse <dot> Gardella <at> Nokia <dot> com | Rel-14 | 74 |  |  |
| 4016 | 1626 | **Enhancements to Multi-stream Multiparty Conferencing Media Handling** | 398.62d? | 2016-03-02 A | 2017-03-21 A | 100% |  |  | 10320h | 10320h | MMCMH_Enh | 37 | nleung@qti.qualcomm.com | Rel-14 | 72 | SP-170528 |  |
| 4017 | 1626.1 | Overall aspects of MMCMH_Enh | 196d? | 2016-06-13 A | 2017-03-10 A | 100% | finish no earlier than 2017-03-10 | S4 | 1568h | 1568h | MMCMH_Enh | 37 | nleung@qti.qualcomm.com | Rel-14 | 72 |  |  |
| 4018 | 1626.2 | **CT aspects of MMCMH_Enh** | 398.62d? | 2016-03-02 A | 2017-03-21 A | 100% |  | ct | 8752h | 8752h | MMCMH_Enh-CT | 37 | nevenka.biondic@ericsson.com | Rel-14 | 72 |  |  |
| 4019 | 1626.2.1 | CT1 aspects of MMCMH_Enh | 272d? | 2016-03-02 A | 2017-03-15 A | 100% | finish no earlier than 2017-03-15 | C1 | 2176h | 2176h | MMCMH_Enh-CT | 37 | nevenka.biondic@ericsson.com | Rel-14 | 72 |  |  |
| 4020 | 1626.2.2 | CT3 aspects of MMCMH_Enh | 272d? | 2016-03-02 A | 2017-03-15 A | 100% | finish no earlier than 2017-03-15 | C3 | 2176h | 2176h | MMCMH_Enh-CT | 37 | nevenka.biondic@ericsson.com | Rel-14 | 72 |  |  |
| 4021 | 1626.2.3 | CT4 aspects of MMCMH_Enh | 272d? | 2016-03-02 A | 2017-03-15 A | 100% | finish no earlier than 2017-03-15 | C4 | 2176h | 2176h | MMCMH_Enh-CT | 37 | nevenka.biondic@ericsson.com | Rel-14 | 72 |  |  |
| 4022 | 1626.2.4 | (IETF) Using Simulcast in SDP and RTP Sessions (draft-ietf-mmusic-sdp-simulcast) | 1d? | 2017-03-21 A | 2017-03-21 A | 100% | start no earlier than 2017-03-21 | C1-IETF | 8h | 8h | MMCMH_Enh-CT | 38 | tomas.frankkila@ericsson.com | Rel-14 | 75 |  |  |
| 4023 | 1626.2.5 | (IETF) RTP Payload Format Restrictions (draft-ietf-mmusic-rid) | 1d? | 2017-03-21 A | 2017-03-21 A | 100% | start no earlier than 2017-03-21 | C1-IETF | 8h | 8h | MMCMH_Enh-CT | 38 |  | Rel-14 | 75 |  |  |
| 4024 | 1627 | **Stopped - CT aspects of (or "Enhancements of") MTSI Extension on Multi-stream** | 204.88d? | 2016-03-02 A | 2016-09-15 A | 100% |  | ct | 4576h | 4576h | MMCMH-CT | 36 | nevenka.biondic@ericsson.com | Rel-14 | 71 |  | CP-72 |
| 4025 | 1627.1 | deleted -CT1 aspects of MTSI Extension on Multi-stream | 143d? | 2016-03-02 A | 2016-09-15 A | 100% | start no earlier than 2016-03-02 | C1 | 1144h | 1144h | MMCMH-CT | 36 | nevenka.biondic@ericsson.com | Rel-14 | 71 |  | CP-72 |
| 4026 | 1627.2 | deleted -CT3 aspects of MTSI Extension on Multi-stream | 143d? | 2016-03-02 A | 2016-09-15 A | 100% | start no earlier than 2016-03-02 | C3 | 1144h | 1144h | MMCMH-CT | 36 | nevenka.biondic@ericsson.com | Rel-14 | 71 |  | CP-72 |
| 4027 | 1627.3 | deleted -CT4 aspects of MTSI Extension on Multi-stream | 143d? | 2016-03-02 A | 2016-09-15 A | 100% | start no earlier than 2016-03-02 | C4 | 1144h | 1144h | MMCMH-CT | 36 | nevenka.biondic@ericsson.com | Rel-14 | 71 |  | CP-72 |
| 4028 | 1628 | **Control and User Plane Separation of EPC nodes** | 565.38d? | 2015-09-17 A | 2017-03-15 A | 100% |  |  | 5248h | 5248h | CUPS | 35 | mirko.schramm@huawei.com | Rel-14 | 69 | SP-170520 |  |
| 4029 | 1628.1 | Study on Control and User Plane Separation of EPC nodes | 197d? | 2015-09-17 A | 2016-06-17 A | 100% | finish no earlier than 2016-06-17 | S2 | 1576h | 1576h | FS_CUPS | 35 | mirko.schramm@huawei.com | Rel-14 | 69 |  |  |
| 4030 | 1628.2 | Control and User Plane Separation of EPC nodes | 72d? | 2016-06-09 A | 2016-09-15 A | 100% | finish no earlier than 2016-09-15 | S2 | 576h | 576h | CUPS | 37 | mirko.schramm@huawei.com | Rel-14 | 72 |  |  |
| 4031 | 1628.3 | **CT aspects for CUPS** | 187.5d? | 2016-09-16 A | 2017-03-15 A | 100% |  | ct | 3096h | 3096h | CUPS-CT | 37 | peter.schmitt@huawei.com | Rel-14 | 73 |  |  |
| 4032 | 1628.3.1 | CT3 aspects for CUPS | 129d? | 2016-09-16 A | 2017-03-15 A | 100% | finish no earlier than 2017-03-15 | C3 | 1032h | 1032h | CUPS-CT | 37 | peter.schmitt@huawei.com | Rel-14 | 73 |  |  |
| 4033 | 1628.3.2 | CT4 aspects for CUPS | 129d? | 2016-09-16 A | 2017-03-15 A | 100% | finish no earlier than 2017-03-15 | C4 | 1032h | 1032h | CUPS-CT | 37 | peter.schmitt@huawei.com | Rel-14 | 73 |  |  |
| 4034 | 1629 | **OAM14 Rel-14 Operations, Administration, Maintenance and Provisioning (OAM&P)** | 1042.88d? | 2015-03-12 A | 2017-12-12 A | 100% |  | S5 | 35193.6h | 35193.6h | OAM14 | 35 |  | Rel-14 | 68 |  |  |
| 4035 | 1629.1 | **Management of mobile networks that include virtualized network functions** | 944.38d? | 2015-06-15 A | 2017-12-12 A | 100% |  | S5 | 23968h | 23968h | OAM14-MAMO_VNF | 35 | liujinglei@chinamobile.com | Rel-14 | 68 |  |  |
| 4036 | 1629.1.1 | Management concept, architecture and requirements for mobile networks that include virtualized network functions | 395d? | 2015-06-15 A | 2016-12-15 A | 100% | finish no earlier than 2016-12-15 | S5 | 3160h | 3160h | OAM14-MAMO_VNF-MCAR | 35 | liujinglei@chinamobile.com | Rel-14 | 68 |  |  |
| 4037 | 1629.1.2 | Configuration Management for mobile networks that include virtualized network functions | 454d? | 2015-09-16 A | 2017-06-09 A | 100% | finish no earlier than 2017-06-09 | S5 | 3632h | 3632h | OAM14-MAMO_VNF-CM | 35 | zhu.weihong@zte.com.cn | Rel-14 | 69 |  |  |
| 4038 | 1629.1.3 | Fault Management for mobile networks that include virtualized network functions | 454d? | 2015-09-16 A | 2017-06-09 A | 100% | finish no earlier than 2017-06-09 | S5 | 3632h | 3632h | OAM14-MAMO_VNF-FM | 35 | kai.zhangkai@huawei.com | Rel-14 | 69 |  |  |
| 4039 | 1629.1.4 | Performance management for mobile networks that include virtualized network functions | 586d? | 2015-09-16 A | 2017-12-12 A | 100% | finish no earlier than 2017-12-12 | S5 | 4688h | 4688h | OAM14-MAMO_VNF-PM | 35 | joey.chou@intel.com | Rel-14 | 69 |  |  |
| 4040 | 1629.1.5 | Lifecycle management for mobile networks that include virtualized network functions | 454d? | 2015-09-16 A | 2017-06-09 A | 100% | finish no earlier than 2017-06-09 | S5 | 3632h | 3632h | OAM14-MAMO_VNF-LCM | 35 | anatoly.andrianov@nokia.com | Rel-14 | 69 |  |  |
| 4041 | 1629.2 | Filtering of PM measurements and data volume | 199d? | 2016-03-01 A | 2016-12-01 A | 100% | start no earlier than 2016-03-01 | S5 | 1592h | 1592h | OAM14-FILMEAS | 36 | robert.petersen@ericsson.com | Rel-14 | 71 |  |  |
| 4042 | 1629.3 | Study on OAM support for Licensed Shared Access (LSA) | 262d? | 2015-03-12 A | 2016-03-11 A | 100% | finish no earlier than 2016-03-11 | S5 | 2096h | 2096h | FS_OAM_LSA | 34 | anatoly<dot>andrianov<at>nokia<dot>com | Rel-14 | 67 |  |  |
| 4043 | 1629.4 | OAM support for Licensed Shared Access (LSA) | 262d? | 2016-06-13 A | 2017-06-12 A | 100% | start no earlier than 2016-06-13 | S5 | 2096h | 2096h | OAM14-LSA | 37 |  | Rel-14 | 72 |  |  |
| 4044 | 1630 | Development of super-wideband and fullband P.835 | 524d? | 2015-06-16 A | 2017-06-15 A | 100% | finish no earlier than 2017-06-15 | S4 | 4192h | 4192h | DESUDAPS | 35 | sisabelle@audience.com | Rel-14 | 68 | SP-170346 |  |
| 4045 | 1631 | Enhancing Location Capabilities for Indoor and Outdoor Emergency Communications | 200d? | 2015-03-11 A | 2015-12-15 A | 100% | finish no earlier than 2015-12-15 | S1 | 1600h | 1600h | ELIOT | 34 | Gregory.schumacher@sprint.com | Rel-14 | 67 | SP-170553 |  |
| 4046 | 1632 | Enhancements to Domain Selection between VoLTE and CDMA CS | 69d? | 2015-03-11 A | 2015-06-15 A | 100% | finish no earlier than 2015-06-15 | S1 | 552h | 552h | eDSVCC | 34 | zhuhongmei@gsta.com | Rel-14 | 67 |  |  |
| 4047 | 1633 | Control of Applications when Third party Servers encounter difficulties | 93d? | 2015-05-11 A | 2015-09-16 A | 100% | finish no earlier than 2015-09-16 | S1 | 744h | 744h | CATS | 35 | er-yoshida (at) kddi (dot) com | Rel-14 | 68 | SP-170338 |  |

Notes:
- 4011: WI rapporteur name: Huawei, Peter Schmitt
- 4012: WI rapporteur name: Huawei, Peter Schmitt
- 4013: 6/3/17: 0%->100 / Impacted TSs and TRs: 29.061; 29.153; 29.154; 29.212; 29.214; 29.215; 29.217; 29.219; 29.368; 29.468; 29.213; 29.155; 29.201 / WI rapporteur name: Huawei, Peter Schmitt
- 4014: 2/12/16: 0%->10¦6/3/17: 10%->100 / Impacted TSs and TRs: 29.109; 29.128; 29.172; 29.173; 29.228; 29.229; 29.272; 29.273; 29.283; 29.328; 29.329; 29.336; 29.337; 29.338; 29.343; 29.344; 29.345 / WI rapporteur name: Huawei, Peter Schmitt
- 4015: 6/3/17: 0%->100 / Impacted TSs and TRs: 32.240; 32.251; 32.260; 32.270; 32.271; 32.272; 32.273; 32.274; 32.275; 32.278; 32.280; 32.295; 32.296; 32.297; 32.299 / WI rapporteur name: Nokia
- 4016: Impacted TSs and TRs: 26.114 / WI rapporteur name: Nikolai Leung
- 4017: 19/9/16: WID:SP-160272->SP-160785¦19/9/16: 0%->50¦1/12/16: 50%->80¦1/12/16: FCD:12/16->03/17¦6/3/17: 80%->100 / Impacted TSs and TRs: 26.114; 26.980 / WI rapporteur name: Nikolai Leung
- 4018: To be checked at SA4 if a part can stay in Rel-13 (now Stages 1 and 2 by SA4 in UID660050), while the CT aspects are in Rel-14. 06/16: Name changed from "CT aspects of (or "Enhancements of") MTSI Extension on Multi-stream". Acronym changed from "MMCMH- / WI rapporteur name: Ericsson, Nevenka Biondic
- 4019: Name changed from "CT1 aspects of MTSI Extension on Multi-stream". Acronym changed from "MMCMH-CT"¦13/6/16: WID:CP-160117->CP-160250. FCD: 09/16->03/17¦13/6/16: WID:CP-160250->CP-160369¦2/12/16: 0%->95¦6/3/17: 95%->100 / Impacted TSs and TRs: 24.229 / WI rapporteur name: Ericsson, Nevenka Biondic
- 4020: Acronym changed from "MMCMH-CT"¦13/6/16: WID:CP-160117->CP-160250. FCD: 09/16->03/17¦13/6/16: WID:CP-160250->CP-160369¦6/3/17: 0%->100 / Impacted TSs and TRs: 29.162; 29.213; 29.214; 29.165 / WI rapporteur name: Ericsson, Nevenka Biondic
- 4021: 3/6/16: WID:CP-160117->CP-160250. FCD: 09/16->03/17¦13/6/16: WID:CP-160250->CP-160369¦2/12/16: 0%->35¦6/3/17: 35%->75¦5/6/17: 75%->100 / Impacted TSs and TRs: 23.333; 29.333; 23.334; 29.334; 29.238 / WI rapporteur name: Ericsson, Nevenka Biondic
- 4022: 23/4/20: 50%->90; 9/4/21: RFC 8853 added; / Impacted TSs and TRs: RFC 8853 / WI rapporteur name: Ericsson
- 4023: 23/4/20: 20%->90; 9/4/21: RFC 8851 added; / Impacted TSs and TRs: RFC 8851 / WI rapporteur name: Ericsson
- 4024: Deleted, "replaced" by MMCMH_Enh-CT / WI rapporteur name: Ericsson, Nevenka Biondic
- 4025: Deleted, "replaced" by MMCMH_Enh-CT / Impacted TSs and TRs: 24.229 / WI rapporteur name: Ericsson, Nevenka Biondic
- 4026: Deleted, "replaced" by MMCMH_Enh-CT / Impacted TSs and TRs: 29.162; 29.213; 29.214; 29.165 / WI rapporteur name: Ericsson, Nevenka Biondic
- 4027: Deleted, "replaced" by MMCMH_Enh-CT / Impacted TSs and TRs: 23.333; 29.333; 23.334; 29.334; 29.238 / WI rapporteur name: Ericsson, Nevenka Biondic
- 4028: 7/12/15: 0%->20¦7/3/16: 20%->40¦9/6/16: 40%->100¦28/7/16: 23.214 added; / Impacted TSs and TRs: 23.714; 23.214 / WI rapporteur name: Huawei, Mirko Schramm
- 4029: 7/12/15: 0%->20¦7/3/16: 20%->40¦9/6/16: 40%->100 / Impacted TSs and TRs: 23.714 / WI rapporteur name: Huawei, Mirko Schramm
- 4030: 19/9/16: 0%->80¦1/12/16: 80%->100 / Impacted TSs and TRs: 23.214; 23.002; 23.203; 23.401; 23.402 / WI rapporteur name: Huawei, Mirko Schramm
- 4031: WI rapporteur name: Huawei, Peter Schmitt
- 4032: 8/6/17: 0%->100 / Impacted TSs and TRs: 29.212; 29.213 / WI rapporteur name: Huawei, Peter Schmitt
- 4033: 2/12/16: 0%->40¦6/3/17: 40%->75¦5/6/17: 75%->100 / Impacted TSs and TRs: 23.007; 29.274; 29.281; 29.303; 23.008 / WI rapporteur name: Huawei, Peter Schmitt
- 4035: June2015: WID:SP-150308->SP-150362 / WI rapporteur name: Jinglei Liu, China Mobile
- 4036: June2015: WID:SP-150309->SP-150363. Aug2015: FCD: Mar 2016¦07/09/15: 0%->20. 15/09/15: FCD: Mar 16->Dec 16, moved to Rel-14¦7/12/15: 20%->40¦7/3/16: 40%->50¦7/3/16: WID:SP-150363->SP-160023 ( FCD: Dec16->Sep16)¦13/6/16: 50%->70¦19/9/16: FCD:09/16 / Impacted TSs and TRs: 28.xyz; 32.101 / WI rapporteur name: Jinglei Liu, China Mobile (liujinglei@chinamobile.com)
- 4037: 5/10/15: 28.513¦28.512¦28.511¦28.510 added¦7/12/15: 0%->15¦7/3/16: 15%->20¦13/6/16: 20%->30¦19/9/16: 30%->50¦1/12/16: 50%->60¦1/12/16: FCD:12/16->03/17¦6/3/17: FCD:03/17->06/17¦6/3/17: 60%->80¦7/6/17: 80%->100 / Impacted TSs and TRs: 28.513; 28.512; 28.511; 28.510; 28.621; 28.622; 28.623; 28.704; 28.707 / WI rapporteur name: ZTE Corporation (Zhu Weihong, zhu.weihong@zte.com.cn)
- 4038: 5/10/15: 28.518¦28.517¦28.516¦28.515 added¦7/12/15: 0%->10¦7/3/16: 10%->15¦13/6/16: 15%->50¦13/6/16: WID:SP-150404->SP-160403¦19/9/16: 50%->75¦1/12/16: 75%->80¦1/12/16: 80%->¦1/12/16: FCD:12/16->03/17¦6/3/17: FCD:03/17->06/17¦6/3/17: 80%-> / Impacted TSs and TRs: 28.515; 28.516; 28.517; 28.518; 32.111-1; 32.111-2; 32.111-6 / WI rapporteur name: Huawei (Kai ZHANG, kai.zhangkai@huawei.com)
- 4039: 5/10/15: 28.523¦28.522¦28.521¦28.520 added¦7/12/15: 0%->10¦7/3/16: 10%->15¦13/6/16: 15%->30¦13/6/16: WID:SP-150401->SP-160402¦19/9/16: 30%->60¦1/12/16: FCD:12/16->03/17¦6/3/17: FCD:03/17->06/17¦6/3/17: 60%->75¦7/6/17: 75%->90¦7/6/17: FCD:0 / Impacted TSs and TRs: 28.523; 28.522; 28.521; 28.520; 32.426; 32.409; 32.401 / WI rapporteur name: Intel (Joey Chou, joey.chou@intel.com)
- 4040: 5/10/15: 28.528¦28.527¦28.526¦28.525 added¦7/12/15: 0%->10¦7/3/16: 10%->15¦13/6/16: 15%->25¦13/6/16: WID:SP-150403->SP-160427¦19/9/16: 25%->40¦1/12/16: 40%->60¦1/12/16: FCD:12/16->03/17¦6/3/17: FCD:03/17->06/17¦6/3/17: 60%->80¦7/6/17: 80%- / Impacted TSs and TRs: 28.525; 28.526; 28.527; 28.528; 28.704; 28.705; 28.706; 28.707; 28.708; 28.709 / WI rapporteur name: Anatoly Andrianov (anatoly.andrianov@nokia.com), Nokia Networks
- 4041: 13/6/16: 0%->15¦19/9/16: WID:SP-160022->SP-160610¦19/9/16: 15%->60¦1/12/16: 60%->95¦6/3/17: 95%->100 / Impacted TSs and TRs: New 32.817; 32.425; 32.412; 32.416; 32.130 / WI rapporteur name: Ericsson: Robert Petersen
- 4042: June2015: Compl:0%->15¦07/09/15: 15%->70¦7/12/15: 70%->75¦7/3/16: 75%->100. 22/3/16: FCD: 09/15->03/16. Rel-13->Rel-14¦28/7/16: 28.303 added¦28/7/16: 28.302 added¦28/7/16: 28.301 added¦28/7/16: 33.250 added¦28/7/16: added; / Impacted TSs and TRs: 28.303; 28.302; 28.301; / WI rapporteur name: Nokia Networks, Anatoly Andrianov
- 4043: 28/7/16: 28.303 added¦28/7/16: 28.302 added¦28/7/16: 28.301 added¦19/9/16: 0%->20¦1/12/16: 20%->30¦6/3/17: 30%->40¦7/6/17: 40%->100 / Impacted TSs and TRs: 32.101; 28.303; 28.302; 28.301 / WI rapporteur name: Nokia: Olaf Pollakowski
- 4044: 06/15: FCD corrected to Dec.15¦Aug2015: 0%->5¦07/09/15: 5%->20, FCD: 12/15->06.16¦7/12/15: 20%->40, MOVED TO REL-14¦7/3/16: 40%->50. 15/4/16: 6/16->12/16¦11/6/16: 50%->60¦19/9/16: 60%->70, fcd: 12/16->06/17¦1/12/16: 70%->75¦6/3/17: 75%->80¦7/6 / Impacted TSs and TRs: 26.131; 26.132 / WI rapporteur name: Scott Isabelle (Knowles, Inc.)
- 4045: 1/4/15: rapporteur added, Impacted TS added¦June2015: Compl:0%->25¦07/09/15: 25%->80¦2/3/16: 80%->100 / Impacted TSs and TRs: 22.101; 22.071 / WI rapporteur name: Greg Schumacher
- 4046: 1/4/15: rapporteur added, Impacted TS added¦June2015: Compl:0%->100 / Impacted TSs and TRs: 22.101 / WI rapporteur name: China Telecom, Hongmei Zhu
- 4047: 07/09/15: 0%->100 / Impacted TSs and TRs: 22.011 / WI rapporteur name: Eriko Yoshida, KDDI

| ID | WBS | Task | Duration | Start | Finish | Complete | Constraint | Resources | Work | Actual work | Acronym | PCG approved | WI rapporteur name | WI rapporteur e-mail | Release | TSG approved | Status Report |
| --- | --- | --- | --- | --- | --- | --- | --- | --- | --- | --- | --- | --- | --- | --- | --- | --- | --- |
| 4048 | 1634 | **PS Data Off Services** | 599.38d? | 2015-11-09 A | 2017-06-09 A | 100% |  |  | 5416h | 5416h | PS_Data_Off | 36 | Orange, Bruno Tossou | bruno.tossou@orange.com | Rel-14 | 70 | SP-170708 |
| 4049 | 1634.1 | PS Data Off Services | 92d? | 2015-11-09 A | 2016-03-15 A | 100% | finish no earlier than 2016-03-15 | S1 | 736h | 736h | PS_Data_Off | 36 | Orange, Bruno Tossou | bruno.tossou@orange.com | Rel-14 | 70 |  |
| 4050 | 1634.2 | Study on Stage 2 of PS Data off function | 131d? | 2016-06-17 A | 2016-12-15 A | 100% | finish no earlier than 2016-12-15 | S2 | 1048h | 1048h | FS_PS_DATA_OFF | 37 | Orange, david <dot> cailliere <at> orange <dot> com | david <dot> cailliere <at> orange <dot> com | Rel-14 | 72 |  |
| 4051 | 1634.3 | Stage 2 of PS Data Off | 21d? | 2016-11-17 A | 2016-12-15 A | 100% | finish no earlier than 2016-12-15 | S2 | 168h | 168h | PS_DATA_OFF | 38 | Christophe Petit (Orange) | kris (dot) petit (at) orange (dot) com | Rel-14 | 74 |  |
| 4052 | 1634.4 | **Stage 3 of PS Data Off** | 107.75d? | 2016-12-01 A | 2017-03-14 A | 100% |  | ct | 2368h | 2368h | PS_DATA_OFF-CT | 38 | Herrero Veron, Christian (Huawei) | Christian.Herrero at huawei.com | Rel-14 | 74 |  |
| 4053 | 1634.4.1 | CT1 aspects of PS Data Off | 74d? | 2016-12-01 A | 2017-03-14 A | 100% | finish no earlier than 2017-03-14 | C1 | 592h | 592h | PS_DATA_OFF-CT | 38 | Herrero Veron, Christian (Huawei) | Christian.Herrero at huawei.com | Rel-14 | 74 |  |
| 4054 | 1634.4.2 | CT3 aspects of PS Data Off | 74d? | 2016-12-01 A | 2017-03-14 A | 100% | finish no earlier than 2017-03-14 | C3 | 592h | 592h | PS_DATA_OFF-CT | 38 | Herrero Veron, Christian (Huawei) | Christian.Herrero at huawei.com | Rel-14 | 74 |  |
| 4055 | 1634.4.3 | CT6 aspects of PS Data Off | 74d? | 2016-12-01 A | 2017-03-14 A | 100% | finish no earlier than 2017-03-14 | C6 | 592h | 592h | PS_DATA_OFF-CT | 38 | Herrero Veron, Christian (Huawei) | Christian.Herrero at huawei.com | Rel-14 | 74 |  |
| 4056 | 1634.5 | Charging Aspect for 3GPP PS Data off Function | 137d? | 2016-12-01 A | 2017-06-09 A | 100% | finish no earlier than 2017-06-09 | S5 | 1096h | 1096h | PS_DATA_OFF-CH | 38 | Huawei， Chen, Shan | chenshan@huawei.com | Rel-14 | 74 |  |
| 4057 | 1635 | SCC AS Restoration | 208d? | 2016-03-02 A | 2016-12-15 A | 100% | finish no earlier than 2016-12-15 | C4 | 1664h | 1664h | SCCAS_RES | 36 | China Mobile, Hao Zhang, | zhanghao@chinamobile.com | Rel-14 | 71 |  |
| 4058 | 1636 | Paging Policy Enhancements and Procedure | 22d? | 2016-02-01 A | 2016-03-01 A | 100% | finish no earlier than 2016-03-01 | S1 | 176h | 176h | PPEPO_LTE | 36 | China Unicom, Zhuoyun Zhang | zhangzy910@chinaunicom.cn | Rel-14 | 71 | SP-170549 |
| 4059 | 1637 | **Enhancement to Flexible Mobile Service Steering** | 511.38d? | 2015-05-11 A | 2016-09-15 A | 100% |  |  | 1968h | 1968h | eFMSS | 37 | China Mobile, Lu Lu | lulu@chinamobile.com | Rel-14 | 72 |  |
| 4060 | 1637.1 | Study on enhancement to FMSS for Rel 14 | 158d? | 2015-05-11 A | 2015-12-16 A | 100% | finish no earlier than 2015-12-16 | S1 | 1264h | 1264h | FS_eFMSS | 35 | Lu Lu, China Mobile | lulu@chinamobile.com | Rel-14 | 68 |  |
| 4061 | 1637.2 | Stage 1 of Enhancement to Flexible Mobile Service Steering | 22d? | 2016-02-01 A | 2016-03-01 A | 100% | start no earlier than 2016-02-01 | S1 | 176h | 176h | eFMSS | 36 | China Mobile, Lu Lu | lulu@chinamobile.com | Rel-14 | 71 |  |
| 4062 | 1637.3 | Stage 2 of Enhancement to Flexible Mobile Service Steering | 66d? | 2016-06-17 A | 2016-09-15 A | 100% | finish no earlier than 2016-09-15 | S2 | 528h | 528h | eFMSS | 37 | ZTE, Tricci So |  | Rel-14 | 72 |  |
| 4063 | 1638 | **Media Handling Extensions of IMS-based Telepresence** | 285.62d? | 2016-03-01 A | 2016-12-01 A | 100% |  |  | 17512h | 17512h | IMS_TELEP_EXT | 36 | Ozgur Oyman, Intel | ozgur.oyman@intel.com | Rel-14 | 71 | SP-170515 |
| 4064 | 1638.1 | S4 aspects of Media Handling Extensions of IMS-based Telepresence | 199d? | 2016-03-01 A | 2016-12-01 A | 100% | finish no earlier than 2016-12-01 | S4 | 1592h | 1592h | IMS_TELEP_EXT | 37 | Ozgur Oyman, Intel | ozgur.oyman@intel.com | Rel-14 | 72 |  |
| 4065 | 1638.2 | **(IETF) Other IETF aspects of IMS_TELEP_EXT** | 285.62d? | 2016-03-01 A | 2016-12-01 A | 100% |  | S4-IETF | 15920h | 15920h | IMS_TELEP_EXT | 37 | Ozgur Oyman, Intel | ozgur.oyman@intel.com | Rel-14 | 72 |  |
| 4066 | 1638.2.1 | (IETF) RTP Payload Format for Flexible Forward Error Correction (FEC) (draft-ietf-payload-flexible-fec-scheme) --> RFC 8627 | 199d? | 2016-03-01 A | 2016-12-01 A | 100% | start no earlier than 2016-03-01 | S4-IETF | 1592h | 1592h | IMS_TELEP_EXT | 41 | Ozgur Oyman, Intel | ozgur.oyman@intel.com | Rel-14 | 80 |  |
| 4067 | 1638.2.2 | (IETF) Framework for Telepresence Multi-Streams (draft-ietf-clue-framework) | 199d? | 2016-03-01 A | 2016-12-01 A | 100% | start no earlier than 2016-03-01 | S4-IETF | 1592h | 1592h | IMS_TELEP_EXT | 41 | Ozgur Oyman, Intel | ozgur.oyman@intel.com | Rel-14 | 80 |  |
| 4068 | 1638.2.3 | (IETF) CLUE Protocol data channel (draft-ietf-clue-datachannel) | 199d? | 2016-03-01 A | 2016-12-01 A | 100% | start no earlier than 2016-03-01 | S4-IETF | 1592h | 1592h | IMS_TELEP_EXT | 41 | Ozgur Oyman, Intel | ozgur.oyman@intel.com | Rel-14 | 80 |  |
| 4069 | 1638.2.4 | (IETF) Session Signaling for Controlling Multiple Streams for Telepresence (CLUE) (draft-ietf-clue-signaling) | 199d? | 2016-03-01 A | 2016-12-01 A | 100% | start no earlier than 2016-03-01 | S4-IETF | 1592h | 1592h | IMS_TELEP_EXT | 41 | Ozgur Oyman, Intel | ozgur.oyman@intel.com | Rel-14 | 80 |  |
| 4070 | 1638.2.5 | (IETF) An XML Schema for the CLUE data model (draft-ietf-clue-data-model-schema) | 199d? | 2016-03-01 A | 2016-12-01 A | 100% | start no earlier than 2016-03-01 | S4-IETF | 1592h | 1592h | IMS_TELEP_EXT | 41 | Ozgur Oyman, Intel | ozgur.oyman@intel.com | Rel-14 | 80 |  |
| 4071 | 1638.2.6 | (IETF) Protocol for Controlling Multiple Streams for Telepresence (CLUE) (draft-ietf-clue-protocol) | 199d? | 2016-03-01 A | 2016-12-01 A | 100% | start no earlier than 2016-03-01 | S4-IETF | 1592h | 1592h | IMS_TELEP_EXT | 41 | Ozgur Oyman, Intel | ozgur.oyman@intel.com | Rel-14 | 80 |  |
| 4072 | 1638.2.7 | (IETF) Mapping RTP streams to CLUE Media Captures (draft-ietf-clue-rtp-mapping) | 199d? | 2016-03-01 A | 2016-12-01 A | 100% | start no earlier than 2016-03-01 | S4-IETF | 1592h | 1592h | IMS_TELEP_EXT | 41 | Ozgur Oyman, Intel | ozgur.oyman@intel.com | Rel-14 | 80 |  |
| 4073 | 1638.2.8 | (IETF) Session Description Protocol (SDP) Offer/Answer Procedures For Stream Control Transmission Protocol (SCTP) over Datagram Transport Layer Security (DTLS) Transport. (draft-ietf-mmusic-sctp-sdp) | 199d? | 2016-03-01 A | 2016-12-01 A | 100% | start no earlier than 2016-03-01 | S4-IETF | 1592h | 1592h | IMS_TELEP_EXT | 41 | Ozgur Oyman, Intel | ozgur.oyman@intel.com | Rel-14 | 80 |  |
| 4074 | 1638.2.9 | (IETF) SDP-based Data Channel Negotiation (draft-ietf-mmusic-data-channel-sdpneg) | 199d? | 2016-03-01 A | 2016-12-01 A | 100% | start no earlier than 2016-03-01 | S4-IETF | 1592h | 1592h | IMS_TELEP_EXT | 41 | Ozgur Oyman, Intel | ozgur.oyman@intel.com | Rel-14 | 80 |  |
| 4075 | 1639 | Improved Streaming QoE Reporting in 3GPP | 273d? | 2016-03-01 A | 2017-03-15 A | 100% | finish no earlier than 2017-03-15 | S4 | 2184h | 2184h | IQoE | 36 | Zhiming Li, Huawei | Lizhiming@huawei.com | Rel-14 | 71 | SP-170521 |
| 4076 | 1640 | New GPRS algorithms for EASE | 67d? | 2016-03-15 A | 2016-06-15 A | 100% | start no earlier than 2016-03-15 | S3 | 536h | 536h | EASE_ALGOs_SA3 | 36 | Tim Evans, Vodafone |  | Rel-14 | 71 |  |

Notes:
- 4048: 2/3/16: 0%->100 / Impacted TSs and TRs: 22.030
- 4049: 2/3/16: 0%->100 / Impacted TSs and TRs: 22.030
- 4050: 28/7/16: 23.702 added¦19/9/16: 0%->60¦1/12/16: FCD:09/16->12/16¦1/12/16: 60%->100 / Impacted TSs and TRs: 23.702
- 4051: 1/12/16: 0%->100 / Impacted TSs and TRs: 23.401; 23.203; 23.060; 23.228; 23.292; 23.221
- 4053: 6/3/17: 0%->95¦5/6/17: 95%->100 / Impacted TSs and TRs: 24.008; 24.301; 27.007; 24.229; 24.368; 24.167
- 4054: 6/3/17: 0%->60¦8/6/17: 60%->100 / Impacted TSs and TRs: 29.212; 29.213
- 4055: 7/3/17: 0%->100 / Impacted TSs and TRs: 31.102; 31.103; 31.111
- 4056: 6/3/17: 0%->70¦6/3/17: FCD:03/17->06/17¦7/6/17: 70%->100 / Impacted TSs and TRs: 32.251; 32.298; 32.299
- 4057: 13/6/16: 0%->100 / Impacted TSs and TRs: 23.380
- 4058: Impacted TSs and TRs: 22.101
- 4059: Impacted TSs and TRs: 22.115; 22.101
- 4060: 7/12/15: 70%->100 / Impacted TSs and TRs: 22.808
- 4061: Impacted TSs and TRs: 22.115; 22.101
- 4062: 19/9/16: 0%->100 / Impacted TSs and TRs: 23.203
- 4063: 11/6/16: 0%->10 / Impacted TSs and TRs: 26.223
- 4064: 11/6/16: 0%->10¦19/9/16: 10%->60¦1/12/16: 60%->100 / Impacted TSs and TRs: 26.223
- 4065: Impacted TSs and TRs: draft-ietf-payload-rtp-h265; -flexible-fec-scheme ; draft-ietf-clue-framework ; -datachannel; -signalling; -data-model-schema; -protocol; -rtp-mapping; draft-ietf-mmusic-sctp-sdp; -data-channel-sdpneg; draft-ietf-tsvwg-sctp-dtls-encaps
- 4066: 23/4/20: 25%->100
- 4067: 23/4/20: 25%->90; 9/4/21: RFC 8845 added; / Impacted TSs and TRs: RFC 8845
- 4068: 23/4/20: 25%->90; 9/4/21: RFC 8850 added; / Impacted TSs and TRs: RFC 8850
- 4069: 23/4/20: 25%->90; 9/4/21: RFC 8848 added; / Impacted TSs and TRs: RFC 8848
- 4070: 23/4/20: 25%->90; 9/4/21: RFC 8846 added; / Impacted TSs and TRs: RFC 8846
- 4071: 23/4/20: 25%->90; 9/4/21: RFC 8847 added; / Impacted TSs and TRs: RFC 8847
- 4072: 23/4/20: 25%->90; 9/4/21: RFC 8849 added; / Impacted TSs and TRs: RFC 8849
- 4073: 23/4/20: 25%->90; 9/4/21: RFC 8841 added; / Impacted TSs and TRs: RFC 8841
- 4074: 23/4/20: 25%->90; 9/4/21: RFC 8864 added; / Impacted TSs and TRs: RFC 8864
- 4075: 11/6/16: 0%->10¦19/9/16: 10%->55. FDC: 12/16->03/17¦1/12/16: 55%->65¦6/3/17: 65%->100 / Impacted TSs and TRs: New 26.909; 26.247; 26.346
- 4076: Discussion whether it should be Rel-13. To be concluded at SA#72.¦13/6/16: 0%->60¦1/12/16: 60%->70¦6/3/17: 70%->100 / Impacted TSs and TRs: 55.241; 55.242; 55.243; 55.251; 55.252; 55.253

| ID | WBS | Task | Duration | Start | Finish | Complete | Constraint | Resources | Work | Actual work | Acronym | PCG approved | Release | TSG approved | Status Report | WI rapporteur name | WI rapporteur e-mail |
| --- | --- | --- | --- | --- | --- | --- | --- | --- | --- | --- | --- | --- | --- | --- | --- | --- | --- |
| 4077 | 1641 | **S8 Home Routing Architecture for VoLTE** | 748.62d? | 2015-06-18 A | 2017-06-09 A | 100% |  |  | 7832h | 7832h | V8 | 36 | Rel-14 | 71 | SP-170522 |  |  |
| 4078 | 1641.1 | Study on S8 Home Routing Architecture | 191d? | 2015-06-18 A | 2016-03-10 A | 100% | finish no earlier than 2016-03-10 | S2 | 1528h | 1528h | FS_V8 | 35 | Rel-14 | 68 |  | Motohiro ABE | motohiro(dot)abe(dot)cu(at) nttdocomo (dot) com |
| 4079 | 1641.2 | Study on LI in S8 Home Routing Architecture for VoLTE | 197d? | 2015-09-17 A | 2016-06-17 A | 100% | finish no earlier than 2016-06-17 | S3 | 1576h | 1576h | FS_LIV8 | 35 | Rel-14 | 69 |  | Greg Schumacher (SPRINT) Gregory | Schumacher@sprint.com |
| 4080 | 1641.3 | S8 Home Routing Architecture for VoLTE | 135d? | 2016-06-13 A | 2016-12-15 A | 100% | finish no earlier than 2016-12-15 | S2 | 1080h | 1080h | V8 | 37 | Rel-14 | 72 |  | Motohiro ABE | motohiro(dot)abe(dot)cu(at) nttdocomo (dot) com |
| 4081 | 1641.4 | **CT Aspects of V8** | 94.25d? | 2016-09-16 A | 2016-12-15 A | 100% |  | ct | 1560h | 1560h | V8-CT | 37 | Rel-14 | 73 |  | Tsuyoshi Takakura (NTT DOCOMO) | tsuyoshi.takakura.ey@s1.nttdocomo.com |
| 4082 | 1641.4.1 | CT1 Aspects of V8 | 65d? | 2016-09-16 A | 2016-12-15 A | 100% | finish no earlier than 2016-12-15 | C1 | 520h | 520h | V8-CT | 37 | Rel-14 | 73 |  | Tsuyoshi Takakura (NTT DOCOMO) | tsuyoshi.takakura.ey@s1.nttdocomo.com |
| 4083 | 1641.4.2 | CT3 Aspects of V8 | 65d? | 2016-09-16 A | 2016-12-15 A | 100% | finish no earlier than 2016-12-15 | C3 | 520h | 520h | V8-CT | 37 | Rel-14 | 73 |  | Tsuyoshi Takakura (NTT DOCOMO) | tsuyoshi.takakura.ey@s1.nttdocomo.com |
| 4084 | 1641.5 | Charging Aspects of S8 Home Routing Architecture for VoLTE | 261d? | 2016-06-13 A | 2017-06-09 A | 100% | finish no earlier than 2017-06-09 | S5 | 2088h | 2088h | CH14-V8 | 37 | Rel-14 | 72 |  | Chen, Ai (China Mobile) | chenai(at) chinamobile (dot) com |
| 4085 | 1642 | **Improvements of awareness of user location change** | 654.38d? | 2015-09-17 A | 2017-06-09 A | 100% |  |  | 5256h | 5256h | AULC | 37 | Rel-14 | 72 | SP-170524 | Yang Xu | xuyang49@chinaunicom.cn |
| 4086 | 1642.1 | Study on improvement of awareness of user location change | 197d? | 2015-09-17 A | 2016-06-17 A | 100% | finish no earlier than 2016-06-17 | S2 | 1576h | 1576h | FS_AULC | 35 | Rel-14 | 69 |  | Yang Xu | xuyang49@chinaunicom.cn |
| 4087 | 1642.2 | Improvements of awareness of user location change | 75d? | 2016-06-06 A | 2016-09-15 A | 100% | finish no earlier than 2016-09-15 | S2 | 600h | 600h | AULC | 37 | Rel-14 | 72 |  | Yang Xu | xuyang49@chinaunicom.cn |
| 4088 | 1642.3 | **CT Aspect of AULC** | 94.25d? | 2016-09-16 A | 2016-12-15 A | 100% |  | ct | 1560h | 1560h | AULC-CT | 37 | Rel-14 | 73 |  | Huawei, Wu Yizhuang | wuyizhuang@huawei.com |
| 4089 | 1642.3.1 | CT3 Aspect of AULC | 65d? | 2016-09-16 A | 2016-12-15 A | 100% | finish no earlier than 2016-12-15 | C3 | 520h | 520h | AULC-CT | 37 | Rel-14 | 73 |  | Huawei, Wu Yizhuang | wuyizhuang@huawei.com |
| 4090 | 1642.3.2 | CT4 Aspect of AULC | 65d? | 2016-09-16 A | 2016-12-15 A | 100% | finish no earlier than 2016-12-15 | C4 | 520h | 520h | AULC-CT | 37 | Rel-14 | 73 |  | Huawei, Wu Yizhuang | wuyizhuang@huawei.com |
| 4091 | 1642.4 | Charging Aspects of Improvements of AULC | 190d? | 2016-09-19 A | 2017-06-09 A | 100% | finish no earlier than 2017-06-09 | S5 | 1520h | 1520h | AULC-CH | 37 | Rel-14 | 73 |  | Huawei， Chen, Shan | chenshan@huawei.com |
| 4092 | 1643 | **Service Domain Centralization** | 334.38d? | 2015-11-02 A | 2016-09-19 A | 100% |  | S2 | 3896h | 3896h | SeDoC | 37 | Rel-14 | 72 |  | Chris Joul (T-Mobile USA) | chris (dot) joul (at) t (dash) mobile (dot) com |
| 4093 | 1643.1 | Study on Service Domain Centralization | 230d? | 2015-11-02 A | 2016-09-15 A | 100% | finish no earlier than 2016-09-15 | S2 | 1840h | 1840h | FS_SeDoC | 36 | Rel-14 | 70 |  | Chris Joul (T-Mobile USA) | chris (dot) joul (at) t (dash) mobile (dot) com |
| 4094 | 1643.2 | Service Domain Centralization | 25d? | 2016-08-16 A | 2016-09-19 A | 100% | finish no earlier than 2016-09-19 | S2 | 200h | 200h | SeDoC | 37 | Rel-14 | 73 |  | Chris Joul (T-Mobile USA) | chris (dot) joul (at) t (dash) mobile (dot) com |
| 4095 | 1644 | **Sponsored data connectivity improvements** | 424.38d? | 2015-11-02 A | 2016-12-15 A | 100% |  |  | 2880h | 2880h | SDCI | 37 | Rel-14 | 72 | SP-170523 | Yang Xu | xuyang49@chinaunicom.cn |
| 4096 | 1644.1 | Study on sponsored data connectivity improvements | 160d? | 2015-11-02 A | 2016-06-10 A | 100% | finish no earlier than 2016-06-10 | S2 | 1280h | 1280h | FS_SDCI | 36 | Rel-14 | 70 |  | Yang Xu | xuyang49@chinaunicom.cn |
| 4097 | 1644.2 | Sponsored data connectivity improvements | 70d? | 2016-06-13 A | 2016-09-15 A | 100% | finish no earlier than 2016-09-15 | S2 | 560h | 560h | SDCI | 37 | Rel-14 | 72 |  | Yang Xu | xuyang49@chinaunicom.cn |
| 4098 | 1644.3 | **CT Aspects of SDCI** | 94.25d? | 2016-09-16 A | 2016-12-15 A | 100% |  | ct | 1040h | 1040h | SDCI-CT | 37 | Rel-14 | 73 |  | China Unicom, Xu, Yang | xuyang49@chinaunicom.cn |
| 4099 | 1644.3.1 | CT3 Aspects of SDCI | 65d? | 2016-09-16 A | 2016-12-15 A | 100% | finish no earlier than 2016-12-15 | C3 | 520h | 520h | SDCI-CT | 37 | Rel-14 | 73 |  | China Unicom, Xu, Yang | xuyang49@chinaunicom.cn |
| 4100 | 1645 | **Stage-3 SAE Protocol Development - Phase 5** | 392.38d? | 2016-03-02 A | 2017-03-15 A | 100% |  | C1 | 8704h | 8704h | SAES5 | 36 | Rel-14 | 71 |  | Interdigital, Aghili, Behrouz | Behrouz.aghili@interdigital.com |
| 4101 | 1645.1 | SAES5 CS Fallback in EPS | 272d? | 2016-03-02 A | 2017-03-15 A | 100% | start no earlier than 2016-03-02 | C1 | 2176h | 2176h | SAES5-CSFB | 36 | Rel-14 | 71 |  | Interdigital, Aghili, Behrouz | Behrouz.aghili@interdigital.com |
| 4102 | 1645.2 | SAES5 for support for non-3GPP accesses | 272d? | 2016-03-02 A | 2017-03-15 A | 100% | start no earlier than 2016-03-02 | C1 | 2176h | 2176h | SAES5-non3GPP | 36 | Rel-14 | 71 |  | Interdigital, Aghili, Behrouz | Behrouz.aghili@interdigital.com |
| 4103 | 1645.3 | SAE Protocol Development (Stage 3) - Phase 5 | 272d? | 2016-03-02 A | 2017-03-15 A | 100% | start no earlier than 2016-03-02 | C1 | 2176h | 2176h | SAES5 | 37 | Rel-14 | 72 |  |  |  |

Notes:
- 4077: Umbrella, created by MCC to group SA2 and SA3 activities
- 4078: 07/09/15: 0%->10¦07/09/15: 10%->100¦7/12/15: 100%->10% (mistake?) then 10%->70, FCD: 12/15-?03/16¦7/3/16: 70%->80¦9/6/16: 80%->100 / Impacted TSs and TRs: New 23.xxx
- 4079: 7/12/15: 0%->45¦28/1/16: 33.827 added¦7/3/16: 45%->55¦19/9/16: 55%->65¦15/12/17: 65%->100 / Impacted TSs and TRs: 33.827
- 4080: 11/6/16: 0%->60¦19/9/16: 60%->95¦1/12/16: FCD:09/16->12/16¦1/12/16: 95%->100 / Impacted TSs and TRs: 23.228; 23.167; 23.203
- 4082: 2/12/16: 40%->100 / Impacted TSs and TRs: 24.229
- 4083: 2/12/16: 40%->100 / Impacted TSs and TRs: 29.212; 29.213; 29.214
- 4084: 19/9/16: 0%->15¦1/12/16: FCD:12/16->03/17¦1/12/16: 15%->60¦1/12/16: WID:SP-160429->SP-160838¦6/3/17: FCD:03/17->06/17¦7/6/17: 60%->100 / Impacted TSs and TRs: 32.240; 32.251; 32.260
- 4086: 7/12/15: 0%->40¦7/3/16: 40%->70¦9/6/16: 70%->100 / Impacted TSs and TRs: 23.710
- 4087: 11/6/16: 0%->10¦19/9/16: 10%->100 / Impacted TSs and TRs: 23.401; 23.203; 23.060
- 4089: 2/12/16: 0%->10¦6/3/17: 10%->100 / Impacted TSs and TRs: 29.212; 29.213
- 4090: 2/12/16: 0%->95¦6/3/17: 95%->100 / Impacted TSs and TRs: 29.274
- 4091: 1/12/16: 0%->40¦6/3/17: 40%->80¦6/3/17: FCD:03/17->06/17¦7/6/17: 80%->100 / Impacted TSs and TRs: TS32.251; TS32.298; TS32.299
- 4093: Comes back from previous release¦28/1/16: 23.719 added¦7/3/16: 0%->30¦7/3/16: WID:SP-150626->SP-1601679/6/16: 30%->70¦11/6/16: WID:SP-160167->SP-160306. FCD: 06/16->09/16¦1/12/16: 70%->100 / Impacted TSs and TRs: 23.719
- 4094: 19/9/16: 0%->100 / Impacted TSs and TRs: 23.292; 23.167
- 4096: 28/1/16: 23.721 added¦7/3/16: 10%->40¦9/6/16: 40%->100 / Impacted TSs and TRs: 23.721
- 4097: 19/9/16: 0%->100 / Impacted TSs and TRs: 23.203; 23.682
- 4098: 6/10/16: 29.251 added; / Impacted TSs and TRs: 29.251
- 4099: 6/10/16: 29.250 added¦2/12/16: 10%->30¦6/3/17: 30%->80¦5/6/17: 80%->100 / Impacted TSs and TRs: 29.212; 29.213; 29.214; 29.201; 29.250
- 4100: Impacted TSs and TRs: 23.122; 24.008; 24.167; 24.229; 24.301; 24.302; 24.303; 24.304; 24.305; 24.312; 29.018; 29.118
- 4101: 11/6/16: 0%->5¦16/9/16: 5%->20¦2/12/16: 20%->70¦6/3/17: 70%->100 / Impacted TSs and TRs: 23.122; 24.008; 24.167; 24.229; 24.301; 24.302; 24.303; 24.304; 24.305; 24.312; 29.018; 29.118
- 4102: 11/6/16: 0%->15¦16/9/16: 15%->20¦2/12/16: 20%->85¦6/3/17: 85%->100 / Impacted TSs and TRs: 23.122; 24.008; 24.167; 24.229; 24.301; 24.302; 24.303; 24.304; 24.305; 24.312; 29.018; 29.118
- 4103: Added following CT1's chair e-mail 14/06/16¦16/9/16: 0%->20¦2/12/16: 20%->85¦6/3/17: 85%->100

| ID | WBS | Task | Duration | Start | Finish | Complete | Constraint | Resources | Work | Actual work | Acronym | PCG approved | WI rapporteur name | WI rapporteur e-mail | Release | TSG approved | Status Report |
| --- | --- | --- | --- | --- | --- | --- | --- | --- | --- | --- | --- | --- | --- | --- | --- | --- | --- |
| 4104 | 1646 | **Group based enhancements in the network capability exposure functions** | 425.38d? | 2015-11-02 A | 2016-12-16 A | 100% |  | S2 | 4752h | 4752h | GENCEF | 36 | Samsung, Sung Hwan Won | sunghwan.won@samsung.com | Rel-14 | 70 | SP-170517 |
| 4105 | 1646.1 | Study on group based enhancements in the network capability exposure functions | 160d? | 2015-11-02 A | 2016-06-10 A | 100% | start no earlier than 2015-11-02 | S2 | 1280h | 1280h | FS_GENCEF | 36 | Samsung, Sung Hwan Won | sunghwan.won@samsung.com | Rel-14 | 70 |  |
| 4106 | 1646.2 | Group based enhancements in the network capability exposure functions | 138d? | 2016-06-09 A | 2016-12-16 A | 100% | finish no earlier than 2016-12-16 | S2 | 1104h | 1104h | GENCEF | 37 | Samsung, Sunghoon Kim | s.hun.kim@samsung.com | Rel-14 | 72 |  |
| 4107 | 1647 | **Robust Call Setup for VoLTE subscriber in LTE** | 1085.12d? | 2015-11-02 A | 2018-09-14 A | 100% |  |  | 11776h | 11776h | RobVoLTE | 37 |  |  | Rel-14 | 72 |  |
| 4108 | 1647.1 | Study on Robust Call Setup for VoLTE subscriber in LTE | 160d? | 2015-11-02 A | 2016-06-10 A | 100% | start no earlier than 2015-11-02 | S2 | 1280h | 1280h | FS_RobVoLTE | 36 | Xiaobo Wu, Huawei | wuxiaobo@ huawei.com | Rel-14 | 70 |  |
| 4109 | 1647.2 | Robust Call Setup for VoLTE subscriber in LTE | 66d? | 2016-06-17 A | 2016-09-15 A | 100% | finish no earlier than 2016-09-15 | S2 | 528h | 528h | RobVoLTE | 37 | Xiaobo Wu, Huawei | wuxiaobo@ huawei.com | Rel-14 | 72 |  |
| 4110 | 1647.3 | CT Aspects of RobVoLTE | 130d? | 2016-09-16 A | 2017-03-16 A | 100% | finish no earlier than 2017-03-16 | C1 | 1040h | 1040h | RobVoLTE-CT | 37 | PATEL, Milan | Milan.Patel@huawei.com | Rel-14 | 73 |  |
| 4111 | 1647.4 | **Voice and Video Enhancement for LTE** | 756d? | 2016-09-15 A | 2018-09-14 A | 100% |  | R2 | 7832h | 7832h | LTE_VoLTE_ViLTE_enh | 37 | CMCC |  | Rel-14 | 73 |  |
| 4112 | 1647.4.1 | Core part: Voice and Video Enhancement for LTE | 130d? | 2016-09-15 A | 2017-03-15 A | 100% | finish no earlier than 2017-03-15 | R2 | 1040h | 1040h | LTE_VoLTE_ViLTE_enh-Core | 37 | CMCC |  | Rel-14 | 73 | RP-170323 |
| 4113 | 1647.4.2 | UE Conformance Test Aspects –Voice and Video Enhancement for LTE | 327d? | 2017-06-15 A | 2018-09-14 A | 100% | finish no earlier than 2018-09-15 | R5 | 2616h | 2616h | LTE_VoLTE_ViLTE_enh-UEConTest | 39 | CATT |  | Rel-14 | 76 |  |
| 4114 | 1647.5 | RAN-Assisted Codec Adaptation in MTSI | 137d? | 2016-12-01 A | 2017-06-09 A | 100% | finish no earlier than 2017-06-09 | S4 | 1096h | 1096h | LTE_VoLTE_ViLTE_enh-S4 | 38 | Ozgur Oyman, Intel | ozgur.oyman@intel.com | Rel-14 | 74 | SP-170516 |
| 4115 | 1648 | Extension of UE Delay test methods and requirements | 261d? | 2016-06-13 A | 2017-06-09 A | 100% | finish no earlier than 2017-06-09 | S4 | 2088h | 2088h | EXT_UED | 37 | Stéphane Ragot, ORANGE | stephane.ragot@orange.com | Rel-14 | 72 | SP-170345 |
| 4116 | 1649 | **Improved operator control using new UE configuration parameters** | 285.62d? | 2016-06-13 A | 2017-03-15 A | 100% |  |  | 3184h | 3184h | IOC_UE_conf | 37 | Sedlacek, Ivo | ivo.sedlacek@ericsson.com | Rel-14 | 72 | CP-171176 |
| 4117 | 1649.1 | CT1 aspects of IOC_UE_conf | 199d? | 2016-06-13 A | 2017-03-15 A | 100% | finish no earlier than 2017-03-15 | C1 | 1592h | 1592h | IOC_UE_conf | 37 | Sedlacek, Ivo | ivo.sedlacek@ericsson.com | Rel-14 | 72 |  |
| 4118 | 1649.2 | CT6 aspects of IOC_UE_conf | 199d? | 2016-06-13 A | 2017-03-15 A | 100% | finish no earlier than 2017-03-15 | C6 | 1592h | 1592h | IOC_UE_conf | 37 | Adrian Buckley | abuckley@blackberry.com | Rel-14 | 72 |  |
| 4119 | 1650 | Shared Subscription Data Update | 135d? | 2016-06-13 A | 2016-12-15 A | 100% | finish no earlier than 2016-12-15 | C4 | 1080h | 1080h | eSDU | 37 | Nokia, Ulrich Wiehe | ulrich.wiehe@nokia.com | Rel-14 | 72 | CP-171050 |
| 4120 | 1651 | **Rel-14 Charging** | 482.38d? | 2016-03-01 A | 2017-06-09 A | 100% |  | S5 | 8544h | 8544h | CH14 | 36 |  |  | Rel-14 | 71 |  |
| 4121 | 1651.1 | Resource Optimization for PS Domain Online | 335d | 2016-03-01 A | 2017-06-09 A | 100% | finish no earlier than 2017-06-09 | S5 | 2680h | 2680h | CH14-ROPOCH | 36 | Shrader, David(Ericsson) | david.shrader@ericsson.com | Rel-14 | 71 |  |
| 4122 | 1651.2 | Charging for SMS via T4 | 137d? | 2016-12-01 A | 2017-06-09 A | 100% | finish no earlier than 2017-06-09 | S5 | 1096h | 1096h | CH14-SMST4 | 38 | Nokia | Maryse <dot> Gardella <at> Nokia <dot> com | Rel-14 | 74 |  |
| 4123 | 1651.3 | Charging Aspects of Enhanced Proximity-based Services | 261d? | 2016-06-13 A | 2017-06-09 A | 100% | finish no earlier than 2017-06-09 | S5 | 2088h | 2088h | CH14-ProSe | 37 | Chen, Shan | chenshan@huawei.com | Rel-14 | 72 | SP-170408 |
| 4124 | 1652 | **Determination of Completeness of Charging Information in IMS** | 374.62d? | 2016-06-13 A | 2017-06-09 A | 100% |  | S5 | 5952h | 5952h | CH14-DCCII | 37 | Jesske, Roland (Deutsche Telekom) |  | Rel-14 | 72 |  |
| 4125 | 1652.1 | Determination of Completeness of Charging Information in IMS | 261d? | 2016-06-13 A | 2017-06-09 A | 100% | finish no earlier than 2017-06-09 | S5 | 2088h | 2088h | CH14-DCCII | 37 | Jesske, Roland (Deutsche Telekom) |  | Rel-14 | 72 | SP-170344 |
| 4126 | 1652.2 | **CT Aspects of Determination of Completeness of Charging Information in IMS** | 107.75d? | 2016-12-01 A | 2017-03-14 A | 100% |  | ct | 1776h | 1776h | CH14-DCCII-CT | 38 | Michael KREIPL, Deutsche Telekom | michael(dot)kreipl(at)telekom(dot)de | Rel-14 | 74 | CP-171048 |
| 4127 | 1652.2.1 | CT1 Aspects of Determination of Completeness of Charging Information in IMS | 74d? | 2016-12-01 A | 2017-03-14 A | 100% | finish no earlier than 2017-03-14 | C1 | 592h | 592h | CH14-DCCII-CT | 38 | Michael KREIPL, Deutsche Telekom | michael(dot)kreipl(at)telekom(dot)de | Rel-14 | 74 |  |
| 4128 | 1652.2.2 | CT3 Aspects of Determination of Completeness of Charging Information in IMS | 74d? | 2016-12-01 A | 2017-03-14 A | 100% | finish no earlier than 2017-03-14 | C3 | 592h | 592h | CH14-DCCII-CT | 38 | Michael KREIPL, Deutsche Telekom | michael(dot)kreipl(at)telekom(dot)de | Rel-14 | 74 |  |

Notes:
- 4105: 28/1/16: 23.773 added¦28/1/16: 23.742 added¦7/3/16: 0%->10¦9/6/16: 10%->100 / Impacted TSs and TRs: 23.xyz; 23.773; 23.742
- 4106: 19/9/16: 0%->90¦1/12/16: FCD:09/16->12/16¦1/12/16: 90%->100 / Impacted TSs and TRs: 23.682
- 4108: 28/1/16: 23.750 added¦7/3/16: 0%->20¦9/6/16: 20%->100 / Impacted TSs and TRs: 23.8xx; 23.750
- 4109: 19/9/16: 0%->100. 1/12/16: UID changed: 720085 -> 720301 (720085 was also used for RP-161181) / Impacted TSs and TRs: 23.228; 23.237
- 4110: 2/12/16: 0%->80¦6/3/17: 80%->100 / Impacted TSs and TRs: 24.229; 24.292
- 4112: ¦20/12/16: Compl:0%->80%¦21/3/17: Compl:80%->100%¦21/3/17: Stat Rep: ->RP-170323
- 4113: ¦19/9/17: Compl:0%->20%¦8/1/18: Compl:20%->60%¦ 27/3/18: Compl:60 ;; 11/10/20: 95%->100
- 4114: 6/3/17: 0%->65¦6/3/17: FCD:03/17->06/17¦7/6/17: 65%->100
- 4115: 19/9/16: WID:SP-160271->SP-160600¦19/9/16: 0%->20¦1/12/16: 20%->30¦14/12/16: 30%->50¦6/3/17: 50%->60¦6/3/17: FCD:03/17->06/17¦7/6/17: 60%->100 / Impacted TSs and TRs: 26.954; 26.131; 26.132
- 4116: 11/6/16: 0%->10¦17/10/16: WID:CP-160296->CP-160374¦5/12/16: WID:CP-160374->CP-160828 / Impacted TSs and TRs: 24.167; 24.229; 24.301; 24.302; 24.312; 24.341; 24.368; 24.607; 24.623; 24.XXX; 24.YYY
- 4117: 11/6/16: 0%->10¦16/9/16: 10%->20¦17/10/16: WID:CP-160296->CP-160374¦2/12/16: 20%->75¦6/3/17: 75%->100 / Impacted TSs and TRs: 24.167; 24.229; 24.301; 24.302; 24.312; 24.341; 24.368; 24.607; 24.623; 24.275
- 4118: 11/6/16: 0%->10¦14/12/16: 0%->15¦7/3/17: 15%->85¦5/6/17: 85%->100 / Impacted TSs and TRs: 31.102; 31.103
- 4119: 13/6/16: 0%->25¦2/12/16: 25%->100¦5/12/16: WID:CP-160243->CP-160644 / Impacted TSs and TRs: 29.272; 29.002; 29.305; 29.230
- 4120: Umbrella Feature
- 4121: 13/6/16: 0%->10. FCD:09/16->03/17¦19/9/16: FCD: 09/16->03/17¦19/9/16: 10%->20¦1/12/16: 20%->50¦6/3/17: 50%->80¦6/3/17: FCD:03/17->06/20¦7/6/17: 80%->100 / Impacted TSs and TRs: 32.251; 32.299
- 4122: 6/3/17: 0%->20¦6/3/17: FCD:03/17->06/17¦7/6/17: 20%->100 / Impacted TSs and TRs: 32.274; 32.250 ; 32.298; 32.299
- 4123: 19/9/16: 0%->40¦1/12/16: 40%->60¦6/3/17: FCD:03/17->06/17¦6/3/17: 60%->80¦7/6/17: 80%->100 / Impacted TSs and TRs: 32.240; 32.251; 32.277; 32.298; 32.299
- 4124: 19/9/16: 0%->10 / Impacted TSs and TRs: 32.240; 32.260; 32.298; 32.299
- 4125: 19/9/16: 0%->10¦6/3/17: FCD:03/17->06/17¦7/6/17: 10%->100 / Impacted TSs and TRs: 32.240; 32.260; 32.298; 32.299
- 4127: 2/12/16: 0%->10¦6/3/17: 10%->35¦5/6/17: 35%->100 / Impacted TSs and TRs: 24.229
- 4128: 8/6/17: 0%->100 / Impacted TSs and TRs: 29.165

| ID | WBS | Task | Duration | Start | Finish | Complete | Total slack | Constraint | Resources | Work | Actual work | Acronym | PCG approved | WI rapporteur name | Release | TSG approved | Status Report | Impacted TSs and TRs |
| --- | --- | --- | --- | --- | --- | --- | --- | --- | --- | --- | --- | --- | --- | --- | --- | --- | --- | --- |
| 4129 | 1653 | **Enhanced LAA for LTE** | 1040.62d? | 2015-12-15 A | 2018-09-14 A | 100% |  |  |  | 10480h | 10480h | LTE_eLAA | 36 | Ericsson | Rel-14 | 70 |  |  |
| 4130 | 1653.1 | Core part: Enhanced LAA for LTE | 328d? | 2015-12-15 A | 2017-03-15 A | 100% |  | finish no earlier than 2017-03-15 | R1 | 2624h | 2624h | LTE_eLAA-Core | 36 | Ericsson | Rel-14 | 70 | RP-170269 |  |
| 4131 | 1653.2 | Perf. part: Enhanced LAA for LTE | 460d? | 2015-12-15 A | 2017-09-15 A | 100% |  | finish no earlier than 2017-09-15 | R4 | 3680h | 3680h | LTE_eLAA-Perf | 36 | Ericsson | Rel-14 | 70 |  |  |
| 4132 | 1653.3 | UE Conformance Test Aspects - Enhanced LAA for LTE | 522d? | 2016-09-15 A | 2018-09-14 A | 100% |  | finish no earlier than 2018-09-15 | R5 | 4176h | 4176h | LTE_eLAA-UEConTest | 37 | Intel | Rel-14 | 73 |  |  |
| 4133 | 1654 | **RRC optimization for UMTS** | 285.62d? | 2015-12-15 A | 2016-09-15 A | 100% |  |  | R2 | 3184h | 3184h | UTRA_RRCopt | 36 | Ericsson | Rel-14 | 70 |  |  |
| 4134 | 1654.1 | Core part: RRC optimization for UMTS | 199d? | 2015-12-15 A | 2016-09-15 A | 100% |  | finish no earlier than 2016-09-15 | R2 | 1592h | 1592h | UTRA_RRCopt-Core | 36 | Ericsson | Rel-14 | 70 | RP-172758 |  |
| 4135 | 1655 | **DTX/DRX enhancements in CELL_FACH** | 379.88d? | 2015-12-15 A | 2016-12-15 A | 100% |  |  | R2 | 4224h | 4224h | FACH_DTXDRX | 36 | Huawei | Rel-14 | 70 |  |  |
| 4136 | 1655.1 | Core part: DTX/DRX enhancements in CELL_FACH | 264d? | 2015-12-15 A | 2016-12-15 A | 100% |  | finish no earlier than 2016-12-15 | R2 | 2112h | 2112h | FACH_DTXDRX-Core | 36 | Huawei | Rel-14 | 70 | RP-162132 |  |
| 4137 | 1656 | **AWS-3/4 Band for LTE** | 379.88d? | 2015-12-15 A | 2016-12-15 A | 100% |  |  |  | 2640h | 2640h | LTE_AWS_3_4 | 36 | Dish Network | Rel-14 | 70 |  |  |
| 4138 | 1656.1 | Core part: AWS-3/4 Band for LTE | 132d? | 2015-12-15 A | 2016-06-15 A | 100% |  | finish no earlier than 2016-09-15 | R4 | 1056h | 1056h | LTE_AWS_3_4-Core | 36 | Dish Network | Rel-14 | 70 |  | 36.749 |
| 4139 | 1656.2 | Perf. part: AWS-3/4 Band for LTE | 132d? | 2015-12-15 A | 2016-06-15 A | 100% |  | finish no earlier than 2016-09-15 | R4 | 1056h | 1056h | LTE_AWS_3_4-Perf | 36 | Dish Network | Rel-14 | 70 |  |  |
| 4140 | 1656.3 | UE Conformance Test Aspects – AWS-3/4 Band for LTE (Band 70) | 66d? | 2016-09-15 A | 2016-12-15 A | 100% |  | finish no earlier than 2017-03-15 | R5 | 528h | 528h | LTE_AWS_3_4-UEConTest | 37 | Dish Network | Rel-14 | 73 |  |  |
| 4141 | 1657 | **LTE FDD in the Bands 1980-2010 MHz and 2170-2200MHz for Region 3** | 1d? | 2015-12-15 | 2015-12-15 |  | 41607.8d |  | R4 | 16h |  | LTE_1980_2170_REG3 | 36 | KT Corp. | Rel-14 | 70 |  |  |
| 4142 | 1657.1 | Core part: LTE FDD in the Bands 1980-2010 MHz and 2170-2200MHz for Region 3 | 1d? | 2015-12-15 | 2015-12-15 |  | 41607.8d | finish no earlier than 2015-12-15 | R4 | 8h |  | LTE_1980_2170_REG3-Core | 36 | KT Corp. | Rel-14 | 70 |  |  |
| 4143 | 1658 | **Addition of 1.4 and 3 MHz Channel Bandwidth to E-UTRA operating band 65 for CGC (Complementary Ground Component) operations in Region 1** | 284.75d? | 2016-12-15 A | 2017-09-15 A | 100% |  |  | R4 | 2632h | 2632h | LTE_1980_2170_REG1_addBWs | 38 | Hughes Network Systems | Rel-14 | 74 |  |  |
| 4144 | 1658.1 | Core part: Addition of 1.4 and 3 MHz Channel Bandwidth to E-UTRA operating band 65 for CGC (Complementary Ground Component) operations in Region 1 | 65d? | 2016-12-15 A | 2017-03-15 A | 100% |  | finish no earlier than 2017-03-15 | R4 | 520h | 520h | LTE_1980_2170_REG1_addBWs-Core | 38 | Hughes Network Systems | Rel-14 | 74 |  |  |
| 4145 | 1658.2 | UE Conformance Test Aspects – Addition of 1.4 and 3 MHz Channel Bandwidth to E-UTRA operating band 65 for CGC (Complementary Ground Component) operations in Region 1 | 67d? | 2017-06-15 A | 2017-09-15 A | 100% |  | finish no earlier than 2017-09-15 | R5 | 536h | 536h | LTE_1980_2170_REG1_addBWs-UEConTest | 39 | Dish Network | Rel-14 | 76 |  |  |
| 4146 | 1659 | **LTE 2.6 GHz FDD Supplemental DL band (2570-2620 MHz) and LTE Carrier Aggregation (2DL/1UL) with Band 3 for region 1** | 757.88d? | 2015-12-15 A | 2017-12-15 A | 100% |  |  | R4 | 7896h | 7896h | LTE_FDD_2600_CA_B3 | 36 | Orange | Rel-14 | 70 |  |  |
| 4147 | 1659.1 | Core part: LTE 2.6 GHz FDD Supplemental DL band (2570-2620 MHz) and LTE Carrier Aggregation (2DL/1UL) with Band 3 for region 1 | 132d? | 2015-12-15 A | 2016-06-15 A | 100% |  | finish no earlier than 2016-09-15 | R4 | 1056h | 1056h | LTE_FDD_2600_CA_B3-Core | 36 | Orange | Rel-14 | 70 |  | 36.858 |
| 4148 | 1659.2 | Perf. part: LTE 2.6 GHz FDD Supplemental DL band (2570-2620 MHz) and LTE Carrier Aggregation (2DL/1UL) with Band 3 for region 1 | 132d? | 2015-12-15 A | 2016-06-15 A | 100% |  | finish no earlier than 2016-09-15 | R4 | 1056h | 1056h | LTE_FDD_2600_CA_B3-Perf | 36 | Orange | Rel-14 | 70 |  |  |
| 4149 | 1659.3 | UE Conformance Test Aspects - LTE 2.6 GHz FDD SDL band (2570-2620 MHz) and LTE Carrier Aggregation (2DL/1UL) with Band 3 for Region 1 (Band 69) | 198d? | 2017-03-15 A | 2017-12-15 A | 100% |  | finish no earlier than 2017-12-15 | R5 | 1584h | 1584h | LTE_FDD_2600_CA_B3-UEConTest | 38 | Bureau Veritas | Rel-14 | 75 |  |  |
| 4150 | 1660 | **Multi-Band Base Station testing with three or more bands** | 379.88d? | 2015-12-15 A | 2016-12-15 A | 100% |  |  | R4 | 6336h | 6336h | MB_BS_test_3B | 36 | Alcatel-Lucent | Rel-14 | 70 |  |  |
| 4151 | 1660.1 | Core part: Multi-Band Base Station testing with three or more bands | 264d? | 2015-12-15 A | 2016-12-15 A | 100% |  | finish no earlier than 2016-12-15 | R4 | 2112h | 2112h | MB_BS_test_3B-Core | 36 | Alcatel-Lucent | Rel-14 | 70 | RP-162032 | 37.871 |
| 4152 | 1660.2 | Perf. part: Multi-Band Base Station testing with three or more bands | 264d? | 2015-12-15 A | 2016-12-15 A | 100% |  | finish no earlier than 2016-12-15 | R4 | 2112h | 2112h | MB_BS_test_3B-Perf | 36 | Alcatel-Lucent | Rel-14 | 70 |  |  |

Notes:
- 4130: 22/3/16: Compl:0%->20%22/3/16: WID: RP-152272->RP-1604071/7/16: Compl:20%->60%1/7/16: WID: RP-160407->RP-160881¦26/9/16: Compl:60%->92%¦26/9/16: CD:Thu 15/09/16->Thu 15/12/16¦26/9/16: WID: ¦20/12/16: Compl:92%->97%¦20/12/16:21/3/17: Compl:
- 4131: 22/3/16: WID: RP-152272->RP-160407¦1/7/16: WID: RP-160407->RP-16088126/9/16: CD:Wed 15/03/17->Thu 15/06/1726/9/16: WID: RP-160881->RP-161832¦20/12/16: WID: RP-161832->RP-162235;21/3/17: Compl:0%->33%¦19/6/17: Compl:33%->50%¦ ;
- 4132: ¦21/3/17: Compl:0%->5% ;19/6/17: Compl:5%->6%¦19/9/17: Compl 8/1/18: C2 ;; 11/10/20: 85%->100
- 4134: 22/3/16: Compl:0%->8%¦ 1/7/16: Compl:8%->70%26/9/16: Compl:70%->100%¦8/1/18: Stat Rep: ->RP-172758
- 4136: 22/3/16: Compl:0%->20%¦1/7/16: Compl:20%->50%26/9/16: Compl:50%->65%¦20/12/16: Compl:65%->100%¦
- 4138: ¦22/3/16: Compl:0%->60%¦1/7/16: Compl:60%->100%¦1/7/16: CD:Th
- 4139: 1/7/16: Compl:0%->100%1/7/16: CD:Thu 15/09/16->Wed 15/06
- 4140: ¦20/12/16: Compl:0%->100%¦
- 4144: ¦21/3/17: Compl:0%->100% ¦2
- 4145: ¦19/9/17: Compl:0%->100%
- 4147: 28/1/16: 36.858 added;22/3/16: Compl:0%->40%22/3/16: WID: RP-152253->RP-160378¦1/7/16: Compl:40%->100%;
- 4148: ¦22/3/16: WID: RP-152253->RP-1603781/7/16: Compl:0%->100%1/7/16
- 4149: ¦19/9/17: Compl:43%->96%¦8/1/18: Compl:96%->100%¦
- 4151: 22/3/16: Compl:0%->50%22/3/16: WID: RP-152205->RP-1600631/7/16: Compl:50%->90%¦26/9/16: Compl:90%->95%¦26/9/16¦20/12/16: Compl:95%->100%¦
- 4152: 22/3/16: Compl:0%->5%22/3/16: WID: RP-152205->RP-160063¦1/7/16: Compl:5%->30%26/9/16: Compl:30%->60%26/¦20/12/16: Compl:60%->100%¦

| ID | WBS | Task | Duration | Start | Finish | Complete | Constraint | Resources | Work | Actual work | Acronym | PCG approved | WI rapporteur name | Release | TSG approved | Status Report | WI rapporteur e-mail |
| --- | --- | --- | --- | --- | --- | --- | --- | --- | --- | --- | --- | --- | --- | --- | --- | --- | --- |
| 4153 | 1661 | **Performance enhancements for high speed scenario in LTE** | 1040.62d? | 2015-12-15 A | 2018-09-14 A | 100% |  | R4 | 14168h | 14168h | LTE_high_speed | 36 | NTT DOCOMO | Rel-14 | 70 |  |  |
| 4154 | 1661.1 | Core part: Performance enhancements for high speed scenario in LTE | 264d? | 2015-12-15 A | 2016-12-15 A | 100% | finish no earlier than 2016-12-15 | R4 | 2112h | 2112h | LTE_high_speed-Core | 36 | NTT DOCOMO | Rel-14 | 70 | RP-162222 |  |
| 4155 | 1661.2 | Perf. part: Performance enhancements for high speed scenario in LTE | 394d? | 2015-12-15 A | 2017-06-15 A | 100% | finish no earlier than 2017-06-15 | R4 | 3152h | 3152h | LTE_high_speed-Perf | 36 | NTT DOCOMO | Rel-14 | 70 |  |  |
| 4156 | 1661.3 | UE Conformance Test Aspects - Performance enhancements for high speed scenario in LTE | 393d? | 2017-03-15 A | 2018-09-14 A | 100% | finish no earlier than 2018-09-15 | R5 | 3144h | 3144h | LTE_high_speed-UEConTest | 38 | CMCC | Rel-14 | 75 |  |  |
| 4157 | 1662 | **Further Indoor Positioning Enhancements for UTRA and LTE** | 663.62d? | 2016-03-15 A | 2017-12-15 A | 100% |  | R2 | 9488h | 9488h | UTRA_LTE_iPos_enh2 | 36 | Huawei | Rel-14 | 71 |  |  |
| 4158 | 1662.1 | Core part: Further Indoor Positioning Enhancements for UTRA and LTE | 199d? | 2016-03-15 A | 2016-12-15 A | 100% | finish no earlier than 2016-12-15 | R2 | 1592h | 1592h | UTRA_LTE_iPos_enh2-Core | 36 | Huawei | Rel-14 | 71 | RP-162506 |  |
| 4159 | 1662.2 | Perf. part: Further Indoor Positioning Enhancements for UTRA and LTE | 329d? | 2016-03-15 A | 2017-06-15 A | 100% | finish no earlier than 2017-06-15 | R4 | 2632h | 2632h | UTRA_LTE_iPos_enh2-Perf | 36 | Huawei | Rel-14 | 71 |  |  |
| 4160 | 1662.3 | UE Conformance Test Aspects - RAT Independent Further Indoor Positioning Enhancements for LTE | 198d? | 2017-03-15 A | 2017-12-15 A | 100% | finish no earlier than 2017-12-15 | R5 | 1584h | 1584h | LTE_iPos_enh2_RI-UEConTest | 38 | NextNav | Rel-14 | 75 |  |  |
| 4161 | 1663 | **Radiated performance requirements for the verification of multi-antenna reception of UEs in LTE** | 756.88d? | 2016-03-15 A | 2018-03-15 A | 100% |  | R4 | 10480h | 10480h | LTE_MIMO_OTA | 36 | Intel | Rel-14 | 71 |  |  |
| 4162 | 1663.1 | Core part: Radiated performance requirements for the verification of multi-antenna reception of UEs in LTE | 395d? | 2016-03-15 A | 2017-09-15 A | 100% | finish no earlier than 2017-09-15 | R4 | 3160h | 3160h | LTE_MIMO_OTA-Core | 36 | Intel | Rel-14 | 71 |  |  |
| 4163 | 1663.2 | UE Conformance Test Aspects - Radiated Performance of Multiple-antenna Receivers in the LTE UE | 391d? | 2016-09-15 A | 2018-03-15 A | 100% | finish no earlier than 2018-03-15 | R5 | 3128h | 3128h | LTE_MIMO_OTA-UEConTest | 37 | Intel | Rel-14 | 73 |  |  |
| 4164 | 1664 | **Enhancements on Full-Dimension (FD) MIMO for LTE** | 2372.5d? | 2016-03-15 A | 2022-06-22 A | 100% |  | R1 | 25800h | 25800h | LTE_eFDMIMO | 36 | Samsung | Rel-14 | 71 |  |  |
| 4165 | 1664.1 | Core part: Enhancements on Full-Dimension (FD) MIMO for LTE | 263d? | 2016-03-15 A | 2017-03-15 A | 100% | finish no earlier than 2017-03-15 | R1 | 2104h | 2104h | LTE_eFDMIMO-Core | 36 | Samsung | Rel-14 | 71 | RP-170173 |  |
| 4166 | 1664.2 | Perf. part: Enhancements on Full-Dimension (FD) MIMO for LTE | 460d? | 2016-03-15 A | 2017-12-15 A | 100% | finish no earlier than 2017-12-15 | R4 | 3680h | 3680h | LTE_eFDMIMO-Perf | 36 | Samsung | Rel-14 | 71 |  |  |
| 4167 | 1664.3 | UE Conformance Test Aspects - Enhancements on Full-Dimension (FD) MIMO for LTE | 864d | 2019-03-01 A | 2022-06-22 A | 100% | finish no earlier than 2022-06-22 | R5 | 6912h | 6912h | LTE_eFDMIMO-UEConTest | 42 | Mikael ZIRÉN | Rel-14 | 83 | RP-221217 | Mikael.ziren@ericsson.com |
| 4168 | 1665 | **Further mobility enhancements in LTE** | 474.12d? | 2016-03-15 A | 2017-06-15 A | 100% |  | R2 | 5784h | 5784h | LTE_eMob | 36 | ZTE | Rel-14 | 71 |  |  |
| 4169 | 1665.1 | Core part: Further mobility enhancements in LTE | 263d? | 2016-03-15 A | 2017-03-15 A | 100% | finish no earlier than 2017-03-15 | R2 | 2104h | 2104h | LTE_eMob-Core | 36 | ZTE | Rel-14 | 71 | RP-170369 |  |
| 4170 | 1665.2 | Perf. Part: Further mobility enhancements in LTE | 131d? | 2016-12-15 A | 2017-06-15 A | 100% | finish no earlier than 2017-06-15 | R4 | 1048h | 1048h | LTE_eMob-Perf | 38 | ZTE | Rel-14 | 74 |  |  |
| 4171 | 1666 | **Uplink Capacity Enhancements for LTE** | 1040.62d? | 2016-03-15 A | 2018-12-14 A | 100% |  | R1 | 13112h | 13112h | LTE_UL_CAP_enh | 36 | Ericsson | Rel-14 | 71 |  |  |
| 4172 | 1666.1 | Core part: Uplink Capacity Enhancements for LTE | 263d? | 2016-03-15 A | 2017-03-15 A | 100% | finish no earlier than 2017-03-15 | R1 | 2104h | 2104h | LTE_UL_CAP_enh-Core | 36 | Ericsson | Rel-14 | 71 | RP-170115 |  |
| 4173 | 1666.2 | Perf. part: Uplink Capacity Enhancements for LTE | 395d? | 2016-03-15 A | 2017-09-15 A | 100% | finish no earlier than 2017-09-15 | R4 | 3160h | 3160h | LTE_UL_CAP_enh-Perf | 36 | Ericsson | Rel-14 | 71 |  |  |
| 4174 | 1666.3 | UE Conformance Test Aspects - Uplink capacity enhancements for LTE | 261d? | 2017-12-15 A | 2018-12-14 A | 100% | finish no earlier than 2018-12-15 | R5 | 2088h | 2088h | LTE_UL_CAP_enh-UEConTest | 40 | Ericsson | Rel-14 | 78 |  |  |
| 4175 | 1667 | **L2 latency reduction techniques for LTE** | 756.88d? | 2016-03-15 A | 2018-03-15 A | 100% |  | R2 | 5784h | 5784h | LTE_LATRED_L2 | 36 | Ericsson | Rel-14 | 71 |  |  |
| 4176 | 1667.1 | Core part: L2 latency reduction techniques for LTE | 134d? | 2016-03-15 A | 2016-09-15 A | 100% | finish no earlier than 2016-09-15 | R2 | 1072h | 1072h | LTE_LATRED_L2-Core | 36 | Ericsson | Rel-14 | 71 | RP-172559 |  |
| 4177 | 1667.2 | UE Conformance Test Aspects - L2 latency reduction techniques for LTE | 65d? | 2017-12-15 A | 2018-03-15 A | 100% | finish no earlier than 2018-06-15 | R5 | 520h | 520h | LTE_LATRED_L2-UEConTest | 40 | Ericsson | Rel-14 | 78 |  |  |

Notes:
- 4154: 22/3/16: Compl:0%->5%22/3/16: WID: RP-152263->RP-160172¦1/7/16: Compl:5%->25%26/9/16: Compl:25%->45%20/12/16: Compl:45%->100%20/12/16: Stat Rep: ->RP-162222
- 4155: 22/3/16: WID: RP-152263->RP-1601721/7/16: Compl:0%->20%¦26/9/16: Compl:20%->25%¦20/12/16: Compl:25%->35% ¦21/3/17: Compl:35%->70%¦19/6/17: Compl:70%->100%¦19/6/17: WID: RP-160172->RP-171039
- 4156: tested: REL-14 LTE_high_speed-Core;¦19/6/17: Compl: 1 8/1/18:27/3/ ;; 11/10/20: 95%->100
- 4157: follow-up WI of REL-13 WI UTRA_LTE_iPos_enh
- 4158: follow-up WI of REL-13 WI UTRA_LTE_iPos_enh1/7/16: Compl:0%->30%¦26/9/16: Compl:30%->60%¦26/9/16: WID:¦20/12/16: Compl:60%->100%¦
- 4159: 26/9/16: CD:Wed 15/03/17->Thu 15/06/1726/9/16: WID: RP-160538->RP-161850¦20/12/16: Compl:0%->30%¦20/12/16: WI21/3/17: Compl:30%->50%19/6/17: Compl:50%->100%
- 4160: tested: REL-14 UTRA_LTE_iPos_enh2-Core (but only RAT independent aspects for LTE);¦ ;
- 4161: follow-up WI of REL-13 WI UTRA_LTE_MIMO_OTA-Core¦no Perf. part
- 4162: follow-up WI of REL-13 WI UTRA_LTE_MIMO_OTA-Core¦no Perf. part1/7/16: Compl:0%->10%1/7/16: WID: RP-160603->RP-16091426/9/16: Compl:10%->15%¦20/12/16: Compl:15%->25%¦20/12/16: WID: RP-160914->RP-162306;21/3/17: Compl:25%->33%;1 ;
- 4163: ¦20/12/16: Compl:0%->5%21/3/17: Compl:5%->20%19/6/17: Compl:20% 1 8/1/18: C27/3
- 4165: ¦1/7/16: Compl:0%->25%26/9/16: Compl:25%->40%¦20/12/16: Compl:40%->80%¦20/12/16: Stat Rep: -->¦21/3/17: Compl:80%->100%¦21/3/17: Stat Rep: ->RP-170173
- 4166: ¦20/12/16: Stat Rep: -->¦19/6/17: Compl:0%->50%19/9/17: Compl:50%->70%19/9/17: CD:Fri 15/09/17->Fri 15/12/17¦8/1/18: Compl:70%->100%
- 4167: 08/10/20: UID corrected (was 830185); 8/10/20: 0%->5; 8/10/20: FCD:13/09/2019->12/20; 8/4/21: FCD:11/12/2020->06/21; 2/7/21: 5%->5; 2/7/21: FCD:Fri 11/06/->12/21; 20/6/22: FCD:15/12/2021->22/06/2022; Compl:5%->100%; Stat Rep: ->RP-221217; Rapporteur: Ericsson->Mikael ZIRÉN; Rap eMail: ->Mikael.ziren@ericsson.com;
- 4168: no Perf. part
- 4169: no Perf. part¦1/7/16: Compl:0%->25%¦1/7/16: WID: RP-160636->RP-160921¦26/9/16: Compl:25%->50%¦20/12/16: Compl:50%->90%¦20/12/16: CD:Thu 15/12/16->Wed 15/03/1721/3/17: Compl:90%->100%¦21/3/17: St
- 4172: 1/7/16: Compl:0%->25%26/9/16: Compl:25%->40%¦20/12/16: Compl:40%->85%¦20/12/16: WID: RP-160664->RP-162488¦20/12/16: Stat Rep: -->21/3/17: Compl:85%->100%21/3/17: Stat Rep: ->RP-170115
- 4173: ¦20/12/16: WID: RP-160664->RP-162488¦20/12/16: Stat Rep: -->;21/3/17: Compl:0%->20%19/6/17: Compl:20%->75%¦19/9/17: Compl:75%->100%
- 4174: tested: REL-14 WI LTE_UL_CAP_enh-Core¦related to UL 256 QAM27/3 ;¦26/3/19: 35%->100
- 4175: no Perf. part¦follow-up WI of SI FS_LTE_LATRED
- 4176: no Perf. part¦follow-up WI of SI FS_LTE_LATRED¦1/7/16: Compl:0%->80%¦26/9/16: Compl:80%->100%8/1/18: Stat Rep: -->RP-172559
- 4177: tested: REL-14 WI LTE_LATRED_L2-Core27/3/18: Compl:0%->100%;

| ID | WBS | Task | Duration | Start | Finish | Complete | Constraint | Resources | Work | Actual work | Acronym | PCG approved | WI rapporteur name | Release | TSG approved | Status Report | WI rapporteur e-mail |
| --- | --- | --- | --- | --- | --- | --- | --- | --- | --- | --- | --- | --- | --- | --- | --- | --- | --- |
| 4178 | 1668 | **eMBMS enhancements for LTE** | 569.38d? | 2016-03-15 A | 2017-09-15 A | 100% |  | R1 | 9480h | 9480h | MBMS_LTE_enh2 | 36 | Ericsson | Rel-14 | 71 | RP-171628 |  |
| 4179 | 1668.1 | Core part: eMBMS enhancements for LTE | 395d? | 2016-03-15 A | 2017-09-15 A | 100% | finish no earlier than 2017-09-15 | R1 | 3160h | 3160h | MBMS_LTE_enh2-Core | 36 | Ericsson | Rel-14 | 71 |  |  |
| 4180 | 1668.2 | Perf. part: eMBMS enhancements for LTE | 395d? | 2016-03-15 A | 2017-09-15 A | 100% | finish no earlier than 2017-09-15 | R4 | 3160h | 3160h | MBMS_LTE_enh2-Perf | 36 | Ericsson | Rel-14 | 71 |  |  |
| 4181 | 1669 | **SRS (sounding reference signal) switching between LTE component carriers** | 852.12d? | 2016-03-15 A | 2018-06-15 A | 100% |  | R1 | 11568h | 11568h | LTE_SRS_switch | 36 | Huawei | Rel-14 | 71 |  |  |
| 4182 | 1669.1 | Core part: SRS (sounding reference signal) switching between LTE component carriers | 199d? | 2016-03-15 A | 2016-12-15 A | 100% | finish no earlier than 2016-12-15 | R1 | 1592h | 1592h | LTE_SRS_switch-Core | 36 | Huawei | Rel-14 | 71 | RP-162137 |  |
| 4183 | 1669.2 | Perf. part: SRS (sounding reference signal) switching between LTE component carriers | 329d? | 2016-03-15 A | 2017-06-15 A | 100% | finish no earlier than 2017-06-15 | R4 | 2632h | 2632h | LTE_SRS_switch-Perf | 36 | Huawei | Rel-14 | 71 |  |  |
| 4184 | 1669.3 | UE Conformance Test Aspects - SRS (sounding reference signal) switching between LTE component carriers | 328d? | 2017-03-15 A | 2018-06-15 A | 100% | finish no earlier than 2018-06-15 | R5 | 2624h | 2624h | LTE_SRS_switch-UEConTest | 38 | Huawei | Rel-14 | 75 |  |  |
| 4185 | 1670 | **Downlink Multiuser Superposition Transmission for LTE** | 474.12d? | 2016-03-15 A | 2017-06-15 A | 100% |  | R1 | 6856h | 6856h | LTE_MUST | 36 | MediaTek | Rel-14 | 71 |  |  |
| 4186 | 1670.1 | Core part: Downlink Multiuser Superposition Transmission for LTE | 199d? | 2016-03-15 A | 2016-12-15 A | 100% | finish no earlier than 2016-12-15 | R1 | 1592h | 1592h | LTE_MUST-Core | 36 | MediaTek | Rel-14 | 71 | RP-162504 |  |
| 4187 | 1670.2 | Perf. part: Downlink Multiuser Superposition Transmission for LTE | 329d? | 2016-03-15 A | 2017-06-15 A | 100% | finish no earlier than 2017-06-15 | R4 | 2632h | 2632h | LTE_MUST-Perf | 36 | MediaTek | Rel-14 | 71 |  |  |
| 4188 | 1671 | **IMS Stage-3 IETF Protocol Alignment** | 284.62d? | 2016-06-14 A | 2017-03-15 A | 100% |  | C1 | 7920h | 7920h | IMSProtoc8 | 37 |  | Rel-14 | 72 |  |  |
| 4189 | 1671.1 | CT1 aspects of IMS Stage-3 IETF Protocol Alignment | 198d? | 2016-06-14 A | 2017-03-15 A | 100% | finish no earlier than 2017-03-15 | C1 | 1584h | 1584h | IMSProtoc8 | 37 | Alcatel-Lucent | Rel-14 | 72 |  | Keith Drage |
| 4190 | 1671.2 | (IETF) CT1 aspects of IMS Stage-3 IETF Protocol Alignment | 198d? | 2016-06-14 A | 2017-03-15 A | 100% | start no earlier than 2016-06-14 | C1-IETF | 1584h | 1584h | IMSProtoc8 | 37 | Alcatel-Lucent | Rel-14 | 72 |  | Keith Drage |
| 4191 | 1671.3 | (IETF) Session Description Protocol (SDP) Offer/Answer Considerations for Datagram Transport Layer Security (DTLS) and Transport Layer Security (TLS) (draft-ietf-mmusic-dtls-sdp) | 198d? | 2016-06-14 A | 2017-03-15 A | 100% | start no earlier than 2016-06-14 | C1-IETF | 1584h | 1584h | IMSProtoc8 | 41 | Alcatel-Lucent | Rel-14 | 80 |  | Keith Drage |
| 4192 | 1671.4 | CT3 aspects of IMS Stage-3 IETF Protocol Alignment | 198d? | 2016-06-14 A | 2017-03-15 A | 100% | start no earlier than 2016-06-14 | C3 | 1584h | 1584h | IMSProtoc8 | 37 | Alcatel-Lucent | Rel-14 | 72 |  | Keith Drage |
| 4193 | 1672 | **Multi-Carrier Enhancements for UMTS** | 379.88d? | 2015-12-15 A | 2016-12-15 A | 100% |  | R2 | 4232h | 4232h | UTRA_MCe | 37 | Huawei, HiSilicon | Rel-14 | 72 |  |  |
| 4194 | 1672.1 | Study on Multi-Carrier Enhancements for UMTS | 132d? | 2015-12-15 A | 2016-06-15 A | 100% | finish no earlier than 2016-06-15 | R1 | 1056h | 1056h | FS_UTRA_MCe | 36 | Huawei | Rel-14 | 70 |  |  |
| 4195 | 1672.2 | Core part: Multi-Carrier Enhancements for UMTS | 133d? | 2016-06-15 A | 2016-12-15 A | 100% | finish no earlier than 2016-12-15 | R2 | 1064h | 1064h | UTRA_MCe-Core | 37 | Huawei, HiSilicon | Rel-14 | 72 | RP-162129 |  |
| 4196 | 1673 | **Citizens Broadband Radio Service (CBRS) 3.5GHz band for LTE in the United States** | 378.88d? | 2016-06-15 A | 2017-06-15 A | 100% |  | R4 | 5280h | 5280h | LTE_TDD_3550_CBRS_US | 37 | Nokia | Rel-14 | 72 |  |  |
| 4197 | 1673.1 | Core part: Citizens Broadband Radio Service (CBRS) 3.5GHz band for LTE in the United States | 133d? | 2016-06-15 A | 2016-12-15 A | 100% | finish no earlier than 2016-12-15 | R4 | 1064h | 1064h | LTE_TDD_3550_CBRS_US-Core | 37 | Nokia | Rel-14 | 72 |  |  |
| 4198 | 1673.2 | Perf. part: Citizens Broadband Radio Service (CBRS) 3.5GHz band for LTE in the United States | 133d? | 2016-06-15 A | 2016-12-15 A | 100% | finish no earlier than 2016-12-15 | R4 | 1064h | 1064h | LTE_TDD_3550_CBRS_US-Perf | 37 | Nokia | Rel-14 | 72 |  |  |
| 4199 | 1673.3 | UE Conformance Test Aspects – Citizens Broadband Radio Service (CBRS) 3.5GHz Band for LTE in the United States (Band 48) | 131d? | 2016-12-15 A | 2017-06-15 A | 100% | finish no earlier than 2017-06-15 | R5 | 1048h | 1048h | LTE_TDD_3550_CBRS_US-UEConTest | 38 | Nokia | Rel-14 | 74 |  |  |
| 4200 | 1674 | **LTE Band 41 UE power class 2 operation** | 283.62d? | 2016-06-15 A | 2017-03-15 A | 100% |  | R4 | 4744h | 4744h | LTE_B41_UE_PC2 | 37 | Sprint | Rel-14 | 72 |  |  |
| 4201 | 1674.1 | Core part: LTE Band 41 UE power class 2 operation | 133d? | 2016-06-15 A | 2016-12-15 A | 100% | finish no earlier than 2016-12-15 | R4 | 1064h | 1064h | LTE_B41_UE_PC2-Core | 37 | Sprint | Rel-14 | 72 |  |  |
| 4202 | 1674.2 | Perf. part: LTE Band 41 UE power class 2 operation | 133d? | 2016-06-15 A | 2016-12-15 A | 100% | finish no earlier than 2016-12-15 | R4 | 1064h | 1064h | LTE_B41_UE_PC2-Perf | 37 | Sprint | Rel-14 | 72 |  |  |
| 4203 | 1674.3 | UE Conformance Test Aspects – LTE Band 41 UE power class 2 operation | 130d? | 2016-09-15 A | 2017-03-15 A | 100% | finish no earlier than 2017-03-15 | R5 | 1040h | 1040h | LTE_B41_UE_PC2-UEConTest | 37 | Sprint | Rel-14 | 73 |  |  |

Notes:
- 4179: 1/7/16: Compl:0%->10%1/7/16: CD:Tue 15/03/16->Wed 15/03/171/7/16: WID: RP-160675->RP-16129726/9/16: Compl:10%->55%¦20/12/16: Compl:55%->80%¦20/12/16: WID: RP-161297->RP-162231 ¦21/3/17: Compl:80%->90% ¦19/6/17: Compl:90 ;
- 4180: ¦1/7/16: CD:Wed 15/06/16->Fri 15/09/17¦1/7/16: WID: RP-160675->RP-161297¦20/12/16: WID: RP-161297->RP-162231¦20/12/16: Stat Rep: --> ¦21/3/17: WID: RP-162231->RP-17019919/6/17: Compl:0%->70%¦19/9/17: Compl:70%->100%
- 4182: 1/7/16: Compl:0%->35%1/7/16: WID: RP-160676->RP-160935¦26/9/16: Compl:35%->55%¦20/12/16: Compl:55%->100%¦20/12/16: Stat Rep: -->RP-162137
- 4183: 1/7/16: WID: RP-160676->RP-160935¦20/12/16: Stat Rep: --> 21/3/17: Compl:0%->25% 21/3/17: CD:Wed 15/03/17->Thu 15/06/17¦19/6/17: Compl:25%->100%
- 4184: tested: REL-14 LTE_SRS_switch-Core;¦19/6/17: Compl:0%->5%¦8/1/18: Compl:27/3/ ;
- 4186: ¦1/7/16: Compl:0%->40%¦1/7/16: WID: RP-160680->RP-16101926/9/16: Compl:40%->60%¦20/12/16: Compl:60%->100%¦20/12/16: Stat Rep: -->RP-162504
- 4187: 1/7/16: WID: RP-160680->RP-161019¦26/9/16: CD:Fri 15/09/17->Thu 15/06/17¦20/12/16: Stat Rep: --> ¦21/3/17: Compl:0%->25%19/6/17: Compl:25%->100%
- 4188: 11/6/16: 0%->15¦5/6/17: 67%->100
- 4189: Mar.15: 0->10%¦June2015: Compl:10%->30¦07/09/15: 30%->70¦7/12/15: 70%->100¦16/9/16: 0%->30¦2/12/16: 30%->75¦6/3/17: 75%->100
- 4190: Impacted TSs and TRs: draft-ietf-mmusic-dtls-sdp; draft-ietf-mmusic-4572-update (became RFC 8122)
- 4191: 23/4/20: 25%->90; 9/4/21: RFC 8842 added;; 16/7/24: 90%->100 / Impacted TSs and TRs: RFC 8842
- 4192: 2/4/15: added, following CT3 chair's info that the WID also has a CT3 part¦June2015: Compl:0%->20¦07/09/15: 20%->40¦7/12/15: 40%->100¦20/9/16: 0%->10¦2/12/16: 10%->30¦6/3/17: 30%->100
- 4193: no Perf. part¦follow-up WI of REL-14 SI FS_UTRA_MCe
- 4194: 22/3/16: Compl:0%->20%¦1/7/16: Compl:20%->100%¦28/7/16: 25.707 added; / Impacted TSs and TRs: 25.707
- 4195: no Perf. part¦follow-up WI of REL-14 SI FS_UTRA_MCe¦26/9/16: Compl:0%->35%¦20/12/16: Compl:35%->100%;
- 4197: 26/9/16: Compl:0%->70%¦6/10/16: 36.744 added¦20/12/16: Compl:70%->100%¦ / Impacted TSs and TRs: 36.744
- 4198: ¦20/12/16: Compl:0%->100%¦
- 4199: 21/3/17: Compl:0%->60% ¦ 19/6/17: Compl:60%->100%
- 4200: follow-up WI of SI FS_LTE_B41_HPUE
- 4201: follow-up WI of SI FS_LTE_B41_HPUE¦26/9/16: Compl:0%->80%¦20/12/16: Compl:80%->100%
- 4202: 26/9/16: Compl:0%->80%¦20/12/16: Compl:80%->100%
- 4203: ¦20/12/16: Compl:0%->65% 21/3/17: Compl:65%->100%

| ID | WBS | Task | Duration | Start | Finish | Complete | Constraint | Resources | Work | Actual work | Acronym | PCG approved | WI rapporteur name | Release | TSG approved | Status Report | Impacted TSs and TRs | WI rapporteur e-mail |
| --- | --- | --- | --- | --- | --- | --- | --- | --- | --- | --- | --- | --- | --- | --- | --- | --- | --- | --- |
| 4204 | 1675 | **Dedicated Core Networks for GERAN** | 96.12d? | 2016-06-15 A | 2016-09-15 A | 100% |  | R6 | 1088h | 1088h | DECOR_GERAN | 37 | Ericsson | Rel-14 | 72 |  |  |  |
| 4205 | 1675.1 | Core part: Dedicated Core Networks for GERAN | 68d? | 2016-06-15 A | 2016-09-15 A | 100% | finish no earlier than 2016-12-15 | R6 | 544h | 544h | DECOR_GERAN-Core | 37 | Ericsson | Rel-14 | 72 | RP-170194 |  |  |
| 4206 | 1676 | **Positioning Enhancements for GERAN** | 378.88d? | 2016-06-15 A | 2017-06-15 A | 100% |  | R6 | 6312h | 6312h | ePOS_GERAN | 37 | Ericsson | Rel-14 | 72 |  |  |  |
| 4207 | 1676.1 | Core part: Positioning Enhancements for GERAN | 263d? | 2016-06-15 A | 2017-06-15 A | 100% | finish no earlier than 2017-06-15 | R6 | 2104h | 2104h | ePOS_GERAN-Core | 37 | Ericsson | Rel-14 | 72 | RP-170920 |  |  |
| 4208 | 1676.2 | Perf. part: Positioning Enhancements for GERAN | 263d? | 2016-06-15 A | 2017-06-15 A | 100% | finish no earlier than 2017-06-15 | R6 | 2104h | 2104h | ePOS_GERAN-Perf | 37 | Ericsson | Rel-14 | 72 |  |  |  |
| 4209 | 1677 | **Quality of Experience (QoE) Measurement Collection for streaming services in UTRAN** | 1241.62d? | 2014-12-03 A | 2018-03-15 A | 100% |  | R2 | 12664h | 12664h | UMTS_QMC_Streaming | 37 | China Unicom | Rel-14 | 73 |  |  |  |
| 4210 | 1677.1 | Study on KQIs for Service Experience | 333d? | 2014-12-03 A | 2016-03-11 A | 100% | finish no earlier than 2016-03-11 | S5 | 2664h | 2664h | FS_KQISE | 34 | Li, Hui (hui.li(at)huawei.com) | Rel-14 | 66 |  | 32.8xy | hui.li(at)huawei.com |
| 4211 | 1677.2 | Core part:Quality of Experience (QoE) Measurement Collection for streaming services in UTRAN | 130d? | 2016-09-15 A | 2017-03-15 A | 100% | finish no earlier than 2017-03-15 | R2 | 1040h | 1040h | UMTS_QMC_Streaming-Core | 37 | China Unicom | Rel-14 | 73 | RP-170259 |  |  |
| 4212 | 1677.3 | UE Conformance Test Aspects -Quality of Experience (QoE) Measurement Collection for streaming services in UTRAN | 262d? | 2017-03-15 A | 2018-03-15 A | 100% | finish no earlier than 2018-03-15 | R5 | 2096h | 2096h | UMTS_QMC_Streaming-UEConTest | 38 | Huawei | Rel-14 | 75 |  |  |  |
| 4213 | 1678 | **Flexible eNB-ID and Cell-ID in E-UTRAN** | 378.88d? | 2016-03-15 A | 2017-03-15 A | 100% |  | R3 | 4216h | 4216h | LTE_FNBID | 37 | China Telecom | Rel-14 | 73 |  |  |  |
| 4214 | 1678.1 | Study on flexible eNB-ID and Cell-ID in E-UTRAN | 134d? | 2016-03-15 A | 2016-09-15 A | 100% | finish no earlier than 2016-09-15 | R3 | 1072h | 1072h | FS_LTE_FNBID | 36 | China Telecom | Rel-14 | 71 |  | New 36.896 |  |
| 4215 | 1678.2 | Core part: Flexible eNB-ID and Cell-ID in E-UTRAN | 130d? | 2016-09-15 A | 2017-03-15 A | 100% | finish no earlier than 2017-03-15 | R3 | 1040h | 1040h | LTE_FNBID-Core | 37 | China Telecom | Rel-14 | 73 | RP-170478 |  |  |
| 4216 | 1679 | **4 receiver (4Rx) antenna ports with Carrier Aggregation (CA) for LTE downlink (DL)** | 756d? | 2016-09-15 A | 2018-09-14 A | 100% |  | R4 | 14648h | 14648h | LTE_4Rx_AP_DL_CA | 37 | Ericsson | Rel-14 | 73 |  |  |  |
| 4217 | 1679.1 | Core part: 4 receiver (RX) antenna ports with Carrier Aggregation (CA) for LTE downlink (DL) | 66d? | 2016-09-15 A | 2016-12-15 A | 100% | finish no earlier than 2016-12-15 | R4 | 528h | 528h | LTE_4Rx_AP_DL_CA-Core | 37 | Ericsson | Rel-14 | 73 | RP-162059 |  |  |
| 4218 | 1679.2 | Perf. part: 4 receiver (RX) antenna ports with Carrier Aggregation (CA) for LTE downlink (DL) | 262d? | 2016-09-15 A | 2017-09-15 A | 100% | finish no earlier than 2017-09-15 | R4 | 2096h | 2096h | LTE_4Rx_AP_DL_CA-Perf | 37 | Ericsson | Rel-14 | 73 |  |  |  |
| 4219 | 1679.3 | **Introduction of new band support for 4Rx antenna ports for LTE** | 661.75d? | 2016-12-15 A | 2018-09-14 A | 100% |  | R4 | 7848h | 7848h | LTE_4Rx_AP_DL_bands | 38 | Huawei | Rel-14 | 74 |  |  |  |
| 4220 | 1679.3.1 | Core part: Introduction of new band support for 4Rx antenna ports for LTE | 131d? | 2016-12-15 A | 2017-06-15 A | 100% | finish no earlier than 2017-06-15 | R4 | 1048h | 1048h | LTE_4Rx_AP_DL_bands-Core | 38 | Huawei | Rel-14 | 74 |  |  |  |
| 4221 | 1679.3.2 | UE Conformance Test Aspects - 4 Rx antenna ports with CA for LTE DL | 393d? | 2017-03-15 A | 2018-09-14 A | 100% | finish no earlier than 2018-09-15 | R5 | 3144h | 3144h | LTE_4Rx_AP_DL_CA-UEConTest | 38 | Ericsson | Rel-14 | 75 |  |  |  |
| 4222 | 1680 | **Requirements for a new UE category with single receiver based on Category 1 for LTE** | 756d? | 2016-09-15 A | 2018-09-14 A | 100% |  | R4 | 10456h | 10456h | LTE_UE_cat_1RX | 37 | Qualcomm | Rel-14 | 73 |  |  |  |
| 4223 | 1680.1 | Core part: Requirements for a new UE category with single receiver based on Category 1 for LTE | 196d? | 2016-09-15 A | 2017-06-15 A | 100% | finish no earlier than 2017-06-15 | R4 | 1568h | 1568h | LTE_UE_cat_1RX-Core | 37 | Qualcomm | Rel-14 | 73 | RP-171317 |  |  |
| 4224 | 1680.2 | Perf. part: Requirements for a new UE category with single receiver based on Category 1 for LTE | 262d? | 2016-09-15 A | 2017-09-15 A | 100% | finish no earlier than 2017-09-15 | R4 | 2096h | 2096h | LTE_UE_cat_1RX-Perf | 37 | Qualcomm | Rel-14 | 73 |  |  |  |
| 4225 | 1680.3 | UE Conformance Test Aspects – Requirements for a new UE category 1bis with single receiver based on category 1 for LTE | 327d? | 2017-06-15 A | 2018-09-14 A | 100% | finish no earlier than 2018-09-15 | R5 | 2616h | 2616h | LTE_UE_cat_1RX-UEConTest | 39 | Qualcomm | Rel-14 | 76 |  |  |  |
| 4226 | 1681 | **Enhanced LTE WLAN Radio Level Integration with IPsec Tunnel (eLWIP)** | 188.5d? | 2016-09-15 A | 2017-03-15 A | 100% |  | R3 | 2080h | 2080h | LTE_WLAN_eLWIP | 37 | Nokia | Rel-14 | 73 |  |  |  |
| 4227 | 1681.1 | Core part: Enhanced LTE WLAN Radio Level Integration with IPsec Tunnel (eLWIP) | 130d? | 2016-09-15 A | 2017-03-15 A | 100% | finish no earlier than 2017-03-15 | R3 | 1040h | 1040h | LTE_WLAN_eLWIP-Core | 37 | Nokia | Rel-14 | 73 | RP-170706 |  |  |

Notes:
- 4204: no Perf. part¦DECOR was a REL-13 SA2 feature
- 4205: no Perf. part¦DECOR was a REL-13 SA2 feature¦26/9/16: Compl:0%->100%21/3/17: Stat Rep: ->RP-170194
- 4207: 26/9/16: Compl:0%->30%¦20/12/16: Compl:30%->50% 21/3/17: Compl:50%->80% ¦19/6/17: Compl:80%->100%;
- 4208: ¦20/12/16: Compl:0%->50% ¦21/3/17: Compl:50%->80%¦19/6/17: Compl:80%->100%¦
- 4210: Mar 15: 0->5%¦June2015: Compl:0%->40¦07/09/15: 40%->50¦14/09/15: WID:SP-140784->SP-150405¦7/12/15: 50%->75¦7/12/15: WID:SP-150405->SP-150676 ¦7/3/16: 75%->100. 22/3/16: FCD: 09/15->03/16. Rel-13->Rel-14
- 4211: ¦20/12/16: Compl:0%->60% ¦21/3/17: Compl:60%->100%
- 4212: tested: REL-14 UMTS_QMC_Streaming-Core;19/6/17: Comp 19/ 8/1/18: 27/3
- 4214: 1/7/16: Compl:0%->60%26/9/16: Compl:60%->100%
- 4215: ¦20/12/16: Compl:0%->80%21/3/17: Compl:80%->100%21/3/17: Stat Rep: ->RP-170478
- 4217: ¦20/12/16: Compl:0%->100%¦20/12/16: Stat Rep: ->RP-162059
- 4218: ¦20/12/16: Compl:0%->30%;21/3/17: Compl:30%->50%19/6/17: Compl:50%->90%¦19/9/17: Compl:90%->100%
- 4219: Pending acronym
- 4220: ¦21/3/17: Compl:0%->80% ¦2119/6/17: Compl:80%->100%
- 4221: tested: REL-14 LTE_4Rx_AP_DL_CA-Core¦19/6/17: C 1 8/1/18: C 27/3/ ;¦26/3/19: 90%->100
- 4223: ¦20/12/16: Compl:0%->70%¦20/12/16: CD:Thu 15/12/16->Wed 15/03/17 ¦21/3/17: Compl:70%->95% 21/3/17: CD:Wed 15/03/17->Thu 15/06/1 19/6/17: Compl:95%->100%;
- 4224: ¦20/12/16: Compl:0%->20%¦20/12/16: CD:Thu 15/06/17->Fri 15/09/17 21/3/17: Compl:20%->70% ¦21/3/17: WID: RP-162570->RP-17079119/6/17: Compl:70%->100%;
- 4225: ¦19/9/17: Compl:0%->5%¦8/1/18: Compl:5%->45%27/3/18: Compl:45%->70%;; 11/10/20: 80%->100
- 4227: ¦20/12/16: Compl:0%->60% 21/3/17: Compl:60%->100% 21/3/17: Stat Rep: ->RP-170706

| ID | WBS | Task | Duration | Start | Finish | Complete | Remaining | Baseline start | Baseline finish | Baseline duration | Total slack | Constraint | Resources | Work | Actual work | Acronym | PCG approved | WI rapporteur name | Release | TSG approved | Status Report | WI rapporteur e-mail | MCC resp | Acronym_3GU_Export | TSG stopped | Special Focus Doc |
| --- | --- | --- | --- | --- | --- | --- | --- | --- | --- | --- | --- | --- | --- | --- | --- | --- | --- | --- | --- | --- | --- | --- | --- | --- | --- | --- |
| 4228 | 1682 | **LTE Measurement Gap Enhancement** | 474.12d? | 2016-03-15 A | 2017-06-15 A | 100% |  |  |  |  |  |  |  | 5264h | 5264h | LTE_meas_gap_enh | 36 | Intel | Rel-14 | 71 |  |  |  |  |  |  |
| 4229 | 1682.1 | Core part: LTE Measurement Gap Enhancement | 329d? | 2016-03-15 A | 2017-06-15 A | 100% |  |  |  |  |  | finish no earlier than 2017-06-15 | R4 | 2632h | 2632h | LTE_meas_gap_enh-Core | 36 | Intel | Rel-14 | 71 | RP-171330 |  |  |  |  |  |
| 4230 | 1682.2 | Perf. part: LTE Measurement Gap Enhancement | 329d? | 2016-03-15 A | 2017-06-15 A | 100% |  |  |  |  |  | finish no earlier than 2017-06-15 | R4 | 2632h | 2632h | LTE_meas_gap_enh-Perf | 36 | Intel | Rel-14 | 71 |  |  |  |  |  |  |
| 4231 | 1683 | **Enhanced CRS and SU-MIMO Interference Mitigation Performance Requirements for LTE** | 379d? | 2016-09-15 A | 2017-09-15 A | 100% |  |  |  |  |  |  |  | 2096h | 2096h | LTE_eCRSIM_eSUMIMO | 37 | Intel | Rel-14 | 73 |  |  |  |  |  |  |
| 4232 | 1683.1 | Perf. part: Enhanced CRS and SU-MIMO Interference Mitigation Performance Requirements for LTE | 262d? | 2016-09-15 A | 2017-09-15 A | 100% |  |  |  |  |  | finish no earlier than 2017-09-15 | R4 | 2096h | 2096h | LTE_eCRSIM_eSUMIMO-Perf | 37 | Intel | Rel-14 | 73 |  |  |  |  |  |  |
| 4233 | 1684 | **Miscellaneous IETF dependencies** | 1221d? | 2017-03-15 A | 2020-06-05 A | 100% |  |  |  |  |  |  |  | 5488h | 5488h | TEI14_IETF | 40 |  | Rel-14 | 78 |  |  |  |  |  |  |
| 4234 | 1684.1 | (IETF) T.140 Real-time Text Conversation over WebRTC Data Channels (draft-ietf-mmusic-t140-usage-data-channel) | 87d? | 2020-02-06 A | 2020-06-05 A | 100% |  |  |  |  |  | finish no earlier than 2020-06-06 | CT1-IETF | 696h | 696h | TEI14_IETF | 40 |  | Rel-14 | 78 |  |  |  |  |  |  |
| 4235 | 1684.2 | (IETF) SDP Offer/Answer Clarifications for RTP/RTCP Multiplexing [RFC 5761 (was draft-ietf-avtcore-5761-update)] | 133d? | 2017-03-15 A | 2017-09-15 A | 100% |  |  |  |  |  | finish no earlier than 2017-09-15 | CT1-IETF | 1064h | 1064h | TEI14_IETF | 40 |  | Rel-14 | 78 |  |  |  |  |  |  |
| 4236 | 1684.3 | (IETF) T.140 Real-time Text Conversation over WebRTC Data Channels (draft-ietf-mmusic-t140-usage-data-channel) | 197d? | 2017-03-15 A | 2017-12-14 A | 100% |  |  |  |  |  | finish no earlier than 2017-12-14 | CT1-IETF | 1576h | 1576h | TEI14_IETF | 40 |  | Rel-14 | 78 |  |  |  |  |  |  |
| 4237 | 1684.4 | (IETF) T.140 Real-time Text Conversation over WebRTC Data Channels (draft-ietf-mmusic-t140-usage-data-channel) | 197d? | 2017-03-15 A | 2017-12-14 A | 100% |  |  |  |  |  | finish no earlier than 2017-12-14 | CT1-IETF | 1576h | 1576h | TEI14_IETF | 40 |  | Rel-14 | 78 |  |  |  |  |  |  |
| 4238 | 1684.5 | (IETF) Negotiating Media Multiplexing Using the Session Description Protocol (SDP) (draft-ietf-mmusic-sdp-bundle-negotiation) | 24d | 2020-03-23 A | 2020-04-23 A | 100% |  |  |  |  |  | start no earlier than 2020-03-23 | C1-IETF | 192h | 192h | TEI14_IETF | 44 |  | Rel-14 | 87 |  |  |  |  |  |  |
| 4239 | 1684.6 | (IETF) Indicating Exclusive Support of RTP/RTCP Multiplexing using SDP (draft-ietf-mmusic-mux-exclusive) | 24d | 2020-03-23 A | 2020-04-23 A | 100% |  |  |  |  |  | start no earlier than 2020-03-23 | C1-IETF | 192h | 192h | TEI14_IETF | 44 |  | Rel-14 | 87 |  |  |  |  |  |  |
| 4240 | 1684.7 | (IETF) IP Mobility Support for IPv4, Revised (draft-ietf-mip4-rfc3344bis) --> RFC 5944 | 24d | 2020-03-23 A | 2020-04-23 A | 100% |  |  |  |  |  | start no earlier than 2020-03-23 | C1-IETF | 192h | 192h | TEI14_IETF | 44 |  | Rel-14 | 87 |  |  |  |  |  |  |
| 4241 | 1685 | **Security Assurance Specification for 3GPP network products** | 1330.12d? | 2013-12-09 A | 2017-06-15 A | 100% |  | 2013-12-09 | 2015-03-18 | 334d? |  |  | S3 | 23192h | 23192h | SCAS | 32 | NTT DOCOMO | Rel-14 | 62 |  | Alf Zugenmaier (alf.zugenmaier@hm.edu) | Mirko | SCAS |  |  |
| 4242 | 1685.1 | STOPPED - TR on Pilot development of Security Assurance Specification for MME network product class | 266d? | 2013-12-09 A | 2014-12-12 A | 100% |  | 2013-12-09 | 2014-12-10 | 264d? |  | finish no earlier than 2014-12-12 | S3 | 2120h | 2120h | SCAS-SA3Pil_TR | 32 | NTT DOCOMO | Rel-14 | 62 |  | Alf Zugenmaier (alf.zugenmaier@hm.edu) | Mirko |  | 80 |  |
| 4243 | 1685.2 | TR on Security Assurance scheme for 3GPP network products | 791d? | 2013-12-09 A | 2016-12-15 A | 100% |  | 2013-12-09 | 2014-12-10 | 264d? |  | finish no earlier than 2016-12-15 | S3 | 6320h | 6320h | SCAS-SA3TR | 32 | NTT DOCOMO | Rel-14 | 62 |  | Alf Zugenmaier (alf.zugenmaier@hm.edu) | Mirko |  |  |  |
| 4244 | 1685.3 | Security Assurance Specification for 3GPP network product classes | 920d? | 2013-12-13 A | 2017-06-15 A | 100% |  | 2013-12-10 | 2015-03-18 | 333d? |  | finish no earlier than 2017-06-15 | S3 | 7360h | 7360h | SCAS-SA3 | 32 | China Mobile | Rel-14 | 62 |  | Judy Zhu (zhuhongru@chinamobile.com) | Mirko |  |  |  |
| 4245 | 1686 | (Small) Technical Enhancements and Improvements for Rel-14 | 29d? | 2015-05-11 A | 2015-06-18 A | 100% |  |  |  |  |  | start no earlier than 2015-05-11 | SP; CP; RP; R4 | 928h | 928h | TEI14 | 35 |  | Rel-14 | 68 |  |  |  |  |  |  |
| 4246 | 1687 | (Small) Test Technical Enhancements and Improvements for Rel-14 | 593d? | 2016-09-13 A | 2018-12-20 A | 100% |  |  |  |  |  | start no earlier than 2016-09-13 | SP; CP; RP; GP | 18976h | 18976h | TEI14_Test | 35 |  | Rel-14 | 68 |  |  |  |  |  |  |
| 4247 | 1688 | **Rel-14 LTE Carrier Aggregation** | 131d? | 2015-09-15 A | 2016-01-19 | 90% | 13.09d? | 2014-03-06 | 2015-06-12 | 332d? | 41572d |  | R4 | 9734h | 8791.15h | LTE_CA_Rel14 | 30 |  | Rel-14 | 58 |  |  | Issam | LTE_CA_Rel-13 |  | CA |
| 4248 | 1688.1 | **LTE Advanced 4 Band Carrier Aggregation (4DL/1UL) of Band 4, Band 5, Band 12 and Band 12** | 131d? | 2015-09-15 A | 2016-01-19 | 90% | 13.09d? |  |  |  | 41572d |  | R4 | 3144h | 2829.72h | LTE_CA_B4_B5_B12_B12 | PCG-35 | US Cellular | Rel-14 | RP-69 |  |  |  |  |  |  |
| 4249 | 1688.1.1 | Core part: LTE Advanced 4 Band Carrier Aggregation (4DL/1UL) of Band 4, Band 5, Band 12 and Band 12 | 131d? | 2015-09-15 A | 2016-01-19 | 90% | 13.1d? |  |  |  | 41572d | finish no earlier than 2016-03-15 | R4 | 1048h | 943.2h | LTE_CA_B4_B5_B12_B12-Core | PCG-35 | US Cellular | Rel-14 | RP-69 |  |  |  |  |  |  |
| 4250 | 1688.1.2 | Perf. part: LTE Advanced 4 Band Carrier Aggregation (4DL/1UL) of Band 4, Band 5, Band 12 and Band 12 | 131d? | 2015-09-15 A | 2016-01-19 | 90% | 13.1d? |  |  |  | 41572d | finish no earlier than 2016-03-15 | R4 | 1048h | 943.2h | LTE_CA_B4_B5_B12_B12-Perf | PCG-35 | US Cellular | Rel-14 | RP-69 |  |  |  |  |  |  |
| 4251 | 1688.2 | **LTE Advanced 4 Band Carrier Aggregation (4DL/1UL) of Band 4, Band 4, Band 12 and Band 12** | 131d? | 2015-09-15 A | 2016-01-19 | 90% | 13.09d? |  |  |  | 41572d |  | R4 | 3144h | 2829.72h | LTE_CA_B4_B4_B12_B12 | PCG-35 | US Cellular | Rel-14 | RP-69 |  |  |  |  |  |  |
| 4252 | 1688.2.1 | Core part: LTE Advanced 4 Band Carrier Aggregation (4DL/1UL) of Band 4, Band 4, Band 12 and Band 12 | 131d? | 2015-09-15 A | 2016-01-19 | 90% | 13.1d? |  |  |  | 41572d | finish no earlier than 2016-03-15 | R4 | 1048h | 943.2h | LTE_CA_B4_B4_B12_B12-Core | PCG-35 | US Cellular | Rel-14 | RP-69 |  |  |  |  |  |  |
| 4253 | 1688.2.2 | Perf. part: LTE Advanced 4 Band Carrier Aggregation (4DL/1UL) of Band 4, Band 4, Band 12 and Band 12 | 131d? | 2015-09-15 A | 2016-01-19 | 90% | 13.1d? |  |  |  | 41572d | finish no earlier than 2016-03-15 | R4 | 1048h | 943.2h | LTE_CA_B4_B4_B12_B12-Perf | PCG-35 | US Cellular | Rel-14 | RP-69 |  |  |  |  |  |  |

Notes:
- 4229: ¦1/7/16: Compl:0%->10%¦1/7/16: CD:Thu 15/06/17->Wed 15/03/17¦1/7/16: WID: RP-160678->RP-160912¦26/9/16: Compl:10%->25%26/9/16: R¦20/12/16: Compl:25%->60% 21/3/17: Compl:60%->95% 19/6/17: Compl:95%->100%
- 4230: 1/7/16: WID: RP-160678->RP-1609121/7/16: Release: Rel-15->Rel-14¦20/12/16: Stat Rep: -->¦20/12/16: Release: Rel-15->Rel-14 21/3/17: Compl:0%->20% 21/3/17: Release: Rel19/6/17: Compl:20%->100%
- 4231: Impacted TSs and TRs: 39.747
- 4232: 6/10/16: 36.176 added¦20/12/16: Compl:0%->30%21/3/17: Compl:30%->50% ¦21/3/17: Release: Rel-15->Rel-14¦19/6/17: Compl:50%->85%19/9/17: Compl:85%->100% / Impacted TSs and TRs: 36.176
- 4233: Created upon demand of RAN5
- 4234: 9/4/21: RFC 8865 added;; 16/7/24: 100%->100 / Impacted TSs and TRs: RFC 8865
- 4236: was (IETF) T.140 Text Conversation over Data Channels (draft-schwarz-mmusic-t140-usage-data-channel); 9/4/21: RFC 8865 added; / Impacted TSs and TRs: RFC 8865
- 4237: 22/3/18: 25%->100. was (IETF) BFCP floor control signalling over Data Channels (draft-schwarz-mmusic-bfcp-usage-data-channel). ; 9/4/21: RFC 8865 added; / Impacted TSs and TRs: RFC 8865
- 4238: 9/4/21: RFC 8843 added; / Impacted TSs and TRs: RFC 8843
- 4239: 9/4/21: RFC 8858 added; / Impacted TSs and TRs: RFC 8858
- 4241: Triggered by Rel-12 TR 33.805 Study on Security Assurance Methodology for 3GPP Network Elements (FS_SECAM)¦June2015: WID:SP-130718->SP-150292. Aug 15: TR numb added¦28/1/16: 33.926 added¦28/7/16: 33.250 added;06/10/16: moved to Rel-14 as per John/M / Impacted TSs and TRs: 33.199; 33.926; 33.117; 33.250; 33.515
- 4242: This TR collects input for the new TS 33.116. Dec.14: 55->70%. 3/3/15: 70->55%. 10/03/15: 55->75%¦June2015: Compl:75%->80¦7/12/15: STOPPED AT 80% (marked as 100% here since no more work expected) / Impacted TSs and TRs: New 33.806
- 4243: This TR contains results of the second WID objective. Dec.14: 75->85%¦June2015: Compl:85%->90¦7/12/15: 90%->92¦10/12/15: WID:SP-130718->SP-150716¦19/9/16: 92%->98. FCD set to 12.16 (was 03/16)¦6/10/16: 33.216 added¦1/12/16: 81%->100 / Impacted TSs and TRs: New 33.916; 33.216
- 4244: June2015: 0%->5¦7/12/15: 5%->72.¦10/12/15: WID:SP-130718->SP-150716¦7/3/16: 72%->75¦28/7/16: 33.250 added¦19/9/16: 75%->90. FCD set to 12.16 (was 03/16). 6/3/17: moved from Rel-14.¦15/2/18: moved back to Rel-14¦6/8/18: 33.515 added; / Impacted TSs and TRs: New 33.116; 33.117; 33.250; 22.511; 22.512; 22.513; 22.514; 33.515
- 4246: Created upon demand of RAN5
- 4247: Acronym changed from "LTE_CA_Rel-13" to "LTE_CA_Rel13"

| ID | WBS | Task | Duration | Start | Finish | Complete | Remaining | Baseline start | Baseline finish | Baseline duration | Total slack | Constraint | Resources | Work | Actual work | Acronym | PCG approved | WI rapporteur name | Release | TSG approved | MCC resp | Special Focus Doc | Acronym_3GU_Export | Impacted TSs and TRs |
| --- | --- | --- | --- | --- | --- | --- | --- | --- | --- | --- | --- | --- | --- | --- | --- | --- | --- | --- | --- | --- | --- | --- | --- | --- |
| 4254 | 1688.3 | **LTE Advanced 4 Band Carrier Aggregation (4DL/1UL) of Band 2, Band 4, Band 12 and Band 12** | 131d? | 2015-09-15 A | 2016-01-19 | 90% | 13.09d? |  |  |  | 41572d |  | R4 | 3144h | 2829.72h | LTE_CA_B2_B4_B12_B12 | PCG-35 | US Cellular | Rel-14 | RP-69 |  |  |  |  |
| 4255 | 1688.3.1 | Core part: LTE Advanced 4 Band Carrier Aggregation (4DL/1UL) of Band 2, Band 4, Band 12 and Band 12 | 131d? | 2015-09-15 A | 2016-01-19 | 90% | 13.1d? |  |  |  | 41572d | finish no earlier than 2016-03-15 | R4 | 1048h | 943.2h | LTE_CA_B2_B4_B12_B12-Core | PCG-35 | US Cellular | Rel-14 | RP-69 |  |  |  |  |
| 4256 | 1688.3.2 | Perf. part: LTE Advanced 4 Band Carrier Aggregation (4DL/1UL) of Band 2, Band 4, Band 12 and Band 12 | 131d? | 2015-09-15 A | 2016-01-19 | 90% | 13.1d? |  |  |  | 41572d | finish no earlier than 2016-03-15 | R4 | 1048h | 943.2h | LTE_CA_B2_B4_B12_B12-Perf | PCG-35 | US Cellular | Rel-14 | RP-69 |  |  |  |  |
| 4257 | 1689 | **Rel-14LTE Advanced inter-band Carrier Aggregation** | 2183.12d? | 2015-12-15 A | 2021-09-21 | 87% | 274.62d? | 2014-03-06 | 2015-06-12 | 332d? | 39425.6d |  | R4 | 96616h | 70396.3h | LTE_AIBCA_Rel14 | 30 |  | Rel-14 | 58 | Issam | CA | LTE_CA_Rel-13 |  |
| 4258 | 1689.1 | **LTE Advanced inter-band Carrier Aggregation Rel-14 for 5DL/1UL** | 394d? | 2015-12-15 A | 2016-12-29 | 95% | 19.69d? |  |  |  | 41214.8d |  | R4 | 9456h | 8416.04h | LTE_CA_R14_5DL1UL | PCG-36 | Nokia Networks | Rel-14 | RP-70 |  |  |  |  |
| 4259 | 1689.1.1 | Core part: LTE Advanced inter-band Carrier Aggregation Rel-14 for 5DL/1UL | 394d? | 2015-12-15 A | 2016-12-29 | 95% | 19.7d? |  |  |  | 41214.8d | finish no earlier than 2017-06-15 | R4 | 3152h | 2994.4h | LTE_CA_R14_5DL1UL-Core | PCG-36 | Nokia Networks | Rel-14 | RP-70 |  |  |  | 36.714-05-01 |
| 4260 | 1689.1.2 | Perf. part: LTE Advanced inter-band Carrier Aggregation Rel-14 for 5DL/1UL | 394d? | 2015-12-15 A | 2016-12-29 | 95% | 19.7d? |  |  |  | 41214.8d | finish no earlier than 2017-06-15 | R4 | 3152h | 2994.4h | LTE_CA_R14_5DL1UL-Perf | PCG-36 | Nokia Networks | Rel-14 | RP-70 |  |  |  |  |
| 4261 | 1689.2 | **LTE Advanced inter-band Carrier Aggregation Rel-14 for 2DL/1UL** | 394d? | 2015-12-15 A | 2016-12-29 | 80% | 78.8d? |  |  |  | 41214.8d |  | R4 | 9456h | 7076.85h | LTE_CA_R14_2DL1UL | PCG-36 | Qualcomm | Rel-14 | RP-70 |  |  |  |  |
| 4262 | 1689.2.1 | Core part: LTE Advanced inter-band Carrier Aggregation Rel-14 for 2DL/1UL | 394d? | 2015-12-15 A | 2016-12-29 | 80% | 78.8d? |  |  |  | 41214.8d | finish no earlier than 2017-06-15 | R4 | 3152h | 2521.6h | LTE_CA_R14_2DL1UL-Core | PCG-36 | Qualcomm | Rel-14 | RP-70 |  |  |  | 36.714-02-01 |
| 4263 | 1689.2.2 | Perf. part: LTE Advanced inter-band Carrier Aggregation Rel-14 for 2DL/1UL | 394d? | 2015-12-15 A | 2016-12-29 | 80% | 78.8d? |  |  |  | 41214.8d | finish no earlier than 2017-06-15 | R4 | 3152h | 2521.6h | LTE_CA_R14_2DL1UL-Perf | PCG-36 | Qualcomm | Rel-14 | RP-70 |  |  |  |  |
| 4264 | 1689.3 | **LTE Advanced inter-band Carrier Aggregation Rel-14 for 2DL/2UL** | 394d? | 2015-12-15 A | 2016-12-29 | 90% | 39.4d? |  |  |  | 41214.8d |  | R4 | 9456h | 7904.07h | LTE_CA_R14_2DL2UL | PCG-36 | Huawei | Rel-14 | RP-70 |  |  |  |  |
| 4265 | 1689.3.1 | Core part: LTE Advanced inter-band Carrier Aggregation Rel-14 for 2DL/2UL | 394d? | 2015-12-15 A | 2016-12-29 | 90% | 39.4d? |  |  |  | 41214.8d | finish no earlier than 2017-06-15 | R4 | 3152h | 2836.8h | LTE_CA_R14_2DL2UL-Core | PCG-36 | Huawei | Rel-14 | RP-70 |  |  |  | 36.714-02-02 |
| 4266 | 1689.3.2 | Perf. part: LTE Advanced inter-band Carrier Aggregation Rel-14 for 2DL/2UL | 394d? | 2015-12-15 A | 2016-12-29 | 90% | 39.4d? |  |  |  | 41214.8d | finish no earlier than 2017-06-15 | R4 | 3152h | 2836.8h | LTE_CA_R14_2DL2UL-Perf | PCG-36 | Huawei | Rel-14 | RP-70 |  |  |  |  |
| 4267 | 1689.4 | **LTE Advanced inter-band Carrier Aggregation Rel-14 for 3DL/3UL** | 473.12d? | 2015-12-15 A | 2017-03-15 A | 100% |  |  |  |  |  |  | R4 | 7872h | 7872h | LTE_CA_R14_3DL3UL | PCG-36 | Nokia Networks | Rel-14 | RP-70 |  |  |  |  |
| 4268 | 1689.4.1 | Core part: LTE Advanced inter-band Carrier Aggregation Rel-14 for 3DL/3UL | 328d? | 2015-12-15 A | 2017-03-15 A | 100% |  |  |  |  |  | finish no earlier than 2017-03-15 | R4 | 2624h | 2624h | LTE_CA_R14_3DL3UL-Core | PCG-36 | Nokia Networks | Rel-14 | RP-70 |  |  |  | 36.714-03-03 |
| 4269 | 1689.4.2 | Perf. part: LTE Advanced inter-band Carrier Aggregation Rel-14 for 3DL/3UL | 328d? | 2015-12-15 A | 2017-03-15 A | 100% |  |  |  |  |  | finish no earlier than 2017-03-15 | R4 | 2624h | 2624h | LTE_CA_R14_3DL3UL-Perf | PCG-36 | Nokia Networks | Rel-14 | RP-70 |  |  |  |  |
| 4270 | 1689.5 | **LTE Advanced inter-band Carrier Aggregation Rel-14 for xDL/2UL with x=3,4,5** | 568.38d? | 2015-12-15 A | 2017-06-15 | 48% | 298.4d? |  |  |  | 41040.4d |  | R4 | 9456h | 4240.77h | LTE_CA_R14_xDL2UL | PCG-36 | LG Electronics | Rel-14 | RP-70 |  |  |  |  |
| 4271 | 1689.5.1 | Core part: LTE Advanced inter-band Carrier Aggregation Rel-14 for xDL/2UL with x=3,4,5 | 394d? | 2015-12-15 A | 2016-12-29 | 95% | 19.7d? |  |  |  | 41214.8d | finish no earlier than 2017-06-15 | R4 | 3152h | 2994.4h | LTE_CA_R14_xDL2UL-Core | PCG-36 | LG Electronics | Rel-14 | RP-70 |  |  |  | 36.714-00-02 |
| 4272 | 1689.5.2 | Perf. part: LTE Advanced inter-band Carrier Aggregation Rel-14 for xDL/2UL with x=3,4,5 | 394d? | 2016-05-31 | 2017-06-15 |  |  |  |  |  | 41040.4d | finish no earlier than 2017-06-15 | R4 | 3152h |  | LTE_CA_R14_xDL2UL-Perf | PCG-36 | LG Electronics | Rel-14 | RP-70 |  |  |  |  |
| 4273 | 1689.6 | **LTE Advanced inter-band Carrier Aggregation Rel-14 for 4DL/1UL** | 394d? | 2015-12-15 A | 2016-12-29 | 95% | 19.69d? |  |  |  | 41214.8d |  | R4 | 9456h | 8481.62h | LTE_CA_R14_4DL1UL | PCG-36 | Ericsson | Rel-14 | RP-70 |  |  |  |  |
| 4274 | 1689.6.1 | Core part: LTE Advanced inter-band Carrier Aggregation Rel-14 for 4DL/1UL | 394d? | 2015-12-15 A | 2016-12-29 | 95% | 19.7d? |  |  |  | 41214.8d | finish no earlier than 2017-06-15 | R4 | 3152h | 2994.4h | LTE_CA_R14_4DL1UL-Core | PCG-36 | Ericsson | Rel-14 | RP-70 |  |  |  | 36.714-04-01 |
| 4275 | 1689.6.2 | Perf. part: LTE Advanced inter-band Carrier Aggregation Rel-14 for 4DL/1UL | 394d? | 2015-12-15 A | 2016-12-29 | 95% | 19.7d? |  |  |  | 41214.8d | finish no earlier than 2017-06-15 | R4 | 3152h | 2994.4h | LTE_CA_R14_4DL1UL-Perf | PCG-36 | Ericsson | Rel-14 | RP-70 |  |  |  |  |
| 4276 | 1689.7 | **LTE Advanced intra-band Carrier Aggregation for xDL/yUL including contiguous and non-contiguous spectrum** | 394d? | 2015-12-15 A | 2016-12-29 | 82% | 70.92d? |  |  |  | 41214.8d |  | R4 | 9456h | 7084.9h | LTE_CA_R14_intra | PCG-36 | Ericsson | Rel-14 | RP-70 |  |  |  |  |
| 4277 | 1689.7.1 | Core part: LTE Advanced intra-band Carrier Aggregation for xDL/yUL including contiguous and non-contiguous spectrum | 394d? | 2015-12-15 A | 2016-12-29 | 82% | 70.92d? |  |  |  | 41214.8d | finish no earlier than 2017-06-15 | R4 | 3152h | 2584.64h | LTE_CA_R14_intra-Core | PCG-36 | Ericsson | Rel-14 | RP-70 |  |  |  | 36.714-00-00 |
| 4278 | 1689.7.2 | Perf. part: LTE Advanced intra-band Carrier Aggregation for xDL/yUL including contiguous and non-contiguous spectrum | 394d? | 2015-12-15 A | 2016-12-29 | 82% | 70.92d? |  |  |  | 41214.8d | finish no earlier than 2017-06-15 | R4 | 3152h | 2584.64h | LTE_CA_R14_intra-Perf | PCG-36 | Ericsson | Rel-14 | RP-70 |  |  |  |  |

Notes:
- 4257: Acronym changed from "LTE_CA_Rel-13" to "LTE_CA_Rel13"
- 4259: 28/1/16: 36.714-05-01 added¦22/3/16: Compl:0%->15%¦22/3/16: WID: RP-151671->RP-1606151/7/16: Compl:15%->40%¦26/9/16: Compl:40%->60%¦20/12/16: Compl ¦21/3/17
- 4260: 22/3/16: WID: RP-151671->RP-1606151/7/16: WID: RP-160615->RP-16105226/9/16: WID: RP-161052->RP-161496¦20/12/16: Compl:0%->90% ¦21/3/17: Compl:90%->95%;
- 4262: 28/1/16: 36.714-02-01 added¦22/3/16: Compl:0%->20%¦22/3/16: WID: RP-152196->RP-160616¦1/7/16: Compl:20%->30%¦1/7/16: WI26/9/16: Compl:30%->50%¦20/12/16: Com 21/3/17:
- 4263: 22/3/16: WID: RP-152196->RP-1606161/7/16: Compl:0%->30%1/7/16: WID: RP-160616->RP-161202¦26/9/16: Compl:30%->50% 20/12/16: Compl:50%->75% 21/3/17: Compl:75%->80%;
- 4265: 28/1/16: 36.714-02-02 added;22/3/16: Compl:0%->20%22/3/16: WID: RP-152237->RP-160192¦1/7/16: Compl:20%->40%¦26/9/16: Compl:40%->60%¦20/12/16: C ¦21/3/17:
- 4266: ¦22/3/16: WID: RP-152237->RP-1601921/7/16: WID: RP-160192->RP-16094726/9/16: WID: RP-160947->RP-161676¦20/12/16: Compl:0%->80%¦21/3/17: Compl:80%->90
- 4268: 28/1/16: 36.714-03-03 added;22/3/16: Compl:0%->1%1/7/16: Compl:1%->15%¦21/3/17: Compl:15%->100%
- 4269: ¦1/7/16: Compl:0%->15%21/3/17: Compl:15%->100%
- 4271: 28/1/16: 36.714-00-02 added¦22/3/16: Compl:0%->10%¦22/3/16: WID: RP-152246->RP-160148¦1/7/16: Compl:10%->40%¦26/9/16: Compl:40%->70%¦20/¦21/3/17:
- 4272: 22/3/16: WID: RP-152246->RP-1601481/7/16: WID: RP-160148->RP-160748¦26/9/16: WID: RP-160748->RP-161487¦20/12/16: WID: RP-161487->RP-16203621/3/17:
- 4274: 28/1/16: 36.714-04-01 added;22/3/16: Compl:0%->30%22/3/16: WID: RP-152249->RP-1606141/7/16: Compl:30%->38%¦26/9/16: Compl:38%->74%¦20/12/16: Compl:74%->9521/3/1
- 4275: ¦22/3/16: WID: RP-152249->RP-160614¦1/7/16: Compl:0%->38%¦1/7/16: WID: RP-160614->RP-16082126/9/16: Compl:38%->0%¦20/12/16: Compl:0%->95% ¦21/3/17: CD:Wed 1
- 4277: 28/1/16: 36.714-00-00 added;22/3/16: Compl:0%->60%22/3/16: WID: RP-152250->RP-160613¦1/7/16: Compl:60%->50%¦1/7/16: WID: RP-160613¦26/9/16: Compl:50%->44%¦20/12/16:21/3/1
- 4278: ¦22/3/16: WID: RP-152250->RP-1606131/7/16: Compl:0%->50%1/7/16: WID: RP-160613->RP-16082226/9/16: WID: RP-160822->RP-161473¦20/12/16: Compl:50%->64% 21/3/17: Compl:64%->

| ID | WBS | Task | Type | Duration | Start | Finish | Complete | Remaining | Baseline start | Baseline finish | Baseline duration | Total slack | Constraint | Resources | Work | Actual work | Acronym | PCG approved | WI rapporteur name | Release | TSG approved | Impacted TSs and TRs | Status Report | WI rapporteur e-mail | MCC resp | Acronym_3GU_Export | Special Focus Doc | TSG stopped |
| --- | --- | --- | --- | --- | --- | --- | --- | --- | --- | --- | --- | --- | --- | --- | --- | --- | --- | --- | --- | --- | --- | --- | --- | --- | --- | --- | --- | --- |
| 4279 | 1689.8 | **LTE Advanced inter-band Carrier Aggregation Rel-14 for 3DL/1UL** |  | 394d? | 2015-12-15 A | 2016-12-29 | 90% | 39.4d? |  |  |  | 41214.8d |  | R4 | 9456h | 7904.07h | LTE_CA_R14_3DL1UL | PCG-36 | Huawei | Rel-14 | RP-70 |  |  |  |  |  |  |  |
| 4280 | 1689.8.1 | Core part: LTE Advanced inter-band Carrier Aggregation Rel-14 for 3DL/1UL |  | 394d? | 2015-12-15 A | 2016-12-29 | 90% | 39.4d? |  |  |  | 41214.8d | finish no earlier than 2017-06-15 | R4 | 3152h | 2836.8h | LTE_CA_R14_3DL1UL-Core | PCG-36 | Huawei | Rel-14 | RP-70 | 36.714-03-01 |  |  |  |  |  |  |
| 4281 | 1689.8.2 | Perf. part: LTE Advanced inter-band Carrier Aggregation Rel-14 for 3DL/1UL |  | 394d? | 2015-12-15 A | 2016-12-29 | 90% | 39.4d? |  |  |  | 41214.8d | finish no earlier than 2017-06-15 | R4 | 3152h | 2836.8h | LTE_CA_R14_3DL1UL-Perf | PCG-36 | Huawei | Rel-14 | RP-70 |  |  |  |  |  |  |  |
| 4282 | 1689.9 | UE Conformance Test Aspects – Rel-14 CA configurations |  | 1376d? | 2016-06-15 A | 2021-09-21 A | 100% |  |  |  |  |  | finish no earlier than 2021-09-21 | R5 | 11008h | 11008h | LTE_CA_R14-UEConTest | 37 | Ericsson | Rel-14 | 72 |  | RP-211865 |  |  |  |  |  |
| 4283 | 1690 | Release 14 Studies |  | 323d? | 2014-09-17 A | 2015-12-11 A | 100% |  |  |  |  |  | finish no earlier than 2015-12-11 | SP; RP; CP; GP | 10336h | 10336h |  |  |  | Rel-14 |  |  |  |  |  |  |  |  |
| 4284 | 1691 | Study on channel model for frequency spectrum above 6 GHz |  | 197d? | 2015-09-15 A | 2016-06-15 A | 100% |  |  |  |  |  | finish no earlier than 2016-06-15 | R1 | 1576h | 1576h | FS_6GHz_CH_model | 35 | Samsung | Rel-14 | 69 | 38.900 |  |  |  |  |  |  |
| 4285 | 1692 | Study on Scenarios and Requirements for Next Generation Access Technologies |  | 264d? | 2015-12-15 A | 2016-12-15 A | 100% |  |  |  |  |  | finish no earlier than 2016-12-15 | RP | 2112h | 2112h | FS_NG_SReq | 36 | CMCC | Rel-14 | 70 | 38.xxx |  |  |  |  |  |  |
| 4286 | 1693 | Study on NB-IoT RF requirement for coexistence with CDMA |  | 133d? | 2016-06-15 A | 2016-12-15 A | 100% |  |  |  |  |  | finish no earlier than 2016-12-15 | R4 | 1064h | 1064h | FS_NB_IOT_CDMA_coex | 37 | China Telecom | Rel-14 | 72 | 36.752 |  |  |  |  |  |  |
| 4287 | 1694 | Study on need for Multiple Access Point Names |  | 464d? | 2013-09-12 A | 2015-06-19 A | 100% |  | 2013-09-12 | 2014-12-10 | 327d? |  | finish no earlier than 2015-06-19 | S1 | 3704h | 3704h | FS_MAPN | 31 | Giesecke & Devrient | Rel-14 | 61 | 22.802 |  | Ilario.macchi@gi-de.com | Alain | FS_MAPN |  |  |
| 4288 | 1695 | Study on Multimedia Broadcast Supplement for Public Warning System |  | 264d? | 2013-12-11 A | 2014-12-12 A | 100% |  | 2013-12-11 | 2014-09-17 | 202d? |  | finish no earlier than 2014-12-12 | S1 | 2104h | 2104h | FS_MBSP | 32 | Qualcomm | Rel-14 | 62 | 22.815 |  | Eddy Hall (edhall@qti.qualcomm.com) | Alain | FS_MBSP | Public Safety (I-A) |  |
| 4289 | 1696 | Study on service aspects for dealing with User Control over spoofed calls |  | 271d? | 2014-03-07 A | 2015-03-20 A | 100% |  | 2014-03-07 | 2014-12-10 | 199d? |  | finish no earlier than 2015-03-20 | S1 | 2168h | 2168h | FS_UC_SPOOF | 32 | Sprint | Rel-14 | 63 | 22.898 |  | Gregory.schumacher@sprint.com | Alain | FS_UC_SPOOF |  |  |
| 4290 | 1697 | Study on User Location Reporting Support enhancements |  | 261d? | 2014-06-19 A | 2015-06-17 A | 100% |  | 2014-06-18 | 2015-06-17 | 261d? |  | finish no earlier than 2015-06-17 | S1 | 2088h | 2088h | FS_eULRS | 33 | China Unicom | Rel-14 | 64 | 22.899 |  | Zhuoyun Zhang ( zhangzy910@chinaunicom.cn) |  | FS_eULRS |  |  |
| 4291 | 1698 | Study on Control of Applications when Third party Servers encounter difficulties |  | 259d? | 2014-06-19 A | 2015-06-15 A | 100% |  | 2014-06-18 | 2014-12-10 | 126d? |  | finish no earlier than 2015-06-15 | S1 | 2072h | 2072h | FS_CATS | 33 | KDDI | Rel-14 | 64 | 22.818 |  | Eriko Yoshida (er-yoshida@kddi.com) |  | FS_CATS |  |  |
| 4292 | 1699 | Study on Paging Policy Enhancements and Procedure Optimizations in LTE |  | 176d? | 2015-04-14 A | 2015-12-15 A | 100% |  |  |  |  |  | finish no earlier than 2015-12-15 | S1 | 1408h | 1408h | FS_PPEPO_LTE | 34 | Zhuoyun Zhang (China Unicom) | Rel-14 | 67 | New 22.838 |  | zhangzy910@chinaunicom.cn |  |  |  |  |
| 4293 | 1700 | Study on Latency reduction techniques for LTE |  | 328d? | 2015-03-16 A | 2016-06-15 A | 100% |  |  |  |  |  | finish no earlier than 2016-06-15 | R2 | 2624h | 2624h | FS_LTE_LATRED | 34 | Ericsson | Rel-14 | 67 | 36.881 |  |  |  |  |  |  |
| 4294 | 1701 | Study on High Power LTE UE for Band 41 |  | 263d? | 2015-06-15 A | 2016-06-15 A | 100% |  |  |  |  |  | finish no earlier than 2016-12-15 | R4 | 2104h | 2104h | FS_LTE_B41_HPUE | 35 | Sprint | Rel-14 | 68 | 36.886 |  |  |  |  |  |  |
| 4295 | 1702 | Study on Media and Quality Aspects of SRVCC Enhancements |  | 192d? | 2015-06-18 A | 2016-03-11 A | 100% |  |  |  |  |  | finish no earlier than 2016-03-11 | S4 | 1536h | 1536h | FS_SETA_S4 | 35 | Frédéric Gabin, Ericsson LM | Rel-14 | 68 | New 26.916; 26.114 |  | frederic . gabin @ ericsson . com |  |  |  |  |
| 4296 | 1703 | Stopped - Study on SON for eCoMP for LTE |  | 3d? | 2016-06-14 A | 2016-06-16 A | 100% |  |  |  |  |  | start no earlier than 2016-06-14 | R3 | 24h | 24h | delFS_LTE_SON_eCOMP | 37 | Nokia | Rel-14 | 72 | 23.228; 23.237 |  |  |  |  |  | 80 |
| 4297 | 1704 | Study on UICC power optimization for MTC |  | 133d? | 2016-06-15 A | 2016-12-15 A | 100% |  |  |  |  |  |  | C6 | 1064h | 1064h | FS_UICC_MTC_OPT | 36 | Berionne, Michele | Rel-14 | 70 | 31.970 |  | micheleb [at] qti [dot] qualcomm [dot] com |  |  |  |  |
| 4298 | 1705 | Study on Server and Network Assisted DASH for 3GPP |  | 209d? | 2016-03-01 A | 2016-12-15 A | 100% |  |  |  |  |  | finish no earlier than 2016-12-15 | S4 | 1672h | 1672h | FS_SAND | 36 | Ozgur Oyman, Intel | Rel-14 | 71 | TR26.957 |  | ozgur.oyman@intel.com |  |  |  |  |
| 4299 | 1706 | Study on MBMS usage for mission critical communication services | milestone | 0d? | 2016-03-01 A | 2016-03-01 A | 100% |  |  |  |  |  | finish no earlier than 2016-12-15 | C1 |  |  | FS_MBMS_MCservices | 36 | Magnus Tränk, Ericsson LM | Rel-14 | 71 | 23.780 |  | magnus.trank@ericsson.com |  |  |  |  |
| 4300 | 1707 | Study on enhancement of VoLTE |  | 134d? | 2016-03-15 A | 2016-09-15 A | 100% |  |  |  |  |  | finish no earlier than 2016-09-15 | R2 | 1072h | 1072h | FS_LTE_eVoLTE | 36 | CMCC | Rel-14 | 71 | 36.750 |  |  |  |  |  |  |
| 4301 | 1708 | Study on HSPA and LTE Joint Operation |  | 199d? | 2016-03-15 A | 2016-12-15 A | 100% |  |  |  |  |  | finish no earlier than 2016-12-15 | R3 | 1592h | 1592h | FS_UTRA_LTE_JOP | 36 | China Unicom | Rel-14 | 71 | New 37.805 |  |  |  |  |  |  |
| 4302 | 1709 | Study on LTE Advanced Carrier Aggregation of Band 3 and Band 39 |  | 263d? | 2016-03-15 A | 2017-03-15 A | 100% |  |  |  |  |  | finish no earlier than 2017-03-15 | R4 | 2104h | 2104h | FS_LTE_CA_B3_B39 | 36 | ZTE | Rel-14 | 71 |  |  |  |  |  |  |  |
| 4303 | 1710 | Study on Context Aware Service Delivery in RAN for LTE |  | 263d? | 2016-03-15 A | 2017-03-15 A | 100% |  |  |  |  |  | finish no earlier than 2017-03-15 | R3 | 2104h | 2104h | FS_LTE_context | 36 | CMCC | Rel-14 | 71 |  |  |  |  |  |  |  |
| 4304 | 1711 | Study on further enhancements to Coordinated Multi-Point (CoMP) Operation for LTE |  | 263d? | 2016-03-15 A | 2017-03-15 A | 100% |  |  |  |  |  | finish no earlier than 2017-03-15 | R1 | 2104h | 2104h | FS_feCOMP_LTE | 36 | Intel | Rel-14 | 71 |  |  |  |  |  |  |  |
| 4305 | 1712 | Study on Determination of Completeness of Charging Information in IMS |  | 267d? | 2015-03-05 A | 2016-03-11 A | 100% |  |  |  |  |  | finish no earlier than 2016-03-11 | S5 | 2136h | 2136h | FS_DCCHII | 34 | Jesske, Roland | Rel-14 | 67 | 32.xyz |  | r.jesske@telekom.de |  |  |  |  |
| 4306 | 1713 | Study on Interactivity Support for 3GPP-based Streaming and Download Services |  | 587d? | 2014-12-12 A | 2017-03-10 A | 100% |  |  |  |  |  | finish no earlier than 2017-03-10 | S4 | 4696h | 4696h | FS_IS3 | 34 | Lo, Charles, Qualcomm | Rel-14 | 66 | 26.953 |  | clo@qti.qualcomm.com |  |  |  |  |
| 4307 | 1714 | Study on MBMS usage and codecs for MCPTT call and MC Video Service |  | 199d? | 2016-06-13 A | 2017-03-15 A | 100% |  |  |  |  |  | finish no earlier than 2017-03-15 | S4 | 1592h | 1592h | FS_MCP_V | 37 | Zhiming Li, Huawei | Rel-14 | 72 | 26.880 |  | lizhiming@huawei.com |  |  |  |  |
| 4308 | 1715 | Study on MBMS Extensions for Provisioning and Content Ingestion |  | 196d? | 2016-06-13 A | 2017-03-10 A | 100% |  |  |  |  |  | finish no earlier than 2017-03-10 | S4 | 1568h | 1568h | FS_xMBMS | 37 | Kyungmo Park, sk telecom | Rel-14 | 72 | 26.981 |  | kyungmo.park@sk.com |  |  |  |  |
| 4309 | 1716 | Study on global application of LTE Band 11 and of LTE Band 21 UEs |  | 133d? | 2016-06-15 A | 2016-12-15 A | 100% |  |  |  |  |  | finish no earlier than 2016-12-15 | R4 | 1064h | 1064h | FS_LTE_B11_B21_global | 37 | SoftBank | Rel-14 | 72 | 36.745 |  |  |  |  |  |  |
| 4310 | 1717 | Study on Downlink MIMO for GERAN |  | 68d? | 2016-06-15 A | 2016-09-15 A | 100% |  |  |  |  |  | finish no earlier than 2016-09-15 | R6 | 544h | 544h | FS_DOMIMO_RAN6 | 37 | Nokia, Alcatel-Lucent Shanghai Bell | Rel-14 | 72 |  |  |  |  |  |  |  |
| 4311 | 1718 | Release 14 studies on 5G MObile Network for Advanced communications |  | 707.12d? | 2015-02-02 A | 2016-12-15 A | 100% |  |  |  |  |  |  | S1 | 2160h | 2160h |  | 34 | Adrian Neal (Vodafone) | Rel-14 | 67 | New 22.891 |  | adrian.neal@vodafone.com |  |  |  |  |

Notes:
- 4280: 28/1/16: 36.714-03-01 added;22/3/16: Compl:0%->15%22/3/16: WID: RP-152278->RP-1605821/7/16: Compl:15%->40%1/7/1626/9/16: Compl:40%->60%¦20/12/16: Compl:60%->80 21/3/1
- 4281: 22/3/16: WID: RP-152278->RP-160582¦1/7/16: WID: RP-160582->RP-160945¦26/9/16: WID: RP-160945->RP-161674¦20/12/16: Compl:0%->80%21/3/17: Compl:80%->90%;
- 4282: testing REL-14 CA basket WIs: LTE_CA_R14_intra-Core, LTE_CA_R14_2DL1UL-Core, LTE_CA_R14_3DL1UL-Core, LTE_CA_R14_4DL1UL-Core, LTE_CA_R14_5DL1UL-Core, LTE_CA_R14_2DL2UL-Core, LTE_CA_R14_xDL2UL-Core, LTE_CA_R14_3DL3UL-Core ;; 8/10/20: 20%->38; 8/10/20: F
- 4283: -
- 4284: will start only in RAN in Q4/15¦28/1/16: 38.900 added¦22/3/16: Compl:10%->20%¦22/3/16: WID: RP-151606->RP-160210¦1/7/16: Compl:20%->100%. 2/12/16: Moved to Rel-15 according JMM email to move all 38.xxx related WIDs to Rel-15¦21/3/17: Stat Rep: -->
- 4285: 22/3/16: Compl:0%->80%1/7/16: WID: RP-152257->RP-160811. 18/9/16: FCD: Sept 16, 80->95%26/9/16: Compl:95%->100%¦14/12/16: FCD:09/16->12/16¦14/12/16: 100%->9820/12/16: Compl:98%->100%20/12/16: CD:Mon 12/12/16->Thu 15/12/1620/12/16: Release: Rel-15->Re
- 4286: ¦26/9/16: Compl:0%->35%¦6/10/16: 36.752 added¦20/12/16: Compl:35%->100%
- 4287: SP#65 moved to Rel-14. Completion 12/14=>03/15. Triggered by S1-133134 LS on GSMA Connected Living Programme Request for APN Storage in the SIM. Dec.14: 50->70%, CD: 03/15->06/15. Mar.15: 90%¦June2015: Compl:90%->100
- 4288: SP#65 completion 09/14=>12/14. Moved to Rel-14. TR 22.815v100 for Information. Linked to Rel-9 Feature PWS. Dec.14:70->100%
- 4289: SP#65 moved to Rel-14. Linked to SA3 Rel-11 TR 33.838 PUCI and Rel-12 ongoing study TR 33.831 (FS_SPOOF). Dec.14: 70->90, CD: 12/14->03/15. Mar.15: 100%
- 4290: SP#65 moved to Rel-14. Linked to Rel-12 SA2 TR 23.843 Study on Core Network Overload solutions (FS_CNO) and Rel-13 Feature Service Exposure and Enablement Support (SEES). Dec.14: 30->70%. Mar.15: 90%¦June2015: Compl:90%->100
- 4291: SP#65 completion 12/14=>03/15. Moved to Rel-14. Linked to Rel-13 Feature SEES and Rel-13 TR 22.806 (FS_ACDC). Dec.14: 30->60%, WID SP-140246->SP-140758, CD: 12/14->03/15. Mar.15: CD: 03/13->06/15. 60->90%¦June2015: Compl:90%->100
- 4292: 1/4/15:TR number added¦June2015: Compl:0%->40¦07/09/15: 40%->60¦7/12/15: 60%->100
- 4293: 03/07/15: Compl:0%->10% 03/07/15: Stat Rep: -->RP-150780 03/07/15: Release: Rel-13->Rel-14 29/09/15: Compl:10%->25% 29/09/15: Stat Rep: RP-150780->RP-151286 22/3/16: Compl:50%->60%;
- 4294: 7/9/15: TR added 29/09/15: Compl:0%->1% 29/09/15: Stat Rep: -->RP-151436 ¦22/3/16: Compl:10%->40%¦22/3/16: WID: RP-151104->RP-1600921/7/16: Compl
- 4295: Aug2015: 0%->25¦07/09/15: 25%->30¦7/12/15: 30%->80, FCD: 12/15->03/16, MOVED TO REL-14¦7/3/16: 80%->100
- 4296: 26/9/16: Compl:0%->10%. 1/12/16: Deleted: 720085 was allocated twice: to FS_LTE_SON-ECOMP (now in 720063) and to ROBVOLTE (now in 720301)
- 4297: 7/3/16: 0%->100¦5/6/17: 71%->100
- 4298: 11/6/16: 0%->10¦19/9/16: 10%->60¦1/12/16: 60%->100
- 4299: 11/6/16: 0%->35. Name corrected¦19/9/16: WID:SP-160201->SP-160525¦FCD: 09/16->12/16¦19/9/16: 35%->60¦23/9/16: WID:SP-160525->SP-160728¦1/12/16: 60%->95¦3/3/17: 95%->100
- 4300: 1/7/16: Compl:0%->75%1/7/16: WI¦28/7/16: 36.750 added¦26/9/16: Compl:75%->100%
- 4301: ¦1/7/16: Compl:0%->30%¦26/9/16: Compl:30%->80%¦ 20/12/16: Compl:80%->100%¦
- 4302: intention to capture results in existing TR 36.714-02-01 ¦1/7/16: Compl:0%->30%¦26/9/16: Compl:30%->50%¦20/12/16: Compl ¦21/3/17: Compl:8
- 4303: 1/7/16: Compl:0%->25%1/26/9/16: Compl:25%->40%¦20/12/16: Compl:40%->70% ¦21/3/17: Compl:70%->100%
- 4304: ¦1/7/16: Compl:0%->15%¦26/9/16: Compl:15%->30%¦20/12/16: Compl:30%->80%21/3/17: Compl:80%->100%
- 4305: 11/03/15: WID changed from FS_DCCII to FS_DCCHII as per SA5 chair request¦June2015: Compl:0%->7¦07/09/15: 7%->15¦7/12/15: 15%->60, FCD: 09/15->03/16¦7/3/16: 60%->100. 22/3/16: Rel-13->Rel-14
- 4306: TR number added. Mar. 15: 0->5%¦June2015: Compl:5%->10¦Aug2015: 10%->15¦07/09/15: 15%->30, FCD: 12/15->03/16¦7/3/16: 30%->40. 15/4/16: moved from Rel-13. FCD: 11/3/16->23/9/16¦11/6/16: 40%->50¦19/9/16: 50%->70, FCD:09/16->12/16¦1/12/16: 70%->80;
- 4307: 28/7/16: 26.880 added¦19/9/16: 0%->30, FCD: 12/16->03/17¦1/12/16: 30%->60¦6/3/17: 60%->100
- 4308: 28/7/16: 26.981 added¦19/9/16: 0%->30¦1/12/16: 30%->50¦1/12/16: FCD:12/16->03/17¦6/3/17: 50%->100
- 4309: 26/9/16: Compl:0%->30%¦6/10/16: 36.745 added¦20/12/16: Compl:30%->100%
- 4310: continuation of GERAN SI UID 590034, DOMIMO under RAN626/9/16: Compl:0%->100%
- 4311: 11/3: WID: SP-150050->150142¦June2015: Compl:0%->20¦07/09/15: 20%->60. 07/12/15: Created by MCC as BB to dissociate SA1 versus SA2 aspects

| ID | WBS | Task | Type | Duration | Start | Finish | Complete | Baseline start | Baseline finish | Baseline duration | Constraint | Resources | Work | Actual work | Acronym | PCG approved | Impacted TSs and TRs | WI rapporteur name | WI rapporteur e-mail | Release | TSG approved | MCC resp | Special Focus Doc | Acronym_3GU_Export | Status Report | TSG stopped |
| --- | --- | --- | --- | --- | --- | --- | --- | --- | --- | --- | --- | --- | --- | --- | --- | --- | --- | --- | --- | --- | --- | --- | --- | --- | --- | --- |
| 4312 | 1719 | **Study on Stage 1 for New Services and Markets Technology Enablers** |  | 512.5d? | 2015-02-02 A | 2016-06-10 A | 100% |  |  |  |  | S1 | 10120h | 10120h | FS_SMARTER | 34 | New 22.891 | Adrian Neal (Vodafone) | adrian.neal@vodafone.com | Rel-14 | 67 |  |  |  |  |  |
| 4313 | 1719.1 | General aspects of FS_SMARTER SA1 |  | 270d? | 2015-02-02 A | 2016-02-12 A | 100% |  |  |  | finish no earlier than 2016-02-12 | S1 | 2160h | 2160h | FS_SMARTER | 34 | New 22.891 | Adrian Neal (Vodafone) | adrian.neal@vodafone.com | Rel-14 | 67 |  |  |  |  |  |
| 4314 | 1719.2 | FS_SMARTER – massive Internet of Things |  | 160d? | 2015-11-02 A | 2016-06-10 A | 100% |  |  |  | finish no earlier than 2016-06-10 | S1 | 1280h | 1280h | FS_SMARTER-mIoT | 36 | New 22.861 | Adrian Neal (Vodafone) | adrian.neal@vodafone.com | Rel-14 | 70 |  |  |  |  |  |
| 4315 | 1719.3 | FS_SMARTER – Critical Communications |  | 160d? | 2015-11-02 A | 2016-06-10 A | 100% |  |  |  | finish no earlier than 2016-06-10 | S1 | 1280h | 1280h | FS_SMARTER-CRIC | 36 | New 22.862 | Kanerva, Mikko | mikko.kanerva@nokia.com | Rel-14 | 70 |  |  |  |  |  |
| 4316 | 1719.4 | FS_SMARTER – enhanced Mobile Broadband |  | 160d? | 2015-11-02 A | 2016-06-10 A | 100% |  |  |  | finish no earlier than 2016-06-10 | S1 | 1280h | 1280h | FS_SMARTER-eMBB | 36 | New 22.863 | Laurence Meriau | laurence.meriau@huawei.com | Rel-14 | 70 |  |  |  |  |  |
| 4317 | 1719.5 | FS_SMARTER – Network Operation |  | 160d? | 2015-11-02 A | 2016-06-10 A | 100% |  |  |  | finish no earlier than 2016-06-10 | S1 | 1280h | 1280h | FS_SMARTER-NEO | 36 | New 22.864 | Lu Lu | lulu@chinamobile.com | Rel-14 | 70 |  |  |  |  |  |
| 4318 | 1720 | SA2 aspects on Study on Architecture and Security for next Generation System |  | 270d? | 2015-12-07 A | 2016-12-15 A | 100% |  |  |  | finish no earlier than 2016-12-15 | S2 | 2160h | 2160h | FS_NextGen | 36 | 23.799 | suntao@chinamobile.com, devaki.chandramouli@nokia.com | suntao@chinamobile.com, devaki.chandramouli@nokia.com | Rel-14 | 70 |  |  |  |  |  |
| 4319 | 1721 | Study on New Radio (NR) Access Technology |  | 263d? | 2016-03-15 A | 2017-03-15 A | 100% |  |  |  | finish no earlier than 2017-03-15 | R1 | 2104h | 2104h | FS_NR_newRAT | 36 | 38.801; 38.912; 38.802; 38.901; 38.805 | NTT DOCOMO |  | Rel-14 | 71 |  |  |  |  |  |
| 4320 | 1722 | --- RELEASE 13 --- |  | 253.25d? | 2013-12-11 A | 2014-11-25 A | 100% | 2015-04-14 | 2015-12-25 | 183.25d? |  | SP; RP; CP; GP | 8104h | 8104h |  |  |  |  |  | Rel-13 |  |  |  |  |  |  |
| 4321 | 1723 | **Mission Critical Push To Talk over LTE (MCPTT)** |  | 1706.12d? | 2013-12-11 A | 2018-06-15 A | 100% | 2013-12-11 | 2015-06-17 | 397d? |  |  | 39400h | 39400h | MCPTT | 32 | Stage 1/2; | NIST | david.cypher@nist.gov | Rel-13 | 62 | Alain | Public Safety (A-A) | MCPTT |  |  |
| 4322 | 1723.1 | Study on Application Architecture to support MCPTT |  | 326d? | 2014-06-23 A | 2015-09-16 A | 100% | 2014-06-18 | 2014-12-10 | 126d? | finish no earlier than 2015-09-16 | S6 | 2608h | 2608h | MCPTT | 33 | New 23.779 | Yannick Lair | yannick.lair@lge.com | Rel-13 | 64 |  | Public Safety (A-A) |  |  |  |
| 4323 | 1723.2 | SA2 Study on Architecture Enhancements at the EPS and IMS Level to Support MCPTT |  | 69d? | 2015-03-13 A | 2015-06-17 A | 100% |  |  |  | finish no earlier than 2015-06-17 | S2 | 552h | 552h | MCPTT | 34 |  | Randy Bloomfield (randy@its.bldrdoc.gov) | Randy Bloomfield (randy@its.bldrdoc.gov) | Rel-13 | 67 |  |  |  |  |  |
| 4324 | 1723.3 | Study on Security Enhancements for MCPTT |  | 261d? | 2015-03-13 A | 2016-03-11 A | 100% |  |  |  | finish no earlier than 2016-03-11 | S3 | 2088h | 2088h | MCPTT | 34 | 33.879; 33.280; 39.880 | Peter Haigh (peter.haigh at cesg.gsi.gov.uk) | Peter Haigh (peter.haigh at cesg.gsi.gov.uk) | Rel-13 | 67 |  |  |  |  |  |
| 4325 | 1723.4 | Study on media, codecs and MBMS enhancements for MCPTT |  | 326d? | 2014-12-12 A | 2016-03-11 A | 100% |  |  |  | finish no earlier than 2016-03-11 | S4 | 2608h | 2608h | MCPTT | 34 | New 26.879 | Zhiming Li (lizhiming@huawei.com) | Zhiming Li (lizhiming@huawei.com) | Rel-13 | 67 |  |  |  |  |  |
| 4326 | 1723.5 | Stage 1 for MCPTT |  | 263d? | 2013-12-11 A | 2014-12-12 A | 100% | 2013-12-11 | 2014-12-10 | 261d? | finish no earlier than 2014-12-12 | S1 | 2104h | 2104h | MCPTT | 32 | New 22.179 | NIST | david.cypher@nist.gov | Rel-13 | 62 | Alain | Public Safety (A-A) |  | SP-140502 |  |
| 4327 | 1723.6 | Functional architecture and information flows to support MCPTT |  | 127d? | 2015-06-18 A | 2015-12-11 A | 100% | 2014-06-18 | 2014-12-10 | 126d? | finish no earlier than 2015-12-11 | S6 | 1016h | 1016h | MCPTT | 33 | New 23.179 | Yannick Lair | yannick.lair@lge.com | Rel-13 | 64 |  | Public Safety (A-A) |  |  |  |
| 4328 | 1723.7 | Security of MCPTT |  | 326d? | 2014-12-12 A | 2016-03-11 A | 100% |  |  |  | finish no earlier than 2016-03-11 | S3 | 2608h | 2608h | MCPTT | 34 | 33.179 | Peter Haigh (peter.haigh at cesg.gsi.gov.uk) | Peter Haigh (peter.haigh at cesg.gsi.gov.uk) | Rel-13 | 66 |  |  |  |  |  |
| 4329 | 1723.8 | MCPTT Codecs and media handling |  | 267d? | 2015-03-05 A | 2016-03-11 A | 100% |  |  |  | finish no earlier than 2016-03-11 | S4 | 2136h | 2136h | MCPTT | 34 | 26.346; new 26.179 | Zhiming Li (lizhiming@huawei.com) | Zhiming Li (lizhiming@huawei.com) | Rel-13 | 67 |  |  |  |  |  |
| 4330 | 1723.9 | **MCPTT protocol aspects** |  | 308.38d? | 2015-09-07 A | 2016-06-30 A | 100% |  |  |  |  | ct | 17408h | 17408h | MCPTT-CT | 35 |  | Keith Drage, Alcatel-Lucent |  | Rel-13 | 69 |  |  |  |  |  |
| 4331 | 1723.9.1 | **CT1 aspects for MCPTT protocol aspects** |  | 193.5d? | 2015-09-07 A | 2016-03-11 A | 100% |  |  |  |  | C1 | 10800h | 10800h | MCPTT-CT | 35 | 24.379; 24.380 24.38; 24.382; 24.383; 24.384; 24.229 | Samsung, Ricky Kaura | ricky.kaura@samsung.com | Rel-13 | 69 |  |  |  |  |  |
| 4332 | 1723.9.1.1 | Call Control – On Network |  | 135d? | 2015-09-07 A | 2016-03-11 A | 100% |  |  |  | finish no earlier than 2016-03-11 | C1 | 1080h | 1080h | MCPTT-CT | 35 | 24.379 | Samsung, Ricky Kaura | ricky.kaura@samsung.com | Rel-13 | 69 |  |  |  |  |  |
| 4333 | 1723.9.1.2 | Call Control – Off Network |  | 135d? | 2015-09-07 A | 2016-03-11 A | 100% |  |  |  | finish no earlier than 2016-03-11 | C1 | 1080h | 1080h | MCPTT-CT | 35 | 24.379 | Samsung, Ricky Kaura | ricky.kaura@samsung.com | Rel-13 | 69 |  |  |  |  |  |
| 4334 | 1723.9.1.3 | Floor Control – On Network |  | 135d? | 2015-09-07 A | 2016-03-11 A | 100% |  |  |  | finish no earlier than 2016-03-11 | C1 | 1080h | 1080h | MCPTT-CT | 35 | 24.380 | Samsung, Ricky Kaura | ricky.kaura@samsung.com | Rel-13 | 69 |  |  |  |  |  |
| 4335 | 1723.9.1.4 | Floor Control – Off Network |  | 135d? | 2015-09-07 A | 2016-03-11 A | 100% |  |  |  | finish no earlier than 2016-03-11 | C1 | 1080h | 1080h | MCPTT-CT | 35 | 24.380 | Samsung, Ricky Kaura | ricky.kaura@samsung.com | Rel-13 | 69 |  |  |  |  |  |
| 4336 | 1723.9.1.5 | Broadcast – Call Control and Floor Control |  | 135d? | 2015-09-07 A | 2016-03-11 A | 100% |  |  |  | finish no earlier than 2016-03-11 | C1 | 1080h | 1080h | MCPTT-CT | 35 | 24.379; 24.380 | Samsung, Ricky Kaura | ricky.kaura@samsung.com | Rel-13 | 69 |  |  |  |  |  |
| 4337 | 1723.9.1.6 | Group management |  | 135d? | 2015-09-07 A | 2016-03-11 A | 100% |  |  |  | finish no earlier than 2016-03-11 | C1 | 1080h | 1080h | MCPTT-CT | 35 | 24.381 | Samsung, Ricky Kaura | ricky.kaura@samsung.com | Rel-13 | 69 |  |  |  |  |  |
| 4338 | 1723.9.1.7 | Identity management |  | 135d? | 2015-09-07 A | 2016-03-11 A | 100% |  |  |  | finish no earlier than 2016-03-11 | C1 | 1080h | 1080h | MCPTT-CT | 35 | 24.382 | Samsung, Ricky Kaura | ricky.kaura@samsung.com | Rel-13 | 69 |  |  |  |  |  |
| 4339 | 1723.9.1.8 | Management Object |  | 135d? | 2015-09-07 A | 2016-03-11 A | 100% |  |  |  | finish no earlier than 2016-03-11 | C1 | 1080h | 1080h | MCPTT-CT | 35 | 24.383 | Samsung, Ricky Kaura | ricky.kaura@samsung.com | Rel-13 | 69 |  |  |  |  |  |
| 4340 | 1723.9.1.9 | Configuration management |  | 135d? | 2015-09-07 A | 2016-03-11 A | 100% |  |  |  | start no earlier than 2015-09-07 | C1 | 1080h | 1080h | MCPTT-CT | 36 | 24.384 | Samsung, Ricky Kaura | ricky.kaura@samsung.com | Rel-13 | 71 |  |  |  |  |  |
| 4341 | 1723.9.2 | CT3 aspects for MCPTT protocol aspects |  | 135d? | 2015-09-07 A | 2016-03-11 A | 100% |  |  |  | finish no earlier than 2016-03-11 | C3 | 1080h | 1080h | MCPTT-CT | 35 | 29.165 | Alcatel-Lucent, Keith Drage | keith.drage@alcatel-lucent.com | Rel-13 | 69 |  |  |  |  |  |
| 4342 | 1723.9.3 | CT4 aspects for MCPTT protocol aspects |  | 135d? | 2015-09-07 A | 2016-03-11 A | 100% |  |  |  | finish no earlier than 2016-03-11 | C4 | 1080h | 1080h | MCPTT-CT | 35 | 23.003; 23.008; 29.283 | Alcatel-Lucent, Keith Drage | keith.drage@alcatel-lucent.com | Rel-13 | 69 |  |  |  |  |  |
| 4343 | 1723.9.4 | CT6 aspects for MCPTT protocol aspects |  | 135d? | 2015-09-07 A | 2016-03-11 A | 100% |  |  |  | finish no earlier than 2016-03-11 | C6 | 1080h | 1080h | MCPTT-CT | 36 | 31.102; 31.103 | Alcatel-Lucent, Keith Drage | keith.drage@alcatel-lucent.com | Rel-13 | 70 |  |  |  |  |  |
| 4344 | 1723.9.5 | (IETF) IANA Registration of New SIP Resource- Priority Namespace for MCPTT |  | 103d? | 2016-02-10 A | 2016-06-30 A | 100% |  |  |  | start no earlier than 2016-02-10 | C1-IETF | 824h | 824h | MCPTT-CT | 36 | draft-holmberg-dispatch-mcptt-rp-namespace | Ericsson | christer.holmberg@ericsson.com | Rel-13 | 71 |  |  |  |  |  |
| 4345 | 1723.9.6 | (IETF) OAuth 2.0 Token Exchange (draft-ietf-oauth-token-exchange) --> RFC 8693 |  | 103d? | 2016-02-10 A | 2016-06-30 A | 100% |  |  |  | start no earlier than 2016-02-10 | C1-IETF | 824h | 824h | MCPTT-CT | 44 |  |  |  | Rel-13 | 87 |  |  |  |  |  |
| 4346 | 1723.10 | IMS Profile to support MCPTT |  | 130d? | 2015-09-14 A | 2016-03-11 A | 100% |  |  |  | finish no earlier than 2016-03-11 | C1 | 1040h | 1040h | MCPTT-Prof | 35 | 24.980 | Huawei, PATEL Milan | Milan.Patel@huawei.com | Rel-13 | 69 |  |  |  |  |  |
| 4347 | 1723.11 | UE Conformance Test Aspects - Support for Mission Critical Push To Talk over LTE (MCPTT) |  | 392d? | 2016-12-15 A | 2018-06-15 A | 100% |  |  |  | finish no earlier than 2018-06-15 | R5 | 3136h | 3136h | MCPTT-ConTest | 38 | 36.579-5 | US Department of Commerce |  | Rel-13 | 74 |  |  |  |  |  |
| 4348 | 1723.12 | Deleted: SA2 aspects for MCPTT |  | 1d? | 2015-03-13 A | 2015-03-13 A | 100% | 2014-06-18 | 2015-06-17 | 261d? | finish no earlier than 2015-03-13 | S2 | 8h | 8h | MCPTT | 33 | New 23.179 | Randy Bloomfield (randy@its.bldrdoc.gov) | Randy Bloomfield (randy@its.bldrdoc.gov) | Rel-13 | 64 |  | Public Safety (A-A) |  |  | SP-69 |
| 4349 | 1723.13 | Deleted (duplicated): Application Architecture to support MCPTT | milestone | 0d? | 2015-03-13 A | 2015-03-13 A | 100% |  |  |  | finish no earlier than 2015-03-13 | S6 |  |  | MCPTT | 34 |  | U.S. Department of Commerce | Randy Bloomfield (randy@its.bldrdoc.gov) | Rel-13 | 67 |  |  |  |  | SP-69 |
| 4350 | 1723.14 | Deleted (duplicated): SA6 aspects for MCPTT |  | 261d? | 2014-12-12 A | 2015-12-11 A | 100% |  |  |  | finish no earlier than 2015-12-11 | S6 | 2088h | 2088h | MCPTT | 34 |  | David Cypher (david.cypher at nist.gov) | David Cypher (david.cypher at nist.gov) | Rel-13 | 66 |  |  |  |  | SP-69 |

Notes:
- 4313: 7/12/15: 60%->85¦2/3/16: 85%->95¦7/6/17: 95%->100
- 4314: 2/3/16: 35%->65¦9/6/16: 65%->100
- 4315: 2/3/16: 15%->60¦9/6/16: 60%->95¦7/6/17: 95%->100
- 4316: 2/3/16: 40%->75¦9/6/16: 75%->100
- 4317: 2/3/16: 30%->60¦19/9/16: 60%->100
- 4318: 28/1/16: 23.799 added¦Acronym corrected ("NexGen"->"NextGen")¦7/3/16: 5%->15¦10/3/16: WID:SP-150853->SP-160200. Name changed from "Study on Architecture for next Generation System"¦9/6/16: 15%->35¦19/9/16: 35%->64¦22/9/16: WID:SP-160227->SP-16072
- 4319: includes RAN TR 38.801¦1/7/16: Compl:0%->10%¦1/7/16: CD:Thu 15/06/17->Wed 15/03/17¦1/7/16: WID: RP-160671->RP-161214¦1/7/16: Release: Rel-15->Rel-14¦28/7/16: 38.802 added¦26/9/16: Compl:10%->20%¦26/9/16: WID: RP-161214->RP-161596. 2/12/16: Moved
- 4320: -
- 4321: SP#65 updated WID SP-140276=>SP-140435. Mar 15: WID: SP-140879->SP-150164. 4/15: S4 added. 6/15: WID updated
- 4322: SP#65 completion 12/14=>06/15. Updated WID SP-140276=>SP-140435. Dec.14: 2->20%. Mar 15: WID: SP-140879->SP-150095. Mar15: 30%. Transferred to SA6. June 15: FCD shifted to Sept,WID updated¦June2015: Compl:24%->50¦June2015: Compl:50%->70. 3/8/15: Rapp
- 4323: Mar 2015: WID: SP-140879->SP-150164.¦June2015: Compl:0%->30, WID updated¦07/09/15: 30%->100, "To be confirmed" deleted, since SA2 has completed it.
- 4324: Mar 2015: WID: SP-140879->SP-150164. Name clarified.6/15: WID updated¦7/12/15: 0%->75¦10/12/15: FCD->March, ES in SP-150729¦7/3/16: 75%->80¦28/7/16: 33.280 added¦28/7/16: 39.880 added¦1/12/16: 80%->100
- 4325: Mar 2015: WID: SP-140879->SP-150164. Name clarified. 5/5/15: TR number added¦June2015: Compl:0%->5, WID updated¦Aug2015: 5%->15¦07/09/15: 15%->40¦7/12/15: 40%->80, FCD: 12/15->03/16¦7/3/16: 80%->85; 26/6/20: 85%->100
- 4326: SP#65 completion 09/14=>12/14. Exception in SP-140502. TS 22.179v100 for Information. Completed. Mar 15: WID: SP-140879->SP-150164. 6/15: WID updated
- 4327: June2015: added as per SP-150356¦June2015: Compl:0%->15. 31 July: Rapporteur corrected. 3/8/15: name aligned to the WID¦07/09/15: 15%->50¦07/09/15: 50%->85. 15/09/15: FCD: 09/15->12/15¦7/3/16: 85%->100
- 4328: Mar 2015: WID: SP-140879->SP-150164. Name clarified. FCD: 03/2016->12/2015¦June2015: Compl:5%->15, WID updated. 7/9/15: TS number added¦7/12/15: 15%->60. FCD -> 03/16, ES in SP-150729¦7/3/16: 60%->85¦1/12/16: 85%->98¦6/3/17: 98%->100
- 4329: Mar 2015: WID: SP-140879->SP-150164. Name clarified. FCD: 03/2016->12/2015¦June2015: Compl:0%->5, WID updated¦Aug2015: 5%->15¦07/09/15: 15%->40. ES in SP-150663¦7/3/16: 40%->85; 26/6/20: 85%->100
- 4330: 7/12/15: WID:CP-150587->CP-150793¦28/1/16: 24.384 added;
- 4331: 7/12/15: WID:CP-150587->CP-150793¦7/3/16: WID:CP-150863->CP-160160¦5/12/16: WID:CP-160160->CP-160817
- 4332: Proposed by Atle after some talks with several interested parties¦7/12/15: 0%->50¦7/12/15: WID:CP-150587->CP-150863. FCD->03/16, ES in CP-150721¦7/3/16: 50%->100¦7/3/16: WID:CP-150863->CP-160160¦5/12/16: WID:CP-160160->CP-160817
- 4333: Proposed by Atle after some talks with several interested parties¦7/12/15: 0%->75¦7/12/15: WID:CP-150587->CP-150863. FCD->03/16, ES in CP-150721¦7/3/16: 75%->100¦7/3/16: WID:CP-150863->CP-160160¦5/12/16: WID:CP-160160->CP-160817
- 4334: Proposed by Atle after some talks with several interested parties¦7/12/15: 0%->80¦7/12/15: WID:CP-150587->CP-150863. FCD->03/16, ES in CP-150721¦7/3/16: 80%->100¦7/3/16: WID:CP-150863->CP-160160¦5/12/16: WID:CP-160160->CP-160817
- 4335: Proposed by Atle after some talks with several interested parties¦7/12/15: 0%->85¦7/12/15: WID:CP-150587->CP-150863. FCD->03/16, ES in CP-150721¦7/3/16: 85%->100¦7/3/16: WID:CP-150863->CP-160160¦5/12/16: WID:CP-160160->CP-160817
- 4336: Proposed by Atle after some talks with several interested parties¦7/12/15: 0%->50¦7/12/15: WID:CP-150587->CP-150863. FCD->03/16, ES in CP-150721¦7/3/16: 50%->100¦7/3/16: WID:CP-150863->CP-160160¦5/12/16: WID:CP-160160->CP-160817
- 4337: Proposed by Atle after some talks with several interested parties¦7/12/15: 0%->75¦7/12/15: WID:CP-150587->CP-150863. FCD->03/16, ES in CP-150721¦7/3/16: 75%->100¦7/3/16: WID:CP-150863->CP-160160¦5/12/16: WID:CP-160160->CP-160817
- 4338: Proposed by Atle after some talks with several interested parties¦7/12/15: WID:CP-150587->CP-150863. FCD->03/16, ES in CP-150721¦7/3/16: 0%->100¦7/3/16: WID:CP-150863->CP-160160¦5/12/16: WID:CP-160160->CP-160817
- 4339: Proposed by Atle after some talks with several interested parties¦7/12/15: 0%->10¦7/12/15: WID:CP-150587->CP-150863. FCD->03/16, ES in CP-150721¦7/3/16: 10%->100. Name changed from "Configuration management"¦7/3/16: WID:CP-150863->CP-160160¦5/12/1
- 4340: Introduced from CT1 WP update in 03/16¦7/3/16: WID:CP-150863->CP-160160¦5/12/16: WID:CP-160160->CP-160817
- 4341: 7/12/15: 0%->70¦7/12/15: WID:CP-150587->CP-150863. FCD -> 03/16, ES in CP-150643¦7/3/16: 70%->100¦7/3/16: WID:CP-150863->CP-160160¦5/12/16: WID:CP-160160->CP-160817
- 4342: 7/12/15: WID:CP-150587->CP-150863. FCD -> 03/16, ES in CP-150864¦7/3/16: 0%->100¦7/3/16: WID:CP-150863->CP-160160¦5/12/16: WID:CP-160160->CP-160817
- 4343: 7/12/15: WID:CP-150587->CP-150863. FCD -> 03/16, ES in CP-150866¦7/3/16: 0%->100¦7/3/16: WID:CP-150863->CP-160160¦5/12/16: WID:CP-160160->CP-160817
- 4344: 5/12/16: WID:CP-160160->CP-160817
- 4346: 12/15: TR # added¦7/12/15: 0%->60¦7/12/15: WID:CP-150500->CP-150794. FCD -> 03/16, ES in CP-150722¦7/3/16: 60%->100
- 4347: 6/1/17: acronym changed from "MCPTT-UEConTest" ¦21/3/17: Compl:0%->5%¦21/3/17: 36.579-5 added;
- 4348: Mar 2015: transferred to SA6. Was 06/14 to 06/15. 6/15: WID updated
- 4349: Mar 2015: WID: SP-140879->SP-150164. Name clarified.6/15: WID updated. 7/15: removed since duplicates 640143 and 660054 (only 640143 is kept)
- 4350: Mar 2015: WID: SP-140879->SP-150164. Name clarified. 6/15: WID updated. 31 July: deleted since duplicates 640143 and 670031 (only 640143 is kept)

| ID | WBS | Task | Duration | Start | Finish | Complete | Baseline start | Baseline finish | Baseline duration | Constraint | Resources | Work | Actual work | Acronym | PCG approved | Impacted TSs and TRs | WI rapporteur name | WI rapporteur e-mail | Release | TSG approved | MCC resp | Status Report | Special Focus Doc | Acronym_3GU_Export |
| --- | --- | --- | --- | --- | --- | --- | --- | --- | --- | --- | --- | --- | --- | --- | --- | --- | --- | --- | --- | --- | --- | --- | --- | --- |
| 4351 | 1724 | **MBMS Extensions and Profiling** | 292d? | 2015-03-05 A | 2015-12-11 A | 100% |  |  |  |  | S4 | 4848h | 4848h | MEPRO | 34 | 26.346; new 26.852 | Imed Bouazizi, Samsung and Thorsten Lohmar, Ericsson | i.bouazizi@samsung.com, thorsten.lohmar@ericsson.com | Rel-13 | 67 |  |  |  |  |
| 4352 | 1724.1 | TR on Profiling and Extensions of MBMS | 202d? | 2015-03-05 A | 2015-12-11 A | 100% |  |  |  | finish no earlier than 2015-12-11 | S4 | 1616h | 1616h | MEPRO | 34 | new 26.852 | Imed Bouazizi, Samsung and Thorsten Lohmar, Ericsson | i.bouazizi@samsung.com, thorsten.lohmar@ericsson.com | Rel-13 | 67 |  |  |  |  |
| 4353 | 1724.2 | Specification of MBMS Extensions and Profiling | 202d? | 2015-03-05 A | 2015-12-11 A | 100% |  |  |  | start no earlier than 2015-03-05 | S4 | 1616h | 1616h | MEPRO | 34 | 26.346 | Imed Bouazizi, Samsung and Thorsten Lohmar, Ericsson | i.bouazizi@samsung.com, thorsten.lohmar@ericsson.com | Rel-13 | 67 |  |  |  |  |
| 4354 | 1725 | **Isolated E-UTRAN Operation for Public Safety** | 761.88d? | 2014-03-07 A | 2016-03-11 A | 100% | 2014-03-07 | 2014-09-17 | 139d? |  | S1 | 8600h | 8600h | IOPS | 32 | New 22.346 | General Dynamics | paul.piggin@gd-broadband.com | Rel-13 | 63 | Alain | S1-143304 | Public Safety (A-A) | IOPS |
| 4355 | 1725.1 | Stage 1 fo Isolated E-UTRAN Operation for Public Safety | 140d? | 2014-03-07 A | 2014-09-17 A | 100% | 2014-03-07 | 2014-09-17 | 139d? | finish no earlier than 2014-09-17 | S1 | 1120h | 1120h | IOPS | 32 | New 22.346 | General Dynamics | paul.piggin@gd-broadband.com | Rel-13 | 63 | Alain | S1-143304 | Public Safety (A-A) | IOPS |
| 4356 | 1725.2 | Stage 2 for Isolated E-UTRAN Operation for Public Safety | 140d? | 2015-06-18 A | 2015-12-30 A | 100% | 2014-03-07 | 2014-09-17 | 139d? | start no earlier than 2015-06-18 | S2 | 1120h | 1120h | IOPS | 32 | 23.401 | Phil Young | phil.young@gd-broadband.com | Rel-13 | 63 | Alain |  | Public Safety (A-A) | IOPS |
| 4357 | 1725.3 | Security aspects for Isolated E-UTRAN Operation for Public Safety | 76d? | 2015-09-16 A | 2015-12-30 A | 100% | 2014-03-07 | 2014-09-17 | 139d? | start no earlier than 2015-09-16 | S3 | 608h | 608h | IOPS | 32 | 33.401 | General Dynamics | paul.piggin@gd-ms.uk | Rel-13 | 63 | Alain |  | Public Safety (A-A) | IOPS |
| 4358 | 1725.4 | **CT aspects for IOPS** | 135.5d? | 2015-11-02 A | 2016-03-11 A | 100% |  |  |  |  | C6 | 1520h | 1520h | IOPS-CT | 36 |  | Heiko Kruse, Morpho Cards GmbH | heiko.kruse@mrpho.com | Rel-13 | 70 |  |  |  |  |
| 4359 | 1725.4.1 | CT6 aspects for IOPS | 95d? | 2015-11-02 A | 2016-03-11 A | 100% |  |  |  | finish no earlier than 2016-03-11 | C6 | 760h | 760h | IOPS-CT | 36 | 31.102 | Heiko Kruse, Morpho Cards GmbH | heiko.kruse@mrpho.com | Rel-13 | 70 |  |  |  |  |
| 4360 | 1726 | Service Requirements Maintenance for Group Communication System Enablers for LTE | 67d? | 2014-06-18 A | 2014-09-17 A | 100% | 2014-06-18 | 2014-09-17 | 66d? | finish no earlier than 2014-09-17 | S1 | 536h | 536h | SRM_GCSE_LTE | 33 | 22.468 | Nokia Networks | Juergen.Merkel@nsn.com | Rel-13 | 64 |  | S1-143307 | Public Safety (A-A) | SRM_GCSE_LTE |
| 4361 | 1727 | Enhanced Calling Information Presentation | 330d? | 2014-09-15 A | 2015-12-16 A | 100% | 2013-12-11 | 2014-09-17 | 201d? | finish no earlier than 2015-12-16 | S1 | 2640h | 2640h | ECIP | 32 | 22.182 (CAT); 22.183 (CRS) | China Mobile | LI Xiaofan (lixiaofan@chinamobile.com | Rel-13 | 62 | Alain | S1-143311 |  | ECIP |
| 4362 | 1728 | **Flexible Mobile Service Steering** | 563d? | 2014-09-15 A | 2016-03-11 A | 100% | 2013-12-11 | 2014-09-17 | 202d? |  | S1; S2 | 6367.76h | 6367.76h | FMSS | 33 | 22.101 | China Mobile | Lu Lu (lulu@chinamobile.com) | Rel-13 | 65 | Alain | S1-143310 |  | FMSS |
| 4363 | 1728.1 | Stage 1 for Flexible Mobile Service Steering | 3d? | 2014-09-15 A | 2014-09-17 A | 100% | 2013-12-11 | 2014-09-17 | 202d? | start no earlier than 2014-09-15 | S1 | 23.85h | 23.85h | FMSS-ST1 | 33 | 22.101 | China Mobile | Lu Lu (lulu@chinamobile.com) | Rel-13 | 65 | Alain | S1-143310 |  | FMSS |
| 4364 | 1728.2 | Flexible Mobile Service Steering TR Phase | 134d? | 2014-12-12 A | 2015-06-17 A | 100% |  |  |  | finish no earlier than 2015-06-17 | S2 | 1072h | 1072h | FMSS-SA2TR | 34 | 23.718 | Lu Lu, China Mobile | lulu@chinamobile.com | Rel-13 | 66 |  |  |  |  |
| 4365 | 1728.3 | Flexible Mobile Service Steering - Stage 2 | 134d? | 2014-12-12 A | 2015-06-17 A | 100% |  |  |  | start no earlier than 2014-12-12 | S2 | 1072h | 1072h | FMSS-SA2 | 34 |  | Lu Lu, China Mobile | lulu@chinamobile.com | Rel-13 | 66 |  |  |  |  |
| 4366 | 1728.4 | CT3 Aspect of Flexible Mobile Service Steering | 133d? | 2015-09-09 A | 2016-03-11 A | 100% |  |  |  | finish no earlier than 2016-03-11 | C3 | 1064h | 1064h | FMSS-CT | 35 | 29.abc; 29.212; 29.213 | ZTE,Zhou Xiaoyun | zhou.xiaoyun@zte.com.cn | Rel-13 | 69 |  |  |  |  |
| 4367 | 1729 | GERAN UTRAN Sharing Enhancements | 63d? | 2014-09-19 A | 2014-12-12 A | 100% |  |  |  | finish no earlier than 2014-12-12 | S1 | 504h | 504h | GUSH | 33 | 22.101 | Telefónica | chris.friel@telefonica.com | Rel-13 | 65 |  | SP-140515 |  | GUSH |
| 4368 | 1730 | **Application specific Congestion control for Data Communication** | 655.12d? | 2014-06-18 A | 2016-03-11 A | 100% | 2014-06-18 | 2014-09-17 | 66d? |  | S1; C1 | 14808h | 14808h | ACDC | 33 | 22.011 | NTT DOCOMO | Atsushi Minokuchi (minokuchi@nttdocomo.co.jp) | Rel-13 | 64 |  | S1-143305 |  | ACDC |
| 4369 | 1730.1 | Stage 1 for Application specific Congestion control for Data Communication | 67d? | 2014-06-18 A | 2014-09-17 A | 100% | 2014-06-18 | 2014-09-17 | 66d? | finish no earlier than 2014-09-17 | S1 | 536h | 536h | ACDC-ST1 | 33 | 22.011 | NTT DOCOMO | Atsushi Minokuchi (minokuchi@nttdocomo.co.jp) | Rel-13 | 64 |  | S1-143305 |  | ACDC |
| 4370 | 1730.2 | **Stage 3 for Application specific Congestion control for Data Communication** | 480.5d? | 2014-12-04 A | 2016-03-11 A | 100% |  |  |  |  | C1 | 7472h | 7472h | ACDC-CT | 34 | 24.105; 24.301; 24.008; 27.007; 31.102 | Kim, Jaehyun, LGE | jaehyun7.kim@lge.com | Rel-13 | 66 |  |  |  |  |
| 4371 | 1730.2.1 | CT1 part of Stage 3 for Application specific Congestion control for Data Communication | 270d? | 2014-12-04 A | 2015-12-16 A | 100% |  |  |  | finish no earlier than 2015-12-16 | C1 | 2160h | 2160h | ACDC-CT | 34 | 24.105; 24.301; 24.008; 27.007; 23.122 | Kim, Jaehyun, LGE | jaehyun7.kim@lge.com | Rel-13 | 66 |  |  |  |  |
| 4372 | 1730.2.2 | CT6 part of Stage 3 for Application specific Congestion control for Data Communication | 332d? | 2014-12-04 A | 2016-03-11 A | 100% |  |  |  | finish no earlier than 2016-03-11 | C6 | 2656h | 2656h | ACDC-CT | 34 | 31.102 | Kim, Jaehyun, LGE | jaehyun7.kim@lge.com | Rel-13 | 66 |  |  |  |  |
| 4373 | 1730.3 | **RAN aspects of Application specific Congestion control for Data Communication** | 284.75d? | 2015-03-16 A | 2015-12-15 A | 100% |  |  |  |  | R2 | 3152h | 3152h | ACDC-RAN | 34 |  | LG Electronics |  | Rel-13 | 67 |  |  |  |  |
| 4374 | 1730.3.1 | Core part: RAN aspects of Application specific Congestion control for Data Communication | 197d? | 2015-03-16 A | 2015-12-15 A | 100% |  |  |  | finish no earlier than 2015-12-15 | R2 | 1576h | 1576h | ACDC-RAN-Core | 34 |  | LG Electronics |  | Rel-13 | 67 |  | RP-151275 |  |  |

Notes:
- 4351: 1/4/15: TS number added¦14/09/15: WID:SP-150099->SP-150439
- 4352: 8/4/15: line added¦June2015: Compl:0%->10¦Aug2015: 10%->15¦07/09/15: 15%->40¦14/09/15: WID:SP-150099->SP-150439¦7/12/15: 40%->100
- 4353: 8/4/15: line added¦June2015: Compl:0%->10¦Aug2015: 10%->15¦07/09/15: 15%->40¦14/09/15: WID:SP-150099->SP-150439¦7/12/15: 40%->100
- 4354: SP#65 completed. TS 22.346v100 for 1-step Approval. Triggered by Rel-13 TR 22.897 (FS_IOPS)¦14/09/15: WID:SP 150358->SP-150463
- 4355: SP#65 completed. TS 22.346v100 for 1-step Approval. Triggered by Rel-13 TR 22.897 (FS_IOPS)¦14/09/15: WID:SP 150358->SP-150463
- 4356: 07/09/15: 0%->100¦14/09/15: WID:SP 150358->SP-150463
- 4357: 07/09/15: 0%->100¦11/12/15: 0%->100
- 4359: ES in CP-150837¦7/3/16: 0%->100
- 4360: SP#65 completed. Some Rel-12 service reqs have no Stage 2/3 implementation
- 4361: SP#65 approved WID & completed. Triggered by Rel-13 TR 22.810. Linked to Multimedia Telephony Service for IMS (UID_7038), Customized Alerting Tone (CAT) UID_370028, Customized Ringing Signal (CRS) UID_380067. 31/07/15: 100%
- 4362: SP#65 WID approved & completed. Triggered by Rel-13 TR 22.808 (FS_FMSS)
- 4363: SP#65 WID approved & completed. Triggered by Rel-13 TR 22.808 (FS_FMSS). Dec.14: moved from Feature to S1 BB
- 4364: 3/3: TR number added.Mar15: 15->20%¦June2015: Compl:20%->85¦07/09/15: 85%->100
- 4365: 07/09/15: 0%->90¦07/09/15: 90%->100
- 4366: 07/09/15: 0%->20¦14/09/15: WID:CP-150488->CP-150577¦7/12/15: 20%->90¦7/12/15: WID:CP-150577->CP-150799. FCD -> 03/16. ES in CP-150646¦7/3/16: 90%->100
- 4367: SP#65 exception in SP-140515. Triggered by TR 22.852 (FS_RSE and FS_GUSH). Completed.
- 4368: SP#65 completed. Triggered by Rel-13 Study TR 22.806
- 4369: Results from MCC Split of the SA1 feature into F+BB for stage 1
- 4370: Presented at CT#66. June 2015: FCD: June->Dec 2015, WID: CP-140999-> CP-150282
- 4371: Presented at CT#66¦June2015: Compl:0%->10. June 2015: FCD: June->Dec 2015, WID: CP-140999-> CP-150282¦07/09/15: 5%->70¦7/12/15: 70%->100
- 4372: Presented at CT#66. June 2015: FCD: June->Dec 2015, WID: CP-140999-> CP-150282. 12/15: FCD -> 03/16, ES in CP-150838¦7/3/16: 0%->100
- 4374: 03/07/15: Compl:0%->25% 03/07/15: WID: RP-150512->RP-150662 03/07/15: Stat Rep: ->RP-150661 29/09/15: Compl:25%->70% 29/09/15: Stat Rep: RP-150661->RP-151275¦1/1/16: Compl:70%->100%

| ID | WBS | Task | Duration | Start | Finish | Complete | Baseline start | Baseline finish | Baseline duration | Constraint | Resources | Work | Actual work | Acronym | PCG approved | WI rapporteur name | WI rapporteur e-mail | Release | TSG approved | MCC resp | Acronym_3GU_Export | PCG stopped | TSG stopped | Status Report |
| --- | --- | --- | --- | --- | --- | --- | --- | --- | --- | --- | --- | --- | --- | --- | --- | --- | --- | --- | --- | --- | --- | --- | --- | --- |
| 4375 | 1731 | **User Plane Congestion management** | 949.38d? | 2012-09-12 A | 2015-03-18 A | 100% | 2012-02-02 | 2015-06-17 | 890d? |  | S1; S2; C3; C4 | 39368h | 39368h | UPCON | 29 | KDDI | Eriko Yoshida (er-yoshida@kddi.com) | Rel-13 | 57 | Alain | UPCON |  |  |  |
| 4376 | 1731.1 | Stage 1 for User Plane Congestion management | 129d? | 2012-09-12 A | 2013-03-06 A | 100% | 2012-02-02 | 2013-03-06 | 289d? | start no earlier than 2012-09-12 | S1 | 1032h | 1032h | UPCON-ST1 | 29 | KDDI | Eriko Yoshida (er-yoshida@kddi.com) | Rel-13 | 57 | Alain |  |  |  |  |
| 4377 | 1731.2 | TR on Stage 2 for User Plane Congestion management | 595d? | 2012-12-12 A | 2015-03-18 A | 100% | 2012-12-12 | 2014-12-10 | 525d? | finish no earlier than 2015-03-18 | S2 | 4760h | 4760h | UPCON-SA2TR | 30 | Allot | Alla Goldner (agoldner@allot.com) | Rel-13 | 58 | Maurice |  |  |  |  |
| 4378 | 1731.3 | Deleted - Stage 2 for User Plane Congestion management | 261d? | 2012-12-19 A | 2013-12-11 A | 100% | 2012-12-19 | 2013-12-11 | 261d? | finish no earlier than 2013-12-11 | S2 | 2088h | 2088h | UPCON-SA2Del | 30 | NEC | andreas.maeder@neclab.eu | Rel-13 | 58 | Maurice |  | PCG-32 | SP-62 |  |
| 4379 | 1731.4 | **BB1: RAN Downlink Traffic Differentiation, Congestion Detection and Reporting** | 384.88d? | 2014-03-07 A | 2015-03-13 A | 100% | 2014-03-07 | 2015-06-17 | 334d? |  | S2 | 10048h | 10048h | UPCON-DOTCON | 32 | Allot | Alla Goldner (agoldner@allot.com) | Rel-13 | 63 | Maurice | UPCON-DOTCON |  |  |  |
| 4380 | 1731.4.1 | Stage 2 for RAN Downlink Traffic Differentiation, Congestion Detection and Reporting | 201d? | 2014-03-07 A | 2014-12-12 A | 100% | 2014-03-07 | 2015-06-17 | 334d? | finish no earlier than 2014-12-12 | S2 | 1608h | 1608h | UPCON-DOTCON-SA2 | 32 | Allot | Alla Goldner (agoldner@allot.com) | Rel-13 | 63 | Maurice |  |  |  |  |
| 4381 | 1731.4.2 | **CT aspects of User Plane Congestion Management for BB1** | 373.38d? | 2014-03-18 A | 2015-03-13 A | 100% |  |  |  |  | C3 | 6288h | 6288h | UPCON-DOTCON-CT | 33 | Huawei | Xia Haitao (xiahaitao@huawei.com) | Rel-13 | 65 |  | UPCON-DOTCON-CT |  |  |  |
| 4382 | 1731.4.2.1 | CT3 part of CT aspects of User Plane Congestion Management for BB1 | 262d? | 2014-03-18 A | 2015-03-13 A | 100% |  |  |  | finish no earlier than 2015-03-13 | C3 | 2096h | 2096h | UPCON-DOTCON-CT | 33 | Huawei | Xia Haitao (xiahaitao@huawei.com) | Rel-13 | 65 |  |  |  |  |  |
| 4383 | 1731.4.2.2 | CT4 part of CT aspects of User Plane Congestion Management for BB1 | 262d? | 2014-03-18 A | 2015-03-13 A | 100% |  |  |  | finish no earlier than 2015-03-13 | C4 | 2096h | 2096h | UPCON-DOTCON-CT | 33 | Huawei | Xia Haitao (xiahaitao@huawei.com) | Rel-13 | 65 |  |  |  |  |  |
| 4384 | 1731.5 | Deleted - BB2: Application and Content Prioritization | 140d? | 2014-03-07 A | 2014-09-17 A | 100% | 2014-03-07 | 2015-06-17 | 334d? | finish no earlier than 2014-09-17 | S2 | 1120h | 1120h | UPCON-CONDEL | 32 | Allot | Alla Goldner (agoldner@allot.com) | Rel-13 | 63 | Maurice | UPCON-CON | PCG-33 | SP-65 |  |
| 4385 | 1731.6 | Deleted - BB3: Uplink traffic and attended/unattended traffic | 140d? | 2014-03-07 A | 2014-09-17 A | 100% | 2014-03-07 | 2015-06-17 | 334d? | finish no earlier than 2014-09-17 | S2 | 1120h | 1120h | UPCON-TRAFDEL | 32 | Allot | Alla Goldner (agoldner@allot.com) | Rel-13 | 63 | Maurice | UPCON-TRAF | PCG-33 | SP-65 |  |
| 4386 | 1732 | **Media Handling Aspects of IMS-based Telepresence** | 951.38d? | 2014-09-09 A | 2017-03-15 A | 100% |  |  |  |  |  | 15416h | 15416h | IMS_TELEP_S4 | 33 | Intel | ozgur.oyman@intel.com | Rel-13 | 65 |  | IMS_TELEP_S4 |  |  |  |
| 4387 | 1732.1 | TR on Media Handling Aspects of IMS-based Telepresence | 269d? | 2014-09-09 A | 2015-09-16 A | 100% |  |  |  | finish no earlier than 2015-09-16 | S4 | 2152h | 2152h | IMS_TELEP_S4 | 33 | Intel | ozgur.oyman@intel.com | Rel-13 | 65 |  |  |  |  |  |
| 4388 | 1732.2 | Specification on Media Handling Aspects of IMS-based Telepresence | 334d? | 2014-09-09 A | 2015-12-16 A | 100% |  |  |  | finish no earlier than 2015-12-16 | S4 | 2672h | 2672h | IMS_TELEP_S4 | 33 | Intel | ozgur.oyman@intel.com | Rel-13 | 65 |  |  |  |  |  |
| 4389 | 1732.3 | (IETF) Protocol for Controlling Multiple Streams for Telepresence (CLUE) (draft-ietf-clue-protocol) | 331d? | 2015-12-10 A | 2017-03-15 A | 100% |  |  |  | finish no earlier than 2017-03-15 | S4-IETF | 2648h | 2648h | IMS_TELEP_S4 | 36 | Intel | ozgur.oyman@intel.com | Rel-13 | 71 |  |  |  |  |  |
| 4390 | 1732.4 | (IETF) Mapping RTP streams to CLUE media captures (draft-ietf-clue-rtp-mapping) | 331d? | 2015-12-10 A | 2017-03-15 A | 100% |  |  |  | finish no earlier than 2017-03-15 | S4-IETF | 2648h | 2648h | IMS_TELEP_S4 | 36 | Intel | ozgur.oyman@intel.com | Rel-13 | 71 |  |  |  |  |  |
| 4391 | 1732.5 | Deleted - (IETF) DTLS Encapsulation of SCTP Packets (draft-ietf-tsvwg-sctp-dtls-encaps) | 331d? | 2015-12-10 A | 2017-03-15 A | 100% |  |  |  | finish no earlier than 2017-03-15 | S4-IETF | 2648h | 2648h | IMS_TELEP_S4 | 36 | Intel | ozgur.oyman@intel.com | Rel-13 | 71 |  |  |  |  |  |
| 4392 | 1732.6 | (IETF) Using Simulcast in SDP and RTP Sessions (draft-ietf-mmusic-sdp-simulcast) | 331d? | 2015-12-10 A | 2017-03-15 A | 100% |  |  |  | finish no earlier than 2017-03-15 | S4-IETF | 2648h | 2648h | IMS_TELEP_S4 | 36 | Ericsson | tomas.frankkila@ericsson.com | Rel-13 | 71 |  |  |  |  |  |
| 4393 | 1733 | **RAN Sharing Enhancements** | 941.62d? | 2013-06-19 A | 2015-12-15 A | 100% | 2013-06-19 | 2013-12-11 | 129d? |  | S1; R3 | 16824h | 16824h | RSE | 31 | NEC | joerg.swetina@neclab.eu | Rel-13 | 60 | Alain | RSE |  |  |  |
| 4394 | 1733.1 | Stage 1 for RAN Sharing Enhancements | 181.88d? | 2013-06-19 A | 2013-12-11 A | 100% | 2013-06-19 | 2013-12-11 | 129d? |  | S1 | 1032h | 1032h | RSE-SA1 | 31 | NEC | joerg.swetina@neclab.eu | Rel-13 | 60 | Alain |  |  |  |  |
| 4395 | 1733.2 | **RAN aspects of RAN Sharing Enhancements for LTE** | 476.25d? | 2014-09-12 A | 2015-12-15 A | 100% | 2014-06-13 | 2015-06-12 | 261d? |  | R3 | 5280h | 5280h | RSE-RAN_LTE | 33 | NEC | Siva.Vakeesar@emea.nec.com | Rel-13 | 65 |  | RSE-RAN_LTE |  |  |  |
| 4396 | 1733.2.1 | Core part: RAN aspects of RAN Sharing Enhancements for LTE | 330d? | 2014-09-12 A | 2015-12-15 A | 100% | 2014-06-13 | 2015-06-12 | 261d? | finish no earlier than 2015-12-15 | R3 | 2640h | 2640h | RSE-RAN_LTE-Core | 33 | NEC | Siva.Vakeesar@emea.nec.com | Rel-13 | 65 |  | RSE-RAN_LTE-Core |  |  | RP-151295 |
| 4397 | 1734 | **Enhancements to WEBRTC interoperability** | 862.38d? | 2014-03-07 A | 2016-06-16 A | 100% | 2014-03-07 | 2015-06-17 | 334d? |  | S1; S2; S3 | 31200h | 31200h | eWebRTCi | 32 | Alcatel-Lucent | betsy.covell@alcatel-lucent.com | Rel-13 | 63 | Alain | eWebRTCi |  |  |  |
| 4398 | 1734.1 | Stage 1 for Enhancements to WEBRTC interoperability | 139d? | 2014-03-07 A | 2014-09-17 A | 100% | 2014-03-07 | 2014-09-17 | 139d? | finish no earlier than 2014-09-17 | S1 | 1112h | 1112h | eWebRTCi | 32 | Alcatel-Lucent | betsy.covell@alcatel-lucent.com | Rel-13 | 63 | Alain |  |  |  | S1-143303 |
| 4399 | 1734.2 | TR on Stage 2 for Enhancements to WEBRTC interoperability | 196d? | 2014-06-19 A | 2015-03-18 A | 100% | 2014-06-18 | 2015-03-18 | 196d? | finish no earlier than 2015-03-18 | S2 | 1568h | 1568h | eWebRTCi | 33 | China Mobile | Yu Qing (yuqing@chinamobile.com) | Rel-13 | 64 |  |  |  |  |  |
| 4400 | 1734.3 | Stage 2 for Enhancements to WEBRTC interoperability | 261d? | 2014-06-23 A | 2015-06-17 A | 100% | 2014-06-18 | 2015-06-17 | 261d? | finish no earlier than 2015-06-17 | S2 | 2088h | 2088h | eWebRTCi | 33 | China Mobile | Yu Qing (yuqing@chinamobile.com) | Rel-13 | 64 |  |  |  |  |  |
| 4401 | 1734.4 | TR on Security for Enhancements to WEBRTC interoperability | 273d? | 2014-09-17 A | 2015-09-30 A | 100% |  |  |  | start no earlier than 2014-09-17 | S3 | 2184h | 2184h | eWebRTCi | 33 | Ericsson | vesa.lehtovirta@ericsson.com | Rel-13 | 65 |  |  |  |  |  |
| 4402 | 1734.5 | Security for Enhancements to WEBRTC interoperability | 273d? | 2014-09-17 A | 2015-09-30 A | 100% |  |  |  | start no earlier than 2014-09-17 | S3 | 2184h | 2184h | eWebRTCi | 33 | Ericsson | vesa.lehtovirta@ericsson.com | Rel-13 | 65 |  |  |  |  |  |
| 4403 | 1734.6 | (IETF) Session Traversal Utilities for NAT (STUN) Extension for Third Party Authorization (draft-ietf-tram-turn-third-party-authz) | 198d? | 2014-09-17 A | 2015-08-12 A | 100% |  |  |  | start no earlier than 2014-09-17 | S3-IET | 1584h | 1584h | eWebRTCi | 35 | Alcatel-Lucent |  | Rel-13 | 69 |  |  |  |  |  |

Notes:
- 4375: SP#65 updated WID SP-140153=>SP-140631 (BBII & BBIII stopped). Triggered by Rel-12 TR 22.805 Study on User Plane Congestion management (FS_UPCON) / Impacted TSs and TRs: Stage 1/2/3
- 4376: SP#63 moved to Rel-13 updated WID SP-120890=>SP-140153. SP#59 completed. Convert TR 22.805 clause 6 consolidated requirements to normative requirements in 22.101. 3/3/15: start date corrected (was Mar 12) / Impacted TSs and TRs: 22.101
- 4377: SP#65 updated WID SP-140153=>SP-140631. TR 23.705v100 for Information. Dec.14: 87->98%. Mar15: 100% / Impacted TSs and TRs: new 23.705
- 4378: SP#62 stopped at 0% completion / Impacted TSs and TRs: TBD
- 4379: SP#65 updated WID SP-140153=>SP-140631. IncludES in CP-150RAN Congestion Detection: , RAN Traffic Differentiation, RAN Congestion Reporting, CN Congestion Mitigation mechanisms, Dynamic Policy Control
- 4380: SP#65 updated WID SP-140153=>S2-142850 (added impacted specs). Dec.14: 70->100% only if RAN agrees to standardize the FPI / Impacted TSs and TRs: 23.060; 23.203; 23.401
- 4381: Stage 3¦WID: CP-140734->CP-140929. June 2015: WID: CP-140929-> CP-150365. / Impacted TSs and TRs: Stage 3
- 4382: Dec.14: 0->60¦WID: CP-140734->CP-140929. Mar.15: 60->95%¦June2015: Compl:95%->100. WID: CP-140929-> CP-150365. / Impacted TSs and TRs: 29.201; 29.212; 29.213; 29.214; 29.215; 29.219; New 29.217 (PCC over Np)
- 4383: Dec.14: 0->20¦WID: CP-140734->CP-140929. Mar. 15: 50%¦June2015: Compl:50%->90. WID: CP-140929-> CP-150365.¦07/09/15: 90%->100 / Impacted TSs and TRs: 23.003; 29.303; New 29.405 (UPCON over Nq)
- 4384: SP#65 updated WID SP-140153=>SP-140631 (BBII & BBIII stopped). IncludES in CP-150Content specific UP prioritization (Video), Application specific UP prioritization / Impacted TSs and TRs: TBD
- 4385: SP#65 updated WID SP-140153=>SP-140631 (BBII & BBIII stopped). IncludES in CP-150Uplink Congestion Management, Un/Attended UE Information / Impacted TSs and TRs: TBD
- 4386: Can be seen as an "enhancement" of Rel-12 IMS-based Telepresence (IMS_TELEP) UID_530042. Mar. 15: 20%
- 4387: Dec.14: 0->10%. 8/4/15: 20%¦June2015: Compl:20%->30¦Aug2015: 30%->35¦07/09/15: 35%->60¦7/12/15: 60%->100 / Impacted TSs and TRs: New 26.9xy
- 4388: Dec.14: 0->10%. 8/4/15: 20%¦June2015: Compl:20%->30¦07/09/15: 30%->60¦7/12/15: 60%->100 / Impacted TSs and TRs: New 26.1xy
- 4389: 23/4/20: 60%->90. was (IETF) CLUE Protocol (draft-ietf-clue-protocol); 9/4/21: RFC 8847 added; / Impacted TSs and TRs: 26.22; RFC 8847
- 4390: 23/4/20: 60%->90; 9/4/21: RFC 8849 added; / Impacted TSs and TRs: 26.22; RFC 8849
- 4391: 22/3/18: 95%->100. 07/06/18: deleted as per SP-180260; 9/4/21: RFC 8261 added; / Impacted TSs and TRs: 26.22; RFC 8261
- 4392: 23/4/20: 60%->90; 9/4/21: RFC 8853 added; / Impacted TSs and TRs: 26.114; 26.223; RFC 8853
- 4393: Triggered by Rel-12 TR 22.852 Study on RAN Sharing Enhancements (FS_RSE)
- 4394: SP#62 completed / Impacted TSs and TRs: 22.101
- 4395: Triggered by TR 36.856 Study on RAN aspects of RAN Sharing Enhancements for LTE (FS_RSE-RAN_LTE) & SA1 22.101 Stage 1 / Impacted TSs and TRs: LTE
- 4396: ¦CD:Mon 15/06/15->Tue 15/09/15¦Stat Rep: -->RP-141891 1st Apr 15: Compl:15%->20% 1st Apr 15: Stat Rep: RP-141891->RP-150289 03/07/15: Compl:20%->75% 03/07/15: Stat Rep: RP-150289->RP-150875 29/09/15: Compl:75%->80% 29/09/15: CD:Tue 15/09/15->Tue 15/1 / Impacted TSs and TRs: 36.300; 36.413; 36.423
- 4397: SP#65 updated WID SP-14028=>SP-140630 (added SA3 part, SA1 change). Add enhanced interoperability support for WebRTC to Rel-12 Web Real Time Communication (WebRTC) Access to IMS. / Impacted TSs and TRs: Stage 1/2
- 4398: SP#65 completed. Updated WID SP-140286=>SP-140630 / Impacted TSs and TRs: 22.228
- 4399: SP#65 updated WID SP-14028=>SP-140630 (added SA3 part). Dec.14: 9->55%¦June2015: Compl:55%->85¦07/09/15: 85%->100 / Impacted TSs and TRs: New 23.706
- 4400: SP#65 updated WID SP-14028=>SP-140630 (added SA3 part)¦June2015: Compl:0%->85¦07/09/15: 85%->100 / Impacted TSs and TRs: 23.228
- 4401: SP#65 updated WID SP-14028=>SP-140630 (added SA3 part). Dec.14: 0->20%, TR number added. 3/3/15: 30%.¦June2015: Compl:30%->75¦11/12/15: 54%->100¦11/12/15: 100%->100 / Impacted TSs and TRs: New 33.872
- 4402: SP#65 updated WID SP-14028=>SP-140630 (added SA3 part). Dec.14: 0->20%¦11/12/15: 15%->100 / Impacted TSs and TRs: 33.203; 33.328
- 4403: TS 33.203 CR0235draft-ietf-tram-turn-third-party-authz¦7/3/16: 10%->100; 9/4/21: RFC 7635 added; / Impacted TSs and TRs: 33.203; RRC 7635 (was draft-ietf-tram-turn-third-party-authz); RFC 7635

| ID | WBS | Task | Type | Duration | Start | Finish | Complete | Baseline start | Baseline finish | Baseline duration | Constraint | Resources | Work | Actual work | Acronym | PCG approved | WI rapporteur name | WI rapporteur e-mail | Release | TSG approved | Impacted TSs and TRs | MCC resp | Acronym_3GU_Export | Special Focus Doc |
| --- | --- | --- | --- | --- | --- | --- | --- | --- | --- | --- | --- | --- | --- | --- | --- | --- | --- | --- | --- | --- | --- | --- | --- | --- |
| 4404 | 1734.7 | **Stage 3 for Enhancements to WebRTC interoperability** |  | 294d? | 2015-09-07 A | 2016-06-16 A | 100% |  |  |  |  | ct | 8808h | 8808h | eWebRTCi-CT | 35 | China Mobile, Song Yue | songyue@chinamobile.com | Rel-13 | 69 |  |  |  |  |
| 4405 | 1734.7.1 | CT1 aspects 3 for Enhancements to WebRTC interoperability |  | 75d? | 2015-09-07 A | 2015-12-18 A | 100% |  |  |  | finish no earlier than 2015-12-18 | C1 | 600h | 600h | eWebRTCi-CT | 35 | China Mobile, Song Yue | songyue@chinamobile.com | Rel-13 | 69 | 24.371; 24.229 |  |  |  |
| 4406 | 1734.7.2 | CT3 aspects for Enhancements to WebRTC interoperability |  | 135d? | 2015-09-07 A | 2016-03-11 A | 100% |  |  |  | finish no earlier than 2016-03-11 | C3 | 1080h | 1080h | eWebRTCi-CT | 35 | China Mobile, Song Yue | songyue@chinamobile.com | Rel-13 | 69 | 29.214 |  |  |  |
| 4407 | 1734.7.3 | CT4 aspects for Enhancements to WebRTC interoperability |  | 135d? | 2015-09-07 A | 2016-03-11 A | 100% |  |  |  | finish no earlier than 2016-03-11 | C4 | 1080h | 1080h | eWebRTCi-CT | 35 | China Mobile, Song Yue | songyue@chinamobile.com | Rel-13 | 69 | 29.228; 23.334; 29.334; 23.008 |  |  |  |
| 4408 | 1734.7.4 | (IETF) SDP-based Data Channel Negotiation (draft-ietf-mmusic-data-channel-sdpneg) |  | 69d? | 2015-12-08 A | 2016-03-11 A | 100% |  |  |  | finish no earlier than 2016-03-11 | C1-IETF; SA4-IETF | 1104h | 1104h | eWebRTCi-CT | 36 | Ericsson | christer.holmberg@ericsson.com | Rel-13 | 71 | 24.371; 24.229; RFC 8864 |  |  |  |
| 4409 | 1734.7.5 | (IETF) MSRP over Data Channels (draft-ietf-mmusic-msrp-usage-data-channel) |  | 69d? | 2015-12-08 A | 2016-03-11 A | 100% |  |  |  | start no earlier than 2015-12-08 | C1-IETF | 552h | 552h | eWebRTCi-CT | 36 | Ericsson | christer.holmberg@ericsson.com | Rel-13 | 71 | 24.371; 24.229; 26.223 |  |  |  |
| 4410 | 1734.7.6 | (IETF) A Language for Rules Describing JSON Content (draft-newton-json-content-rules) |  | 69d? | 2015-12-08 A | 2016-03-11 A | 100% |  |  |  | start no earlier than 2015-12-08 | C3-IETF | 552h | 552h | eWebRTCi-CT | 36 | Ericsson | christer.holmberg@ericsson.com | Rel-13 | 71 | 24.371; 24.229; 26.223 |  |  |  |
| 4411 | 1734.7.7 | Deleted - (IETF) Oauth 2.0 Proof-of-Possession (PoP) Security Architecture (draft-ietf-oauth-pop-architecture) |  | 138d? | 2015-12-08 A | 2016-06-16 A | 100% |  |  |  | start no earlier than 2015-12-08 | S3-IETF | 1104h | 1104h | eWebRTCi-CT | 44 |  |  | Rel-13 | 87 |  |  |  |  |
| 4412 | 1734.7.8 | (IETF) Session Traversal Utilities for NAT (STUN) Extension for Third-Party Authorization (draft-ietf-tram-turn-third-party-authz) --> RFC 7635 |  | 138d? | 2015-12-08 A | 2016-06-16 A | 100% |  |  |  | start no earlier than 2015-12-08 | S3-IETF | 1104h | 1104h | eWebRTCi-CT | 44 |  |  | Rel-13 | 87 |  |  |  |  |
| 4413 | 1735 | **Improvements to CS/PS coordination in UTRAN/GERAN Shared Networks** |  | 826.12d? | 2014-03-07 A | 2016-05-12 A | 100% | 2014-03-07 | 2014-12-10 | 199d? |  | S2 | 9768h | 9768h | CSPS_Coord | 32 | Ericsson | roland.gustafsson@ericsson.com | Rel-13 | 63 | Stage 2 | Maurice | CSPS_Coord |  |
| 4414 | 1735.1 | TR on Stage 2 for Improvements to CS/PS coordination in UTRAN/GERAN Shared Networks |  | 140d? | 2014-03-07 A | 2014-09-17 A | 100% | 2014-03-07 | 2014-12-10 | 199d? | finish no earlier than 2014-09-17 | S2 | 1120h | 1120h | CSPS_Coord-SA2TR | 32 | Ericsson | roland.gustafsson@ericsson.com | Rel-13 | 63 | New 23.704 | Maurice |  |  |
| 4415 | 1735.2 | Stage 2 for Improvements to CS/PS coordination in UTRAN/GERAN Shared Networks |  | 201d? | 2014-03-12 A | 2014-12-12 A | 100% | 2014-03-07 | 2014-12-10 | 199d? | finish no earlier than 2014-12-12 | S2 | 1608h | 1608h | CSPS_Coord-SA2 | 32 | Ericsson | roland.gustafsson@ericsson.com | Rel-13 | 63 | 23.216; 23.251; 23.272 | Maurice |  |  |
| 4416 | 1735.3 | RAN aspects for improvements to CS/PS coordination in GERAN Shared Networks |  | 307d? | 2015-03-11 A | 2016-05-12 A | 100% |  |  |  | finish no earlier than 2016-05-12 | G2 | 2456h | 2456h | CSPS_Coord_GERAN | 33 | Nicklas Johansson, Ericsson LM | Nicklas.Johansson@Ericsson.com | Rel-13 | 65 | 48.008; 48.018 |  |  |  |
| 4417 | 1736 | **Enhancements to Proximity-based Services** |  | 1127.75d? | 2013-03-18 A | 2016-03-11 A | 100% | 2014-06-18 | 2015-06-12 | 258d? |  | S1; S2; S3 | 27152h | 27152h | eProSe | 33 | Qualcomm | Eddy Hall (edhall@qti.qualcomm.com) | Rel-13 | 64 | Stage 1/2 |  | eProSe | Public Safety (A-A) |
| 4418 | 1736.1 | Stage 1 for Enhancements to Proximity-based Services |  | 66d? | 2014-06-19 A | 2014-09-17 A | 100% | 2014-06-18 | 2014-09-17 | 66d? | finish no earlier than 2014-09-17 | S1 | 528h | 528h | eProSe-SA1 | 33 | Qualcomm | Eddy Hall (edhall@qti.qualcomm.com) | Rel-13 | 64 | 22.115; 22.278 |  |  | Public Safety (A-A) |
| 4419 | 1736.2 | Stage 2 for Enhancements to Proximity-based Services - Extensions |  | 326d? | 2014-06-23 A | 2015-09-16 A | 100% | 2014-06-18 | 2015-06-12 | 258d? | finish no earlier than 2015-09-16 | S2 | 2608h | 2608h | eProSe-Ext-SA2 | 33 | Qualcomm | Haris Zisimopoulos (harisz@qti.qualcomm.com) | Rel-13 | 64 | 23.303; TBD |  | eProSe-Ext | Public Safety (A-A) |
| 4420 | 1736.3 | TR on Stage 2 for Enhancements to Proximity-based Services - Extensions |  | 193d? | 2014-06-18 A | 2015-03-13 A | 100% | 2014-06-18 | 2015-03-13 | 193d? | finish no earlier than 2015-03-13 | S2 | 1544h | 1544h | eProSe-Ext-SA2TR | 33 | Qualcomm | Haris Zisimopoulos (harisz@qti.qualcomm.com) | Rel-13 | 64 | New 23.713 |  |  | Public Safety (A-A) |
| 4421 | 1736.4 | Security for Enhancements to Proximity-based Services - Extensions |  | 388d? | 2014-09-19 A | 2016-03-11 A | 100% |  |  |  | finish no earlier than 2016-03-11 | S3 | 3104h | 3104h | eProSe-Ext-SA3 | 33 | Qualcomm | Adrian Escott (aescott@qti.qualcomm.com) | Rel-13 | 65 | 33.303 |  |  | Public Safety (A-A) |
| 4422 | 1736.5 | **CT aspects of enhancements to Proximity-based** |  | 280.5d? | 2015-06-15 A | 2016-03-11 A | 100% |  |  |  |  | C1 | 7304h | 7304h | eProSe-Ext-CT | 35 | Lena Chaponniere | lguellec@qti.qualcomm.com | Rel-13 | 68 | 23.122; 24.301; 24.333; 24.334 |  |  |  |
| 4423 | 1736.5.1 | CT1 aspects of enhancements to Proximity-based |  | 195d? | 2015-06-15 A | 2016-03-11 A | 100% |  |  |  | finish no earlier than 2016-03-11 | C1 | 1560h | 1560h | eProSe-Ext-CT | 35 | Lena Chaponniere | lguellec@qti.qualcomm.com | Rel-13 | 68 | 29.343 |  |  |  |
| 4424 | 1736.5.2 | CT3 aspects of enhancements to Proximity-based |  | 133d? | 2015-06-15 A | 2015-12-16 A | 100% |  |  |  | start no earlier than 2015-06-15 | C3 | 1064h | 1064h | eProSe-Ext-CT | 35 | Lena Chaponniere | lguellec@qti.qualcomm.com | Rel-13 | 68 | 23.003; 23.008; 29.272; 29.344; 29.345 |  |  |  |
| 4425 | 1736.5.3 | CT4 aspects of enhancements to Proximity-based |  | 195d? | 2015-06-15 A | 2016-03-11 A | 100% |  |  |  | finish no earlier than 2016-03-11 | C4 | 1560h | 1560h | eProSe-Ext-CT | 35 | Lena Chaponniere | lguellec@qti.qualcomm.com | Rel-13 | 68 | 31.102; 31.111 |  |  |  |
| 4426 | 1736.5.4 | CT6 aspects of enhancements to Proximity-based |  | 195d? | 2015-06-15 A | 2016-03-11 A | 100% |  |  |  | finish no earlier than 2016-03-11 | C6 | 1560h | 1560h | eProSe-Ext-CT | 35 | Lena Chaponniere | lguellec@qti.qualcomm.com | Rel-13 | 68 | 31.102; 31.111 |  |  |  |
| 4427 | 1736.6 | Study on Security for Proximity-based Services |  | 596d? | 2013-03-18 A | 2015-06-17 A | 100% | 2013-03-07 | 2014-09-17 | 401d? | finish no earlier than 2015-06-17 | S3 | 4768h | 4768h | FS_ProSe_Sec | 30 | Qualcomm | Adrian Escott (aescott@qti.qualcomm.com) | Rel-13 | 59 | 33.833 | Mirko | FS_ProSe_Sec | Public Safety (A-A) |
| 4428 | 1736.7 | Note: Charging Aspects done in Rel-14 under CH14-Prose (UID 720049) | milestone | 0d? | 2015-06-17 A | 2015-06-17 A | 100% |  |  |  | start no earlier than 2015-06-17 | S5 |  |  | eProSe | 37 |  |  | Rel-13 | 72 |  |  |  |  |

Notes:
- 4404: 7/12/15: WID:CP-150498->CP-150790->CP-150767
- 4405: 7/12/15: 0%->100¦7/12/15: WID:CP-150498->CP-150790->CP-150767
- 4406: 7/12/15: WID:CP-150498->CP-150790->CP-150767. ES in CP-150644¦7/3/16: 0%->100
- 4407: 7/12/15: WID:CP-150498->CP-150790->CP-150767. ES in CP-150623¦7/3/16: 0%->100
- 4408: 7/3/16: Introduced by IETF updates; 23/4/20: 75%->90; 9/4/21: RFC 8864 added;
- 4409: 7/3/16: Introduced by IETF updates
- 4410: 7/3/16: Introduced by IETF updates. This individual draft will not further progress in IETF but is kept as reference in version -09; 23/4/20: 25%->100
- 4411: 9/4/21: 25%->100
- 4413: Provide improvements to the solutions for CS/PS coordination in TS 23.251 to ensure that CS/PS coordination can be achieved for all mobility scenarios
- 4414: SP#65 completed. TR 23.704v200 for Approval
- 4415: Dec.14: 0->100%
- 4416: June2015: Compl:0%->35¦07/09/15: 35%->50, FCD:08/15->11/15¦7/12/15: 50%->95, FCD: 12/15->02/16. 02/03/16: FCD: 02/16->05/16¦13/6/16: 95%->100
- 4417: -
- 4418: SP#65 completed. Some Rel-12 ProSe service requirements have not been implemented at Stage 2/3 level. These are taken up in Rel-13 Stage 2/3 and need Stage 1 appropriate service requirements. No new service requirements are introduced.
- 4419: SP#65 updated WID SP-140385=>SP-140573 (added SA3 part). Mar15: WID: SP-140573 ->SP-150028¦June2015: Compl:0%->30. FCD: June->Sept. 07/09/15: 24->70%¦07/09/15: 70%->90¦7/12/15: 90%->100
- 4420: SP#65 updated WID SP-140385=>SP-140573 (added SA3 part). Acronym corrected: eProSe-Ex-SA2TRt->eProSe-Ext-SA2TR. Mar15: 60% Mar15: WID: SP-140573 ->SP-150028¦June2015: Compl:60%->90¦07/09/15: 90%->95¦07/09/15: 95%->100
- 4421: SP#65 updated WID SP-140385=>SP-140573 (added SA3 part). Acronym corrected: eProSe-Ex-SA3t->eProSe-Ext-SA3. Mar15: WID: SP-140573 ->SP-150028¦7/12/15: 0%->75¦10/12/15: FCD ->03/16, ES in SP-150714¦7/3/16: 75%->100
- 4423: 07/09/15: 0%->40¦7/12/15: 40%->90. FCD -> 03/16, ES in CP-150724¦7/3/16: 90%->100
- 4424: 07/09/15: 0%->60¦8/3/16: 60%->100
- 4425: 07/09/15: 0%->10¦7/12/15: 10%->80. FCD->03/16. ES in CP-150616¦7/3/16: 80%->100
- 4426: 7/12/15: FCD -> 03/16, ES in CP-150839. FCD->03/16. ES in CP-150616¦7/3/16: 0%->95¦8/3/16: 95%->100
- 4427: SP#65 updated WID SP-140300=>SP-140629 (Moved the TR phase to Rel-13 as a stand-alone Study). Completion 09/14=>06/15. SP#64 TR 33.833 v100 for Information. 4/3/15: 95%->70% (more topics to be included)¦June2015: Compl:70%->75¦7/12/15: 75%->95¦7/3/1

| ID | WBS | Task | Duration | Start | Finish | Complete | Baseline start | Baseline finish | Baseline duration | Constraint | Resources | Work | Actual work | Acronym | PCG approved | WI rapporteur name | Release | TSG approved | Acronym_3GU_Export | TSG stopped |
| --- | --- | --- | --- | --- | --- | --- | --- | --- | --- | --- | --- | --- | --- | --- | --- | --- | --- | --- | --- | --- |
| 4429 | 1737 | **voice over E-UTRAN Paging Policy Differentiation** | 185.88d? | 2014-06-16 A | 2014-12-12 A | 100% | 2014-06-16 | 2014-12-10 | 128d? |  | S1; S2; C4; C1; C3 | 9244.75h | 9244.75h | voE_UTRAN_PPD | 33 | Alcatel-Lucent | Rel-13 | 64 | voE_UTRAN_PPD |  |
| 4430 | 1737.1 | Stage 1 for voice over E-UTRAN Paging Policy Differentiation | 3d? | 2014-06-16 A | 2014-06-18 A | 100% | 2014-06-16 | 2014-06-18 | 3d? | finish no earlier than 2014-06-18 | S1 | 24h | 24h | voE_UTRA-N_PPD-SA1 | 33 | Alcatel-Lucent | Rel-13 | 64 |  |  |
| 4431 | 1737.2 | Stage 2 for voice over E-UTRAN Paging Policy Differentiation | 128d? | 2014-06-18 A | 2014-12-12 A | 100% | 2014-06-18 | 2014-12-10 | 126d? | finish no earlier than 2014-12-12 | S2 | 1024h | 1024h | voE_UTRAN_PPD-SA2 | 33 | Alcatel-Lucent | Rel-13 | 64 |  |  |
| 4432 | 1737.3 | **CT aspects of voice over E-UTRAN Paging Policy Differentiation** | 87.75d? | 2014-09-16 A | 2014-12-09 A | 100% |  |  |  |  | C4; C1; C3 | 3024h | 3024h | voE_UTRAN_PPD-CT | 33 | Alcatel-Lucent | Rel-13 | 65 |  |  |
| 4433 | 1737.3.1 | CT4 part of CT aspects of voice over E-UTRAN Paging Policy Differentiation | 63d? | 2014-09-16 A | 2014-12-09 A | 100% |  |  |  | finish no earlier than 2014-12-09 | C4 | 504h | 504h | voE_UTRAN_PPD-CT | 33 | Alcatel-Lucent | Rel-13 | 65 |  |  |
| 4434 | 1737.3.2 | CT1 part of CT aspects of voice over E-UTRAN Paging Policy Differentiation | 63d? | 2014-09-16 A | 2014-12-09 A | 100% |  |  |  | finish no earlier than 2014-12-09 | C1 | 504h | 504h | voE_UTRAN_PPD-CT | 33 | Alcatel-Lucent | Rel-13 | 65 |  |  |
| 4435 | 1737.3.3 | CT3 part of CT aspects of voice over E-UTRAN Paging Policy Differentiation | 63d? | 2014-09-16 A | 2014-12-09 A | 100% |  |  |  | finish no earlier than 2014-12-09 | C3 | 504h | 504h | voE_UTRAN_PPD-CT | 33 | Alcatel-Lucent | Rel-13 | 65 |  |  |
| 4436 | 1738 | **IP Flow Mobility support for S2a and S2b Interfaces** | 754.62d? | 2014-06-18 A | 2016-06-15 A | 100% | 2014-06-18 | 2015-06-17 | 261d? |  | S2 | 15656h | 15656h | NBIFOM | 33 | Tricci So, ZTE | Rel-13 | 64 | NBIFOM |  |
| 4437 | 1738.1 | TR for IP Flow Mobility support for S2a and S2b Interfaces | 193d? | 2014-06-18 A | 2015-03-13 A | 100% | 2014-06-18 | 2015-03-13 | 193d? | finish no earlier than 2015-03-13 | S2 | 1544h | 1544h | NBIFOM-SA2TR | 33 | Tricci So, ZTE | Rel-13 | 64 |  |  |
| 4438 | 1738.2 | Stage 2 for IP Flow Mobility support for S2a and S2b Interfaces | 326d? | 2014-06-23 A | 2015-09-16 A | 100% | 2014-06-18 | 2015-06-17 | 261d? | finish no earlier than 2015-09-16 | S2 | 2608h | 2608h | NBIFOM-SA2 | 33 | Tricci So, ZTE | Rel-13 | 64 |  |  |
| 4439 | 1738.3 | Charging Aspects of IP Flow Mobility support for S2a and S2b Interfaces (NBIFOM) | 196d? | 2015-09-16 A | 2016-06-15 A | 100% | 2014-06-18 | 2015-06-17 | 261d? | finish no earlier than 2016-06-15 | S5 | 1568h | 1568h | NBIFOM-CH | 35 | GUO Wenjie, ZTE | Rel-13 | 69 |  |  |
| 4440 | 1738.4 | **CT aspects of IP Flow Mobility support for S2a and S2b Interfaces** | 280.5d? | 2015-06-15 A | 2016-03-11 A | 100% |  |  |  |  | C1 | 5744h | 5744h | NBIFOM-CT | 35 | Xingyue(Joy) Zhou, ZTECorporation | Rel-13 | 68 |  |  |
| 4441 | 1738.4.1 | CT1 aspects of IP Flow Mobility support for S2a and S2b Interfaces | 195d? | 2015-06-15 A | 2016-03-11 A | 100% |  |  |  | finish no earlier than 2016-03-11 | C1 | 1560h | 1560h | NBIFOM-CT | 35 | Xingyue(Joy) Zhou, ZTECorporation. ES in 641 | Rel-13 | 68 |  |  |
| 4442 | 1738.4.2 | CT3 aspects of IP Flow Mobility support for S2a and S2b Interfaces | 195d? | 2015-06-15 A | 2016-03-11 A | 100% |  |  |  | finish no earlier than 2016-03-11 | C3 | 1560h | 1560h | NBIFOM-CT | 35 | 680001Xingyue(Joy) Zhou, ZTECorporation. ES in 641 | Rel-13 | 68 |  |  |
| 4443 | 1738.4.3 | CT4 aspects of IP Flow Mobility support for S2a and S2b Interfaces | 133d? | 2015-06-15 A | 2015-12-16 A | 100% |  |  |  | start no earlier than 2015-06-15 | C4 | 1064h | 1064h | NBIFOM-CT | 35 | Xingyue(Joy) Zhou, ZTECorporation | Rel-13 | 68 |  |  |
| 4444 | 1739 | **Double Resource Reuse for Multiple Media Sessions** | 377.62d? | 2014-03-14 A | 2015-03-13 A | 100% | 2014-03-14 | 2015-03-13 | 261d? |  | S2 | 5952h | 5952h | DRuMS | 33 | Ericsson | Rel-13 | 64 | DRuMS |  |
| 4445 | 1739.1 | Stage 2 for Double Resource Reuse for Multiple Media Sessions | 377.62d? | 2014-03-14 A | 2015-03-13 A | 100% | 2014-03-14 | 2015-03-13 | 261d? | finish no earlier than 2015-03-13 | S2 | 2088h | 2088h | DRuMS-SA2 | 33 | Ericsson | Rel-13 | 64 |  |  |
| 4446 | 1739.2 | **CT aspects of Double Resource Reuse for Multiple Media Sessions** | 104.5d? | 2014-12-03 A | 2015-03-13 A | 100% |  |  |  |  | C3 | 1752h | 1752h | DRuMS-CT | 34 | Ericsson | Rel-13 | 66 |  |  |
| 4447 | 1739.2.1 | CT1 aspects of Double Resource Reuse for Multiple Media Sessions | 73d? | 2014-12-03 A | 2015-03-13 A | 100% |  |  |  | start no earlier than 2014-12-03 | C1 | 584h | 584h | DRuMS-CT | 34 | Ericsson | Rel-13 | 66 |  |  |
| 4448 | 1739.2.2 | CT3 aspects of Double Resource Reuse for Multiple Media Sessions | 73d? | 2014-12-03 A | 2015-03-13 A | 100% |  |  |  | start no earlier than 2014-12-03 | C3 | 584h | 584h | DRuMS-CT | 34 | Ericsson | Rel-13 | 66 |  |  |
| 4449 | 1740 | Lawful Interception in the 3GPP Rel-13 | 656d? | 2014-06-18 A | 2016-12-15 A | 100% | 2014-06-18 | 2015-12-09 | 386d? | finish no earlier than 2016-12-15 | S3 | 5248h | 5248h | LI13 | 33 | PIDS, Alcatel-Lucent | Rel-13 | 64 | LI13 |  |
| 4450 | 1741 | STOPPED - Study on Lawful Interception Service Evolution | 386d? | 2014-06-23 A | 2015-12-09 A | 100% | 2014-06-18 | 2015-12-09 | 386d? | finish no earlier than 2015-12-09 | S3 | 3088h | 3088h | FS_LISE | 33 | Alcatel-Lucent | Rel-13 | 64 | FS_LISE | 80 |
| 4451 | 1742 | **Video enhancements by Region-Of-Interest information signalling** | 566.12d? | 2014-06-18 A | 2015-12-16 A | 100% | 2014-06-18 | 2015-06-17 | 261d? |  | S4 | 10016h | 10016h | ROI | 33 | Intel | Rel-13 | 64 | ROI |  |
| 4452 | 1742.1 | SA4 aspects of Video enhancements by Region-Of-Interest information signalling | 329d? | 2014-06-18 A | 2015-09-16 A | 100% |  |  |  | finish no earlier than 2015-09-16 | S4 | 2632h | 2632h | ROI | 33 | Intel | Rel-13 | 64 |  |  |

Notes:
- 4429: - / Impacted TSs and TRs: Stage 1/2 / WI rapporteur e-mail: (betsy.covell@alcatel-lucent.com)
- 4430: SP#64 approved WID & completed / Impacted TSs and TRs: 22.228; 22.278 / WI rapporteur e-mail: betsy.covell@alcatel-lucent.com
- 4431: Architectural enhancements allowing a differentiated paging policy for IMS voice calls over E-UTRAN. Dec.14: 25->100% / Impacted TSs and TRs: 23.228; 23.401 / WI rapporteur e-mail: laurent.thiebaut@alcatel-lucent.com
- 4432: Stage 3 / Impacted TSs and TRs: Stage 3 / WI rapporteur e-mail: bruno.landais@alcatel-lucent.com
- 4433: Mar.15: 0->100% / Impacted TSs and TRs: 29.274; 29.281 / WI rapporteur e-mail: bruno.landais@alcatel-lucent.com
- 4434: Dec.14: 0->50%¦07/09/15: 50%->50¦7/12/15: 50%->100 / Impacted TSs and TRs: 24.229 / WI rapporteur e-mail: bruno.landais@alcatel-lucent.com
- 4435: Mar.15: 0->100% / Impacted TSs and TRs: 29.061 / WI rapporteur e-mail: bruno.landais@alcatel-lucent.com
- 4436: 06/15: WID: SP-140279->SP-150250 / Impacted TSs and TRs: Stage 2 / WI rapporteur e-mail: tso@zte.com.cn
- 4437: Revived the Rel-12 DRAFT TR 23.861 stopped at SP#59 (at 40% completion). Dec.14: 20->60%¦June2015: Compl:60%->90, WID: SP-140279->SP-150250 / Impacted TSs and TRs: New 23.861 / WI rapporteur e-mail: tso@zte.com.cn
- 4438: June2015: Compl:0%->65, WID: SP-140279->SP-150250¦07/09/15: 52%->100 / Impacted TSs and TRs: 23.402; New 23.203 / WI rapporteur e-mail: tso@zte.com.cn
- 4439: 7/12/15: 0%->50. ES in SP-150710 (wrong UID mentioned in the ES)¦7/3/16: 50%->85%, FCD:03/16->06/16¦13/6/16: 85%->100 / Impacted TSs and TRs: 32.251; 32.298; 32.299 / WI rapporteur e-mail: guo.wenjie1@zte.com.cn
- 4440: 14/09/15: WID:CP-150285->CP-150497¦7/12/15: WID:CP-150497->CP-150791->874 / Impacted TSs and TRs: 24.161 / WI rapporteur e-mail: zhou.xingyue@zte.com.cn
- 4441: 07/09/15: 0%->25¦14/09/15: WID:CP-150285->CP-150497¦7/12/15: 25%->75¦7/12/15: WID:CP-150497->CP-150791->874. FCD -> 03/16. ES in CP-150725¦7/3/16: 75%->100 / Impacted TSs and TRs: 24.301; 24.302; 24.244; 24.008 / WI rapporteur e-mail: zhou.xingyue@zte.com.cn
- 4442: 07/09/15: 0%->40¦14/09/15: WID:CP-150285->CP-150497¦7/12/15: 40%->95¦7/12/15: WID:CP-150497->CP-150791->874. FCD -> 03/16. ES in CP-150725¦7/3/16: 95%->100 / Impacted TSs and TRs: 29.212; 29.213; 29.214; 29.215 / WI rapporteur e-mail: zhou.xingyue@zte.com.cn
- 4443: 07/09/15: 0%->20¦14/09/15: WID:CP-150285->CP-150497¦7/12/15: 20%->100¦7/12/15: WID:CP-150497->CP-150791->874 / Impacted TSs and TRs: 29.274; 23.008 / WI rapporteur e-mail: zhou.xingyue@zte.com.cn
- 4444: - / Impacted TSs and TRs: Stage 2 / WI rapporteur e-mail: George.Foti@ericsson.com
- 4445: Dec.14: 49->95%. Mar15: 100% / Impacted TSs and TRs: 23.203; 23.228 / WI rapporteur e-mail: George.Foti@ericsson.com
- 4446: Impacted TSs and TRs: 24.229; 24.615; 24.610; 24.605; 29.212; 29.213; 29.214; 29.215
- 4447: 5/5/15: C3 corrected in C1¦June2015: Compl:65%->90¦07/09/15: 90%->100 / Impacted TSs and TRs: 24.229; 24.615; 24.610; 24.605
- 4448: Mar.15: 65->95%¦June2015: Compl:95%->100 / Impacted TSs and TRs: 29.212; 29.213; 29.214; 29.215 / WI rapporteur e-mail: Jan Holm
- 4449: SP#65 updated WID SP-140400=>SP-140578. 2/4/15: WID SP-140815->SP-150111¦June2015: Compl:0%->10. WID: SP-150111->SP-150290¦14/09/15: WID:SP-150290->SP-150460¦7/12/15: 10%->15¦7/3/16: 13%->20¦7/3/16: WID:SP-150460->SP-160043¦19/9/16: 20%->60. FCD / Impacted TSs and TRs: 33.106; 33.107; 33.108 / WI rapporteur e-mail: Koen Jaspers (k.b.jaspers@minjus.nl), terry.jacobson@alcatel-lucent.com
- 4450: Linked to LI13 which defines existing LI service requirements in TS 33.106 as well as existing HI1, HI2 & HI3 reference points. 3/3/15: 0->5%¦7/12/15: 5%->10. Stoppped at 10% in March 2017.¦6/3/17: 10%->100 / Impacted TSs and TRs: 33.826 / WI rapporteur e-mail: terry.jacobson@alcatel-lucent.com
- 4451: Dec.14: 5->20%. Mar.15: 40%¦07/09/15: 43%->100 / Impacted TSs and TRs: 26.114 / WI rapporteur e-mail: ozgur.oyman@intel.com
- 4452: Created by MCC as the structure of the Feature get expanded to include CT aspects¦June2015: Compl:40%->90, FCD: 06/15->09/15¦Aug2015: Compl:90%->95 / Impacted TSs and TRs: 26.114 / WI rapporteur e-mail: ozgur.oyman@intel.com

| ID | WBS | Task | Duration | Start | Finish | Complete | Baseline start | Baseline finish | Baseline duration | Constraint | Resources | Work | Actual work | Acronym | PCG approved | WI rapporteur name | Release | TSG approved | Impacted TSs and TRs | Acronym_3GU_Export | Status Report | MCC resp |
| --- | --- | --- | --- | --- | --- | --- | --- | --- | --- | --- | --- | --- | --- | --- | --- | --- | --- | --- | --- | --- | --- | --- |
| 4453 | 1742.2 | **CT Aspects of Video Enhancements by Region-Of-Interest information signalling** | 191.5d? | 2015-06-15 A | 2015-12-16 A | 100% |  |  |  |  | C4 | 4256h | 4256h | ROI-CT | 35 | Vivek Gupta, Intel | Rel-13 | 68 |  |  |  |  |
| 4454 | 1742.2.1 | CT1 Aspects of Video Enhancements by Region-Of-Interest information signalling | 133d? | 2015-06-15 A | 2015-12-16 A | 100% |  |  |  | start no earlier than 2015-06-15 | C1 | 1064h | 1064h | ROI-CT | 35 | Vivek Gupta, Intel | Rel-13 | 68 | 24.229 |  |  |  |
| 4455 | 1742.2.2 | CT3 Aspects of Video Enhancements by Region-Of-Interest information signalling | 133d? | 2015-06-15 A | 2015-12-16 A | 100% |  |  |  | start no earlier than 2015-06-15 | C3 | 1064h | 1064h | ROI-CT | 35 | Vivek Gupta, Intel | Rel-13 | 68 | 29.162 |  |  |  |
| 4456 | 1742.2.3 | CT4 Aspects of Video Enhancements by Region-Of-Interest information signalling | 133d? | 2015-06-15 A | 2015-12-16 A | 100% |  |  |  | start no earlier than 2015-06-15 | C4 | 1064h | 1064h | ROI-CT | 35 | Vivek Gupta, Intel | Rel-13 | 68 | 23.334; 29.334; 29.238 |  |  |  |
| 4457 | 1743 | **TV video profile** | 569.25d? | 2014-09-09 A | 2016-03-11 A | 100% |  |  |  |  | S4 | 9504h | 9504h | TVProf | 33 | Orange | Rel-13 | 65 |  | TVProf |  |  |
| 4458 | 1743.1 | TR on TV video profile | 396d? | 2014-09-09 A | 2016-03-11 A | 100% |  |  |  | finish no earlier than 2016-03-11 | S4 | 3168h | 3168h | TVProf-SA4TR | 33 | Orange | Rel-13 | 65 | New 26.9xy; ES in SP-150650 |  |  |  |
| 4459 | 1743.2 | Specification on TV video profile | 396d? | 2014-09-09 A | 2016-03-11 A | 100% |  |  |  | finish no earlier than 2016-03-11 | S4 | 3168h | 3168h | TVProf-SA4 | 33 | Orange | Rel-13 | 65 | 26.234; 26.244; 26.346; 26.247; New 26.xyz; ES in SP-150650 |  |  |  |
| 4460 | 1744 | Enhanced LTE UE Delay test methods and requirements | 464d? | 2014-09-09 A | 2016-06-15 A | 100% |  |  |  | finish no earlier than 2016-06-15 | S4 | 3712h | 3712h | E_LTE_UED | 33 | Orange | Rel-13 | 65 | 26.131; 26.132 | E_LTE_UED |  |  |
| 4461 | 1745 | HTML5 Presentation Layer | 334d? | 2014-09-09 A | 2015-12-16 A | 100% |  |  |  | finish no earlier than 2015-12-16 | S4 | 2672h | 2672h | HTML5 | 33 | Samsung | Rel-13 | 65 | 26.140; 26.234; 26.247; 26.346; New 26.xyz | HTML5 |  |  |
| 4462 | 1746 | **Support of EVS in 3G Circuit-Switched networks** | 569.25d? | 2014-09-09 A | 2016-03-11 A | 100% |  |  |  |  | S4; C4; C1; C3; R1; R2; R3 | 24952h | 24952h | EVSoCS | 33 | Qualcomm | Rel-13 | 65 | 26.103; 28.062; New 26.454; New 26.453 | EVSoCS |  |  |
| 4463 | 1746.1 | SA4 aspects of EVS in 3G Circuit-Switched networks | 396d? | 2014-09-09 A | 2016-03-11 A | 100% |  |  |  | finish no earlier than 2016-03-11 | S4 | 3168h | 3168h | EVSoCS-S4 | 33 | Qualcomm | Rel-13 | 65 | 26.103; 28.062; New 26.454; New 26.453 | EVSoCS |  |  |
| 4464 | 1746.2 | **CT aspects of EVS in 3G Circuit-Switched Networks** | 387.25d? | 2015-03-04 A | 2016-03-11 A | 100% |  |  |  |  | C4; C1; C3 | 12344h | 12344h | EVSoCS-CT | 34 | Qualcomm, Lena Chaponniere | Rel-13 | 67 |  |  |  |  |
| 4465 | 1746.2.1 | CT1 aspects of EVS in 3G Circuit-Switched Networks | 203d? | 2015-03-04 A | 2015-12-11 A | 100% |  |  |  | finish no earlier than 2015-12-11 | C1 | 1624h | 1624h | EVSoCS-CT | 34 | Qualcomm, Lena Chaponniere | Rel-13 | 67 | 24.008 |  |  |  |
| 4466 | 1746.2.2 | CT3 aspects of EVS in 3G Circuit-Switched Networks | 268d? | 2015-03-04 A | 2016-03-11 A | 100% |  |  |  | finish no earlier than 2016-03-11 | C3 | 2144h | 2144h | EVSoCS-CT | 34 | Qualcomm, Lena Chaponniere | Rel-13 | 67 | 29.163; 29.414; 29.415 |  |  |  |
| 4467 | 1746.2.3 | CT4 aspects of EVS in 3G Circuit-Switched Networks | 268d? | 2015-03-04 A | 2016-03-11 A | 100% |  |  |  | finish no earlier than 2016-03-11 | C4 | 2144h | 2144h | EVSoCS-CT | 34 | Qualcomm, Lena Chaponniere | Rel-13 | 67 | 23.153; 23.334; 29.002; 29.231; 29.232; 29.332; 29.334 |  |  |  |
| 4468 | 1746.3 | **Support of EVS over UTRAN CS** | 189.17d? | 2015-06-16 A | 2015-12-15 A | 100% |  |  |  |  | R2; R1; R3 | 6272h | 6272h | EVSoCS_UTRAN | 34 | Qualcomm | Rel-13 | 66 |  |  |  |  |
| 4469 | 1746.3.1 | Core part: Support of EVS over UTRAN CS | 130.67d? | 2015-06-16 A | 2015-12-15 A | 100% |  |  |  | finish no earlier than 2015-12-15 | R2; R1; R3 | 3136h | 3136h | EVSoCS_UTRAN-Core | 34 | Francesco Pica - Qualcomm Incorporated | Rel-13 | 66 |  |  | RP-151282 |  |
| 4470 | 1747 | Enhanced DASH (Dynamic Adaptive Streaming over HTTP in 3GPP) | 334d? | 2014-09-09 A | 2015-12-16 A | 100% |  |  |  | finish no earlier than 2015-12-16 | S4 | 2672h | 2672h | eDASH | 33 | Qualcomm, Huawei | Rel-13 | 65 | 26.233; 26.234; 26.244; 26.247; 26.938; 26.346; 26.946 | eDASH |  |  |
| 4471 | 1748 | **QoS End-to-end Multimedia Telephony Service for IMS (MTSI) extensions (Stage 3)** | 1140.25d? | 2013-03-06 A | 2016-03-11 A | 100% | 2013-03-06 | 2015-03-13 | 533d? |  | S4; C3; C1; C4 | 53457.8h | 53457.8h | QOSE2EMTSI | 30 | Ericsson | Rel-13 | 59 |  | QOSE2EMTSI |  | Paolo |
| 4472 | 1748.1 | TR on improved end-to-end QoS handling for MTSI | 589d? | 2013-12-11 A | 2016-03-11 A | 100% | 2013-12-11 | 2015-03-13 | 329d? | finish no earlier than 2016-03-11 | S4 | 4705.83h | 4705.83h | QOSE2EMTSI | 32 | Ericsson | Rel-13 | 62 | new 26.924 |  |  | Paolo |
| 4473 | 1748.2 | SA4 part of QoS End-to-end Multimedia Telephony Service for IMS (MTSI) extensions (Stage 3) | 792d? | 2013-03-06 A | 2016-03-11 A | 100% | 2013-03-06 | 2015-03-13 | 532d? | finish no earlier than 2016-03-11 | S4 | 6336h | 6336h | QOSE2EMTSI | 30 | Ericsson | Rel-13 | 59 | 26.114 |  |  | Paolo |
| 4474 | 1748.3 | **CT Aspects of QoS End-to-End MTSI Extensions** | 510.5d? | 2014-11-05 A | 2016-03-11 A | 100% |  |  |  |  | C3; C1; C4 | 16944h | 16944h | QOSE2EMTSI-CT | 34 | Ericsson | Rel-13 | 66 |  |  |  |  |
| 4475 | 1748.3.1 | CT3 Aspects of QoS End-to-End MTSI Extensions | 353d? | 2014-11-05 A | 2016-03-11 A | 100% |  |  |  | finish no earlier than 2016-03-11 | C3 | 2824h | 2824h | QOSE2EMTSI-CT | 34 | Ericsson | Rel-13 | 66 | 29.162; 29.163; 29.213; 29.214 |  |  |  |
| 4476 | 1748.3.2 | CT1 Aspects of QoS End-to-End MTSI Extensions | 353d? | 2014-11-05 A | 2016-03-11 A | 100% |  |  |  | finish no earlier than 2016-03-11 | C1 | 2824h | 2824h | QOSE2EMTSI-CT | 34 | Ericsson | Rel-13 | 66 | 24.229 |  |  |  |
| 4477 | 1748.3.3 | CT4 Aspects of QoS End-to-End MTSI Extensions | 353d? | 2014-11-05 A | 2016-03-11 A | 100% |  |  |  | finish no earlier than 2016-03-11 | C4 | 2824h | 2824h | QOSE2EMTSI-CT | 34 | Ericsson | Rel-13 | 66 | 23.333; 23.334; 29.238; 29.332; 29.333; 29.334 |  |  |  |

Notes:
- 4453: 14/09/15: WID:CP-150241->CP-150425 / WI rapporteur e-mail: vivek.g.gupta@intel.com
- 4454: 07/09/15: 100%->50¦14/09/15: WID:CP-150241->CP-150425¦7/12/15: 50%->100 / WI rapporteur e-mail: vivek.g.gupta@intel.com
- 4455: 07/09/15: 100%->10¦14/09/15: WID:CP-150241->CP-150425¦7/12/15: 10%->100 / WI rapporteur e-mail: vivek.g.gupta@intel.com
- 4456: 07/09/15: 100%->5¦14/09/15: WID:CP-150241->CP-150425¦7/12/15: 5%->100 / WI rapporteur e-mail: vivek.g.gupta@intel.com
- 4457: Mar. 15: 5->15% / WI rapporteur e-mail: gilles.teniou@orange.com
- 4458: Dec.14: 0->5%¦June2015: Compl:15%->30¦Aug2015: 30%->45¦07/09/15: 45%->70¦7/12/15: 70%->85, FCD: 12/15->03/16¦7/3/16: 85%->100 / WI rapporteur e-mail: gilles.teniou@orange.com
- 4459: Dec.14: 0->5%¦June2015: Compl:15%->30¦Aug2015: 30%->45¦07/09/15: 45%->70¦7/12/15: 70%->85, FCD: 12/15->03/16. ES in SP-150650¦7/3/16: 85%->100 / WI rapporteur e-mail: gilles.teniou@orange.com
- 4460: Mar. 15: 0->5%¦June2015: Compl:5%->10¦Aug2015: 10%->15¦07/09/15: 15%->50¦7/12/15: 50%->80, FCD: 12/15->03/16. ES in SP-150652¦7/3/16: FCD: 03/16->06/16¦11/6/16: 80%->100 / WI rapporteur e-mail: stephane.ragot@orange.com
- 4461: Triggered by Rel-12 TR 26.907 (Study of HTML5 and 3GPP User Services). Dec.14: 0->5%. Mar. 15: 10%¦June2015: Compl:10%->20¦Aug2015: 20%->40¦07/09/15: 40%->70¦7/12/15: 70%->100 / WI rapporteur e-mail: Imed Bouazizi (i.bouazizi@samsung.com)
- 4462: Provide CS support of EVS to enhance voice quality in CS services over UTRAN (3G WCDMA). Dec.14: 0->5%¦28/1/16: 26.454 added¦28/1/16: 26.453 added; / WI rapporteur e-mail: Imre Varga (ivarga@qti.qualcomm.com)
- 4463: Created by MCC (duplicated from previously single-line Feature) due to the introduction of the CT BB. Mar. 15: 10%¦Aug2015: 10%->20¦07/09/15: 20%->40¦7/12/15: 40%->60, FCD:12/15->03/16. ES in SP-150655¦28/1/16: 26.454 added¦28/1/16: 26.453 added; / WI rapporteur e-mail: Imre Varga (ivarga@qti.qualcomm.com)
- 4464: WI rapporteur e-mail: lguellec@qti.qualcomm.com
- 4465: 07/09/15: 0%->90¦7/12/15: 90%->100 / WI rapporteur e-mail: lguellec@qti.qualcomm.com
- 4466: June2015: Compl:0%->10¦07/09/15: 10%->15¦7/12/15: 15%->90. FCD -> 03/16, ES in CP-150638¦7/3/16: 90%->100 / WI rapporteur e-mail: lguellec@qti.qualcomm.com
- 4467: June2015: Compl:0%->95. FCD -> 03/16, ES in CP-150618¦7/3/16: 95%->100 / WI rapporteur e-mail: lguellec@qti.qualcomm.com
- 4468: WI rapporteur e-mail: Qualcomm
- 4469: Rapporteur details and involved WGs updated 1st Apr 15: Compl:0%->10% 1st Apr 15: Stat Rep: ->RP-150128. 5/5/15: 0->10% 03/07/15: Compl:10%->25% 03/07/15: Stat Rep: RP-150128->RP-150759 29/09/15: Compl:25%->50% 29/09/15: CD:Tue 15/09/15->Tue 15/12/15 2 / WI rapporteur e-mail: fpica@qti.qualcomm.com
- 4470: Triggered by Rel-12 Dec.14: 0->10%. Mar. 15: 15%¦June2015: Compl:15%->25. WID updated¦Aug2015: 25%->30¦07/09/15: 30%->60¦14/09/15: WID:SP-150211->SP-150448¦7/12/15: 60%->100 / WI rapporteur e-mail: Thomas Stockhammer (tsto@qti.qualcomm.com), Li Zhiming (lizhiming@huawei.com)
- 4471: SP#65 updated WID SP-130670=>SP-140601 (moved work from Rel-12 incl. new TR to Rel-13). Co-ordinate with SA2, CT1/3/4, IETF MMUSIC. Linked to SA4 Rel-7 Media handling and interaction in MTSI (MTSI-MHI) UID_7040 / WI rapporteur e-mail: tomas.frankkila@ericsson.com
- 4472: SP#65 updated WID SP-130670=>SP-140601 (moved work from Rel12 incl. new TR to Rel-13). Completion 03/15=>06/15. Mar15: 26.924 for info. 8/4/15: 50%¦Aug2015: 50%->60¦7/12/15: 75%->90, FCD: 06/15->03/16¦7/3/16: 90%->100 / WI rapporteur e-mail: tomas.frankkila@ericsson.com
- 4473: SP#65: WID SP-130670=>SP-140601 (moved from Rel12 incl. new TR to Rel-13). FCD 03/15=>06/15. St1 in TS 22.173. 12/14: 70->40%, CD: 06/15->09/15. 03/15: 50%. June 15: FCD: 09/15->12/15¦08/15: 60%¦09/15: 75%¦7/12. ES in SP-150658¦7/3/16: 90%->100 / WI rapporteur e-mail: tomas.frankkila@ericsson.com
- 4475: 7/12/15: 0%->70. FCD -> 03/16, ES in CP-150636¦7/3/16: 70%->100
- 4476: FCD -> 03/16, ES in CP-150726¦7/3/16: 0%->100
- 4477: FCD -> 03/16, ES in CP-150620¦7/3/16: 0%->100

| ID | WBS | Task | Duration | Start | Finish | Complete | Baseline start | Baseline finish | Baseline duration | Constraint | Resources | Work | Actual work | Acronym | PCG approved | Release | TSG approved | MCC resp | Special Focus Doc | Acronym_3GU_Export |
| --- | --- | --- | --- | --- | --- | --- | --- | --- | --- | --- | --- | --- | --- | --- | --- | --- | --- | --- | --- | --- |
| 4478 | 1749 | **MTSI Extension on Multi-stream Multiparty** | 468.25d? | 2014-12-12 A | 2016-03-07 A | 100% |  |  |  |  |  | 3176h | 3176h | MMCMH | 34 | Rel-13 | 66 |  |  |  |
| 4479 | 1749.1 | Codec aspects for MMCMH | 265d? | 2014-12-12 A | 2015-12-17 A | 100% |  |  |  | finish no earlier than 2015-12-17 | S4 | 2120h | 2120h | MMCMH | 34 | Rel-13 | 66 |  |  |  |
| 4480 | 1749.2 | (IETF) RTP Stream Pause and Resume (RFC 7728) | 66d? | 2015-12-07 A | 2016-03-07 A | 100% |  |  |  | finish no earlier than 2016-03-07 | S4-IETF | 528h | 528h | MMCMH | 36 | Rel-13 | 71 |  |  |  |
| 4481 | 1749.3 | (IETF) Using Simulcast in SDP and RTP Sessions (draft-ietf-mmusic-sdp-simulcast) | 66d? | 2015-12-07 A | 2016-03-07 A | 100% |  |  |  | start no earlier than 2015-12-07 | S4-IETF | 528h | 528h | MMCMH | 37 | Rel-13 | 72 |  |  |  |
| 4482 | 1750 | **Video Telephony Robustness Improvements Extensions** | 283.75d? | 2014-12-12 A | 2015-09-11 A | 100% |  |  |  |  | S4 | 6272h | 6272h | VTRI_EXT | 34 | Rel-13 | 66 |  |  |  |
| 4483 | 1750.1 | TR on Video Telephony Robustness Improvements | 196d? | 2014-12-12 A | 2015-09-11 A | 100% |  |  |  | finish no earlier than 2015-09-11 | S4 | 1568h | 1568h | VTRI_EXT | 34 | Rel-13 | 66 |  |  |  |
| 4484 | 1750.2 | Specification on Video Telephony Robustness Improvements | 196d? | 2014-12-12 A | 2015-09-11 A | 100% |  |  |  | finish no earlier than 2015-09-11 | S4 | 1568h | 1568h | VTRI_EXT | 34 | Rel-13 | 66 |  |  |  |
| 4485 | 1750.3 | (IETF) RTP Payload Format for Non-Interleaved and Interleaved Parity Forward Error Correction (FEC) (draft-ietf-payload-flexible-fec-scheme) --> RFC 8627 | 196d? | 2014-12-12 A | 2015-09-11 A | 100% |  |  |  | finish no earlier than 2015-09-11 | S4-IETF | 1568h | 1568h | VTRI_EXT | 35 | Rel-13 | 69 |  |  |  |
| 4486 | 1751 | Acoustic Test methods and Performance Objectives for Speakerphone Performance in Noisy Environments | 326d? | 2014-12-12 A | 2016-03-11 A | 100% |  |  |  | finish no earlier than 2016-03-11 | S4 | 2608h | 2608h | ATeMPO_SPINE | 34 | Rel-13 | 66 |  |  |  |
| 4487 | 1752 | **Rel-13 Operations, Administration, Maintenance and Provisioning (OAM&P)** | 1408d? | 2012-06-20 A | 2016-03-11 A | 100% | 2014-09-17 | 2015-12-11 | 323d? |  | S5 | 57504h | 57504h | OAM13 | 32 | Rel-13 | 63 | Mirko | SON | OAM13 |
| 4488 | 1752.1 | Enhanced Network Management (NM) centralized Coverage and Capacity Optimization | 319d? | 2014-09-19 A | 2015-12-11 A | 100% | 2014-09-17 | 2015-12-11 | 319d? | finish no earlier than 2015-12-11 | S5 | 2552h | 2552h | SON-NM-CCO | 29 | Rel-13 | 56 | Mirko | SON | SON-NM-CCO |
| 4489 | 1752.2 | **Compliance of 3GPP SA5 specifications to the NGMN Top Operational Efficiency (OPE) Recommendations** | 1036.25d? | 2012-06-20 A | 2015-03-18 A | 100% | 2012-06-20 | 2014-09-17 | 595d? |  | S5 | 17368h | 17368h | OAM-NGMN_OPE | 29 | Rel-13 | 56 | Mirko |  | OAM-NGMN_OPE |
| 4490 | 1752.2.1 | TR on Compliance of 3GPP SA5 specifications to the NGMN Top Operational Efficiency (OPE) Recommendations | 723d? | 2012-06-20 A | 2015-03-18 A | 100% | 2012-06-20 | 2014-09-17 | 593d? | finish no earlier than 2015-03-18 | S5 | 5784h | 5784h | OAM-NGMN_OPE | 29 | Rel-13 | 56 | Mirko |  |  |
| 4491 | 1752.2.2 | TS work on Compliance of 3GPP SA5 specifications to the NGMN Top Operational Efficiency (OPE) Recommendations | 720d? | 2012-06-25 A | 2015-03-18 A | 100% | 2012-06-25 | 2014-09-17 | 590d? | finish no earlier than 2015-03-18 | S5 | 5760h | 5760h | OAM-NGMN_OPE | 29 | Rel-13 | 56 | Mirko |  |  |
| 4492 | 1752.3 | Converged management Performance Management Interface Definitions | 910d? | 2012-06-20 A | 2015-12-11 A | 100% | 2012-06-20 | 2014-09-17 | 588d? | finish no earlier than 2015-12-11 | S5 | 7280h | 7280h | OAM-PMID | 29 | Rel-13 | 56 | Mirko |  | OAM-PMID |
| 4493 | 1752.4 | **WLAN Management** | 1123.25d? | 2012-06-27 A | 2015-06-17 A | 100% | 2012-06-20 | 2014-09-17 | 595d? |  | S5 | 18848h | 18848h | WLAN-OAM | 29 | Rel-13 | 56 | Mirko | WLAN | WLAN-OAM |
| 4494 | 1752.4.1 | WLAN Network Resource Model for Type-2 interface | 784d? | 2012-06-27 A | 2015-06-17 A | 100% | 2012-06-27 | 2014-09-17 | 589d? | finish no earlier than 2015-06-17 | S5 | 6272h | 6272h | WLAN-OAM-SA5 | 29 | Rel-13 | 56 | Mirko | WLAN |  |
| 4495 | 1752.4.2 | WLAN measurements defined in IEEE and IETF WLAN performance measurements for use on Type-2 interface | 784d? | 2012-06-27 A | 2015-06-17 A | 100% | 2012-06-27 | 2014-09-17 | 589d? | finish no earlier than 2015-06-17 | S5 | 6272h | 6272h | WLAN-OAM-SA5ietf | 29 | Rel-13 | 56 | Mirko | WLAN |  |
| 4496 | 1752.5 | Energy Efficiency related Performance Measurements | 713d? | 2013-06-21 A | 2016-03-11 A | 100% | 2013-06-21 | 2014-09-17 | 326d? | finish no earlier than 2016-03-11 | S5 | 5704h | 5704h | OAM-PM_EE | 31 | Rel-13 | 60 | Mirko |  | OAM-PM_EE |
| 4497 | 1752.6 | Multi-Broadcast Single Frequency Network (MBSFN) Minimization of Drive Tests (MDT) enhancement | 1d? | 2014-12-12 A | 2014-12-12 A | 100% |  |  |  | start no earlier than 2014-12-12 | S5 | 8h | 8h | MBSFN_MDT | 34 | Rel-13 | 66 |  |  |  |
| 4498 | 1753 | **Rel-13 Charging** | 565.12d? | 2014-06-19 A | 2015-12-16 A | 100% | 2014-06-18 | 2015-12-09 | 386d? |  | S5 | 16236h | 16236h | CH13 | 33 | Rel-13 | 64 |  |  | CH13 |
| 4499 | 1753.1 | **Inter-PLMN PS domain online charging** | 565.12d? | 2014-06-19 A | 2015-12-16 A | 100% | 2014-06-18 | 2015-12-09 | 386d? |  | S5 | 8360h | 8360h | iPLMN-PS-OCH | 33 | Rel-13 | 64 |  |  | iPLMN-PS-OCH |
| 4500 | 1753.1.1 | TR on Inter-PLMN PS domain online charging | 261d? | 2014-06-19 A | 2015-06-17 A | 100% | 2014-06-18 | 2015-06-17 | 261d? | finish no earlier than 2015-06-17 | S5 | 2088h | 2088h | iPLMN-PS-OCH | 33 | Rel-13 | 64 |  |  |  |
| 4501 | 1753.1.2 | Specification of Inter-PLMN PS domain online charging | 391d? | 2014-06-23 A | 2015-12-16 A | 100% | 2014-06-18 | 2015-12-09 | 386d? | finish no earlier than 2015-12-16 | S5 | 3128h | 3128h | iPLMN-PS-OCH | 33 | Rel-13 | 64 |  |  |  |
| 4502 | 1753.2 | ULI and release causes for charging enhancement for VoLTE | 257d? | 2014-12-12 A | 2015-12-07 A | 100% |  |  |  | finish no earlier than 2015-12-07 | S5 | 2056h | 2056h | ULRELC-CH | 34 | Rel-13 | 66 |  |  |  |
| 4503 | 1753.3 | Charging on enhancements for IMS Service Continuity | 135d? | 2015-03-05 A | 2015-09-09 A | 100% |  |  |  | finish no earlier than 2015-12-11 | S5 | 1080h | 1080h | CHeISC | 34 | Rel-13 | 67 |  |  |  |
| 4504 | 1753.4 | Announcements for IMS Online Charging | 131d? | 2015-06-15 A | 2015-12-14 A | 100% |  |  |  | start no earlier than 2015-06-14 | S5 | 1048h | 1048h | ANIMO | 35 | Rel-13 | 68 |  |  |  |
| 4505 | 1753.5 | Enhanced S2a Mobility Over Trusted WLAN access to EPC - Charging | 68.5d? | 2015-06-15 A | 2015-09-17 A | 100% |  |  |  | start no earlier than 2015-06-15 | S5 | 548h | 548h | eSaMOG-CH | 35 | Rel-13 | 68 |  |  |  |

Notes:
- 4478: Mar. 15: 0->10%. WID: SP-140738->SP-150097¦June2015: Compl:10%->30¦Aug2015: 30%->50, FCD: sep->Dec 2015¦07/09/15: 50%->60¦7/12/15: 60%->100¦10/12/15: WID:SP-150097->SP-150660. Might be moved to Rel-14 (see note in UID710002) / Impacted TSs and TRs: 26.114; New 26.980 / WI rapporteur name: Tomas Frankkila, Ericsson LM / WI rapporteur e-mail: tomas.frankkila@ericsson.com
- 4479: Introduced by MCC to dissociate S4 from IeTF aspects / Impacted TSs and TRs: 26.114; New 26.980 / WI rapporteur name: Tomas Frankkila, Ericsson LM / WI rapporteur e-mail: tomas.frankkila@ericsson.com
- 4480: 02/2016: published as RFC 7728 / Impacted TSs and TRs: (IETF) RTP Stream Pause and Resume (RFC 7728) / WI rapporteur name: Ericsson / WI rapporteur e-mail: tomas.frankkila@ericsson.com
- 4481: Was (IETF) (draft-ietf-mmusic-sdp-simulcast); 23/4/20: 0%->90; 9/4/21: RFC 8853 added; / Impacted TSs and TRs: RFC 8853
- 4482: New TR added. 3/3/15: "extensions" added in the title. Mar. 15: 0->10% / Impacted TSs and TRs: 26.922 (new); 26.114 / WI rapporteur name: Muhammed Coban, Qualcomm Incorporated / WI rapporteur e-mail: mcoban@qti.qualcomm.com
- 4483: 3/3/15: created to distinguish TR and TS tasks¦June2015: Compl:10%->40¦Aug2015: 40%->95¦07/09/15: 95%->100 / Impacted TSs and TRs: 26.922 (new); 26.114 / WI rapporteur name: Muhammed Coban, Qualcomm Incorporated / WI rapporteur e-mail: mcoban@qti.qualcomm.com
- 4484: 3/3/15: created to distinguish TR and TS tasks¦June2015: Compl:10%->40¦Aug2015: 40%->95¦07/09/15: 95%->100 / Impacted TSs and TRs: 26.922 (new); 26.114 / WI rapporteur name: Muhammed Coban, Qualcomm Incorporated / WI rapporteur e-mail: mcoban@qti.qualcomm.com
- 4485: 26.114, draft-ietf-payload-flexible-fec-scheme. 7/10/15: rapporteur added; 23/4/20: 10%->100 / Impacted TSs and TRs: 26.114; draft-ietf-payload-flexible-fec-scheme / WI rapporteur name: Muhammed Coban, Qualcomm Incorporated / WI rapporteur e-mail: mcoban@qti.qualcomm.com
- 4486: June2015: Compl:0%->10. Aug: FCD: Jun->Sep15¦07/09/15: 10%->30, FCD:09/15->12/15¦7/12/15: 40%->80, FCD: 12/15->03/16. ES in SP-150642¦7/3/16: 80%->100 / Impacted TSs and TRs: 26.131; 26.132 / WI rapporteur name: Andre Schevciw, Qualcomm Incorporated; Scott Isabelle, Audience Inc. / WI rapporteur e-mail: aschevci@qti.qualcomm.com; sisabelle@audience.com
- 4487: OAM13 is an umbrella Feature for changes that are not part of any other dedicated feature/WI¦June2015: WID:-->SP-150305¦5/10/15: 28.683 added; / Impacted TSs and TRs: 28.683
- 4488: SP#64 work not started. Dec.14: 0->20, cd: 06/15->12/15. Mar 15: 20->30%¦June2015: Compl:30%->50¦07/09/15: 50%->60¦7/12/15: 60%->100 / Impacted TSs and TRs: 28.627; 28.628; 32.103; 32.422; 32.425; 32.442 / WI rapporteur name: Ericsson / WI rapporteur e-mail: robert.petersen@ericsson.com
- 4489: SP#65 updated WID SP-120349=>SP-140538. Completion 12/14=>03/15. Moved to Rel-13. Source of external requirements: NGMN Top OPE Recommendations 1.0 / WI rapporteur name: Huawei / WI rapporteur e-mail: christian.toche@huawei.com
- 4490: SP#65 updated WID SP-120349=>SP-140538. Completion 12/14=>03/15. Moved to Rel-13.. Dec.14: 72->78. Mar 15: 80%¦June2015: Compl:80%->85¦07/09/15: 85%->90¦7/12/15: 90%->100 / Impacted TSs and TRs: New 32.838 / WI rapporteur name: Huawei / WI rapporteur e-mail: christian.toche@huawei.com
- 4491: SP#65 updated WID SP-120349=>SP-140538. Completion 12/14=>03/15. Moved to Rel-13¦7/12/15: 50%->100 / Impacted TSs and TRs: 32.101/2/3.32.111-1.32.111-2.32.111-6.32.15x.32.401.32.411.32.412.32.421.32.422.32.423.32.431.32.432.32.436.32.441.32.442.32.446.32.500.32.501.32.502.32.506.32.521.32.522.32.526.32.531.32.532.32.536.32.551.32.691.32.692.32.696.32.762 / WI rapporteur name: Huawei / WI rapporteur e-mail: christian.toche@huawei.com
- 4492: SP#65 updated WID SP-130641=>SP-140613. Completion 09/14=>12/15. Moved to Rel-13. Completion 09/14=>12/15. Dec.14: 20->30¦June2015: Compl:30%->60¦07/09/15: 60%->80¦7/12/15: 80%->100¦7/12/15: WID:SP-140613->SP-150678 / Impacted TSs and TRs: new TSs 32.863 / WI rapporteur name: Huawei / WI rapporteur e-mail: christian.toche@huawei.com
- 4493: SP#65 moved to Rel-13. Updated WID SP-130042=>SP-140535 (split into Rel-12 Study & Rel-13 normative WI). TR 32.841 was completed as a Rel-12 Study and has triggered this normative work / WI rapporteur name: Intel / WI rapporteur e-mail: joey.chou@intel.com
- 4494: SP#65 updated WID SP-130042=>SP-140535. Completion 09/14=>06/15. Moved to Rel-13. Dec.14: 10->20¦June2015: Compl:20%->70¦07/09/15: 70%->80¦7/12/15: 80%->100 / Impacted TSs and TRs: new (28.680; 28.682); 28.681 / WI rapporteur name: Intel / WI rapporteur e-mail: joey.chou@intel.com
- 4495: SP#65 updated WID SP-130042=>SP-140535. Completion 09/14=>06/15. Moved to Rel-13. 22/01:Acronym modified¦June2015: Compl:5%->20¦07/09/15: 20%->60¦7/12/15: 60%->100 / Impacted TSs and TRs: new 28.403 / WI rapporteur name: Intel / WI rapporteur e-mail: joey.chou@intel.com
- 4496: SP#65 updated WID SP-130263=>SP-140612. Completion 09/14=>06/15. Moved to Rel-13¦June2015: Compl:25%->40¦07/09/15: 40%->50. ES in SP-150708¦7/3/16: 50%->100 / Impacted TSs and TRs: 32.425 / WI rapporteur name: Nokia Networks / WI rapporteur e-mail: Yizhi.yao@nsn.com
- 4497: Mar 15: 0->15%¦June2015: Compl:15%->100 / Impacted TSs and TRs: 32.421; 32.422; 32.423; 32.441; 32.442; 32.446 / WI rapporteur name: Padma Sudarsan (Alcatel-Lucent) / WI rapporteur e-mail: padma.sudarsan<AT>alcatel-lucent<DOT>com
- 4498: CH13 is an umbrella Feature for changes that are not part of any other dedicated feature/WI¦June2015: WID:-->SP-150307
- 4499: Study and specify Gy Reference Point service data flows based online charging for inter-PLMN situations / Impacted TSs and TRs: Stage 2/3 / WI rapporteur name: Alcatel-Lucent / WI rapporteur e-mail: maryse.gardella@alcatel-lucent.com
- 4500: Dec.14: 10->25%. Mar15: 20->60%. 06/15: 100%¦7/12/15: 100%->100 / Impacted TSs and TRs: New 32.843 / WI rapporteur name: Alcatel-Lucent / WI rapporteur e-mail: maryse.gardella@alcatel-lucent.com
- 4501: 07/09/15: 0%->80¦7/12/15: 80%->100 / Impacted TSs and TRs: 32.251; 32.299 / WI rapporteur name: Alcatel-Lucent / WI rapporteur e-mail: maryse.gardella@alcatel-lucent.com
- 4502: Acronym changed to ULRELC-CH. Mar15: 0->5%. CD: 12/14->09/15. 06/15: 20%¦07/09/15: 20%->40¦7/12/15: 40%->100, FCD: 09/15->12/15 / Impacted TSs and TRs: 32.251; 32.260; 32.299; 32.298; / WI rapporteur name: Alcatel-Lucent, Maryse Gardella / WI rapporteur e-mail: Alcatel-Lucent, Maryse <dot> Gardella <at> Alcatel-Lucent <dot> com
- 4503: 06/15: 0->50%¦07/09/15: 50%->100. FCD: 12/15->09/15 / Impacted TSs and TRs: 32.260; 32.299; 32.298 / WI rapporteur name: Gerald Goermer / WI rapporteur e-mail: Gerald <dot> Goermer <at> nsn <dot> com
- 4504: 07/09/15: 0%->30¦7/12/15: 30%->100¦7/12/15: WID:SP-150307->SP-150675 / Impacted TSs and TRs: 32.260; 32.275; 32.299; 32.240; 32.281 / WI rapporteur name: Amdocs, Naceur <dot> Lagha <at> Amdocs <dot> com
- 4505: 07/09/15: 0%->30¦7/12/15: 30%->100 / Impacted TSs and TRs: 32.240; 32.251; 32.299; 32.298 / WI rapporteur name: Alcatel-Lucent, Maryse <dot> Gardella <at> Alcatel-Lucent <dot> com

| ID | WBS | Task | Duration | Start | Finish | Complete | Remaining | Baseline start | Baseline finish | Baseline duration | Total slack | Constraint | Resources | Work | Actual work | Acronym | PCG approved | WI rapporteur name | WI rapporteur e-mail | Release | TSG approved | MCC resp | Acronym_3GU_Export | Status Report |
| --- | --- | --- | --- | --- | --- | --- | --- | --- | --- | --- | --- | --- | --- | --- | --- | --- | --- | --- | --- | --- | --- | --- | --- | --- |
| 4506 | 1754 | **Support of Real-time Transport Protocol (RTP) / Real-time Transport Control Protocol (RTCP) multiplexing (signalling) in IMS** | 852.62d? | 2013-09-09 A | 2015-12-11 A | 100% |  | 2013-09-09 | 2014-09-12 | 267d? |  |  | C4; C1; C3 | 28464h | 28464h | RTCP_MUX | 31 | Alcatel-Lucent | Albrecht.Schwarz@alcatel-lucent.com | Rel-13 | 61 | Kimmo | RTCP_MUX |  |
| 4507 | 1754.1 | CT4 part of Support of RTP / RTCP multiplexing (signalling) in IMS | 591d? | 2013-09-09 A | 2015-12-11 A | 100% |  | 2013-09-09 | 2014-09-12 | 266d? |  | finish no earlier than 2015-12-11 | C4 | 4728h | 4728h | RTCP_MUX | 31 | Alcatel-Lucent | Albrecht.Schwarz@alcatel-lucent.com | Rel-13 | 61 | Kimmo |  |  |
| 4508 | 1754.2 | CT1 part of Support of RTP / RTCP multiplexing (signalling) in IMS | 591d? | 2013-09-13 A | 2015-12-11 A | 100% |  | 2013-09-10 | 2014-09-12 | 266d? |  | finish no earlier than 2015-12-11 | C1 | 4728h | 4728h | RTCP_MUX | 31 | Alcatel-Lucent | Albrecht.Schwarz@alcatel-lucent.com | Rel-13 | 61 | Frederic |  |  |
| 4509 | 1754.3 | CT3 part of Support of RTP / RTCP multiplexing (signalling) in IMS | 591d? | 2013-09-13 A | 2015-12-11 A | 100% |  | 2013-09-10 | 2014-06-13 | 201d? |  | finish no earlier than 2015-12-11 | C3 | 4728h | 4728h | RTCP_MUX | 31 | Alcatel-Lucent | Albrecht.Schwarz@alcatel-lucent.com | Rel-13 | 61 | Adrian |  |  |
| 4510 | 1755 | **LTE in the 1670-1675 MHz Band for US (on hold till 12/2014)** | 1003.62d? | 2012-03-05 A | 2014-10-31 | 8% | 926.79d? | 2012-03-05 | 2015-06-12 | 865d? | 42032.8d |  | R4; R2; R3 | 35192h | 2347.6h | LTE_FDD_1670_US | 28 | LightSquared | masoud.olfat@lightsquared.com | Rel-13 | 55 | Issam | LTE_FDD_1670_US |  |
| 4511 | 1755.1 | Core part: LTE in the 1670-1675 MHz Band for US (on hold till 12/2014) | 313d? | 2013-08-06 A | 2014-10-31 | 15% | 266.05d? | 2013-08-06 | 2015-03-13 | 313d? | 42032.8d | finish no earlier than 2015-03-13 | R4; R2; R3 | 7512h | 1126.8h | LTE_FDD_1670_US-Core | 28 | LightSquared | masoud.olfat@lightsquared.com | Rel-13 | 55 | Issam | LTE_FDD_1670_US-Core | RP-141452 |
| 4512 | 1755.2 | Perf. Part: LTE in the 1670-1675 MHz Band for US (on hold till 12/2014) | 865d? | 2012-03-05 A | 2014-06-19 | 5% | 821.75d? | 2012-03-05 | 2015-06-12 | 865d? | 42171.4d | finish no earlier than 2015-06-12 | R4 | 6920h | 346h | LTE_FDD_1670_US-Perf | 28 | LightSquared | masoud.olfat@lightsquared.com | Rel-13 | 55 | Issam | LTE_FDD_1670_US-Perf | RP-141452 |
| 4513 | 1756 | **Enhanced Signalling for Inter-eNB Coordinated Multi-Point (CoMP) for LTE** | 470.88d? | 2014-06-18 A | 2015-09-15 A | 100% |  | 2014-06-13 | 2014-12-05 | 126d? |  |  | R3 | 5248h | 5248h | COMP_LTE_IeNB_sig | 33 | Samsung | sunghwan.won@samsung.com | Rel-13 | 64 |  | COMP_LTE_IeNB_sig |  |
| 4514 | 1756.1 | Core part: Enhanced Signalling for Inter-eNB Coordinated Multi-Point (CoMP) for LTE | 328d? | 2014-06-18 A | 2015-09-15 A | 100% |  | 2014-06-13 | 2014-12-05 | 126d? |  | finish no earlier than 2015-09-15 | R3 | 2624h | 2624h | COMP_LTE_IeNB_sig-Core | 33 | Samsung | sunghwan.won@samsung.com | Rel-13 | 64 |  | COMP_LTE_IeNB_sig-Core | RP-151213 |
| 4515 | 1757 | **2GHz FDD LTE in Region 1 (1980-2010MHz and 2170-2200MHz Bands)** | 850.75d? | 2014-06-17 A | 2016-09-15 A | 100% |  | 2014-06-13 | 2015-06-12 | 261d? |  |  | R4 | 12096h | 12096h | LTE_1980_2170_REG1 | 33 | DISH Network | johny.kim@dish.com, mariam.sorond@dish.com | Rel-13 | 64 |  | LTE_1980_2170_REG1 |  |
| 4516 | 1757.1 | Core part: 2GHz FDD LTE in Region 1 (1980-2010MHz and 2170-2200MHz Bands) | 393d? | 2014-06-17 A | 2015-12-15 A | 100% |  | 2014-06-13 | 2015-06-12 | 261d? |  | finish no earlier than 2015-12-15 | R4 | 3144h | 3144h | LTE_1980_2170_REG1-Core | 33 | DISH Network | johny.kim@dish.com, mariam.sorond@dish.com | Rel-13 | 64 |  | LTE_1980_2170_REG1-Core | RP-151299 |
| 4517 | 1757.2 | Perf. Part: 2GHz FDD LTE in Region 1 (1980-2010MHz and 2170-2200MHz Bands) | 393d? | 2014-06-18 A | 2015-12-15 A | 100% |  | 2014-06-13 | 2015-06-12 | 261d? |  | finish no earlier than 2015-12-15 | R4 | 3144h | 3144h | LTE_1980_2170_REG1-Perf | 33 | DISH Network | johny.kim@dish.com, mariam.sorond@dish.com | Rel-13 | 64 |  | LTE_1980_2170_REG1-Perf | RP-151299 |
| 4518 | 1757.3 | UE Conformance Test Aspects - FDD LTE band 1980-2010 MHz and 2170-2200MHz (band 65) in Region1 and Region 3 | 134d? | 2016-03-15 A | 2016-09-15 A | 100% |  |  |  |  |  | finish no earlier than 2016-09-15 | R5 | 1072h | 1072h | LTE_1980_2170_REG1_REG3-UEConTest | 36 | Dish Network |  | Rel-13 | 71 |  |  |  |
| 4519 | 1758 | **Self Organizing Networks (SON) for Active Antenna System (AAS) based deployments** | 286.75d? | 2014-09-12 A | 2015-06-15 A | 100% |  | 2014-06-13 | 2015-06-12 | 261d? |  |  | R3; G2 | 4776h | 4776h | UTRA_LTE_SON_AAS | 33 | Nokia Networks | krzysztof.kordybach@nsn.com | Rel-13 | 65 |  | UTRA_LTE_SON_AAS |  |
| 4520 | 1758.1 | Core part: Self Organizing Networks (SON) for Active Antenna System (AAS) based deployments | 199d? | 2014-09-12 A | 2015-06-15 A | 100% |  | 2014-06-13 | 2015-06-12 | 261d? |  | finish no earlier than 2015-06-15 | R3 | 1592h | 1592h | UTRA_LTE_SON_AAS-Core | 33 | Nokia Networks | krzysztof.kordybach@nsn.com | Rel-13 | 65 |  | UTRA_LTE_SON_AAS-Core | RP-150727 |
| 4521 | 1759 | **Usage Monitoring Control PCC Extension** | 203d? | 2014-12-03 A | 2015-06-16 A | 100% |  |  |  |  |  |  | S2 | 2824h | 2824h | eUMONC | 34 | CTBRI |  | Rel-13 | 66 |  |  |  |
| 4522 | 1759.1 | Stage 2 of Usage Monitoring Control PCC Extension | 140d? | 2014-12-03 A | 2015-06-16 A | 100% |  |  |  |  |  | finish no earlier than 2015-06-16 | S2 | 1120h | 1120h | eUMONC-SA2 | 34 | China Telecom, Jinyan Li | lijy@ctbri.com.cn | Rel-13 | 66 |  |  |  |
| 4523 | 1759.2 | CT3 Aspect of Usage Monitoring Control extension | 73d? | 2014-12-03 A | 2015-03-13 A | 100% |  |  |  |  |  | finish no earlier than 2015-03-13 | C3 | 584h | 584h | eUMONC-CT3 | 34 | ZTE |  | Rel-13 | 66 |  |  |  |
| 4524 | 1760 | **Enhanced P-CSCF discovery using signalling for access to EPC via WLAN** | 164.5d? | 2014-10-06 A | 2015-03-13 A | 100% |  |  |  |  |  |  | C1 | 2424h | 2424h | ePCSCF_WLAN | 34 | Ericsson |  | Rel-13 | 66 |  |  |  |
| 4525 | 1760.1 | CT1 aspects of Enhanced P-CSCF discovery using signalling for access to EPC via WLAN | 73d? | 2014-12-03 A | 2015-03-13 A | 100% |  |  |  |  |  | finish no earlier than 2015-03-13 | C1 | 584h | 584h | ePCSCF_WLAN | 34 | Ericsson |  | Rel-13 | 66 |  |  |  |
| 4526 | 1760.2 | CT4 aspects of Enhanced P-CSCF discovery using signalling for access to EPC via WLAN | 115d? | 2014-10-06 A | 2015-03-13 A | 100% |  |  |  |  |  | finish no earlier than 2015-03-13 | C4 | 920h | 920h | ePCSCF_WLAN | 34 | Ericsson |  | Rel-13 | 66 |  |  |  |
| 4527 | 1761 | **P-CSCF Restoration Enhancements with WLAN** | 389.55d? | 2014-12-03 A | 2015-12-14 A | 100% |  |  |  |  |  |  | C4 | 6432.4h | 6432.4h | PCSCF_RES_WLAN | 34 | Jean-Jacques Trottin, Alcatel-Lucent | jean-jacques.trottin@alcatel-lucent.com | Rel-13 | 66 |  |  |  |
| 4528 | 1761.1 | CT1 aspects of P-CSCF Restoration Enhancements with WLAN | 268d? | 2014-12-03 A | 2015-12-14 A | 100% |  |  |  |  |  | finish no earlier than 2015-12-11 | C1 | 2144h | 2144h | PCSCF_RES_WLAN | 34 | Jean-Jacques Trottin, Alcatel-Lucent | jean-jacques.trottin@alcatel-lucent.com | Rel-13 | 66 |  |  |  |
| 4529 | 1761.2 | CT4 aspects of P-CSCF Restoration Enhancements with WLAN | 268d? | 2014-12-03 A | 2015-12-11 A | 100% |  |  |  |  |  | finish no earlier than 2015-12-11 | C4 | 2144h | 2144h | PCSCF_RES_WLAN | 34 | Jean-Jacques Trottin, Alcatel-Lucent | jean-jacques.trottin@alcatel-lucent.com | Rel-13 | 66 |  |  |  |

Notes:
- 4506: CP#65 moved to Rel-13. Stage 2/3 / Impacted TSs and TRs: Stage 2/3
- 4507: CP#65 moved to Rel-13. Completion 09/14=>12/15. Dec.14: 10->100 / Impacted TSs and TRs: 23.334; 29.334
- 4508: CP#65 moved to Rel-13. Completion 09/14=>12/15¦7/12/15: 0%->100 / Impacted TSs and TRs: 24.229
- 4509: CP#65 moved to Rel-13. Completion 09/14=>12/15¦8/12/15: 0%->100 / Impacted TSs and TRs: 29.213; 29.214
- 4510: RP#65 FS_LTE_FDD_1670_US is extended to 12/14 and this WI (LTE_FDD_1670_US) is on hold till 12/14 / Impacted TSs and TRs: LTE
- 4511: RP#65 completion 03/15=>06/15. On hold till 12/2014 / Impacted TSs and TRs: 25.101; 25.104; 25.113; 25.133; 25.306; 25.307; 25.331; 25.461; 25.466; 34.124; 36.101; 36.104; 36.113; 36.124; 36.133; 36.307; new 36.832
- 4512: RP#65 completion 06/15=>09/15. . On hold till 12/2014 / Impacted TSs and TRs: 25.133; 25.306; 25.307; 25.331; 25.461; 25.466; 34.124; 36.113; 36.124; 36.133; 36.141; 36.307
- 4513: Triggered by TR 36.874 Study on Coordinated Multi-Point (CoMP) operation for LTE with Non-Ideal Backhaul (UID_600015) / Impacted TSs and TRs: LTE
- 4514: CD:Thu 11/12/14->Mon 15/06/15¦Compl:0%->15%¦Stat Rep: -->RP-141805 1st Apr 15: Compl:15%->30% 1st Apr 15: Stat Rep: RP-141805->RP-150162 03/07/15: Compl:30%->90% 03/07/15: CD:Mon 15/06/15->Tue 15/09/15 03/07/15: Stat Rep: RP-150162->RP-150846 29/09/1 / Impacted TSs and TRs: 36.300; 36.423
- 4515: Triggered by TR 37.846 Study on 2GHz FDD for UTRA and LTE in Region 1 (1980-2010MHz and 2170-2200MHz Bands) FS_UTRA_LTE_1980_2170_REG1 / Impacted TSs and TRs: LTE
- 4516: CD:Fri 12/06/15->Mon 15/06/15¦Compl:5%->15%¦Stat Rep: RP-141627->RP-141795 1st Apr 15: Compl:15%->35% 1st Apr 15: WID: RP-141710->RP-150424 1st Apr 15: Stat Rep: RP-141795->RP-150106 03/07/15: Compl:35%->70% 03/07/15: CD:Mon 15/06/15->Tue 15/12/15 03 / Impacted TSs and TRs: 36.101; 36.104; 36.133; 36.141; 36.307; generic 36.853 (3 Band CA with 1UL); New 36.862 (Technical Report for 2 GHz Band in Region 1)
- 4517: CD:Fri 12/06/15->Mon 15/06/15¦Compl:0%->0%¦Stat Rep: RP-141627->RP-141795 1st Apr 15: WID: RP-141710->RP-150424 1st Apr 15: Stat Rep: RP-141795->RP-150106 03/07/15: CD:Mon 15/06/15->Tue 15/12/15 03/07/15: Stat Rep: RP-150106->RP-150705 29/09/15: Stat / Impacted TSs and TRs: 36.101; 36.104; 36.133; 36.141; 36.307; 36.862
- 4518: testing REL-13 LTE_1980_2170_REG1-Core and LTE_1980_2170_REG3-Core¦
- 4519: Triggered by TR 37.822 Study on Next-Generation SON for UTRA and LTE (FS_UTRA_LTE_NG_SON) / Impacted TSs and TRs: LTE
- 4520: CD:Tue 16/06/15->Mon 15/06/15¦Compl:0%->15%¦Stat Rep: -->RP-141854 1st Apr 15: Compl:15%->25% 1st Apr 15: Stat Rep: RP-141854->RP-150110 03/07/15: Compl:25%->100% 03/07/15: Stat Rep: RP-150110->RP-150727 / Impacted TSs and TRs: 36.300; 36.423; 36.413; 25.413
- 4522: June2015: Compl:6%->100. Verbal indication from SA2 chair / Impacted TSs and TRs: 23.203
- 4523: Mar.15: 10->100% / Impacted TSs and TRs: 29.212; 29.215
- 4525: . 12/12:0->100%. 5/5/15: acronym changed from ePCSCF_WLAN-CT1 to ePCSCF_WLAN / Impacted TSs and TRs: 24.229; 24.302
- 4526: Mar.15: 0->100%. 5/5/15: acronym changed from ePCSCF_WLAN-CT1 to ePCSCF_WLAN / Impacted TSs and TRs: 29.274; 29.275
- 4527: WID added, acronym. June 2015: WID: CP-140995-> CP-150275
- 4528: CT4->CT1. 2/4/15: acronym changed to PCSCF_RES_WLAN¦June2015: Compl:0%->10. June 2015: WID: CP-140995-> CP-150275¦07/09/15: 10%->70¦7/12/15: 70%->100 / Impacted TSs and TRs: 24.302; 24.229; 24.244; 24.008
- 4529: Dec.14: 0->5%. Mar.15: 5->100%. 2/4/15: acronym changed to PCSCF_RES_WLAN¦June2015: Compl:100%->75. June 2015: WID: CP-140995-> CP-150275¦07/09/15: 75%->85¦7/12/15: 85%->100 / Impacted TSs and TRs: New 29.8xy; 23.380; 29.273; 29.274; 29.275; 23.008

| ID | WBS | Task | Duration | Start | Finish | Complete | Constraint | Resources | Work | Actual work | Acronym | PCG approved | WI rapporteur name | WI rapporteur e-mail | Release | TSG approved |
| --- | --- | --- | --- | --- | --- | --- | --- | --- | --- | --- | --- | --- | --- | --- | --- | --- |
| 4530 | 1762 | **Mobile Equipment Identity signalling over WLAN** | 98.25d? | 2015-06-15 A | 2015-09-17 A | 100% |  | C4 | 1656h | 1656h | MEI_WLAN | 35 | Bruno Landais, Alcatel-Lucent | bruno.landais@alcatel-lucent.com | Rel-13 | 68 |
| 4531 | 1762.1 | CT1 aspects of Mobile Equipment Identity signalling over WLAN | 69d? | 2015-06-15 A | 2015-09-17 A | 100% | start no earlier than 2015-06-15 | C1 | 552h | 552h | MEI_WLAN | 35 | Bruno Landais, Alcatel-Lucent | bruno.landais@alcatel-lucent.com | Rel-13 | 68 |
| 4532 | 1762.2 | CT4 aspects of Mobile Equipment Identity signalling over WLAN | 69d? | 2015-06-15 A | 2015-09-17 A | 100% | start no earlier than 2015-06-15 | C4 | 552h | 552h | MEI_WLAN | 35 | Bruno Landais, Alcatel-Lucent | bruno.landais@alcatel-lucent.com | Rel-13 | 68 |
| 4533 | 1763 | Authentication Signalling Improvements for WLAN | 195d? | 2015-06-15 A | 2016-03-11 A | 100% | finish no earlier than 2016-03-11 | C1 | 1560h | 1560h | ASI_WLAN | 35 | Youyang Yu | yuyouyang@huawei.com | Rel-13 | 68 |
| 4534 | 1764 | **Stage-3 SAE Protocol Development - Phase 4** | 387.25d? | 2014-12-03 A | 2015-12-11 A | 100% |  | C1 | 8576h | 8576h | SAES4 | 34 | interdigital |  | Rel-13 | 66 |
| 4535 | 1764.1 | SAE Protocol Development (Stage 3) - Phase 4 | 268d? | 2014-12-03 A | 2015-12-11 A | 100% | start no earlier than 2014-12-03 | C1 | 2144h | 2144h | SAES4 | 34 | interdigital |  | Rel-13 | 66 |
| 4536 | 1764.2 | CS Fallback in EPS - Phase 4 | 268d? | 2014-12-03 A | 2015-12-11 A | 100% | start no earlier than 2014-12-03 | C1 | 2144h | 2144h | SAES4-CSFB | 34 | interdigital |  | Rel-13 | 66 |
| 4537 | 1764.3 | SAE for support for non-3GPP accesses - Phase 4 | 268d? | 2014-12-03 A | 2015-12-11 A | 100% | start no earlier than 2014-12-03 | C1 | 2144h | 2144h | SAES4-non3GPP | 34 | interdigital |  | Rel-13 | 66 |
| 4538 | 1765 | **Interworking solution for Called IN number and original called IN number ISUP parameters** | 104.5d? | 2014-12-03 A | 2015-03-13 A | 100% |  | C1; C3 | 2354.5h | 2354.5h | INNB_IW | 34 | Orange |  | Rel-13 | 66 |
| 4539 | 1765.1 | Interworking solution for Called IN number and original called IN number ISUP parameters | 73d? | 2014-12-03 A | 2015-03-13 A | 100% | start no earlier than 2014-12-03 | C1 | 584h | 584h | INNB_IW | 34 | Orange |  | Rel-13 | 66 |
| 4540 | 1765.2 | (IETF) CT1 part of Interworking solution for Called IN number and original called IN number ISUP parameters | 51.75d? | 2014-12-03 A | 2015-03-10 A | 100% | finish no earlier than 2015-03-10 | C1-IETF | 414h | 414h | INNB_IW | 34 | Orange |  | Rel-13 | 66 |
| 4541 | 1765.3 | CT3 aspects of Interworking solution for Called IN number and original called IN number ISUP parameters | 73d? | 2014-12-03 A | 2015-03-13 A | 100% | finish no earlier than 2015-03-13 | C3 | 584h | 584h | INNB_IW | 34 | Orange |  | Rel-13 | 66 |
| 4542 | 1766 | **Warning Status Report in EPS** | 296.25d? | 2014-12-03 A | 2015-09-14 A | 100% |  | C4 | 4896h | 4896h | WSR_EPS | 34 | one2many |  | Rel-13 | 66 |
| 4543 | 1766.1 | CT1 aspects of Warning Status Report in EPS | 204d? | 2014-12-03 A | 2015-09-14 A | 100% | start no earlier than 2014-12-03 | C1 | 1632h | 1632h | WSR_EPS | 34 | one2many |  | Rel-13 | 66 |
| 4544 | 1766.2 | CT4 aspects of Warning Status Report in EPS | 204d? | 2014-12-03 A | 2015-09-14 A | 100% | finish no earlier than 2015-09-14 | C4 | 1632h | 1632h | WSR_EPS | 34 | one2many |  | Rel-13 | 66 |
| 4545 | 1767 | Shared Data Update for Multiple Subscriber | 1d? | 2014-12-03 A | 2014-12-03 A | 100% | start no earlier than 2014-12-03 | C4 | 8h | 8h | SHARED_SubData_UPD | 34 | Huawei, Susan Shi | susan.shishufeng@huawei.com | Rel-13 | 66 |
| 4546 | 1768 | **IMS Stage-3 IETF Protocol Alignment** | 964.12d? | 2014-12-03 A | 2017-06-20 A | 100% |  | C1 | 11760h | 11760h | IMSProtoc7 | 34 | Alcatel-Lucent | Keith Drage | Rel-13 | 66 |
| 4547 | 1768.1 | CT1 aspects of IMS Stage-3 IETF Protocol Alignment | 268d? | 2014-12-03 A | 2015-12-11 A | 100% | finish no earlier than 2015-12-11 | C1 | 2144h | 2144h | IMSProtoc7 | 34 | Alcatel-Lucent | Keith Drage | Rel-13 | 66 |
| 4548 | 1768.2 | (IETF) CT1 aspects of IMS Stage-3 IETF Protocol Alignment | 268d? | 2016-06-13 A | 2017-06-20 A | 100% | finish no earlier than 2015-12-11 | C1 | 2144h | 2144h | IMSProtoc7 | 34 | Alcatel-Lucent | Keith Drage | Rel-13 | 66 |
| 4549 | 1768.3 | CT3 aspects of IMS Stage-3 IETF Protocol Alignment | 268d? | 2014-12-03 A | 2015-12-11 A | 100% | start no earlier than 2014-12-03 | C3 | 2144h | 2144h | IMSProtoc7 | 34 | Alcatel-Lucent | Keith Drage | Rel-13 | 67 |
| 4550 | 1769 | Retry restriction for Improving System Efficiency | 205d? | 2015-03-04 A | 2015-12-15 A | 100% | finish no earlier than 2015-12-15 | C1 | 1640h | 1640h | RISE | 34 | Huawei, Lin Shu | shulin@huawei.com | Rel-13 | 67 |
| 4551 | 1770 | **H.248 Aspects of WebRTC Data Channel on IMS Access Gateway** | 387.25d? | 2015-03-04 A | 2016-03-11 A | 100% |  | C4 | 4288h | 4288h | WebRTCH248DC | 34 | China Mobile, Xiaoning Du | duxiaoning@chinamobile.com | Rel-13 | 67 |
| 4552 | 1770.1 | CT4 Aspect of H.248 Aspects of WebRTC Data Channel on IMS Access Gateway | 268d? | 2015-03-04 A | 2016-03-11 A | 100% | finish no earlier than 2016-03-11 | C4 | 2144h | 2144h | WebRTCH248DC | 34 | China Mobile, Xiaoning Du. ES in 639 | duxiaoning@chinamobile.com | Rel-13 | 67 |
| 4553 | 1771 | Continuation of the Overload Control for PCC based Diameter applications | 203d? | 2015-03-04 A | 2015-12-11 A | 100% | finish no earlier than 2015-12-11 | C3 | 1624h | 1624h | cDOCME_PCC | 34 | ZTE, Zhou Xiaoyun | zhou.xiaoyun@zte.com.cn | Rel-13 | 67 |
| 4554 | 1772 | Review of dedicated 3GPP UICC features | 200d? | 2015-03-09 A | 2015-12-11 A | 100% | finish no earlier than 2015-12-11 | C6 | 1600h | 1600h | Red_UCe | 34 | Blackberry, Adrian Buckley | abuckley@blackberry.com | Rel-13 | 67 |

Notes:
- 4530: Impacted TSs and TRs: 24.244; 24.302; 29.273; 29.274; 29.275; 23.008
- 4531: 07/09/15: 0%->80¦7/12/15: 80%->100 / Impacted TSs and TRs: 24.244; 24.302
- 4532: 07/09/15: 0%->90¦7/12/15: 90%->100 / Impacted TSs and TRs: 29.273; 29.274; 29.275; 23.008
- 4533: 07/09/15: 0%->40¦7/12/15: 40%->95. FCD -> 03/16, ES in CP-150727¦7/3/16: 95%->100 / Impacted TSs and TRs: 24.302; 24.244
- 4534: WP Structure created 24/03/15 to avoid confusion in Acronyms / Impacted TSs and TRs: 23.12; 24.008; 24.167; 24.229; 24.301; 24.302; 24.303; 24.304; 24.305; 24.312; 29.018; 29.118
- 4535: WP Structure created 24/03/15 to avoid confusion in Acronyms. 5/5/15: acronym changed from "SAES4-CT1"¦June2015: Compl:0%->30¦07/09/15: 30%->70¦7/12/15: 70%->100
- 4536: WP Structure created 24/03/15 to avoid confusion in Acronyms¦June2015: Compl:0%->30¦07/09/15: 30%->70¦7/12/15: 70%->100
- 4537: WP Structure created 24/03/15 to avoid confusion in Acronyms¦June2015: Compl:0%->30¦07/09/15: 30%->50¦7/12/15: 50%->100
- 4539: 5/5/15: created¦June2015: Compl:0%->70¦07/09/15: 70%->100 / Impacted TSs and TRs: 24.229
- 4540: Mar15: resp WG:C1->C1-IETF. WID changed from INNB_IW-CT1 / Impacted TSs and TRs: draft-mohali-dispatch-cause-for-service-number
- 4541: Mar.15: 80->90%. WID changed from INNB_IW-CT3¦June2015: Compl:0%->98¦07/09/15: 98%->99¦7/12/15: 99%->100
- 4542: 5/5/15: acronym changed from "WSR_EP"¦7/12/15: WID:CP-140998->CP-150792
- 4543: 2/4/15: acronym changed to WSR_EP. 5/5/15: acronym changed from "WSR_EP"¦07/09/15: 0%->25¦7/12/15: 25%->100¦7/12/15: WID:CP-140998->CP-150792 / Impacted TSs and TRs: New 23.712
- 4544: 2/4/15: acronym changed to WSR_EP. 5/5/15: acronym changed from "WSR_EP"¦7/12/15: 0%->100¦7/12/15: WID:CP-140998->CP-150792
- 4545: Mar.15: 0->50%, WID: CP-140804->CP-150013¦June2015: Compl:50%->95¦07/09/15: 95%->100 / Impacted TSs and TRs: 29.328; 29.364
- 4546: Mar.15: 0->10% / Impacted TSs and TRs: 23.218; 24.998; 24.930
- 4547: Mar.15: 0->10%¦June2015: Compl:10%->30¦07/09/15: 30%->70¦7/12/15: 70%->100
- 4548: Impacted TSs and TRs: draft-ietf-mmusic-dtls-sdp; draft-ietf-mmusic-4572-update
- 4549: 2/4/15: added, following CT3 chair's info that the WID also has a CT3 part¦June2015: Compl:0%->20¦07/09/15: 20%->40¦7/12/15: 40%->100
- 4550: Continuation of Rel-12 SINE UID 620006. 5/5/15: acronym changed from "RISE"¦June2015: Compl:0%->10¦07/09/15: 10%->70¦14/09/15: WID:CP-150092->CP-150495¦7/12/15: 70%->100
- 4551: Impacted TSs and TRs: 23.334
- 4552: June2015: Compl:0%->10¦07/09/15: 10%->20¦7/12/15: 20%->90¦7/3/16: 90%->100 / Impacted TSs and TRs: 23.334
- 4553: Relates to UID 580026 (Study on Diameter overload control mechanism)¦June2015: Compl:0%->100 / Impacted TSs and TRs: 29.212; 29.215; 29.219; 29.217
- 4554: Results from the homonymous Study¦June2015: Compl:0%->60¦07/09/15: 60%->75¦7/3/16: 75%->100 / Impacted TSs and TRs: 31.102; 31.111; 31.121; 31.124

| ID | WBS | Task | Type | Duration | Start | Finish | Complete | Baseline start | Baseline finish | Baseline duration | Constraint | Resources | Work | Actual work | Acronym | PCG approved | WI rapporteur name | WI rapporteur e-mail | Release | TSG approved | Status Report | Acronym_3GU_Export | TSG stopped | MCC resp |
| --- | --- | --- | --- | --- | --- | --- | --- | --- | --- | --- | --- | --- | --- | --- | --- | --- | --- | --- | --- | --- | --- | --- | --- | --- |
| 4555 | 1773 | **Controlling IMS Media Plane with SDP Capability** |  | 280.5d? | 2015-06-15 A | 2016-03-11 A | 100% |  |  |  |  | C4 | 4680h | 4680h | SDPCN_IMS | 35 | Weiwei(Tommy) Yang, Huawei. ES in 640 | tommy@huawei.com | Rel-13 | 68 |  |  |  |  |
| 4556 | 1773.1 | CT3 aspects of Controlling IMS Media Plane with SDP Capability |  | 195d? | 2015-06-15 A | 2016-03-11 A | 100% |  |  |  | finish no earlier than 2016-03-11 | C3 | 1560h | 1560h | SDPCN_IMS | 35 | Weiwei(Tommy) Yang, Huawei. ES in 640 | tommy@huawei.com | Rel-13 | 68 |  |  |  |  |
| 4557 | 1773.2 | CT4 aspects of Controlling IMS Media Plane with SDP Capability |  | 195d? | 2015-06-15 A | 2016-03-11 A | 100% |  |  |  | finish no earlier than 2016-03-11 | C4 | 1560h | 1560h | SDPCN_IMS | 35 | Weiwei(Tommy) Yang, Huawei. ES in 640 | tommy@huawei.com | Rel-13 | 68 |  |  |  |  |
| 4558 | 1774 | **(SA66: on hold) Co-ordinated packet data network gateway (P-GW) change for SIPTO** |  | 94.12d? | 2014-06-18 A | 2014-09-16 A | 100% | 2014-06-18 | 2014-09-17 | 66d? |  | S1 | 1056h | 1056h | CSIPTO | 33 | Intel | Eric.siow@intel.com | Rel-13 | 64 | S1-143306 | CSIPTO |  |  |
| 4559 | 1774.1 | Stage 1 for Co-ordinated packet data network gateway (P-GW) change for SIPTO |  | 94.12d? | 2014-06-18 A | 2014-09-16 A | 100% | 2014-06-18 | 2014-09-17 | 66d? | finish no earlier than 2014-09-17 | S1 | 528h | 528h | CSIPTO-ST1 | 33 | Intel | Eric.siow@intel.com | Rel-13 | 64 | S1-143306 | CSIPTO |  |  |
| 4560 | 1775 | **Enhanced CS Fallback (CSFB)** |  | 278.12d? | 2014-06-18 A | 2015-03-13 A | 100% | 2014-06-18 | 2015-03-18 | 196d? |  | S2; S3 | 2600h | 2600h | eCSFB | 33 | China Unicom | Yang Xu (xuyang49@chinaunicom.cn) | Rel-13 | 64 |  | eCSFB |  |  |
| 4561 | 1775.1 | TR for Enhanced CS Fallback (CSFB) |  | 128d? | 2014-06-18 A | 2014-12-12 A | 100% | 2014-06-18 | 2014-12-10 | 126d? | finish no earlier than 2014-12-12 | S2 | 1024h | 1024h | eCSFB | 33 | China Unicom | Yang Xu (xuyang49@chinaunicom.cn) | Rel-13 | 64 |  |  |  |  |
| 4562 | 1775.2 | Deleted - Stage 2 for Enhanced CS Fallback (CSFB) | milestone | 0d? | 2015-03-13 A | 2015-03-13 A | 100% | 2014-06-18 | 2015-03-18 | 196d? | start no earlier than 2015-03-13 | S2 |  |  | eCSFB | 33 | China Unicom | Yang Xu (xuyang49@chinaunicom.cn) | Rel-13 | 64 |  |  | SP-69 |  |
| 4563 | 1775.3 | Deleted - Security for Enhanced CS Fallback (CSFB) |  | 1d? | 2014-09-18 A | 2014-09-18 A | 100% |  |  |  | start no earlier than 2014-09-17 | S3 | 8h | 8h | eCSFB | 33 | China Unicom | Feng Gao (gaofeng149@chinaunicom.cn) | Rel-13 | 65 |  |  | SP-69 |  |
| 4564 | 1776 | **SRVCC Enhancements for Transcoding Avoidance** |  | 281.5d? | 2014-09-19 A | 2015-06-17 A | 100% |  |  |  |  | S2 | 2592h | 2592h | SETA | 33 | Ericsson | George.Foti@ericsson.com | Rel-13 | 65 |  | SETA |  |  |
| 4565 | 1776.1 | TR for SRVCC Enhancements for Transcoding Avoidance |  | 128d? | 2014-09-19 A | 2015-03-13 A | 100% |  |  |  | finish no earlier than 2015-03-13 | S2 | 1024h | 1024h | SETA-SA2TR | 33 | Ericsson | George.Foti@ericsson.com | Rel-13 | 65 |  |  |  |  |
| 4566 | 1776.2 | Deleted - Stage 2 for SRVCC Enhancements for Transcoding Avoidance | milestone | 0d? | 2015-06-17 A | 2015-06-17 A | 100% |  |  |  | start no earlier than 2015-06-17 | S2 |  |  | SETA-SA2 | 33 | Ericsson | George.Foti@ericsson.com | Rel-13 | 65 |  |  | SP-69 |  |
| 4567 | 1777 | **Base Station (BS) RF requirements for Active Antenna System (AAS)** |  | 1336.88d? | 2013-03-04 A | 2016-09-15 A | 100% | 2013-03-04 | 2014-12-05 | 465d? |  | R4 | 21184h | 21184h | AAS_BS_LTE_UTRA | 30 | Huawei | ronnie.zhang@huawei.com | Rel-13 | 59 |  | AAS_BS_LTE_UTRA |  | Issam |
| 4568 | 1777.1 | Core part: Base Station (BS) RF requirements for Active Antenna System (AAS) |  | 793d? | 2013-03-04 A | 2016-03-15 A | 100% | 2013-03-04 | 2014-09-12 | 401d? | finish no earlier than 2016-03-15 | R4 | 6344h | 6344h | AAS_BS_LTE_UTRA-Core | 30 | Huawei | ronnie.zhang@huawei.com | Rel-13 | 59 | RP-151241 | AAS_BS_LTE_UTRA-Core |  | Issam |
| 4569 | 1777.2 | Perf. part: Base Station (BS) RF requirements for Active Antenna System (AAS) |  | 922d? | 2013-03-15 A | 2016-09-15 A | 100% | 2013-03-07 | 2014-12-05 | 461d? | finish no earlier than 2016-09-15 | R4 | 7376h | 7376h | AAS_BS_LTE_UTRA-Perf | 30 | Huawei | ronnie.zhang@huawei.com | Rel-13 | 59 | RP-151241 | AAS_BS_LTE_UTRA-Perf |  | Issam |
| 4570 | 1778 | **Enhanced LTE Device to Device Proximity Services** |  | 663.62d? | 2014-12-15 A | 2016-09-15 A | 100% |  |  |  |  | R2 | 11016h | 11016h | LTE_eD2D_Prox | 34 | Qualcomm | Qualcomm | Rel-13 | 66 |  |  |  |  |
| 4571 | 1778.1 | Core part: Enhanced LTE Device to Device Proximity Services |  | 152.33d? | 2015-08-14 A | 2016-03-15 A | 100% |  |  |  | finish no earlier than 2016-03-15 | R2; R1; R3 | 3656h | 3656h | LTE_eD2D_Prox-Core | 34 | Qualcomm Incorporated, Shailesh Patil | patil@qti.qualcomm.com | Rel-13 | 66 | RP-151337 |  |  |  |
| 4572 | 1778.2 | Perf. part: Enhanced LTE Device to Device Proximity Services |  | 460d? | 2014-12-15 A | 2016-09-15 A | 100% |  |  |  | finish no earlier than 2016-09-15 | R4 | 3680h | 3680h | LTE_eD2D_Prox-Perf | 34 | Qualcomm | Qualcomm | Rel-13 | 66 | RP-151337 |  |  |  |
| 4573 | 1779 | **Radiated requirements for the verification of multi-antenna reception performance of UEs** |  | 473.25d? | 2014-12-15 A | 2016-03-15 A | 100% |  |  |  |  | R4 | 5232h | 5232h | UTRA_LTE_MIMO_OTA | 34 | Intel | Intel | Rel-13 | 66 | RP-171826 |  |  |  |
| 4574 | 1779.1 | Core part: Radiated requirements for the verification of multi-antenna reception performance of UEs |  | 327d? | 2014-12-15 A | 2016-03-15 A | 100% |  |  |  | finish no earlier than 2016-03-15 | R4 | 2616h | 2616h | UTRA_LTE_MIMO_OTA-Core | 34 | Intel | Intel | Rel-13 | 66 | RP-151573 |  |  |  |
| 4575 | 1780 | **UE core requirements for uplink 64 QAM** |  | 284.75d? | 2014-12-15 A | 2015-09-15 A | 100% |  |  |  |  | R4 | 3152h | 3152h | LTE_UL64QAM | 34 | Huawei | Huawei | Rel-13 | 66 |  |  |  |  |
| 4576 | 1780.1 | Core part: UE core requirements for uplink 64 QAM |  | 197d? | 2014-12-15 A | 2015-09-15 A | 100% |  |  |  | finish no earlier than 2015-09-15 | R4 | 1576h | 1576h | LTE_UL64QAM-Core | 34 | Huawei | Huawei | Rel-13 | 66 | RP-151244 |  |  |  |
| 4577 | 1781 | UE Conformance Test Aspects - Core Requirements for Uplink 64QAM for E-UTRA |  | 132d? | 2015-06-15 A | 2015-12-15 A | 100% |  |  |  | finish no earlier than 2015-12-15 | R5 | 1056h | 1056h | LTE_UL64QAM-UEConTest | 35 | CMCC |  | Rel-13 | 68 | RP-151174 |  |  |  |
| 4578 | 1782 | **Performance requirements of MMSE-IRC receiver for LTE BS** |  | 568.5d? | 2014-12-15 A | 2016-06-15 A | 100% |  |  |  |  | R4 | 6288h | 6288h | LTE_MMSE_IRC_BS | 34 | China Telecom | China Telecom | Rel-13 | 66 |  |  |  |  |
| 4579 | 1782.1 | Perf. part: Performance requirements of MMSE-IRC receiver for LTE BS |  | 393d? | 2014-12-15 A | 2016-06-15 A | 100% |  |  |  | finish no earlier than 2016-06-15 | R4 | 3144h | 3144h | LTE_MMSE_IRC_BS-Perf | 34 | China Telecom | China Telecom | Rel-13 | 66 | RP-151215 |  |  |  |

Notes:
- 4555: Impacted TSs and TRs: 23.334; 29.334; 29.162; 29.238; 23.333; 29.333; 29.163; 29.332; 29.292; 29.232; 29.235
- 4556: 7/12/15: 0%->90. FCD->03/16. ES in CP-150614¦7/3/16: 90%->100 / Impacted TSs and TRs: 29.162; 29.163; 29.292; 29.235
- 4557: 07/09/15: 0%->5¦7/12/15: 5%->70. FCD->03/16. ES in CP-150614¦7/3/16: 70%->100 / Impacted TSs and TRs: 23.334; 29.334; 29.238; 23.333; 29.333; 29.332; 29.232
- 4558: SP#65 completed. Updated WID SP-140235=>SP-140509. Triggered by Rel-13 Study TR 22.828 (FS_CSIPTO) / Impacted TSs and TRs: 22.101
- 4559: SP#65 completed. Updated WID SP-140235=>SP-140509. Triggered by Rel-13 Study TR 22.828 (FS_CSIPTO). Dec.14: former S1-only feature split / Impacted TSs and TRs: 22.101
- 4560: SP#65 updated ID SP-140285=>SP-140579 (added SA3 part). Linked to Rel-8 WIs Single Radio Voice Call Continuity for 3GPP (SAES-SRVCC) and CS Fallback in EPS (SAES-CSFB) / Impacted TSs and TRs: Stage 2
- 4561: SP#65 updated ID SP-140285=>SP-140579 (added SA3 part). Dec.14: 35->85%¦14/09/15: 85%->100. SA#69: decision not to continue the work on this. No normative work. / Impacted TSs and TRs: New 23.772
- 4562: SP#65 updated ID SP-140285=>SP-140579 (added SA3 part) / Impacted TSs and TRs: 23.272
- 4563: SP#65 updated ID SP-140285=>SP-140579¦14/09/15: 0%->100. SA#69: deleted, since SA2 has stopped the work.
- 4564: Enhance chances for end-to-end transcoder free operation (TrFo) where possible/ ensure proper CS radio resources are reserved for optimal RAN codec. Address TrFo of EVS codecs during SRVCC that are not covered by Rel-12 / Impacted TSs and TRs: Stage 2
- 4565: Dec.14: 0->70%¦14/09/15: 70%->100. Stopped without conclusion, no intention to continue the study nor to do any mormative work. / Impacted TSs and TRs: New 23.7xy
- 4566: SA#69: stop the work on this. / Impacted TSs and TRs: 23.216; 23.237
- 4567: Triggered by Rel-12 TR 37.840 Study of RF and EMC Requirements for Active Antenna Array System BS (FS_AAS_BS_LTE_UTRA) / Impacted TSs and TRs: UTRA; LTE; GERAN
- 4568: ¦CD:Thu 11/12/14->Tue 15/12/15¦WID: RP-141966->RP-142235¦Stat Rep: RP-141249->RP-141908¦Release: Rel-12->Rel-13 03/07/15: Stat Rep: RP-141908->RP-150687 29/09/15: Compl:75%->80% 29/09/15: Stat Rep: RP-150687->RP-151241¦ / Impacted TSs and TRs: New 37.142 (AAS BS Tx & Rx); New 37.842; 37.114; 37.145-1; 37.145-2
- 4569: ¦CD:Sat 18/06/16->Wed 15/06/16¦WID: RP-141966->RP-142235¦Stat Rep: RP-141249->RP-141908¦Release: Rel-12->Rel-13 03/07/15: Stat Rep: RP-141908->RP-150687 29/09/15: Stat Rep: RP-150687->RP-151241 22/3/16: Compl:2 26/9/16: Compl:95%->100% / Impacted TSs and TRs: New 37.1xy (AAS BS conformance testing)
- 4571: Rapporteur details and involved WGs updated 1st Apr 15: WID: RP-142311->RP-150441 1st Apr 15: Stat Rep: ->RP-150095 03/07/15: Compl:0%->32% 03/07/15: Stat Rep: RP-150095->RP-150795 29/09/15: Compl:32%->55% 29/09/15: Stat Rep: RP-150795->RP-151337¦
- 4572: 1st Apr 15: WID: RP-142311->RP-150441 1st Apr 15: Stat Rep: ->RP-150095 03/07/15: Stat Rep: RP-150095->RP-150795 29/09/15: Stat Rep: RP-150795->RP-151337¦1/1/16: CD¦22/3/16: Compl:0%->10%;26/9/16: Compl:85%->100%
- 4574: 1st Apr 15: Compl:0%->5% 1st Apr 15: WID: RP-142221->RP-150261 1st Apr 15: Stat Rep: ->RP-150260 03/07/15: Compl:5%->15% 03/07/15: Stat Rep: RP-150260->RP-150746 29/09/15: Compl:15%->25% 29/09/15: WID: RP-150261->RP-151574 29/09/15: Stat Rep: RP-15074
- 4576: 1st Apr 15: Compl:0%->10% 1st Apr 15: Stat Rep: ->RP-150232 03/07/15: Compl:10%->90% 03/07/15: WID: RP-142222->RP-150691 03/07/15: Stat Rep: RP-150232->RP-150688 29/09/15: Compl:90%->100% 29/09/15: Stat Rep: RP-150688->RP-151244
- 4577: tested Core part: LTE_UL64QAM-Core which is not yet completed 29/09/15: Compl:0%->5% 29/09/15: Stat Rep: -->RP-151174 1/1/16: Compl:5%->100%
- 4579: 1st Apr 15: Compl:0%->10% 1st Apr 15: WID: RP-142223->RP-150206 1st Apr 15: Stat Rep: ->RP-150204 03/07/15: Compl:10%->35% 03/07/15: Stat Rep: RP-150204->RP-150630 29/09/15: Compl:35%->50% 29/09/15: Stat Rep: RP-150630->RP-151215¦

| ID | WBS | Task | Duration | Start | Finish | Complete | Constraint | Resources | Work | Actual work | Acronym | PCG approved | WI rapporteur name | WI rapporteur e-mail | Release | TSG approved | Status Report |
| --- | --- | --- | --- | --- | --- | --- | --- | --- | --- | --- | --- | --- | --- | --- | --- | --- | --- |
| 4580 | 1783 | **CRS Interference Mitigation for LTE Homogenous Deployments** | 473.25d? | 2014-12-15 A | 2016-03-15 A | 100% |  | R4 | 5232h | 5232h | LTE_CRSIM | 34 | Ericsson | Ericsson | Rel-13 | 66 |  |
| 4581 | 1783.1 | Perf. part: CRS Interference Mitigation for LTE Homogenous Deployments | 327d? | 2014-12-15 A | 2016-03-15 A | 100% | finish no earlier than 2016-03-15 | R4 | 2616h | 2616h | LTE_CRSIM-Perf | 34 | Ericsson | Ericsson | Rel-13 | 66 | RP-151171 |
| 4582 | 1784 | **Dual Connectivity enhancements for LTE** | 474.25d? | 2015-03-16 A | 2016-06-15 A | 100% |  | R2 | 6824h | 6824h | LTE_dualC_enh | 34 | NTT DOCOMO |  | Rel-13 | 67 |  |
| 4583 | 1784.1 | Core part: Dual Connectivity enhancements for LTE | 197d? | 2015-03-16 A | 2015-12-15 A | 100% | finish no earlier than 2015-12-15 | R2 | 1576h | 1576h | LTE_dualC_enh-Core | 34 | NTT DOCOMO |  | Rel-13 | 67 | RP-151330 |
| 4584 | 1784.2 | Perf. part: Dual Connectivity enhancements for LTE | 328d? | 2015-03-16 A | 2016-06-15 A | 100% | finish no earlier than 2016-06-15 | R4 | 2624h | 2624h | LTE_dualC_enh-Perf | 34 | NTT DOCOMO |  | Rel-13 | 67 | RP-151330 |
| 4585 | 1785 | **Multicarrier Load Distribution of UEs in LTE** | 569.38d? | 2015-03-16 A | 2016-09-15 A | 100% |  | R2 | 7896h | 7896h | LTE_MC_load | 34 | ZTE |  | Rel-13 | 67 |  |
| 4586 | 1785.1 | Core part: Multicarrier Load Distribution of UEs in LTE | 197d? | 2015-03-16 A | 2015-12-15 A | 100% | finish no earlier than 2015-12-15 | R2 | 1576h | 1576h | LTE_MC_load-Core | 34 | ZTE |  | Rel-13 | 67 | RP-151190 |
| 4587 | 1785.2 | Perf. part: Multicarrier Load Distribution of UEs in LTE | 395d? | 2015-03-16 A | 2016-09-15 A | 100% | finish no earlier than 2016-09-15 | R4 | 3160h | 3160h | LTE_MC_load-Perf | 34 | ZTE |  | Rel-13 | 67 | RP-151190 |
| 4588 | 1786 | **LTE-WLAN Radio Level Integration and Interworking Enhancement** | 1324.38d? | 2015-03-16 A | 2018-09-14 A | 100% |  | R2 | 16760h | 16760h | LTE_WLAN_radio | 34 | Intel |  | Rel-13 | 67 |  |
| 4589 | 1786.1 | Core part: LTE-WLAN Radio Level Integration and Interworking Enhancement | 262d? | 2015-03-16 A | 2016-03-15 A | 100% | finish no earlier than 2016-03-15 | R2 | 2096h | 2096h | LTE_WLAN_radio-Core | 34 | Intel |  | Rel-13 | 67 | RP-151563 |
| 4590 | 1786.2 | Perf. part: LTE-WLAN Radio Level Integration and Interworking Enhancement | 262d? | 2015-03-16 A | 2016-03-15 A | 100% | finish no earlier than 2016-03-15 | R4 | 2096h | 2096h | LTE_WLAN_radio-Perf | 34 | Intel |  | Rel-13 | 67 | RP-151563 |
| 4591 | 1786.3 | UE Conformance Test Aspects - WLAN/3GPP Radio Level Integration and Interworking Enhancement Interworking | 655d? | 2016-03-15 A | 2018-09-14 A | 100% | finish no earlier than 2018-09-15 | R5 | 5240h | 5240h | LTE_WLAN_radio-UEConTest | 36 | Intel |  | Rel-13 | 71 |  |
| 4592 | 1787 | **RAN aspects for improvements to CS/PS coordination in UTRAN Shared Network** | 284.75d? | 2015-03-16 A | 2015-12-15 A | 100% |  | R3 | 3152h | 3152h | CSPS_Coord-UTRA | 34 | Ericsson |  | Rel-13 | 67 |  |
| 4593 | 1787.1 | Core part: RAN aspects for improvements to CS/PS coordination in UTRAN Shared Network | 197d? | 2015-03-16 A | 2015-12-15 A | 100% | finish no earlier than 2015-12-15 | R3 | 1576h | 1576h | CSPS_Coord-UTRA-Core | 34 | Ericsson |  | Rel-13 | 67 | RP-151289 |
| 4594 | 1788 | **LTE DL 4 Rx antenna ports** | 6694.38d? | 2000-01-03 A | 2017-09-15 A | 100% |  | R4 | 77392h | 77392h | LTE_4Rx_AP_DL | 34 | Ericsson |  | Rel-13 | 67 |  |
| 4595 | 1788.1 | Core part: LTE DL 4 Rx antenna ports | 197d? | 2015-03-16 A | 2015-12-15 A | 100% | finish no earlier than 2015-12-15 | R4 | 1576h | 1576h | LTE_4Rx_AP_DL-Core | 34 | Ericsson |  | Rel-13 | 67 | RP-151265 |
| 4596 | 1788.2 | Perf. part: LTE DL 4 Rx antenna ports | 4378d? | 2000-01-03 A | 2016-09-15 A | 100% | finish no earlier than 2016-09-15 | R4 | 35024h | 35024h | LTE_4Rx_AP_DL-Perf | 34 | Ericsson |  | Rel-13 | 67 | RP-151265 |
| 4597 | 1788.3 | UE Conformance Test Aspects - LTE DL 4 Rx antenna ports | 460d? | 2015-12-15 A | 2017-09-15 A | 100% | finish no earlier than 2017-09-15 | R5 | 3680h | 3680h | LTE_4Rx_AP_DL-UEConTest | 36 | Ericsson |  | Rel-13 | 70 |  |
| 4598 | 1789 | **AWS-Extension Band for LTE** | 569.38d? | 2015-03-16 A | 2016-09-15 A | 100% |  | R4 | 7904h | 7904h | LTE_AWS_EXT | 34 | Ericsson |  | Rel-13 | 67 |  |
| 4599 | 1789.1 | Core part: AWS-Extension Band for LTE | 197d? | 2015-03-16 A | 2015-12-15 A | 100% | finish no earlier than 2015-12-15 | R4 | 1576h | 1576h | LTE_AWS_EXT-Core | 34 | Ericsson |  | Rel-13 | 67 | RP-151343 |
| 4600 | 1789.2 | Perf. part: AWS-Extension Band for LTE | 197d? | 2015-03-16 A | 2015-12-15 A | 100% | finish no earlier than 2015-12-15 | R4 | 1576h | 1576h | LTE_AWS_EXT-Perf | 34 | Ericsson |  | Rel-13 | 67 | RP-151343 |
| 4601 | 1789.3 | UE Conformance Test Aspects - AWS-Extension Band for LTE (Band 66) | 199d? | 2015-12-15 A | 2016-09-15 A | 100% | finish no earlier than 2016-09-15 | R5 | 1592h | 1592h | LTE_AWS_EXT-UEConTest | 36 | Ericsson |  | Rel-13 | 70 |  |
| 4602 | 1790 | **Additional bandwidth combination set for LTE Advanced inter-band Carrier Aggregation of Band 5 and Band 7** | 95.25d? | 2015-03-16 A | 2015-06-15 A | 100% |  | R4 | 1584h | 1584h | LTE_CA_B5_B7_BWset | 34 | Nokia Networks |  | Rel-13 | 67 |  |
| 4603 | 1790.1 | Core part: Additional bandwidth combination set for LTE Advanced inter-band Carrier Aggregation of Band 5 and Band 7 | 66d? | 2015-03-16 A | 2015-06-15 A | 100% | finish no earlier than 2015-06-15 | R4 | 528h | 528h | LTE_CA_B5_B7_BWset-Core | 34 | Nokia Networks |  | Rel-13 | 67 | RP-150536 |
| 4604 | 1790.2 | Perf. part: Additional bandwidth combination set for LTE Advanced inter-band Carrier Aggregation of Band 5 and Band 7 | 66d? | 2015-03-16 A | 2015-06-15 A | 100% | finish no earlier than 2015-06-15 | R4 | 528h | 528h | LTE_CA_B5_B7_BWset-Perf | 34 | Nokia Networks |  | Rel-13 | 67 | RP-150536 |

Notes:
- 4581: 1st Apr 15: Compl:0%->10% 1st Apr 15: CD:Mon 15/06/15->Tue 15/03/16 1st Apr 15: Stat Rep: ->RP-150061 03/07/15: Compl:10%->20% 03/07/15: Stat Rep: RP-150061->RP-150584 29/09/15: Compl:20%->30% 29/09/15: Stat Rep: RP-150584->RP-151171
- 4583: 03/07/15: Compl:0%->25% 03/07/15: Stat Rep: ->RP-150744 29/09/15: Compl:25%->55% 29/09/15: Stat Rep: RP-150744->RP-151330 1/1/16: Compl:55%->100%
- 4584: 03/07/15: Stat Rep: ->RP-150744 29/09/15: Stat Rep: RP-150744->RP-151330 ¦1/1/16: WID: RP-150490->RP-15173922/3/16: Compl:0%->50%;
- 4586: 03/07/15: Compl:0%->40% 03/07/15: WID: RP-150491->RP-150611 03/07/15: Stat Rep: ->RP-150610 29/09/15: Compl:40%->55% 29/09/15: WID: RP-150611->RP-151206 29/09/15: Stat Rep: RP-150610->RP-151190
- 4587: 03/07/15: WID: RP-150491->RP-150611 03/07/15: Stat Rep: ->RP-150610 29/09/15: WID: RP-150611->RP-151206 29/09/15: Stat Rep: RP-150610->RP-1511901/1/16:22/3/16: Compl:70%->75%¦26/9/16: Compl:90%->100%¦26/9/16: WID: RP-152181
- 4589: 03/07/15: Compl:0%->30% 03/07/15: WID: RP-150510->RP-151114 03/07/15: Stat Rep: ->RP-151081, 07/08/15: impacted TSs added 29/09/15: Compl:30%->35% 29/09/15: Stat Rep: RP-151081->RP-151563; / Impacted TSs and TRs: 36.461; 36.462; 36.463; 36.464; 36.465; 36.622; 36.623; 36.624; 36.625; 36.360
- 4590: 03/07/15: WID: RP-150510->RP-151114 03/07/15: Stat Rep: ->RP-151081 29/09/15: Stat Rep: RP-151081->RP-1515631/1/16: Compl:0%->10% ¦22/3/16: Compl:10%->100%¦
- 4591: testing REL-13 LTE_WLAN_radio-Core¦1/7/16: Compl:0%->5%¦20/21/3/17: Compl:20 ;27/3/18: ;¦26/3/19: 58%->100
- 4593: 03/07/15: Compl:0%->45% 03/07/15: Stat Rep: ->RP-150842 29/09/15: Compl:45%->80% 29/09/15: CD:Tue 15/09/15->Tue 15/12/15 29/09/15: Stat Rep: RP-150842->RP-1512891/1/16: Compl:80%->100%
- 4595: 03/07/15: Compl:0%->25% 03/07/15: Stat Rep: ->RP-150803 29/09/15: Compl:25%->50% 29/09/15: Stat Rep: RP-150803->RP-151265¦1/1/16: Compl:50%->100%
- 4596: 03/07/15: Compl:0%->15% 03/07/15: CD:Mon 02/10/00->Wed 15/06/16 03/07/15: Stat Rep: ->RP-150803 29/09/15: Compl:15%->35% 29/09/15: Stat Rep: RP-150803->RP-15126522/3/16: Compl:60%-;26/9/16: Compl:90%->100%
- 4597: ¦22/3/16: Compl:0%->10%¦1/7/16: Compl:10%->25%¦ 26/9/16: 21/3/17: Compl:60%->70 ;
- 4599: 03/07/15: Compl:0%->20% 03/07/15: WID: RP-150428->RP-150800 03/07/15: Stat Rep: ->RP-150796 29/09/15: Compl:20%->50% 29/09/15: Stat Rep: RP-150796->RP-151343
- 4600: 03/07/15: WID: RP-150428->RP-150800 03/07/15: Stat Rep: ->RP-150796 29/09/15: Stat Rep: RP-150796->RP-151343¦
- 4601: ¦22/3/16: Compl:0%->10%1/7/16: Compl:10%->65%26/9/16: Comp
- 4603: 03/07/15: Compl:0%->100% 03/07/15: WID: RP-150171->RP-150602 03/07/15: Stat Rep: ->RP-150536
- 4604: 03/07/15: Compl:0%->100% 03/07/15: WID: RP-150171->RP-150602 03/07/15: Stat Rep: ->RP-150536

| ID | WBS | Task | Duration | Start | Finish | Complete | Constraint | Resources | Work | Actual work | Acronym | PCG approved | WI rapporteur name | Release | TSG approved | Status Report | WI rapporteur e-mail | TSG stopped |
| --- | --- | --- | --- | --- | --- | --- | --- | --- | --- | --- | --- | --- | --- | --- | --- | --- | --- | --- |
| 4605 | 1791 | **Additional bandwidth combination set for LTE Advanced inter-band Carrier Aggregation of Band 3 and Band 5** | 95.25d? | 2015-03-16 A | 2015-06-15 A | 100% |  | R4 | 1584h | 1584h | LTE_CA_B3_B5_BWset | 34 | Samsung | Rel-13 | 67 |  |  |  |
| 4606 | 1791.1 | Core part: Additional bandwidth combination set for LTE Advanced inter-band Carrier Aggregation of Band 3 and Band 5 | 66d? | 2015-03-16 A | 2015-06-15 A | 100% | finish no earlier than 2015-06-15 | R4 | 528h | 528h | LTE_CA_B3_B5_BWset-Core | 34 | Samsung | Rel-13 | 67 | RP-150536 |  |  |
| 4607 | 1791.2 | Perf. part: Additional bandwidth combination set for LTE Advanced inter-band Carrier Aggregation of Band 3 and Band 5 | 66d? | 2015-03-16 A | 2015-06-15 A | 100% | finish no earlier than 2015-06-15 | R4 | 528h | 528h | LTE_CA_B3_B5_BWset-Perf | 34 | Samsung | Rel-13 | 67 | RP-150536 |  |  |
| 4608 | 1792 | **Multiflow Enhancements for UTRA** | 190.5d? | 2015-03-16 A | 2015-09-15 A | 100% |  | R2 | 2112h | 2112h | HSDPA_MFTX_enh | 34 | Nokia | Rel-13 | 67 |  | alexander.sayenko@nokia.com |  |
| 4609 | 1792.1 | Core part: Multiflow Enhancements for UTRA | 132d? | 2015-03-16 A | 2015-09-15 A | 100% | finish no earlier than 2015-09-15 | R2 | 1056h | 1056h | HSDPA_MFTX_enh-Core | 34 | Nokia | Rel-13 | 67 | RP-151302 | alexander.sayenko@nokia.com |  |
| 4610 | 1793 | **Message interworking during PS to CS SRVCC** | 97.25d? | 2015-06-15 A | 2015-09-16 A | 100% |  | C1 | 1632h | 1632h | mSRVCC | 35 | Ivo Sedlacek, Ericsson | Rel-13 | 68 |  | ivo.sedlacek@ericsson.com |  |
| 4611 | 1793.1 | CT1 aspects of Message interworking during PS to CS SRVCC | 68d? | 2015-06-15 A | 2015-09-16 A | 100% | start no earlier than 2015-06-15 | C1 | 544h | 544h | mSRVCC | 35 | Ivo Sedlacek, Ericsson | Rel-13 | 68 |  | ivo.sedlacek@ericsson.com |  |
| 4612 | 1793.2 | CT3 aspects of Message interworking during PS to CS SRVCC | 68d? | 2015-06-15 A | 2015-09-16 A | 100% | finish no earlier than 2015-09-16 | C3 | 544h | 544h | mSRVCC | 35 | Ivo Sedlacek, Ericsson | Rel-13 | 68 |  | ivo.sedlacek@ericsson.com |  |
| 4613 | 1794 | **Support of Emergency services over WLAN – phase 1** | 277.5d? | 2015-06-18 A | 2016-03-11 A | 100% |  | S2 | 5896h | 5896h | SEW1 | 35 | Laurent thiebaut | Rel-13 | 68 |  | Laurent.thiebaut@alcatel-lucent.com |  |
| 4614 | 1794.1 | Stage 2 of Support of Emergency services over WLAN - phase 1 | 65d? | 2015-06-18 A | 2015-09-16 A | 100% | finish no earlier than 2015-09-16 | S2 | 520h | 520h | SEW1 | 35 | Laurent thiebaut | Rel-13 | 68 |  | Laurent.thiebaut@alcatel-lucent.com |  |
| 4615 | 1794.2 | **CT aspects of Support of Emergency services over WLAN – phase 1** | 193.5d? | 2015-09-07 A | 2016-03-11 A | 100% |  | ct | 3840h | 3840h | SEW1-CT | 35 | Alcatel-Lucent, Jennifer Liu (CT1) | Rel-13 | 69 |  | jennifer.liu@alcatel-lucent.com |  |
| 4616 | 1794.2.1 | CT1 aspects of Support of Emergency services over WLAN – phase 1 | 135d? | 2015-09-07 A | 2016-03-11 A | 100% | finish no earlier than 2016-03-11 | C1 | 1080h | 1080h | SEW1-CT | 35 | Alcatel-Lucent, Jennifer Liu (CT1) | Rel-13 | 69 |  | jennifer.liu@alcatel-lucent.com |  |
| 4617 | 1794.2.2 | CT3 aspects of Support of Emergency services over WLAN – phase 1 | 70d? | 2015-09-07 A | 2015-12-11 A | 100% | finish no earlier than 2015-12-11 | C3 | 560h | 560h | SEW1-CT | 35 | Alcatel-Lucent, Jennifer Liu (CT1) | Rel-13 | 69 |  | jennifer.liu@alcatel-lucent.com |  |
| 4618 | 1794.2.3 | CT4 aspects of Support of Emergency services over WLAN – phase 1 | 70d? | 2015-09-07 A | 2015-12-11 A | 100% | finish no earlier than 2015-12-11 | C4 | 560h | 560h | SEW1-CT | 35 | Alcatel-Lucent, Jennifer Liu (CT1) | Rel-13 | 69 |  | jennifer.liu@alcatel-lucent.com |  |
| 4619 | 1794.2.4 | CT6 aspects of Support of Emergency services over WLAN – phase 1 | 70d? | 2015-09-07 A | 2015-12-11 A | 100% | finish no earlier than 2015-12-11 | C6 | 560h | 560h | SEW1-CT | 35 | Alcatel-Lucent, Jennifer Liu (CT1) | Rel-13 | 69 |  | jennifer.liu@alcatel-lucent.com |  |
| 4620 | 1795 | **MBMS Enhancements** | 383.25d? | 2014-12-03 A | 2015-12-07 A | 100% |  | S2 | 4320h | 4320h | MBMS_enh | 34 | Nokia Networks, Curt Wong | Rel-13 | 66 |  |  |  |
| 4621 | 1795.1 | MBMS Enhancements TR Phase | 204d? | 2014-12-03 A | 2015-09-14 A | 100% | finish no earlier than 2015-09-14 | S2 | 1632h | 1632h | FS_MBMS_enh_TR | 34 | Nokia Networks, Curt Wong | Rel-13 | 66 |  |  |  |
| 4622 | 1795.2 | MBMS Enhancements | 28d? | 2015-08-10 A | 2015-09-16 A | 100% | finish no earlier than 2015-09-16 | S2 | 224h | 224h | MBMS_enh_St2 | 35 | Nokia Networks, Curt Wong | Rel-13 | 69 |  |  |  |
| 4623 | 1795.3 | **CT aspects of MBMS Enhancements** | 30d? | 2015-11-09 A | 2015-12-07 A | 100% |  | C3 | 344h | 344h | MBMS_enh-CT | 36 | Nokia Networks, Thomas Belling | Rel-13 | 70 |  |  |  |
| 4624 | 1795.3.1 | CT3 aspects of MBMS enhancements | 21d? | 2015-11-09 A | 2015-12-07 A | 100% | start no earlier than 2015-11-09 | C3 | 168h | 168h | MBMS_enh-CT | 36 | Nokia Networks, Thomas Belling | Rel-13 | 70 |  |  |  |
| 4625 | 1795.3.2 | CT4 aspects of MBMS enhancements | 21d? | 2015-11-09 A | 2015-12-07 A | 100% | finish no earlier than 2015-12-07 | C4 | 168h | 168h | MBMS_enh-CT | 36 | Nokia Networks, Thomas Belling | Rel-13 | 70 |  |  |  |
| 4626 | 1795.4 | Deleted (not approved) - MBMS Enhancements - Stage 2 | 1d? | 2015-03-13 A | 2015-03-13 A | 100% | finish no earlier than 2015-03-13 | S2 | 8h | 8h | MBMS_enh_TS | 34 | Rainer Liebhart | Rel-13 | 66 |  |  | SP-69 |
| 4627 | 1796 | **EPC Signalling Improvements for race scenarios** | 193.5d? | 2015-09-07 A | 2016-03-11 A | 100% |  | C4 | 2760h | 2760h | EPC_SIG_RACE | 35 | Huawei, Peter Schmitt | Rel-13 | 69 |  | Huawei, Peter Schmitt, Peter.Schmitt@HUAWEI.COM |  |
| 4628 | 1796.1 | CT3 aspects for EPC Signalling Improvements for race scenarios | 135d? | 2015-09-07 A | 2016-03-11 A | 100% | finish no earlier than 2016-03-11 | C3 | 1080h | 1080h | EPC_SIG_RACE | 35 | Huawei, Peter Schmitt | Rel-13 | 69 |  | Huawei, Peter Schmitt, Peter.Schmitt@HUAWEI.COM |  |
| 4629 | 1796.2 | CT4 aspects for EPC Signalling Improvements for race scenarios | 75d? | 2015-09-07 A | 2015-12-18 A | 100% | finish no earlier than 2015-12-18 | C4 | 600h | 600h | EPC_SIG_RACE | 35 | Huawei, Peter Schmitt | Rel-13 | 69 |  | Huawei, Peter Schmitt, Peter.Schmitt@HUAWEI.COM |  |

Notes:
- 4606: 03/07/15: Compl:0%->100% 03/07/15: Stat Rep: ->RP-150536
- 4607: 03/07/15: Compl:0%->100% 03/07/15: Stat Rep: ->RP-150536
- 4609: 03/07/15: Compl:0%->80% 03/07/15: WID: RP-150288->RP-151021 03/07/15: Stat Rep: ->RP-150827 29/09/15: Compl:80%->100% 29/09/15: Stat Rep: RP-150827->RP-151302
- 4611: 07/09/15: 0%->25¦7/12/15: 25%->100 / Impacted TSs and TRs: 24.237; 24.292
- 4612: 07/09/15: 0%->70¦7/12/15: 70%->100 / Impacted TSs and TRs: 29.292
- 4613: 07/09/15: 0%->100 / Impacted TSs and TRs: 23.402; 23.167; 23.271; 23.203; 23.228
- 4614: 07/09/15: 0%->100 / Impacted TSs and TRs: 23.402; 23.167; 23.271; 23.203; 23.228
- 4616: 7/12/15: 60%->95. FCD -> 03/16, ES in CP-150729¦7/3/16: 95%->100 / Impacted TSs and TRs: 24.302; 24.229
- 4617: 7/12/15: 0%->100 / Impacted TSs and TRs: 29.212; 29.214
- 4618: 7/12/15: 0%->100 / Impacted TSs and TRs: 23.003; 23.008; 29.273; 29.274
- 4619: 7/3/16: 0%->100 / Impacted TSs and TRs: 31.102
- 4620: . 3/3: WID tdoc number updated¦14/09/15: WID:SP-140883->SP-150516
- 4621: Acronym changed from "MBMS_enh-SA2TR". Mar15: 0->10%¦June2015: Compl:10%->50¦07/09/15: 50%->70. acronym changed from "MBMS_enh" to "MBMS_enh_TR"¦07/09/15: 70%->100¦14/09/15: WID:SP-140883->SP-150516 / Impacted TSs and TRs: 23.8xy
- 4622: SA#69: no normative work, moved as Study only. 14/10/15: corrected: was mentioned as FS_ / Impacted TSs and TRs: 23.246; 23.468
- 4624: 8/12/15: 0%->100 / Impacted TSs and TRs: 29.061; 29.468
- 4625: Impacted TSs and TRs: 29.274; 23.008; 29.230
- 4626: Commented during RAN#67 that it should have never beeen here. 07/09/15: "undeleted", acronym changed from "MBMS_enh-del" to "MBMS_enh_TS". 14/10/15: SP-140883 was never approved so this line should have never appeared in the WP. / Impacted TSs and TRs: 23.246; 23.468
- 4628: 7/12/15: FCD -> 03/16, ES in CP-150861¦8/12/15: 0%->100 / Impacted TSs and TRs: 29.212; 29.213
- 4629: 7/12/15: 95%->100 / Impacted TSs and TRs: 29.274; 29.274; 29.275; 29.282; 29.273; 29.230; 23.008; 29.273

| ID | WBS | Task | Duration | Start | Finish | Complete | Remaining | Total slack | Constraint | Resources | Work | Actual work | Acronym | PCG approved | WI rapporteur name | WI rapporteur e-mail | Release | TSG approved | Status Report |
| --- | --- | --- | --- | --- | --- | --- | --- | --- | --- | --- | --- | --- | --- | --- | --- | --- | --- | --- | --- |
| 4630 | 1797 | **Diameter Message Priority** | 236d? | 2015-11-02 A | 2016-06-16 A | 100% |  |  |  | C4 | 3736h | 3736h | DiaPri | 36 | Alcatel-Lucent, Jean-Jacques Trottin | jean-jacques.trottin@alcatel-lucent.com | Rel-13 | 70 |  |
| 4631 | 1797.1 | CT3 aspects of DiaPri | 95d? | 2015-11-02 A | 2016-03-11 A | 100% |  |  | finish no earlier than 2016-03-11 | C3 | 760h | 760h | DiaPri | 36 | Intel, Vivek Gupta |  | Rel-13 | 70 |  |
| 4632 | 1797.2 | CT4 aspects of DiaPri | 95d? | 2015-11-02 A | 2016-03-11 A | 100% |  |  | finish no earlier than 2016-03-11 | C4 | 760h | 760h | DiaPri | 36 | Alcatel-Lucent, Jean-Jacques Trottin | jean-jacques.trottin@alcatel-lucent.com | Rel-13 | 70 |  |
| 4633 | 1797.3 | (IETF) Diameter Routing Message Priority (draft-ietf-dime-drmp) | 138d? | 2015-12-08 A | 2016-06-16 A | 100% |  |  | finish no earlier than 2016-06-16 | C4-IETF | 1104h | 1104h | DiaPri | 36 | Alcatel-Lucent, Jean-Jacques Trottin | jean-jacques.trottin@alcatel-lucent.com | Rel-13 | 71 |  |
| 4634 | 1798 | **Downlink TPC Enhancements for UMTS** | 284.75d? | 2015-06-15 A | 2016-03-15 A | 100% |  |  |  | R1 | 4208h | 4208h | UTRA_EDL_TPC | 35 | Huawei |  | Rel-13 | 68 |  |
| 4635 | 1798.1 | Core part: Downlink TPC Enhancements for UMTS | 44d? | 2015-10-15 A | 2015-12-15 A | 100% |  |  | finish no earlier than 2015-12-15 | R1; R2; R3 | 1056h | 1056h | UTRA_EDL_TPC-Core | 35 | Huawei |  | Rel-13 | 68 | RP-151564 |
| 4636 | 1798.2 | Perf. part: Downlink TPC Enhancements for UMTS | 197d? | 2015-06-15 A | 2016-03-15 A | 100% |  |  | finish no earlier than 2016-03-15 | R4 | 1576h | 1576h | UTRA_EDL_TPC-Perf | 35 | Huawei |  | Rel-13 | 68 | RP-151564 |
| 4637 | 1799 | **Licensed-Assisted Access using LTE** | 853.12d? | 2015-06-15 A | 2017-09-15 | 99% | 0d? | 0d |  | R1 | 12624h | 8599.11h | LTE_LAA | 35 | Ericsson |  | Rel-13 | 68 |  |
| 4638 | 1799.1 | Core part: Licensed-Assisted Access using LTE | 132d? | 2015-06-15 A | 2015-12-15 A | 100% |  |  | finish no earlier than 2015-12-15 | R1 | 1056h | 1056h | LTE_LAA-Core | 35 | Ericsson |  | Rel-13 | 68 | RP-151390 |
| 4639 | 1799.2 | Perf. part: Licensed-Assisted Access using LTE | 395d? | 2015-06-15 A | 2016-12-15 A | 100% |  |  | finish no earlier than 2016-12-15 | R4 | 3160h | 3160h | LTE_LAA-Perf | 35 | Ericsson |  | Rel-13 | 68 |  |
| 4640 | 1799.3 | UE Conformance Test Aspects - Licensed-Assisted Access using LTE | 460d? | 2015-12-15 A | 2017-09-15 A | 100% |  |  | finish no earlier than 2017-09-15 | R5 | 3680h | 3680h | LTE_LAA-UEConTest | 36 | Motorola Mobility |  | Rel-13 | 70 |  |
| 4641 | 1800 | **Elevation Beamforming/Full-Dimension (FD) MIMO for LTE** | 1324.38d? | 2015-06-15 A | 2018-12-14 | 99% | 0d? | 0d |  | R1 | 13632h | 8944h | LTE_EBF_FDMIMO | 35 | Samsung |  | Rel-13 | 68 |  |
| 4642 | 1800.1 | Core part: Elevation Beamforming/Full-Dimension (FD) MIMO for LTE | 132d? | 2015-06-15 A | 2015-12-15 A | 100% |  |  | finish no earlier than 2015-12-15 | R1 | 1056h | 1056h | LTE_EBF_FDMIMO-Core | 35 | Samsung |  | Rel-13 | 68 | RP-151565 |
| 4643 | 1800.2 | Perf. part: Elevation Beamforming/Full-Dimension (FD) MIMO for LTE | 330d? | 2015-06-15 A | 2016-09-15 A | 100% |  |  | finish no earlier than 2016-09-15 | R4 | 2640h | 2640h | LTE_EBF_FDMIMO-Perf | 35 | Samsung |  | Rel-13 | 68 | RP-151565 |
| 4644 | 1800.3 | UE Conformance Test Aspects - Elevation Beamforming/Full-Dimension MIMO for LTE | 326d? | 2017-09-15 A | 2018-12-14 A | 100% |  |  | finish no earlier than 2018-12-15 | R5 | 2608h | 2608h | LTE_EBF_FDMIMO-UEConTest | 39 | Ericsson |  | Rel-13 | 77 |  |
| 4645 | 1801 | **L2/L3 Downlink enhancements for UMTS** | 190.5d? | 2015-06-15 A | 2015-12-15 A | 100% |  |  |  | R2 | 2112h | 2112h | UTRA_EDL_L23 | 35 | Huawei |  | Rel-13 | 68 |  |
| 4646 | 1801.1 | Core part: L2/L3 Downlink enhancements for UMTS | 132d? | 2015-06-15 A | 2015-12-15 A | 100% |  |  | finish no earlier than 2015-12-15 | R2 | 1056h | 1056h | UTRA_EDL_L23-Core | 35 | Huawei |  | Rel-13 | 68 | RP-151238 |
| 4647 | 1802 | **Support of single-cell point-to-multipoint transmission in LTE** | 475.12d? | 2015-06-15 A | 2016-09-15 A | 100% |  |  |  | R2 | 5824h | 5824h | LTE_SC_PTM | 35 | Huawei |  | Rel-13 | 68 |  |
| 4648 | 1802.1 | Core part: Support of single-cell point-to-multipoint transmission in LTE | 132d? | 2015-06-15 A | 2015-12-15 A | 100% |  |  | finish no earlier than 2015-12-15 | R2 | 1056h | 1056h | LTE_SC_PTM-Core | 35 | Huawei |  | Rel-13 | 68 | RP-151237 |
| 4649 | 1802.2 | Perf. part: Support of single-cell point-to-multipoint transmission in LTE | 132d? | 2015-06-15 A | 2015-12-15 A | 100% |  |  | finish no earlier than 2016-06-15 | R4 | 1056h | 1056h | LTE_SC_PTM-Perf | 35 | Huawei |  | Rel-13 | 68 | RP-151237 |
| 4650 | 1802.3 | UE Conformance Test Aspects - Support of single-cell point-to-multipoint transmission in LTE | 134d? | 2016-03-15 A | 2016-09-15 A | 100% |  |  | finish no earlier than 2016-12-15 | R5 | 1072h | 1072h | LTE_SC_PTM-UEConTest | 36 | Huawei |  | Rel-13 | 71 |  |
| 4651 | 1803 | **Extension of Dual Connectivity in E-UTRAN** | 190.5d? | 2015-06-15 A | 2015-12-15 A | 100% |  |  |  | R3 | 2112h | 2112h | LTE_dualC_ext | 35 | Samsung |  | Rel-13 | 68 |  |
| 4652 | 1803.1 | Core part: Extension of Dual Connectivity in E-UTRAN | 132d? | 2015-06-15 A | 2015-12-15 A | 100% |  |  | finish no earlier than 2015-12-15 | R3 | 1056h | 1056h | LTE_dualC_ext-Core | 35 | Samsung |  | Rel-13 | 68 | RP-151214 |
| 4653 | 1804 | **RAN sharing enhancements for UMTS** | 190.5d? | 2015-06-15 A | 2015-12-15 A | 100% |  |  |  | R3 | 2112h | 2112h | RSE_UTRA_GUSH | 35 | Huawei |  | Rel-13 | 68 |  |
| 4654 | 1804.1 | Core part: RAN sharing enhancements for UMTS | 132d? | 2015-06-15 A | 2015-12-15 A | 100% |  |  | finish no earlier than 2015-12-15 | R3 | 1056h | 1056h | RSE_UTRA_GUSH-Core | 35 | Huawei |  | Rel-13 | 68 | RP-151239 |

Notes:
- 4631: ES in CP-150645¦7/3/16: 65%->100 / Impacted TSs and TRs: 29.153; 29.154; 29.201; 29.212; 29.213; 29.214; 29.215; 29.217; 29.219
- 4632: ES in CP-150622¦7/3/16: 70%->100 / Impacted TSs and TRs: 29.228; 29.229; 29.272; 29.273; 29.328; 29.329; 29.336; 29.337; 29.338; 29.344; 29.345
- 4633: 02/2016: publication requested¦2/12/16: 85%->100; 9/4/21: RFC 7944 added; 7/3/16:introducedbyIETFinputs / Impacted TSs and TRs: 29.227; 29.272; 29.273; 29.229; RFC 7944
- 4634: follow-up WI of REL-13 SI FS_UTRA_EDL¦TPC = Transmit Power Control
- 4635: follow-up WI of REL-13 SI FS_UTRA_EDL¦TPC = Transmit Power Control 29/09/15: Compl:0%->35% 29/09/15: Stat Rep: -->RP-1515641/1/16: Compl:35%->100%1/1/16: WID:
- 4636: follow-up WI of REL-13 SI FS_UTRA_EDL¦TPC = Transmit Power Control 29/09/15: Stat Rep: -->RP-151564¦1/1/16: Compl:0%->80%¦1/1/16: WID: RP-151044->RP-151880
- 4637: follow-up WI of REL-13 SI FS_LTE_LAA
- 4638: follow-up WI of REL-13 SI FS_LTE_LAA 29/09/15: Compl:0%->25% 29/09/15: Stat Rep: -->RP-1513901/1/16: Compl:25%->100%
- 4639: follow-up WI of REL-13 SI FS_LTE_LAA 29/09/15: Stat Rep: -->RP-15139022/3/16: Compl:0%->33%¦1/7/16: Compl:3¦26/9/16: Compl:50%->90%¦20/12/16: Compl:90%->100%¦20/12/16: Stat Rep: RP-151390->
- 4640: ¦22/3/16: Compl:0%->5%1/7/16: Compl:5%->8%26/9/16: Compl:8%->15%¦20/21/3/17: Com ;
- 4641: follow-up WI of REL-13 SI FS_LTE_EBF_FDMIMO
- 4642: follow-up WI of REL-13 SI FS_LTE_EBF_FDMIMO 29/09/15: Compl:0%->25% 29/09/15: Stat Rep: -->RP-151565 1/1/16: Compl:25%->100%
- 4643: follow-up WI of REL-13 SI FS_LTE_EBF_FDMIMO 29/09/15: Stat Rep: -->RP-151565 ¦1/1/16: Compl:0%->5%¦22/3/16: Compl:5%->35%;26/9/16: Compl:70%->100%
- 4644: ¦8/1/18: Compl:0%->5%¦27/3/18: Compl:5%->10%¦27/6/18: CD:Fri 15/06/18-; 26/3/20: 10%->100
- 4645: no Perf. part¦follow-up of Rel-13 SI FS_UTRA_EDL
- 4646: no Perf. part¦follow-up of Rel-13 SI FS_UTRA_EDL 29/09/15: Compl:0%->35% 29/09/15: WID: RP-151043->RP-151249 29/09/15: Stat Rep: -->RP-1512381/1/16: Compl:35%->100% ¦
- 4647: follow-up WI of REL-13 SI FS_LTE_SC_PTM
- 4648: follow-up WI of REL-13 SI FS_LTE_SC_PTM 29/09/15: Compl:0%->30% 29/09/15: Stat Rep: -->RP-151237 1/1/16: Compl:30%->100%
- 4649: follow-up WI of REL-13 SI FS_LTE_SC_PTM 29/09/15: Stat Rep: -->RP-1512371/1/16: Compl:0%->100%
- 4650: testing REL-13 LTE_SC_PTM-Core1/7/16: Compl:0%->40%26/9/16
- 4651: no Perf. part¦follow-up WI of REL-13 SI FS_LTE_dualC_ext;
- 4652: no Perf. part¦follow-up WI of REL-13 SI FS_LTE_dualC_ext¦29/09/15: Compl:0%->30% 29/09/15: Stat Rep: -->RP-151214¦1/1/16: Compl:3
- 4653: no Perf. part¦follow-up WI for Rel-13 SI FS_RSE_UTRA_GUSH¦note: GUSH was a REL-13 SA1 WI¦there is an ongoing REL-13 WI for LTE: RSE-RAN_LTE;
- 4654: no Perf. part¦follow-up WI for Rel-13 SI FS_RSE_UTRA_GUSH¦note: GUSH was a REL-13 SA1 WI¦there is an ongoing REL-13 WI for LTE: RSE-RAN_LTE¦29/09/15: Compl:0%->30% 29/09/15: WID: RP-151086->RP-151251 29/09/15: Stat Rep: -->RP-151239 ¦

| ID | WBS | Task | Duration | Start | Finish | Complete | Constraint | Resources | Work | Actual work | Acronym | PCG approved | WI rapporteur name | Release | TSG approved | Status Report | Impacted TSs and TRs | WI rapporteur e-mail |
| --- | --- | --- | --- | --- | --- | --- | --- | --- | --- | --- | --- | --- | --- | --- | --- | --- | --- | --- |
| 4655 | 1805 | **Interference mitigation for downlink control channels of LTE** | 1230.12d? | 2015-06-15 A | 2018-09-14 A | 100% |  | R4 | 12056h | 12056h | LTE_IM_DLCCH | 35 | Intel | Rel-13 | 68 |  |  |  |
| 4656 | 1805.1 | Perf. part: Interference mitigation for downlink control channels of LTE | 263d? | 2015-06-15 A | 2016-06-15 A | 100% | finish no earlier than 2016-06-15 | R4 | 2104h | 2104h | LTE_IM_DLCCH-Perf | 35 | Intel | Rel-13 | 68 | RP-151301 |  |  |
| 4657 | 1805.2 | UE Conformance Test Aspects - Interference Mitigation for Downlink Control Channels of LTE | 393d? | 2017-03-15 A | 2018-09-14 A | 100% | finish no earlier than 2018-09-15 | R5 | 3144h | 3144h | LTE_IM_DLCCH-UEConTest | 38 | Intel | Rel-13 | 75 |  |  |  |
| 4658 | 1806 | **Network-Assisted Interference Cancellation and Suppression for UMTS** | 95.25d? | 2015-09-15 A | 2015-12-15 A | 100% |  | R1 | 1056h | 1056h | UTRA_NAICS | 35 | Huawei | Rel-13 | 69 |  |  |  |
| 4659 | 1806.1 | Core part: Network-Assisted Interference Cancellation and Suppression for UMTS | 66d? | 2015-09-15 A | 2015-12-15 A | 100% | finish no earlier than 2015-12-15 | R1 | 528h | 528h | UTRA_NAICS-Core | 35 | Huawei | Rel-13 | 69 |  |  |  |
| 4660 | 1807 | **Dual Carrier HSUPA Enhancements for UTRAN CS** | 95.25d? | 2015-09-15 A | 2015-12-15 A | 100% |  | R2 | 1056h | 1056h | DC_HSUPA_CS | 35 | Nokia Networks | Rel-13 | 69 |  |  |  |
| 4661 | 1807.1 | Core part: Dual Carrier HSUPA Enhancements for UTRAN CS | 66d? | 2015-09-15 A | 2015-12-15 A | 100% | finish no earlier than 2015-12-15 | R2 | 528h | 528h | DC_HSUPA_CS-Core | 35 | Nokia Networks | Rel-13 | 69 |  |  |  |
| 4662 | 1808 | **Further Enhancements of Minimization of Drive Tests for E-UTRAN** | 756.88d? | 2015-03-16 A | 2017-03-15 A | 100% |  | R2 | 6304h | 6304h | LTE_eMDT2 | 35 | CMCC | Rel-13 | 69 |  |  |  |
| 4663 | 1808.1 | Study on further Enhancements of Minimization of Drive Tests for E-UTRAN | 132d? | 2015-03-16 A | 2015-09-15 A | 100% | finish no earlier than 2015-09-15 | R2 | 1056h | 1056h | FS_LTE_eMDT2 | 34 | CMCC | Rel-13 | 67 | RP-151181 | 36.880 |  |
| 4664 | 1808.2 | Core part: Further Enhancements of Minimization of Drive Tests for E-UTRAN | 66d? | 2015-09-15 A | 2015-12-15 A | 100% | finish no earlier than 2015-12-15 | R2 | 528h | 528h | LTE_eMDT2-Core | 35 | CMCC | Rel-13 | 69 |  |  |  |
| 4665 | 1808.3 | UE Conformance Test Aspects – Further Enhancements of Minimization of Drive Tests for E-UTRAN | 197d? | 2016-06-15 A | 2017-03-15 A | 100% | finish no earlier than 2017-03-15 | R5 | 1576h | 1576h | LTE_eMDT2-UEConTest | 37 | Intel | Rel-13 | 72 |  |  |  |
| 4666 | 1809 | **LTE-WLAN RAN Level Integration supporting legacy WLAN** | 189.5d? | 2015-09-15 A | 2016-03-15 A | 100% |  | R2 | 2096h | 2096h | LTE_WLAN_radio_legacy | 35 | Alcatel-Lucent | Rel-13 | 69 |  |  |  |
| 4667 | 1809.1 | Core part: LTE-WLAN RAN Level Integration supporting legacy WLAN | 131d? | 2015-09-15 A | 2016-03-15 A | 100% | finish no earlier than 2016-03-15 | R2 | 1048h | 1048h | LTE_WLAN_radio_legacy-Core | 35 | Alcatel-Lucent | Rel-13 | 69 |  | 36.361 |  |
| 4668 | 1810 | **Indoor Positioning enhancements for UTRA and LTE** | 567.38d? | 2015-09-15 A | 2017-03-15 A | 100% |  | R2 | 7152h | 7152h | UTRA_LTE_iPos_enh | 35 | NextNav | Rel-13 | 69 |  |  |  |
| 4669 | 1810.1 | Core part: Indoor Positioning enhancements for UTRA and LTE | 66d? | 2015-09-15 A | 2015-12-15 A | 100% | finish no earlier than 2015-12-15 | R2 | 528h | 528h | UTRA_LTE_iPos_enh-Core | 35 | NextNav | Rel-13 | 69 |  |  |  |
| 4670 | 1810.2 | Perf. part: Indoor Positioning enhancements for UTRA and LTE | 197d? | 2015-09-15 A | 2016-06-15 A | 100% | finish no earlier than 2016-06-15 | R4 | 1576h | 1576h | UTRA_LTE_iPos_enh-Perf | 35 | NextNav | Rel-13 | 69 |  | 37.171; 37.958 |  |
| 4671 | 1810.3 | **CT aspects of Indoor Positionning** | 59d? | 2015-10-12 A | 2015-12-07 A | 100% |  | C4 | 328h | 328h | UTRA_LTE_iPos_enh-CT | 36 | Ericsson, Jesús de Gregorio | Rel-13 | 70 |  | 29.171; 29.172; 29.230; 29.002 | jesus.de.gregorio@ericsson.com |
| 4672 | 1810.3.1 | CT4 aspects of Indoor Positionning | 41d? | 2015-10-12 A | 2015-12-07 A | 100% | finish no earlier than 2015-12-07 | C4 | 328h | 328h | UTRA_LTE_iPos_enh-CT | 36 | Ericsson, Jesús de Gregorio | Rel-13 | 70 |  | 29.171; 29.172; 29.230; 29.002 | jesus.de.gregorio@ericsson.com |
| 4673 | 1810.4 | UE Conformance Test Aspects – Indoor Positioning Enhancement Support for LTE and UMTS | 197d? | 2016-06-15 A | 2017-03-15 A | 100% | finish no earlier than 2017-06-15 | R5 | 1576h | 1576h | UTRA_LTE_iPos_enh-UEConTest | 37 | NextNav | Rel-13 | 72 |  |  |  |
| 4674 | 1811 | **Power saving enhancements for UMTS** | 284.75d? | 2015-06-15 A | 2016-03-15 A | 100% |  | R2 | 3160h | 3160h | UTRA_SDATA_POWSAV | 35 | Ericsson | Rel-13 | 68 |  |  |  |
| 4675 | 1811.1 | Core part: Power saving enhancements for UMTS | 132d? | 2015-06-15 A | 2015-12-15 A | 100% | finish no earlier than 2015-12-15 | R2 | 1056h | 1056h | UTRA_SDATA_POWSAV-Core | 35 | Ericsson | Rel-13 | 68 | RP-151291 |  |  |
| 4676 | 1811.2 | Perf. Part: Power saving enhancements for UMTS | 66d? | 2015-12-15 A | 2016-03-15 A | 100% | finish no earlier than 2016-03-15 | R4 | 528h | 528h | UTRA_SDATA_POWSAV-Perf | 36 | Ericsson | Rel-13 | 70 |  |  |  |
| 4677 | 1812 | **700MHz E-UTRA FDD Band for Arab Region** | 284.75d? | 2015-06-15 A | 2016-03-15 A | 100% |  | R4 | 4728h | 4728h | LTE_FDD_700_ARAB | 35 | Etisalat | Rel-13 | 68 |  |  |  |
| 4678 | 1812.1 | Core part: 700MHz E-UTRA FDD Band for Arab Region | 197d? | 2015-06-15 A | 2016-03-15 A | 100% | finish no earlier than 2016-03-15 | R4 | 1576h | 1576h | LTE_FDD_700_ARAB-Core | 35 | Etisalat | Rel-13 | 68 | RP-151207 | 36.893 |  |
| 4679 | 1812.2 | Perf. part: 700MHz E-UTRA FDD Band for Arab Region | 197d? | 2015-06-15 A | 2016-03-15 A | 100% | finish no earlier than 2016-03-15 | R4 | 1576h | 1576h | LTE_FDD_700_ARAB-Perf | 35 | Etisalat | Rel-13 | 68 | RP-151207 |  |  |

Notes:
- 4655: only Perf. part, no Core part;
- 4656: only Perf. part, no Core part¦29/09/15: CD:Tue 15/03/16->Wed 15/06/16 29/09/15: Stat Rep: -->RP-1513011/1/16: Compl:0%->40%22/3/16: Compl:40%->70%
- 4657: tested: REL-13 LTE_IM_DLCCH-Perf (note: WI had no Core part);19/6/171 8/1/18: C 27/3/18 ;¦26/3/19: 84%->100
- 4658: no Perf. part¦follow-up WI REL-13 RAN1 SI FS_UTRA_NAICS
- 4659: no Perf. part¦follow-up WI REL-13 RAN1 SI FS_UTRA_NAICS ¦1/1/16: Compl:0%->100% ¦1/1/16: WID: RP-151577->RP-151879
- 4660: no Perf. part¦compare REL-13 WI HSUPA_DB_MC
- 4661: no Perf. part¦compare REL-13 WI HSUPA_DB_MC 1/1/16: Compl:0%->100% 1/1/16: WID: RP-151607->RP-151780
- 4662: no Perf. part¦follow-up WI of REL-13 SI FS_LTE_eMDT2
- 4663: 03/07/15: Compl:0%->70% 03/07/15: Stat Rep: -->RP-150806 29/09/15: Compl:70%->100% 29/09/15: Stat Rep: RP-150806->RP-151181
- 4664: no Perf. part¦follow-up WI of REL-13 SI FS_LTE_eMDT2¦1/1/16: Compl:0%->100%
- 4665: tested REL-13 WI: LTE_eMDT2-Core26/9/16: Com;21/3/17: Compl:5%->100%
- 4666: no Perf. part¦compare REL-13 WI LTE_WLAN_radio
- 4667: no Perf. part¦compare REL-13 WI LTE_WLAN_radio1/1/16: Compl:0%->95% 22/3/16: Compl:95%->100%¦28/7/16: 36.361 added;
- 4668: follow-up WI of REL-13 SI FS_UTRA_LTE_iPos_enh
- 4669: follow-up WI of REL-13 SI FS_UTRA_LTE_iPos_enh1/1/16: Compl:0%->100%1/1/16: WID: RP-151624->RP-15225122/3/16: WID: RP-152251->RP-160332
- 4670: follow-up WI of REL-13 SI FS_UTRA_LTE_iPos_enh 1/1/16: Compl:0%->10% 1/1/16: WID: RP-151624->RP-152251¦22/3/16: Compl:10%->20%¦22/3/16: WID: RP-152251->RP-160332 28/7/16: 37.171 added¦28/7/16: 37.958 added;
- 4672: 8/12/15: 0%->100
- 4673: tested REL-13 WI: UTRA_LTE_iPos_enh-Core¦26/9/1¦20/12/16:21/3/17: Compl:
- 4674: no Perf. part¦follow-up WI of SI FS_UTRA_SDATA
- 4675: no Perf. part¦follow-up WI of SI FS_UTRA_SDATA 29/09/15: Compl:0%->25% 29/09/15: CD:Tue 15/03/16->Tue 15/12/15 29/09/15: WID: RP-151092->RP-151292 29/09/15: Stat Rep: -->RP-151291 29/09/15: Release: Rel-14->Rel-13
- 4676: ¦22/3/16: Compl:0%->100%
- 4677: REL-independent from REL-9
- 4678: REL-independent from REL-9. Aug 15: TR numb added 29/09/15: Compl:0%->15% 29/09/15: CD:Tue 15/03/16->Tue 15/12/15 29/09/15: Stat Rep: -->RP-151207 29/09/15: Release: Rel-14->Rel-13;
- 4679: REL-independent from REL-9 29/09/15: CD:Tue 15/03/16->Tue 15/12/15 29/09/15: Stat Rep: -->RP-151207 29/09/15: Release: Rel-14->Rel-13

| ID | WBS | Task | Duration | Start | Finish | Complete | Remaining | Baseline start | Baseline finish | Baseline duration | Total slack | Constraint | Resources | Work | Actual work | Acronym | PCG approved | WI rapporteur name | Release | TSG approved | Status Report | WI rapporteur e-mail | MCC resp | Special Focus Doc | Acronym_3GU_Export |
| --- | --- | --- | --- | --- | --- | --- | --- | --- | --- | --- | --- | --- | --- | --- | --- | --- | --- | --- | --- | --- | --- | --- | --- | --- | --- |
| 4680 | 1813 | **European 700 Supplemental Downlink band (738-758 MHz) in E-UTRA and LTE Carrier Aggregation (2DL/1UL) with Band 20** | 190.5d? | 2015-06-15 A | 2015-12-15 A | 100% |  |  |  |  |  |  | R4 | 3168h | 3168h | LTE_CA_700EU_B20 | 35 | TeliaSonera | Rel-13 | 68 |  |  |  |  |  |
| 4681 | 1813.1 | Core part: European 700 Supplemental Downlink band (738-758 MHz) in E-UTRA and LTE Carrier Aggregation (2DL/1UL) with Band 20 | 132d? | 2015-06-15 A | 2015-12-15 A | 100% |  |  |  |  |  | finish no earlier than 2015-12-15 | R4 | 1056h | 1056h | LTE_CA_700EU_B20-Core | 35 | TeliaSonera | Rel-13 | 68 | RP-151232 |  |  |  |  |
| 4682 | 1813.2 | Perf. part: European 700 Supplemental Downlink band (738-758 MHz) in E-UTRA and LTE Carrier Aggregation (2DL/1UL) with Band 20 | 132d? | 2015-06-15 A | 2015-12-15 A | 100% |  |  |  |  |  | finish no earlier than 2016-03-15 | R4 | 1056h | 1056h | LTE_CA_700EU_B20-Perf | 35 | TeliaSonera | Rel-13 | 68 | RP-151232 |  |  |  |  |
| 4683 | 1814 | Release 13 Features on Internet of Things (IoT) | 438.25d? | 2013-09-12 A | 2015-05-12 A | 100% |  | 2015-04-14 | 2015-12-25 | 183.25d? |  |  | SP; RP; CP; GP | 14024h | 14024h |  |  |  | Rel-13 |  |  |  |  |  |  |
| 4684 | 1815 | Service Requirements Maintenance for Machine-Type Communications (MTC) | 194d? | 2015-09-15 A | 2016-06-10 A | 100% |  | 2013-12-12 | 2014-12-10 | 261d? |  |  | S1 | 1552h | 1552h | SRMMTC | 32 | KPN | Rel-13 | 62 |  | toon.norp@tno.nl | Alain | MTC, M2M | SRMMTC |
| 4685 | 1816 | **Cellular (Narrowband) Internet of Things** | 852.12d? | 2015-09-15 A | 2017-12-15 A | 100% |  |  |  |  |  |  |  | 16648h | 16648h | CIoT | 36 |  | Rel-13 | 70 |  |  |  |  |  |
| 4686 | 1816.1 | Stage 2 of CIoT | 1d? | 2015-10-05 A | 2015-10-05 A | 100% |  |  |  |  |  | start no earlier than 2015-10-05 | S2 | 8h | 8h | CIoT | 36 | Intel, Puneet Jain | Rel-13 | 70 |  | puneet.jain@intel.com |  |  |  |
| 4687 | 1816.2 | Security Aspects of CIoT (aka NB-IoT) | 160d? | 2015-11-02 A | 2016-06-10 A | 100% |  |  |  |  |  | finish no earlier than 2016-06-10 | S3 | 1280h | 1280h | CIoT | 36 | Tim Evans, Vodafone | Rel-13 | 70 |  |  |  |  |  |
| 4688 | 1816.3 | **CT aspects of CIoT** | 198.75d? | 2015-12-07 A | 2016-06-15 A | 100% |  |  |  |  |  |  | C1 | 4976h | 4976h | CIoT-CT | 36 | Intel, Vivek Gupta | Rel-13 | 70 |  | vivek.g.gupta@intel.com |  |  |  |
| 4689 | 1816.3.1 | CT1 aspects of CIoT | 70d? | 2015-12-07 A | 2016-03-11 A | 100% |  |  |  |  |  | finish no earlier than 2016-03-11 | C1 | 560h | 560h | CIoT-CT | 36 | Intel, Vivek Gupta | Rel-13 | 70 |  | vivek.g.gupta@intel.com |  |  |  |
| 4690 | 1816.3.2 | CT3 aspects of CIoT | 138d? | 2015-12-07 A | 2016-06-15 A | 100% |  |  |  |  |  | finish no earlier than 2016-06-15 | C3 | 1104h | 1104h | CIoT-CT | 36 | Intel, Vivek Gupta | Rel-13 | 70 |  | vivek.g.gupta@intel.com |  |  |  |
| 4691 | 1816.3.3 | CT4 aspects of CIoT | 138d? | 2015-12-07 A | 2016-06-15 A | 100% |  |  |  |  |  | finish no earlier than 2016-06-15 | C4 | 1104h | 1104h | CIoT-CT | 36 | Intel, Vivek Gupta | Rel-13 | 70 |  | vivek.g.gupta@intel.com |  |  |  |
| 4692 | 1816.3.4 | CT6 aspects of CIoT | 138d? | 2015-12-07 A | 2016-06-15 A | 100% |  |  |  |  |  | finish no earlier than 2016-06-15 | C6 | 1104h | 1104h | CIoT-CT | 36 | Intel, Vivek Gupta | Rel-13 | 70 |  | vivek.g.gupta@intel.com |  |  |  |
| 4693 | 1816.4 | Charging Aspects of CIoT | 23d? | 2016-05-12 A | 2016-06-13 A | 100% |  |  |  |  |  | finish no earlier than 2016-06-13 | S5 | 184h | 184h | CIoT-CH | 37 | Gardella, Maryse (Nokia) | Rel-13 | 72 |  | Gardella, Maryse (Nokia) |  |  |  |
| 4694 | 1816.5 | **RAN aspects of CIoT aka Narrowband Internet of Things (IOT)** | 474.12d? | 2015-09-15 A | 2016-12-15 A | 100% |  |  |  |  |  |  | R1 | 6320h | 6320h | NB_IOT | 35 | Vodafone | Rel-13 | 69 |  |  |  |  |  |
| 4695 | 1816.5.1 | Core part: Narrowband Internet of Things (IOT) | 197d? | 2015-09-15 A | 2016-06-15 A | 100% |  |  |  |  |  | finish no earlier than 2016-06-15 | R1 | 1576h | 1576h | NB_IOT-Core | 35 | Vodafone | Rel-13 | 69 |  |  |  |  |  |
| 4696 | 1816.5.2 | Perf. part: Narrowband Internet of Things (IOT) | 264d? | 2015-12-15 A | 2016-12-15 A | 100% |  |  |  |  |  | finish no earlier than 2016-12-15 | R4 | 2112h | 2112h | NB_IOT-Perf | 36 | Vodafone | Rel-13 | 70 |  |  |  |  |  |
| 4697 | 1816.6 | Management for NB-IoT | 25d? | 2016-05-12 A | 2016-06-15 A | 100% |  |  |  |  |  | finish no earlier than 2016-06-15 | S5 | 200h | 200h | NB_IOT-OAM | 37 | Huawei, Kai ZHANG | Rel-13 | 72 |  | kai.zhangkai@huawei.com |  |  |  |
| 4698 | 1816.7 | UE Conformance Test Aspects - Narrowband Internet of Things (NB-IOT) | 460d? | 2016-03-15 A | 2017-12-15 A | 100% |  |  |  |  |  | finish no earlier than 2017-12-15 | R5 | 3680h | 3680h | NB_IOT-UEConTest | 36 | CMCC | Rel-13 | 71 |  |  |  |  |  |
| 4699 | 1817 | **Extended Coverage GSM (EC-GSM) for support of Cellular Internet of Things** | 369.12d? | 2015-09-25 A | 2016-09-15 | 69% | 112.66d? |  |  |  | 41323.1d |  | G1; G2 | 8864h | 4044.7h | CIoT_EC_GSM | 35 | Marteen Sunberg, Ericsson | Rel-13 | 69 |  | Marteen.Sunberg@Ericsson.com |  |  |  |
| 4700 | 1817.1 | Extended Coverage GSM (EC-GSM) for support of Cellular Internet of Things Core part | 164.5d? | 2015-09-25 A | 2016-05-12 A | 100% |  |  |  |  |  | finish no earlier than 2016-05-12 | G1; G2 | 2632h | 2632h | CIoT_EC_GSM-Core | 36 | Marteen Sunberg, Ericsson | Rel-13 | 70 |  | Marteen.Sunberg@Ericsson.com |  |  |  |
| 4701 | 1817.2 | Test for CIoT_EC_GSM | 132d? | 2015-11-11 | 2016-03-17 |  |  |  |  |  | 41512d | start no earlier than 2015-11-11 | G3 | 1056h |  | CIoT_EC_GSM_GERAN3new | 36 | Sierra Wireless S.A | Rel-13 | 70 |  | Marteen.Sunberg@Ericsson.com |  |  |  |
| 4702 | 1817.3 | Perf. Part: Extended Coverage GSM (EC-GSM) for support of Cellular Internet of Things | 68d? | 2016-06-15 A | 2016-09-15 A | 100% |  |  |  |  |  | finish no earlier than 2016-09-15 | R6 | 544h | 544h | CIoT_EC_GSM-Perf | 37 | Ericsson | Rel-13 | 72 |  |  |  |  |  |
| 4703 | 1817.4 | MS Conformance Test Aspects - Extended Coverage GSM (EC-GSM) for support of Cellular Internet of Things | 68d? | 2016-06-15 A | 2016-09-15 A | 100% |  |  |  |  |  | finish no earlier than 2016-09-15 | R5 | 544h | 544h | CIoT_EC_GSM-MSConTest | 37 | Ericsson | Rel-13 | 72 |  |  |  |  |  |

Notes:
- 4680: introduction of new DL only band and 2DL/1UL CA with it
- 4681: introduction of new DL only band and 2DL/1UL CA with it. Aug 15: TR numb added 29/09/15: Compl:0%->80% 29/09/15: CD:Tue 15/03/16->Tue 15/12/15 29/09/15: WID: RP-150861->RP-151228 29/09/15: Stat Rep: -->RP-151232 29/09/15: Release: Rel-14->Rel-13 / Impacted TSs and TRs: 36.895
- 4682: introduction of new DL only band and 2DL/1UL CA with it 29/09/15: WID: RP-150861->RP-151228 29/09/15: Stat Rep: -->RP-151232 29/09/15: Release: Rel-14->Rel-13
- 4683: -
- 4684: SP#65 completed. Linked to Rel-13 SEES, Rel-12 Support for Interworking with M2M Service Enablement (MTCe-SIMSE), Service Requirement Maintenance (MTCe-SRM). Decide which MTC reqs with no Stage 2 should be removed/maintained in Rel-13. / Impacted TSs and TRs: 22.368
- 4686: 7/3/16: 0%->95 / Impacted TSs and TRs: 23.401; 23.682; 23.251
- 4687: 7/3/16: 0%->39¦19/9/16: 39%->100 / Impacted TSs and TRs: 33.401
- 4688: 11/6/16: WID:CP-150795->CP-160292
- 4689: 7/3/16: 0%->35¦11/6/16: 35%->100¦11/6/16: WID:CP-150795->CP-160292 / Impacted TSs and TRs: 24.301; 24.008; 23.122
- 4690: 7/3/16: 0%->90¦11/6/16: WID:CP-150795->CP-160292¦13/6/16: 90%->100 / Impacted TSs and TRs: 29.061; 29.212
- 4691: 7/3/16: 0%->65¦11/6/16: WID:CP-150795->CP-160292¦13/6/16: 65%->100 / Impacted TSs and TRs: 29.272; 29.274; 23.008; 23.007; 29.128; 29.275; 29.230; 29.336; 29.281; 29.002; 29.303
- 4692: 11/6/16: WID:CP-150795->CP-160292¦13/6/16: 0%->100 / Impacted TSs and TRs: 31.102
- 4693: 32.25x¦13/6/16: 0%->100 / Impacted TSs and TRs: 32.25x; 32.240; 32.251; 32.274; 32.299; 32.298; 32.297
- 4694: no Perf. part¦note: WI only stays in REL-13 because of PCG decision
- 4695: no Perf. part¦note: WI only stays in REL-13 because of PCG decision1/1/16: Compl:0%->25% 22/3/16: Compl:25%->75%;1/7/16: Com / Impacted TSs and TRs: 36.802
- 4696: 22/3/16: WID: RP-152284->RP-160656¦1/7/16: WID: RP-160656->RP-16093326/9/16: Compl:0%->60%26/9/16: CD:Thu 15/09/16->Thu 15/12/16¦20/12/16: Compl:60%->100%¦20/12/16: WID: RP-160933->RP-162134
- 4697: 13/6/16: 0%->100 / Impacted TSs and TRs: 28.657; 28.658; 28.659; 32.425
- 4698: testing REL-13 NB_IOT-Core1/7/16: Compl:0%->5%¦26/9¦20/12/1¦21/3/17: Compl: ;
- 4699: 7/12/15: 0%->60
- 4700: 7/12/15:created by MCC to distinguish core versus test parts. 2/3/16: FCD: 11/15->05/16, 40->90%¦13/6/16: 90%->100
- 4701: 7/12/15: created GERAN. 2/3/16: G1,G2->G3, Acronym: CIoT_EC_GSM-Test->CIoT_EC_GSM_GERAN3new
- 4702: related to GERAN REL-13 WI CIoT_EC_GSM-Core26/9/16: Compl:0%->100%
- 4703: tested REL-13 WI: CIoT_EC_GSM-Core26/9/16: Compl

| ID | WBS | Task | Duration | Start | Finish | Complete | Remaining | Baseline start | Baseline finish | Baseline duration | Total slack | Constraint | Resources | Work | Actual work | Acronym | PCG approved | WI rapporteur name | WI rapporteur e-mail | Release | TSG approved | Status Report | Acronym_3GU_Export |
| --- | --- | --- | --- | --- | --- | --- | --- | --- | --- | --- | --- | --- | --- | --- | --- | --- | --- | --- | --- | --- | --- | --- | --- |
| 4704 | 1818 | **Extended DRX cycle for Power Consumption** | 676.12d? | 2014-12-03 A | 2016-09-15 | 93% | 45.17d? |  |  |  | 41323.1d |  | S2; R2; G2 | 27696h | 16791.6h | eDRX | 35 | Miguel Griot | mgriot@qti.qualcomm.com | Rel-13 | 68 |  |  |
| 4705 | 1818.1 | Study on Extended DRX cycle for Power Consumption Optimization | 268d? | 2014-12-03 A | 2015-12-11 A | 100% |  |  |  |  |  | finish no earlier than 2015-12-11 | S2 | 2144h | 2144h | FS_eDRX | 34 | Miguel Griot, Qualcomm | mgriot@qti.qualcomm.com | Rel-13 | 66 |  |  |
| 4706 | 1818.2 | Stage 2 for Extended DRX cycle for Power Consumption | 133d? | 2015-06-15 A | 2015-12-16 A | 100% |  |  |  |  |  | finish no earlier than 2015-12-16 | S2 | 1064h | 1064h | eDRX | 35 | Miguel Griot | mgriot@qti.qualcomm.com | Rel-13 | 68 |  |  |
| 4707 | 1818.3 | **CT aspects of extended DRX cycle** | 193.5d? | 2015-09-07 A | 2016-03-11 A | 100% |  |  |  |  |  |  | ct | 4912h | 4912h | eDRX-CT | 35 | Catovic, Amer, Qualcomm | Catovic, Amer, Qualcomm | Rel-13 | 69 |  |  |
| 4708 | 1818.3.1 | CT1 aspects of extended DRX cycle | 135d? | 2015-09-07 A | 2016-03-11 A | 100% |  |  |  |  |  | finish no earlier than 2016-03-11 | C1 | 1080h | 1080h | eDRX-CT | 35 | Catovic, Amer, Qualcomm | Catovic, Amer, Qualcomm | Rel-13 | 69 |  |  |
| 4709 | 1818.3.2 | CT3 aspects of extended DRX cycle | 135d? | 2015-09-07 A | 2016-03-11 A | 100% |  |  |  |  |  | finish no earlier than 2016-03-11 | C3 | 1080h | 1080h | eDRX-CT | 35 | Catovic, Amer, Qualcomm | Catovic, Amer, Qualcomm | Rel-13 | 69 |  |  |
| 4710 | 1818.3.3 | CT4 aspects of extended DRX cycle | 74d? | 2015-09-07 A | 2015-12-17 A | 100% |  |  |  |  |  | finish no earlier than 2015-12-17 | C4 | 592h | 592h | eDRX-CT | 35 | Catovic, Amer, Qualcomm | Catovic, Amer, Qualcomm | Rel-13 | 69 |  |  |
| 4711 | 1818.3.4 | CT6 aspects of extended DRX cycle | 135d? | 2015-09-07 A | 2016-03-11 A | 100% |  |  |  |  |  | finish no earlier than 2016-03-11 | C6 | 1080h | 1080h | eDRX-CT | 36 | Catovic, Amer, Qualcomm | Catovic, Amer, Qualcomm | Rel-13 | 70 |  |  |
| 4712 | 1818.4 | **RAN enhancements for extended DRX in LTE** | 379d? | 2015-03-16 A | 2016-03-15 A | 100% |  |  |  |  |  |  | R2 | 4192h | 4192h | LTE_extDRX | 34 | Qualcomm |  | Rel-13 | 67 |  |  |
| 4713 | 1818.4.1 | Core part: RAN enhancements for extended DRX in LTE | 262d? | 2015-03-16 A | 2016-03-15 A | 100% |  |  |  |  |  | finish no earlier than 2016-03-15 | R2 | 2096h | 2096h | LTE_extDRX-Core | 34 | Qualcomm |  | Rel-13 | 67 | RP-151338 |  |
| 4714 | 1818.5 | UE Conformance Test Aspects - RAN enhancements for extended DRX in LTE | 134d? | 2016-03-15 A | 2016-09-15 A | 100% |  |  |  |  |  | finish no earlier than 2016-12-15 | R5 | 1072h | 1072h | LTE_extDRX-UEConTest | 36 | Qualcomm |  | Rel-13 | 71 |  |  |
| 4715 | 1818.6 | **Extended DRX (eDRX) for GSM** | 225d? | 2015-08-28 A | 2016-04-01 | 44% | 124.95d? |  |  |  | 41496.2d |  | G2; G1 | 4832h | 2072.8h | eDRX_GSM | 35 | John Diachina, Ericsson LM | John.Diachina@Ericsson.com | Rel-13 | 69 |  |  |
| 4716 | 1818.6.1 | Core Part: Extended DRX (eDRX) for GSM | 60.5d? | 2015-08-28 A | 2015-11-20 A | 100% |  |  |  |  |  | finish no earlier than 2015-11-20 | G2; G1 | 968h | 968h | eDRX_GSM-Core | 36 | John Diachina, Ericsson LM | John.Diachina@Ericsson.com | Rel-13 | 70 |  |  |
| 4717 | 1818.6.2 | MS test: Extended DRX (eDRX) for GSM | 114d? | 2015-12-07 A | 2016-04-01 | 15% | 96.9d? |  |  |  | 41496.2d | start no earlier than 2015-12-07 | G3 | 912h | 136.8h | eDRX_GSM_GERAN3new | 36 | Sierra Wireless S.A | John.Diachina@Ericsson.com | Rel-13 | 70 |  |  |
| 4718 | 1819 | **Optimizations to Support High Latency Communications** | 470d? | 2014-09-19 A | 2015-12-16 A | 100% |  |  |  |  |  |  | S2 | 5824h | 5824h | HLcom | 34 | Ericsson, Hans Rönneke | hans.ronneke(at)ericsson.com | Rel-13 | 67 |  |  |
| 4719 | 1819.1 | Study on Optimizations to support High Latency communications | 196d? | 2014-09-19 A | 2015-06-17 A | 100% |  |  |  |  |  | finish no earlier than 2015-06-17 | S2 | 1568h | 1568h | FS_HLcom | 33 | Ericsson | hans.ronneke@ericsson.com | Rel-13 | 65 |  | FS_HLcom |
| 4720 | 1819.2 | Optimizations to Support High Latency Communications | 73d? | 2015-03-05 A | 2015-06-15 A | 100% |  |  |  |  |  | finish no earlier than 2015-06-15 | S2 | 584h | 584h | HLcom | 34 | Ericsson, Hans Rönneke | hans.ronneke(at)ericsson.com | Rel-13 | 67 |  |  |
| 4721 | 1819.3 | CT aspects of Optimizations to Support High Latency | 133d? | 2015-06-15 A | 2015-12-16 A | 100% |  |  |  |  |  | finish no earlier than 2015-12-16 | C4 | 1064h | 1064h | HLcom-CT | 35 | Yong Yang, Ericsson | frank.yong.yang@ericsson.com | Rel-13 | 68 |  |  |
| 4722 | 1820 | **Further LTE Physical Layer Enhancements for MTC** | 1138.88d? | 2014-09-12 A | 2017-09-15 A | 100% |  | 2014-06-13 | 2015-06-12 | 261d? |  |  | R1; R4; R2 | 36320h | 36320h | LTE_MTCe2_L1 | 33 | Ericsson | johan.bergman@ericsson.com | Rel-13 | 65 |  | LTE_MTCe2_L1 |
| 4723 | 1820.1 | Core part: Further LTE Physical Layer Enhancements for MTC | 395d? | 2014-09-12 A | 2016-03-15 A | 100% |  | 2014-06-13 | 2015-06-12 | 261d? |  | finish no earlier than 2016-03-15 | R1; R2; R4 | 9480h | 9480h | LTE_MTCe2_L1-Core | 33 | Ericsson | johan.bergman@ericsson.com | Rel-13 | 65 | RP-151186 | LTE_MTCe2_L1-Core |
| 4724 | 1820.2 | Perf. Part: Further LTE Physical Layer Enhancements for MTC | 593d? | 2014-09-12 A | 2016-12-15 A | 100% |  | 2014-06-13 | 2015-06-12 | 261d? |  | finish no earlier than 2016-12-15 | R4 | 4744h | 4744h | LTE_MTCe2_L1-Perf | 33 | Ericsson | johan.bergman@ericsson.com | Rel-13 | 65 |  | LTE_MTCe2_L1-Perf |
| 4725 | 1820.3 | UE Conformance Test Aspects - Further LTE Physical Layer Enhancements for MTC | 395d? | 2016-03-15 A | 2017-09-15 A | 100% |  |  |  |  |  | finish no earlier than 2017-09-15 | R5 | 3160h | 3160h | LTE_MTCe2_L1-UEConTest | 36 | Ericsson |  | Rel-13 | 71 |  |  |
| 4726 | 1821 | EGPRS Access Security Enhancements in relation to Cellular IoT | 128d? | 2015-09-16 A | 2016-03-11 A | 100% |  |  |  |  |  | finish no earlier than 2016-03-11 | S3 | 1024h | 1024h | EASE_EC_GSM | 35 | Vesa Torvinen, Ericsson |  | Rel-13 | 69 |  |  |
| 4727 | 1822 | **Group based Enhancements** | 566.12d? | 2014-06-18 A | 2015-12-16 A | 100% |  | 2014-06-18 | 2015-09-16 | 326d? |  |  | S2; S3 | 18676.8h | 18676.8h | GROUPE | 33 | Huawei | ZhangWanqiang@huawei.com | Rel-13 | 64 |  | GROUPE |
| 4728 | 1822.1 | TR for Group based Enhancements | 196d? | 2014-06-18 A | 2015-03-18 A | 100% |  | 2014-06-18 | 2015-03-18 | 196d? |  | finish no earlier than 2015-03-18 | S2 | 1568h | 1568h | GROUPE | 33 | Huawei, Wanqiang Zhang | ZhangWanqiang@huawei.com | Rel-13 | 64 |  |  |
| 4729 | 1822.2 | Stage 2 for Group based Enhancements | 261d? | 2014-06-23 A | 2015-06-17 A | 100% |  | 2014-06-18 | 2015-06-17 | 261d? |  | finish no earlier than 2015-06-17 | S2 | 2088h | 2088h | GROUPE | 33 | Huawei | ZhangWanqiang@huawei.com | Rel-13 | 64 |  |  |
| 4730 | 1822.3 | TR on Security for Group based Enhancements | 231.6d? | 2014-06-18 A | 2015-06-12 A | 100% |  | 2014-06-18 | 2015-06-17 | 231.6d? |  | start no earlier than 2014-06-18 | S3 | 1852.8h | 1852.8h | GROUPE | 33 | Samsung | Rajavelsamy R (rajvel@samsung.com) | Rel-13 | 64 |  |  |
| 4731 | 1822.4 | Security for Group based Enhancements | 326d? | 2014-06-23 A | 2015-09-16 A | 100% |  | 2014-06-18 | 2015-09-16 | 326d? |  | finish no earlier than 2015-09-16 | S3 | 2608h | 2608h | GROUPE | 33 | Samsung | Rajavelsamy R (rajvel@samsung.com) | Rel-13 | 64 |  |  |

Notes:
- 4704: June2015: WID:SP-150254->SP-150369 / Impacted TSs and TRs: 23.401; 23.060; 23.682; 23.271; 23.272
- 4705: No Ran aspects yet. GERAN in FS_uPoD.29/1: TS number added Mar15: 0->30%¦June2015: Compl:30%->95, Exc S granted in SP-150352¦07/09/15: 95%->100 / Impacted TSs and TRs: 23.770
- 4706: June2015: WID:SP-150254->SP-150369¦07/09/15: 0%->95¦7/12/15: 95%->99 / Impacted TSs and TRs: 23.401; 23.060; 23.682; 23.271; 23.272
- 4707: 14/09/15: WID:CP-150499->CP-150541
- 4708: 14/09/15: WID:CP-150499->CP-150541¦7/12/15: 25%->80. FCD ->03/16. ES in CP-150723¦7/3/16: 80%->100 / Impacted TSs and TRs: 24.301; 24.008; 29.118
- 4709: 14/09/15: WID:CP-150499->CP-150541. FCD ->03/16. ES in CP-150723¦8/12/15: 0%->100 / Impacted TSs and TRs: 29.338; 23.007; 29.274; 29.060; 29.172
- 4710: 14/09/15: WID:CP-150499->CP-150541¦7/12/15: 40%->100¦8/12/15: 100%->95¦8/3/16: 95%->100 / Impacted TSs and TRs: 29.212
- 4711: 7/12/15: Added. FCD ->03/16. ES in CP-150723¦8/3/16: 0%->100
- 4713: 03/07/15: Compl:0%->15% 03/07/15: Stat Rep: ->RP-150798 29/09/15: Compl:15%->35% 29/09/15: WID: RP-150493->RP-151339 29/09/15: Stat Rep: RP-150798->RP-151338 ¦22/3/16: Compl:95%->100%
- 4714: testing REL-13 LTE_extDRX-Core and CT1 feature eDRX-CT;
- 4715: 07/09/15: 0%->40¦7/12/15: 40%->100 / Impacted TSs and TRs: 43.064; 44.018; 44.060; 45.008; 48.018; 43.022
- 4716: 7/12/15: created by MCC to distinguish Core versus test parts / Impacted TSs and TRs: 43.064; 44.018; 44.060; 45.008; 48.018; 43.022
- 4717: 7/12/15: created by GERAN. 2/3/16: G1,G2->G3. Acronym: eDRX_GSM-Test -> eDRX_GSM_GERAN3new (to conform to WID)¦0->15%
- 4718: Impacted TSs and TRs: 23.401; 23.060; 23.682
- 4719: Dec.14: 0->30%. Mar15: 70%¦June2015: Compl:70%->100 / Impacted TSs and TRs: New 23.709
- 4720: June 2015: created by MCC as a result of the split of the one-line Feature into a several-lines Feature (now Stage 2 and Stage 3 aspects)¦June2015: Compl:0%->100. WID: SP-150030->SP-150252 / Impacted TSs and TRs: 23.401; 23.060; 23.682
- 4721: 07/09/15: 0%->80¦7/12/15: 80%->100 / Impacted TSs and TRs: 29.274; 29.060; 29.281; 23.008; 29.272; 29.230; 29.002; 29.336; 29.xyz
- 4722: Triggered by Rel-12 TR 36.888 Study on Provision of low-cost MTC UEs based on LTE (FS_LC_MTC_LTE) and Low cost & enhanced coverage MTC UE for LTE (LC_MTC_UE) / Impacted TSs and TRs: LTE
- 4723: 3/3/15: WID: RP-141865¦Stat Rep: -->RP-141785 1st Apr 15: Compl:10%->25% 1st Apr 15: WID: RP-141865->RP-150492 1st Apr 15: Stat Rep: RP-141785->RP-150495 03/07/15: Compl:25%->45% 03/07/15: Stat Rep: RP-150495->RP-150583 29/09/15: Compl:45%->65% 29/09 / Impacted TSs and TRs: 36.101; 36.104; 36.133; 36.201; 36.211; 36.212; 36.213; 36.214; 36.300; 36.302; 36.306; 36.321; 36.331
- 4724: ¦WID: RP-142043->RP-141865¦Stat Rep: -->RP-141785 1st Apr 15: WID: RP-141865->RP-150492 1st Apr 15: Stat Rep: RP-141785->RP-150495 03/07/15: Stat Rep: RP-150495->RP-150583 29/09/15: Stat Rep: RP-150583->RP-151186 ;26/9/16: Compl:70%-¦ / Impacted TSs and TRs: 36.101; 36.104; 36.133
- 4725: testing REL-13 LTE_MTCe2_L1-Core¦1/7/16: Compl:0%->6%¦26/¦2¦21/3/17: Compl:70% ;
- 4726: 7/12/15: 0%->5¦28/1/16: 33.420 added¦7/3/16: 5%->80¦11/6/16: 80%->98¦19/9/16: 98%->99¦21/3/17: 99%->100->99%¦7/6/17: 99%->100 / Impacted TSs and TRs: New 33.420
- 4727: - / Impacted TSs and TRs: Stage 2
- 4728: Dec.14: 20->70%. Mar15: 90%¦June2015: Compl:90%->100 / Impacted TSs and TRs: New 23.769
- 4729: Mar15: 0->20%¦June2015: Compl:20%->100 / Impacted TSs and TRs: 23.682; TBD
- 4730: TR 33.8xy will capture requirements, solution alternatives, evaluations and conclusions for the AESE, MONTE and GROUPE WIDs. 3/3/15: 5->10%.¦June2015: Compl:10%->60¦11/12/15: 60%->100 / Impacted TSs and TRs: New 33.889
- 4731: -¦11/12/15: 0%->100 / Impacted TSs and TRs: 33.187

| ID | WBS | Task | Duration | Start | Finish | Complete | Baseline start | Baseline finish | Baseline duration | Constraint | Resources | Work | Actual work | Acronym | PCG approved | WI rapporteur name | WI rapporteur e-mail | Release | TSG approved | Acronym_3GU_Export | Status Report | MCC resp | Special Focus Doc |
| --- | --- | --- | --- | --- | --- | --- | --- | --- | --- | --- | --- | --- | --- | --- | --- | --- | --- | --- | --- | --- | --- | --- | --- |
| 4732 | 1822.5 | **CT aspects of Group based Enhancements** | 191.5d? | 2015-06-15 A | 2015-12-16 A | 100% |  |  |  |  | C4 | 4256h | 4256h | GROUPE-CT | 35 | Peter Schmitt, Huawei | Peter.Schmitt@huawei.com | Rel-13 | 68 |  |  |  |  |
| 4733 | 1822.5.1 | CT1 aspects of Group based Enhancements | 133d? | 2015-06-15 A | 2015-12-16 A | 100% |  |  |  | start no earlier than 2015-06-15 | C1 | 1064h | 1064h | GROUPE-CT | 35 | Peter Schmitt, Huawei | Peter.Schmitt@huawei.com | Rel-13 | 68 |  |  |  |  |
| 4734 | 1822.5.2 | DELETED: CT3 aspects of Group based Enhancements | 133d? | 2015-06-15 A | 2015-12-16 A | 100% |  |  |  | start no earlier than 2015-06-15 | C3 | 1064h | 1064h | GROUPE-CT | 35 | Peter Schmitt, Huawei | Peter.Schmitt@huawei.com | Rel-13 | 68 |  |  |  |  |
| 4735 | 1822.5.3 | CT4 aspects of Group based Enhancements | 133d? | 2015-06-15 A | 2015-12-16 A | 100% |  |  |  | start no earlier than 2015-06-15 | C4 | 1064h | 1064h | GROUPE-CT | 35 | Peter Schmitt, Huawei | Peter.Schmitt@huawei.com | Rel-13 | 68 |  |  |  |  |
| 4736 | 1823 | **Monitoring Enhancements** | 655.12d? | 2014-06-18 A | 2016-03-11 A | 100% | 2014-06-18 | 2015-09-16 | 326d? |  | S2; S3 | 21684.8h | 21684.8h | MONTE | 33 | Intel | puneet.jain@intel.com | Rel-13 | 64 | MONTE |  |  |  |
| 4737 | 1823.1 | TR for Monitoring Enhancements | 196d? | 2014-09-17 A | 2015-06-17 A | 100% | 2014-09-17 | 2015-06-17 | 196d? | finish no earlier than 2015-06-17 | S2 | 1568h | 1568h | MONTE | 33 | Intel, Puneet Jain | puneet.jain@intel.com | Rel-13 | 64 |  |  |  |  |
| 4738 | 1823.2 | Stage 2 for Monitoring Enhancements | 261d? | 2014-06-23 A | 2015-06-17 A | 100% | 2014-06-18 | 2015-06-17 | 261d? | finish no earlier than 2015-06-17 | S2 | 2088h | 2088h | MONTE | 33 | Intel, Puneet Jain | puneet.jain@intel.com | Rel-13 | 64 |  |  |  |  |
| 4739 | 1823.3 | TR on Security for Monitoring Enhancements | 231.6d? | 2014-06-18 A | 2015-06-12 A | 100% | 2014-06-18 | 2015-06-17 | 231.6d? | start no earlier than 2014-06-18 | S3 | 1852.8h | 1852.8h | MONTE | 33 | Samsung | Rajavelsamy R (rajvel@samsung.com) | Rel-13 | 64 |  |  |  |  |
| 4740 | 1823.4 | Security for Monitoring Enhancements | 326d? | 2014-06-23 A | 2015-09-16 A | 100% | 2014-06-18 | 2015-09-16 | 326d? | finish no earlier than 2015-09-16 | S3 | 2608h | 2608h | MONTE | 33 | Samsung | Rajavelsamy R (rajvel@samsung.com) | Rel-13 | 64 |  |  |  |  |
| 4741 | 1823.5 | Charging aspects of MONTE | 128d? | 2015-09-16 A | 2016-03-11 A | 100% | 2014-06-18 | 2015-09-16 | 326d? | finish no earlier than 2016-03-11 | S5 | 1024h | 1024h | MONTE-CH | 35 | Huawei(Li Li, jasmine.li@huawei.com) | jasmine.li@huawei.com | Rel-13 | 69 |  |  |  |  |
| 4742 | 1823.6 | **Monitoring Enhancements CT aspects** | 280.5d? | 2015-06-15 A | 2016-03-11 A | 100% |  |  |  |  | C4 | 5248h | 5248h | MONTE-CT | 35 | Peter Schmitt, Huawei | peter.schmitt@huawei.com | Rel-13 | 68 |  |  |  |  |
| 4743 | 1823.6.1 | CT1 aspects of Monitoring Enhancements | 133d? | 2015-06-15 A | 2015-12-16 A | 100% |  |  |  | start no earlier than 2015-06-15 | C1 | 1064h | 1064h | MONTE-CT | 35 | Peter Schmitt, Huawei | peter.schmitt@huawei.com | Rel-13 | 68 |  |  |  |  |
| 4744 | 1823.6.2 | CT3 aspects of Monitoring Enhancements | 133d? | 2015-06-15 A | 2015-12-16 A | 100% |  |  |  | start no earlier than 2015-06-15 | C3 | 1064h | 1064h | MONTE-CT | 35 | Peter Schmitt, Huawei | peter.schmitt@huawei.com | Rel-13 | 68 |  |  |  |  |
| 4745 | 1823.6.3 | CT4 aspects of Monitoring Enhancements | 195d? | 2015-06-15 A | 2016-03-11 A | 100% |  |  |  | finish no earlier than 2016-03-11 | C4 | 1560h | 1560h | MONTE-CT | 35 | Peter Schmitt, Huawei | peter.schmitt@huawei.com | Rel-13 | 68 |  |  |  |  |
| 4746 | 1824 | **Dedicated Core Networks** | 655.12d? | 2014-06-18 A | 2016-03-11 A | 100% | 2014-06-18 | 2015-03-18 | 196d? |  | S2 | 11518.4h | 11518.4h | DECOR | 33 | NTT DOCOMO | Daisuke Fujishima (fujishimad@nttdocomo.co.jp) | Rel-13 | 64 | DECOR |  |  |  |
| 4747 | 1824.1 | TR for Dedicated Core Networks | 128d? | 2014-06-18 A | 2014-12-12 A | 100% | 2014-06-18 | 2014-12-10 | 126d? | finish no earlier than 2014-12-12 | S2 | 1024h | 1024h | DECOR | 33 | NTT DOCOMO | Daisuke Fujishima (fujishimad@nttdocomo.co.jp) | Rel-13 | 64 |  |  |  |  |
| 4748 | 1824.2 | Stage 2 for Dedicated Core Networks | 196d? | 2014-06-23 A | 2015-03-18 A | 100% | 2014-06-18 | 2015-03-18 | 196d? | finish no earlier than 2015-03-18 | S2 | 1568h | 1568h | DECOR | 33 | NTT DOCOMO | Daisuke Fujishima (fujishimad@nttdocomo.co.jp) | Rel-13 | 64 |  |  |  |  |
| 4749 | 1824.3 | **CT aspects of Dedicated Core Networks** | 270.05d? | 2015-06-25 A | 2016-03-11 A | 100% |  |  |  |  | ct | 3166.4h | 3166.4h | DECOR-CT | 35 | Huawei, Xiaoyan SHI (Sean.shixiaoyan@huawei.com) | Huawei, Xiaoyan SHI (Sean.shixiaoyan@huawei.com) | Rel-13 | 69 |  |  |  |  |
| 4750 | 1824.3.1 | CT1 aspects for Dedicated Core Networks CT aspects | 74d? | 2015-09-07 A | 2015-12-17 A | 100% |  |  |  | finish no earlier than 2015-12-17 | C1 | 592h | 592h | DECOR-CT | 35 | Huawei |  | Rel-13 | 69 |  |  |  |  |
| 4751 | 1824.3.2 | CT4 aspects for Dedicated Core Networks CT aspects | 135d? | 2015-06-25 A | 2016-03-11 A | 100% |  |  |  | finish no earlier than 2016-03-11 | C4 | 1080h | 1080h | DECOR-CT | 35 |  |  | Rel-13 | 69 |  |  |  |  |
| 4752 | 1824.4 | **Dedicated Core Networks RAN Aspects** | 190.5d? | 2015-06-15 A | 2015-12-15 A | 100% |  |  |  |  | R3 | 2112h | 2112h | DECOR-UTRA_LTE | 35 | Ericsson |  | Rel-13 | 68 |  |  |  |  |
| 4753 | 1824.4.1 | Core part: Dedicated Core Networks | 132d? | 2015-06-15 A | 2015-12-15 A | 100% |  |  |  | finish no earlier than 2015-12-15 | R3 | 1056h | 1056h | DECOR-UTRA_LTE-Core | 35 | Ericsson |  | Rel-13 | 68 |  | RP-151290 |  |  |
| 4754 | 1825 | **Service Exposure and Enablement Support** | 383.88d? | 2013-09-12 A | 2014-09-17 A | 100% | 2013-09-12 | 2014-09-17 | 267d? |  | S1 | 5880h | 5880h | SEES | 31 | KPN | toon.norp@tno.nl | Rel-13 | 61 | SEES | S1-143301 | Alain | MTC, M2M |
| 4755 | 1825.1 | TR on Stage 1 for Service Exposure and Enablement Support | 202d? | 2013-09-12 A | 2014-06-18 A | 100% | 2013-09-12 | 2014-06-18 | 202d? | finish no earlier than 2014-06-18 | S1 | 1608h | 1608h | SEES | 31 | KPN | toon.norp@tno.nl | Rel-13 | 61 |  | S1-143301 | Alain | MTC, M2M |
| 4756 | 1825.2 | Stage 1 for Service Exposure and Enablement Support | 266d? | 2013-09-12 A | 2014-09-17 A | 100% | 2013-09-12 | 2014-09-17 | 266d? | finish no earlier than 2014-09-17 | S1 | 2128h | 2128h | SEES | 31 | KPN | toon.norp@tno.nl | Rel-13 | 61 |  | S1-143301 | Alain | MTC, M2M |

Notes:
- 4732: 7/12/15: WID:CP-150240->CP-150816 / Impacted TSs and TRs: 24.008; 24.301; 29.468; 29.272; 23.008; 29.336; 29.303; 29.002; 29.230; 29.305; 23.003
- 4733: 07/09/15: 0%->15¦7/12/15: 15%->100¦7/12/15: WID:CP-150240->CP-150816 / Impacted TSs and TRs: 24.008; 24.301
- 4734: 7/12/15: WID:CP-150240->CP-150816. CT3 task removed / Impacted TSs and TRs: 29.468
- 4735: 07/09/15: 0%->80¦7/12/15: 80%->100¦7/12/15: WID:CP-150240->CP-150816 / Impacted TSs and TRs: 29.272; 23.008; 29.336; 29.303; 29.002; 29.230; 29.305; 23.003
- 4736: Linked to Rel-13 Feature Architecture Enhancements for Service Exposure (AESE). Although service requirements (TS 22.368 clause 7.2.8) are motivated by MTC, the solution may apply to normal UEs¦5/10/15: 32.278 added; / Impacted TSs and TRs: 32.278
- 4737: Dec.14: 25->85%. Mar15: 100% / Impacted TSs and TRs: New 23.789
- 4738: -¦June2015: Compl:0%->100 / Impacted TSs and TRs: 23.682; TBD
- 4739: TR 33.8xy will capture requirements, solution alternatives, evaluations and conclusions for the AESE, MONTE and GROUPE WIDs.3/3/15: 5->10%.¦June2015: Compl:10%->15¦11/12/15: 15%->100 / Impacted TSs and TRs: New 33.889
- 4740: -¦11/12/15: 0%->100 / Impacted TSs and TRs: 33.187
- 4741: 7/10/15: acronym changed from "MONTE" to "MONTE-CH"¦7/12/15: 0%->50. ES in SP-150709 (wrong UID in the ES)¦7/3/16: 25%->100 / Impacted TSs and TRs: 32.27x; 32.240; 32.299; 32.298
- 4742: 14/09/15: WID:CP-150396->CP-150422
- 4743: 07/09/15: 0%->95¦14/09/15: WID:CP-150396->CP-150422¦7/12/15: 95%->100 / Impacted TSs and TRs: 24.301; 24.008
- 4744: 07/09/15: 0%->100¦14/09/15: WID:CP-150396->CP-150422 / Impacted TSs and TRs: 29.214; 29.213; 29.201
- 4745: 61907/09/15: 0%->50¦14/09/15: WID:CP-150396->CP-150422¦7/12/15: 50%->85. FCD -> 03/16, ES in CP-150619¦7/3/16: 85%->100 / Impacted TSs and TRs: New 29.128; 29.272; 29.002; 29.336; 29.230; 23.008
- 4746: 06/15: WID: SP-140707-> SP-150249 / Impacted TSs and TRs: Stage 2
- 4747: Dec.14: 30->100%. 06/15: WID: SP-140707-> SP-150249 / Impacted TSs and TRs: New 23.707
- 4748: Mar15: 0->70%¦June2015: Compl:70%->100, WID: SP-140707-> SP-150249 / Impacted TSs and TRs: 23.060; 23.401; 23.236
- 4750: 7/12/15: 0%->100 / Impacted TSs and TRs: 24.301; 24.008
- 4751: 7/12/15: 70%->90. FCD -> 03/16, ES CP-150617¦7/3/16: 90%->100 / Impacted TSs and TRs: 29.274; 29.060; 23.003; 29.272; 29.002; 29.305; 23.008; 29.230; 29.303; 23.007
- 4752: no Perf. part¦note: DECOR is a REL-13 SA2 WI;
- 4753: no Perf. part¦note: DECOR is a REL-13 SA2 WI¦29/09/15: Compl:0%->30% 29/09/15: Stat Rep: -->RP-1512901/1/16: Compl:30%->100%
- 4754: SP#62 completion 06/14=>09/14. Linked to Rel-12 Study TR 22.888 (FS_MTCe) and to Features Rel-11 SIMTC & Rel-12 MTCe and MOSAP / Impacted TSs and TRs: Stage 1
- 4755: SP#64 completed. TR 22.853v200 for Approval. External requirements from oneM2M TR0001(oneM2M Use Case collection), TS0002 (M2M Requirements) / Impacted TSs and TRs: New 22.853
- 4756: SP#65 completed / Impacted TSs and TRs: 22.101; 22.115; 22.368; TBD

| ID | WBS | Task | Duration | Start | Finish | Complete | Remaining | Baseline start | Baseline finish | Baseline duration | Total slack | Constraint | Resources | Work | Actual work | Acronym | PCG approved | WI rapporteur name | WI rapporteur e-mail | Release | TSG approved | Acronym_3GU_Export | MCC resp | Special Focus Doc | Status Report |
| --- | --- | --- | --- | --- | --- | --- | --- | --- | --- | --- | --- | --- | --- | --- | --- | --- | --- | --- | --- | --- | --- | --- | --- | --- | --- |
| 4757 | 1826 | **Architecture Enhancements for Service capability Exposure** | 655.12d? | 2014-06-18 A | 2016-03-11 A | 100% |  | 2014-06-18 | 2015-09-16 | 326d? |  |  | S2; S3 | 16027.2h | 16027.2h | AESE | 33 | Intel | puneet.jain@intel.com | Rel-13 | 64 | AESE |  |  |  |
| 4758 | 1826.1 | TR for Architecture Enhancements for Service capability Exposure | 196d? | 2014-06-18 A | 2015-03-18 A | 100% |  | 2014-06-18 | 2015-03-18 | 196d? |  | finish no earlier than 2015-03-18 | S2 | 1568h | 1568h | AESE | 33 | Intel, Puneet Jain | puneet.jain@intel.com | Rel-13 | 64 |  |  |  |  |
| 4759 | 1826.2 | Stage 2 for Architecture Enhancements for Service capability Exposure | 261d? | 2014-06-23 A | 2015-06-17 A | 100% |  | 2014-06-18 | 2015-06-17 | 261d? |  | finish no earlier than 2015-06-17 | S2 | 2088h | 2088h | AESE | 33 | Intel, Puneet Jain | puneet.jain@intel.com | Rel-13 | 64 |  |  |  |  |
| 4760 | 1826.3 | TR on Security for Architecture Enhancements for Service capability Exposure | 241.4d? | 2014-06-23 A | 2015-06-17 A | 100% |  | 2014-06-18 | 2015-06-17 | 241.4d? |  | finish no earlier than 2015-06-17 | S3 | 1931.2h | 1931.2h | AESE | 33 | Samsung | Rajavelsamy R (rajvel@samsung.com) | Rel-13 | 64 |  |  |  |  |
| 4761 | 1826.4 | Security for Architecture Enhancements for Service capability Exposure | 326d? | 2014-06-23 A | 2015-09-16 A | 100% |  | 2014-06-18 | 2015-09-16 | 326d? |  | finish no earlier than 2015-09-16 | S3 | 2608h | 2608h | AESE | 33 | Samsung | Rajavelsamy R (rajvel@samsung.com) | Rel-13 | 64 |  |  |  |  |
| 4762 | 1826.5 | **CT aspects of Architecture Enhancements for Service capability Exposure** | 280.5d? | 2015-06-15 A | 2016-03-11 A | 100% |  |  |  |  |  |  | C3 | 4184h | 4184h | AESE-CT | 35 | Yizhuang Wu, Huawei | wuyizhuang@huawei.com | Rel-13 | 68 |  |  |  |  |
| 4763 | 1826.5.1 | CT3 aspects of Architecture Enhancements for Service capability Exposure | 195d? | 2015-06-15 A | 2016-03-11 A | 100% |  |  |  |  |  | finish no earlier than 2016-03-11 | C3 | 1560h | 1560h | AESE-CT | 35 | Yizhuang Wu, Huawei. FCD+3, ES in 642 | wuyizhuang@huawei.com | Rel-13 | 68 |  |  |  |  |
| 4764 | 1826.5.2 | CT4 aspects of Architecture Enhancements for Service capability Exposure | 133d? | 2015-06-15 A | 2015-12-16 A | 100% |  |  |  |  |  | start no earlier than 2015-06-15 | C4 | 1064h | 1064h | AESE-CT | 35 | Yizhuang Wu, Huawei | wuyizhuang@huawei.com | Rel-13 | 68 |  |  |  |  |
| 4765 | 1827 | **Rel-13 LTE Carrier Aggregation** | 1896.62d? | 2013-12-09 A | 2018-12-14 | 95% | 96.93d? | 2014-03-06 | 2015-06-12 | 332d? | 40473.9d |  | R4 | 556616h | 514647h | LTE_CA_Rel13 | 32 |  |  | Rel-13 | 62 | LTE_CA_Rel-13 | Issam | CA |  |
| 4766 | 1827.1 | **LTE Advanced 4 Band Carrier Aggregation (4DL/1UL) of Band 4, Band 4, Band 5 and Band 12** | 95.25d? | 2015-09-15 A | 2015-12-15 A | 100% |  |  |  |  |  |  | R4 | 1584h | 1584h | LTE_CA_B4_B4_B5_B12 | 35 | US Cellular |  | Rel-13 | 69 |  |  |  |  |
| 4767 | 1827.1.1 | Core part:LTE Advanced 4 Band Carrier Aggregation (4DL/1UL) of Band 4, Band 4, Band 5 and Band 12 | 66d? | 2015-09-15 A | 2015-12-15 A | 100% |  |  |  |  |  | finish no earlier than 2016-03-15 | R4 | 528h | 528h | LTE_CA_B4_B4_B5_B12-Core | 35 | US Cellular |  | Rel-13 | 69 |  |  |  |  |
| 4768 | 1827.1.2 | Perf. part:LTE Advanced 4 Band Carrier Aggregation (4DL/1UL) of Band 4, Band 4, Band 5 and Band 12 | 66d? | 2015-09-15 A | 2015-12-15 A | 100% |  |  |  |  |  | finish no earlier than 2016-03-15 | R4 | 528h | 528h | LTE_CA_B4_B4_B5_B12-Perf | 35 | US Cellular |  | Rel-13 | 69 |  |  |  |  |
| 4769 | 1827.2 | **LTE Advanced 4 Band Carrier Aggregation (4DL/1UL) of Band 2, Band 4, Band 4 and Band 5** | 95.25d? | 2015-09-15 A | 2015-12-15 A | 100% |  |  |  |  |  |  | R4 | 1584h | 1584h | LTE_CA_B2_B4_B4_B5 | 35 | US Cellular |  | Rel-13 | 69 |  |  |  |  |
| 4770 | 1827.2.1 | Core part:LTE Advanced 4 Band Carrier Aggregation (4DL/1UL) of Band 2, Band 4, Band 4 and Band 5 | 66d? | 2015-09-15 A | 2015-12-15 A | 100% |  |  |  |  |  | finish no earlier than 2016-03-15 | R4 | 528h | 528h | LTE_CA_B2_B4_B4_B5-Core | 35 | US Cellular |  | Rel-13 | 69 |  |  |  |  |
| 4771 | 1827.2.2 | Perf. part:LTE Advanced 4 Band Carrier Aggregation (4DL/1UL) of Band 2, Band 4, Band 4 and Band 5 | 66d? | 2015-09-15 A | 2015-12-15 A | 100% |  |  |  |  |  | finish no earlier than 2016-03-15 | R4 | 528h | 528h | LTE_CA_B2_B4_B4_B5-Perf | 35 | US Cellular |  | Rel-13 | 69 |  |  |  |  |
| 4772 | 1827.3 | **LTE Advanced inter-band Carrier Aggregation of Band 8 and Band 27** | 531d? | 2013-12-09 A | 2015-05-06 | 30% | 371.7d? | 2013-12-09 | 2014-12-11 | 265d? | 41839.5d |  | R4 | 12696h | 2643.08h | LTE_CA_B8_B27 | 32 | KT | ilwhan.kim@kt.com | Rel-13 | 62 | LTE_CA_B8_B27 | Issam | CA |  |
| 4773 | 1827.3.1 | Core part:LTE Advanced inter-band Carrier Aggregation of Band 8 and Band 27 | 528d? | 2013-12-09 A | 2015-05-06 | 30% | 369.6d? | 2013-12-09 | 2014-12-11 | 265d? | 41839.5d | finish no earlier than 2015-12-15 | R4 | 4224h | 1267.2h | LTE_CA_B8_B27-Core | 32 | KT | ilwhan.kim@kt.com | Rel-13 | 62 | LTE_CA_B8_B27-Core | Issam | CA | RP-151131 |
| 4774 | 1827.3.2 | Perf. part:LTE Advanced inter-band Carrier Aggregation of Band 8 and Band 27 | 528d? | 2013-12-09 A | 2015-05-06 | 30% | 369.6d? | 2013-12-09 | 2014-12-11 | 265d? | 41839.5d | finish no earlier than 2015-12-15 | R4 | 4224h | 1267.2h | LTE_CA_B8_B27-Perf | 32 | KT | ilwhan.kim@kt.com | Rel-13 | 62 | LTE_CA_B8_B27-Perf | Issam | CA | RP-151131 |
| 4775 | 1827.4 | **LTE Advanced 3 band Carrier Aggregation (3DL/1UL) for Band 3, Band 8 and Band 27** | 531d? | 2013-12-09 A | 2015-05-06 | 25% | 398.25d? | 2013-12-09 | 2014-12-05 | 261d? | 41839.5d |  | R4 | 12696h | 2384h | LTE_CA_B3_B8_B27 | 32 | KT | Chungwoo HWANG (cwhwang@kt.com) | Rel-13 | 62 | LTE_CA_B3_B8_B27 | Issam | CA |  |
| 4776 | 1827.4.1 | Core part:LTE Advanced 3 band Carrier Aggregation (3DL/1UL) for Band 3, Band 8 and Band 27 | 528d? | 2013-12-09 A | 2015-05-06 | 25% | 396d? | 2013-12-09 | 2014-12-05 | 261d? | 41839.5d | finish no earlier than 2015-12-15 | R4 | 4224h | 1056h | LTE_CA_B3_B8_B27-Core | 32 | KT | Chungwoo HWANG (cwhwang@kt.com) | Rel-13 | 62 | LTE_CA_B3_B8_B27-Core | Issam | CA | RP-151131 |
| 4777 | 1827.4.2 | Perf. part:LTE Advanced 3 band Carrier Aggregation (3DL/1UL) for Band 3, Band 8 and Band 27 | 528d? | 2013-12-09 A | 2015-05-06 | 25% | 396d? | 2013-12-09 | 2014-12-05 | 261d? | 41839.5d | finish no earlier than 2015-12-15 | R4 | 4224h | 1056h | LTE_CA_B3_B8_B27-Perf | 32 | KT | Chungwoo HWANG (cwhwang@kt.com) | Rel-13 | 62 | LTE_CA_B3_B8_B27-Perf | Issam | CA | RP-151131 |
| 4778 | 1827.5 | **LTE Advanced inter-band Carrier Aggregation of Band 7 and Band 22** | 483.38d? | 2014-03-06 A | 2015-06-15 A | 100% |  | 2014-03-06 | 2014-12-05 | 197d? |  |  | R4 | 8016h | 8016h | LTE_CA_B7_B22 | 32 | Orange, Ericsson | erika.tejedor@ericsson.com | Rel-13 | 63 | LTE_CA_B7_B22 | Issam | CA |  |
| 4779 | 1827.5.1 | Core part:LTE Advanced inter-band Carrier Aggregation of Band 7 and Band 22 | 333d? | 2014-03-06 A | 2015-06-15 A | 100% |  | 2014-03-06 | 2014-12-05 | 197d? |  | finish no earlier than 2015-06-15 | R4 | 2664h | 2664h | LTE_CA_B7_B22-Core | 32 | Orange, Ericsson | erika.tejedor@ericsson.com | Rel-13 | 63 | LTE_CA_B7_B22-Core | Issam | CA | RP-150536 |
| 4780 | 1827.5.2 | Perf. part:LTE Advanced inter-band Carrier Aggregation of Band 7 and Band 22 | 333d? | 2014-03-11 A | 2015-06-15 A | 100% |  | 2014-03-06 | 2014-12-05 | 197d? |  | finish no earlier than 2015-06-15 | R4 | 2664h | 2664h | LTE_CA_B7_B22-Perf | 32 | Orange, Ericsson | erika.tejedor@ericsson.com | Rel-13 | 63 | LTE_CA_B7_B22-Perf | Issam | CA | RP-150536 |

Notes:
- 4757: - / Impacted TSs and TRs: Stage 2
- 4758: Dec.14: 30->65%. Mar15: 75%¦June2015: Compl:75%->100 / Impacted TSs and TRs: New 23.708
- 4759: -¦June2015: Compl:0%->100 / Impacted TSs and TRs: 23.682; 33.187
- 4760: TR 33.8xy will capture requirements, solution alternatives, evaluations and conclusions for the AESE, MONTE and GROUPE WIDs. Dec.14: 0->40%. 3/3/15: 45%.¦June2015: Compl:45%->60¦11/12/15: 60%->100 / Impacted TSs and TRs: New 33.889
- 4761: -¦11/12/15: 0%->100 / Impacted TSs and TRs: 33.187
- 4762: 14/09/15: WID:CP-150402->CP-150487->CP-150576
- 4763: 07/09/15: 0%->35¦14/09/15: WID:CP-150402->CP-150487->CP-150576¦7/12/15: 35%->90¦7/3/16: 90%->100 / Impacted TSs and TRs: 29.154
- 4764: 07/09/15: 0%->40¦14/09/15: WID:CP-150402->CP-150487->CP-150576¦7/12/15: 40%->100 / Impacted TSs and TRs: 29.201; 29.336; 29.230; 29.272; 23.008
- 4765: Acronym changed from "LTE_CA_Rel-13" to "LTE_CA_Rel13"
- 4766: 13/6/16: moved from Rel-14 to Rel-13 (was a mistake)
- 4767: 13/6/16: moved from Rel-14 to Rel-13 (was a mistake)
- 4768: 13/6/16: moved from Rel-14 to Rel-13 (was a mistake)
- 4769: 13/6/16: moved from Rel-14 to Rel-13 (was a mistake)
- 4770: 13/6/16: moved from Rel-14 to Rel-13 (was a mistake)
- 4771: 13/6/16: moved from Rel-14 to Rel-13 (was a mistake)
- 4772: Inter-band CA 2DL/1UL / Impacted TSs and TRs: LTE
- 4773: CD:Thu 18/06/15->Mon 15/06/15¦Compl:10%->10%¦Stat Rep: RP-141084->RP-141732 1st Apr 15: Compl:10%->15% 1st Apr 15: Stat Rep: RP-141732->RP-150013 03/07/15: Compl:15%->30% 03/07/15: CD:Mon 15/06/15->Tue 15/12/15 03/07/15: Stat Rep: RP-150013->RP-15053 / Impacted TSs and TRs: 36.101; 36.104; 36.133; generic 36.851
- 4774: CD:Thu 18/06/15->Mon 15/06/15¦Compl:10%->10%¦Stat Rep: RP-141084->RP-141732 1st Apr 15: Compl:10%->15% 1st Apr 15: Stat Rep: RP-141732->RP-150013 03/07/15: Compl:15%->30% 03/07/15: CD:Mon 15/06/15->Tue 15/12/15 03/07/15: Stat Rep: RP-150013->RP-15053 / Impacted TSs and TRs: 36.141; 36.307
- 4775: Inter-band CA 3DL / Impacted TSs and TRs: LTE
- 4776: CD:Thu 18/06/15->Mon 15/06/15¦Compl:25%->25%¦Stat Rep: RP-141084->RP-141732 1st Apr 15: Compl:25%->30% 1st Apr 15: Stat Rep: RP-141732->RP-150013 03/07/15: Compl:30%->25% 03/07/15: CD:Mon 15/06/15->Tue 15/12/15 03/07/15: Stat Rep: RP-150013->RP-15053 / Impacted TSs and TRs: 36.101; 36.104; 36.133; 36.141; 36.307; new generic 36.853 (3 Band CA with 1UL)
- 4777: CD:Thu 18/06/15->Mon 15/06/15¦Compl:25%->25%¦Stat Rep: RP-141084->RP-141732 1st Apr 15: Compl:25%->30% 1st Apr 15: Stat Rep: RP-141732->RP-150013 03/07/15: Compl:30%->25% 03/07/15: CD:Mon 15/06/15->Tue 15/12/15 03/07/15: Stat Rep: RP-150013->RP-15053 / Impacted TSs and TRs: 36.101; 36.104; 36.133; 36.141; 36.307
- 4778: Inter-band CA 2DL / Impacted TSs and TRs: LTE
- 4779: CD:Thu 11/12/14->Mon 15/06/15¦Compl:10%->10%¦Stat Rep: RP-141084->RP-141732 03/07/15: Compl:10%->100% 03/07/15: Stat Rep: RP-141732->RP-150536 / Impacted TSs and TRs: 36.101; 36.104; 36.133; generic 36.851 (2 Band CA with 1UL).
- 4780: CD:Thu 11/12/14->Mon 15/06/15¦Compl:0%->0%¦Stat Rep: RP-141084->RP-141732 03/07/15: Compl:0%->100% 03/07/15: Stat Rep: RP-141732->RP-150536 / Impacted TSs and TRs: 36.141; 36.307

| ID | WBS | Task | Duration | Start | Finish | Complete | Baseline start | Baseline finish | Baseline duration | Constraint | Resources | Work | Actual work | Acronym | PCG approved | WI rapporteur name | WI rapporteur e-mail | Release | TSG approved | Special Focus Doc | Acronym_3GU_Export | Status Report |
| --- | --- | --- | --- | --- | --- | --- | --- | --- | --- | --- | --- | --- | --- | --- | --- | --- | --- | --- | --- | --- | --- | --- |
| 4781 | 1827.6 | **LTE Advanced 3 Band Carrier Aggregation (3DL/1UL) for Band 2, Band 2 and Band 12** | 375.62d? | 2014-06-18 A | 2015-06-15 A | 100% | 2014-06-13 | 2015-03-13 | 196d? |  | R4 | 6288h | 6288h | LTE_CA_B2_B2_B12 | 33 | U.S. Cellular | sebastian.thalanany@uscellular.com | Rel-13 | 64 | CA | LTE_CA_B2_B2_B12 |  |
| 4782 | 1827.6.1 | Core part:LTE Advanced 3 Band Carrier Aggregation (3DL/1UL) for Band 2, Band 2 and Band 12 | 262d? | 2014-06-18 A | 2015-06-15 A | 100% | 2014-06-13 | 2014-12-05 | 126d? | finish no earlier than 2015-06-15 | R4 | 2096h | 2096h | LTE_CA_B2_B2_B12-Core | 33 | U.S. Cellular | sebastian.thalanany@uscellular.com | Rel-13 | 64 | CA | LTE_CA_B2_B2_B12-Core | RP-150536 |
| 4783 | 1827.6.2 | Perf. Part:LTE Advanced 3 Band Carrier Aggregation (3DL/1UL) for Band 2, Band 2 and Band 12 | 262d? | 2014-06-18 A | 2015-06-15 A | 100% | 2014-06-13 | 2015-03-13 | 196d? | finish no earlier than 2015-06-15 | R4 | 2096h | 2096h | LTE_CA_B2_B2_B12-Perf | 33 | U.S. Cellular | sebastian.thalanany@uscellular.com | Rel-13 | 64 | CA | LTE_CA_B2_B2_B12-Perf | RP-150536 |
| 4784 | 1827.7 | **LTE Advanced 3 Band Carrier Aggregation (3DL/1UL) of Band 3, Band 3 and Band 8** | 377.62d? | 2014-06-16 A | 2015-06-15 A | 100% | 2014-06-13 | 2015-06-12 | 261d? |  | R4 | 6304h | 6304h | LTE_CA_B3_B3_B8 | 33 | CHTTL | Po-Han Hsieh (pohanhsieh@cht.com.tw) | Rel-13 | 64 | CA | LTE_CA_B3_B3_B8 |  |
| 4785 | 1827.7.1 | Core part:LTE Advanced 3 Band Carrier Aggregation (3DL/1UL) of Band 3, Band 3 and Band 8 | 262d? | 2014-06-16 A | 2015-06-15 A | 100% | 2014-06-13 | 2015-06-12 | 261d? | finish no earlier than 2015-06-15 | R4 | 2096h | 2096h | LTE_CA_B3_B3_B8-Core | 33 | CHTTL | Po-Han Hsieh (pohanhsieh@cht.com.tw) | Rel-13 | 64 | CA | LTE_CA_B3_B3_B8-Core | RP-150536 |
| 4786 | 1827.7.2 | Perf. Part:LTE Advanced 3 Band Carrier Aggregation (3DL/1UL) of Band 3, Band 3 and Band 8 | 262d? | 2014-06-18 A | 2015-06-15 A | 100% | 2014-06-13 | 2015-06-12 | 261d? | finish no earlier than 2015-06-15 | R4 | 2096h | 2096h | LTE_CA_B3_B3_B8-Perf | 33 | CHTTL | Po-Han Hsieh (pohanhsieh@cht.com.tw) | Rel-13 | 64 | CA | LTE_CA_B3_B3_B8-Perf | RP-150536 |
| 4787 | 1827.8 | **LTE Advanced 3 Band Carrier Aggregation (3DL/1UL) of Band 41, Band 42 and Band 42** | 377.62d? | 2014-06-16 A | 2015-06-15 A | 100% | 2014-06-13 | 2014-12-05 | 126d? |  | R4 | 6304h | 6304h | LTE_CA_B41_B42_B42 | 33 | Huawei | leo.liuye@huawei.com | Rel-13 | 64 | CA | LTE_CA_B41_B42_B42 |  |
| 4788 | 1827.8.1 | Core part:LTE Advanced 3 Band Carrier Aggregation (3DL/1UL) of Band 41, Band 42 and Band 42 | 262d? | 2014-06-16 A | 2015-06-15 A | 100% | 2014-06-13 | 2014-12-05 | 126d? | finish no earlier than 2015-06-15 | R4 | 2096h | 2096h | LTE_CA_B41_B42_B42-Core | 33 | Huawei | leo.liuye@huawei.com | Rel-13 | 64 | CA | LTE_CA_B41_B42_B42-Core | RP-150536 |
| 4789 | 1827.8.2 | Perf. Part:LTE Advanced 3 Band Carrier Aggregation (3DL/1UL) of Band 41, Band 42 and Band 42 | 262d? | 2014-06-18 A | 2015-06-15 A | 100% | 2014-06-13 | 2014-12-05 | 126d? | finish no earlier than 2015-06-15 | R4 | 2096h | 2096h | LTE_CA_B41_B42_B42-Perf | 33 | Huawei | leo.liuye@huawei.com | Rel-13 | 64 | CA | LTE_CA_B41_B42_B42-Perf | RP-150536 |
| 4790 | 1827.9 | **LTE Advanced inter-band Carrier Aggregation of Band 3 and Band 38** | 283.5d? | 2014-09-15 A | 2015-06-15 A | 100% | 2014-06-13 | 2015-03-13 | 196d? |  | R4 | 4752h | 4752h | LTE_CA_B3_B38 | 33 | Nokia Networks | iwajlo.angelow@nsn.com | Rel-13 | 65 | CA | LTE_CA_B3_B38 |  |
| 4791 | 1827.9.1 | Core part:LTE Advanced inter-band Carrier Aggregation of Band 3 and Band 38 | 198d? | 2014-09-15 A | 2015-06-15 A | 100% | 2014-06-13 | 2015-03-13 | 196d? | finish no earlier than 2015-06-15 | R4 | 1584h | 1584h | LTE_CA_B3_B38-Core | 33 | Nokia Networks | iwajlo.angelow@nsn.com | Rel-13 | 65 | CA | LTE_CA_B3_B38-Core | RP-150536 |
| 4792 | 1827.9.2 | Perf. Part:LTE Advanced inter-band Carrier Aggregation of Band 3 and Band 38 | 198d? | 2014-09-15 A | 2015-06-15 A | 100% | 2014-06-13 | 2015-03-13 | 196d? | finish no earlier than 2015-06-15 | R4 | 1584h | 1584h | LTE_CA_B3_B38-Perf | 33 | Nokia Networks | iwajlo.angelow@nsn.com | Rel-13 | 65 | CA | LTE_CA_B3_B38-Perf | RP-150536 |
| 4793 | 1827.10 | **LTE Advanced inter-band Carrier Aggregation of Band 2 and Band 28** | 283.5d? | 2014-09-15 A | 2015-06-15 A | 100% | 2014-06-13 | 2015-03-13 | 196d? |  | R4 | 4752h | 4752h | LTE_CA_B2_B28 | 33 | Huawei | alf.ahlstrom@huawei.com | Rel-13 | 65 | CA | LTE_CA_B2_B28 |  |
| 4794 | 1827.10.1 | Core part:LTE Advanced inter-band Carrier Aggregation of Band 2 and Band 28 | 198d? | 2014-09-15 A | 2015-06-15 A | 100% | 2014-06-13 | 2015-03-13 | 196d? | finish no earlier than 2015-06-15 | R4 | 1584h | 1584h | LTE_CA_B2_B28-Core | 33 | Huawei | alf.ahlstrom@huawei.com | Rel-13 | 65 | CA | LTE_CA_B2_B28-Core | RP-150536 |
| 4795 | 1827.10.2 | Perf. Part:LTE Advanced inter-band Carrier Aggregation of Band 2 and Band 28 | 198d? | 2014-09-15 A | 2015-06-15 A | 100% | 2014-06-13 | 2015-03-13 | 196d? | finish no earlier than 2015-06-15 | R4 | 1584h | 1584h | LTE_CA_B2_B28-Perf | 33 | Huawei | alf.ahlstrom@huawei.com | Rel-13 | 65 | CA | LTE_CA_B2_B28-Perf | RP-150536 |
| 4796 | 1827.11 | **LTE Advanced inter-band Carrier Aggregation of Band 4 and Band 28** | 283.5d? | 2014-09-15 A | 2015-06-15 A | 100% | 2014-06-13 | 2015-03-13 | 196d? |  | R4 | 4752h | 4752h | LTE_CA_B4_B28 | 33 | Huawei | alf.ahlstrom@huawei.com | Rel-13 | 65 | CA | LTE_CA_B4_B28 |  |
| 4797 | 1827.11.1 | Core part:LTE Advanced inter-band Carrier Aggregation of Band 4 and Band 28 | 198d? | 2014-09-15 A | 2015-06-15 A | 100% | 2014-06-13 | 2015-03-13 | 196d? | finish no earlier than 2015-06-15 | R4 | 1584h | 1584h | LTE_CA_B4_B28-Core | 33 | Huawei | alf.ahlstrom@huawei.com | Rel-13 | 65 | CA | LTE_CA_B4_B28-Core | RP-150536 |
| 4798 | 1827.11.2 | Perf. Part:LTE Advanced inter-band Carrier Aggregation of Band 4 and Band 28 | 198d? | 2014-09-15 A | 2015-06-15 A | 100% | 2014-06-13 | 2015-03-13 | 196d? | finish no earlier than 2015-06-15 | R4 | 1584h | 1584h | LTE_CA_B4_B28-Perf | 33 | Huawei | alf.ahlstrom@huawei.com | Rel-13 | 65 | CA | LTE_CA_B4_B28-Perf | RP-150536 |
| 4799 | 1827.12 | **LTE Advanced inter-band Carrier Aggregation of Band 20 and Band 40** | 476.25d? | 2014-09-12 A | 2015-12-15 A | 100% | 2014-06-13 | 2015-03-13 | 196d? |  | R4 | 7912h | 7912h | LTE_CA_B20_B40 | 33 | Ericsson | imadur.rahman@ericsson.com | Rel-13 | 65 | CA | LTE_CA_B20_B40 |  |
| 4800 | 1827.12.1 | Core part:LTE Advanced inter-band Carrier Aggregation of Band 20 and Band 40 | 330d? | 2014-09-12 A | 2015-12-15 A | 100% | 2014-06-13 | 2015-03-13 | 196d? | finish no earlier than 2015-12-15 | R4 | 2640h | 2640h | LTE_CA_B20_B40-Core | 33 | Ericsson | imadur.rahman@ericsson.com | Rel-13 | 65 | CA | LTE_CA_B20_B40-Core | RP-151131 |
| 4801 | 1827.12.2 | Perf. Part:LTE Advanced inter-band Carrier Aggregation of Band 20 and Band 40 | 329d? | 2014-09-15 A | 2015-12-15 A | 100% | 2014-06-13 | 2015-03-13 | 196d? | finish no earlier than 2015-12-15 | R4 | 2632h | 2632h | LTE_CA_B20_B40-Perf | 33 | Ericsson | imadur.rahman@ericsson.com | Rel-13 | 65 | CA | LTE_CA_B20_B40-Perf | RP-151131 |
| 4802 | 1827.13 | **LTE Advanced inter-band Carrier Aggregation of Band 1 and Band 40** | 473d? | 2014-09-15 A | 2015-12-15 A | 100% | 2014-06-13 | 2015-03-13 | 196d? |  | R4 | 7896h | 7896h | LTE_CA_B1_B40 | 33 | KT | ilwhan.kim@kt.com | Rel-13 | 65 | CA | LTE_CA_B1_B40 |  |
| 4803 | 1827.13.1 | Core part:LTE Advanced inter-band Carrier Aggregation of Band 1 and Band 40 | 329d? | 2014-09-15 A | 2015-12-15 A | 100% | 2014-06-13 | 2015-03-13 | 196d? | finish no earlier than 2015-12-15 | R4 | 2632h | 2632h | LTE_CA_B1_B40-Core | 33 | KT | ilwhan.kim@kt.com | Rel-13 | 65 | CA | LTE_CA_B1_B40-Core | RP-151131 |
| 4804 | 1827.13.2 | Perf. Part:LTE Advanced inter-band Carrier Aggregation of Band 1 and Band 40 | 329d? | 2014-09-15 A | 2015-12-15 A | 100% | 2014-06-13 | 2015-03-13 | 196d? | finish no earlier than 2015-12-15 | R4 | 2632h | 2632h | LTE_CA_B1_B40-Perf | 33 | KT | ilwhan.kim@kt.com | Rel-13 | 65 | CA | LTE_CA_B1_B40-Perf | RP-151131 |

Notes:
- 4781: Inter-band CA 3DL/1UL / Impacted TSs and TRs: LTE
- 4782: CD:Thu 12/03/15->Sun 15/03/15¦Compl:0%->40%¦Stat Rep: RP-141084->RP-141732 1st Apr 15: Compl:40%->99% 1st Apr 15: CD:Sun 15/03/15->Mon 15/06/15 1st Apr 15: Stat Rep: RP-141732->RP-150013 03/07/15: Compl:99%->100% 03/07/15: Stat Rep: RP-150013->RP-150536 / Impacted TSs and TRs: 36.101; 36.104; 36.133; 36.141; 36.307; generic new Rel-13 TR36.8xy [similar to Rel-12 36.853 (3 Band CA with 1UL)]
- 4783: CD:Thu 18/06/15->Mon 15/06/15¦Compl:0%->10%¦Stat Rep: RP-141084->RP-141732 1st Apr 15: Compl:10%->99% 1st Apr 15: Stat Rep: RP-141732->RP-150013 03/07/15: Compl:99%->100% 03/07/15: Stat Rep: RP-150013->RP-150536 / Impacted TSs and TRs: 36.101; 36.104; 36.133; 36.141; 36.307
- 4784: Inter-band CA 3DL/1UL / Impacted TSs and TRs: LTE
- 4785: ¦WID: RP-142043->RP-141832¦Stat Rep: RP-141084->RP-141732 1st Apr 15: Compl:60%->99% 1st Apr 15: Stat Rep: RP-141732->RP-150013 03/07/15: Compl:99%->100% 03/07/15: WID: RP-141832->RP-150874 03/07/15: Stat Rep: RP-150013->RP-150536 / Impacted TSs and TRs: 36.101; 36.133; generic 36.853 (3 Band CA with 1UL)
- 4786: ¦WID: RP-142043->RP-141832¦Stat Rep: RP-141084->RP-141732 1st Apr 15: Compl:0%->99% 1st Apr 15: Stat Rep: RP-141732->RP-150013 03/07/15: Compl:99%->100% 03/07/15: WID: RP-141832->RP-150874 03/07/15: Stat Rep: RP-150013->RP-150536 / Impacted TSs and TRs: 36.307
- 4787: Inter-band CA 3DL/1UL / Impacted TSs and TRs: LTE
- 4788: CD:Thu 11/12/14->Sun 15/03/15¦Compl:30%->50%¦Stat Rep: RP-141084->RP-141732 1st Apr 15: Compl:50%->60% 1st Apr 15: CD:Sun 15/03/15->Mon 15/06/15 1st Apr 15: Stat Rep: RP-141732->RP-150013 03/07/15: Compl:60%->100% 03/07/15: Stat Rep: RP-150013->RP-15 / Impacted TSs and TRs: 36.101; 36.104; 36.133; generic 36.853 (3 Band CA with 1UL)
- 4789: CD:Thu 11/12/14->Sun 15/03/15¦Compl:0%->0%¦Stat Rep: RP-141084->RP-141732 1st Apr 15: Compl:0%->60% 1st Apr 15: CD:Sun 15/03/15->Mon 15/06/15 1st Apr 15: Stat Rep: RP-141732->RP-150013 03/07/15: Compl:60%->100% 03/07/15: Stat Rep: RP-150013->RP-150536 / Impacted TSs and TRs: 36.141; 36.307
- 4790: Inter-band CA 2DL/1UL / Impacted TSs and TRs: LTE
- 4791: CD:Thu 11/12/14->Sun 15/03/15¦Compl:0%->90%¦Stat Rep: -->RP-141732 1st Apr 15: CD:Sun 15/03/15->Mon 15/06/15 1st Apr 15: Stat Rep: RP-141732->RP-150013 03/07/15: Compl:90%->100% 03/07/15: WID: RP-141129->RP-150717 03/07/15: Stat Rep: RP-150013->RP-15 / Impacted TSs and TRs: 36.101; 36.104; New 36.8xx
- 4792: CD:Thu 11/12/14->Sun 15/03/15¦Compl:0%->90%¦Stat Rep: -->RP-141732 1st Apr 15: CD:Sun 15/03/15->Mon 15/06/15 1st Apr 15: Stat Rep: RP-141732->RP-150013 03/07/15: Compl:90%->100% 03/07/15: WID: RP-141129->RP-150717 03/07/15: Stat Rep: RP-150013->RP-15 / Impacted TSs and TRs: 36.141; 36.307
- 4793: Inter-band CA 2DL/1UL / Impacted TSs and TRs: LTE
- 4794: CD:Fri 11/12/15->Sun 15/03/15¦Compl:0%->50%¦Stat Rep: -->RP-141732 1st Apr 15: Compl:50%->99% 1st Apr 15: CD:Sun 15/03/15->Mon 15/06/15 1st Apr 15: Stat Rep: RP-141732->RP-150013 03/07/15: Compl:99%->100% 03/07/15: Stat Rep: RP-150013->RP-150536 / Impacted TSs and TRs: 36.101; 36.104; New 36.8xx
- 4795: CD:Thu 12/03/15->Sun 15/03/15¦Compl:0%->0%¦Stat Rep: -->RP-141732 1st Apr 15: Compl:0%->99% 1st Apr 15: CD:Sun 15/03/15->Mon 15/06/15 1st Apr 15: Stat Rep: RP-141732->RP-150013 03/07/15: Compl:99%->100% 03/07/15: Stat Rep: RP-150013->RP-150536 / Impacted TSs and TRs: 36.141; 36.307
- 4796: Inter-band CA 2DL/1UL / Impacted TSs and TRs: LTE
- 4797: CD:Fri 11/12/15->Sun 15/03/15¦Compl:0%->35%¦Stat Rep: -->RP-141732 1st Apr 15: Compl:35%->99% 1st Apr 15: CD:Sun 15/03/15->Mon 15/06/15 1st Apr 15: Stat Rep: RP-141732->RP-150013 03/07/15: Compl:99%->100% 03/07/15: Stat Rep: RP-150013->RP-150536 / Impacted TSs and TRs: 36.101; 36.104; New 36.8xx
- 4798: CD:Thu 12/03/15->Sun 15/03/15¦Compl:0%->0%¦Stat Rep: -->RP-141732 1st Apr 15: Compl:0%->99% 1st Apr 15: CD:Sun 15/03/15->Mon 15/06/15 1st Apr 15: Stat Rep: RP-141732->RP-150013 03/07/15: Compl:99%->100% 03/07/15: Stat Rep: RP-150013->RP-150536 / Impacted TSs and TRs: 36.141; 36.307
- 4799: Inter-band CA 2DL/1UL / Impacted TSs and TRs: LTE
- 4800: CD:Wed 11/03/15->Sun 15/03/15¦Compl:0%->30%¦Stat Rep: -->RP-141732 1st Apr 15: Compl:30%->70% 1st Apr 15: CD:Sun 15/03/15->Mon 15/06/15 1st Apr 15: Stat Rep: RP-141732->RP-150013 03/07/15: CD:Mon 15/06/15->Tue 15/09/15 03/07/15: Stat Rep: RP-150013-> / Impacted TSs and TRs: 36.101; 36.104; 36.133; New 36.8xx
- 4801: CD:Thu 12/03/15->Sun 15/03/15¦Compl:0%->0%¦Stat Rep: -->RP-141732 1st Apr 15: CD:Sun 15/03/15->Mon 15/06/15 1st Apr 15: Stat Rep: RP-141732->RP-150013 03/07/15: Compl:0%->70% 03/07/15: CD:Mon 15/06/15->Tue 15/09/15 03/07/15: Stat Rep: RP-150013->RP-1 / Impacted TSs and TRs: 36.141; 36.307
- 4802: Inter-band CA 2DL/1UL / Impacted TSs and TRs: LTE
- 4803: CD:Fri 12/06/15->Mon 15/06/15¦Compl:0%->70%¦Stat Rep: -->RP-141732 1st Apr 15: Compl:70%->80% 1st Apr 15: Stat Rep: RP-141732->RP-150013 03/07/15: Compl:80%->70% 03/07/15: CD:Mon 15/06/15->Tue 15/12/15 03/07/15: Stat Rep: RP-150013->RP-150536 29/09/1 / Impacted TSs and TRs: 36.101; 36.104; 36.133; New 36.8xx
- 4804: CD:Fri 11/12/15->Mon 15/06/15¦Compl:0%->70%¦Stat Rep: -->RP-141732 1st Apr 15: Compl:70%->80% 1st Apr 15: Stat Rep: RP-141732->RP-150013 03/07/15: Compl:80%->70% 03/07/15: CD:Mon 15/06/15->Tue 15/12/15 03/07/15: Stat Rep: RP-150013->RP-150536 29/09/1 / Impacted TSs and TRs: 36.141; 36.307

| ID | WBS | Task | Duration | Start | Finish | Complete | Baseline start | Baseline finish | Baseline duration | Constraint | Resources | Work | Actual work | Acronym | PCG approved | WI rapporteur name | WI rapporteur e-mail | Release | TSG approved | Special Focus Doc | Acronym_3GU_Export | Status Report |
| --- | --- | --- | --- | --- | --- | --- | --- | --- | --- | --- | --- | --- | --- | --- | --- | --- | --- | --- | --- | --- | --- | --- |
| 4805 | 1827.14 | **LTE Advanced inter-band Carrier Aggregation of Band 3 and Band 40** | 283.5d? | 2014-09-15 A | 2015-06-15 A | 100% | 2014-06-13 | 2015-03-13 | 196d? |  | R4 | 4752h | 4752h | LTE_CA_B3_B40 | 33 | KT | Chungwoo HWANG (cwhwang@kt.com) | Rel-13 | 65 | CA | LTE_CA_B3_B40 |  |
| 4806 | 1827.14.1 | Core part:LTE Advanced inter-band Carrier Aggregation of Band 3 and Band 40 | 198d? | 2014-09-15 A | 2015-06-15 A | 100% | 2014-06-13 | 2015-03-13 | 196d? | finish no earlier than 2015-06-15 | R4 | 1584h | 1584h | LTE_CA_B3_B40-Core | 33 | KT | Chungwoo HWANG (cwhwang@kt.com) | Rel-13 | 65 | CA | LTE_CA_B3_B40-Core | RP-150536 |
| 4807 | 1827.14.2 | Perf. Part:LTE Advanced inter-band Carrier Aggregation of Band 3 and Band 40 | 198d? | 2014-09-15 A | 2015-06-15 A | 100% | 2014-06-13 | 2015-03-13 | 196d? | finish no earlier than 2015-06-15 | R4 | 1584h | 1584h | LTE_CA_B3_B40-Perf | 33 | KT | Chungwoo HWANG (cwhwang@kt.com) | Rel-13 | 65 | CA | LTE_CA_B3_B40-Perf | RP-150536 |
| 4808 | 1827.15 | **LTE Advanced inter-band Carrier Aggregation of Band 20 and Band 31** | 283.5d? | 2014-09-15 A | 2015-06-15 A | 100% | 2014-06-13 | 2015-03-13 | 196d? |  | R4 | 4752h | 4752h | LTE_CA_B20_B31 | 33 | Huawei | Liu Liehai (liuliehai@huawei.com) | Rel-13 | 65 | CA | LTE_CA_B20_B31 |  |
| 4809 | 1827.15.1 | Core part:LTE Advanced inter-band Carrier Aggregation of Band 20 and Band 31 | 198d? | 2014-09-15 A | 2015-06-15 A | 100% | 2014-06-13 | 2015-03-13 | 196d? | finish no earlier than 2015-06-15 | R4 | 1584h | 1584h | LTE_CA_B20_B31-Core | 33 | Huawei | Liu Liehai (liuliehai@huawei.com) | Rel-13 | 65 | CA | LTE_CA_B20_B31-Core | RP-150536 |
| 4810 | 1827.15.2 | Perf. Part:LTE Advanced inter-band Carrier Aggregation of Band 20 and Band 31 | 198d? | 2014-09-15 A | 2015-06-15 A | 100% | 2014-06-13 | 2015-03-13 | 196d? | finish no earlier than 2015-06-15 | R4 | 1584h | 1584h | LTE_CA_B20_B31-Perf | 33 | Huawei | Liu Liehai (liuliehai@huawei.com) | Rel-13 | 65 | CA | LTE_CA_B20_B31-Perf | RP-150536 |
| 4811 | 1827.16 | **LTE Advanced inter-band Carrier Aggregation of Band 3 and Band 31** | 283.5d? | 2014-09-15 A | 2015-06-15 A | 100% | 2014-06-13 | 2015-03-13 | 196d? |  | R4 | 4752h | 4752h | LTE_CA_B3_B31 | 33 | Huawei | Liu Liehai (liuliehai@huawei.com) | Rel-13 | 65 | CA | LTE_CA_B3_B31 |  |
| 4812 | 1827.16.1 | Core part:LTE Advanced inter-band Carrier Aggregation of Band 3 and Band 31 | 198d? | 2014-09-15 A | 2015-06-15 A | 100% | 2014-06-13 | 2015-03-13 | 196d? | finish no earlier than 2015-06-15 | R4 | 1584h | 1584h | LTE_CA_B3_B31-Core | 33 | Huawei | Liu Liehai (liuliehai@huawei.com) | Rel-13 | 65 | CA | LTE_CA_B3_B31-Core | RP-150536 |
| 4813 | 1827.16.2 | Perf. Part:LTE Advanced inter-band Carrier Aggregation of Band 3 and Band 31 | 198d? | 2014-09-15 A | 2015-06-15 A | 100% | 2014-06-13 | 2015-03-13 | 196d? | finish no earlier than 2015-06-15 | R4 | 1584h | 1584h | LTE_CA_B3_B31-Perf | 33 | Huawei | Liu Liehai (liuliehai@huawei.com) | Rel-13 | 65 | CA | LTE_CA_B3_B31-Perf | RP-150536 |
| 4814 | 1827.17 | **LTE Advanced inter-band Carrier Aggregation of Band 5 and Band 40** | 286.75d? | 2014-09-12 A | 2015-06-15 A | 100% | 2014-06-13 | 2015-03-13 | 196d? |  | R4 | 4768h | 4768h | LTE_CA_B5_B40 | 33 | SK Telecom | haesung.park@sk.com | Rel-13 | 65 | CA | LTE_CA_B5_B40 |  |
| 4815 | 1827.17.1 | Core part:LTE Advanced inter-band Carrier Aggregation of Band 5 and Band 40 | 199d? | 2014-09-12 A | 2015-06-15 A | 100% | 2014-06-13 | 2015-03-13 | 196d? | finish no earlier than 2015-06-15 | R4 | 1592h | 1592h | LTE_CA_B5_B40-Core | 33 | SK Telecom | haesung.park@sk.com | Rel-13 | 65 | CA | LTE_CA_B5_B40-Core | RP-150536 |
| 4816 | 1827.17.2 | Perf. Part:LTE Advanced inter-band Carrier Aggregation of Band 5 and Band 40 | 198d? | 2014-09-15 A | 2015-06-15 A | 100% | 2014-06-13 | 2015-03-13 | 196d? | finish no earlier than 2015-06-15 | R4 | 1584h | 1584h | LTE_CA_B5_B40-Perf | 33 | SK Telecom | haesung.park@sk.com | Rel-13 | 65 | CA | LTE_CA_B5_B40-Perf | RP-150536 |
| 4817 | 1827.18 | **LTE Advanced intra-band contiguous Carrier Aggregation in Band 42 for 3DL** | 283.5d? | 2014-09-15 A | 2015-06-15 A | 100% | 2014-06-13 | 2015-03-13 | 196d? |  | R4 | 4752h | 4752h | LTE_CA_C_B42_3DL | 33 | CATT | Yuexia Song (songyuexia@catt.cn) | Rel-13 | 65 | CA | LTE_CA_C_B42_3DL |  |
| 4818 | 1827.18.1 | Core part: LTE Advanced intra-band contiguous Carrier Aggregation in Band 42 for 3DL | 198d? | 2014-09-15 A | 2015-06-15 A | 100% | 2014-06-13 | 2015-03-13 | 196d? | finish no earlier than 2015-06-15 | R4 | 1584h | 1584h | LTE_CA_C_B42_3DL-Core | 33 | CATT | Yuexia Song (songyuexia@catt.cn) | Rel-13 | 65 | CA | LTE_CA_C_B42_3DL-Core | RP-150536 |
| 4819 | 1827.18.2 | Perf. Part: LTE Advanced intra-band contiguous Carrier Aggregation in Band 42 for 3DL | 198d? | 2014-09-15 A | 2015-06-15 A | 100% | 2014-06-13 | 2015-03-13 | 196d? | finish no earlier than 2015-06-15 | R4 | 1584h | 1584h | LTE_CA_C_B42_3DL-Perf | 33 | CATT | Yuexia Song (songyuexia@catt.cn) | Rel-13 | 65 | CA | LTE_CA_C_B42_3DL-Perf | RP-150536 |
| 4820 | 1827.19 | **LTE Advanced 3 Band Carrier Aggregation (3DL/1UL) of Band 8, Band 41 and Band 41** | 286.75d? | 2014-09-12 A | 2015-06-15 A | 100% | 2014-06-13 | 2015-03-13 | 196d? |  | R4 | 4768h | 4768h | LTE_CA_B8_B41_B41 | 33 | China Mobile | PAN, Qun (panqun@chinamobile.com) | Rel-13 | 65 | CA | LTE_CA_B8_B41_B41 |  |
| 4821 | 1827.19.1 | Core part:LTE Advanced 3 Band Carrier Aggregation (3DL/1UL) of Band 8, Band 41 and Band 41 | 198d? | 2014-09-15 A | 2015-06-15 A | 100% | 2014-06-13 | 2015-03-13 | 196d? | finish no earlier than 2015-06-15 | R4 | 1584h | 1584h | LTE_CA_B8_B41_B41-Core | 33 | China Mobile | PAN, Qun (panqun@chinamobile.com) | Rel-13 | 65 | CA | LTE_CA_B8_B41_B41-Core | RP-150536 |
| 4822 | 1827.19.2 | Perf. Part:LTE Advanced 3 Band Carrier Aggregation (3DL/1UL) of Band 8, Band 41 and Band 41 | 199d? | 2014-09-12 A | 2015-06-15 A | 100% | 2014-06-13 | 2015-03-13 | 196d? | finish no earlier than 2015-06-15 | R4 | 1592h | 1592h | LTE_CA_B8_B41_B41-Perf | 33 | China Mobile | PAN, Qun (panqun@chinamobile.com) | Rel-13 | 65 | CA | LTE_CA_B8_B41_B41-Perf | RP-150536 |
| 4823 | 1827.20 | **LTE Advanced 3 Band Carrier Aggregation (3DL/1UL) of Band 38, Band 40 and Band 40** | 283.5d? | 2014-09-15 A | 2015-06-15 A | 100% | 2014-06-13 | 2015-03-13 | 196d? |  | R4 | 4752h | 4752h | LTE_CA_B38_B40_B40 | 33 | Samsung | xutao.zhou@samsung.com | Rel-13 | 65 | CA | LTE_CA_B38_B40_B40 |  |
| 4824 | 1827.20.1 | Core part:LTE Advanced 3 Band Carrier Aggregation (3DL/1UL) of Band 38, Band 40 and Band 40 | 198d? | 2014-09-15 A | 2015-06-15 A | 100% | 2014-06-13 | 2015-03-13 | 196d? | finish no earlier than 2015-06-15 | R4 | 1584h | 1584h | LTE_CA_B38_B40_B40-Core | 33 | Samsung | xutao.zhou@samsung.com | Rel-13 | 65 | CA | LTE_CA_B38_B40_B40-Core | RP-150536 |
| 4825 | 1827.20.2 | Perf. Part:LTE Advanced 3 Band Carrier Aggregation (3DL/1UL) of Band 38, Band 40 and Band 40 | 198d? | 2014-09-15 A | 2015-06-15 A | 100% | 2014-06-13 | 2015-03-13 | 196d? | finish no earlier than 2015-06-15 | R4 | 1584h | 1584h | LTE_CA_B38_B40_B40-Perf | 33 | Samsung | xutao.zhou@samsung.com | Rel-13 | 65 | CA | LTE_CA_B38_B40_B40-Perf | RP-150536 |
| 4826 | 1827.21 | **LTE Advanced 3 Band Carrier Aggregation (3DL/1UL) of Band 2, Band 5 and Band 29** | 283.5d? | 2014-09-15 A | 2015-06-15 A | 100% | 2014-06-13 | 2015-03-13 | 196d? |  | R4 | 4752h | 4752h | LTE_CA_B2_B5_B29 | 33 | Huawei | SHAN Huiping (shanhuiping@huawei.com) | Rel-13 | 65 | CA | LTE_CA_B2_B5_B29 |  |
| 4827 | 1827.21.1 | Core part:LTE Advanced 3 Band Carrier Aggregation (3DL/1UL) of Band 2, Band 5 and Band 29 | 198d? | 2014-09-15 A | 2015-06-15 A | 100% | 2014-06-13 | 2015-03-13 | 196d? | finish no earlier than 2015-06-15 | R4 | 1584h | 1584h | LTE_CA_B2_B5_B29-Core | 33 | Huawei | SHAN Huiping (shanhuiping@huawei.com) | Rel-13 | 65 | CA | LTE_CA_B2_B5_B29-Core | RP-150536 |
| 4828 | 1827.21.2 | Perf. Part:LTE Advanced 3 Band Carrier Aggregation (3DL/1UL) of Band 2, Band 5 and Band 29 | 198d? | 2014-09-15 A | 2015-06-15 A | 100% | 2014-06-13 | 2015-03-13 | 196d? | finish no earlier than 2015-06-15 | R4 | 1584h | 1584h | LTE_CA_B2_B5_B29-Perf | 33 | Huawei | SHAN Huiping (shanhuiping@huawei.com) | Rel-13 | 65 | CA | LTE_CA_B2_B5_B29-Perf | RP-150536 |

Notes:
- 4805: Inter-band CA 2DL/1UL / Impacted TSs and TRs: LTE
- 4806: CD:Fri 11/12/15->Mon 15/06/15¦Compl:0%->70%¦Stat Rep: -->RP-141732 1st Apr 15: Compl:70%->80% 1st Apr 15: Stat Rep: RP-141732->RP-150013 03/07/15: Compl:80%->100% 03/07/15: WID: RP-141674->RP-150832 03/07/15: Stat Rep: RP-150013->RP-150536 / Impacted TSs and TRs: 36.101; 36.104; 36.133; New 36.8xx
- 4807: CD:Fri 12/06/15->Mon 15/06/15¦Compl:0%->70%¦Stat Rep: -->RP-141732 1st Apr 15: Compl:70%->80% 1st Apr 15: Stat Rep: RP-141732->RP-150013 03/07/15: Compl:80%->100% 03/07/15: WID: RP-141674->RP-150832 03/07/15: Stat Rep: RP-150013->RP-150536 / Impacted TSs and TRs: 36.141; 36.307
- 4808: Inter-band CA 2DL/1UL / Impacted TSs and TRs: LTE
- 4809: ¦WID: RP-142043->RP-142007¦Stat Rep: -->RP-141732 1st Apr 15: Compl:75%->99% 1st Apr 15: CD:Sun 15/03/15->Mon 15/06/15 1st Apr 15: Stat Rep: RP-141732->RP-150013 03/07/15: Compl:99%->100% 03/07/15: Stat Rep: RP-150013->RP-150536 / Impacted TSs and TRs: 36.101; 36.104; New 36.8xx
- 4810: ¦WID: RP-142043->RP-142007¦Stat Rep: -->RP-141732 1st Apr 15: Compl:0%->99% 1st Apr 15: CD:Sun 15/03/15->Mon 15/06/15 1st Apr 15: Stat Rep: RP-141732->RP-150013 03/07/15: Compl:99%->100% 03/07/15: Stat Rep: RP-150013->RP-150536 / Impacted TSs and TRs: 36.141; 36.307
- 4811: Inter-band CA 2DL/1UL / Impacted TSs and TRs: LTE
- 4812: CD:Fri 11/12/15->Sun 15/03/15¦Compl:0%->50%¦Stat Rep: -->RP-141732 1st Apr 15: Compl:50%->75% 1st Apr 15: CD:Sun 15/03/15->Mon 15/06/15 1st Apr 15: WID: RP-141337->RP-150318 1st Apr 15: Stat Rep: RP-141732->RP-150013 03/07/15: Compl:75%->100% 03/07/1 / Impacted TSs and TRs: 36.101; 36.104; New 36.8xx
- 4813: CD:Thu 12/03/15->Sun 15/03/15¦Compl:0%->0%¦Stat Rep: -->RP-141732 1st Apr 15: CD:Sun 15/03/15->Mon 15/06/15 1st Apr 15: WID: RP-141337->RP-150318 1st Apr 15: Stat Rep: RP-141732->RP-150013 03/07/15: Compl:0%->100% 03/07/15: Stat Rep: RP-150013->RP-15 / Impacted TSs and TRs: 36.141; 36.307
- 4814: Inter-band CA 2DL/1UL / Impacted TSs and TRs: LTE
- 4815: ¦WID: RP-142043->RP-141888¦Stat Rep: -->RP-141732 1st Apr 15: Compl:0%->80% 1st Apr 15: WID: RP-141888->RP-150285 1st Apr 15: Stat Rep: RP-141732->RP-150013 03/07/15: Compl:80%->100% 03/07/15: Stat Rep: RP-150013->RP-150536 / Impacted TSs and TRs: 36.101; 36.104; New 36.8xx
- 4816: ¦WID: RP-142043->RP-141888¦Stat Rep: -->RP-141732 1st Apr 15: Compl:0%->80% 1st Apr 15: WID: RP-141888->RP-150285 1st Apr 15: Stat Rep: RP-141732->RP-150013 03/07/15: Compl:80%->100% 03/07/15: Stat Rep: RP-150013->RP-150536 / Impacted TSs and TRs: 36.141; 36.307
- 4817: Intra-band contig. CA 3DL / Impacted TSs and TRs: LTE
- 4818: CD:Fri 12/06/15->Mon 15/06/15¦Compl:0%->70%¦Stat Rep: -->RP-141732 1st Apr 15: Compl:70%->99% 1st Apr 15: WID: RP-141677->RP-150319 1st Apr 15: Stat Rep: RP-141732->RP-150013 03/07/15: Compl:99%->100% 03/07/15: WID: RP-150319->RP-151027 03/07/15: Sta / Impacted TSs and TRs: 36.101; 36.104; 36.133; New 36.833-5-42
- 4819: CD:Fri 12/06/15->Mon 15/06/15¦Compl:0%->0%¦Stat Rep: -->RP-141732 1st Apr 15: Compl:0%->99% 1st Apr 15: WID: RP-141677->RP-150319 1st Apr 15: Stat Rep: RP-141732->RP-150013 03/07/15: Compl:99%->100% 03/07/15: WID: RP-150319->RP-151027 03/07/15: Stat / Impacted TSs and TRs: 36.141; 36.307
- 4820: Inter-band CA 3DL/1UL / Impacted TSs and TRs: LTE
- 4821: ¦WID: RP-142043->RP-141845¦Stat Rep: -->RP-141732 1st Apr 15: Compl:80%->99% 1st Apr 15: CD:Sun 15/03/15->Mon 15/06/15 1st Apr 15: Stat Rep: RP-141732->RP-150013 03/07/15: Compl:99%->100% 03/07/15: Stat Rep: RP-150013->RP-150536 / Impacted TSs and TRs: 36.101; 36.104; 36.133; New 36.8xx
- 4822: ¦WID: RP-142043->RP-141845¦Stat Rep: -->RP-141732 1st Apr 15: Compl:0%->99% 1st Apr 15: CD:Sun 15/03/15->Mon 15/06/15 1st Apr 15: Stat Rep: RP-141732->RP-150013 03/07/15: Compl:99%->100% 03/07/15: Stat Rep: RP-150013->RP-150536 / Impacted TSs and TRs: 36.141; 36.307
- 4823: Inter-band CA 3DL/1UL / Impacted TSs and TRs: LTE
- 4824: CD:Fri 12/06/15->Mon 15/06/15¦Compl:0%->0%¦Stat Rep: -->RP-141732 1st Apr 15: Compl:0%->70% 1st Apr 15: Stat Rep: RP-141732->RP-150013 03/07/15: Compl:70%->100% 03/07/15: Stat Rep: RP-150013->RP-150536 / Impacted TSs and TRs: 36.101; 36.104; 36.133; New 36.8xx
- 4825: CD:Fri 12/06/15->Mon 15/06/15¦Compl:0%->0%¦Stat Rep: -->RP-141732 1st Apr 15: Compl:0%->70% 1st Apr 15: Stat Rep: RP-141732->RP-150013 03/07/15: Compl:70%->100% 03/07/15: Stat Rep: RP-150013->RP-150536 / Impacted TSs and TRs: 36.141; 36.307
- 4826: Inter-band CA 3DL/1UL / Impacted TSs and TRs: LTE
- 4827: CD:Fri 11/12/15->Mon 15/06/15¦Compl:0%->50%¦Stat Rep: -->RP-141732 1st Apr 15: Compl:50%->99% 1st Apr 15: Stat Rep: RP-141732->RP-150013 03/07/15: Compl:99%->100% 03/07/15: Stat Rep: RP-150013->RP-150536 / Impacted TSs and TRs: 36.101; 36.104; 36.133; New 36.8xy (inter-band CA 2DL/1UL (introduce CA_B5-B29); New 36.8xz (inter-band CA 3DL/1UL)
- 4828: CD:Fri 12/06/15->Mon 15/06/15¦Compl:0%->0%¦Stat Rep: -->RP-141732 1st Apr 15: Compl:0%->99% 1st Apr 15: Stat Rep: RP-141732->RP-150013 03/07/15: Compl:99%->100% 03/07/15: Stat Rep: RP-150013->RP-150536 / Impacted TSs and TRs: 36.141; 36.307

| ID | WBS | Task | Duration | Start | Finish | Complete | Constraint | Resources | Work | Actual work | Acronym | PCG approved | WI rapporteur name | WI rapporteur e-mail | Release | TSG approved | Status Report |
| --- | --- | --- | --- | --- | --- | --- | --- | --- | --- | --- | --- | --- | --- | --- | --- | --- | --- |
| 4829 | 1827.22 | **LTE Carrier Aggregation Enhancement Beyond 5 Carriers** | 1418.62d? | 2014-12-15 A | 2018-09-14 A | 100% |  |  | 9416h | 9416h | LTE_CA_enh_b5C | 34 | Nokia Networks | Nokia | Rel-13 | 66 |  |
| 4830 | 1827.22.1 | Core part: LTE Carrier Aggregation Enhancement Beyond 5 Carriers | 262d? | 2014-12-15 A | 2015-12-15 A | 100% | finish no earlier than 2015-12-15 | R1 | 2096h | 2096h | LTE_CA_enh_b5C-Core | 34 | Nokia Networks | Nokia | Rel-13 | 66 | RP-151285 |
| 4831 | 1827.22.2 | Perf. part: LTE Carrier Aggregation Enhancement Beyond 5 Carriers | 393d? | 2014-12-15 A | 2016-06-15 A | 100% | finish no earlier than 2016-06-15 | R4 | 3144h | 3144h | LTE_CA_enh_b5C-Perf | 34 | Nokia Networks | Nokia | Rel-13 | 66 | RP-151285 |
| 4832 | 1827.22.3 | UE Conformance Test Aspects - LTE Carrier Aggregation Enhancement Beyond 5 Carriers: PUCCH on Scell | 522d? | 2016-09-15 A | 2018-09-14 A | 100% | finish no earlier than 2018-09-15 | R5 | 4176h | 4176h | LTE_CA_enh_b5C_PUCCH-UEConTest | 37 | Huawei |  | Rel-13 | 73 |  |
| 4833 | 1827.23 | **HSPA Dual-Band UL carrier aggregation** | 473.25d? | 2014-12-15 A | 2016-03-15 A | 100% |  | R4 | 7328h | 7328h | HSUPA_DB_MC | 34 | Qualcomm | Qualcomm | Rel-13 | 66 |  |
| 4834 | 1827.23.1 | Core part: HSPA Dual-Band UL carrier aggregation | 262d? | 2014-12-15 A | 2015-12-15 A | 100% | finish no earlier than 2015-12-15 | R4 | 2096h | 2096h | HSUPA_DB_MC-Core | 34 | Qualcomm | Qualcomm | Rel-13 | 66 | RP-151281 |
| 4835 | 1827.23.2 | Perf. part: HSPA Dual-Band UL carrier aggregation | 327d? | 2014-12-15 A | 2016-03-15 A | 100% | finish no earlier than 2016-03-15 | R4 | 2616h | 2616h | HSUPA_DB_MC-Perf | 34 | Qualcomm | Qualcomm | Rel-13 | 66 | RP-151281 |
| 4836 | 1827.24 | **LTE Advanced inter-band Carrier Aggregation of Band 25 and Band 26** | 189.5d? | 2014-12-15 A | 2015-06-15 A | 100% |  | R4 | 3144h | 3144h | LTE_CA_B25_B26 | 34 | Sprint | Sprint | Rel-13 | 66 |  |
| 4837 | 1827.24.1 | Core part:LTE Advanced inter-band Carrier Aggregation of Band 25 and Band 26 | 131d? | 2014-12-15 A | 2015-06-15 A | 100% | finish no earlier than 2015-06-15 | R4 | 1048h | 1048h | LTE_CA_B25_B26-Core | 34 | Sprint | Sprint | Rel-13 | 66 | RP-150536 |
| 4838 | 1827.24.2 | Perf. part:LTE Advanced inter-band Carrier Aggregation of Band 25 and Band 26 | 131d? | 2014-12-15 A | 2015-06-15 A | 100% | finish no earlier than 2015-06-15 | R4 | 1048h | 1048h | LTE_CA_B25_B26-Perf | 34 | Sprint | Sprint | Rel-13 | 66 | RP-150536 |
| 4839 | 1827.25 | **LTE Advanced inter-band Carrier Aggregation of Band 3 and Band 41** | 379d? | 2014-12-15 A | 2015-12-15 A | 100% |  | R4 | 6288h | 6288h | LTE_CA_B3_B41 | 34 | China Telecom | China Telecom | Rel-13 | 66 |  |
| 4840 | 1827.25.1 | Core part:LTE Advanced inter-band Carrier Aggregation of Band 3 and Band 41 | 262d? | 2014-12-15 A | 2015-12-15 A | 100% | finish no earlier than 2015-12-15 | R4 | 2096h | 2096h | LTE_CA_B3_B41-Core | 34 | China Telecom | China Telecom | Rel-13 | 66 | RP-151131 |
| 4841 | 1827.25.2 | Perf. part:LTE Advanced inter-band Carrier Aggregation of Band 3 and Band 41 | 262d? | 2014-12-15 A | 2015-12-15 A | 100% | finish no earlier than 2015-12-15 | R4 | 2096h | 2096h | LTE_CA_B3_B41-Perf | 34 | China Telecom | China Telecom | Rel-13 | 66 | RP-151131 |
| 4842 | 1827.26 | **LTE Advanced 3 band Carrier Aggregation (3DL/1UL) of Band 1, Band 3 and Band 3** | 284.75d? | 2014-12-15 A | 2015-09-15 A | 100% |  | R4 | 4728h | 4728h | LTE_CA_B1_B3_B3 | 34 | China Unicom | China Unicom | Rel-13 | 66 |  |
| 4843 | 1827.26.1 | Core part:LTE Advanced 3 band Carrier Aggregation (3DL/1UL) of Band 1, Band 3 and Band 3 | 197d? | 2014-12-15 A | 2015-09-15 A | 100% | finish no earlier than 2015-09-15 | R4 | 1576h | 1576h | LTE_CA_B1_B3_B3-Core | 34 | China Unicom | China Unicom | Rel-13 | 66 | RP-151131 |
| 4844 | 1827.26.2 | Perf. part:LTE Advanced 3 band Carrier Aggregation (3DL/1UL) of Band 1, Band 3 and Band 3 | 197d? | 2014-12-15 A | 2015-09-15 A | 100% | finish no earlier than 2015-09-15 | R4 | 1576h | 1576h | LTE_CA_B1_B3_B3-Perf | 34 | China Unicom | China Unicom | Rel-13 | 66 | RP-151131 |
| 4845 | 1827.27 | **LTE Advanced 3 Band Carrier Aggregation (3DL/1UL) of Band 1, Band 19 and Band 28** | 284.75d? | 2014-12-15 A | 2015-09-15 A | 100% |  | R4 | 4728h | 4728h | LTE_CA_B1_B19_B28 | 34 | NTT DOCOMO | NTT DOCOMO | Rel-13 | 66 |  |
| 4846 | 1827.27.1 | Core part:LTE Advanced 3 Band Carrier Aggregation (3DL/1UL) of Band 1, Band 19 and Band 28 | 197d? | 2014-12-15 A | 2015-09-15 A | 100% | finish no earlier than 2015-09-15 | R4 | 1576h | 1576h | LTE_CA_B1_B19_B28-Core | 34 | NTT DOCOMO | NTT DOCOMO | Rel-13 | 66 | RP-151131 |
| 4847 | 1827.27.2 | Perf. part:LTE Advanced 3 Band Carrier Aggregation (3DL/1UL) of Band 1, Band 19 and Band 28 | 197d? | 2014-12-15 A | 2015-09-15 A | 100% | finish no earlier than 2015-09-15 | R4 | 1576h | 1576h | LTE_CA_B1_B19_B28-Perf | 34 | NTT DOCOMO | NTT DOCOMO | Rel-13 | 66 | RP-151131 |
| 4848 | 1827.28 | **LTE Advanced 3 Band Carrier Aggregation (3DL/1UL) of Band 21, Band 42 and Band 42** | 189.5d? | 2014-12-15 A | 2015-06-15 A | 100% |  | R4 | 3144h | 3144h | LTE_CA_B21_B42_B42 | 34 | NTT DOCOMO | NTT DOCOMO | Rel-13 | 66 |  |
| 4849 | 1827.28.1 | Core part:LTE Advanced 3 Band Carrier Aggregation (3DL/1UL) of Band 21, Band 42 and Band 42 | 131d? | 2014-12-15 A | 2015-06-15 A | 100% | finish no earlier than 2015-06-15 | R4 | 1048h | 1048h | LTE_CA_B21_B42_B42-Core | 34 | NTT DOCOMO | NTT DOCOMO | Rel-13 | 66 | RP-150536 |
| 4850 | 1827.28.2 | Perf. part:LTE Advanced 3 Band Carrier Aggregation (3DL/1UL) of Band 21, Band 42 and Band 42 | 131d? | 2014-12-15 A | 2015-06-15 A | 100% | finish no earlier than 2015-06-15 | R4 | 1048h | 1048h | LTE_CA_B21_B42_B42-Perf | 34 | NTT DOCOMO | NTT DOCOMO | Rel-13 | 66 | RP-150536 |
| 4851 | 1827.29 | **LTE Advanced 3 Band Carrier Aggregation (3DL/1UL) of Band 7, Band 40 and Band 40** | 284.75d? | 2014-12-15 A | 2015-09-15 A | 100% |  | R4 | 4728h | 4728h | LTE_CA_B7_B40_B40 | 34 | ZTE | ZTE | Rel-13 | 66 |  |
| 4852 | 1827.29.1 | Core part:LTE Advanced 3 Band Carrier Aggregation (3DL/1UL) of Band 7, Band 40 and Band 40 | 197d? | 2014-12-15 A | 2015-09-15 A | 100% | finish no earlier than 2015-09-15 | R4 | 1576h | 1576h | LTE_CA_B7_B40_B40-Core | 34 | ZTE | ZTE | Rel-13 | 66 | RP-151131 |
| 4853 | 1827.29.2 | Perf. part:LTE Advanced 3 Band Carrier Aggregation (3DL/1UL) of Band 7, Band 40 and Band 40 | 197d? | 2014-12-15 A | 2015-09-15 A | 100% | finish no earlier than 2015-09-15 | R4 | 1576h | 1576h | LTE_CA_B7_B40_B40-Perf | 34 | ZTE | ZTE | Rel-13 | 66 | RP-151131 |

Notes:
- 4829: FCD: 06/16->12/15, Rel-14?->Rel-13
- 4830: FCD: 06/16->12/15, Rel-14?->Rel-13 1st Apr 15: Compl:0%->10% 1st Apr 15: WID: RP-142286->RP-150277 1st Apr 15: Stat Rep: ->RP-150272 03/07/15: Compl:10%->40% 03/07/15: WID: RP-150277->RP-150771 03/07/15: Stat Rep: RP-150272->RP-150769 29/09/15: Compl:4
- 4831: 1st Apr 15: WID: RP-142286->RP-150277 1st Apr 15: Stat Rep: ->RP-150272 03/07/15: WID: RP-150277->RP-150771 03/07/15: Stat Rep: RP-150272->RP-150769 29/09/15: Stat Rep: RP-150769->RP-151285¦22/3/16: ;
- 4832: ¦20/12/16: Compl:0%->5%19/6/17: Compl:5%->8%¦19/9/17: Compl:8%->15%¦8/1/18: 27/3/18; 14/1/20: WID:RP-171764->RP-192558; 14/1/20: 20%->100
- 4834: 1st Apr 15: Compl:0%->10% 1st Apr 15: WID: RP-142237->RP-150129 1st Apr 15: Stat Rep: ->RP-150127 03/07/15: Compl:10%->40% 03/07/15: Stat Rep: RP-150127->RP-150761 29/09/15: Compl:40%->50% 29/09/15: Stat Rep: RP-150761->RP-151281¦
- 4835: 1st Apr 15: WID: RP-142237->RP-150129 1st Apr 15: Stat Rep: ->RP-150127 03/07/15: Stat Rep: RP-150127->RP-150761 29/09/15: Stat Rep: RP-150761->RP-1512811/1/16: Compl:0%->90% ¦
- 4837: 1st Apr 15: Compl:0%->95% 1st Apr 15: CD:Tue 15/12/15->Mon 15/06/15 1st Apr 15: WID: RP-142020->RP-150115 1st Apr 15: Stat Rep: ->RP-150013 03/07/15: Compl:95%->100% 03/07/15: Stat Rep: RP-150013->RP-150536
- 4838: 1st Apr 15: Compl:0%->95% 1st Apr 15: CD:Tue 15/12/15->Mon 15/06/15 1st Apr 15: WID: RP-142020->RP-150115 1st Apr 15: Stat Rep: ->RP-150013 03/07/15: Compl:95%->100% 03/07/15: Stat Rep: RP-150013->RP-150536
- 4840: 1st Apr 15: Compl:0%->20% 1st Apr 15: Stat Rep: ->RP-150013 03/07/15: Compl:20%->65% 03/07/15: Stat Rep: RP-150013->RP-150536 29/09/15: CD:Tue 15/09/15->Tue 15/12/15 29/09/15: WID: RP-142239->RP-151446 29/09/15: Stat Rep: RP-150536->RP-151131¦29/09/1
- 4841: 1st Apr 15: Compl:0%->20% 1st Apr 15: Stat Rep: ->RP-150013 03/07/15: Compl:20%->65% 03/07/15: Stat Rep: RP-150013->RP-150536 29/09/15: CD:Tue 15/09/15->Tue 15/12/15 29/09/15: WID: RP-142239->RP-151446 29/09/15: Stat Rep: RP-150536->RP-151131¦29/09/1
- 4843: 1st Apr 15: Compl:0%->50% 1st Apr 15: Stat Rep: ->RP-150013 03/07/15: Compl:50%->90% 03/07/15: CD:Mon 15/06/15->Tue 15/09/15 03/07/15: Stat Rep: RP-150013->RP-150536 29/09/15: Compl:90%->100% 29/09/15: Stat Rep: RP-150536->RP-151131
- 4844: 03/07/15: Compl:0%->90% 03/07/15: CD:Mon 15/06/15->Tue 15/09/15 03/07/15: Stat Rep: ->RP-150536 29/09/15: Compl:90%->100% 29/09/15: Stat Rep: RP-150536->RP-151131
- 4846: 1st Apr 15: Compl:0%->50% 1st Apr 15: Stat Rep: ->RP-150013 03/07/15: Compl:50%->90% 03/07/15: CD:Mon 15/06/15->Tue 15/09/15 03/07/15: WID: RP-141791->RP-150639 03/07/15: Stat Rep: RP-150013->RP-150536 29/09/15: Compl:90%->100% 29/09/15: Stat Rep: RP-
- 4847: 03/07/15: CD:Mon 15/06/15->Tue 15/09/15 03/07/15: WID: RP-141791->RP-150639 03/07/15: Stat Rep: ->RP-150536 29/09/15: Compl:0%->100% 29/09/15: Stat Rep: RP-150536->RP-151131
- 4849: 1st Apr 15: Compl:0%->90% 1st Apr 15: Stat Rep: ->RP-150013 03/07/15: Compl:90%->100% 03/07/15: WID: RP-141792->RP-150640 03/07/15: Stat Rep: RP-150013->RP-150536
- 4850: 03/07/15: Compl:0%->100% 03/07/15: WID: RP-141792->RP-150640 03/07/15: Stat Rep: ->RP-150536
- 4852: 1st Apr 15: Compl:0%->40% 1st Apr 15: Stat Rep: ->RP-150013 03/07/15: Compl:40%->75% 03/07/15: CD:Mon 15/06/15->Tue 15/09/15 03/07/15: WID: RP-141802->RP-150614 03/07/15: Stat Rep: RP-150013->RP-150536 29/09/15: Compl:75%->100% 29/09/15: Stat Rep: RP-
- 4853: 1st Apr 15: Compl:0%->40% 1st Apr 15: Stat Rep: ->RP-150013 03/07/15: Compl:40%->75% 03/07/15: CD:Mon 15/06/15->Tue 15/09/15 03/07/15: WID: RP-141802->RP-150614 03/07/15: Stat Rep: RP-150013->RP-150536 29/09/15: Compl:75%->100% 29/09/15: Stat Rep: RP-

| ID | WBS | Task | Duration | Start | Finish | Complete | Remaining | Total slack | Constraint | Resources | Work | Actual work | Acronym | PCG approved | WI rapporteur name | WI rapporteur e-mail | Release | TSG approved | Status Report |
| --- | --- | --- | --- | --- | --- | --- | --- | --- | --- | --- | --- | --- | --- | --- | --- | --- | --- | --- | --- |
| 4854 | 1827.30 | **LTE Advanced 3 band Carrier Aggregation (3DL/1UL) of Band 1, Band 8 and Band 28** | 327d? | 2014-12-15 A | 2015-10-26 | 40% | 196.2d? | 41659.8d |  | R4 | 7848h | 2723.2h | LTE_CA_B1_B8_B28 | 34 | Softbank Mobile | Softbank Mobile | Rel-13 | 66 |  |
| 4855 | 1827.30.1 | Core part:LTE Advanced 3 band Carrier Aggregation (3DL/1UL) of Band 1, Band 8 and Band 28 | 327d? | 2014-12-15 A | 2015-10-26 | 40% | 196.2d? | 41659.8d | finish no earlier than 2016-03-15 | R4 | 2616h | 1046.4h | LTE_CA_B1_B8_B28-Core | 34 | Softbank Mobile | Softbank Mobile | Rel-13 | 66 | RP-151131 |
| 4856 | 1827.30.2 | Perf. part:LTE Advanced 3 band Carrier Aggregation (3DL/1UL) of Band 1, Band 8 and Band 28 | 327d? | 2014-12-15 A | 2015-10-26 | 40% | 196.2d? | 41659.8d | finish no earlier than 2016-03-15 | R4 | 2616h | 1046.4h | LTE_CA_B1_B8_B28-Perf | 34 | Softbank Mobile | Softbank Mobile | Rel-13 | 66 | RP-151131 |
| 4857 | 1827.31 | **LTE Advanced 3 Band Carrier Aggregation (3DL/1UL) of Band 3, Band 7 and Band 7** | 189.5d? | 2014-12-15 A | 2015-06-15 A | 100% |  |  |  | R4 | 3144h | 3144h | LTE_CA_B3_B7_B7_Bwset | 34 | Ericsson | Ericsson | Rel-13 | 66 |  |
| 4858 | 1827.31.1 | Core part: Additional bandwidth combination set for LTE Advanced 3 Band Carrier Aggregation (3DL/1UL) of Band 3, Band 7 and Band 7 | 131d? | 2014-12-15 A | 2015-06-15 A | 100% |  |  | finish no earlier than 2015-06-15 | R4 | 1048h | 1048h | LTE_CA_B3_B7_B7_Bwset-Core | 34 | Ericsson | Ericsson | Rel-13 | 66 | RP-150536 |
| 4859 | 1827.31.2 | Perf. Part: Additional bandwidth combination set for LTE Advanced 3 Band Carrier Aggregation (3DL/1UL) of Band 3, Band 7 and Band 7 | 131d? | 2014-12-15 A | 2015-06-15 A | 100% |  |  | finish no earlier than 2015-06-15 | R4 | 1048h | 1048h | LTE_CA_B3_B7_B7_BWset-Perf | 34 | Ericsson | Ericsson | Rel-13 | 66 | RP-150536 |
| 4860 | 1827.32 | **LTE Advanced 3 Band Carrier Aggregation (3DL/1UL) of Band 7, Band 7 and Band 28** | 189.5d? | 2014-12-15 A | 2015-06-15 A | 100% |  |  |  | R4 | 3144h | 3144h | LTE_CA_B7_B7_B28 | 34 | Ericsson | Ericsson | Rel-13 | 66 |  |
| 4861 | 1827.32.1 | Core part:LTE Advanced 3 Band Carrier Aggregation (3DL/1UL) of Band 7, Band 7 and Band 28 | 131d? | 2014-12-15 A | 2015-06-15 A | 100% |  |  | finish no earlier than 2015-06-15 | R4 | 1048h | 1048h | LTE_CA_B7_B7_B28-Core | 34 | Ericsson | Ericsson | Rel-13 | 66 | RP-150536 |
| 4862 | 1827.32.2 | Perf. part:LTE Advanced 3 Band Carrier Aggregation (3DL/1UL) of Band 7, Band 7 and Band 28 | 131d? | 2014-12-15 A | 2015-06-15 A | 100% |  |  | finish no earlier than 2015-06-15 | R4 | 1048h | 1048h | LTE_CA_B7_B7_B28-Perf | 34 | Ericsson | Ericsson | Rel-13 | 66 | RP-150536 |
| 4863 | 1827.33 | **LTE Advanced 3 band Carrier Aggregation (3DL/1UL) of Band 1, Band 3 and Band 40** | 379d? | 2014-12-15 A | 2015-12-15 A | 100% |  |  |  | R4 | 6288h | 6288h | LTE_CA_B1_B3_B40 | 34 | KT | KT | Rel-13 | 66 |  |
| 4864 | 1827.33.1 | Core part:LTE Advanced 3 band Carrier Aggregation (3DL/1UL) of Band 1, Band 3 and Band 40 | 262d? | 2014-12-15 A | 2015-12-15 A | 100% |  |  | finish no earlier than 2015-12-15 | R4 | 2096h | 2096h | LTE_CA_B1_B3_B40-Core | 34 | KT | KT | Rel-13 | 66 | RP-151131 |
| 4865 | 1827.33.2 | Perf. part:LTE Advanced 3 band Carrier Aggregation (3DL/1UL) of Band 1, Band 3 and Band 40 | 262d? | 2014-12-15 A | 2015-12-15 A | 100% |  |  | finish no earlier than 2015-12-15 | R4 | 2096h | 2096h | LTE_CA_B1_B3_B40-Perf | 34 | KT | KT | Rel-13 | 66 | RP-151131 |
| 4866 | 1827.34 | **LTE Advanced 3 band Carrier Aggregation (3DL/1UL) of Band 1, Band 8 and Band 40** | 379d? | 2014-12-15 A | 2015-12-15 A | 100% |  |  |  | R4 | 6288h | 6288h | LTE_CA_B1_B8_B40 | 34 | KT | KT | Rel-13 | 66 |  |
| 4867 | 1827.34.1 | Core part:LTE Advanced 3 band Carrier Aggregation (3DL/1UL) of Band 1, Band 8 and Band 40 | 262d? | 2014-12-15 A | 2015-12-15 A | 100% |  |  | finish no earlier than 2015-12-15 | R4 | 2096h | 2096h | LTE_CA_B1_B8_B40-Core | 34 | KT | KT | Rel-13 | 66 | RP-151131 |
| 4868 | 1827.34.2 | Perf. part:LTE Advanced 3 band Carrier Aggregation (3DL/1UL) of Band 1, Band 8 and Band 40 | 262d? | 2014-12-15 A | 2015-12-15 A | 100% |  |  | finish no earlier than 2015-12-15 | R4 | 2096h | 2096h | LTE_CA_B1_B8_B40-Perf | 34 | KT | KT | Rel-13 | 66 | RP-151131 |
| 4869 | 1827.35 | **LTE Advanced 3 band Carrier Aggregation (3DL/1UL) of Band 3, Band 8 and Band 40** | 379d? | 2014-12-15 A | 2015-12-15 A | 100% |  |  |  | R4 | 6288h | 6288h | LTE_CA_B3_B8_B40 | 34 | KT | KT | Rel-13 | 66 |  |
| 4870 | 1827.35.1 | Core part:LTE Advanced 3 band Carrier Aggregation (3DL/1UL) of Band 3, Band 8 and Band 40 | 262d? | 2014-12-15 A | 2015-12-15 A | 100% |  |  | finish no earlier than 2015-12-15 | R4 | 2096h | 2096h | LTE_CA_B3_B8_B40-Core | 34 | KT | KT | Rel-13 | 66 | RP-151131 |
| 4871 | 1827.35.2 | Perf. part:LTE Advanced 3 band Carrier Aggregation (3DL/1UL) of Band 3, Band 8 and Band 40 | 262d? | 2014-12-15 A | 2015-12-15 A | 100% |  |  | finish no earlier than 2015-12-15 | R4 | 2096h | 2096h | LTE_CA_B3_B8_B40-Perf | 34 | KT | KT | Rel-13 | 66 | RP-151131 |
| 4872 | 1827.36 | **LTE Advanced 3 Band Carrier Aggregation (3DL) of Band 3, Band 7 and Band 8** | 189.5d? | 2014-12-15 A | 2015-06-15 A | 100% |  |  |  | R4 | 3144h | 3144h | LTE_CA_B3_B7_B8 | 34 | Ericsson | Ericsson | Rel-13 | 66 |  |
| 4873 | 1827.36.1 | Core part:LTE Advanced 3 Band Carrier Aggregation (3DL) of Band 3, Band 7 and Band 8 | 131d? | 2014-12-15 A | 2015-06-15 A | 100% |  |  | finish no earlier than 2015-06-15 | R4 | 1048h | 1048h | LTE_CA_B3_B7_B8-Core | 34 | Ericsson | Ericsson | Rel-13 | 66 | RP-150536 |
| 4874 | 1827.36.2 | Perf. part:LTE Advanced 3 Band Carrier Aggregation (3DL) of Band 3, Band 7 and Band 8 | 131d? | 2014-12-15 A | 2015-06-15 A | 100% |  |  | finish no earlier than 2015-06-15 | R4 | 1048h | 1048h | LTE_CA_B3_B7_B8-Perf | 34 | Ericsson | Ericsson | Rel-13 | 66 | RP-150536 |
| 4875 | 1827.37 | **LTE Advanced 3 Band Carrier Aggregation (3DL/1UL) of Band 1, Band 3 and Band 28** | 189.5d? | 2014-12-15 A | 2015-06-15 A | 100% |  |  |  | R4 | 3144h | 3144h | LTE_CA_B1_B3_B28 | 34 | Nokia Networks | Nokia Networks | Rel-13 | 66 |  |
| 4876 | 1827.37.1 | Core part:LTE Advanced 3 Band Carrier Aggregation (3DL/1UL) of Band 1, Band 3 and Band 28 | 131d? | 2014-12-15 A | 2015-06-15 A | 100% |  |  | finish no earlier than 2015-06-15 | R4 | 1048h | 1048h | LTE_CA_B1_B3_B28-Core | 34 | Nokia Networks | Nokia Networks | Rel-13 | 66 | RP-150536 |
| 4877 | 1827.37.2 | Perf. part:LTE Advanced 3 Band Carrier Aggregation (3DL/1UL) of Band 1, Band 3 and Band 28 | 131d? | 2014-12-15 A | 2015-06-15 A | 100% |  |  | finish no earlier than 2015-06-15 | R4 | 1048h | 1048h | LTE_CA_B1_B3_B28-Perf | 34 | Nokia Networks | Nokia Networks | Rel-13 | 66 | RP-150536 |

Notes:
- 4855: 1st Apr 15: Compl:0%->20% 1st Apr 15: WID: RP-141826->RP-150447 1st Apr 15: Stat Rep: ->RP-150013 03/07/15: Compl:20%->40% 03/07/15: Stat Rep: RP-150013->RP-150536 29/09/15: CD:Tue 15/09/15->Tue 15/12/15 29/09/15: Stat Rep: RP-150536->RP-151131
- 4856: 1st Apr 15: Compl:0%->20% 1st Apr 15: WID: RP-141826->RP-150447 1st Apr 15: Stat Rep: ->RP-150013 03/07/15: Compl:20%->40% 03/07/15: Stat Rep: RP-150013->RP-150536 29/09/15: CD:Tue 15/09/15->Tue 15/12/15 29/09/15: Stat Rep: RP-150536->RP-151131
- 4857: Acronym changed from LTE_CA_B3_B7_B7
- 4858: Acronym changed from LTE_CA_B3_B7_B7-Core 1st Apr 15: Compl:0%->99% 1st Apr 15: CD:Sun 15/03/15->Mon 15/06/15 1st Apr 15: Stat Rep: ->RP-150013 03/07/15: Compl:99%->100% 03/07/15: Stat Rep: RP-150013->RP-150536
- 4859: Acronym changed from LTE_CA_B3_B7_B7-Perf 1st Apr 15: Compl:0%->99% 1st Apr 15: CD:Sun 15/03/15->Mon 15/06/15 1st Apr 15: Stat Rep: ->RP-150013 03/07/15: Compl:99%->100% 03/07/15: Stat Rep: RP-150013->RP-150536
- 4861: 1st Apr 15: Compl:0%->99% 1st Apr 15: CD:Sun 15/03/15->Mon 15/06/15 1st Apr 15: Stat Rep: ->RP-150013 03/07/15: Compl:99%->100% 03/07/15: Stat Rep: RP-150013->RP-150536
- 4862: 1st Apr 15: Compl:0%->99% 1st Apr 15: CD:Sun 15/03/15->Mon 15/06/15 1st Apr 15: Stat Rep: ->RP-150013 03/07/15: Compl:99%->100% 03/07/15: Stat Rep: RP-150013->RP-150536
- 4864: 1st Apr 15: Compl:0%->10% 1st Apr 15: Stat Rep: ->RP-150013 03/07/15: Compl:10%->60% 03/07/15: CD:Tue 15/09/15->Tue 15/12/15 03/07/15: Stat Rep: RP-150013->RP-150536 29/09/15: Compl:60%->80% 29/09/15: WID: RP-141946->RP-151258 29/09/15: Stat Rep: RP-1
- 4865: 1st Apr 15: Compl:0%->10% 1st Apr 15: Stat Rep: ->RP-150013 03/07/15: Compl:10%->60% 03/07/15: CD:Tue 15/09/15->Tue 15/12/15 03/07/15: Stat Rep: RP-150013->RP-150536 29/09/15: Compl:60%->80% 29/09/15: WID: RP-141946->RP-151258 29/09/15: Stat Rep: RP-1
- 4867: 1st Apr 15: Compl:0%->10% 1st Apr 15: Stat Rep: ->RP-150013 03/07/15: Compl:10%->60% 03/07/15: CD:Tue 15/09/15->Tue 15/12/15 03/07/15: Stat Rep: RP-150013->RP-150536 29/09/15: Compl:60%->80% 29/09/15: WID: RP-141947->RP-151259 29/09/15: Stat Rep: RP-1
- 4868: 1st Apr 15: Compl:0%->10% 1st Apr 15: Stat Rep: ->RP-150013 03/07/15: Compl:10%->60% 03/07/15: CD:Tue 15/09/15->Tue 15/12/15 03/07/15: Stat Rep: RP-150013->RP-150536 29/09/15: Compl:60%->80% 29/09/15: WID: RP-141947->RP-151259 29/09/15: Stat Rep: RP-1
- 4870: 1st Apr 15: Compl:0%->10% 1st Apr 15: Stat Rep: ->RP-150013 03/07/15: Compl:10%->60% 03/07/15: CD:Tue 15/09/15->Tue 15/12/15 03/07/15: Stat Rep: RP-150013->RP-150536 29/09/15: Compl:60%->95% 29/09/15: WID: RP-141949->RP-151261 29/09/15: Stat Rep: RP-1
- 4871: 1st Apr 15: Compl:0%->10% 1st Apr 15: Stat Rep: ->RP-150013 03/07/15: Compl:10%->60% 03/07/15: CD:Tue 15/09/15->Tue 15/12/15 03/07/15: Stat Rep: RP-150013->RP-150536 29/09/15: Compl:60%->90% 29/09/15: WID: RP-141949->RP-151261 29/09/15: Stat Rep: RP-1
- 4873: 1st Apr 15: Compl:0%->95% 1st Apr 15: Stat Rep: ->RP-150013 03/07/15: Compl:95%->100% 03/07/15: Stat Rep: RP-150013->RP-150536
- 4874: 1st Apr 15: Compl:0%->99% 1st Apr 15: Stat Rep: ->RP-150013 03/07/15: Compl:99%->100% 03/07/15: Stat Rep: RP-150013->RP-150536
- 4876: 1st Apr 15: Compl:0%->99% 1st Apr 15: CD:Sun 15/03/15->Mon 15/06/15 1st Apr 15: Stat Rep: ->RP-150013 03/07/15: Compl:99%->100% 03/07/15: WID: RP-142038->RP-150719 03/07/15: Stat Rep: RP-150013->RP-150536
- 4877: 1st Apr 15: Compl:0%->99% 1st Apr 15: CD:Sun 15/03/15->Mon 15/06/15 1st Apr 15: Stat Rep: ->RP-150013 03/07/15: Compl:99%->100% 03/07/15: WID: RP-142038->RP-150719 03/07/15: Stat Rep: RP-150013->RP-150536

| ID | WBS | Task | Duration | Start | Finish | Complete | Remaining | Total slack | Constraint | Resources | Work | Actual work | Acronym | PCG approved | WI rapporteur name | WI rapporteur e-mail | Release | TSG approved | Status Report |
| --- | --- | --- | --- | --- | --- | --- | --- | --- | --- | --- | --- | --- | --- | --- | --- | --- | --- | --- | --- |
| 4878 | 1827.38 | **LTE Advanced 3 band Carrier Aggregation (3DL/1UL) of Band 3, Band 8 and Band 28** | 327d? | 2014-12-15 A | 2015-10-26 | 40% | 196.2d? | 41659.8d |  | R4 | 7848h | 2332.07h | LTE_CA_B3_B8_B28 | 34 | Softbank Mobile | Softbank Mobile | Rel-13 | 66 |  |
| 4879 | 1827.38.1 | Core part:LTE Advanced 3 band Carrier Aggregation (3DL/1UL) of Band 3, Band 8 and Band 28 | 327d? | 2014-12-15 A | 2015-10-26 | 40% | 196.2d? | 41659.8d | finish no earlier than 2016-03-15 | R4 | 2616h | 1046.4h | LTE_CA_B3_B8_B28-Core | 34 | Softbank Mobile | Softbank Mobile | Rel-13 | 66 | RP-151131 |
| 4880 | 1827.38.2 | Perf. part:LTE Advanced 3 band Carrier Aggregation (3DL/1UL) of Band 3, Band 8 and Band 28 | 327d? | 2014-12-15 A | 2015-10-26 | 40% | 196.2d? | 41659.8d | finish no earlier than 2016-03-15 | R4 | 2616h | 1046.4h | LTE_CA_B3_B8_B28-Perf | 34 | Softbank Mobile | Softbank Mobile | Rel-13 | 66 | RP-151131 |
| 4881 | 1827.39 | **LTE Advanced 3 Band Carrier Aggregation (3DL/1UL) of Band 8, Band 42 and Band 42** | 473.25d? | 2014-12-15 A | 2016-03-15 A | 100% |  |  |  | R4 | 7848h | 7848h | LTE_CA_B8_B42_B42 | 34 | Softbank Mobile | Softbank Mobile | Rel-13 | 66 |  |
| 4882 | 1827.39.1 | Core part:LTE Advanced 3 Band Carrier Aggregation (3DL/1UL) of Band 8, Band 42 and Band 42 | 327d? | 2014-12-15 A | 2016-03-15 A | 100% |  |  | finish no earlier than 2016-03-15 | R4 | 2616h | 2616h | LTE_CA_B8_B42_B42-Core | 34 | Softbank Mobile | Softbank Mobile | Rel-13 | 66 | RP-151131 |
| 4883 | 1827.39.2 | Perf. part:LTE Advanced 3 Band Carrier Aggregation (3DL/1UL) of Band 8, Band 42 and Band 42 | 327d? | 2014-12-15 A | 2016-03-15 A | 100% |  |  | finish no earlier than 2016-03-15 | R4 | 2616h | 2616h | LTE_CA_B8_B42_B42-Perf | 34 | Softbank Mobile | Softbank Mobile | Rel-13 | 66 | RP-151131 |
| 4884 | 1827.40 | **LTE Advanced 3 Band Carrier Aggregation (3DL/1UL) of Band 28, Band 40 and Band 40** | 379d? | 2014-12-15 A | 2015-12-15 A | 100% |  |  |  | R4 | 6288h | 6288h | LTE_CA_B28_B40_B40 | 34 | Huawei | Huawei | Rel-13 | 66 |  |
| 4885 | 1827.40.1 | Core part:LTE Advanced 3 Band Carrier Aggregation (3DL/1UL) of Band 28, Band 40 and Band 40 | 262d? | 2014-12-15 A | 2015-12-15 A | 100% |  |  | finish no earlier than 2015-12-15 | R4 | 2096h | 2096h | LTE_CA_B28_B40_B40-Core | 34 | Huawei | Huawei | Rel-13 | 66 | RP-151131 |
| 4886 | 1827.40.2 | Perf. part:LTE Advanced 3 Band Carrier Aggregation (3DL/1UL) of Band 28, Band 40 and Band 40 | 262d? | 2014-12-15 A | 2015-12-15 A | 100% |  |  | finish no earlier than 2015-12-15 | R4 | 2096h | 2096h | LTE_CA_B28_B40_B40-Perf | 34 | Huawei | Huawei | Rel-13 | 66 | RP-151131 |
| 4887 | 1827.41 | **LTE Advanced 3 Band Carrier Aggregation (3DL/1UL) of Band 3, Band 40 and Band 40** | 189.5d? | 2014-12-15 A | 2015-06-15 A | 100% |  |  |  | R4 | 3144h | 3144h | LTE_CA_B3_B40_B40 | 34 | Huawei | Huawei | Rel-13 | 66 |  |
| 4888 | 1827.41.1 | Core part:LTE Advanced 3 Band Carrier Aggregation (3DL/1UL) of Band 3, Band 40 and Band 40 | 131d? | 2014-12-15 A | 2015-06-15 A | 100% |  |  | finish no earlier than 2015-06-15 | R4 | 1048h | 1048h | LTE_CA_B3_B40_B40-Core | 34 | Huawei | Huawei | Rel-13 | 66 | RP-150536 |
| 4889 | 1827.41.2 | Perf. part:LTE Advanced 3 Band Carrier Aggregation (3DL/1UL) of Band 3, Band 40 and Band 40 | 131d? | 2014-12-15 A | 2015-06-15 A | 100% |  |  | finish no earlier than 2015-06-15 | R4 | 1048h | 1048h | LTE_CA_B3_B40_B40-Perf | 34 | Huawei | Huawei | Rel-13 | 66 | RP-150536 |
| 4890 | 1827.42 | **LTE Advanced 3 Band Carrier Aggregation (3DL/1UL) of Band 1, Band 7 and Band 28** | 189.5d? | 2014-12-15 A | 2015-06-15 A | 100% |  |  |  | R4 | 3144h | 3144h | LTE_CA_B1_B7_B28 | 34 | Huawei | Huawei | Rel-13 | 66 |  |
| 4891 | 1827.42.1 | Core part:LTE Advanced 3 Band Carrier Aggregation (3DL/1UL) of Band 1, Band 7 and Band 28 | 131d? | 2014-12-15 A | 2015-06-15 A | 100% |  |  | finish no earlier than 2015-06-15 | R4 | 1048h | 1048h | LTE_CA_B1_B7_B28-Core | 34 | Huawei | Huawei | Rel-13 | 66 | RP-150536 |
| 4892 | 1827.42.2 | Perf. part:LTE Advanced 3 Band Carrier Aggregation (3DL/1UL) of Band 1, Band 7 and Band 28 | 131d? | 2014-12-15 A | 2015-06-15 A | 100% |  |  | finish no earlier than 2015-06-15 | R4 | 1048h | 1048h | LTE_CA_B1_B7_B28-Perf | 34 | Huawei | Huawei | Rel-13 | 66 | RP-150536 |
| 4893 | 1827.43 | **LTE Advanced 3 Band Carrier Aggregation (3DL/1UL) of Band 1, Band 3 and Band 7** | 379d? | 2014-12-15 A | 2015-12-15 A | 100% |  |  |  | R4 | 6288h | 6288h | LTE_CA_B1_B3_B7 | 34 | Huawei | Huawei | Rel-13 | 66 |  |
| 4894 | 1827.43.1 | Core part:LTE Advanced 3 Band Carrier Aggregation (3DL/1UL) of Band 1, Band 3 and Band 7 | 262d? | 2014-12-15 A | 2015-12-15 A | 100% |  |  | finish no earlier than 2015-12-15 | R4 | 2096h | 2096h | LTE_CA_B1_B3_B7-Core | 34 | Huawei | Huawei | Rel-13 | 66 | RP-151131 |
| 4895 | 1827.43.2 | Perf. part:LTE Advanced 3 Band Carrier Aggregation (3DL/1UL) of Band 1, Band 3 and Band 7 | 262d? | 2014-12-15 A | 2015-12-15 A | 100% |  |  | finish no earlier than 2015-12-15 | R4 | 2096h | 2096h | LTE_CA_B1_B3_B7-Perf | 34 | Huawei | Huawei | Rel-13 | 66 | RP-151131 |
| 4896 | 1827.44 | **LTE Advanced 3 Band Carrier Aggregation (3DL/1UL) of Band 3, Band 3 and Band 5** | 189.5d? | 2014-12-15 A | 2015-06-15 A | 100% |  |  |  | R4 | 3144h | 3144h | LTE_CA_B3_B3_B5 | 34 | Intel | Intel | Rel-13 | 66 |  |
| 4897 | 1827.44.1 | Core part:LTE Advanced 3 Band Carrier Aggregation (3DL/1UL) of Band 3, Band 3 and Band 5 | 131d? | 2014-12-15 A | 2015-06-15 A | 100% |  |  | finish no earlier than 2015-09-15 | R4 | 1048h | 1048h | LTE_CA_B3_B3_B5-Core | 34 | Intel | Intel | Rel-13 | 66 | RP-150536 |
| 4898 | 1827.44.2 | Perf. part:LTE Advanced 3 Band Carrier Aggregation (3DL/1UL) of Band 3, Band 3 and Band 5 | 131d? | 2014-12-15 A | 2015-06-15 A | 100% |  |  | finish no earlier than 2015-09-15 | R4 | 1048h | 1048h | LTE_CA_B3_B3_B5-Perf | 34 | Intel | Intel | Rel-13 | 66 | RP-150536 |
| 4899 | 1827.45 | **LTE Advanced 3 Band Carrier Aggregation (3DL/1UL) of Band 3, Band 7 and Band 28** | 189.5d? | 2014-12-15 A | 2015-06-15 A | 100% |  |  |  | R4 | 3144h | 3144h | LTE_CA_B3_B7_B28 | 34 | Ericsson | Ericsson | Rel-13 | 66 |  |
| 4900 | 1827.45.1 | Core part:LTE Advanced 3 Band Carrier Aggregation (3DL/1UL) of Band 3, Band 7 and Band 28 | 131d? | 2014-12-15 A | 2015-06-15 A | 100% |  |  | finish no earlier than 2015-06-15 | R4 | 1048h | 1048h | LTE_CA_B3_B7_B28-Core | 34 | Ericsson | Ericsson | Rel-13 | 66 | RP-150536 |
| 4901 | 1827.45.2 | Perf. part:LTE Advanced 3 Band Carrier Aggregation (3DL/1UL) of Band 3, Band 7 and Band 28 | 131d? | 2014-12-15 A | 2015-06-15 A | 100% |  |  | finish no earlier than 2015-06-15 | R4 | 1048h | 1048h | LTE_CA_B3_B7_B28-Perf | 34 | Ericsson | Ericsson | Rel-13 | 66 | RP-150536 |

Notes:
- 4879: 1st Apr 15: Compl:0%->20% 1st Apr 15: CD:Tue 15/12/15->Tue 15/09/15 1st Apr 15: Stat Rep: ->RP-150013 03/07/15: Compl:20%->40% 03/07/15: Stat Rep: RP-150013->RP-150536 29/09/15: CD:Tue 15/09/15->Tue 15/12/15 29/09/15: Stat Rep: RP-150536->RP-151131¦
- 4880: 1st Apr 15: Compl:0%->20% 1st Apr 15: Stat Rep: ->RP-150013 03/07/15: Compl:20%->40% 03/07/15: Stat Rep: RP-150013->RP-150536 29/09/15: CD:Tue 15/09/15->Tue 15/12/15 29/09/15: Stat Rep: RP-150536->RP-151131
- 4882: 1st Apr 15: Compl:0%->20% 1st Apr 15: CD:Tue 15/12/15->Mon 15/06/15 1st Apr 15: Stat Rep: ->RP-150013 03/07/15: Compl:20%->40% 03/07/15: CD:Mon 15/06/15->Tue 15/09/15 03/07/15: Stat Rep: RP-150013->RP-150536 29/09/15: CD:Tue 15/09/15->Tue 15/12/15 29
- 4883: 1st Apr 15: Compl:0%->20% 1st Apr 15: Stat Rep: ->RP-150013 03/07/15: Compl:20%->40% 03/07/15: CD:Mon 15/06/15->Tue 15/09/15 03/07/15: Stat Rep: RP-150013->RP-150536 29/09/15: CD:Tue 15/09/15->Tue 15/12/15 29/09/15: Stat Rep: RP-150536->RP-151131;
- 4885: 1st Apr 15: Compl:0%->30% 1st Apr 15: CD:Tue 15/12/15->Mon 15/06/15 1st Apr 15: WID: RP-142206->RP-150233 1st Apr 15: Stat Rep: ->RP-150013 03/07/15: Compl:30%->60% 03/07/15: CD:Mon 15/06/15->Tue 15/12/15 03/07/15: WID: RP-150233->RP-150676 03/07/15:
- 4886: 1st Apr 15: WID: RP-142206->RP-150233 1st Apr 15: Stat Rep: ->RP-150013 03/07/15: CD:Mon 15/06/15->Tue 15/12/15 03/07/15: WID: RP-150233->RP-150676 03/07/15: Stat Rep: RP-150013->RP-150536 29/09/15: Stat Rep: RP-150536->RP-151131¦
- 4888: 1st Apr 15: Compl:0%->50% 1st Apr 15: CD:Tue 15/12/15->Mon 15/06/15 1st Apr 15: Stat Rep: ->RP-150013 03/07/15: Compl:50%->100% 03/07/15: WID: RP-142207->RP-151071 03/07/15: Stat Rep: RP-150013->RP-150536
- 4889: 03/07/15: Compl:0%->100% 03/07/15: WID: RP-142207->RP-151071 03/07/15: Stat Rep: ->RP-150536
- 4891: 1st Apr 15: Compl:0%->50% 1st Apr 15: CD:Tue 15/12/15->Mon 15/06/15 1st Apr 15: WID: RP-142208->RP-150234 1st Apr 15: Stat Rep: ->RP-150013 03/07/15: Compl:50%->100% 03/07/15: Stat Rep: RP-150013->RP-150536
- 4892: 1st Apr 15: WID: RP-142208->RP-150234 1st Apr 15: Stat Rep: ->RP-150013 03/07/15: Compl:0%->100% 03/07/15: Stat Rep: RP-150013->RP-150536
- 4894: 1st Apr 15: Compl:0%->30% 1st Apr 15: CD:Tue 15/12/15->Mon 15/06/15 1st Apr 15: Stat Rep: ->RP-150013 03/07/15: Compl:30%->40% 03/07/15: CD:Mon 15/06/15->Tue 15/09/15 03/07/15: Stat Rep: RP-150013->RP-150536 29/09/15: Compl:40%->50% 29/09/15: CD:Tue 1
- 4895: 03/07/15: CD:Mon 15/06/15->Tue 15/09/15 03/07/15: Stat Rep: ->RP-150536 29/09/15: CD:Tue 15/09/15->Tue 15/12/15 29/09/15: Stat Rep: RP-150536->RP-151131
- 4897: 1st Apr 15: Compl:0%->10% 1st Apr 15: Stat Rep: ->RP-150013 03/07/15: Compl:10%->100% 03/07/15: CD:Tue 15/09/15->Mon 15/06/15 03/07/15: Stat Rep: RP-150013->RP-150536
- 4898: 03/07/15: Compl:0%->100% 03/07/15: CD:Tue 15/09/15->Mon 15/06/15 03/07/15: Stat Rep: ->RP-150536
- 4900: 1st Apr 15: Compl:0%->99% 1st Apr 15: CD:Sun 15/03/15->Mon 15/06/15 1st Apr 15: Stat Rep: ->RP-150013 03/07/15: Compl:99%->100% 03/07/15: Stat Rep: RP-150013->RP-150536
- 4901: 1st Apr 15: Compl:0%->99% 1st Apr 15: CD:Sun 15/03/15->Mon 15/06/15 1st Apr 15: Stat Rep: ->RP-150013 03/07/15: Compl:99%->100% 03/07/15: Stat Rep: RP-150013->RP-150536
